# 3GPP_Release-2000

Schedule from MS Project, 1984-10-18 to 2020-06-15, A marks actual dates.

## Calendars

- Standard: Mon-Fri 08:00-12:00, 13:00-17:00; Sat-Sun off. Exceptions (off unless hours are given): 2000-01-15 08:00-12:00, 13:00-17:00, 2009-05-30 08:00-12:00, 13:00-17:00, 2011-08-27 to 2011-08-28 08:00-12:00, 13:00-17:00, 2011-09-24 08:00-12:00, 13:00-17:00, 2012-06-02 08:00-12:00, 13:00-17:00, 2012-09-01 08:00-12:00, 13:00-17:00, 2012-11-18 08:00-12:00, 13:00-17:00, 2012-11-24 08:00-12:00, 13:00-17:00, 2013-02-16 08:00-12:00, 13:00-17:00, 2013-06-02 08:00-12:00, 13:00-17:00, 2013-08-10 to 2013-08-11 08:00-12:00, 13:00-17:00, 2013-09-14 08:00-12:00, 13:00-17:00, 2014-03-01 08:00-12:00, 13:00-17:00, 2014-08-24 08:00-12:00, 13:00-17:00, 2014-09-21 08:00-12:00, 13:00-17:00, 2014-10-05 08:00-12:00, 13:00-17:00, 2016-06-18 08:00-12:00, 13:00-17:00.

## Resources

| Resource |
| --- |
| NP |
| N1 |
| N2 |
| N3 |
| N4 |
| N5 |
| TP |
| T1 |
| T2 |
| T3 |
| RP |
| R1 |
| R2 |
| R3 |
| R4 |
| SP |
| S1 |
| S2 |
| S3 |
| S4 |
| S5 |
| PCG |
| GP |
| No |
| CN4 |
| ? |
| WG G2 |
| G2 |
| G1 |
| G4 |
| G3 |
| All |
| Generic |
| MLST |
| G5 |
| S3, G2 |
| WG T2 |
| GP,G1 |
| G4,G5 |
| OMA |
| GP-G2 |
| Yes |
| GP, |
| N4, |
| GP, N1 |
| CT5 |
| C5 |
| C1 |
| C4 |
| C3 |
| C6 |
| G1, |
| 4 |
| ct |
| c,s,r |
| CT,RAN,SA |
| G2, |
| G1, G3 |
| CT6 |
| CT1 |
| CT1, CT3, CT4 |
| C1, C3, C4 |
| CP |
| R5 |
| C |
| Rel-8 |
| GP, G2 |
| R1,R4 |
| S5,C1 |
| CT,RAN,SA,GERAN |
| S3,C1,C4 |
| 5 |
| S1,C1,C3,C4,S5 |
| S1,C1,C3,C5 |
| S1,C1,C3,C4 |
| S1,S5 |
| S2,S3 |
| RAN,SA |
| RP,S5 |
| S2,CT |
| S1,CT |
| S1,CT,GERAN |
| S1,C5 |
| S3,CT |
| S4,CT |
| C1,SA |
| S1,S2 |
| S1,S4 |
| S2,S2,S3,CT |
| S2,S3,CT |
| S1,CT,GX |
| S1,S4,CT |
| S2,S2,S3,S5,CT |
| S1,S2,CT |
| S1,S2,S3,CT |
| S1,S2,S3,S5CT |
| S1,S2,S3,S5,CT |
| S2,S5,CT |
| S4,S3 |
| S1,C1 |
| CP,C1 |
| C1,C3 |
| C1,C3,C4 |
| S1,S5,CT |
| C4,C3 |
| CP,RAN,SA,GERAN |
| S1,S2,S3,S5,CP |
| S2,S3,CP |
| S2,CP |
| S1,CP,GX |
| S1,CP |
| S1,S4,CP |
| S1,S2,CP |
| S1,S2,S3,CP |
| S2,S5,CP |
| S3,CP |
| S1,S5,CP |
| RAN,SA,GERAN |
| S1,S2,S3,S5,C1,C3,C4,C6 |
| S2,S3,C1,C3,C4 |
| S2,C4 |
| S2,C1,C3,C4 |
| S2,C1,C4 |
| S2,S3,C1,C4 |
| S1,C1,C4,G2 |
| C1,C4 |
| S1,C1,C3 |
| S1,S4,C1,C3,C4 |
| S1,S2,S3,C1,C3,C4 |
| S2,S5,C3 |
| S1,S2,C1,C4 |
| S2,C1 |
| S2,C1,C3 |
| S3,C1,C3,C4 |
| S1,S5,C1,C3,C4 |
| S2,C3,C4 |
| C3,C1 |
| R2,R4 |
| R2,R5 |
| RP,R5 |
| RP,S5,R5 |
| R1,R5 |
| S1,C1,R5 |
| S1,C1,S4,R5 |
| GERAN |
| G3new |
| G1, G3new |
| C4,C1,C3 |
| R1.R4 |
| R1, R4 |
| R2,R3 |
| C3,C4 |
| S4,C3 |
| S4,C3,C1,C4 |
| S1,S2,C1 |
| S1,S2<C1,C3,C4 |
| S1,S2,C1,C3,C4 |
| S5,C1,C3,C4 |
| GP,C4 |
| C4,C1 |
| S2,S1 |
| RP,SP,GP |
| RP,SP,CP,GP |
| CP,GP,RP,SP |
| GP,C4,S4 |
| S1,C1,C4 |
| S1,S2,C3,C1 |
| R2,R4,R3 |
| CP,GP, RP,SP |
| S2,S1,C1,S5 |
| S2,S1,C1 |
| S1,C1,S4 |
| S1,S2,GP,C4,R2 |
| S1,GP,R2 |
| S1,C6 |
| S1,S2,C1,S4 |
| S2,S3,S5,C1,C3,C4 |
| S2,S5,C1 |
| S2,S3,S5 |
| CP,GP, RP,SP,TP |
| S2,C4,C1 |
| S1,C1,C4,S3 |
| S2,S5 |
| S3,C1 |
| S3,C4 |
| S1,C4 |
| S2,S5,C3,C1 |
| S2,S1,S5,C1,C4 |
| S1,R1,C3 |
| S1,C1,R2 |
| S2,S1,C1,C4 |
| S1,C1,C6 |
| GP,S4,C4,C1,C3 |
| C3,C1,C4 |
| S1,C4,C1 |
| S1,S3 |
| S1,S2,S5,C3,C4 |
| R4,G1 |
| G1,R4 |
| RP,GP |
| R4,GP |
| R3,R2 |
| C6,RP,SP |
| R5,C6 |
| CP,RP,SP |
| RP,SP,CP |
| R3,S5 |
| S1,S2,RP |
| S1,S2,S5,RP |
| S2,S1,RP |
| Rel-9 |
| S3,C6 |
| S1,S2,S3,S5,RP |
| S2,S1,S3 |
| S1,S2,S3 |
| S1,S2,S3,S5 |
| C6,R5 |
| S1,S2,RP,GP |
| S1,S2,S4,S5,RP,GP |
| GP,G2 |
| GP,GP, N1 |
| GP,S2,G1,G2 |
| GP,R2,R3,S2,G1,G2 |
| GP,S2,S5,R2,R3,G2,G1 |
| GP,R3 |
| N4,S2 |
| GP,RP |
| GP,S2,RP |
| G5,G4 |
| G4,R3 |
| S2,R2,R4 |
| S1,S2,R2,R4 |
| GP,S5 |
| S1,S2,S5 |
| R4,R5 |
| R4,R2,R3,R5 |
| S2,S5,N4,RP |
| S1,S2,S3,S5,NP |
| S2,S4,S5 |
| T2,S1,S4,S5 |
| SP,RP |
| S2,RP |
| S1,S2,CP,G2 |
| CP,SP |
| S1,G2 |
| SP,CP |
| S1,S2,S5,C3 |
| S1,C1,S3 |
| G1,G3new |
| C4, C3, C1C4 |
| C4,C3,C1 |
| S1,S2,S3,S5,R2,R3,R4 |
| S1,S2,S3,R2 |
| S2,S3,S5,C4,R2 |
| S1,S5,C1 |
| S1,S2,S3,C1,C3,C4,R2 |
| Ggp |
| S3,S2,C1,C4,G2 G3new |
| R1,R2,R3,R4 |
| R4,R1,R2,R3 |
| R4,R2,R3 |
| S1,C1,C4,R2 |
| R4,R2 |
| S2,C4,R2,R4 |
| S2,C4,R2 |
| S2,S3,S5,C3,C4,R2 |
| S1,S2,S4,T2 |
| S1,S2,S4 |
| S1,S2,S4,R5 |
| S3,S2,C1,C4,G2,G3new |
| GP,C1 |
| S1,S5,C4 |
| S1,S2,S3,S5,R2,R3,R4,GP |
| GP,C4,C3,C1 |
| SMG9 |
| SMG1 |
| SMG2 |
| N3,R5 |
| N1, N2, N4, G1, G2, R3, S1, SMG2 |
| S1,SMG1 |
| SMG1,N4 |
| N1,C1,N4,S1,T2,G2,SMG1,SMG2,SMG3,SMG7,SMG9 |
| SMG1,N2 |
| S1,S2,N2,N4 |
| N4,N2 |
| G1,G2 |
| G1,G2,C1 |
| G1,G2,N1 |
| SMG2, SMG1, SMG3, SMG4, SMG7, SMG9, SMG10, G1, G2, G3, N1, N3, T2 |
| SMG2,G1 |
| S1,G1,G2 |
| SMG1,N1,G1,G2 |
| G2,G1 |
| G1,G2,G3,S1,S2,SMG1,SMG2,SMG7,N1,N2,N3,N4,T2 |
| 23.003, 23.008, 29.060 |
| S1, S2, SMG1, SMG2, SMG12, G2, N1, N2, N4 |
| S1,S2,SMG1,SMG2,SMG12,G2,N1,N2,N4 |
| S1,SMG2,N1,N2,N4 |
| SMG1,T2 |
| S1,N1,N2,N4 |
| S1,S2,N5 |
| SMG2,SMG7,G2,T2 |
| S3,N1,N2,N3 |
| S3,N1,N2,N4 |
| SMG9,T3 |
| SMG2,SMG3,SMG7,G2,N2 |
| SMG2,N1,G1,G2 |
| S1,N2 |
| N1,N3 |
| S2,N1 |
| N1,N2,N4 |
| N2,N1,N4 |
| N2,N4 |
| S1,T3 |
| T2,N3 |
| S3,N2 |
| T2,S1 |
| S1,N4 |
| SMG1,SMG2,SMG7 |
| N1,S1,T1 |
| SMG1,SMG3 |
| N4,S2,N1 |
| S1,S2,SMG1,SMG2,SMG7,G1,G2,G3,N1,N2,N3,N4,T2 |
| SMG1,N3 |
| S1,N3 |
| CP,SP,SMG |
| CP,SP,TP,GP,SMG |
| NP,SP,TP,GP,SMG |
| NP,GP, RP,SP,TP |
| SMG2,SMG1,SMG3,SMG4,SMG7,SMG9,SMG10,G1,G2,G3,N1,N3,T2 |
| S1,N2,N4 |
| S1,S2,S3,C1,C3,C4,R2,R3 |
| R2,R3,R1,R4 |
| R2,R3,R4 |
| R2,R1,R3,R4 |
| S2,C4,R2,R3,R4 |
| S2,C4,R2,R1,R3,R4 |
| S2,S3,S5,C3,C4,R2,R3,R4 |
| R1,R2,R4 |
| R3,R1,R4 |
| S2, |
| S2,G2, |
| S1,S2,G2, |
| S1,S2,G2,R2,R3, |
| S1,S2,C4,G2,R2,R3 |
| S1,S2,N4,G2,R2,R3 |
| S1,S2,SMG1,SMG2,SMG12,G2,N1,N2,N4,R2,R3 |
| S1,SMG1,T2 |
| S1,SMG1,S2 |
| S1,N4,N2 |
| T2,N1,N3 |
| S3,N2,N4 |
| SMG1,SMG2,SMG3,SMG7,SMG9,N1,C1,N4,S1,T2,G2 |
| SMG1,N2,N4 |
| S2,T2,N1,N2,N4 |
| S1,T2 |
| S1,S2,C4 |
| S1,S2,N4,RP |
| S2,N4 |
| S1,S2,N3,N4,RP |
| S1,S2,SMG1,SMG2,SMG12,T2,G2,N1,N2,N4,R2,R3 |
| S1,T2,N1,N3 |
| S1,S2,SMG1,SMG2,SMG12,T2,G2,N1,N2,N3,N4,R2,R3 |
| S1,S2,S3,SMG1,SMG2,SMG12,G2,N1,N2,N4,R2,R3 |
| S1,S2,SMG,G1,G2,G3,N1,N2,N3,N4,T2 |
| S1,S2,SMG,T2,G2,N1,N2,N3,N4,R2,R3 |
| S1,S3,SMG,G1,G2,G3,N1,N2,N3,N4,T2 |
| S1,S3,T2,N2,N4 |
| S1,S2,SMG,T2,G1,G2,G3,N1,N2,N3,N4 |
| G2,S2 |
| T1,R5 |
| R5,T1 |
| S1,S2,S4,T1,R5 |
| S1,S2,S4,S5,T1,RP,GP |
| S1,S2,S3,S5,R2,R3,R4,GP,C1 |
| S1,S2,S3,SMG1,SMG2,SMG12,N1,N2,N4,R2,R3 |
| S1,S2,SMG,T2,N1,N2,N3,N4,R2,R3 |
| NP,SP,TP,SMG |
| S1,S2,SMG,T2,N1,N2,N3,N4 |
| SMG,N1 |
| SMG |
| S1,S2,SMG1,SMG2,SMG7,N1,N2,N3,N4,T2 |
| SMG2,SMG1,SMG3,SMG4,SMG7,SMG9,SMG10,N1,N3,T2 |
| S1,SMG |
| SMG2,SMG7,T2 |
| SMG2,S2 |
| N1,N2,N4,R3,S1,SMG |
| SMG2,SMG3,SMG7,N2 |
| SMG1,SMG2,SMG3,SMG7,SMG9,N1,C1,N4,S1,T2 |
| S1,S2,SMG,N3,N4,RP |
| S1,S2,S4,SMG,N3,N4,RP |
| S2,C1,C4,R2,R1,R3,R4 |
| R2,S2,S4 |
| G3new,R5 |
| GP,R4 |
| S2,S4,R2 |
| SP,GP |
| RP,SP |
| S2,S1,S3,S5 |
| S3,S1 |
| N4,N1,N2,S2 |
| S2,G1,G2,R2,R3 |
| S2,G1,G2 |
| G1,G2,R2,R3 |
| N4,T3 |
| S3,S2,N1,N4,T3,OMA |
| T2,S1,S4,S5,OMA |
| S2,N3 |
| S4,S1 |
| N4,N3,S1 |
| R5,G3new |
| R4,R2,R1 |
| S2,R2 |
| C3, C4,C1 |
| S3,C1,C4,C3 |
| C1,C4,C3 |
| S2,C1,C4,C3 |
| R3,R5 |
| S1,S2,C3 |
| R1,R2 |
| S3,C1,C4,G2,G3new |
| R1,R3 |
| GP,N1 |
| R1,R2,R3 |
| R3,R2,R4 |
| R4,R3 |
| S1,S2,R2,R3 |
| S1,S2,S3,C1,C3,C4,R2,R3,R5 |
| S2,S1,S5 |
| C4, C1 |
| C3, C1, C4 |
| S2,S1,S3,S5,C4,C1 |
| S2,C3,C1,C4 |
| S2,S1,S5,C3 |
| GP,S2,C1 |
| GP,S2,C1,G2 |
| G2,S2,C1 |
| v |
| G3new,G1,G2 |
| G1,G2,C1,G3new |
| S2,S1,S5,C1,C3 |
| C1,C3,C4,R5 |
| R2,R1 |
| S1<S2,N1,R2,R5 |
| S1,S2,N1,R2,R5 |
| S2,R5 |
| S1,S2,S5,R5 |
| S2,C1,C4,R2,R1,R3,R4,R5 |
| S1,S2,S3,S5,NP,R5 |
| S1,S2,S4,S5,RP,R5,GP |
| S1,S2,S3,S5,C1,C6,R2,R3,R4 |
| S1,S2,S3,S5,C1,C6,R2,R3,R4,GP |
| S4,R2 |
| S1,S2,C1,C4,G2 |
| S4,C3,C4 |
| S5,C1,C4 |
| S2,C4,C3,C1 |
| C4, C3, C1 |
| S2,S4,R2,C4,C3,C1 |
| GP1,GP2 |
| GP,GP1,GP2 |
| GP,G1,G2 |
| G2,R3 |
| S1,S2,S3,C1,C3,C4,G2 |
| GP,G1,C1 |
| S1,S2,C4,C3,C1 |
| - |
| GP,G1,G2,G3new |
| S1,S2,S3,C1,C3,C4,G2,R2,R3 |
| S1,S2,C1,C3,C4,G2,R2,R3 |
| C1,C6 |
| GP,G2,C4 |
| S2,C3 |
| R5,R4 |
| C4,GP,G2 |
| S1,S2,C1,C4,G2,R2,R3 |
| R1,R2,R4,S3 |
| S2,S5,C3,C1,C4 |
| S2,S4,C4,C3,C1 |
| S2,S4 |
| S3,S1,S2 |
| S1,S2,S3,C1,R2 |
| S3,S1,S2,C1,R2 |
| S2,C3,S5 |
| S1,S2,C1,C4,C3,G2,R2,R3 |
| S5,C4 |
| S2,S1,C3 |
| C1,C4,C3,C6 |
| S1,S2,C1,C4,C3,C6,G2,R2,R3 |
| R1,R2,R4,S3,C4,C6 |
| R4,R1,R4,R1,R2,R3,R3 |
| S2,R3,R2 |
| S1,S2,S5,CP |
| S1,S3,CP |
| C6,C1 |
| R4,R2,R1,R3 |
| R3,R1,R2 |
| R1,R4,R2,R3 |
| S2,C4,C1,C3 |
| R3,R1,R2,R4 |
| C4,S1 |
| S2,S5,R3,GP, |
| S2,S5,R3,GP |
| S1,S2,S3,S5,C1,C3,C4 |
| S2,S3,S5,C1,C3,C4,C6 |
| S5,S1 |
| 03.06.2011 |
| CT1 CT3, CT4 |
| CT3, |
| CT4 |
| CT3 |
| GP,G2,G1 |
| S5,S1,C1 |
| SP,RP,CP |
| SP,CP,GP,RP |
| R1,R2,R4,R3 |
| R4,R2,R5 |
| R2,R4,R5 |
| R1,R2,R4,S2,S3,C4,C6 |
| C1-IETF |
| S4-IETF |
| C1-IETF, C3-IETF, C4-IETF |
| S3-IETF |
| C4-IETF |
| C1-IETF, C3-IETF |
| S2,S4,C1,R2 |
| S2,S4,C3,C4 |
| S2,S4,C1,C3,R2 |
| S1,S2,C1,IETF |
| S4,IETF |
| C1,C4,IETF |
| S2,S4,C1,C3,R2,IETF |
| S3,C1,C4,C3,IETF |
| S3,C4,IETF |
| C1,IETF |
| S1,S2,S3,S5,C1,C3,C4,C6,IETF |
| S2,S3,C1,C4,IETF |
| S1,S2,C1,C3,C4,IETF |
| C1,C3,C4,IETF |
| S1,S5,C1,C3,C4,IETF |
| C1,C3,IETF |
| S2,C1,C3,C4,IETF |
| S2,S4,C3,C4,IETF |
| S5,C1,C4,IETF |
| S5,C1,C3,C4,IETF |
| S2,S3,S5,C1,C3,C4,IETF |
| S2,IETF |
| S3,C1,C3,C4,IETF |
| S2,S3,C1,C3,C4,IETF |
| S3,S2 |
| S3,S2,C1 |
| S3,S1,S2,C1 |
| S2,S5,N3 |
| S1,S2,S3,S5,N1,N3,N4,T3 |
| S5,N4,R3 |
| S1,S2,S5,C1,C4,C3,C6,G2,R2,R3 |
| S2,N1,N4,R3,GP |
| T2,S3 |
| S3,N4,N1 |
| S2,N3,N4 |
| S3,T2 |
| S2,S1,S3,S5,RP,GP |
| S1,S2,S3,S5,R5 |
| S1,S2,S3,S5,NP,T3,T1,R5 |
| S3,T3 |
| GP,S3 |
| S1,S2,S3,S4,S5,RP,R5,GP |
| N1,N4 |
| S1,S2,S3,S4,N1,N3,N4,OMA |
| S2,C1,C3,C4,G2,R2,R3 |
| S1,C4,C3 |
| S2,S1,C1,C4,IETF |
| C1,C3,C4,C6 |
| C4,C1,C6 |
| S1,S2,S3,C1,C3,C4,C6 |
| S2,S1,C1,C3,C4 |
| S1,S2,C1,C3 |
| C1.IETF |
| C1-IETF,C4-IETF |
| G1,C1 |
| G1,S2,C4 |
| G2,S2,C4 |
| R1,R2,R3,R4,R5 |
| R2,R4,R3,R5 |
| R3,R2,R5 |
| R2,R3,C1,C6 |
| S1,S2,S3,C1,C3,C4,C6,R2,R3 |
| R4,R1 |
| S2,S4,C4,C3,C1,IETF |
| S2,C4,C3 |
| S3.C4,C1 |
| G2,C4 |
| R4,G1,G3new |
| C4,G2 |
| S3,C4,C1 |
| R2,R3,R5 |
| R1,R2,R4,R5 |
| S1,S2,S3,S5,C1,C6,R2,R3,R4,R5,GP |
| S1,C1,C4,R2,R5 |
| S2,S3,S5,C3,C4,R2,R3,R4,R5 |
| R2,R1,R3,R4,R5 |
| S3-IETF, C1-IETF |
| S3-IETF,C1-IETF |
| C1-IETF,C3-IETF |
| S2-IETF |
| S2,S1,C1,C3,C4,IETF |
| 25.101, 25.104, 25.141, 25.317 |
| S1,G2,S2,C1 |
| S1,C1,C4,R2,R3,R5 |
| S5,S2 |
| S4,C3,C4,IETF |
| S4,S3,C3,C4,IETF |
| S4,S3,C3,C4 |
| S4,S3,IETF |
| S1,S2,S3,S5,C1,C3,C4,C6,R2,R3 |
| C1,C4,C6 |
| S1,S2,S5,C1,C4,C6,G2,R2,R3 |
| GP,G1,C1,G3new |
| S2,S5,C1,C3 |
| C4,C3,G2 |
| S2,S1,S5,C3,C1,C4 |
| C3,C4,C1 |
| S2,S1,S5,C3,C4,C1 |
| RAN1 |
| RAN2 |
| RAN3 |
| RAN4 |
| R4,R2,R3, |
| Feasibility Study on LTE Device to Device Communications – Radio Aspects |
| SMG1,SMG2,SMG3,SMG7,SMG9,N1,N4,S1,T2 |
| C3-IETF, C4-IETF |
| S3-IETF,C1-IETF,C3-IETF |
| C3-IETF |
| C3,IETF |
| S2,C1,C4,C3,IETF |
| S1,S2,S3,C1,C3,C4,R2,R3,R5,IETF |
| C1-IETF,C3-IETF,C4-IETF |
| C4,C1,C3,IETF |
| S2,C4,C1,C3,IETF |
| C1,C4,C3,IETF |
| S2,S1,T2,N1,N4,R3,R2 |
| S2,S1,S2,S1,N1,N4 |
| S2,S1,N1,N4 |
| S2,R2,G1 |
| S2,S1,S3,S5,N4,R2,R3,GP |
| S1,S2,N4 |
| S2,OMA |
| S2,N4,OMA |
| S2,S5,N4,R2,R4 |
| S2,S5,N4,R2,R4,OMA |
| GP,R2 |
| S1,S2,GP,R2 |
| G1,G3 |
| S1,G2,R2 |
| S2,S5,N4,R2,R4,R5,OMA |
| SR5 |
| S3,C4,C1,R5 |
| S3,S1,C1 |
| S2,C4,C3,G2 |
| SP,CP,RP |
| S3,R5 |
| GP,G2,G3new |
| S1,S2,S3,S4,S5,N1,N3,RP,R5,GP |
| S1,S2,S3,S4,S5,N1,N3,RP,R5,T1,GP |
| S1,S2,S3,S4,S5,N1,N3,RP,R5,T1,GP,G2,G3new |
| S1,S2,S3,S4,S5,N1,N3,R2,R4,R5,T1,GP,G2,G3new |
| S1,S2,S5,C1,C4,C6,G2,R2,R3,G3new |
| SP,CP,RP,GP |
| G2,G1,G3new |
| G2,G1,C1,G3new |
| RAN |
| R |
| S2,S1,S3,S5,R2 |
| S2,S1,S3,S5,R2,R3 |
| S1,S2,S5,C1,C4,C6,G2,R2,R3,R5,G3new |
| C1,C4,R5,IETF |
| C1,R5 |
| R3,R1 |
| R3,GP |
| S3,IETF |
| S1,S2,S5,C1,C3,C4,C6,R2,R3 |
| S3,C4,C1,C3 |
| C1,C4,S1 |
| C1,C4,R3 |
| R2,R1,R3 |
| R1,R4,R2,R3,R5 |
| RAN5 |
| S2,C4,C1,R3 |
| G1,G2,G3new |
| S4,C1 |
| S4,C4,C1,C3 |
| 14/06/2013 08:00 |
| S2,C1,C3,IETF |
| C3, C1 |
| R3,C4 |
| S2,S1,C1,C3 |
| R3,S2,C4 |
| R% |
| G1,C1,G3new |
| R3,S2,C4,G2 |
| S1,S3,N4 |
| S1,OMA |
| S1,S2,S4,OMA |
| S5,S2,N3 |
| S3,C4,C1,C3,IETF |
| S1,S2,S5,C1,C3,C4,C6,R2,R3,R5 |
| S2,S1,S5<c3 |
| S2,C1,C4,C6 |
| S2,S1,S3,C1,C4,C6 |
| S2,S1,S3,C1 |
| R2,R3,R4,G2,G1,G3new |
| C1,C3,R5 |
| ,C4,C6 |
| S2,S1,S3,C1,C4,C6,R2 |
| S2,S1,S3,C1,C4,C6,R2,R3 |
| S2,S1,S3,C1,C3,C4,C6,R2,R3 |
| S1,S2,S3,IETF |
| S1,S2,S3,C1,C3 |
| S1,S2,S3,C4,C1,C3 |
| C1,S1 |
| C34 |
| S1,S2,S3,C1,C4,IETF |
| IETF |
| SMG12 |
| SMG7 |
| SMG3 |
| SMG4 |
| SMG10 |
| C3-IETF,C4-IETF |
| NP,GP,RP,SP,TP |
| S3,G2 |
| R2,S2 |
| R2,S2,C1 |
| R2,C1 |
| S1` |
| R2,S1,C1 |
| C1-IET |
| 18/06/2014 08:00 |
| C4-IET |
| RAN1 (primary) |
| C3.S2 |
| C3-IET |
| S6 |
| ` |
| SA5 |
| Rel-13 |
| Rel-14 |
| 18/06/2015 |
| SA2 |
| S3-IET |
| SA1 |
| SA4-IETF |
| R6 |
| S3LI |
| ITU-R AH |
| Rel-15 |
| CT1-IETF |
| FRASE |
| SP-180438 |
| SP-180439 |
| SP-180440 |
| SP-180441 |
| SP-180442 |
| SP-180443 |
| SP-180387 |
| SP-180388 |
| SP-180390 |
| SP-180391 |

## Schedule

| ID | WBS | Task | Type | Duration | Start | Finish | Complete | Remaining | Total slack | Constraint | Resources | Work | Actual work | Release | Acronym | WI rapporteur name | WI rapporteur e-mail | PCG approved | TSG approved | Status Report |
| --- | --- | --- | --- | --- | --- | --- | --- | --- | --- | --- | --- | --- | --- | --- | --- | --- | --- | --- | --- | --- |
| 1 | 1 | Work Plan 3GPP version June 7th 2018 |  | 1d? | 2000-01-03 | 2000-01-03 |  |  | 5354d |  |  |  |  | Rel-16 |  |  |  |  |  |  |
| 2 | 2 | UIDs in the 80xxxx series proposed at TSG#80 |  | 1d? | 2000-01-03 | 2000-01-03 |  |  | 5354d |  |  |  |  | Rel-16 |  |  |  |  |  |  |
| 3 | 3 | Next targets: Rel-15: St.3: 06/18; Rel-16 St.1: 12/18 |  | 1d? | 2000-01-03 | 2000-01-03 |  |  | 5354d |  |  |  |  | Rel-16 |  |  |  |  |  |  |
| 5 | 4 | Release 16 Features and related studies | milestone | 0d? | 2016-03-15 A | 2016-03-15 A | 100% |  |  | start no earlier than 2016-03-15 |  |  |  | Rel-16 |  |  |  |  |  |  |
| 6 | 5 | Release 16 Features on Use of 5G by different sectors ("verticals") | milestone | 0d? | 2016-06-09 A | 2016-06-09 A | 100% |  |  | finish no earlier than 2016-06-09 |  |  |  | Rel-16 |  |  |  |  |  |  |
| 7 | 6 | Study on 5GS Enhanced support of Vertical and LAN Services |  | 138d? | 2018-06-06 | 2018-12-14 |  |  | 391d | finish no earlier than 2018-12-14 | S2 | 1104h |  | Rel-16 | FS_Vertical_LAN | Devaki Chandramouli, Nokia | Devaki.chandramouli@nokia.com |  |  |  |
| 8 | 7 | Study on Communication for Automation in Vertical Domains |  | 271d? | 2017-03-02 A | 2018-03-15 A | 100% |  |  | finish no earlier than 2018-03-15 | S1 | 2168h | 2168h | Rel-16 | FS_CAV | Walewski, Joachim, Siemens AG | joachim.walewski@siemens.com | 38 | 75 |  |
| 9 | 8 | Study on Remote Identification of Unmanned Aerial Systems |  | 132d? | 2018-03-15 A | 2018-09-14 | 60% | 52.8d? | 456d | finish no earlier than 2018-09-14 | S1 | 1056h | 633.6h | Rel-16 | FS_ID_UAS | Eddy Hall; Qualcomm Incorporated | edhall@qti.qualcomm.com |  | 79 |  |
| 10 | 9 | Study on Improvement of V2X Service Handling |  | 66d? | 2018-03-15 A | 2018-06-14 | 75% | 16.5d? | 522d | finish no earlier than 2018-06-14 | S1 | 528h | 396h | Rel-16 | FS_V2XIMP | SungDuck Chun; LG Electronics | sungduck.chun@lge.com |  | 79 |  |
| 11 | 10 | Study on application layer support for V2X services |  | 196d? | 2017-12-15 A | 2018-09-14 | 45% | 107.8d? | 456d | finish no earlier than 2018-09-14 | S6 | 1568h | 705.6h | Rel-16 | FS_V2XAPP | Niranth Amogh, Huawei Telecommunications India | namogh@huawei.com |  | 78 |  |
| 12 | 11 | Study on architecture enhancements for 3GPP support of advanced V2X services |  | 333d? | 2017-06-05 A | 2018-09-12 | 35% | 216.45d? | 458d | finish no earlier than 2018-09-12 | S2 | 2664h | 932.4h | Rel-16 | FS_eV2XARC | LaeYoung Kim, LG Electronics | laeyoung.kim@lge.com | 39 | 76 | SP-170412 |
| 13 | 12 | **Mobile Communication System for Railways 2** |  | 400d? | 2017-06-05 A | 2018-12-14 | 60% | 160.51d? | 391d |  |  | 6928h | 4148h | Rel-16 | MONASTERY2 | Merkel, Juergen, Nokia | juergen.merkel@nokia.com | 39 | 76 |  |
| 14 | 12.1 | Study on MONASTERY2 |  | 269d? | 2017-06-05 A | 2018-06-14 | 85% | 40.35d? | 522d | finish no earlier than 2018-06-14 | S1 | 2152h | 1829.2h | Rel-16 | FS_FRMCS2 | Merkel, Juergen, Nokia | juergen.merkel@nokia.com | 39 | 76 |  |
| 15 | 12.2 | Study on application architecture for the Future Railway Mobile Communication System (FRMCS) Phase 2 |  | 197d? | 2018-03-15 A | 2018-12-14 | 5% | 187.15d? | 391d | start no earlier than 2018-03-15 | S6 | 1576h | 78.8h | Rel-16 | FS_FRMCS2 | Oettl, Martin, Nokia | martin(dot)oettl(at)nokia(dot)com |  | 79 |  |
| 16 | 12.3 | Stage 1 of MONASTERY2 |  | 400d? | 2017-06-05 A | 2018-12-14 | 70% | 120d? | 391d | finish no earlier than 2018-12-14 | S1 | 3200h | 2240h | Rel-16 | MONASTERY2 | Merkel, Juergen, Nokia | juergen.merkel@nokia.com | 39 | 76 |  |
| 17 | 13 | **Maritime Communication Services over 3GPP System** |  | 584d? | 2016-09-19 A | 2018-12-13 | 73% | 157.59d? | 392d |  | S1 | 5950h | 3458h | Rel-16 | MARCOM | Hyounhee Koo, SyncTechno Inc | koo at synctechno dot com |  |  |  |
| 18 | 13.1 | Study on Maritime Communication Services over 3GPP system |  | 455d? | 2016-09-19 A | 2018-06-15 | 95% | 22.75d? | 521d | finish no earlier than 2018-06-15 | S1 | 3640h | 3458h | Rel-16 | FS_MARCOM | SyncTechno Inc., Hyounhee Koo | koo at synctechno dot com | 37 | 73 |  |
| 19 | 13.2 | Stage 1 of MARCOM |  | 137d? | 2018-06-06 | 2018-12-13 |  |  | 392d | finish no earlier than 2018-12-13 | S1 | 1096h |  | Rel-16 | MARCOM | Hyounhee Koo, SyncTechno Inc | koo at synctechno dot com |  |  |  |
| 20 | 14 | Service requirements for cyber-physical control applications in vertical domains |  | 73d? | 2018-06-06 A | 2018-09-14 | 5% | 69.35d? | 456d | finish no earlier than 2018-09-14 | S1 | 584h | 29.2h | Rel-16 | cyberCAV | Joachim W. Walewski (Siemens) |  |  |  |  |
| 21 | 15 | **LAN support in 5G** |  | 335d? | 2017-06-05 A | 2018-09-14 | 84% | 52.97d? | 456d |  | S1 | 3264h | 1865.6h | Rel-16 | 5GLAN | Almodovar Chico, Jose Luis, KPN | jose.almodovarchico@tno.nl |  |  |  |
| 22 | 15.1 | Study on LAN Support in 5G |  | 204d? | 2017-06-05 A | 2018-03-15 A | 100% |  |  | finish no earlier than 2018-03-15 | S1 | 1632h | 1632h | Rel-16 | FS_5GLAN | Nasielski, Jack, Qualcomm Incorporated | jackn@qti.qualcomm.com | 39 | 76 |  |
| 23 | 15.2 | Stage 1 of 5GLAN |  | 73d? | 2018-06-06 A | 2018-09-14 | 40% | 43.8d? | 456d | finish no earlier than 2018-09-14 | S1 | 584h | 233.6h | Rel-16 | 5GLAN | Almodovar Chico, Jose Luis, KPN | jose.almodovarchico@tno.nl |  |  |  |
| 24 | 16 | Release 16 Features specific to 5G | milestone | 0d? | 2016-06-09 A | 2016-06-09 A | 100% |  |  | finish no earlier than 2016-06-09 |  |  |  | Rel-16 |  |  |  |  |  |  |
| 25 | 17 | New Services and Markets Technology Enablers – Phase 2 |  | 197d? | 2018-03-15 A | 2018-12-14 | 10% | 177.3d? | 391d | finish no earlier than 2018-12-14 | S1 | 1576h | 157.6h | Rel-16 | SMARTER_Ph2 | Li, Alice, Vodafone | alice.li@vodafone.com |  | 79 |  |
| 26 | 18 | Charging for IMS over 5G System Architecture Phase 1 |  | 30d? | 2018-05-07 A | 2018-06-15 A | 100% |  |  | start no earlier than 2018-05-07 | S5 | 240h | 240h | Rel-16 | 5GS_Ph1_IMSCH | Gardella, Maryse, Nokia | maryse.gardella@nokia.com |  |  |  |
| 27 | 19 | 5G Voice Service Continuity |  | 59d? | 2017-12-21 A | 2018-03-13 A | 100% |  |  | finish no earlier than 2018-03-13 | S1 | 472h | 472h | Rel-16 | 5GVSC | Qun Wei, China Unicom | weiqun5@chinaunico.cn |  | 78 |  |
| 28 | 20 | Security Assurance Specification for 5G |  | 392d? | 2018-03-15 | 2019-09-13 |  |  | 196d | finish no earlier than 2019-09-13 | S3 | 3136h |  | Rel-16 | SCAS_5G | Marcus Wong, Huawei Technologies | mwong@huawei.com |  | 79 |  |

Notes:
- 5: -
- 6: -
- 7: Impacted TSs and TRs: New
- 8: 7/6/17: 0%->30; 25/8/17: FCD:12/17->03/18; 11/9/17: 30%->65; 15/12/17: 65%->85; 16/3/18: 85%->95; 7/6/18: 95%->100 / Impacted TSs and TRs: 22.804
- 9: 7/6/18: 0%->60 / Impacted TSs and TRs: 22.8xx
- 10: 7/6/18: 0%->75 / Impacted TSs and TRs: 22.886
- 11: 16/3/18: 0%->45
- 12: 11/9/17: 0%->20; 15/12/17: Changed Rel-15->Rel-16; 16/3/18: WID:SP-170379->SP 170590; 16/3/18: 20%->25; 7/6/18: 25%->35 / Impacted TSs and TRs: 23.786
- 13: 15/12/17: 10%->35 / Impacted TSs and TRs: New 22.289; 22.280; 22.281; 22.282; 22.179
- 14: 15/12/17: 35%->50; 16/3/18: 50%->80; 7/6/18: 80%->85 / Impacted TSs and TRs: New 22.889
- 15: 19/4/18: 0%->5 / Impacted TSs and TRs: TR 23.cde
- 16: 16/3/18: 35%->55; 7/6/18: 55%->70; 7/6/18: FCD:06/18->12/18 / Impacted TSs and TRs: New 22.289; 22.280; 22.281; 22.282; 22.179
- 17: Impacted TSs and TRs: 22.179; 22.280; 22.281; 22.282; 22.261; 22.346; 22.468
- 18: 22.xxx; 1/12/16: 0%->10; 2/3/17: 10%->15; 2/3/17: WID:SP-160556->SP-170166; 10/3/17: FCD:06/17->06/20; 21/3/17: 22.819 added;; 8/6/17: WID:SP-170166->SP-170453; 25/8/17: 15%->35; 15/12/17: 35%->55; 16/3/18: 55%->75; 7/6/18: 75%->95 / Impacted TSs and TRs: 22.819
- 19: Impacted TSs and TRs: 22.179; 22.280; 22.281; 22.282; 22.261; 22.346; 22.468
- 20: Impacted TSs and TRs: 22.261
- 21: Impacted TSs and TRs: 22.261; 22.278
- 22: 11/9/17: 0%->35; 15/12/17: 35%->65; 16/3/18: 65%->100 / Impacted TSs and TRs: 22.821;
- 23: Impacted TSs and TRs: 22.261; 22.278
- 24: -
- 25: 7/6/18: WID:SP-180138->SP-180313; 7/6/18: 0%->10 / Impacted TSs and TRs: 22.261; 22.278
- 26: 7/6/18: 0%->100 / Impacted TSs and TRs: 32.240; 32.260; 32.299; 32.298
- 27: 16/3/18: 0%->100 / Impacted TSs and TRs: 22.261
- 28: 27/3/18: added: 33.514; 33.513; 33.511; 33.512; 33.515 / Impacted TSs and TRs: 33.gNB; 33.AMF; 33.UPF; 33.UDM; 33.SMF; 33.216; 33.926; 33.515

| ID | WBS | Task | Type | Duration | Start | Finish | Complete | Remaining | Total slack | Constraint | Resources | Work | Actual work | Acronym | Impacted TSs and TRs | WI rapporteur name | WI rapporteur e-mail | Release | PCG approved | TSG approved |
| --- | --- | --- | --- | --- | --- | --- | --- | --- | --- | --- | --- | --- | --- | --- | --- | --- | --- | --- | --- | --- |
| 29 | 21 | **Integration of Satellite Access in 5G** |  | 266d? | 2017-09-08 A | 2018-09-14 | 73% | 70.87d? | 456d |  | S1 | 4320h | 3169.05h | 5GSAT | 22.261 | MICHEL, Cyril, Thales | cyril.michel@thalesaleniaspace.com | Rel-16 |  |  |
| 30 | 21.1 | Study on using Satellite Access in 5G |  | 201d? | 2017-09-08 A | 2018-06-15 A | 100% |  |  | finish no earlier than 2018-06-15 | S1 | 1608h | 1608h | FS_5GSAT | New; 22.822 | MICHEL, Cyril | cyril.michel@thalesaleniaspace.com | Rel-16 | 39 | 77 |
| 31 | 21.2 | Stage 1 of 5GSAT |  | 73d? | 2018-06-06 | 2018-09-14 |  |  | 456d | finish no earlier than 2018-09-14 | S1 | 584h |  | 5GSAT | 22.261 | MICHEL, Cyril, Thales | cyril.michel@thalesaleniaspace.com | Rel-16 |  |  |
| 32 | 22 | Study on architecture aspects for using satellite access in 5G |  | 268d? | 2018-06-06 | 2019-06-14 |  |  | 261d | finish no earlier than 2019-06-14 | S2 | 2144h |  | FS_5GSAT_ARCH | New | MICHEL, Cyril | cyril.michel@thalesaleniaspace.com | Rel-16 |  |  |
| 33 | 23 | **5G positioning services** |  | 335d? | 2017-06-05 A | 2018-09-14 | 71% | 97.67d? | 456d |  | S1 | 5424h | 3842.66h | 5G_HYPOS | 22.261 | Ries, Lionel, ESA | lionel.ries at esa.int | Rel-16 |  |  |
| 34 | 23.1 | Study on positioning use cases |  | 270d? | 2017-06-05 A | 2018-06-15 | 90% | 27d? | 521d | finish no earlier than 2018-06-15 | S1 | 2160h | 1944h | FS_5G_HYPOS | 22.872 | Ries, Lionel, ESA | lionel.ries@esa.int | Rel-16 | 39 | 76 |
| 35 | 23.2 | Stage 1 of 5G_HYPOS |  | 73d? | 2018-06-06 | 2018-09-14 |  |  | 456d | finish no earlier than 2018-09-14 | S1 | 584h |  | 5G_HYPOS | 22.261 | Ries, Lionel, ESA | lionel.ries at esa.int | Rel-16 |  |  |
| 36 | 24 | 5GS Transfer of Policies for Background Data Transfer |  | 138d? | 2018-06-06 | 2018-12-14 |  |  | 391d | finish no earlier than 2018-12-14 | S3 | 1104h |  | xBDT | 23.501; 23.502; 23.503 |  | ta-usui@kddi.com | Rel-16 |  |  |
| 37 | 25 | Release 16 Features on Mission Critical and Public Warning | milestone | 0d? | 2016-06-09 A | 2016-06-09 A | 100% |  |  | finish no earlier than 2016-06-09 |  |  |  |  |  |  |  | Rel-16 |  |  |
| 38 | 26 | Study on Mission Critical services support over 5G System |  | 203d? | 2018-06-06 | 2019-03-15 |  |  | 326d | finish no earlier than 2019-03-15 | S6 | 1624h |  | FS_MCOver5GS | New | Verweij, Kees, The Police of the Netherlands | kees.verweij@politie.nl | Rel-16 |  |  |
| 39 | 27 | Study on MC services access aspects |  | 197d? | 2018-03-15 A | 2018-12-14 | 5% | 187.15d? | 391d | start no earlier than 2018-03-15 | S6 | 1576h | 78.8h | FS_MCSAA | new TR 23.xxx | Magnus Tränk, Ericsson | magnus.trank@ericsson.com | Rel-16 |  | 79 |
| 40 | 28 | Study into discreet listening and logging for mission critical services |  | 203d? | 2018-06-06 | 2019-03-15 |  |  | 326d | finish no earlier than 2019-03-15 | S6 | 1624h |  | FS_MCLOG | New | Chater-Lea, David, Motorola Solutions | david.chater-lea@motorolasolutions.com | Rel-16 |  |  |
| 41 | 29 | Enhanced Mission Critical Push-to-talk architecture phase 2 |  | 202d? | 2018-06-06 | 2019-03-14 |  |  | 327d | finish no earlier than 2019-03-14 | S6 | 1616h |  | enh2MCPTT | 23.280; 23.379; 23.281; 23.282; 23.283 | Dom Lazara; Motorola Solutions | Dom.Lazara@motorolasolutions.com | Rel-16 |  |  |
| 42 | 30 | Enhancements to Functional architecture and information flows for Mission Critical Data |  | 268d? | 2018-06-06 | 2019-06-14 |  |  | 261d | finish no earlier than 2019-06-14 | S6 | 2144h |  | eMCData2 | 23.280; 23.282 | Shih, Jerry, AT&T | jerry.shih@att.com | Rel-16 |  |  |
| 43 | 31 | Enhanced Mission Critical System Migration and Interconnection |  | 202d? | 2018-06-06 | 2019-03-14 |  |  | 327d | finish no earlier than 2019-03-14 | S6 | 1616h |  | eMCSMI | 23.280; 23.379; 23.281; 23.282; 23.283 | Chater-Lea, David; Motorola Solutions | david.chater-lea@motorolasolutions.com | Rel-16 |  |  |
| 44 | 32 | **MBMS APIs for Mission Critical Services** |  | 464d? | 2017-06-05 A | 2019-03-14 | 34% | 304.75d? | 327d |  | S6 | 7488h | 2570.03h | MBMSAPI_MCS | New | Ling Zhang, TD Tech Ltd. | zhangling@td-tech.com | Rel-16 |  |  |
| 45 | 32.1 | Study on MBMS APIs for MC Services |  | 270d? | 2017-06-05 A | 2018-06-15 | 60% | 108d? | 521d | finish no earlier than 2018-06-15 | S6 | 2160h | 1296h | FS_MBMSAPI_MC | new 23.792 | Ling Zhang, TD Tech Ltd | zhangling@td-tech.com | Rel-16 | 39 | 76 |
| 46 | 32.2 | Stage 2 of MBMS APIs for MC Services |  | 202d? | 2018-06-06 | 2019-03-14 |  |  | 327d | finish no earlier than 2019-03-14 | S6 | 1616h |  | MBMSAPI_MCS | New | Ling Zhang, TD Tech Ltd. | zhangling@td-tech.com | Rel-16 |  |  |
| 47 | 33 | Enhanced Mission Critical Communication Interworking with Land Mobile Radio Systems |  | 268d? | 2018-06-06 | 2019-06-14 |  |  | 261d | finish no earlier than 2019-06-14 | S6 | 2144h |  | eMCCI | 23.283 | Monnes, Peter, Harris Corporation | pmonnes at harris dot com | Rel-16 |  |  |
| 48 | 34 | Mission Critical Communication Interworking with Land Mobile Radio Systems |  | 138d? | 2018-06-06 A | 2018-12-14 | 5% | 131.1d? | 391d | finish no earlier than 2018-12-14 | C1 | 1104h | 55.2h | MCCI3 | 24.379; 24.380; 24.282; 24.481; 24.483; 24.484; 24.482 | Monnes, Peter, Harris Corporation | pmonnes@harris.com | Rel-16 |  |  |
| 49 | 35 | Mission Critical Services Security Enhancements |  | 202d? | 2018-06-06 | 2019-03-14 |  |  | 327d | finish no earlier than 2019-03-14 | S3 | 1616h |  | MCXSec | 33.180 | Woodward, Tim, Motorola Solutions, Inc |  | Rel-16 |  |  |
| 50 | 36 | **Enhancements of Public Warning System** |  | 585d? | 2016-09-19 A | 2018-12-14 | 99% | 0d? | 0d |  | S1 | 8840h | 6248h | ePWS |  | Hyounhee Koo, SyncTechno Inc. | koo at synctechno dot com | Rel-16 |  | 78 |
| 51 | 36.1 | Study on enhancements of Public Warning System |  | 259d? | 2016-09-19 A | 2017-09-14 A | 100% |  |  | finish no earlier than 2017-09-14 | S1 | 2072h | 2072h | FS_ePWS | 22.869 | SyncTechno Inc., Hyounhee Koo | koo at synctechno dot com | Rel-16 | 37 | 73 |
| 52 | 36.2 | Stage 1 of ePWS |  | 261d? | 2017-12-15 A | 2018-12-14 A | 100% |  |  | finish no earlier than 2018-12-14 | S1 | 2088h | 2088h | ePWS |  | Hyounhee Koo, SyncTechno Inc. | koo at synctechno dot com | Rel-16 |  | 78 |
| 53 | 37 | Release 16 Features on Streaming and TV | milestone | 0d? | 2016-06-09 A | 2016-06-09 A | 100% |  |  | finish no earlier than 2016-06-09 |  |  |  |  |  |  |  | Rel-16 |  |  |

Notes:
- 30: 15/12/17: 22.822 added;; 15/12/17: 0%->30; 15/12/17: FCD:12/17->06/18; 16/3/18: 30%->70; 7/6/18: 70%->100
- 34: 11/9/17: 0%->10; 15/12/17: 10%->50; 15/12/17: FCD:03/18->06/18; 16/3/18: 50%->75; 7/6/18: 75%->90
- 37: -
- 39: 19/4/18: 0%->5
- 45: 12/7/17: WID:SP-170596->SP-170598; 11/9/17: 0%->10; 15/12/17: 10%->20; 15/12/17: Changed Rel-15->Rel-16; 16/3/18: 20%->60; 23/3/18: WID:SP-170598->SP-180237; 23/3/18: FCD:03/18->06/18
- 50: 16/3/18: 0%->100
- 51: 22.xxx; 1/12/16: 0%->5; 2/3/17: 5%->45; 7/6/17: 45%->75; 30/6/17: 22.869 added;; 25/8/17: 75%->95; 15/12/17: 95%->100
- 52: 16/3/18: 0%->100
- 53: -

| ID | WBS | Task | Type | Duration | Start | Finish | Complete | Remaining | Total slack | Constraint | Resources | Work | Actual work | Acronym | WI rapporteur name | WI rapporteur e-mail | Release | PCG approved | TSG approved |
| --- | --- | --- | --- | --- | --- | --- | --- | --- | --- | --- | --- | --- | --- | --- | --- | --- | --- | --- | --- |
| 54 | 38 | **Enhancement of LTE for Efficient delivery of Streaming Service** |  | 402d? | 2016-12-01 A | 2018-06-15 | 99% | 3.19d? | 521d |  | S1 | 6136h | 6087.28h | eLSTR | Xia, Xu, China Telecom | xiaxu.bri@chinatelecom.cn | Rel-16 |  |  |
| 55 | 38.1 | Study on eLSTR |  | 336d? | 2016-12-01 A | 2018-03-15 A | 100% |  |  | finish no earlier than 2018-03-15 | S1 | 2688h | 2688h | FS_eLESTR | China Telecommunications, XIA Xu | xiaxu@ctbri.com.cn | Rel-16 | 38 | 74 |
| 56 | 38.2 | Stage 1 of eLSTR |  | 29d? | 2018-05-08 A | 2018-06-15 | 90% | 2.9d? | 521d | finish no earlier than 2018-06-15 | S1 | 232h | 208.8h | eLSTR | Xia, Xu, China Telecom | xiaxu.bri@chinatelecom.cn | Rel-16 |  |  |
| 57 | 39 | Enhancements to Framework for Live Uplink Streaming |  | 202d? | 2018-06-06 | 2019-03-14 |  |  | 327d | finish no earlier than 2019-03-14 | S4 | 1616h |  | E-FLUS | Lo, Charles, Qualcomm Incorporated | clo@qti.qualcomm.com | Rel-16 |  |  |
| 58 | 40 | Addition of HLG HDR to TV Video Profiles |  | 73d? | 2018-06-06 | 2018-09-14 |  |  | 456d | finish no earlier than 2018-09-14 | S4 | 584h |  | HLG_HDR | Paul Szucs, Sony Europe Limited | jerry.shih@att.com | Rel-16 |  |  |
| 59 | 41 | All other Release 16 Features | milestone | 0d? | 2016-06-09 A | 2016-06-09 A | 100% |  |  | finish no earlier than 2016-06-09 |  |  |  |  |  |  | Rel-16 |  |  |
| 60 | 42 | **User Identities and Authentication** |  | 196d? | 2017-12-15 A | 2018-09-14 | 58% | 83.03d? | 456d |  | S1 | 3192h | 1839.72h | UIA | Bischinger, Kurt; Deutsche Telekom | kurt.bischinger@t-mobile.at | Rel-16 |  |  |
| 61 | 42.1 | Study on a Layer for User Centric Identifiers and Authentication |  | 130d? | 2017-12-15 A | 2018-06-14 | 90% | 13d? | 522d | finish no earlier than 2018-06-14 | S1 | 1040h | 936h | FS_LUCIA | Bischinger, Kurt; Deutsche Telekom | kurt.bischinger@t-mobile.at | Rel-16 |  | 78 |
| 62 | 42.2 | Stage 1 of User Identities and Authentication |  | 73d? | 2018-06-06 | 2018-09-14 |  |  | 456d | finish no earlier than 2018-09-14 | S1 | 584h |  | UIA | Bischinger, Kurt; Deutsche Telekom | kurt.bischinger@t-mobile.at | Rel-16 |  |  |
| 63 | 43 | Multi-device and multi-identity |  | 73d? | 2018-06-06 A | 2018-09-14 | 85% | 10.95d? | 456d | finish no earlier than 2018-09-14 | S1 | 584h | 496.4h | MuD | Peter Bleckert, Ericsson | Peter.Bleckert@ericsson.com | Rel-16 |  |  |
| 64 | 44 | Enhancements to IMS for new real time communication services |  | 132d? | 2018-03-15 A | 2018-09-14 | 25% | 99d? | 456d | finish no earlier than 2018-09-14 | S1 | 1056h | 264h | enIMS | China Mobile, Hui Cai | caihui at chinamobile dot com | Rel-16 |  | 79 |
| 65 | 45 | Service Interactivity |  | 331d? | 2017-09-08 A | 2018-12-14 | 40% | 198.6d? | 391d | finish no earlier than 2018-12-14 | S4 | 2648h | 1059.2h | SerInter | Lo, Charles, Qualcomm Incorporated | clo@qti.qualcomm.com | Rel-16 | 39 | 77 |
| 66 | 46 | EVS Codec Extension for Immersive Voice and Audio Services |  | 591d? | 2017-09-08 A | 2019-12-13 | 15% | 502.35d? | 131d | finish no earlier than 2019-12-13 | S4 | 4728h | 709.2h | IVAS_Codec | Gibbs, Jon, Huawei Technologies Co Ltd | jon.gibbs@oblisco.com | Rel-16 | 39 | 77 |
| 67 | 47 | Alternative EVS implementation using updated fixed-point basic operators |  | 138d? | 2018-06-06 | 2018-12-14 |  |  | 391d | finish no earlier than 2018-12-14 | S4 | 1104h |  | Alt_FX_EVS | Pawate, Raj, Cadence Design Systems Inc | pawateb@cadence.com | Rel-16 |  |  |
| 68 | 48 | Shared Data Handling on Nudm and Nudr |  | 138d? | 2018-06-06 | 2018-12-14 |  |  | 391d | finish no earlier than 2018-12-14 | C4 | 1104h |  | Shared_Data | Wiehe, Ulrich, Nokia | ulrich.wiehe@nokia.com | Rel-16 |  |  |
| 69 | 49 | Usage of CAPIF for xMB API |  | 197d? | 2018-03-15 A | 2018-12-14 | 25% | 147.75d? | 391d | finish no earlier than 2018-12-14 | S4 | 1576h | 394h | CAPIF4xMB | Thorsten Lohmar, Ericsson LM | Thorsten.lohmar@ericsson.com | Rel-16 |  | 79 |
| 70 | 50 | Enhancements for Common API Framework for 3GPP Northbound APIs |  | 197d? | 2018-03-15 A | 2018-12-14 | 15% | 167.45d? | 391d | start no earlier than 2018-03-15 | S6 | 1576h | 236.4h | eCAPIF | Basavaraj Pattan, Samsung | basavarajjp@samsung.com | Rel-16 |  | 79 |
| 71 | 51 | **Provision of Access to Restricted Local Operator Services by Unauthenticated UEs** |  | 532d? | 2016-12-01 A | 2018-12-14 | 57% | 230.71d? | 391d |  |  | 4040h | 2288h | PARLOS | Covell, Betsy Nokia | betsy.covell@nokia.com | Rel-16 | 38 | 74 |
| 72 | 51.1 | Study on Provision of Access to Local Operator Services |  | 75d? | 2016-12-01 A | 2017-03-15 A | 100% |  |  | finish no earlier than 2017-03-15 | S1 | 600h | 600h | FS_PARLOS | Covell, Betsy | betsy.covell@nokia.com | Rel-16 | 38 | 74 |
| 73 | 51.2 | Stage 1 for PARLOS |  | 22d? | 2017-05-10 A | 2017-06-08 A | 100% |  |  | finish no earlier than 2017-06-08 | S1 | 176h | 176h | PARLOS | Covell, Betsy Nokia | betsy.covell@nokia.com | Rel-16 | 39 | 76 |
| 74 | 51.3 | Study on Stage 2 for PARLOS |  | 270d? | 2017-06-05 A | 2018-06-15 | 70% | 81d? | 521d | finish no earlier than 2018-06-15 | S2 | 2160h | 1512h | FS_PARLOS_SA2 | Nokia (Nicolas Drevon | nicolas.drevon@nokia.com | Rel-16 | 39 | 76 |
| 75 | 51.4 | Study on Security Aspects of PARLOS |  | 138d? | 2018-06-06 | 2018-12-14 |  |  | 391d | finish no earlier than 2018-12-14 | S3 | 1104h |  | FS_PARLOS_Sec | Greg Schumacher, Sprint | Gregory.schumacher@sprint.com | Rel-16 |  |  |
| 76 | 52 | **Addition of Power Class 1 UE to bands B31/B72 for LTE** |  | 197d? | 2018-03-15 | 2018-12-15 |  |  | 391d |  | R4 | 3152h |  | LTE_PC1_B31_B72 | Airbus |  | Rel-16 |  | 79 |
| 77 | 52.1 | Core part: Addition of Power Class 1 UE to bands B31/B72 for LTE |  | 197d? | 2018-03-15 | 2018-12-15 |  |  | 391d | finish no earlier than 2018-12-15 | R4 | 1576h |  | LTE_PC1_B31_B72-Core | Airbus |  | Rel-16 |  | 79 |

Notes:
- 54: Impacted TSs and TRs: 22.278; 22.115
- 55: 2/3/17: 0%->20; 7/6/17: 20%->50; 11/9/17: 50%->70; 15/12/17: 70%->75; 15/12/17: FCD:09/17->03/18; 16/3/18: 75%->100 / Impacted TSs and TRs: 22.833
- 56: Impacted TSs and TRs: 22.278; 22.115
- 57: Impacted TSs and TRs: 26.238; 26.939
- 58: Impacted TSs and TRs: 26.116; 26.346; 26.234
- 59: -
- 60: Impacted TSs and TRs: 22.101; 22.115
- 61: 16/3/18: 0%->60; 7/6/18: 60%->90 / Impacted TSs and TRs: 22.904
- 62: Impacted TSs and TRs: 22.101; 22.115
- 63: Impacted TSs and TRs: 22.173
- 64: 7/6/18: 0%->25 / Impacted TSs and TRs: 22.261; 22.468; 22.228; 22.280; 22.281; 22.282; 22.179
- 65: 15/12/17: 0%->10; 16/3/18: 10%->20; 7/6/18: 20%->40; 7/6/18: FCD:06/18->12/18. Moved from Rel-15 / Impacted TSs and TRs: TS 26.346; TS 26.247; TS 26.347
- 66: 15/12/17: added :26.258; 26.256; 26.255; 26.254; 26.253; 26.251; 26.252; 26.250; 26.997; 15/12/17: 0%->5; 16/3/18: 5%->10; 7/6/18: 10%->15 / Impacted TSs and TRs: 26.114, new; 26.258; 26.256; 26.255; 26.254; 26.253; 26.251; 26.252; 26.250; 26.997
- 67: Impacted TSs and TRs: 26.441; 26.442; 26.444; 26.445; 26.446; 26.447; 26.449; 26.450; 26.451; 26.952
- 68: Impacted TSs and TRs: 29.503; 29.505; 29.504
- 69: 7/6/18: 0%->25 / Impacted TSs and TRs: 26.346, new
- 70: 7/6/18: 0%->15 / Impacted TSs and TRs: 23.222
- 71: 16/03/18: Moved to Rel-16 as per SA2 chair indication that St 2 work to be shifted from Rel-15 to Rel-16 / Impacted TSs and TRs: 22.115; 22.101; 22.228
- 72: 1/12/16: 0%->75; 2/3/17: 75%->100 / Impacted TSs and TRs: 22.xxx
- 73: 7/6/17: 0%->100 / Impacted TSs and TRs: 22.115; 22.101; 22.228
- 74: 11/9/17: 0%->20; 16/3/18: FCD:12/17->12/18.; 16/3/18: 20%->45; 23/3/18: WID:SP-170382->SP-180116; 23/3/18: FCD:12/18->06/18; 7/6/18: 45%->70 / Impacted TSs and TRs: 23.715
- 75: Impacted TSs and TRs: New
- 76: to add Power Class 1 (+31dBm) for UE operating in Europe @ 450MHz in frequency bands that are suitable for BB-PPDR operation, i.e. band 31 and band 72;
- 77: to add Power Class 1 (+31dBm) for UE operating in Europe @ 450MHz in frequency bands that are suitable for BB-PPDR operation, i.e. band 31 and band 72;

| ID | WBS | Task | Type | Duration | Start | Finish | Complete | Remaining | Total slack | Constraint | Resources | Work | Actual work | Acronym | WI rapporteur name | Release | TSG approved | Impacted TSs and TRs | WI rapporteur e-mail | PCG approved |
| --- | --- | --- | --- | --- | --- | --- | --- | --- | --- | --- | --- | --- | --- | --- | --- | --- | --- | --- | --- | --- |
| 78 | 53 | **E-UTRA 2.4 GHz TDD Band for US** |  | 197d? | 2018-03-15 | 2018-12-15 |  |  | 391d |  | R4 | 4728h |  | LTE_TDD_2400_US | Globalstar | Rel-16 | 79 |  |  |  |
| 79 | 53.1 | Core part: E-UTRA 2.4 GHz TDD Band for US |  | 197d? | 2018-03-15 | 2018-12-15 |  |  | 391d | finish no earlier than 2018-12-15 | R4 | 1576h |  | LTE_TDD_2400_US-Core | Globalstar | Rel-16 | 79 |  |  |  |
| 80 | 53.2 | Perf. part: E-UTRA 2.4 GHz TDD Band for US |  | 197d? | 2018-03-15 | 2018-12-15 |  |  | 391d | finish no earlier than 2018-12-15 | R4 | 1576h |  | LTE_TDD_2400_US-Perf | Globalstar | Rel-16 | 79 |  |  |  |
| 81 | 54 | Policy delivery to UE for background data transfer |  | 29d? | 2018-05-08 A | 2018-06-15 | 90% | 2.9d? | 521d | start no earlier than 2018-05-08 | S1 | 232h | 208.8h | PDBDT | Takatsugu Kito, KDDI | Rel-16 |  | 22.261 | ta-kito at kddi dot com |  |
| 82 | 55 | QoS Monitoring |  | 67d? | 2018-03-15 A | 2018-06-15 | 60% | 26.8d? | 521d | finish no earlier than 2018-06-15 | S1 | 536h | 321.6h | QoS_MON | Amar Deol | Rel-16 | 79 | TS 22.261 | amar.deol@huawei.com |  |
| 83 | 56 | Inter-RAT Mobility requirements for real time service |  | 73d? | 2018-06-06 A | 2018-09-14 | 70% | 21.9d? | 456d | finish no earlier than 2018-09-14 | S1 | 584h | 408.8h | MOBRT | Yang Xu, Oppo | Rel-16 |  | 22.261 | xuyang@oppo.com |  |
| 84 | 57 | (Small) Technical Enhancements and Improvements for Rel-16 |  | 196d? | 2017-09-11 A | 2018-06-11 A | 100% |  |  | finish no earlier than 2017-12-15 |  |  |  | TEI16 |  | Rel-16 | 77 |  |  | 39 |
| 85 | 58 | Release 16 Studies with no corresponding Feature | milestone | 0d? | 2016-03-15 A | 2016-03-15 A | 100% |  |  | start no earlier than 2016-03-15 |  |  |  |  |  | Rel-16 |  |  |  |  |
| 86 | 59 | Release 16 Studies on CIoT/MIoT and Low Latency | milestone | 0d? | 2016-06-09 A | 2016-06-09 A | 100% |  |  | finish no earlier than 2016-06-09 |  |  |  |  |  | Rel-16 |  |  |  |  |
| 87 | 60 | Study on 5G message service for MIoT |  | 266d? | 2016-06-18 A | 2018-09-14 | 60% | 106.4d? | 456d | finish no earlier than 2018-09-14 | S1 | 2128h | 1276.8h | FS_5GMSG | Zheng, Jianping, China Mobile | Rel-16 | 77 | New; 22.824 | zhengjianping@chinamobile.com | 39 |
| 88 | 61 | Study on Cellular IoT support and evolution for the 5G System |  | 266d? | 2017-09-08 A | 2018-09-14 | 50% | 133d? | 456d | finish no earlier than 2018-09-14 | S2 | 2128h | 1064h | FS_CIoT_5G | Sebastian Speicher | Rel-16 | 77 | New; 23.724 | sspeiche@qti.qualcomm.com | 39 |
| 89 | 62 | Study on evolution of Cellular IoT security for the 5G System |  | 202d? | 2018-06-06 A | 2019-03-14 | 5% | 191.9d? | 327d | finish no earlier than 2019-03-14 | S3 | 1616h | 80.8h | FS_CIoT_sec_5G | Noamen Ben Henda | Rel-16 |  | New | noamen.ben.henda@ericsson.com |  |
| 90 | 63 | Study on enhancement of URLLC supporting in 5GC |  | 197d? | 2018-03-15 A | 2018-12-14 | 15% | 167.45d? | 391d | finish no earlier than 2018-12-14 | S2 | 1576h | 236.4h | FS_5G_URLLC | Hui Ni, Huawei | Rel-16 | 79 | 23.xyz | Hui.ni@huawei.com |  |
| 91 | 64 | Study on EPC support for Mobility with Low Latency Communication |  | 196d? | 2017-12-15 A | 2018-09-14 | 75% | 49d? | 456d | finish no earlier than 2018-09-14 | S2 | 1568h | 1176h | FS_LLC_Mob | Chris PUDNEY | Rel-16 | 78 | new 23.739 | chris dot pudney at vodafone dot com |  |
| 92 | 65 | Study on enhancement of systems using EPS for Ultra Reliability and Availability using commodity equipment |  | 197d? | 2018-03-15 A | 2018-12-14 | 10% | 177.3d? | 391d | start no earlier than 2018-03-15 | S2 | 1576h | 157.6h | FS_EPS_URACE | Chris Pudney | Rel-16 | 79 | new | chris.pudney@vodafone.com |  |
| 93 | 66 | Release 16 Studies on 5G/5GS/5GC/NR | milestone | 0d? | 2016-06-09 A | 2016-06-09 A | 100% |  |  | finish no earlier than 2016-06-09 |  |  |  |  |  | Rel-16 |  |  |  |  |
| 94 | 67 | Study on system architecture for next generation real time communication services |  | 202d? | 2018-06-06 | 2019-03-14 |  |  | 327d | finish no earlier than 2019-03-14 | S2 | 1616h |  | FS_NG_RTC | Yi Jiang | Rel-16 |  | New | jiangyi at chinamobile dot com |  |
| 95 | 68 | Study on Security Aspects of the 5G Service Based Architecture |  | 73d? | 2018-06-06 A | 2018-09-14 | 65% | 25.55d? | 456d | finish no earlier than 2018-09-14 | S3 | 584h | 379.6h | FS_SBA_Sec | Hans Christian Rudolph, Deutsche Telekom AG | Rel-16 |  | New | hans-christian.rudolph@telekom.de |  |
| 96 | 69 | Study on Load and Overload Control of 5GC Service Based Interfaces |  | 268d? | 2018-06-06 | 2019-06-14 |  |  | 261d | finish no earlier than 2019-06-14 | C4 | 2144h |  | FS_5GS_SBILOLC-CT | Sridhar Bhaskaran (Huawei) | Rel-16 |  | New | sridhar.bhaskaran@huawei.com |  |
| 97 | 70 | Study on Network Controlled Interactive Service in 5GS |  | 202d? | 2018-06-06 | 2019-03-14 |  |  | 327d | finish no earlier than 2019-03-14 | S1 | 1616h |  | FS_NCIS | YANG Ning, Oppo | Rel-16 |  | New | yangning@oppo.com |  |
| 98 | 71 | Study on the Wireless and Wireline Convergence for the 5G system architecture |  | 269d? | 2017-06-05 A | 2018-06-14 | 35% | 174.85d? | 522d | finish no earlier than 2018-06-14 | S2 | 2152h | 753.2h | FS_5WWC | Marco Spini, Huawei Technologies | Rel-16 | 76 | 23.716 | m.spini@huawei.com | 39 |
| 99 | 72 | Study on the security of the Wireless and Wireline Convergence for the 5G system architecture |  | 202d? | 2018-06-06 | 2019-03-14 |  |  | 327d | finish no earlier than 2019-03-14 | S3 | 1616h |  | FS_5WWC_SEC | He Li, Huawei Technologies | Rel-16 |  | New | LIHE2@HUAWEI.COM |  |
| 100 | 73 | Study for single radio voice continuity from 5GS to 3G |  | 67d? | 2018-03-15 A | 2018-06-15 | 80% | 13.4d? | 521d | finish no earlier than 2018-06-15 | S2 | 536h | 428.8h | FS_5G-SRVCC | Chi Ren, China Unicom | Rel-16 | 79 |  | renchi1@chinaunicom.cn |  |
| 101 | 74 | Study on security aspects of single radio voice continuity from 5G to UTRAN |  | 262d? | 2018-03-15 A | 2019-03-15 | 50% | 131d? | 326d | finish no earlier than 2019-03-15 | S3 | 2096h | 1048h | FS_5G_UTRAN_SEC | Feng Gao, China Unicom | Rel-16 | 79 | 33.856 | gaofeng149@chinaunicom.cn |  |
| 102 | 75 | Study on Enhancements to the Service-Based 5G System Architecture |  | 197d? | 2018-03-15 A | 2018-12-14 | 15% | 167.45d? | 391d | finish no earlier than 2018-12-14 | S1 | 1576h | 236.4h | FS_eSBA | Tao Sun (China Mobile | Rel-16 | 79 | 23.xxx | suntao@chinamobile.com |  |
| 103 | 76 | Study on Enhanced IMS to 5GC Integration |  | 196d? | 2017-12-15 A | 2018-09-14 | 40% | 117.6d? | 456d | finish no earlier than 2018-09-14 | S2 | 1568h | 627.2h | FS_eIMS5G | Joul, Chris, T-Mobile USA | Rel-16 | 78 | new 23.794 | chris <dot> joul <at> t-mobile <dot> com |  |
| 104 | 77 | Study on Enhancement to the 5GC Location Services |  | 261d? | 2017-12-15 A | 2018-12-14 | 45% | 143.55d? | 391d | finish no earlier than 2018-12-14 | S2 | 2088h | 939.6h | FS_eLCS | Ming Ai, CATT | Rel-16 | 78 | new 23.731 | aiming@catt.cn |  |
| 105 | 78 | Study on supporting 256-bit algorithms for 5G |  | 196d? | 2017-12-15 A | 2018-09-14 | 55% | 88.2d? | 456d | finish no earlier than 2018-09-14 | S3 | 1568h | 862.4h | FS_256_Algo | Evans, Tim, Vodafone Group | Rel-16 | 78 | new | tim.evans1@vodafone.com |  |
| 106 | 79 | Study of enablers for Network Automation for 5G |  | 270d? | 2017-06-05 A | 2018-06-15 | 30% | 189d? | 521d | finish no earlier than 2018-06-15 | S2 | 2160h | 648h | FS_eNA | Xiaobo Wu, Huawei Technologies | Rel-16 | 76 | new | wuxiaobo@huawei.com | 39 |
| 107 | 80 | Study on Enhancing Topology of SMF and UPF in 5G Networks |  | 266d? | 2017-09-08 A | 2018-09-14 | 40% | 159.6d? | 456d | finish no earlier than 2018-09-14 | S2 | 2128h | 851.2h | FS_ETSUN | Laurent Thiebaut (Nokia) | Rel-16 | 77 | New; 23.726 | Laurent.thiebaut@nokia.com | 39 |
| 108 | 81 | Study on IETF QUIC Transport for Service Based Interfaces |  | 202d? | 2018-06-06 | 2019-03-14 |  |  | 327d | finish no earlier than 2019-03-14 | C4 | 1616h |  | FS_5GS_SBIQUIC-CT | Sridhar Bhaskaran (Huawei) | Rel-16 |  | New | sridhar.bhaskaran@huawei.com |  |
| 109 | 82 | Study on User Plane Protocol in 5GC |  | 195d? | 2017-12-15 A | 2018-09-13 | 5% | 185.25d? | 457d | finish no earlier than 2018-09-13 | C4 | 1560h | 78h | FS_UPPS | Satoru Matsushima, SoftBank Corp | Rel-16 | 78 |  | satoru.matsushima@g.softbank.co.jp |  |
| 110 | 83 | Study on Access Traffic Steering, Switch and Splitting support in the 5G system architecture |  | 334d? | 2017-06-05 A | 2018-09-13 | 40% | 200.4d? | 457d | start no earlier than 2017-06-05 | S2 | 2672h | 1068.8h | FS_ATSSS | So, Tricci, ZTE | Rel-16 | 76 | new 23.793 | tso@ztetx.com | 39 |
| 111 | 84 | Study on Application Awareness Interworking between LTE and NR |  | 261d? | 2018-03-15 A | 2019-03-14 | 30% | 182.7d? | 327d | finish no earlier than 2019-03-14 | S2 | 2088h | 626.4h | FS_AAI_LTE_NR | Biao Long, China Telecom | Rel-16 | 79 | new | longb.gd@chinatelecom.cn |  |
| 112 | 85 | Release 16 other Studies | milestone | 0d? | 2016-06-09 A | 2016-06-09 A | 100% |  |  | finish no earlier than 2016-06-09 |  |  |  |  |  | Rel-16 |  |  |  |  |
| 113 | 86 | Study on Audio-Visual Service Production |  | 202d? | 2018-06-06 | 2019-03-14 |  |  | 327d | finish no earlier than 2019-03-14 | S1 | 1616h |  | FS_AVPROD | Roland Beutler, EBU | Rel-16 |  | New | Roland.Beutler@swr.de |  |
| 114 | 87 | Study on optimisations on UE radio capability signalling |  | 138d? | 2018-06-06 | 2018-12-14 |  |  | 391d | finish no earlier than 2018-12-14 | S2 | 1104h |  | FS_RACS | Haris Zisimopoulos, Qualcomm Incorporated | Rel-16 |  | New | harisz@qti.qualcomm.com |  |
| 115 | 88 | Study on supporting Flexible Local Area Data Network |  | 138d? | 2018-06-06 | 2018-12-14 |  |  | 391d | finish no earlier than 2018-12-14 | S2 | 1104h |  | FS_FLADN | LG Electronics, | Rel-16 |  | New | hyuns.kim@lge.com |  |
| 116 | 89 | Study on authentication and key management for applications based on 3GPP credential in 5G |  | 202d? | 2018-06-06 A | 2019-03-14 | 5% | 191.9d? | 327d | finish no earlier than 2019-03-14 | S3 | 1616h | 80.8h | FS_AKMA | Jin Peng, China Mobile | Rel-16 |  | New | pengjin@chinamobile.com |  |
| 117 | 90 | Study on enhancements to IMS for new real time communication services |  | 71d? | 2017-09-08 A | 2017-12-15 A | 100% |  |  | start no earlier than 2017-09-08 | S1 | 568h | 568h | FS_enIMS | China Mobile, Hui Cai | Rel-16 | 77 | New; 22.823 | caihui at chinamobile dot com | 39 |
| 118 | 91 | Study on protocol enhancement for real time communication |  | 202d? | 2018-06-06 | 2019-03-14 |  |  | 327d | finish no earlier than 2019-03-14 | S5 | 1616h |  | FS_PROTIMP | Olaf Pollakowski, Nokia | Rel-16 |  | New | olaf.pollakowski@nokia.com |  |
| 119 | 92 | Study on integration of ONAP and 3GPP configuration management services for 5G networks |  | 202d? | 2018-06-06 | 2019-03-14 |  |  | 327d | finish no earlier than 2019-03-14 | S5 | 1616h |  | FS_ONAPCINT | Li Gang, Ericsson | Rel-16 |  | New | gang.g.li@ericsson.com |  |
| 120 | 93 | Study on management aspects of edge computing |  | 202d? | 2018-06-06 | 2019-03-14 |  |  | 327d | finish no earlier than 2019-03-14 | S5 | 1616h |  | FS_MAN_EC | Joey Chou, Intel | Rel-16 |  | New | joey<dot>chou<at>intel<dot>com |  |
| 121 | 94 | Study on Enhancement of Network Slicing |  | 197d? | 2018-03-15 A | 2018-12-14 | 10% | 177.3d? | 391d | start no earlier than 2018-03-15 | S2 | 1576h | 157.6h | FS_eNS | ZTE, Tricci So | Rel-16 | 79 | new | tso at ztetx dot com |  |
| 122 | 95 | Study on Business Role Models for Network Slicing |  | 266d? | 2017-09-08 A | 2018-09-14 | 75% | 66.5d? | 456d | start no earlier than 2017-09-08 | S1 | 2128h | 1596h | FS_BMNS | Covell, Betsy, Nokia | Rel-16 | 77 | New; 22.830 | betsy.covell@nokia.com | 39 |
| 123 | 96 | Study on Multimedia Priority Service (MPS) Phase 2 |  | 325d? | 2017-12-15 A | 2019-03-14 | 30% | 227.5d? | 327d | finish no earlier than 2019-03-14 | S1 | 2600h | 780h | FS_MPS2 | Singh, Ray P; Vencore Labs | Rel-16 | 78 | 22.854 | rsingh@vencorelabs.com |  |
| 124 | 97 | Study on integration of ONAP DCAE and 3GPP management architecture |  | 326d? | 2017-12-15 A | 2019-03-15 | 20% | 260.8d? | 326d | finish no earlier than 2019-03-15 | S5 | 2608h | 521.6h | FS_ONAPDCAE | ORANGE (Jean-Michel Cornily | Rel-16 | 78 | 28.900 | jeanmichel.cornily@orange.com |  |
| 125 | 98 | Study on encrypted traffic detection and verification |  | 334d? | 2017-06-05 A | 2018-09-13 | 70% | 100.2d? | 457d | finish no earlier than 2018-09-13 | S2 | 2672h | 1870.4h | FS_ENTRADE | Chi Ren, China Unicom | Rel-16 | 76 | new 23.787 | renchi1@chinaunicom.cn | 39 |
| 126 | 99 | Study on Media Handling Aspects of RAN Delay Budget Reporting in MTSI |  | 196d? | 2017-12-15 A | 2018-09-14 | 60% | 78.4d? | 456d | finish no earlier than 2018-09-14 | S4 | 1568h | 940.8h | FS_E2E_DELAY | Oyman, Ozgur, Company: Intel, | Rel-16 | 78 | new | ozgur.oyman@intel.com |  |
| 127 | 100 | Release 15 Features | milestone | 0d? | 2016-03-15 A | 2016-03-15 A | 100% |  |  | finish no earlier than 2016-03-15 |  |  |  |  |  | Rel-15 |  |  |  |  |
| 128 | 101 | Release 15 Features on 5G | milestone | 0d? | 2016-06-09 A | 2016-06-09 A | 100% |  |  | finish no earlier than 2016-06-09 |  |  |  |  |  | Rel-15 |  |  |  |  |

Notes:
- 78: new LTE TDD band for 2483.5 to 2495MHz; compare band 41: 2,496-2,69GHz introduced by WI LTE_TDD_2600_US
- 79: new LTE TDD band for 2483.5 to 2495MHz; compare band 41: 2,496-2,69GHz introduced by WI LTE_TDD_2600_US
- 80: new LTE TDD band for 2483.5 to 2495MHz; compare band 41: 2,496-2,69GHz introduced by WI LTE_TDD_2600_US
- 82: 7/6/18: 0%->60
- 85: -
- 86: -
- 87: 15/12/17: 22.824 added;; 15/12/17: 0%->25; 16/3/18: 25%->60
- 88: 11/09/17: rapporteur change; 15/12/17: 23.724 added;; 16/3/18: 0%->20; 7/6/18: 20%->50
- 90: 7/6/18: 0%->15
- 91: 16/3/18: 0%->35; 7/6/18: 35%->75
- 92: 7/6/18: 0%->10
- 93: -
- 98: 11/9/17: 0%->15; 15/12/17: Changed Rel-15->Rel-16; 16/3/18: 15%->25; 7/6/18: 25%->35
- 100: 7/6/18: 0%->80
- 101: 27/3/18: 33.856 added;; 7/6/18: 0%->50
- 102: 7/6/18: 0%->15
- 103: 16/3/18: 0%->20; 7/6/18: 20%->40
- 104: 16/3/18: 0%->15; 7/6/18: 15%->45
- 105: 16/3/18: 0%->30; 7/6/18: 30%->55
- 106: 16/3/18: FCD:09/18->06/18; 16/3/18: 0%->15; 7/6/18: 15%->30
- 107: 15/12/17: 23.726 added;; 16/3/18: 0%->25; 7/6/18: 25%->40
- 109: 16/3/18: 0%->5
- 110: 11/9/17: 0%->100; 14/9/17: 100%->10; 15/12/17: Changed Rel-15->Rel-16; 16/3/18: 10%->20; 7/6/18: 20%->40
- 111: 7/6/18: 0%->30
- 112: -
- 117: 11/9/17: 0%->20; 15/12/17: 22.823 added;; 15/12/17: 20%->75; 16/3/18: 75%->100
- 121: 7/6/18: 0%->10
- 122: 15/12/17: 22.830 added;; 15/12/17: 0%->10; 15/3/18: WID:SP-170705->SP-180169; 16/3/18: 10%->50; 7/6/18: 50%->75
- 123: 16/3/18: 0%->10; 7/6/18: 10%->30
- 124: 16/3/18: 0%->10; 27/3/18: 28.900 added;; 7/6/18: 10%->20; 7/6/18: FCD:09/18->03/19
- 125: ; 15/12/17: Changed Rel-15->Rel-16; 16/3/18: WID:SP-170381->SP-170934; 16/3/18: 0%->20; 7/6/18: 20%->70
- 126: 16/3/18: 0%->10; 7/6/18: 10%->60
- 127: -
- 128: -

| ID | WBS | Task | Duration | Start | Finish | Complete | Remaining | Total slack | Constraint | Resources | Work | Actual work | Acronym | PCG approved | WI rapporteur name | WI rapporteur e-mail | Release | TSG approved |
| --- | --- | --- | --- | --- | --- | --- | --- | --- | --- | --- | --- | --- | --- | --- | --- | --- | --- | --- |
| 129 | 102 | **5G System - Phase 1** | 788d? | 2016-06-09 A | 2019-06-14 | 90% | 80.76d? | 261d |  |  | 48912h | 41675.4h | 5GS_Ph1 | 38 | China Mobile, Tao Sun | suntao@chinamobile.com | Rel-15 | 74 |
| 130 | 102.1 | Study on Charging Aspects of 5G System Architecture Phase 1 | 206d? | 2017-03-03 A | 2017-12-15 A | 100% |  |  | finish no earlier than 2017-12-15 | S5 | 1648h | 1648h | FS_5GS_Ph1_CH | 38 | Chen, Shan, Huawei | chenshan@huawei.com | Rel-15 | 75 |
| 131 | 102.2 | (Stage 1 of 5G) New Services and Markets Technology Enablers | 201d? | 2016-06-09 A | 2017-03-15 A | 100% |  |  | finish no earlier than 2017-03-15 | S1 | 1608h | 1608h | SMARTER | 37 | Li, Alice | alice.li@vodafone.com | Rel-15 | 72 |
| 132 | 102.3 | Stage 2 of 5G System - Phase 1 | 271d? | 2016-12-01 A | 2017-12-14 | 95% | 13.55d? | 652d | finish no earlier than 2017-12-14 | S2 | 2168h | 2059.6h | 5GS_Ph1 | 38 | China Mobile, Tao Sun | suntao@chinamobile.com | Rel-15 | 74 |
| 133 | 102.4 | Security aspects of 5G System - Phase 1 | 337d? | 2017-03-02 A | 2018-06-15 | 95% | 16.85d? | 521d | finish no earlier than 2018-06-15 | S3 | 2696h | 2561.2h | 5GS_Ph1-SEC | 38 | NTT DOCOMO, Alf Zugenmaier | alf.zugenmaier@hm.edu | Rel-15 | 75 |
| 134 | 102.5 | **CT aspects of 5G System - Phase 1** | 335d? | 2017-03-03 A | 2018-06-14 | 99% | 4.54d? | 522d |  | ct | 28960h | 25982.1h | 5GS_Ph1-CT | 38 | Song Yue (China Mobile) | songyue at chinamobile.com | Rel-15 | 75 |
| 135 | 102.5.1 | **Studies on CT1 aspects of 5G System - Phase 1** | 205d? | 2017-03-03 A | 2017-12-14 A | 100% |  |  |  |  | 11480h | 11480h | 5GS_Ph1-CT | 38 | Herrero Veron, Christian (Huawei) | Christian.Herrero at huawei.com | Rel-15 | 75 |
| 136 | 102.5.1.1 | Study on 5G Network selection | 205d? | 2017-03-03 A | 2017-12-14 A | 100% |  |  | finish no earlier than 2017-12-14 | C1 | 1640h | 1640h | 5GS_Ph1-CT | 39 | Herrero Veron, Christian (Huawei) | Christian.Herrero at huawei.com | Rel-15 | 77 |
| 137 | 102.5.1.2 | Study on 5G Mobility management | 205d? | 2017-03-03 A | 2017-12-14 A | 100% |  |  | finish no earlier than 2017-12-14 | C1 | 1640h | 1640h | 5GS_Ph1-CT | 39 | Herrero Veron, Christian (Huawei) | Christian.Herrero at huawei.com | Rel-15 | 77 |
| 138 | 102.5.1.3 | Study on 5G Session management | 205d? | 2017-03-03 A | 2017-12-14 A | 100% |  |  | finish no earlier than 2017-12-14 | C1 | 1640h | 1640h | 5GS_Ph1-CT | 39 | Herrero Veron, Christian (Huawei) | Christian.Herrero at huawei.com | Rel-15 | 77 |
| 139 | 102.5.1.4 | Study on 5G Non-3GPP access networks | 205d? | 2017-03-03 A | 2017-12-14 A | 100% |  |  | finish no earlier than 2017-12-14 | C1 | 1640h | 1640h | 5GS_Ph1-CT | 39 | Herrero Veron, Christian (Huawei) | Christian.Herrero at huawei.com | Rel-15 | 77 |
| 140 | 102.5.1.5 | Study on 5G Interworking with EPC | 205d? | 2017-03-03 A | 2017-12-14 A | 100% |  |  | finish no earlier than 2017-12-14 | C1 | 1640h | 1640h | 5GS_Ph1-CT | 39 | Herrero Veron, Christian (Huawei) | Christian.Herrero at huawei.com | Rel-15 | 77 |
| 141 | 102.5.1.6 | Study on 5G System core network impact on services, network functions and capabilities | 205d? | 2017-03-03 A | 2017-12-14 A | 100% |  |  | finish no earlier than 2017-12-14 | C1 | 1640h | 1640h | 5GS_Ph1-CT | 39 | Herrero Veron, Christian (Huawei) | Christian.Herrero at huawei.com | Rel-15 | 77 |
| 142 | 102.5.1.7 | Study on 5G Network slicing | 205d? | 2017-03-03 A | 2017-12-14 A | 100% |  |  | finish no earlier than 2017-12-14 | C1 | 1640h | 1640h | 5GS_Ph1-CT | 39 | Herrero Veron, Christian (Huawei) | Christian.Herrero at huawei.com | Rel-15 | 77 |
| 143 | 102.5.2 | **CT1 aspects of 5G System - Phase 1 (normative work)** | 130d? | 2017-12-15 A | 2018-06-14 | 97% | 3.71d? | 522d |  | C1 | 8320h | 8082.28h | 5GS_Ph1-CT | 38 | Herrero Veron, Christian (Huawei) | Christian.Herrero at huawei.com | Rel-15 | 75 |
| 144 | 102.5.2.1 | 5G Network selection | 130d? | 2017-12-15 A | 2018-06-14 A | 100% |  |  | finish no earlier than 2018-06-14 | C1 | 1040h | 1040h | 5GS_Ph1-CT | 39 | Herrero Veron, Christian (Huawei) | Christian.Herrero at huawei.com | Rel-15 | 77 |
| 145 | 102.5.2.2 | 5G Mobility management | 130d? | 2017-12-15 A | 2018-06-14 | 95% | 6.5d? | 522d | start no earlier than 2017-12-15 | C1 | 1040h | 988h | 5GS_Ph1-CT | 39 | Herrero Veron, Christian (Huawei) | Christian.Herrero at huawei.com | Rel-15 | 77 |
| 146 | 102.5.2.3 | 5G Session management | 130d? | 2017-12-15 A | 2018-06-14 A | 100% |  |  | start no earlier than 2017-12-15 | C1 | 1040h | 1040h | 5GS_Ph1-CT | 39 | Herrero Veron, Christian (Huawei) | Christian.Herrero at huawei.com | Rel-15 | 77 |
| 147 | 102.5.2.4 | 5G Non-3GPP access networks | 130d? | 2017-12-15 A | 2018-06-14 | 95% | 6.5d? | 522d | start no earlier than 2017-12-15 | C1 | 1040h | 988h | 5GS_Ph1-CT | 39 | Herrero Veron, Christian (Huawei) | Christian.Herrero at huawei.com | Rel-15 | 77 |
| 148 | 102.5.2.5 | 5G Interworking with EPC | 130d? | 2017-12-15 A | 2018-06-14 A | 100% |  |  | start no earlier than 2017-12-15 | C1 | 1040h | 1040h | 5GS_Ph1-CT | 39 | Herrero Veron, Christian (Huawei) | Christian.Herrero at huawei.com | Rel-15 | 77 |
| 149 | 102.5.2.6 | 5G System core network impact on services, network functions and capabilities | 130d? | 2017-12-15 A | 2018-06-14 | 90% | 13d? | 522d | start no earlier than 2017-12-15 | C1 | 1040h | 936h | 5GS_Ph1-CT | 39 | Herrero Veron, Christian (Huawei) | Christian.Herrero at huawei.com | Rel-15 | 77 |
| 150 | 102.5.2.7 | 5G Network slicing | 130d? | 2017-12-15 A | 2018-06-14 A | 100% |  |  | start no earlier than 2017-12-15 | C1 | 1040h | 1040h | 5GS_Ph1-CT | 39 | Herrero Veron, Christian (Huawei) | Christian.Herrero at huawei.com | Rel-15 | 77 |
| 151 | 102.5.3 | Study on CT3 aspects of 5G System - Phase 1 | 205d? | 2017-03-03 A | 2017-12-14 A | 100% |  |  | finish no earlier than 2017-12-14 | C3 | 1640h | 1640h | 5GS_Ph1-CT | 38 | Fernandez, Susana (Ericsson) | Susana.Fernandez at ericsson.com | Rel-15 | 75 |
| 152 | 102.5.4 | CT3 aspects of 5G System - Phase 1 | 130d? | 2017-12-15 A | 2018-06-14 A | 100% |  |  | start no earlier than 2017-12-15 | C3 | 1040h | 1040h | 5GS_Ph1-CT | 38 | Fernandez, Susana (Ericsson) | Susana.Fernandez at ericsson.com | Rel-15 | 75 |
| 153 | 102.5.5 | CT4 aspects of 5G System - Phase 1 | 205d? | 2017-03-03 A | 2017-12-14 | 95% | 10.25d? | 652d | finish no earlier than 2017-12-14 | C4 | 1640h | 1558h | 5GS_Ph1-CT | 38 | Landais, Bruno (Nokia) | Bruno.Landais at nokia.com | Rel-15 | 75 |
| 154 | 102.5.6 | Study on CT6 aspects of 5G System - Phase 1 | 205d? | 2017-03-03 A | 2017-12-14 A | 100% |  |  | finish no earlier than 2017-12-14 | C6 | 1640h | 1640h | 5GS_Ph1-CT | 38 | Amandeep Virk from Qualcomm |  | Rel-15 | 75 |
| 155 | 102.5.7 | CT6 aspects of 5G System - Phase 1 | 65d? | 2018-03-16 A | 2018-06-14 | 90% | 6.5d? | 522d | finish no earlier than 2018-06-14 | C6 | 520h | 468h | 5GS_Ph1-CT | 38 | Landais, Bruno (Nokia) | Bruno.Landais at nokia.com | Rel-15 | 75 |

Notes:
- 129: 15/12/17: 23.503 added;
- 130: 7/6/17: 0%->15; 11/9/17: 15%->60; 11/9/17: WID:SP-170128->SP-170659; 15/12/17: 60%->100; 21/12/17: WID:SP-170659->SP-170953
- 131: Resulting from FS_SMARTER; 19/9/16: 0%->55; 6/10/16: 22.261 added; 1/12/16: FCD:09/16->03/20; 1/12/16: 55%->75; 2/3/17: 75%->90; 7/6/17: 90%->100 / Impacted TSs and TRs: 22.261
- 132: 3/3/17: 0%->30; 7/6/17: 30%->55; 11/9/17: 55%->75; 21/12/17: 75%->95 / Impacted TSs and TRs: 23.401, 23.167, 23.271, 23.002; 23.228, 23.401, 23.167, 23.271, 23.502, 23.501; 23.503
- 133: 7/6/17: 0%->10; 11/9/17: 10%->30; 15/12/17: 30%->65; 21/12/17: WID:SP-170234->SP-170881; 16/3/18: 65%->85; 16/3/18: FCD:03/18->06/18; 7/6/18: 85%->95 / Impacted TSs and TRs: 33.501
- 134: 6/17: WID:CP-170204->CP-171105; 9/17: WID:CP-171105->CP-172034. Rapp changed, impacted TS clarified; 12/17: added: 24.501 ; 24.502 ; 29.520 added; 29.514; 29.513 ; 29.520a; 29.514a; 12/17: 29.519 added; 29.516 added;; : 2.....; 3/18: 29.554 added;29.59...; 7/6/18: WID:CP-180152->CP-181081 / Impacted TSs and TRs: 24.501; 24.502; 29.520; 29.514; 29.513; ; 29.520a; 29.514a; 29.519; 29.516; 29.512; 29.508; 29.507; 29.551; 29.554; 29.522; 24.568
- 135: 18/12/17: WID:CP-172034->CP-173161 / Impacted TSs and TRs: 23.122; 23.040; 23.041; 24.007; 24.301; 24.008; 24.302; 24.011; 24.312; 24.305; 24.368; 27.007
- 136: Task introduced as per CT1's chair e-mail; 11/9/17: 10%->55; 15/12/17: 55%->80; 16/3/18: 80%->100
- 137: Task introduced as per CT1's chair e-mail; 11/9/17: 40%->70; 15/12/17: 70%->100
- 138: Task introduced as per CT1's chair e-mail; 11/9/17: 35%->75; 15/12/17: 75%->100
- 139: Task introduced as per CT1's chair e-mail; 11/9/17: 15%->55; 15/12/17: 55%->100
- 140: Task introduced as per CT1's chair e-mail; 11/9/17: 15%->45; 15/12/17: 45%->100
- 141: Task introduced as per CT1's chair e-mail; 11/9/17: 20%->65; 15/12/17: 65%->85; 16/3/18: 85%->100
- 142: Task introduced as per CT1's chair e-mail; 11/9/17: 10%->45; 15/12/17: 45%->100
- 143: Impacted TSs and TRs: 23.122; 23.040; 23.041; 24.007; 24.301; 24.008; 24.302; 24.011; 24.312; 24.305; 24.368; 27.007
- 144: 16/3/18: 0%->60; 7/6/18: 60%->100
- 145: 15/12/17: 0%->25; 16/3/18: 25%->70; 7/6/18: 70%->95
- 146: 15/12/17: 0%->35; 16/3/18: 35%->85; 7/6/18: 85%->100
- 147: 15/12/17: 0%->20; 16/3/18: 20%->60; 7/6/18: 60%->95
- 148: 15/12/17: 0%->20; 16/3/18: 20%->60; 7/6/18: 60%->100
- 149: 15/12/17: 0%->10; 16/3/18: 10%->70; 7/6/18: 70%->90
- 150: 15/12/17: 0%->10; 16/3/18: 10%->60; 7/6/18: 60%->100
- 151: 5/6/17: 0%->20; 15/12/17: 20%->95; 22/3/18: 95%->100 / Impacted TSs and TRs: 29.213; 29.214; 29.219; 29.122
- 152: 5/6/17: 0%->20; 15/12/17: 20%->95; 7/6/18: 35%->70; 7/6/18: 70%->100 / Impacted TSs and TRs: 29.213; 29.214; 29.219; 29.122
- 153: 5/6/17: 0%->5; 11/9/17: 5%->25; 15/12/17: 25%->45; 16/3/18: 45%->50; 7/6/18: 50%->95 / Impacted TSs and TRs: 23.003; 23.008; 23.380; 29.281; 29.272; 29.274; 29.303
- 154: 5/6/17: 0%->10; 11/9/17: 10%->60; 15/12/17: 60%->85; 22/3/18: 85%->95; 7/6/18: 95%->100
- 155: 5/6/17: 0%->5; 11/9/17: 5%->25; 15/12/17: 25%->45; 16/3/18: 45%->50; 16/3/18: 0%->20; 7/6/18: 20%->90 / Impacted TSs and TRs: 23.003; 23.008; 23.380; 29.281; 29.272; 29.274; 29.303

| ID | WBS | Task | Type | Duration | Start | Finish | Complete | Remaining | Total slack | Constraint | Resources | Work | Actual work | Acronym | PCG approved | WI rapporteur name | WI rapporteur e-mail | Release | TSG approved |
| --- | --- | --- | --- | --- | --- | --- | --- | --- | --- | --- | --- | --- | --- | --- | --- | --- | --- | --- | --- |
| 156 | 102.6 | **IMS impact due to 5GS IP-CAN** |  | 205d? | 2017-09-04 A | 2018-06-15 | 92% | 17.08d? | 521d |  | ct | 6560h | 6013.33h | 5GS_Ph1-IMSo5G | 39 | Song Yue (China Mobile) | songyue (at) chinamobile (dot) com | Rel-15 | 76 |
| 157 | 102.6.1 | CT1 aspects of IMSo5G |  | 205d? | 2017-09-04 A | 2018-06-15 | 95% | 10.25d? | 521d | finish no earlier than 2018-06-15 | C1 | 1640h | 1558h | 5GS_Ph1-IMSo5G | 39 | Song Yue, China Mobile | songyue@chinamobile.com | Rel-15 | 77 |
| 158 | 102.6.2 | CT3 aspects of IMSo5G |  | 205d? | 2017-09-04 A | 2018-06-15 | 80% | 41d? | 521d | finish no earlier than 2018-06-15 | C3 | 1640h | 1312h | 5GS_Ph1-IMSo5G | 39 | Herrero Veron, Christian (Huawei) | Christian.Herrero at huawei.com | Rel-15 | 77 |
| 159 | 102.6.3 | CT4 aspects of IMSo5G |  | 205d? | 2017-09-04 A | 2018-06-15 A | 100% |  |  | finish no earlier than 2018-06-15 | C4 | 1640h | 1640h | 5GS_Ph1-IMSo5G | 39 | Herrero Veron, Christian (Huawei) | Christian.Herrero at huawei.com | Rel-15 | 77 |
| 160 | 102.7 | Service Based Interface for 5G Charging |  | 196d? | 2017-12-15 A | 2018-09-14 | 55% | 88.2d? | 456d | finish no earlier than 2018-09-14 | S5 | 1568h | 862.4h | 5GS_Ph1-SBI_CH |  | Chen, Shan, Huawei | chenshan@huawei.com | Rel-15 | 78 |
| 161 | 102.8 | Data Charging in 5G System Architecture Phase 1 |  | 196d? | 2017-12-15 A | 2018-09-14 | 60% | 78.4d? | 456d | finish no earlier than 2018-09-14 | S5 | 1568h | 940.8h | 5GS_Ph1-DCH |  | Gardella, Maryse, Nokia | maryse.gardella@nokia.com | Rel-15 | 78 |
| 162 | 102.9 | UE Conformance Test Aspects - CT6 aspects of 5G System |  | 267d? | 2018-06-07 | 2019-06-14 |  |  | 261d | finish no earlier than 2019-06-14 | C6 | 2136h |  | 5GS_Ph1_UEConTest |  | Azem, Dania (COMPRION GmbH) | DAzem@comprion.com | Rel-15 |  |
| 163 | 103 | **EPC enhancements to support 5G New Radio via Dual Connectivity** |  | 271d? | 2017-03-02 A | 2018-03-15 A | 100% |  |  |  |  | 8336h | 8336h | EDCE5 | 38 | Chris Pudney, Vodafone Group | Chris Pudney, Vodafone Group | Rel-15 | 75 |
| 164 | 103.1 | SA2 aspects of EDCE5 |  | 141d? | 2017-03-02 A | 2017-09-14 A | 100% |  |  | finish no earlier than 2017-09-14 | S2 | 1128h | 1128h | EDCE5 | 38 | Chris Pudney, Vodafone Group |  | Rel-15 | 75 |
| 165 | 103.2 | SA3 aspects of EDCE5 |  | 141d? | 2017-03-02 A | 2017-09-14 A | 100% |  |  | finish no earlier than 2017-09-14 | S3 | 1128h | 1128h | EDCE5 | 38 | Adrian Escott, Qualcomm Incorporated |  | Rel-15 | 75 |
| 166 | 103.3 | **CT aspects of EDCE5** |  | 139d? | 2017-06-05 A | 2017-12-14 A | 100% |  |  |  | ct | 4448h | 4448h | EDCE5-CT | 39 | Jesús de Gregorio, Ericsson | jesus.de.gregorio@ericsson.com | Rel-15 | 76 |
| 167 | 103.3.1 | CT1 aspects of EDCE5 |  | 139d? | 2017-06-05 A | 2017-12-14 A | 100% |  |  | finish no earlier than 2017-12-14 | C1 | 1112h | 1112h | EDCE5-CT | 39 | Jesús de Gregorio, Ericsson | jesus.de.gregorio@ericsson.com | Rel-15 | 76 |
| 168 | 103.3.2 | CT3 aspects of EDCE5 |  | 139d? | 2017-06-05 A | 2017-12-14 A | 100% |  |  | finish no earlier than 2017-12-14 | C3 | 1112h | 1112h | EDCE5-CT | 39 | Jesús de Gregorio, Ericsson | jesus.de.gregorio@ericsson.com | Rel-15 | 76 |
| 169 | 103.3.3 | CT4 aspects of EDCE5 |  | 139d? | 2017-06-05 A | 2017-12-14 A | 100% |  |  | finish no earlier than 2017-12-14 | C4 | 1112h | 1112h | EDCE5-CT | 39 | Jesús de Gregorio, Ericsson | jesus.de.gregorio@ericsson.com | Rel-15 | 76 |
| 170 | 103.4 | Charging aspects of EDCE5: PS Charging enhancements to support 5G New Radio via Dual Connectivity |  | 204d? | 2017-06-05 A | 2018-03-15 A | 100% |  |  | finish no earlier than 2018-03-15 | S5 | 1632h | 1632h | EDCE5-CH | 39 | Törnkvist, Robert, Ericsson | robert.tornkvist(at)ericsson.com | Rel-15 | 76 |
| 171 | 104 | **New Radio Access Technology** |  | 458d? | 2017-03-15 A | 2018-12-15 | 35% | 295.54d? | 391d |  | R1 | 9952h | 3530.04h | NR_newRAT | 38 | NTT DOCOMO |  | Rel-15 | 75 |
| 172 | 104.1 | Core part: New Radio Access Technology |  | 328d? | 2017-03-15 A | 2018-06-15 | 85% | 49.2d? | 521d | finish no earlier than 2018-06-15 | R1 | 2624h | 2230.4h | NR_newRAT-Core | 38 | NTT DOCOMO |  | Rel-15 | 75 |
| 173 | 104.2 | Perf. part: New Radio Access Technology |  | 458d? | 2017-03-15 | 2018-12-15 |  |  | 391d | finish no earlier than 2018-12-15 | R4 | 3664h |  | NR_newRAT-Perf | 38 | NTT DOCOMO |  | Rel-15 | 75 |
| 174 | 105 | **LTE connectivity to 5G-CN** |  | 328d? | 2017-03-15 A | 2018-06-15 | 30% | 229.6d? | 521d |  | R2 | 5248h | 1574.42h | LTE_5GCN_connect | 38 | Huawei |  | Rel-15 | 75 |
| 175 | 105.1 | Core part: LTE connectivity to 5G-CN |  | 328d? | 2017-03-15 A | 2018-06-15 | 30% | 229.6d? | 521d | finish no earlier than 2018-06-15 | R2 | 2624h | 787.2h | LTE_5GCN_connect-Core | 38 | Huawei |  | Rel-15 | 75 |
| 176 | 106 | UE Conformance Test Aspects - 5G system with NR and LTE |  | 392d? | 2017-06-15 A | 2018-12-15 | 10% | 352.8d? | 391d | finish no earlier than 2018-12-15 | R5 | 3136h | 313.6h | 5GS_NR_LTE-UEConTest | 39 | Ericsson |  | Rel-15 | 76 |
| 177 | 107 | Release 15 Features on V2X | milestone | 0d? | 2016-06-09 A | 2016-06-09 A | 100% |  |  | finish no earlier than 2016-06-09 |  |  |  |  |  |  |  | Rel-15 |  |
| 178 | 108 | **Enhancement of 3GPP support for V2X scenarios** |  | 206d? | 2016-06-09 A | 2017-03-22 A | 100% |  |  |  |  | 1520h | 1520h | eV2X | 38 | Chun, SungDuck, LG Electronics | sungduck.chun@lge.com | Rel-15 | 75 |
| 179 | 108.1 | Study on Enhancement of 3GPP support for V2X services |  | 137d? | 2016-06-09 A | 2016-12-15 A | 100% |  |  | finish no earlier than 2016-12-15 | S1 | 1096h | 1096h | FS_eV2X | 37 | LG Electronics, SungDuck Chun | sungduck.chun@lge.com | Rel-15 | 72 |
| 180 | 108.2 | Stage 1 of Enhancement of 3GPP support for V2X scenarios |  | 53d? | 2017-01-09 A | 2017-03-22 A | 100% |  |  | finish no earlier than 2017-03-22 | S1 | 424h | 424h | eV2X | 38 | Chun, SungDuck, LG Electronics | sungduck.chun@lge.com | Rel-15 | 75 |

Notes:
- 156: 8/9/17: WID:CP-171103->CP-172033; FCD: 12/17->06/18; 19/3/18: WID:CP-172033->CP-180094
- 157: 14/9/17: 0%->10; 15/12/17: 10%->65; rapporteur changed; 20/3/18: 65%->75; 7/6/18: 75%->95 / Impacted TSs and TRs: 24.229; 24.167
- 158: 7/6/18: 0%->80 / Impacted TSs and TRs: 29.213; 29.214
- 159: 7/6/18: 0%->100 / Impacted TSs and TRs: 23.008; 29.228; 29.229; 29.328; 29.329; 23.003
- 160: 16/3/18: 0%->15; 7/6/18: 15%->55; 7/6/18: FCD:06/18->09/18 / Impacted TSs and TRs: TS 32.240; TS 32.298
- 161: 16/3/18: 0%->10; 7/6/18: 10%->60; 7/6/18: FCD:06/18->09/18 / Impacted TSs and TRs: TS 32.240
- 162: Impacted TSs and TRs: 31.121 ; 31.124
- 163: 9/6/17: WID:SP-170058->SP-170583
- 164: 7/6/17: 0%->55; 11/9/17: 55%->90; 15/12/17: 90%->100
- 165: 7/6/17: 0%->60; 11/9/17: 60%->70; 15/12/17: 70%->100
- 166: 18/12/17: WID:CP-171045->CP-173038
- 167: 14/9/17: 0%->65; 15/12/17: 65%->100 / Impacted TSs and TRs: 24.301; 27.007
- 168: Impacted TSs and TRs: 29.212; 29.213; 29.214; 29.215; 29.201
- 169: 11/9/17: 0%->50; 15/12/17: 50%->100 / Impacted TSs and TRs: 23.008; 29.272; 29.230; 29.002; 29.305; 29.274
- 170: 15/12/17: 0%->20; 16/3/18: 20%->100 / Impacted TSs and TRs: 32.251; 32.298; 32.299
- 171: follow-up WI of REL-14 SI FS_NR_newRAT completed at RAN #75; 30/6/17: 38.425 added;; 14/9/17: WID:RP-170855->RP-171485; 15/12/17: added: 38.305; 38.113; 37.863-04-01; 37.863-03-01; 37.863-02-01; 38.820-04-01; 38.820-03-01; 38.820-02-01; 15/12/17: 37.32...; 27/3/18: 37.872 added; / Impacted TSs and TRs: 38.425; 38.424; 38.423; 38.422; 38.421; 38.420; 38.305; 38.113; 37.863-04-01; 37.863-03-01; 37.863-02-01; 38.820-04-01; 38.820-03-01; 38.820-02-01; 37.324; 37.872
- 172: follow-up WI of REL-14 SI FS_NR_newRAT; 19/6/17: Compl:0%->22%19/6/17: WID: RP-170855->RP-171485; 30/6/17 & 12/6/17: impacted specs added19/9/17: Compl:22%->50%19/9/17: WID: RP-171485->RP-172115; 15/12/17: added: 38.818; 37.865-01-01; 37.834-01-01; 37....27/3/18: Compl:70%->85%27/3/18: WID: RP-172834->RP-180536 / Impacted TSs and TRs: 37.340;37.834-01-01;37.863-05-01;37.864-41-21;37.865-01-01;38.101;38.104;38.12?;38.201/2;38.211/2;38.213to215;38.300;38.304to307;38.321to323;38.331;38.401;38.410to414;38.455;38.470to475;38.815;38.817-01-02;38.818; 38.113
- 173: follow-up WI of REL-14 SI FS_NR_newRAT completed at RAN #75; 19/6/17: WID: RP-170855->RP-171485; 12/7/17: 38.133 added;; 12/7/17: 38.141 added;; 19/9/17: WID: RP-171485->RP-172115; 15/12/17: 38.101-4 added; 8/1/18: WID: RP-172115->RP-172834; 27/3/18: WID: RP-172834->RP-180536 / Impacted TSs and TRs: 38.133; 38.141; 38.101-4
- 174: no Perf. part; 14/9/17: WID:RP-170840->RP-171432
- 175: no Perf. Part19/6/17: Compl:0%->5%19/6/17: WID: RP-170840->RP-17143219/9/17: Compl:5%->10%; 8/1/18: Compl:10%->20%; ...27/3/18: Compl:20%->30%; ...
- 176: ; 19/9/17: Compl:0%->2%; ;…; 15/12/17: impacted specs add; 15/12/17: 38.508-2 added;; ...; ;... / Impacted TSs and TRs: 38.507-1; 38.533; 38.522; 38.521-1-2-3; 38.508; 38.509; 38.903; 38.905; 38.523-1-2-3; ; 38.508-2
- 177: -
- 179: 19/9/16: 30%->70; 6/10/16: 22.886 added; 1/12/16: 70%->95; 2/3/17: 95%->100 / Impacted TSs and TRs: 22.886
- 180: 7/6/17: 90%->100 / Impacted TSs and TRs: 22.186

| ID | WBS | Task | Type | Duration | Start | Finish | Complete | Remaining | Total slack | Constraint | Resources | Work | Actual work | Acronym | PCG approved | Impacted TSs and TRs | WI rapporteur name | Release | TSG approved | WI rapporteur e-mail |
| --- | --- | --- | --- | --- | --- | --- | --- | --- | --- | --- | --- | --- | --- | --- | --- | --- | --- | --- | --- | --- |
| 181 | 109 | **V2X new band combinations for LTE** |  | 328d? | 2017-03-15 A | 2018-06-15 | 70% | 98.4d? | 521d |  | R4 | 5248h | 3673.58h | LTE_V2X_CA_bands | 38 | 36.787 | LG Electronics | Rel-15 | 75 |  |
| 182 | 109.1 | Core part: V2X new band combinations for LTE |  | 328d? | 2017-03-15 A | 2018-06-15 | 70% | 98.4d? | 521d | finish no earlier than 2018-06-15 | R4 | 2624h | 1836.8h | LTE_V2X_CA_bands-Core | 38 |  | LG Electronics | Rel-15 | 75 |  |
| 183 | 110 | **Enhancements on LTE-based V2X Services** |  | 458d? | 2017-03-15 A | 2018-12-15 | 31% | 314.66d? | 391d |  | R1 | 9952h | 3114.75h | LTE_eV2X | 38 |  | Huawei | Rel-15 | 75 |  |
| 184 | 110.1 | Core part: V2X phase 2 based on LTE |  | 328d? | 2017-03-15 A | 2018-06-15 | 75% | 82d? | 521d | finish no earlier than 2018-06-15 | R1 | 2624h | 1968h | LTE_eV2X-Core | 38 | 36.788 | Huawei | Rel-15 | 75 |  |
| 185 | 110.2 | Perf. Part: V2X phase 2 based on LTE |  | 458d? | 2017-03-15 | 2018-12-15 |  |  | 391d | finish no earlier than 2018-12-15 | R4 | 3664h |  | LTE_eV2X-Perf | 38 |  | Huawei | Rel-15 | 75 |  |
| 186 | 111 | Study on security aspects for LTE support of V2X services |  | 465d? | 2015-09-07 A | 2017-06-15 | 90% | 46.5d? | 782d | finish no earlier than 2017-06-15 | S3 | 3720h | 3348h | FS_V2XLTE_ARC | 36 | TR 33.885 | Huawei, Marcus Wong | Rel-15 | 70 | mwong@huawei.com |
| 187 | 112 | Study on V2X Media Handling and Interaction |  | 331d? | 2017-09-08 A | 2018-12-14 | 60% | 132.4d? | 391d | finish no earlier than 2018-12-14 | S4 | 2648h | 1588.8h | FS_mV2X | 39 | New; 26.985 | Jung, Kyunghun, Samsung Electronics Co., Ltd | Rel-15 | 77 | kyunghun.jung@samsung.com |
| 188 | 113 | Release 15 Features on Ultra/Highly Reliable Low Latency Communication | milestone | 0d? | 2016-06-09 A | 2016-06-09 A | 100% |  |  | finish no earlier than 2016-06-09 |  |  |  |  |  |  |  | Rel-15 |  |  |
| 189 | 114 | EPC support for E-UTRAN Ultra Reliable Low Latency Communication |  | 135d? | 2017-09-08 A | 2018-03-15 A | 100% |  |  | finish no earlier than 2018-03-15 | S2 | 1080h | 1080h | EPS_URLLC | 39 | 23.401; 23.214; 23.203 | Chris PUDNEY | Rel-15 | 77 | chris dot pudney at vodafone dot com |
| 190 | 115 | **Highly Reliable Low Latency Communication for LTE** |  | 458d? | 2017-03-15 A | 2018-12-15 | 13% | 400.66d? | 391d |  | R1 | 9952h | 1245.89h | LTE_HRLLC | 38 |  | Ericsson | Rel-15 | 75 |  |
| 191 | 115.1 | Core part: Highly Reliable Low Latency Communication for LTE |  | 328d? | 2017-03-15 A | 2018-06-15 | 30% | 229.6d? | 521d | finish no earlier than 2018-06-15 | R1 | 2624h | 787.2h | LTE_HRLLC-Core | 38 |  | Ericsson | Rel-15 | 75 |  |
| 192 | 115.2 | Perf. part: Highly Reliable Low Latency Communication for LTE |  | 458d? | 2017-03-15 | 2018-12-15 |  |  | 391d | finish no earlier than 2018-12-15 | R4 | 3664h |  | LTE_HRLLC-Perf | 38 |  | Ericsson | Rel-15 | 75 |  |
| 193 | 116 | Release 15 Features on improvements of Mission Critical (MC) | milestone | 0d? | 2016-06-09 A | 2016-06-09 A | 100% |  |  | finish no earlier than 2016-06-09 |  |  |  |  |  |  |  | Rel-15 |  |  |
| 194 | 117 | Study on MC system migration and interconnect between MCPTT systems |  | 262d? | 2016-06-13 A | 2017-06-12 A | 100% |  |  | finish no earlier than 2017-06-12 | S6 | 2096h | 2096h | FS_MCSMI | 37 | New TR 23.781 | Chater-Lea, David | Rel-15 | 72 |  |
| 195 | 118 | Study on MC Communication Interworking between LTE and non-LTE Systems |  | 262d? | 2016-06-13 A | 2017-06-12 A | 100% |  |  | finish no earlier than 2017-06-12 | S6 | 2096h | 2096h | FS_MCCI | 37 | New TR 23.782 | Monnes, Peter (Harris Corp.) | Rel-15 | 72 |  |
| 196 | 119 | Study on MC Security Enhancements |  | 456d? | 2016-06-17 A | 2018-03-15 A | 100% |  |  | finish no earlier than 2018-03-15 | S3 | 3648h | 3648h | FS_MC_Sec | 37 | TR 33.xxx; 33.280; 39.880 | Haigh, Peter, CESG | Rel-15 | 72 | peter.haigh@cesg.gsi.gov.uk |
| 197 | 120 | Removal of 'over LTE' limitation from Mission Critical Specifications |  | 23d? | 2017-11-15 A | 2017-12-15 A | 100% |  |  | finish no earlier than 2017-12-15 | S1 | 184h | 184h | MCOver |  | 22.179; 22.280; 22.281; 22.282; 22.468 | Kees Verweij ;The Police of the Netherlands | Rel-15 | 78 | KeesdotVerweijatPolitiedotNL |
| 198 | 121 | **Enhancements to MCPTT functional architecture and information flows** |  | 336d? | 2017-03-03 A | 2018-06-15 | 60% | 133.08d? | 521d |  |  | 3248h | 1961.6h | enhMCPTT | 38 | TS 23.280 + TS 23.379 | Dom Lazara, Motorola Solutions | Rel-15 | 75 | dom.lazara@motorolasolutions.com |
| 199 | 121.1 | Stage 2 of enhMCPTT |  | 205d? | 2017-03-03 A | 2017-12-14 A | 100% |  |  | finish no earlier than 2017-12-14 | S6 | 1640h | 1640h | enhMCPTT | 38 | TS 23.280 + TS 23.379 | Dom Lazara, Motorola Solutions | Rel-15 | 75 | dom.lazara@motorolasolutions.com |
| 200 | 121.2 | Stage 3 of enhMCPTT |  | 201d? | 2017-09-08 A | 2018-06-15 | 20% | 160.8d? | 521d | finish no earlier than 2018-06-15 | C1 | 1608h | 321.6h | enhMCPTT-CT | 39 | 24.379; 24.380; 24.481; 24.482; 24.483; 24.484 | FREDERICKS, Bob | Rel-15 | 77 | bobfredericks@motorolasolutions.com |
| 201 | 122 | **Enhancements to MC Data Functional architecture and information flows** |  | 336d? | 2017-03-03 A | 2018-06-15 | 93% | 24.95d? | 521d |  |  | 3248h | 3006.8h | eMCData | 38 | 23.280 + TS 23.282 | David Freeman, Home Office | Rel-15 | 75 | david@dnf-consulting.co.uk |
| 202 | 122.1 | Stage 2 of eMCData |  | 205d? | 2017-03-03 A | 2017-12-14 A | 100% |  |  | finish no earlier than 2017-12-14 | S6 | 1640h | 1640h | eMCData | 38 | 23.280 + TS 23.282 | David Freeman, Home Office | Rel-15 | 75 | david@dnf-consulting.co.uk |
| 203 | 122.2 | Stage 3 of eMCData |  | 201d? | 2017-09-08 A | 2018-06-15 | 85% | 30.15d? | 521d | finish no earlier than 2018-06-15 | C1 | 1608h | 1366.8h | eMCData-CT | 39 | 24.282; 24.582; 24.481; 24.483; 24.484 | HASON, Baruh | Rel-15 | 77 | Baruh.Hason@motorolasolutions.com |
| 204 | 123 | **Enhancements to MC Video Functional architecture and information flows** |  | 270d? | 2017-06-05 A | 2018-06-15 | 50% | 134.86d? | 521d |  |  | 6042.8h | 2440.99h | eMCVideo | 39 | 23.280; 23.281 | Niranth Amogh, Huawei Telecommunications (India | Rel-15 | 76 | namogh@huawei.com |
| 205 | 123.1 | Stage 2 of eMCVideo |  | 139d? | 2017-06-05 A | 2017-12-14 A | 100% |  |  | finish no earlier than 2017-12-14 | S6 | 1112h | 1112h | eMCVideo | 39 | 23.280; 23.281 | Niranth Amogh, Huawei Telecommunications (India | Rel-15 | 76 | namogh@huawei.com |

Notes:
- 181: no Perf. part; 12/7/17: 36.787 added;
- 182: no Perf. part; 19/6/17: Compl:0%->20%; ;...; 19/9/17: Compl:20%->40%; 8/1/18: Compl:40%->50%; 27/3/18: Compl:50%->70%;...
- 183: follow-up WI of REL-14 WI LTE_V2X for which the Core part was completed at RAN #75; 14/9/17: WID:RP-170798->RP-171069
- 184: follow-up WI of REL-14 WI LTE_V2X for which the Core part was completed at RAN #75; 19/6/17: Compl:0%->15%; ...; 30/6/17: 36.788 added;; 19/9/17: Compl:15%->30%...; 8/1/18: Compl:30%->55%27/3/18: Compl:55%->75%
- 185: follow-up WI of REL-14 WI LTE_V2X for which the Core part was completed at RAN #7519/6/17: WID: RP-170798->RP-17106919/9/17: WID: RP-171069->RP-171740
- 186: 11/12/15: WID:SP-150715->SP-150743. 28/01/16: typo on name corrected, WD corrected (was SP-150743); 7/3/16: 0%->10; 19/9/16: 10%->65; 1/12/16: 65%->85; 6/3/17: 85%->90; 21/3/17: FCD shifted, moved from Rel-14; 21/3/17: FCD:09/16->06/17
- 187: 15/12/17: 26.985 added;; 15/12/17: 0%->30; 16/3/18: 30%->50; 22/3/18: FCD:09/18->12/18; 7/6/18: 50%->60
- 188: -
- 189: 15/12/17: WID:SP-170797->SP-170811; 15/12/17: 0%->15; 20/3/18: 15%->100
- 190: 14/9/17: WID:RP-170796->RP-171489
- 191: ; 19/6/17: WID: RP-170796->RP-171489; 8/1/18: Compl:0%->10%; 8/1/18: WID: RP-171489->RP-172845; 27/3/18: Compl:10%->30%
- 192: ; 19/6/17: WID: RP-170796->RP-171489; 8/1/18: WID: RP-171489->RP-172845
- 193: -
- 194: 28/7/16: 23.781 added; 19/9/16: WID:SP-160340->SP-160526; FCD: 09/16->12/16; 19/9/16: 0%->40; 1/12/16: WID:SP-160526->SP-160880; 1/12/16: 40%->48; 9/12/16: FCD:12/16->06/17, Rel-14->Rel-15; 3/3/17: 48%->60; 7/6/17: 60%->100
- 195: 28/7/16: 23.782 added; 19/9/16: WID:SP-160341->SP-160527; 19/9/16: 0%->20; 1/12/16: WID:SP-160527->SP-160881; 1/12/16: 20%->22; 9/12/16: FCD:12/16->06/17, Rel-14->Rel-15; 3/3/17: 22%->50; 7/6/17: 50%->90; 11/9/17: 90%->100
- 196: 28/7/16: 33.280 added; 28/7/16: 39.880 added; 19/9/16: WID:SP-160374->SP-160567. FCD: 12/16->03/17; 1/12/16: 0%->35; 6/3/17: FCD:03/17->06/17; 6/3/17: 35%->60; 7/6/17: FCD:06/17->12/17 (Rel-14->Rel-15);60%->65; 8/6/17: WID:SP-160567->SP-170416; 11/9/17...; 16/3/18: 90%->100
- 197: 7/6/18: WID:SP-170986->SP-180354
- 198: 21/3/17: impacted TS/TR added; 7/6/17: 0%->25
- 199: 21/3/17: impacted TS/TR added; 7/6/17: 0%->25; 11/9/17: 25%->45; 15/12/17: 45%->100
- 200: 15/12/17: 0%->10; 7/6/18: 10%->20
- 201: 21/3/17: impacted TS/TR added; 7/6/17: 0%->10; 8/6/17: WID:SP-170249->SP-170462
- 202: 21/3/17: impacted TS/TR added; 7/6/17: 0%->10; 8/6/17: WID:SP-170249->SP-170462; 11/9/17: 10%->15; 15/12/17: 15%->100
- 203: 20/3/18: 0%->30; 7/6/18: 30%->85
- 204: 7/6/17: 0%->10
- 205: 7/6/17: 0%->10; 11/9/17: 10%->60; 15/12/17: 60%->100

| ID | WBS | Task | Type | Duration | Start | Finish | Complete | Remaining | Total slack | Constraint | Resources | Work | Actual work | Acronym | PCG approved | WI rapporteur name | WI rapporteur e-mail | Release | TSG approved | Impacted TSs and TRs |
| --- | --- | --- | --- | --- | --- | --- | --- | --- | --- | --- | --- | --- | --- | --- | --- | --- | --- | --- | --- | --- |
| 206 | 123.2 | **Stage 3 of eMCVideo** |  | 201d? | 2017-09-08 A | 2018-06-15 | 33% | 134d? | 521d |  | ct | 4930.8h | 1328.99h | eMCVideo-CT | 39 | WEI, Haitao | weihaitao@huawei.com | Rel-15 | 77 |  |
| 207 | 123.2.1 | CT1 aspects of eMCVideo |  | 138.45d? | 2017-09-08 A | 2018-06-15 A | 100% |  |  | finish no earlier than 2018-06-15 | C1 | 1107.6h | 1107.6h | eMCVideo-CT | 39 | WEI, Haitao | weihaitao@huawei.com | Rel-15 | 77 | 24.281; 24.581; 24.481; 24.483; 24.484 |
| 208 | 123.2.2 | CT3 aspects of eMCVideo |  | 138.45d? | 2017-12-05 | 2018-06-15 |  |  | 521d | finish no earlier than 2018-06-15 | C3 | 1107.6h |  | eMCVideo-CT | 39 | WEI, Haitao | weihaitao@huawei.com | Rel-15 | 77 | 29.165; 29.213; 29.214 |
| 209 | 123.2.3 | CT6 aspects of eMCVideo |  | 138.45d? | 2017-12-05 | 2018-06-15 |  |  | 521d | finish no earlier than 2018-06-15 | C6 | 1107.6h |  | eMCVideo-CT | 39 | WEI, Haitao | weihaitao@huawei.com | Rel-15 | 77 | 31.102; 31.103 |
| 210 | 124 | MC Security Enhancements |  | 270d? | 2017-06-05 A | 2018-06-15 A | 100% |  |  | finish no earlier than 2018-06-15 | S3 | 2160h | 2160h | eMCSec | 39 | Haigh, Peter, NCSC |  | Rel-15 | 76 | 33.180 |
| 211 | 125 | **MBMS usage for MC communication services** |  | 330d? | 2017-03-03 A | 2018-06-07 | 84% | 52.25d? | 527d |  | S6 | 4640h | 3331.2h | MBMS_Mcservices | 38 | Magnus Tränk, Ericsson | magnus.trank@ericsson.com | Rel-15 | 75 | TS 23.280 + TS 23.281 + TS 23.282 + TS 23.379 |
| 212 | 125.1 | Stage 2 for MBMS_Mcservices |  | 206d? | 2017-03-03 A | 2017-12-15 A | 100% |  |  | finish no earlier than 2017-12-15 | S6 | 1648h | 1648h | MBMS_Mcservices | 38 | Magnus Tränk, Ericsson | magnus.trank@ericsson.com | Rel-15 | 75 | TS 23.280 + TS 23.281 + TS 23.282 + TS 23.379 |
| 213 | 125.2 | Stage 3 for MBMS_Mcservices |  | 44d? | 2018-04-09 A | 2018-06-07 | 10% | 39.6d? | 527d | finish no earlier than 2018-06-07 | C1 | 352h | 35.2h | MBMS_Mcservices |  | Axell, Jörgen, Ericsson | Jorgen.Axell@ericsson.com | Rel-15 |  | 24.281; 24.282; 24.379; 24.380; 24.581; 24.380 |
| 214 | 126 | MC system migration and interconnection |  | 139d? | 2017-06-05 A | 2017-12-14 A | 100% |  |  | start no earlier than 2017-06-05 | S6 | 1112h | 1112h | MCSMI | 39 | Chater-Lea, David; Motorola Solutions | david.chater-lea@motorolasolutions.com | Rel-15 | 76 | TS 23.280; TS 23.379; TS 23.281; TS 23.282 |
| 215 | 127 | MC Communication Interworking between LTE and non-LTE Systems |  | 139d? | 2017-06-05 A | 2017-12-14 A | 100% |  |  | start no earlier than 2017-06-05 | S6 | 1112h | 1112h | MCCI | 39 | Monnes, Peter, Harris Corporation | pmonnes at harris dot com | Rel-15 | 76 | New TS 23.283; TS 23.280; TS 23.379; TS 23.282 |
| 216 | 128 | Protocol enhancements for Mission Critical Services |  | 201d? | 2017-09-08 A | 2018-06-15 A | 100% |  |  | finish no earlier than 2018-06-15 | C1 | 1608h | 1608h | MCProtoc15 | 39 | Jörgen Axell |  | Rel-15 | 77 |  |
| 217 | 129 | Release 15 Features on MTC-IoT | milestone | 0d? | 2016-06-09 A | 2016-06-09 A | 100% |  |  | finish no earlier than 2016-06-09 |  |  |  |  |  |  |  | Rel-15 |  |  |
| 218 | 130 | Battery Efficient Security for very low Throughput MTC Devices |  | 389d? | 2016-09-19 A | 2018-03-15 A | 100% |  |  | finish no earlier than 2018-03-15 | S3 | 3112h | 3112h | BEST_MTC_Sec | 37 | Evans, Tim, VODAFONE Group Plc. |  | Rel-15 | 73 | 33.401, 43.020, 33.220; 33.163 |
| 219 | 131 | AT Commands for CIoT-Ext |  | 130d? | 2017-12-15 A | 2018-06-14 A | 100% |  |  | finish no earlier than 2018-06-14 | C1 | 1040h | 1040h | AT_CIoT-Ext |  | Bakker, John-Luc (Blackberry) | jbakker@blackberry.com | Rel-15 | 78 | 27.007 |
| 220 | 132 | **Even further enhanced MTC for LTE** |  | 458d? | 2017-03-15 A | 2018-12-15 | 25% | 343.33d? | 391d |  | R1 | 9952h | 2491.78h | LTE_eMTC4 | 38 | Ericsson |  | Rel-15 | 75 |  |
| 221 | 132.1 | Core part: Even further enhanced MTC for LTE |  | 328d? | 2017-03-15 A | 2018-06-15 | 60% | 131.2d? | 521d | finish no earlier than 2018-06-15 | R1 | 2624h | 1574.4h | LTE_eMTC4-Core | 38 | Ericsson |  | Rel-15 | 75 |  |
| 222 | 132.2 | Perf. part: Even further enhanced MTC for LTE |  | 458d? | 2017-03-15 | 2018-12-15 |  |  | 391d | finish no earlier than 2018-12-15 | R4 | 3664h |  | LTE_eMTC4-Perf | 38 | Ericsson |  | Rel-15 | 75 |  |
| 223 | 133 | **Further NB-IoT enhancements** |  | 458d? | 2017-03-15 A | 2018-12-15 | 31% | 316.64d? | 391d |  | R1 | 9952h | 3071.68h | NB_IOTenh2 | 38 | Huawei |  | Rel-15 | 75 |  |
| 224 | 133.1 | Core part: Further NB-IoT enhancements |  | 328d? | 2017-03-15 A | 2018-06-15 | 60% | 131.2d? | 521d | finish no earlier than 2018-06-15 | R1 | 2624h | 1574.4h | NB_IOTenh2-Core | 38 | Huawei |  | Rel-15 | 75 |  |
| 225 | 133.2 | Perf. part: Further NB-IoT enhancements |  | 458d? | 2017-03-15 A | 2018-12-15 | 10% | 412.2d? | 391d | finish no earlier than 2018-12-15 | R4 | 3664h | 366.4h | NB_IOTenh2-Perf | 38 | Huawei |  | Rel-15 | 75 |  |
| 226 | 134 | Release 15 Features related to WLAN | milestone | 0d? | 2016-06-09 A | 2016-06-09 A | 100% |  |  | finish no earlier than 2016-06-09 |  |  |  |  |  |  |  | Rel-15 |  |  |
| 227 | 135 | **Inclusion of WLAN direct discovery technologies as an alternative for ProSe direct discovery** |  | 348d? | 2016-11-15 A | 2018-03-15 A | 100% |  |  |  |  | 4528h | 4528h | ProSe_WLAN_DD | 38 | Intel Corporation; Ana Lucia Pinheiro | ana.lucia.a.pinheiro@intel.com | Rel-15 | 74 | 22.278 |
| 228 | 135.1 | Stage 1 of ProSe_WLAN_DD |  | 23d? | 2016-11-15 A | 2016-12-15 A | 100% |  |  | finish no earlier than 2016-12-15 | S1 | 184h | 184h | ProSe_WLAN_DD | 38 | Intel Corporation; Ana Lucia Pinheiro | ana.lucia.a.pinheiro@intel.com | Rel-15 | 74 | 22.278 |
| 229 | 135.2 | Stage 2 of ProSe_WLAN_DD |  | 76d? | 2017-03-02 A | 2017-06-15 A | 100% |  |  | finish no earlier than 2017-06-15 | S2 | 608h | 608h | ProSe_WLAN_DD_Stage2 | 38 | Intel, Sašo Stojanovski | saso.stojanovski@intel.com | Rel-15 | 75 |  |

Notes:
- 206: 7/6/18: WID:CP-172032->CP-181084
- 207: 20/3/18: 0%->25; 7/6/18: 25%->100
- 210: 15/12/17: 0%->80; 15/12/17: FCD:12/17->03/18; 21/12/17: FCD:03/18->05/18. Exception in SP-171056; 16/3/18: 80%->90; 16/3/18: FCD:05/18->06/18; 7/6/18: 90%->100
- 211: 21/3/17: impacted TS/TR added; 7/6/17: 0%->45; 8/9/17: WID:SP-170075->SP-170686; 8/9/17: FCD:09/17->12/17; 11/9/17: 45%->70; 15/12/17: 70%->95; 16/3/18: 95%->100
- 212: 21/3/17: impacted TS/TR added; 7/6/17: 0%->45; 8/9/17: WID:SP-170075->SP-170686; 8/9/17: FCD:09/17->12/17; 11/9/17: 45%->70; 15/12/17: 70%->95; 16/3/18: 95%->100
- 214: 12/7/17: WID:SP-170402->SP-170577; 11/9/17: 0%->20; 15/12/17: 20%->80; 16/3/18: 80%->100
- 215: 11/9/17: 0%->40; 15/12/17: 40%->87; 16/3/18: 87%->100
- 216: 14/9/17: 0%->15; 15/12/17: 15%->40; 20/3/18: 40%->70; 7/6/18: 70%->100
- 217: -
- 218: 6/10/16: 33.163 added 6/3/17: FCD:12/16->09/17; 6/3/17: 0%->20. Moved from Rel-14.; 7/6/17: 20%->95; 15/12/17: FCD:09/17->03/18; 16/3/18: 95%->100
- 219: 20/3/18: 0%->20; 7/6/18: 20%->100
- 220: WI LTE_feMTC-Core got a 3 months exception granted by RAN #75 to complete in REL-14; note: RAN #75 approved WID RP-170732 with working agreement; 14/9/17: WID:RP-170732->RP-171427
- 221: WI LTE_feMTC-Core got a 3 months exception granted by RAN #75 to complete in REL-14; note: RAN #75 approved WID RP-170732 with working agreement; 19/6/17: Compl:0%-...; 19/9/...; 8/1...; 2...
- 222: note: RAN #75 approved WID RP-170732 with working agreement19/6/17: WID: RP-170732->RP-171427; 8/1/18: WID: RP-171427->RP-172811
- 223: follow-up WI of REL-14 WI NB_IOTenh which got an exception granted at RAN #75 to complete by RAN #76; note: RAN #75 approved WID RP-170852 with working agreement; 14/9/17: WID:RP-170852->RP-171428
- 224: follow-up WI of REL-14 WI NB_IOTenh which got an exception granted at RAN #75 to complete by RAN #76; note: RAN #75 approved WID RP-170852 with working agreement; ;...1...; 8/1/1...2...
- 225: follow-up WI of REL-14 WI NB_IOTenh which got an exception granted at RAN #75 to complete by RAN #76; note: RAN #75 approved WID RP-170852 with working agreement; ;...;...; 8/1...
- 226: -
- 227: 1/12/16: 0%->100
- 228: 1/12/16: 0%->100
- 229: 6/3/17: 0%->55; 7/6/17: 55%->100

| ID | WBS | Task | Type | Duration | Start | Finish | Complete | Remaining | Total slack | Constraint | Resources | Work | Actual work | Acronym | PCG approved | WI rapporteur name | WI rapporteur e-mail | Release | TSG approved | Impacted TSs and TRs |
| --- | --- | --- | --- | --- | --- | --- | --- | --- | --- | --- | --- | --- | --- | --- | --- | --- | --- | --- | --- | --- |
| 230 | 135.3 | **Stage 3 of ProSe_WLAN_DD** |  | 134d? | 2017-06-02 A | 2017-12-06 A | 100% |  |  |  | ct | 3216h | 3216h | ProSe_WLAN_DD_Stage3 | 39 | Intel, Vivek Gupta | vivek.g.gupta@intel.com | Rel-15 | 76 |  |
| 231 | 135.3.1 | CT1 aspects of ProSe_WLAN_DD |  | 134d? | 2017-06-02 A | 2017-12-06 A | 100% |  |  | finish no earlier than 2017-12-06 | C1 | 1072h | 1072h | ProSe_WLAN_DD_Stage3 | 39 | Intel, Vivek Gupta | vivek.g.gupta@intel.com | Rel-15 | 76 | 24.334 |
| 232 | 135.3.2 | CT4 aspects of ProSe_WLAN_DD |  | 134d? | 2017-06-02 A | 2017-12-06 A | 100% |  |  | finish no earlier than 2017-12-06 | C4 | 1072h | 1072h | ProSe_WLAN_DD_Stage3 | 39 | Intel, Vivek Gupta | vivek.g.gupta@intel.com | Rel-15 | 76 | 29.345; 29.230; 23.008 |
| 233 | 135.4 | Charging of ProSe_WLAN_DD |  | 65d? | 2017-12-15 A | 2018-03-15 A | 100% |  |  | finish no earlier than 2018-03-15 | S5 | 520h | 520h | ProSe_WLAN_DD-CH | 38 | Yizhi Yao, Intel Corporation | yizhi.yao@intel.com | Rel-15 | 74 | 32.277; 32.298; 32.299 |
| 234 | 136 | **Complementary Features for Voice services over WLAN** |  | 525d? | 2016-06-13 A | 2018-06-14 A | 100% |  |  |  |  | 10416h | 10416h | VoWLAN | 39 |  |  | Rel-15 | 76 |  |
| 235 | 136.1 | Study on Complementary Features for Voice services over WLAN |  | 199d? | 2016-06-13 A | 2017-03-15 A | 100% |  |  | finish no earlier than 2017-03-15 | S2 | 1592h | 1592h | FS_VoWLAN | 37 | Nokia (Nicolas Drevon | nicolas.drevon@nokia.com | Rel-15 | 72 | 23.751 |
| 236 | 136.2 | Stage 2 of VoWLAN |  | 23d? | 2017-05-09 A | 2017-06-08 A | 100% |  |  | finish no earlier than 2017-06-08 | S2 | 184h | 184h | VoWLAN | 39 | Drevon Nicolas, Nokia | nicolas.drevon@nokia.com | Rel-15 | 76 | 23.402 |
| 237 | 136.3 | **CT aspects of VoWLAN** |  | 270d? | 2017-06-02 A | 2018-06-14 A | 100% |  |  |  | ct | 8640h | 8640h | VoWLAN-CT | 39 | Jennifer Liu (Nokia) | Jennifer.Liu at nokia.com | Rel-15 | 76 |  |
| 238 | 136.3.1 | CT1 aspects of VoWLAN |  | 270d? | 2017-06-02 A | 2018-06-14 A | 100% |  |  | finish no earlier than 2018-06-14 | C1 | 2160h | 2160h | VoWLAN-CT | 39 | Jennifer Liu (Nokia) | Jennifer.Liu at nokia.com | Rel-15 | 76 | 24.302 ; 24.312 ; 24.244 |
| 239 | 136.3.2 | CT4 aspects of VoWLAN |  | 270d? | 2017-06-02 A | 2018-06-14 A | 100% |  |  | finish no earlier than 2018-06-14 | C4 | 2160h | 2160h | VoWLAN-CT | 39 | Jennifer Liu (Nokia) | Jennifer.Liu at nokia.com | Rel-15 | 76 | 29.274 |
| 240 | 136.3.3 | CT6 aspects of VoWLAN |  | 270d? | 2017-06-02 A | 2018-06-14 A | 100% |  |  | finish no earlier than 2018-06-14 | C6 | 2160h | 2160h | VoWLAN-CT | 39 | Jennifer Liu (Nokia) | Jennifer.Liu at nokia.com | Rel-15 | 76 | 31.102 |
| 241 | 137 | Release 15 Features on Virtual Reality (VR) | milestone | 0d? | 2016-03-01 A | 2016-03-01 | 32% | 0d? | 1121d |  |  |  |  |  |  |  |  | Rel-15 |  |  |
| 242 | 138 | Study on Virtual Reality |  | 402d? | 2016-03-01 A | 2017-09-12 A | 100% |  |  | finish no earlier than 2017-09-12 | S4 | 3216h | 3216h | FS_VR | 36 | Gilles TENIOU, Orange | gilles.teniou@orange.com | Rel-15 | 71 | TR 26.918 |
| 243 | 139 | Study on QoE metrics for VR |  | 331d? | 2017-09-08 A | 2018-12-14 | 20% | 264.8d? | 391d | finish no earlier than 2018-12-14 | S4 | 2648h | 529.6h | FS_QoE_VR | 39 | Li Ji | lily.jili@huawei.com | Rel-15 | 77 | New; 26.929; 26.119 |
| 244 | 140 | Study on 3GPP codecs for VR audio |  | 71d? | 2017-09-08 A | 2017-12-15 A | 100% |  |  | finish no earlier than 2017-12-15 | S4 | 568h | 568h | FS_CODVRA | 39 | Toftgård, Tomas, Ericsson | tomas.toftgard@ericsson.com | Rel-15 | 77 | 26.918 |
| 245 | 141 | Test Methodologies for the Evaluation of Perceived Listening Quality in Immersive Audio Systems |  | 266d? | 2017-09-08 A | 2018-09-14 | 35% | 172.9d? | 456d | finish no earlier than 2018-09-14 | S4 | 2128h | 744.8h | LiQuImAS | 39 | Schevciw, Andre – Qualcomm Incorporated | aschevci@qti.qualcomm.com | Rel-15 | 77 | New; 26.861; 26.261; 26.260; 26.259 |
| 246 | 142 | Addition of HDR to TV Video Profiles |  | 71d? | 2017-09-08 A | 2017-12-15 A | 100% |  |  | finish no earlier than 2017-12-15 | S4 | 568h | 568h | HDR | 39 | Thomas Stockhammer, Qualcomm Incorporated | tsto@qti.qualcomm.com | Rel-15 | 77 | TS 26.116; TS 26.346; TS 26.234; TS 26.247; TS 26.244 |
| 247 | 143 | Virtual Reality Profiles for Streaming Media |  | 266d? | 2017-09-08 A | 2018-09-14 | 60% | 106.4d? | 456d | finish no earlier than 2018-09-14 | S4 | 2128h | 1276.8h | VRStream | 39 | Thomas Stockhammer, Qualcomm Incorporated | tsto@qti.qualcomm.com | Rel-15 | 77 | TS 26.247; TS 26.346; TS 26.234; new TS; 26.118 |
| 248 | 144 | Release 15 other Features | milestone | 0d? | 2016-06-09 A | 2016-06-09 | 39% | 0d? | 1049d |  |  |  |  |  |  |  |  | Rel-15 |  |  |
| 249 | 145 | Forward compatibility for 3GPP Diameter Charging Applications |  | 67d? | 2018-03-15 A | 2018-06-15 A | 100% |  |  | finish no earlier than 2018-06-15 | S5 | 536h | 536h | FWDCA |  | Gardella, Maryse, Nokia | maryse.gardella@nokia.com | Rel-15 | 79 | 32.251; 32.277; 32.299 |
| 250 | 146 | Diameter Overload Control Mechanisms for Charging |  | 132d? | 2018-03-15 A | 2018-09-14 | 10% | 118.8d? | 456d | finish no earlier than 2018-09-14 | S5 | 1056h | 105.6h | DOCME_CH |  | Törnkvist, Robert, Ericsson | robert(dot)tornkvist(at)Ericsson(dot)com | Rel-15 | 79 | 32.299 |
| 251 | 147 | Charging aspects of WLAN access in EPC |  | 67d? | 2018-03-15 A | 2018-06-15 A | 100% |  |  | start no earlier than 2018-03-15 | S5 | 536h | 536h | WAEPC_CH |  | Gardella, Maryse, Nokia | maryse.gardella@nokia.com | Rel-15 | 79 | 32.251; 32.260; 32.299; 32.298 |
| 252 | 148 | FEC and ROHC Activation for GCSE over MBMS |  | 132d? | 2018-03-15 A | 2018-09-14 | 30% | 92.4d? | 456d | finish no earlier than 2018-09-14 | S4 | 1056h | 316.8h | FRASE |  | Bouazizi, Imed, Samsung Electronics Co., Ltd | i.bouazizi@samsung.com. | Rel-15 | 79 | 26.346, new |
| 253 | 149 | Media Handling Aspects of 5G Conversational Services |  | 132d? | 2018-03-15 A | 2018-09-14 | 60% | 52.8d? | 456d | finish no earlier than 2018-09-14 | S4 | 1056h | 633.6h | 5G_MTSI_Codecs |  | Oyman, Ozgur, Company: Intel | ozgur.oyman@intel.com | Rel-15 | 79 | 26.114; 26.223 |

Notes:
- 230: 18/12/17: WID:CP-171102->CP-173084
- 231: 14/9/17: 0%->60; 15/12/17: 60%->100
- 232: 15/12/17: 0%->100
- 233: 15/12/17: 0%->40; 16/3/18: 40%->100
- 235: 28/7/16: 23.751 added; 19/9/16: 0%->10., 7/12/16: moved from Rel-14, according to SP-160806; 6/3/17: 10%->80; 7/6/17: 80%->100
- 236: 15/12/17: 0%->100
- 237: 7/6/18: WID:CP-171101->CP-181083
- 238: 14/9/17: 0%->70; 15/12/17: 70%->100
- 239: 7/6/18: 0%->100
- 240: 7/6/18: 0%->100
- 241: -
- 242: 11/6/16: 0%->10; 19/9/16: 10%->40, FCD: 12/16->03/17; 1/12/16: FCD:03/17->06/17; 1/12/16: 40%->35; 14/12/16: 35%->45; 14/12/16: FCD:06/17->09/17; 6/3/17: 45%->55; 7/6/17: 55%->70; 11/9/17: 70%->100
- 243: 15/12/17: 26.929 added;; 15/12/17: 26.119 added;; 15/12/17: FCD:06/18->09/18; 15/12/17: 0%->10; 16/3/18: 10%->15; 7/6/18: 15%->20; 7/6/18: FCD:09/18->12/18
- 244: 15/12/17: 0%->100; 15/12/17: FCD:09/17->12/17
- 245: 15/12/17: added: 26.861; 26.261; 26.260; 26.259; 15/12/17: 0%->15; 16/3/18: 15%->20; 7/6/18: 20%->35; 7/6/18: FCD:06/18->09/18
- 246: 15/12/17: 0%->100
- 247: 15/12/17: 26.118 added;; 15/12/17: 0%->25; 16/3/18: 25%->40; 7/6/18: 40%->60; 7/6/18: FCD:06/18->09/18
- 248: -
- 249: 7/6/18: 0%->100
- 250: 7/6/18: 0%->10; 7/6/18: FCD:06/18->09/18
- 251: 7/6/18: 0%->100
- 252: 7/6/18: 0%->30; 7/6/18: FCD:06/18->09/18
- 253: 7/6/18: 0%->60; 7/6/18: FCD:06/18->09/18

| ID | WBS | Task | Duration | Start | Finish | Complete | Remaining | Total slack | Constraint | Resources | Work | Actual work | Acronym | WI rapporteur name | WI rapporteur e-mail | Release | TSG approved | Impacted TSs and TRs | PCG approved |
| --- | --- | --- | --- | --- | --- | --- | --- | --- | --- | --- | --- | --- | --- | --- | --- | --- | --- | --- | --- |
| 254 | 150 | **SRVCC for terminating call in pre-alerting phase** | 66d? | 2018-03-15 A | 2018-06-14 | 98% | 1.65d? | 522d |  |  | 1056h | 1029.6h | bSRVCC_MT | Song Yue (China Mobile) | songyue (at) chinamobile (dot) com | Rel-15 | 79 |  |  |
| 255 | 150.1 | CT1 aspects of bSRVCC_MT | 66d? | 2018-03-15 A | 2018-06-14 A | 100% |  |  | start no earlier than 2018-03-15 | C1 | 528h | 528h | bSRVCC_MT | Song Yue (China Mobile) | songyue (at) chinamobile (dot) com | Rel-15 | 79 | 24.237; 24.008 |  |
| 256 | 150.2 | CT3 aspects of bSRVCC_MT | 66d? | 2018-03-15 A | 2018-06-14 | 95% | 3.3d? | 522d | start no earlier than 2018-03-15 | C3 | 528h | 501.6h | bSRVCC_MT | Song Yue (China Mobile) | songyue (at) chinamobile (dot) com | Rel-15 | 79 | 29.165 |  |
| 257 | 151 | **Enhancements to Call spoofing functionality** | 66d? | 2018-03-15 A | 2018-06-14 | 25% | 49.5d? | 522d |  | C1 | 1584h | 396h | eSPECTRE | Axell, Jörgen, Ericsson | Jorgen.Axell@ericsson.com | Rel-15 | 79 |  |  |
| 258 | 151.1 | CT1 aspects of eSPECTRE | 66d? | 2018-03-15 A | 2018-06-14 | 50% | 33d? | 522d | start no earlier than 2018-03-15 | C1 | 528h | 264h | eSPECTRE | Axell, Jörgen, Ericsson | Jorgen.Axell@ericsson.com | Rel-15 | 79 | 24.229 |  |
| 259 | 151.2 | CT3 aspects of eSPECTRE | 66d? | 2018-03-15 | 2018-06-14 |  |  | 522d | start no earlier than 2018-03-15 | C3 | 528h |  | eSPECTRE | Axell, Jörgen, Ericsson | Jorgen.Axell@ericsson.com | Rel-15 | 79 | 29.163; 29.165 |  |
| 260 | 152 | **Increasing the number of EPS bearers** | 131d? | 2017-12-15 A | 2018-06-15 | 50% | 65.25d? | 521d |  |  | 2632h | 1584h | INOBEAR | Andy.Bennett, Samsung | a <dot> bennett <at> Samsung.com | Rel-15 | 78 | 23.401; 23.167 |  |
| 261 | 152.1 | Stage 2 of INOBEAR | 131d? | 2017-12-15 | 2018-06-15 |  |  | 521d | finish no earlier than 2018-06-15 | S2 | 1048h |  | INOBEAR | Andy.Bennett, Samsung | a <dot> bennett <at> Samsung.com | Rel-15 | 78 | 23.401; 23.167 |  |
| 262 | 152.2 | **Stage 3 of INOBEAR** | 66d? | 2018-03-16 A | 2018-06-15 A | 100% |  |  |  | ct | 1584h | 1584h | INOBEAR-CT | Samsung, Lalith Kumar | lalith.kumar@samsung.com | Rel-15 | 79 |  |  |
| 263 | 152.2.1 | CT1 aspects of INOBEAR | 66d? | 2018-03-16 A | 2018-06-15 A | 100% |  |  | start no earlier than 2018-03-16 | C1 | 528h | 528h | INOBEAR-CT | Samsung, Lalith Kumar | lalith.kumar@samsung.com | Rel-15 | 79 | 24.301; 24.007 |  |
| 264 | 152.2.2 | CT4 aspects of INOBEAR | 66d? | 2018-03-16 A | 2018-06-15 A | 100% |  |  | start no earlier than 2018-03-16 | C4 | 528h | 528h | INOBEAR-CT | Samsung, Lalith Kumar | lalith.kumar@samsung.com | Rel-15 | 79 | 29.274 |  |
| 265 | 153 | **Increased number of E-UTRAN data bearers** | 131d? | 2017-12-15 | 2018-06-15 |  |  | 521d |  | R2 | 2096h |  | INOBEARRAN | Samsung |  | Rel-15 | 78 |  |  |
| 266 | 153.1 | Core part: Increased number of E-UTRAN data bearers | 131d? | 2017-12-15 | 2018-06-15 |  |  | 521d | finish no earlier than 2018-06-15 | R2 | 1048h |  | INOBEARRAN-Core | Samsung |  | Rel-15 | 78 |  |  |
| 267 | 154 | **Remote UE access via relay UE** | 600d? | 2016-03-01 A | 2018-06-15 A | 100% |  |  |  |  | 4960h | 4960h | REAR | Huawei, Laurence Meriau | laurence.meriau@huawei.com | Rel-15 | 71 | 22.278, 22.115 | 36 |
| 268 | 154.1 | Study on architecture enhancements to ProSe UE-to-Network Relay | 206d? | 2016-12-01 A | 2017-09-14 A | 100% |  |  | finish no earlier than 2017-09-14 | S2 | 1648h | 1648h | FS_REAR | Dario Serafino Tonesi, Huawei | dario.tonesi@huawei.com | Rel-15 | 74 | 23.733 | 38 |
| 269 | 154.2 | Study on security aspects of enhancements to ProSe UE-to-Network Relay | 337d? | 2017-03-02 A | 2018-06-15 A | 100% |  |  | finish no earlier than 2018-06-15 | S3 | 2696h | 2696h | FS_REAR_Sec |  | lihe2@huawei.com | Rel-15 | 75 |  | 38 |
| 270 | 154.3 | Stage 1 for REAR | 77d? | 2016-03-01 A | 2016-06-15 A | 100% |  |  | finish no earlier than 2016-06-15 | S1 | 616h | 616h | REAR | Huawei, Laurence Meriau | laurence.meriau@huawei.com | Rel-15 | 71 | 22.278, 22.115 | 36 |
| 271 | 155 | **Enhanced VoLTE performance** | 402d? | 2016-12-01 A | 2018-06-15 A | 100% |  |  |  |  | 5680h | 5680h | eVoLP |  |  | Rel-15 | 78 |  |  |
| 272 | 155.1 | Stage 2 of eVoLP | 47d? | 2017-10-12 A | 2017-12-15 A | 100% |  |  | finish no earlier than 2017-12-15 | S2 | 376h | 376h | eVoLP | Xiaobo Wu, Huawei | wuxiaobo@ huawei.com | Rel-15 | 78 | 23.401; 23.203 |  |
| 273 | 155.2 | **CT aspects on enhanced VoLTE performance** | 130d? | 2017-12-15 A | 2018-06-14 A | 100% |  |  |  |  | 2080h | 2080h | eVoLP-CT | Yan, Yali, Huawei | yanyali@huawei.com | Rel-15 | 78 |  |  |
| 274 | 155.2.1 | CT3 aspects of EvoLP | 130d? | 2017-12-15 A | 2018-06-14 A | 100% |  |  | finish no earlier than 2018-06-14 | C3 | 1040h | 1040h | eVoLP-CT | Yan, Yali, Huawei | yanyali@huawei.com | Rel-15 | 78 | 29.212; 29.213 |  |
| 275 | 155.2.2 | CT4 aspects of EvoLP | 130d? | 2017-12-15 A | 2018-06-14 A | 100% |  |  | finish no earlier than 2018-06-14 | C4 | 1040h | 1040h | eVoLP-CT | Yan, Yali, Huawei | yanyali@huawei.com | Rel-15 | 78 | 29.274 |  |
| 276 | 155.3 | **Study on enhanced VoLTE performance** | 402d? | 2016-12-01 A | 2018-06-15 A | 100% |  |  |  |  | 3224h | 3224h | FS_eVoLP | Fabrice Plante, Intel | fabrice.m.plante@intel.com | Rel-15 | 74 | 23.759 | 38 |
| 277 | 155.3.1 | S2 aspects of FS_eVoLP | 206d? | 2016-12-01 A | 2017-09-14 A | 100% |  |  | finish no earlier than 2017-09-14 | S2 | 1648h | 1648h | FS_eVoLP | Xiaobo Wu |  | Rel-15 | 74 | 23.759 | 38 |
| 278 | 155.3.2 | S4 aspects of FS_eVoLP | 197d? | 2017-09-14 A | 2018-06-15 A | 100% |  |  | finish no earlier than 2018-06-15 | S4 | 1576h | 1576h | FS_eVoLP | Venkatraman, Atti, Qualcomm Incorporated | vatti@qti.qualcomm.com | Rel-15 | 77 | 26.959 | 39 |

Notes:
- 255: 16/3/18: 0%->80; 7/6/18: 80%->100
- 256: 22/3/18: 0%->95
- 258: 16/3/18: 0%->5; 7/6/18: 5%->50
- 263: 7/6/18: 0%->100
- 264: 7/6/18: 0%->100
- 266: 27/3/18: WID: RP-172835->RP-180569
- 267: Previously known as "wearable devices"; 9/6/16: 0%->100; 9/6/16: WID:SP-160231->SP-160371
- 268: 1/12/16: 0%->5. Study on Stage 2 for REAR. When normative work completed, Stage 1 and Stage 2 shall be in the same release; 6/3/17: 5%->30; 7/6/17: 30%->60; 11/9/17: 60%->95; 15/12/17: 95%->100
- 269: 7/6/17: 0%->15; 11/9/17: 15%->50; 15/12/17: 50%->79; 16/3/18: 79%->99; 16/3/18: FCD:03/18->06/18; 7/6/18: 99%->100
- 270: Previously known as "wearable devices"; 9/6/16: 0%->100; 9/6/16: WID:SP-160231->SP-160371; 15/12/17: moved Rel-14->Rel-15
- 274: 16/3/18: 0%->100
- 275: 7/6/18: 0%->100
- 276: 1/12/16: 0%->5; 6/3/17: 5%->50; 7/6/17: 50%->60; 11/9/17: 60%->100
- 277: 1/12/16: 0%->5; 6/3/17: 5%->50; 7/6/17: 50%->60; 11/9/17: 60%->100; 15/12/17: rapporteur changed
- 278: 15/12/17: 26.959 added;; 15/12/17: 0%->50; 16/3/18: 50%->75; 16/3/18: FCD:03/18->06/18; 7/6/18: 75%->100

| ID | WBS | Task | Duration | Start | Finish | Complete | Remaining | Total slack | Constraint | Resources | Work | Actual work | Acronym | PCG approved | WI rapporteur name | WI rapporteur e-mail | Release | TSG approved | Status Report |
| --- | --- | --- | --- | --- | --- | --- | --- | --- | --- | --- | --- | --- | --- | --- | --- | --- | --- | --- | --- |
| 279 | 156 | **Unlicensed Spectrum Offloading System** | 555d? | 2016-02-01 A | 2018-03-15 A | 100% |  |  |  |  | 2952h | 2952h | USOS | 36 | Edward Hall, Qualcomm Incorporated | edhall@qti.qualcomm.com | Rel-15 | 71 | SP-170526 |
| 280 | 156.1 | Study on unlicensed spectrum offloading system enhancements | 141d? | 2016-12-01 A | 2017-06-15 A | 100% |  |  | finish no earlier than 2017-06-15 | S2 | 1128h | 1128h | FS_USOS | 38 | Haris Zisimopoulos, Qualcomm Incorporated | harisz@qti.qualcomm.com | Rel-15 | 74 |  |
| 281 | 156.2 | Stage 1 of USOS | 22d? | 2016-02-01 A | 2016-03-01 A | 100% |  |  | start no earlier than 2016-02-01 | S1 | 176h | 176h | USOS | 36 | Edward Hall, Qualcomm Incorporated | edhall@qti.qualcomm.com | Rel-15 | 71 | SP-170526 |
| 282 | 156.3 | Stage 2 of USOS | 71d? | 2017-09-08 A | 2017-12-15 A | 100% |  |  | finish no earlier than 2017-12-15 | S2 | 568h | 568h | USOS | 39 | Haris Zisimopoulos | harisz@qti.qualcomm.com | Rel-15 | 77 |  |
| 283 | 156.4 | Stage 3 of USOS | 135d? | 2017-09-08 A | 2018-03-15 A | 100% |  |  | finish no earlier than 2018-03-15 | C4 | 1080h | 1080h | USOS-CT | 39 | Lena Chaponniere, Qualcomm Incorporated | lguellec@qti.qualcomm.com | Rel-15 | 77 |  |
| 284 | 157 | **Mobile Communication System for Railways** | 528d? | 2016-06-09 A | 2018-06-15 | 84% | 86.72d? | 521d |  |  | 7440h | 5926.37h | MONASTERY | 38 | Merkel, Juergen, Nokia | juergen.merkel@nokia.com | Rel-15 | 75 |  |
| 285 | 157.1 | Study on Future Railway Mobile Communication System | 267d? | 2016-06-09 A | 2017-06-15 A | 100% |  |  | finish no earlier than 2017-06-15 | S1 | 2136h | 2136h | FS_FRMCS | 37 | Merkel, Juergen | Merkel, Juergen - Nokia Networks | Rel-15 | 72 |  |
| 286 | 157.2 | Study on Application Architecture for the Future Railway Mobile Communication System (stage 2) | 205d? | 2017-03-03 A | 2017-12-14 A | 100% |  |  | finish no earlier than 2017-12-14 | S6 | 1640h | 1640h | FS_FRMCS_ARCH | 38 | Oettl, Martin, Nokia | martin(dot)oettl(at)nokia(dot)com | Rel-15 | 75 |  |
| 287 | 157.3 | Stage 1 of MONASTERY | 76d? | 2017-03-02 A | 2017-06-15 A | 100% |  |  | finish no earlier than 2017-06-15 | S1 | 608h | 608h | MONASTERY | 38 | Merkel, Juergen, Nokia | juergen.merkel@nokia.com | Rel-15 | 75 |  |
| 288 | 157.4 | Stage 2 of MONASTERY | 71d? | 2017-09-08 A | 2017-12-15 A | 100% |  |  | finish no earlier than 2017-12-15 | S6 | 568h | 568h | MONASTERY | 39 | Oettl, Martin, Nokia | martin(dot)oettl(at)nokia(dot)com | Rel-15 | 77 |  |
| 289 | 157.5 | **Stage 3 of MONASTERY** | 66d? | 2018-03-16 A | 2018-06-15 | 28% | 47.3d? | 521d |  | ct | 2112h | 598.37h | MONASTERY |  | Leis, Peter (Nokia) | peter(dot)leis(at)nokia(dot)com | Rel-15 | 79 |  |
| 290 | 157.5.1 | CT1 aspects of MONASTERY | 66d? | 2018-03-16 A | 2018-06-15 | 85% | 9.9d? | 521d | finish no earlier than 2018-06-15 | C1 | 528h | 448.8h | MONASTERY |  | Leis, Peter (Nokia) | peter(dot)leis(at)nokia(dot)com | Rel-15 | 79 |  |
| 291 | 157.5.2 | CT3 aspects of MONASTERY | 66d? | 2018-03-16 | 2018-06-15 |  |  | 521d | finish no earlier than 2018-06-15 | C3 | 528h |  | MONASTERY |  | Leis, Peter (Nokia) | peter(dot)leis(at)nokia(dot)com | Rel-15 | 79 |  |
| 292 | 157.5.3 | CT6 aspects of MONASTERY | 66d? | 2018-03-16 | 2018-06-15 |  |  | 521d | finish no earlier than 2018-06-15 | C6 | 528h |  | MONASTERY |  | Leis, Peter (Nokia) | peter(dot)leis(at)nokia(dot)com | Rel-15 | 79 |  |
| 293 | 157.6 | Security Architecture of MONASTERY | 47d? | 2018-01-11 A | 2018-03-16 A | 100% |  |  | finish no earlier than 2018-06-15 | S3 | 376h | 376h | MONASTERY_SEC |  | Woodward, Tim, Motorola Solutions |  | Rel-15 | 79 |  |
| 294 | 158 | **PS Data Off Phase 2** | 336d? | 2017-03-02 A | 2018-06-14 A | 100% |  |  |  |  | 10296h | 10296h | PS_DATA_OFF2 | 38 | Murhammer, Leopold, Deutsche Telekom AG | leopold.murhammer@t-mobile.at | Rel-15 | 75 |  |
| 295 | 158.1 | Stage 2 of PS Data Off Phase 2 | 207d? | 2017-03-02 A | 2017-12-15 A | 100% |  |  | finish no earlier than 2017-12-15 | S2 | 1656h | 1656h | PS_DATA_OFF2 | 38 | Murhammer, Leopold, Deutsche Telekom AG | leopold.murhammer@t-mobile.at | Rel-15 | 75 |  |
| 296 | 158.2 | **Stage 3 of PS Data Off Phase 2** | 270d? | 2017-06-02 A | 2018-06-14 A | 100% |  |  |  | ct | 8640h | 8640h | PS_DATA_OFF2-CT | 39 | Herrero Veron, Christian (Huawei) | Christian.Herrero at huawei.com | Rel-15 | 76 |  |
| 297 | 158.2.1 | CT1 aspects of PS Data Off Phase 2 | 270d? | 2017-06-02 A | 2018-06-14 A | 100% |  |  | finish no earlier than 2018-06-14 | C1 | 2160h | 2160h | PS_DATA_OFF2-CT | 39 | Herrero Veron, Christian (Huawei) | Christian.Herrero at huawei.com | Rel-15 | 76 |  |
| 298 | 158.2.2 | CT4 aspects of PS Data Off Phase 2 | 270d? | 2017-06-02 A | 2018-06-14 A | 100% |  |  | finish no earlier than 2018-06-14 | C4 | 2160h | 2160h | PS_DATA_OFF2-CT | 39 | Herrero Veron, Christian (Huawei) | Christian.Herrero at huawei.com | Rel-15 | 76 |  |
| 299 | 158.2.3 | CT6 aspects of PS Data Off Phase 2 | 270d? | 2017-06-02 A | 2018-06-14 A | 100% |  |  | finish no earlier than 2018-06-14 | C6 | 2160h | 2160h | PS_DATA_OFF2-CT | 39 | Herrero Veron, Christian (Huawei) | Christian.Herrero at huawei.com | Rel-15 | 76 |  |
| 300 | 159 | **Northbound APIs for SCEF – SCS/AS Interworking** | 337d? | 2017-03-02 A | 2018-06-15 | 99% | 4.46d? | 521d |  |  | 10312h | 10150h | NAPS | 38 | Vaidya, Maulik, Huawei | Maulik.vaidya@huawei.com | Rel-15 | 75 |  |
| 301 | 159.1 | Stage 2 of NAPS | 142d? | 2017-03-02 A | 2017-09-15 A | 100% |  |  | start no earlier than 2017-03-02 | S2 | 1136h | 1136h | NAPS | 38 | Zhu Fenqin, Huawei | zhufenqin@huawei.com | Rel-15 | 75 |  |
| 302 | 159.2 | **Stage 3 of NAPS** | 270d? | 2017-06-02 A | 2018-06-14 | 97% | 6.75d? | 522d |  | C3 | 6480h | 6318h | NAPS-CT |  | Yan, Yali, Huawei, | yanyali@huawei.com | Rel-15 | 78 |  |
| 303 | 159.2.1 | CT3 aspects of NAPS | 270d? | 2017-06-02 A | 2018-06-14 | 95% | 13.5d? | 522d | finish no earlier than 2018-06-14 | C3 | 2160h | 2052h | NAPS-CT | 39 | Yan, Yali, Huawei, | yanyali@huawei.com | Rel-15 | 76 |  |
| 304 | 159.2.2 | CT4 aspects of NAPS | 270d? | 2017-06-02 A | 2018-06-14 A | 100% |  |  | finish no earlier than 2018-06-14 | C4 | 2160h | 2160h | NAPS-CT |  | Yan, Yali, Huawei, | yanyali@huawei.com | Rel-15 | 78 |  |
| 305 | 159.3 | Security aspects of NAPS | 136d? | 2017-09-08 A | 2018-03-16 A | 100% |  |  | finish no earlier than 2018-03-16 | S3 | 1088h | 1088h | NAPS-Sec | 39 | Zhao, Xuwen, Huawei | zhaoxuwen@huawei.com | Rel-15 | 77 |  |
| 306 | 159.4 | Carging aspects of NAPS | 201d? | 2017-09-08 A | 2018-06-15 A | 100% |  |  | finish no earlier than 2018-06-15 | S5 | 1608h | 1608h | NAPS-CH | 39 | Chen, Shan, Huawei | chenshan@huawei.com | Rel-15 | 76 |  |

Notes:
- 279: 08/09/17: Moved from Rel-14
- 280: 1/12/16: 0%->10; 6/3/17: 10%->30; 7/6/17: 30%->90; 11/9/17: 90%->100 / Impacted TSs and TRs: TR 23.729
- 281: Impacted TSs and TRs: 22.101, 22.115
- 282: 15/12/17: 0%->100 / Impacted TSs and TRs: TS 23.401; TS 23.203
- 283: 15/12/17: acronym corrected to USOS-CT as per the approved WID; 18/12/17: 0%->60; 16/3/18: 60%->100 / Impacted TSs and TRs: 23.008; 29.272; 29.230; 29.002; 29.305; 29.274
- 285: 19/9/16: 0%->25; 6/10/16: 22.989 added; 1/12/16: 25%->40; 1/12/16: WID:SP-160371->SP-160903; 9/12/16: FCD:12/16->3/201. WID was in SP-160903; 2/3/17: 40%->80; 2/3/17: FCD:03/17->06/17; 7/6/17: 80%->100 / Impacted TSs and TRs: 22.989
- 286: 21/3/17: added impacted TR; 7/6/17: 0%->10; 11/9/17: 10%->50; 15/12/17: 50%->100 / Impacted TSs and TRs: new TR 23.790
- 287: 7/6/17: 0%->10; 8/9/17: WID:SP-170163->SP-170697; 11/9/17: 10%->100 / Impacted TSs and TRs: 22.280; 22.179
- 288: 14/9/17: SA6 and not SA2; 15/12/17: 0%->100 / Impacted TSs and TRs: 23.280; 23.379
- 290: 16/3/18: 0%->40; 7/6/18: 40%->85 / Impacted TSs and TRs: 24.379; 24.380; 24.481; 24.483; 24.484
- 291: Impacted TSs and TRs: 29.165
- 292: Impacted TSs and TRs: 31.102; 31.103
- 293: 16/3/18: 0%->100 / Impacted TSs and TRs: 33.180
- 295: 7/6/17: 0%->10; 11/9/17: 10%->85; 15/12/17: 85%->100; 15/12/17: FCD:09/17->12/17
- 296: 18/12/17: WID:CP-171104->CP-173162; 7/6/18: WID:CP-173162->CP-181082
- 297: 7/6/18: 0%->100 / Impacted TSs and TRs: 24.008; 24.301; 27.007; 24.229; 24.368; 24.167; 24.173; 24.275; 24.341; 24.390; 24.391
- 298: 15/12/17: 0%->100 / Impacted TSs and TRs: 29.272; 29.274; 29.328; 29.329; 29.228; 29.229; 23.008
- 299: 7/6/18: 0%->100 / Impacted TSs and TRs: 31.102; 31.103; 31.111
- 300: 6/3/17: 0%->10
- 301: 6/3/17: 0%->10; 7/6/17: 10%->85; 30/6/17: 29.122 added;; 11/9/17: 85%->100; 15/12/17: rapoprteur changed / Impacted TSs and TRs: 29.122
- 302: 5/6/17: 0%->25; 8/9/17: WID:CP-171143->CP-172057; 11/9/17: 25%->40; 11/9/17: 40%->90. 18/12/17: WID corrected; 18/12/17: WID:CP-171143 ->CP-173112 / Impacted TSs and TRs: 29.336; 29.128; 29.230
- 303: 5/6/17: 0%->25; 8/9/17: WID:CP-171143->CP-172057; 11/9/17: 25%->40; 11/9/17: 40%->90; 15/12/17: 90%->65. 18/12/17: WID corrected; 16/3/18: 65%->72; 7/6/18: 72%->85; 7/6/18: 85%->95 / Impacted TSs and TRs: 29.336; 29.128; 29.230
- 304: 7/6/18: 95%->100
- 305: 15/12/17: 0%->60; 16/3/18: 60%->100 / Impacted TSs and TRs: 33.187
- 306: 30/6/17: 32.254 added;; 11/9/17: 0%->10; 15/12/17: 10%->20; 16/3/18: 20%->50; 7/6/18: 50%->100 / Impacted TSs and TRs: New TS; impact 32.240; 32.298; 32.299; 32.254

| ID | WBS | Task | Duration | Start | Finish | Complete | Remaining | Total slack | Constraint | Resources | Work | Actual work | Acronym | PCG approved | WI rapporteur name | WI rapporteur e-mail | Release | TSG approved | Status Report |
| --- | --- | --- | --- | --- | --- | --- | --- | --- | --- | --- | --- | --- | --- | --- | --- | --- | --- | --- | --- |
| 307 | 160 | **Common API Framework for 3GPP Northbound APIs** | 331d? | 2017-03-10 A | 2018-06-15 | 98% | 8.15d? | 521d |  |  | 3216h | 3136.8h | CAPIF | 39 | Suresh Chitturi, Samsung | s.chitturi@samsung.com | Rel-15 | 77 |  |
| 308 | 160.1 | Study on CAPIF | 135d? | 2017-03-10 A | 2017-09-14 A | 100% |  |  | finish no earlier than 2017-09-14 | S6 | 1080h | 1080h | FS_CAPIF | 38 | Suresh Chitturi, Samsung | s.chitturi@samsung.com | Rel-15 | 75 |  |
| 309 | 160.2 | Stage 2 of CAPIF | 71d? | 2017-09-08 A | 2017-12-15 A | 100% |  |  | finish no earlier than 2017-12-15 | S6 | 568h | 568h | CAPIF | 39 | Suresh Chitturi, Samsung | s.chitturi@samsung.com | Rel-15 | 77 |  |
| 310 | 160.3 | Stage 3 of CAPIF | 66d? | 2018-03-16 A | 2018-06-15 | 85% | 9.9d? | 521d | finish no earlier than 2018-06-15 | C3 | 528h | 448.8h | CAPIF-CT |  | Nishant Gupta, Samsung | nishant.gup@samsung.com | Rel-15 | 79 |  |
| 311 | 160.4 | Security aspects of CAPIF | 130d? | 2017-12-15 A | 2018-06-14 A | 100% |  |  | finish no earlier than 2018-06-14 | S3 | 1040h | 1040h | CAPIF-Sec |  | Rajavelsamy Rajadurai, Samsung | rajvel{@]samsung.com | Rel-15 | 78 |  |
| 312 | 161 | **Management and orchestration of 5G networks and network slicing** | 591d? | 2016-06-13 A | 2018-09-14 | 81% | 114.62d? | 456d |  | S5 | 23680h | 17808.2h | NETSLICE | 39 | Jan Groenendijk, Ericsson | jan<dot>groenendijk<at>ericsson<dot>com | Rel-15 | 76 |  |
| 313 | 161.1 | General aspects of NETSLICE | 591d? | 2016-06-13 A | 2018-09-14 | 85% | 88.65d? | 456d | finish no earlier than 2018-09-14 | S5 | 4728h | 4018.8h | NETSLICE | 39 | Jan Groenendijk, Ericsson | jan<dot>groenendijk<at>ericsson<dot>com | Rel-15 | 76 |  |
| 314 | 161.2 | Study on management and orchestration of network slicing for next generation network | 328d? | 2016-06-13 A | 2017-09-12 A | 100% |  |  | finish no earlier than 2017-09-12 | S5 | 2624h | 2624h | FS_MONETS | 37 | Ericsson , Robert Petersen |  | Rel-15 | 72 |  |
| 315 | 161.3 | Study on security aspect of 5G Network Slicing Provisioning | 201d? | 2017-09-08 A | 2018-06-15 A | 100% |  |  | finish no earlier than 2018-06-15 | S3 | 1608h | 1608h | FS_NETSLICE_MGT_Sec | 39 | SA3: Huawei | lei.zhongding@huawei.com | Rel-15 | 77 |  |
| 316 | 161.4 | Provisioning of network slicing for 5G networks and services | 335d? | 2017-06-05 A | 2018-09-14 | 80% | 67d? | 456d | finish no earlier than 2018-09-14 | S5 | 2680h | 2144h | NETSLICE-PRO_NS | 39 | Zhang Kai, Huawei | kai.zhangkai@huawei.com | Rel-15 | 76 |  |
| 317 | 161.5 | Network Resource Model (NRM) for 5G networks and network slicing | 196d? | 2017-12-15 A | 2018-09-14 | 60% | 78.4d? | 456d | finish no earlier than 2018-09-14 | S5 | 1568h | 940.8h | NETSLICE-5GNRM |  | Nokia (Weixing Wang | weixing.wang@nokia-sbell.com | Rel-15 | 78 |  |
| 318 | 161.6 | Assurance data and Performance Management for 5G networks and network slicing | 196d? | 2017-12-15 A | 2018-09-14 | 50% | 98d? | 456d | finish no earlier than 2018-09-14 | S5 | 1568h | 784h | NETSLICE-ADPM5G |  | Yizhi Yao, Intel Corporation | yizhi dot yao at intel dot com | Rel-15 | 78 |  |
| 319 | 161.7 | Management and virtualization aspects of 5G networks | 196d? | 2017-12-15 A | 2018-09-14 | 75% | 49d? | 456d | finish no earlier than 2018-09-14 | S5 | 1568h | 1176h | NETSLICE-MNFV5G |  | Joey Chou, Intel | joey<dot>chou<at>intel<dot>com | Rel-15 | 78 |  |
| 320 | 161.8 | 5G Trace management | 130d? | 2017-12-15 A | 2018-06-14 A | 100% |  |  | start no earlier than 2017-12-15 | S5 | 1040h | 1040h | NETSLICE-5GTRACE |  | Nokia (Anatoly Andrianov | anatoly.andrianov@nokia.com | Rel-15 | 78 |  |
| 321 | 161.9 | Fault Supervision for 5G networks and network slicing | 196d? | 2017-12-15 A | 2018-09-14 | 60% | 78.4d? | 456d | finish no earlier than 2018-09-14 | S5 | 1568h | 940.8h | NETSLICE-FS5G |  | Zhu Weihong, ZTE | zhu.weihong@zte.com.cn | Rel-15 | 78 |  |
| 322 | 162 | **Policy and Charging for Volume Based Charging** | 402d? | 2016-12-01 A | 2018-06-15 A | 100% |  |  |  |  | 7584h | 7584h | PC_VBC |  |  |  | Rel-15 | 78 |  |
| 323 | 162.1 | **Study on Policy and Charging for Volume Based Charging** | 272d? | 2016-12-01 A | 2017-12-15 A | 100% |  |  |  | C3 | 6528h | 6528h | FS_PC_VBC | 38 | Huang, Zhenning, China Mobile | huangzhenning <at> chinamobile <dot> com | Rel-15 | 74 |  |
| 324 | 162.1.1 | CT3 aspects of FS_PC_VBC | 272d? | 2016-12-01 A | 2017-12-15 A | 100% |  |  | finish no earlier than 2017-12-15 | C3 | 2176h | 2176h | FS_PC_VBC | 38 | Huang, Zhenning, China Mobile | huangzhenning <at> chinamobile <dot> com | Rel-15 | 74 |  |
| 325 | 162.1.2 | CT1 aspects of FS_PC_VBC | 272d? | 2016-12-01 A | 2017-12-15 A | 100% |  |  | finish no earlier than 2017-12-15 | C1 | 2176h | 2176h | FS_PC_VBC | 38 | Huang, Zhenning, China Mobile | huangzhenning <at> chinamobile <dot> com | Rel-15 | 74 |  |
| 326 | 162.2 | CT1 aspects of PV_VBC | 66d? | 2018-03-16 A | 2018-06-15 A | 100% |  |  | finish no earlier than 2018-06-15 | C1 | 528h | 528h | PC_VBC |  | Huang Zhenning (China Mobile) | huangzhenning (at) chinamobile (dot) com | Rel-15 | 79 |  |
| 327 | 162.3 | CT3 aspects of PV_VBC | 66d? | 2018-03-16 A | 2018-06-15 A | 100% |  |  | finish no earlier than 2018-06-15 | C3 | 528h | 528h | PC_VBC |  | Huang Zhenning (China Mobile) | huangzhenning (at) chinamobile (dot) com | Rel-15 | 79 |  |
| 328 | 163 | Framework for Live Uplink Streaming | 269d? | 2017-06-05 A | 2018-06-14 A | 100% |  |  | finish no earlier than 2018-06-14 | S4 | 2152h | 2152h | FLUS | 39 | Park, Kyungmo, SK Telecom | kyungmo.park@sk.com | Rel-15 | 76 |  |
| 329 | 164 | Self-Organizing Networks (SON) for Active Antenna System (AAS) deployment management | 201d? | 2017-09-08 A | 2018-06-15 | 80% | 40.2d? | 521d | finish no earlier than 2018-06-15 | S5 | 1608h | 1286.4h | OAM_SON_AAS | 39 | Nokia (Weixing Wang) | weixing.wang@nokia-sbell.com | Rel-15 | 77 |  |
| 330 | 165 | Server and Network Assisted DASH for 3GPP Multimedia Services | 206d? | 2016-12-01 A | 2017-09-14 A | 100% |  |  | finish no earlier than 2017-09-14 | S4 | 1648h | 1648h | SAND | 38 | Ozgur Oyman, Intel | ozgur.oyman@intel.com | Rel-15 | 74 | SP-170687 |
| 331 | 166 | SAND for MBMS | 201d? | 2017-09-08 A | 2018-06-15 A | 100% |  |  | finish no earlier than 2018-06-15 | S4 | 1608h | 1608h | SAND4M | 39 | Thomas Stockhammer, Qualcomm Incorporated | tsto@qti.qualcomm.com | Rel-15 | 77 |  |
| 332 | 167 | Management Enhancement for EPC CUPS | 196d? | 2017-12-15 A | 2018-09-14 | 60% | 78.4d? | 456d | finish no earlier than 2018-09-14 | S5 | 1568h | 940.8h | ME_CUPS |  | Huawei (ZHU, Lei | lei.zhu@huawei.com | Rel-15 | 78 |  |
| 333 | 168 | Enhanced QoE Reporting for MTSI | 204d? | 2017-06-05 A | 2018-03-15 A | 100% |  |  | finish no earlier than 2018-03-15 | S4 | 1632h | 1632h | EQoE_MTSI | 39 | Gunnar Heikkilä, Ericsson LM | gunnar.heikkila@ericsson.com | Rel-15 | 76 |  |

Notes:
- 307: 15/12/17: 23.222 added; / Impacted TSs and TRs: New; 23.222
- 308: 21/3/17: added impacted TR; 7/6/17: 0%->35; 8/6/17: WID:SP-170279->SP-170405; 11/9/17: 35%->70; 15/12/17: 70%->100 / Impacted TSs and TRs: new TR 23.722
- 309: 15/12/17: 0%->95; 16/3/18: 95%->100 / Impacted TSs and TRs: New
- 310: 16/3/18: 0%->10; 27/3/18: 29.222 added; 19/4/18: CAPIF->CAPIF-CT; 7/6/18: 10%->35; 7/6/18: 35%->85 / Impacted TSs and TRs: 29.122; 29.116; 29.222
- 311: 16/3/18: 0%->40; 7/6/18: 40%->100
- 312: 21/12/17: WID:SP-170586->SP-170960. Name changed from "Management of Network Slicing in Mobile Networks, Concepts, Use cases and Requirements"; 27/3/18: 32.159 added; / Impacted TSs and TRs: 32.101; 32.103; new; 32.159
- 313: 21/12/17: created from the Feature level, since SP-170960 contains its own specs and completions; 16/3/18: 46%->60; 7/6/18: 60%->85; 7/6/18: FCD:06/18->09/18 / Impacted TSs and TRs: 32.101; 32.103; 28.530
- 314: 28/7/16: 28.801 added; 19/9/16: 0%->10; 1/12/16: 10%->25; 6/3/17: FCD:03/17->06/17; 6/3/17: 25%->60; 21/3/17: moved from rel-14; 7/6/17: FCD:06/17->09/17; 7/6/17: 60%->90; 11/9/17: 90%->100 / Impacted TSs and TRs: 32.8xx; 28.801
- 315: 11/9/17: 0%->5; 15/12/17: 33.811 added;; 15/12/17: 5%->20. Acronym corrected.; 16/3/18: 20%->30; 7/6/18: 30%->100 / Impacted TSs and TRs: 33.811
- 316: 15/12/17: 0%->15; 21/12/17: WID:SP-170580->SP-170955; 16/3/18: 15%->40; 27/3/18: 28.532 added;; 7/6/18: 40%->80; 7/6/18: FCD:06/18->09/18 / Impacted TSs and TRs: new TS; 28.532
- 317: 16/3/18: 0%->25; 7/6/18: 25%->60; 7/6/18: FCD:06/18->09/18 / Impacted TSs and TRs: 28.657; 28.658; 28.659; 28.707; 28.708; 28.709
- 318: 16/3/18: 0%->10; 7/6/18: 10%->50; 7/6/18: FCD:06/18->09/18 / Impacted TSs and TRs: 32.425; 32.426; 32.450; 32.451; 32.455
- 319: 16/3/18: 0%->25; 7/6/18: 25%->75; 7/6/18: FCD:06/18->09/18 / Impacted TSs and TRs: 28.500; 28.510; 28.511; 28.512; 28.513; 28.515; 28.516; 28.517; 28.518; 28.520; 28.521; 28.522; 28.523; 28.525; 28.526; 28.527; 28.528
- 320: 7/6/18: 0%->100 / Impacted TSs and TRs: 32.421; 32.422; 32.423; 32.441; 32.442; 32.446
- 321: 16/3/18: 0%->20; 7/6/18: 20%->60; 7/6/18: FCD:06/18->09/18 / Impacted TSs and TRs: 32.111-1; 32.111-2; 32.111-6; 28.515; 28.516; 28.517; 28.518
- 323: 6/3/17: 0%->30; 21/3/17: 29.827 added;; 5/6/17: 30%->60; 8/9/17: WID:CP-160822->CP-172058; 11/9/17: FCD:06/17->12/17 / Impacted TSs and TRs: TR 29.827
- 324: 6/3/17: 0%->30; 21/3/17: 29.827 added;; 5/6/17: 30%->60; 8/9/17: WID:CP-160822->CP-172058; 11/9/17: FCD:06/17->12/17; 15/12/17: 60%->61; 15/12/17: 61%->100 / Impacted TSs and TRs: TR 29.827
- 325: 15/12/17: 0%->100 / Impacted TSs and TRs: TR 29.827
- 326: 7/6/18: 0%->100 / Impacted TSs and TRs: 24.605; 24.147
- 327: 7/6/18: 0%->100 / Impacted TSs and TRs: 29.212; 29.213; 29.214
- 328: 30/6/17: 26.238 added;; 11/9/17: 0%->10; 15/12/17: 10%->85; 15/12/17: FCD:12/17->06/18; 21/12/17: WID:SP-170576->SP-170824; 16/3/18: 85%->90; 7/6/18: 90%->100 / Impacted TSs and TRs: New TS; 26.238
- 329: 15/12/17: 0%->80 / Impacted TSs and TRs: 28.627; 28.628; 28.629; 28.658; 28.659
- 330: 3/3/17: WID:SP-160779->SP-170031; 6/3/17: 0%->15; 7/6/17: 15%->60; 11/9/17: 60%->100 / Impacted TSs and TRs: TS 26.247, 26.233
- 331: 15/12/17: 0%->50; 15/12/17: FCD:12/17->03/18; 21/12/17: WID:SP-170608->SP-170827; 16/3/18: 50%->60; 16/3/18: FCD:03/18->06/18; 7/6/18: 60%->100 / Impacted TSs and TRs: TS 26.247; TS 26.346; TS 26.347; TR26.946
- 332: ASN.1-type of WID, hence later than St3, indpt of CUPS Rel-14; 16/3/18: 0%->5; 7/6/18: 5%->60 / Impacted TSs and TRs: 32.426; 32.455; 28.658; 28.707; 28.708; 28.709
- 333: 11/9/17: 0%->10; 15/12/17: 10%->80; 16/3/18: 80%->100 / Impacted TSs and TRs: TS 26.114

| ID | WBS | Task | Duration | Start | Finish | Complete | Remaining | Total slack | Constraint | Resources | Work | Actual work | Acronym | PCG approved | WI rapporteur name | Release | TSG approved | WI rapporteur e-mail | Status Report |
| --- | --- | --- | --- | --- | --- | --- | --- | --- | --- | --- | --- | --- | --- | --- | --- | --- | --- | --- | --- |
| 334 | 169 | **Enhanced Calling Name Service** | 390d? | 2016-09-15 A | 2018-03-14 A | 100% |  |  |  |  | 5424h | 5424h | eCNAM | 37 | Hala Mowafy, Ericsson | Rel-15 | 73 |  |  |
| 335 | 169.1 | Stage 1 of eCNAM | 66d? | 2016-09-15 A | 2016-12-15 A | 100% |  |  | finish no earlier than 2016-12-15 | S1 | 528h | 528h | eCNAM | 37 | Hala Mowafy, Ericsson | Rel-15 | 73 |  |  |
| 336 | 169.2 | **CT aspects of eCNAM** | 204d? | 2017-06-02 A | 2018-03-14 A | 100% |  |  |  | ct | 4896h | 4896h | eCNAM-CT | 39 | Mowafy, Hala. Ericsson | Rel-15 | 76 | hala.mowafy@ericsson.com |  |
| 337 | 169.2.1 | CT1 aspects of eCNAM | 204d? | 2017-06-02 A | 2018-03-14 A | 100% |  |  | finish no earlier than 2018-03-14 | C1 | 1632h | 1632h | eCNAM-CT | 39 | Mowafy, Hala. Ericsson | Rel-15 | 76 | hala.mowafy@ericsson.com |  |
| 338 | 169.2.2 | CT3 aspects of eCNAM | 204d? | 2017-06-02 A | 2018-03-14 A | 100% |  |  | finish no earlier than 2018-03-14 | C3 | 1632h | 1632h | eCNAM-CT | 39 | Mowafy, Hala. Ericsson | Rel-15 | 76 | hala.mowafy@ericsson.com |  |
| 339 | 170 | Enhancement of background data transfer | 38d? | 2017-01-16 A | 2017-03-08 A | 100% |  |  | finish no earlier than 2017-03-08 | S1 | 304h | 304h | eBT | 38 | Atsushi Minokuchi, NTT DOCOMO | Rel-15 | 75 | minokuchi at nttdocomo dot com |  |
| 340 | 171 | **Stage-3 SAE Protocol Development - Phase 6** | 272d? | 2017-06-02 A | 2018-06-18 A | 100% |  |  |  | C1 | 8704h | 8704h | SAES6 | 39 | Interdigital, Aghili, Behrouz | Rel-15 | 76 | Behrouz.aghili@interdigital.com |  |
| 341 | 171.1 | SAES6 CS Fallback in EPS | 272d? | 2017-06-02 A | 2018-06-18 A | 100% |  |  | start no earlier than 2017-06-02 | C1 | 2176h | 2176h | SAES6-CSFB | 39 | Interdigital, Aghili, Behrouz | Rel-15 | 76 | Behrouz.aghili@interdigital.com |  |
| 342 | 171.2 | SAES6 for support for non-3GPP accesses | 272d? | 2017-06-02 A | 2018-06-18 A | 100% |  |  | start no earlier than 2017-06-02 | C1 | 2176h | 2176h | SAES6-non3GPP | 39 | Interdigital, Aghili, Behrouz | Rel-15 | 76 | Behrouz.aghili@interdigital.com |  |
| 343 | 171.3 | SAE Protocol Development (Stage 3) - Phase 6 | 272d? | 2017-06-02 A | 2018-06-18 A | 100% |  |  | start no earlier than 2017-06-02 | C1 | 2176h | 2176h | SAES6 | 37 |  | Rel-15 | 72 |  |  |
| 344 | 172 | Security Assurance Specification for eNB network product class | 322d? | 2016-09-19 A | 2017-12-12 A | 100% |  |  | finish no earlier than 2017-12-12 | S3 | 2576h | 2576h | SCAS_eNB | 37 | Marcus Wong, Huawei Technologies | Rel-15 | 73 | mwong@huawei.com |  |
| 345 | 173 | Security Assurance Specification for PGW network product class | 389d? | 2016-06-17 A | 2017-12-12 A | 100% |  |  | finish no earlier than 2017-12-12 | S3 | 3112h | 3112h | SCAS_PGW | 37 | Peng Jin, China Mobile | Rel-15 | 72 | pengjin@chinamobile.com |  |
| 346 | 174 | HPLMN Radio Access Technology deployment Optimisation in Network Selection | 76d? | 2017-03-02 A | 2017-06-15 A | 100% |  |  | finish no earlier than 2017-06-15 | S1 | 608h | 608h | HORNS | 38 | Eddy Hall, Qualcomm Incorporated | Rel-15 | 75 | edhall@qti.qualcomm.com |  |
| 347 | 175 | **IMS Stage-3 IETF Protocol Alignment** | 271d? | 2017-06-02 A | 2018-06-15 | 71% | 78.06d? | 521d |  | ct | 12976h | 7954.81h | IMSProtoc9 | 39 | Dr. Belling, Thomas, Nokia | Rel-15 | 76 | Thomas.Belling@nokia.com |  |
| 348 | 175.1 | CT1 aspects of IMS Stage-3 IETF Protocol Alignment | 269d? | 2017-06-02 A | 2018-06-13 A | 100% |  |  | finish no earlier than 2018-06-13 | C1 | 2152h | 2152h | IMSProtoc9 | 39 | Dr. Belling, Thomas, Nokia | Rel-15 | 76 | Thomas.Belling@nokia.com |  |
| 349 | 175.2 | **(IETF) CT1 aspects of IMS Stage-3 IETF Protocol Alignment** | 271d? | 2017-06-02 A | 2018-06-15 | 50% | 135.38d? | 521d |  | C1-IETF | 6504h | 3255h | IMSProtoc9 | 39 | Dr. Belling, Thomas, Nokia | Rel-15 | 76 | Thomas.Belling@nokia.com |  |
| 350 | 175.2.1 | (IETF) Content-ID header field in SIP (draft-ietf-sipcore-content-id) | 271d? | 2017-06-02 A | 2018-06-15 A | 100% |  |  | finish no earlier than 2018-06-15 | C1-IETF | 2168h | 2168h | IMSProtoc9 |  | Christer Holmberg | Rel-15 | 78 | christer.holmberg@ericsson.com |  |
| 351 | 175.2.2 | (IETF) P-Visited-Network header updated (draft-jesske-update-p-visited-network ) | 271d? | 2017-06-02 A | 2018-06-15 |  | 270.75d? | 521d | finish no earlier than 2018-06-15 | C1-IETF | 2168h | 2h | IMSProtoc9 |  | Michael KREIPL, Deutsche Telekom | Rel-15 | 78 | michael(dot)kreipl(at)telekom(dot)de |  |
| 352 | 175.3 | CT3 aspects of IMS Stage-3 IETF Protocol Alignment | 269d? | 2017-06-02 A | 2018-06-13 | 85% | 40.35d? | 523d | finish no earlier than 2018-06-13 | C3 | 2152h | 1829.2h | IMSProtoc9 | 39 | Dr. Belling, Thomas, Nokia | Rel-15 | 76 | Thomas.Belling@nokia.com |  |
| 353 | 176 | **Lawful Interception Rel-15** | 467d? | 2017-03-02 A | 2018-12-14 | 42% | 272.62d? | 391d |  |  | 6952h | 2893.6h | LI15 | 38 | Alex Leadbeater, BT | Rel-15 | 75 | alex.leadbeater@bt.com |  |
| 354 | 176.1 | Study on R15 Lawful Interception Service | 402d? | 2017-03-02 A | 2018-09-14 | 70% | 120.6d? | 456d | finish no earlier than 2018-09-14 | S3LI | 3216h | 2251.2h | FS_15LIS | 38 | Gerry McQuaid, Vodafone | Rel-15 | 75 | Gerald.McQuaid@vodafone.com |  |
| 355 | 176.2 | Normative work on Lawful Interception Rel-15 | 467d? | 2017-03-02 A | 2018-12-14 | 17% | 386.7d? | 391d | finish no earlier than 2018-12-14 | S3LI | 3736h | 642.4h | LI15 | 38 | Alex Leadbeater, BT | Rel-15 | 75 | alex.leadbeater@bt.com |  |
| 356 | 177 | **DL interference mitigation for UMTS** | 67d? | 2017-03-15 A | 2017-06-15 A | 100% |  |  |  | R2 | 1072h | 1072h | UTRA_DL_IM | 38 | Qualcomm | Rel-15 | 75 |  |  |
| 357 | 177.1 | Core part: DL interference mitigation for UMTS | 67d? | 2017-03-15 A | 2017-06-15 A | 100% |  |  | finish no earlier than 2017-06-15 | R2 | 536h | 536h | UTRA_DL_IM-Core | 38 | Qualcomm | Rel-14 | 75 |  | RP-171135 |
| 358 | 178 | Control and monitoring of Power, Energy and Environmental (PEE) parameters in Radio Access Networks (RAN) | 204d? | 2017-06-05 A | 2018-03-15 A | 100% |  |  | finish no earlier than 2018-03-15 | S5 | 1632h | 1632h | PEE_CMON | 39 | Jean-Michel CORNILY, ORANGE | Rel-15 | 76 |  |  |
| 359 | 179 | Management of QoE measurement collection | 400d? | 2017-06-05 A | 2018-12-14 | 25% | 300d? | 391d | finish no earlier than 2018-12-14 | S5 | 3200h | 800h | QOED | 39 | Petersen, Robert, Ericsson | Rel-15 | 76 | robert <dot> petersen <at>ericsson<dot>ericsson |  |

Notes:
- 334: 1/12/16: 0%->100 / Impacted TSs and TRs: 22.173
- 335: 1/12/16: 0%->100; 30/6/17: 24.196 added; / Impacted TSs and TRs: 22.173; 24.196
- 337: 14/9/17: 0%->40; 15/12/17: 40%->85; 20/3/18: 85%->100 / Impacted TSs and TRs: 24.259; 24.604; 24.606; 24.607; 24.608; 24.610; 24.611; 24.615; 24.616; 24.629; 24.642; 24.647; 24.654
- 338: 7/6/18: 0%->100 / Impacted TSs and TRs: 29.165
- 339: Impacted TSs and TRs: 22.101
- 340: Impacted TSs and TRs: 23.122; 24.008; 24.167; 24.229; 24.301; 24.302; 24.303; 24.304; 24.305; 24.312; 29.018; 29.118; 24.368
- 341: 14/9/17: 0%->20; 15/12/17: 20%->55; 16/3/18: 55%->80; 7/6/18: 80%->100 / Impacted TSs and TRs: 23.122; 24.008; 24.167; 24.229; 24.301; 24.302; 24.303; 24.304; 24.305; 24.312; 29.018; 29.118; 24.368
- 342: 14/9/17: 0%->20; 15/12/17: 20%->55; 16/3/18: 55%->80; 7/6/18: 80%->100 / Impacted TSs and TRs: 23.122; 24.008; 24.167; 24.229; 24.301; 24.302; 24.303; 24.304; 24.305; 24.312; 29.018; 29.118; 24.368
- 343: 14/9/17: 0%->20; 15/12/17: 20%->55; 16/3/18: 55%->80; 7/6/18: 80%->100
- 344: 6/10/16: 33.216 added; 1/12/16: 0%->5; 6/3/17: 5%->25. Moved from Rel-14.; 7/6/17: FCD:06/17->12/17; 7/6/17: 25%->75; 11/9/17: 75%->100 / Impacted TSs and TRs: TS 33.117, TR 33.926; 33.216
- 345: 28/7/16: 33.250 added; 19/9/16: 0%->10; 6/10/16: 33.216 added; 1/12/16: 10%->40. 06/03/17: moved from Rel-14.; 6/3/17: 40%->80; 7/6/17: FCD:06/17->12/17; 7/6/17: 80%->95; 11/9/17: 95%->100 / Impacted TSs and TRs: 33.250; 33.216
- 346: 7/6/17: 75%->100
- 348: 14/9/17: 0%->40; 15/12/17: 40%->60; 16/3/18: 60%->80; 7/6/18: 80%->100 / Impacted TSs and TRs: 23.218; 24.229; 24.930
- 350: 22/3/18: 0%->100
- 352: 15/12/17: 0%->40; 7/6/18: 40%->85 / Impacted TSs and TRs: 29.163; 29.165; 29.949
- 353: 21/12/17: WID:SP-170039->SP-170839; 16/3/18: 10%->20
- 354: 12/7/17: 0%->5; 11/9/17: 5%->10; 16/3/18: 24%->35; 7/6/18: 35%->70; 7/6/18: FCD:06/18->09/18
- 355: 12/7/17: 0%->5; 15/12/17: 5%->10
- 356: no Perf. part
- 357: no Perf. part19/6/17: Compl:0%->100%...
- 358: 30/6/17: 28.306 added;; 30/6/17: 28.305 added;; 30/6/17: 28.304 added;; 11/9/17: 0%->20; 15/12/17: 20%->80; 16/3/18: 80%->100 / Impacted TSs and TRs: New TSs, TS 52.402; TS 32.405; TS 32.425; TS 32.101; TS 32.103; 28.306; 28.305; 28.304
- 359: 30/6/17: 28.309 added;; 30/6/17: 28.308 added;; 30/6/17: 28.307 added;; 30/6/17: 28.406 added;; 11/9/17: 0%->5; 15/12/17: 5%->15; 16/3/18: 15%->25; 7/6/18: FCD:06/18->12/18 / Impacted TSs and TRs: 32.101; 32.103; 6 new TS; 28.309; 28.308; 28.307; 28.406; 28.405; 28.404

| ID | WBS | Task | Type | Duration | Start | Finish | Complete | Remaining | Total slack | Constraint | Resources | Work | Actual work | Acronym | PCG approved | WI rapporteur name | Release | TSG approved | Impacted TSs and TRs | WI rapporteur e-mail | Status Report |
| --- | --- | --- | --- | --- | --- | --- | --- | --- | --- | --- | --- | --- | --- | --- | --- | --- | --- | --- | --- | --- | --- |
| 360 | 180 | **Simplified HS-SCCH for UMTS** |  | 198d? | 2017-03-15 A | 2017-12-15 A | 100% |  |  |  | R6 | 3176h | 3176h | UTRA_simple_HSSCCH | 39 | Ericsson | Rel-15 | 76 |  |  |  |
| 361 | 180.1 | Study on a simplified HS-SCCH for UMTS |  | 67d? | 2017-03-15 A | 2017-06-15 A | 100% |  |  | start no earlier than 2017-03-15 | R1 | 536h | 536h | FS_UTRA_simple_HSSCCH | 38 | gerardo.agni.medina.acosta@ericsson.com | Rel-15 | 75 | 25.709 | gerardo.agni.medina.acosta@ericsson.com |  |
| 362 | 180.2 | Core part: Simplified HS-SCCH for UMTS |  | 132d? | 2017-06-15 A | 2017-12-15 A | 100% |  |  | finish no earlier than 2017-12-15 | R6 | 1056h | 1056h | UTRA_simple_HSSCCH-Core | 39 | Ericsson | Rel-15 | 76 |  |  | RP-172306 |
| 363 | 181 | Charging for enhancement to Flexible Mobile Service Steering (eFMSS) |  | 139d? | 2017-06-05 A | 2017-12-14 A | 100% |  |  | finish no earlier than 2017-12-14 | S5 | 1112h | 1112h | eFMSS_CH | 39 | Long,Biao, China Telecom | Rel-15 | 76 | TS 32.251; TS 32.298; TS 32.299 | longb.gd@chinatelecom.cn. |  |
| 364 | 182 | Receive acoustic output test in the presence of background noise |  | 131d? | 2017-12-15 A | 2018-06-15 A | 100% |  |  | finish no earlier than 2018-06-15 | S4 | 1048h | 1048h | RAOT |  | ISBERG, Peter, Sony Mobile Communications | Rel-15 | 78 | 26.131; 26.132 | peter.isberg [at] sony.com |  |
| 365 | 183 | Speech quality in the presence of ambient noise for super-wideband and fullband modes |  | 196d? | 2017-12-15 A | 2018-09-14 | 80% | 39.2d? | 456d | finish no earlier than 2018-09-14 | S4 | 1568h | 1254.4h | SPAN |  | Reimes, Jan – HEAD acoustics GmbH | Rel-15 | 78 | 26.131 | jan.reimes@head-acoustics.de |  |
| 366 | 184 | **REST Solution Sets** |  | 520d? | 2016-09-19 A | 2018-09-14 | 89% | 59.02d? | 456d |  |  | 4144h | 3673.6h | REST_SS |  |  | Rel-15 | 78 |  |  |  |
| 367 | 184.1 | Study on a RESTful HTTP-based Solution Set |  | 322d? | 2016-09-19 A | 2017-12-12 A | 100% |  |  | finish no earlier than 2017-12-12 | S5 | 2576h | 2576h | FS_OAM_RESTFUL | 37 | Nokia: Pollakowski, Olaf | Rel-15 | 73 | 32.866 | olaf.pollakowski@nokia.com |  |
| 368 | 184.2 | REST Solution Sets (normative work) |  | 196d? | 2017-12-15 A | 2018-09-14 | 70% | 58.8d? | 456d | finish no earlier than 2018-09-14 | S5 | 1568h | 1097.6h | REST_SS |  | Pollakowski, Olaf, Nokia | Rel-15 | 78 | 32.101 | olaf.pollakowski@nokia.com |  |
| 369 | 185 | (Small) Technical Enhancements and Improvements for Rel-15 |  | 196d? | 2017-03-17 A | 2017-12-15 A | 100% |  |  | finish no earlier than 2017-12-15 |  |  |  | TEI15 | 35 |  | Rel-15 | 68 |  |  |  |
| 370 | 186 | (Small) Test Technical Enhancements and Improvements for Rel-15 |  | 196d? | 2017-03-17 A | 2017-12-15 A | 100% |  |  | finish no earlier than 2017-12-15 |  |  |  | TEI15_Test | 38 |  | Rel-15 | 75 |  |  |  |
| 371 | 187 | Release 15 Features on LTE improvements | milestone | 0d? | 2000-01-01 | 2000-01-01 |  |  | 5355d |  |  |  |  |  |  |  | Rel-15 |  |  |  |  |
| 372 | 188 | **UL data compression in LTE** |  | 4834d? | 2000-01-03 A | 2018-06-15 | 99% | 48.33d? | 521d |  | R2 | 77344h | 76047.9h | LTE_UDC | 39 | CATT | Rel-15 | 77 |  |  |  |
| 373 | 188.1 | Core part: UL data compression in LTE |  | 4834d? | 2000-01-03 A | 2018-06-15 | 99% | 48.34d? | 521d | finish no earlier than 2018-06-15 | R2 | 38672h | 38285.3h | LTE_UDC-Core | 39 | CATT | Rel-15 | 77 |  |  | RP-180231 |
| 374 | 189 | **LTE Advanced inter-band Carrier Aggregation (4DL/4UL) of Band 41C and Band 42C** |  | 130d? | 2017-09-15 A | 2018-03-15 A | 100% |  |  |  | R4 | 3120h | 3120h | LTE_CA_4DL4UL_B41_B41_B42_B42 | 39 | KDDI | Rel-15 | 77 |  |  |  |
| 375 | 189.1 | Core part:LTE Advanced inter-band Carrier Aggregation (4DL/4UL) of Band 41C and Band 42C |  | 130d? | 2017-09-15 A | 2018-03-15 A | 100% |  |  | finish no earlier than 2018-06-15 | R4 | 1040h | 1040h | LTE_CA_4DL4UL_B41_B41_B42_B42-Core | 39 | KDDI | Rel-15 | 77 | 36.715-04 |  |  |
| 376 | 189.2 | Perf. part:LTE Advanced inter-band Carrier Aggregation (4DL/4UL) of Band 41C and Band 42C |  | 130d? | 2017-09-15 A | 2018-03-15 A | 100% |  |  | finish no earlier than 2018-06-15 | R4 | 1040h | 1040h | LTE_CA_4DL4UL_B41_B41_B42_B42-Perf | 39 | KDDI | Rel-15 | 77 |  |  |  |
| 377 | 190 | **Additional LTE bands for UE category M1 and/or NB1 in Rel-15** |  | 196d? | 2017-09-15 A | 2018-06-15 | 79% | 41.24d? | 521d |  | R4 | 5752h | 4541.87h | LTE_bands_R15_M1_NB1 | 39 | Ericsson | Rel-15 | 77 |  |  |  |
| 378 | 190.1 | Core part: Additional LTE bands for UE category M1 and/or NB1 in Rel-15 |  | 196d? | 2017-09-15 A | 2018-06-15 | 99% | 1.96d? | 521d | finish no earlier than 2018-06-15 | R4 | 1568h | 1552.32h | LTE_bands_R15_M1_NB1-Core | 39 | Ericsson | Rel-15 | 77 |  |  |  |
| 379 | 190.2 | Perf. part: Additional LTE bands for UE category M1 and/or NB1 in Rel-15 |  | 196d? | 2017-09-15 A | 2018-06-15 | 99% | 1.96d? | 521d | finish no earlier than 2018-06-15 | R4 | 1568h | 1552.32h | LTE_bands_R15_M1_NB1-Perf | 39 | Ericsson | Rel-15 | 77 |  |  |  |
| 380 | 190.3 | UE Conformance Test aspects - LTE bands with UE category M1 and/or NB1 in Rel-15 |  | 131d? | 2017-12-15 A | 2018-06-15 | 19% | 106.11d? | 521d | finish no earlier than 2018-06-15 | R5 | 1048h | 199.12h | LTE_bands_R15_M1_NB1-UEConTest |  | Ericsson | Rel-15 | 78 |  |  |  |
| 381 | 191 | **Additional LTE bands for UE category M2 and/or NB2 in Rel-15** |  | 196d? | 2017-09-15 A | 2018-06-15 | 65% | 68.7d? | 521d |  | R4 | 4184h | 2717.43h | LTE_bands_R15_M2_NB2 | 39 | Ericsson | Rel-15 | 77 |  |  |  |
| 382 | 191.1 | Core part: Additional LTE bands for UE category M2 and/or NB2 in Rel-15 |  | 196d? | 2017-09-15 A | 2018-06-15 | 99% | 1.96d? | 521d | finish no earlier than 2018-06-15 | R4 | 1568h | 1552.32h | LTE_bands_R15_M2_NB2-Core | 39 | Ericsson | Rel-15 | 77 |  |  |  |
| 383 | 191.2 | UE Conformance Test aspects - LTE bands with UE category M2 and/or NB2 in Rel-15 |  | 131d? | 2017-12-15 A | 2018-06-15 | 14% | 112.66d? | 521d | finish no earlier than 2018-06-15 | R5 | 1048h | 146.72h | LTE_bands_R15_M2_NB2-UEConTest |  | Ericsson | Rel-15 | 78 |  |  |  |

Notes:
- 361: 19/6/17: Compl:0%->100%;...; 30/6/17: 25.709 added;
- 362: 11/9/17: 0%->85; 15/12/17: 85%->100; 8/1/18: WID: RP-171443->RP-172720; ...
- 363: 11/9/17: 0%->70; 15/12/17: 70%->100
- 364: 16/3/18: 0%->80; 16/3/18: FCD:03/18->06/18; 7/6/18: 80%->100
- 365: 16/3/18: 0%->50; 7/6/18: 50%->80; 7/6/18: FCD:06/18->09/18
- 367: 6/10/16: 32.866 added; 1/12/16: 0%->5; 7/6/17: 5%->45; 7/6/17: FCD:06/17->12/17; 11/9/17: 45%->80; 15/12/17: 80%->100
- 368: 16/3/18: 0%->20; 7/6/18: 20%->70; 7/6/18: FCD:06/18->09/18
- 370: Created upon demand of RAN5
- 371: -
- 373: ; 8/1/18: Compl:0%->70%; 8/1/18: CD:Mon 03/01/00->Thu 15/03/18; ...27/3/18: Compl:70%->99%27/3/1...
- 375: 15/12/17: 36.715-04 added;; 8/1/18: Compl:0%->80%27/3/18: Compl:80%->100%;...
- 376: ; 27/3/18: Compl:0%->100%; ;...
- 378: ; 8/1/18: Compl:0%->99%27/3/18: WID: RP-172077->RP-180262
- 379: ; 27/3/18: Compl:0%->99%...
- 380: tested: REL-15 WI LTE_bands_R15_M1_NB1-Core27/3/...
- 382: ; 8/1/18: Compl:0%->99%; 27/3/18: WID: RP-172078->RP-180261
- 383: tested: REL-15 WI LTE_bands_R15_M2_NB2-Core; 27/...

| ID | WBS | Task | Duration | Start | Finish | Complete | Remaining | Total slack | Constraint | Resources | Work | Actual work | Acronym | PCG approved | WI rapporteur name | Release | TSG approved | Impacted TSs and TRs | WI rapporteur e-mail | Status Report |
| --- | --- | --- | --- | --- | --- | --- | --- | --- | --- | --- | --- | --- | --- | --- | --- | --- | --- | --- | --- | --- |
| 384 | 192 | **Extended-Band12 new E-UTRA Band** | 130d? | 2017-09-15 A | 2018-03-15 A | 100% |  |  |  | R4 | 3120h | 3120h | Ext_B12_LTE | 39 | Ericsson | Rel-15 | 77 |  |  |  |
| 385 | 192.1 | Core part: Extended-Band12 new E-UTRA Band | 130d? | 2017-09-15 A | 2018-03-15 A | 100% |  |  | finish no earlier than 2018-03-15 | R4 | 1040h | 1040h | Ext_B12_LTE-Core | 39 | Ericsson | Rel-15 | 77 | 37.761 |  |  |
| 386 | 192.2 | Perf. part: Extended-Band12 new E-UTRA Band | 130d? | 2017-09-15 A | 2018-03-15 A | 100% |  |  | finish no earlier than 2018-03-15 | R4 | 1040h | 1040h | Ext_B12_LTE-Perf | 39 | Ericsson | Rel-15 | 77 |  |  |  |
| 387 | 193 | **Signalling reduction to enable light connection for LTE** | 524d? | 2016-03-15 A | 2018-03-15 | 65% | 185.92d? | 587d |  |  | 7120h | 4409.01h | LTE_LIGHT_CON | 36 | Huawei | Rel-15 | 71 |  |  |  |
| 388 | 193.1 | Core part: Signalling reduction to enable light connection for LTE | 524d? | 2016-03-15 A | 2018-03-15 | 79% | 110.04d? | 587d | finish no earlier than 2018-03-15 | R2 | 4192h | 3311.68h | LTE_LIGHT_CON-Core | 36 | Huawei | Rel-16 | 71 |  |  |  |
| 389 | 193.2 | Study on Stage 2 of LTE_LIGHT_CON | 70d? | 2017-03-10 A | 2017-06-15 | 55% | 31.5d? | 782d | finish no earlier than 2017-06-15 | S2 | 560h | 308h | FS_LTE_LIGHT_CON | 38 | Sašo Stojanovski , intel | Rel-15 | 75 | 23.723 | saso.stojanovski@intel.com |  |
| 390 | 193.3 | **Stage 3 of LTE_LIGHT_CON** | 74d? | 2016-12-01 A | 2017-03-14 | 33% | 49.33d? | 849d |  | ct | 2368h | 789.33h | LTE_LIGHT_CON-CT | 38 | Herrero Veron, Christian (Huawei) | Rel-15 | 74 |  | Christian.Herrero at huawei.com |  |
| 391 | 193.3.1 | CT1 aspects of LTE_LIGHT_CON | 74d? | 2016-12-01 | 2017-03-14 |  |  | 849d | finish no earlier than 2017-03-14 | C1 | 592h |  | LTE_LIGHT_CON-CT | 38 | Herrero Veron, Christian (Huawei) | Rel-15 | 74 | 24.008, 24.301, 29.118, 24.368, 27.007 | Christian.Herrero at huawei.com |  |
| 392 | 193.3.2 | CT4 aspects of LTE_LIGHT_CON | 74d? | 2016-12-01 | 2017-03-14 |  |  | 849d | finish no earlier than 2017-03-14 | C4 | 592h |  | LTE_LIGHT_CON-CT | 38 | Herrero Veron, Christian (Huawei) | Rel-15 | 74 | 29.274, 29.272 | Christian.Herrero at huawei.com |  |
| 393 | 193.3.3 | CT6 aspects of LTE_LIGHT_CON | 74d? | 2016-12-01 A | 2017-03-14 A | 100% |  |  | finish no earlier than 2017-03-14 | C6 | 592h | 592h | LTE_LIGHT_CON-CT | 38 | Herrero Veron, Christian (Huawei) | Rel-15 | 74 | 31.102 | Christian.Herrero at huawei.com |  |
| 394 | 194 | **Enhancements of Base Station (BS) RF and EMC requirements for Active Antenna System (AAS)** | 590d? | 2016-03-15 A | 2018-06-15 | 58% | 248.64d? | 521d |  |  | 8400h | 4860h | AASenh_BS_LTE_UTRA | 36 | Huawei | Rel-15 | 71 | 37.843 |  |  |
| 395 | 194.1 | Core part: Enhancements of Base Station (BS) RF and EMC requirements for Active Antenna System (AAS) | 460d? | 2016-03-15 A | 2017-12-15 A | 100% |  |  | finish no earlier than 2017-12-15 | R4 | 3680h | 3680h | AASenh_BS_LTE_UTRA-Core | 36 | Huawei | Rel-15 | 71 |  |  | RP-172345 |
| 396 | 194.2 | Perf. part: Enhancements of Base Station (BS) RF and EMC requirements for Active Antenna System (AAS) | 590d? | 2016-03-15 A | 2018-06-15 | 25% | 442.5d? | 521d | finish no earlier than 2018-06-15 | R4 | 4720h | 1180h | AASenh_BS_LTE_UTRA-Perf | 36 | Huawei | Rel-15 | 71 |  |  |  |
| 397 | 195 | **Shortened TTI and processing time for LTE** | 524d? | 2016-06-15 A | 2018-06-15 | 68% | 166.54d? | 521d |  |  | 7856h | 5359.2h | LTE_sTTIandPT | 37 | Ericsson | Rel-15 | 72 |  |  |  |
| 398 | 195.1 | Core part: Shortened TTI and processing time for LTE | 524d? | 2016-06-15 A | 2018-06-15 | 99% | 5.24d? | 521d | finish no earlier than 2018-06-15 | R1 | 4192h | 4150.08h | LTE_sTTIandPT-Core | 37 | Ericsson | Rel-15 | 72 |  |  | RP-172747 |
| 399 | 195.2 | Perf. part: Shortened TTI and processing time for LTE | 458d? | 2016-09-14 A | 2018-06-15 | 33% | 306.86d? | 521d | finish no earlier than 2018-06-15 | R4 | 3664h | 1209.12h | LTE_sTTIandPT-Perf | 37 | Ericsson | Rel-15 | 72 |  |  |  |
| 400 | 196 | **680073450MHz E-UTRA FDD Band for LTE PPDR and PMR/PAMR in Europe** | 326d? | 2016-12-15 A | 2018-03-15 A | 100% |  |  |  |  | 4192h | 4192h | LTE450_Europe_PPDR | 38 | Airbus | Rel-15 | 74 | 36.748 |  |  |
| 401 | 196.1 | Core part: 450MHz E-UTRA FDD Band for LTE PPDR and PMR/PAMR in Europe | 197d? | 2016-12-15 A | 2017-09-15 A | 100% |  |  | finish no earlier than 2017-09-15 | R4 | 1576h | 1576h | LTE450_Europe_PPDR-Core | 38 | Airbus | Rel-15 | 74 |  |  |  |
| 402 | 196.2 | Perf. part: 450MHz E-UTRA FDD Band for LTE PPDR and PMR/PAMR in Europe | 197d? | 2016-12-15 A | 2017-09-15 A | 100% |  |  | finish no earlier than 2017-09-15 | R4 | 1576h | 1576h | LTE450_Europe_PPDR-Perf | 38 | Airbus | Rel-15 | 74 |  |  |  |
| 403 | 196.3 | UE Conformance Test Aspects - 450MHz E-UTRA FDD Band for LTE PPDR and PMR/PAMR in Europe (Band 72) | 130d? | 2017-09-15 A | 2018-03-15 A | 100% |  |  | finish no earlier than 2018-03-15 | R5 | 1040h | 1040h | LTE450_Europe_PPDR-UEConTest | 39 | Airbus | Rel-15 | 77 |  |  |  |
| 404 | 197 | **E-UTRA 700MHz in Europe for Broadband-PPDR (Public Protection and Disaster Relief)** | 326d? | 2016-12-15 A | 2018-03-15 | 83% | 54.06d? | 587d |  |  | 3136h | 2616h | LTE700_Europe_PPDR | 38 | Airbus | Rel-15 | 74 |  |  |  |
| 405 | 197.1 | Core part: E-UTRA 700MHz in Europe for Broadband-PPDR | 197d? | 2016-12-15 A | 2017-09-15 A | 100% |  |  | finish no earlier than 2017-09-15 | R4 | 1576h | 1576h | LTE700_Europe_PPDR-Core | 38 | Airbus | Rel-15 | 74 |  |  |  |
| 406 | 197.2 | Perf. part: E-UTRA 700MHz in Europe for Broadband-PPDR | 65d? | 2016-12-15 | 2017-03-15 |  |  | 848d | finish no earlier than 2017-03-15 | R4 | 520h |  | LTE700_Europe_PPDR-Perf | 38 | Airbus | Rel-15 | 74 |  |  |  |
| 407 | 197.3 | UE Conformance Test Aspects - E-UTRA 700MHz in Europe for Broadband-PPDR | 130d? | 2017-09-15 A | 2018-03-15 A | 100% |  |  | finish no earlier than 2018-03-15 | R5 | 1040h | 1040h | LTE700_Europe_PPDR-UEConTest | 39 | Airbus | Rel-15 | 77 |  |  |  |

Notes:
- 385: 15/12/17: 37.761 added;; 8/1/18: Compl:0%->25%; ...27/3/18: Compl:25%->100%;...
- 386: ; 8/1/18: WID: RP-172111->RP-17262527/3/18: Compl:0%->100%...
- 387: no Perf. part; 14/9/17: WID:RP-160540->RP-160937; 14/9/17: WID:RP-160937->RP-171459
- 388: no Perf. part; 1/7/16: Compl:0%->10%; 1/7/16: CD:Thu 15/12/16->Wed 15/03/17; 1/7/16: WID: RP-160540->RP-16093726/9/16: Compl:10%->30%; 20/12/16: Compl:30%->75%; 20/12/16: Stat Rep: --> 21/3/17: Compl:75%->79% 21/3/17: CD:W...; ;...; ;...;...
- 389: 21/3/17: 23.723 added;; 7/6/17: 0%->55
- 391: 6/3/17: 0%->25; 11/9/17: 25%->0
- 393: 7/3/17: 0%->100
- 394: follow-up WI of REL-13 WI AAS_BS_LTE_UTRA; 14/9/17: WID:RP-160548->RP-161668
- 395: follow-up WI of REL-13 WI AAS_BS_LTE_UTRA1/7/16: Compl:0%->5%1/7/16: CD:Fri 15/09/17->Wed 15/03/1726/9/16: Compl:5%->10% 20/12/16: Compl:10%->20%21/3/17: Compl:20%->40%...;...; ;...; ;...
- 396: 1/7/16: WID: RP-160548->RP-1609401/7/16: Release: Rel-15->Rel-14; 26/9/16: WID: RP-160940->RP-161668 20/12/16: Stat Rep: -->; 21/3/17: Compl:0%->10%; ;...;...; ;...; ;...
- 398: 26/9/16: Compl:0%->5%; 20/12/16: Compl:5%->10%21/3/17: Compl:10%->30%...19/6/17: Compl:30%->65%19/6/17: CD:...; 19/9/17: Compl:65%->75%; 8/1/18: Compl:75%->99%; 8/1/18: CD:Fri 15/12/17->F...
- 399: ; 26/9/16: WID: RP-161299->RP-161922; 20/12/16: WID: RP-161922->RP-16201421/3/17: WID: RP-162014->RP-170113; 19/6/17: CD:Thu 15/03/18->Fri 15/06/18...27/3/18: Compl:0%->33%
- 400: 21/3/17: 36.748 added;
- 401: 21/3/17: Compl:0%->10%; 19/6/17: Compl:10%->75%; 19/9/17: Compl:75%->100%
- 402: 19/6/17: Compl:0%->50%19/9/17: Compl:50%->100%
- 403: ; 8/1/18: Compl:0%->77%; 27/3/18: Compl:77%->100%;...
- 405: 21/3/17: Compl:0%->25%; ...19/6/17: Compl:25%->80%; 19/9/17: Compl:80%->100%
- 406: 21/3/17: CD:Thu 15/06/17->Wed 15/03/17 ...
- 407: ; 8/1/18: Compl:0%->64%27/3/18: Compl:64%->100%; ;...

| ID | WBS | Task | Duration | Start | Finish | Complete | Remaining | Total slack | Constraint | Resources | Work | Actual work | Acronym | PCG approved | Impacted TSs and TRs | WI rapporteur name | Release | TSG approved | Status Report |
| --- | --- | --- | --- | --- | --- | --- | --- | --- | --- | --- | --- | --- | --- | --- | --- | --- | --- | --- | --- |
| 408 | 198 | **FDD operating band in the L-band for LTE** | 392d? | 2016-12-15 A | 2018-06-15 | 88% | 48.91d? | 521d |  |  | 4200h | 3676h | LTE_FDD_L_Band | 38 | 36.751 | NTT DOCOMO | Rel-15 | 74 |  |
| 409 | 198.1 | Core part: FDD operating band in the L-band for LTE | 197d? | 2016-12-15 A | 2017-09-15 A | 100% |  |  | finish no earlier than 2017-09-15 | R4 | 1576h | 1576h | LTE_FDD_L_Band-Core | 38 |  | NTT DOCOMO | Rel-15 | 74 |  |
| 410 | 198.2 | Perf. part: FDD operating band in the L-band for LTE | 197d? | 2016-12-15 A | 2017-09-15 A | 100% |  |  | finish no earlier than 2017-09-15 | R4 | 1576h | 1576h | LTE_FDD_L_Band-Perf | 38 |  | NTT DOCOMO | Rel-15 | 74 |  |
| 411 | 198.3 | UE Conformance Test Aspects - FDD operating band in the L-band for LTE | 131d? | 2017-12-15 A | 2018-06-15 | 50% | 65.5d? | 521d | finish no earlier than 2018-06-15 | R5 | 1048h | 524h | LTE_FDD_L_band-UEConTest |  |  | NTT DOCOMO | Rel-15 | 78 |  |
| 412 | 199 | **LTE Extended 1.5 GHz SDL band (1427 – 1518 MHz) and LTE Carrier Aggregation (2DL/1UL) with Band 20** | 197d? | 2016-12-15 A | 2017-09-15 A | 100% |  |  |  |  | 2624h | 2624h | LTE_SDL_1500ext | 38 | 36.934; 36.753 | Qualcomm | Rel-15 | 74 |  |
| 413 | 199.1 | Core part: LTE Extended 1.5 GHz SDL band (1427 – 1518 MHz) and LTE Carrier Aggregation (2DL/1UL) with Band 20 | 197d? | 2016-12-15 A | 2017-09-15 A | 100% |  |  | finish no earlier than 2017-09-15 | R4 | 1576h | 1576h | LTE_SDL_1500ext-Core | 38 |  | Qualcomm | Rel-15 | 74 |  |
| 414 | 199.2 | Perf. part: LTE Extended 1.5 GHz SDL band (1427 – 1518 MHz) and LTE Carrier Aggregation (2DL/1UL) with Band 20 | 131d? | 2017-03-17 A | 2017-09-15 A | 100% |  |  | finish no earlier than 2017-09-15 | R4 | 1048h | 1048h | LTE_SDL_1500ext-Perf | 38 |  | Qualcomm | Rel-15 | 74 |  |
| 415 | 200 | **Add UE Power Class 2 to band 41 intra-band contiguous LTE Carrier Aggregation** | 392d? | 2016-12-15 A | 2018-06-15 | 68% | 124.13d? | 521d |  |  | 3144h | 2148.4h | LTE_CA_C_B41_PC2 | 38 |  | Sprint | Rel-15 | 74 |  |
| 416 | 200.1 | Core part: Add UE Power Class 2 to band 41 intra-band contiguous LTE Carrier Aggregation | 262d? | 2016-12-15 A | 2017-12-15 A | 100% |  |  | finish no earlier than 2017-12-15 | R4 | 2096h | 2096h | LTE_CA_C_B41_PC2-Core | 38 |  | Sprint | Rel-15 | 74 |  |
| 417 | 200.2 | UE Conformance Test Aspects - Add UE Power Class 2 to band 41 intra-band contiguous LTE Carrier Aggregation | 131d? | 2017-12-15 A | 2018-06-15 | 5% | 124.45d? | 521d | finish no earlier than 2018-06-15 | R5 | 1048h | 52.4h | LTE_CA_C_B41_PC2-UEConTest |  |  | Sprint | Rel-15 | 78 |  |
| 418 | 201 | **Addition of Power Class 1 UE to bands B3/B20/B28 for LTE** | 262d? | 2016-09-15 A | 2017-09-15 A | 100% |  |  |  |  | 2096h | 2096h | LTE_HPUE_B3_B20_B28 | 37 |  | Motorola Solutions | Rel-15 | 73 |  |
| 419 | 201.1 | Core part: Addition of Power Class 1 UE to bands B3/B20/B28 for LTE | 262d? | 2016-09-15 A | 2017-09-15 A | 100% |  |  | finish no earlier than 2017-09-15 | R4 | 2096h | 2096h | LTE_HPUE_B3_B20_B28-Core | 37 |  | Motorola Solutions | Rel-15 | 73 |  |
| 420 | 202 | **TDD operating band in the L-band for LTE** | 197d? | 2016-12-15 A | 2017-09-15 A | 100% |  |  |  |  | 2624h | 2624h | LTE_TDD_L_Band | 38 | 36.753 | Huawei | Rel-15 | 74 |  |
| 421 | 202.1 | Core part: TDD operating band in the L-band for LTE | 197d? | 2016-12-15 A | 2017-09-15 A | 100% |  |  | finish no earlier than 2017-09-15 | R4 | 1576h | 1576h | LTE_TDD_L_Band-Core | 38 |  | Huawei | Rel-15 | 74 |  |
| 422 | 202.2 | Perf. part: TDD operating band in the L-band for LTE | 131d? | 2017-03-17 A | 2017-09-15 A | 100% |  |  | finish no earlier than 2017-09-15 | R4 | 1048h | 1048h | LTE_TDD_L_Band-Perf | 38 |  | Huawei | Rel-15 | 74 |  |
| 423 | 203 | **Further enhancements to Coordinated Multi-Point (CoMP) Operation for LTE** | 328d? | 2017-03-15 A | 2018-06-15 | 90% | 34.43d? | 521d |  | R1 | 7872h | 6321.42h | feCOMP_LTE | 38 |  | Intel | Rel-15 | 75 |  |
| 424 | 203.1 | Core part: Further enhancements to Coordinated Multi-Point (CoMP) Operation for LTE | 328d? | 2017-03-15 A | 2018-06-15 | 99% | 3.28d? | 521d | finish no earlier than 2018-06-15 | R1 | 2624h | 2597.76h | feCOMP_LTE-Core | 38 |  | Intel | Rel-15 | 75 | RP-180318 |
| 425 | 203.2 | Perf. part: Further enhancements to Coordinated Multi-Point (CoMP) Operation for LTE | 328d? | 2017-03-15 A | 2018-06-15 | 80% | 65.6d? | 521d | finish no earlier than 2018-06-15 | R4 | 2624h | 2099.2h | feCOMP_LTE-Perf | 38 |  | Intel | Rel-15 | 75 |  |
| 426 | 204 | **UE Positioning Accuracy Enhancements for LTE** | 328d? | 2017-03-15 A | 2018-06-15 | 40% | 196.8d? | 521d |  | R2 | 7872h | 3148.82h | LCS_LTE_acc_enh | 38 |  | Nokia | Rel-15 | 75 |  |
| 427 | 204.1 | Core part: UE Positioning Accuracy Enhancements for LTE | 328d? | 2017-03-15 A | 2018-06-15 | 50% | 164d? | 521d | finish no earlier than 2018-06-15 | R2 | 2624h | 1312h | LCS_LTE_acc_enh-Core | 38 |  | Nokia | Rel-15 | 75 |  |
| 428 | 204.2 | Perf. part: UE Positioning Accuracy Enhancements for LTE | 328d? | 2017-03-15 A | 2018-06-15 | 30% | 229.6d? | 521d | finish no earlier than 2018-06-15 | R4 | 2624h | 787.2h | LCS_LTE_acc_enh-Perf | 38 |  | Nokia | Rel-15 | 75 |  |
| 429 | 205 | **Enhancements for high capacity stationary wireless link and introduction of 1024 QAM for LTE DL** | 458d? | 2016-09-14 A | 2018-06-15 | 56% | 202.07d? | 521d |  | R1 | 8912h | 3780.41h | LTE_1024QAM_DL | 38 |  | Huawei | Rel-15 | 75 |  |
| 430 | 205.1 | Core part: Enhancements for high capacity stationary wireless link and introduction of 1024 QAM for LTE DL | 328d? | 2017-03-15 A | 2018-06-15 | 99% | 3.28d? | 521d | finish no earlier than 2018-06-15 | R1 | 2624h | 2597.76h | LTE_1024QAM_DL-Core | 38 | 36.783 | Huawei | Rel-15 | 75 |  |
| 431 | 205.2 | Perf. part: Enhancements for high capacity stationary wireless link and introduction of 1024 QAM for LTE DL | 458d? | 2016-09-14 A | 2018-06-15 | 25% | 343.5d? | 521d | finish no earlier than 2018-06-15 | R4 | 3664h | 916h | LTE_1024QAM_DL-Perf | 38 |  | Huawei | Rel-15 | 75 |  |

Notes:
- 408: 21/3/17: 36.751 added;
- 409: 21/3/17: Compl:0%->50%; 19/6/17: Compl:50%->99%;...; 19/9/17: Compl:99%->100%
- 410: 19/6/17: Compl:0%->99%19/6/17: CD:Thu 15/06/...19/9/17: Compl:99%->100%
- 411: tested: REL-15 WI LTE_FDD_L_Band-Core27/3/18: Compl:...
- 412: 21/3/17: 36.934 added;; 21/3/17: 36.753 added;
- 413: 21/3/17: Compl:0%->20%19/6/17: Compl:20%->50%; ;...19/9/17: Compl:50%->100%
- 414: ; 19/6/17: CD:Thu 15/06/17->Fri 15/09/17...; 19/9/17: Compl:0%->100%
- 416: 21/3/17: Compl:0%->5%; 19/6/17: Compl:5%->50%; ;...; 19/9/17: Compl:50%->90%; 8/1/18: Compl:90%->100%; ;...
- 417: tested: REL-15 WI LTE_CA_C_B41_PC2-Core; 27/3/18: Co...
- 419: ; 20/12/16: Compl:0%->15%; 20/12/16: CD:Wed 15/03/17->Thu 15/06/1721/3/17: Compl:15%->70%19/6/17: Compl:70%->99%...19/9/17: Compl:99%->100%; ;...
- 420: 21/3/17: 36.753 added;; 14/9/17: WID:RP-162557->RP-170304
- 421: 21/3/17: Compl:0%->15%; ...19/6/17: Compl:15%->70%; ...; 19/9/17: Compl:70%->100%
- 422: 21/3/17: WID: RP-162557->RP-170304; 19/6/17: CD:Thu 15/06/17->Fri 15/09/17; 19/9/17: Compl:0%->100%
- 423: follow-up WI of REL-14 SI FS_feCOMP_LTE completed at RAN #75; 14/9/17: WID:RP-170750->RP-171031
- 424: follow-up WI of REL-14 SI FS_feCOMP_LTE completed at RAN #75; 19/6/17: Compl:0%->70%; 19/6/17: CD:Fri 15/09/...; 19/9/17: Compl:70%->90%; 27/3/18: Compl:90%->99%; 27/3/18: CD:Thu 15/03/18->Fri...
- 425: follow-up WI of REL-14 SI FS_feCOMP_LTE completed at RAN #7519/6/17: WID: RP-170750->RP-171031; 8/1/18: Compl:0%->65%; 8/1/18: CD:Thu 15/03/18->Fri 15/06/1827/3/18: Compl:65%->80%27/3/...
- 426: 14/9/17: WID:RP-170813->RP-171508
- 427: ; 19/6/17: Compl:0%->10%; 19/6/17: CD:Fri 15/12/17->Fri 15/06/18...; 19/9/17: Compl:10%->20%; 8/1/18: Compl:20%->40%; 8/1/18: WID: RP-171508->RP-17231327/3/18: Compl:40%->50%
- 428: ; 19/6/17: WID: RP-170813->RP-171508; 8/1/18: Compl:0%->30%; 8/1/18: WID: RP-171508->RP-172313
- 429: 14/9/17: WID:RP-170838->RP-171067
- 430: ; 19/6/17: Compl:0%->20%; 19/6/17: CD:Sat 15/12/18->Thu 15/03/18...; 19/6/17: FCD:03/18->06/18; 12/7/17: 36.783 added;19/9/17: Compl:20%->40%; ;...; 8/1/18: Compl:40%->85%27/3/18: Compl:85%->99%
- 431: ; 19/6/17: CD:Sat 15/12/18->Fri 15/06/18; 19/6/17: WID: RP-170838->RP-171067...; 19/9/17: WID: RP-171067->RP-17173827/3/18: Compl:0%->25%

| ID | WBS | Task | Duration | Start | Finish | Complete | Remaining | Total slack | Constraint | Resources | Work | Actual work | Acronym | PCG approved | WI rapporteur name | Release | TSG approved | Status Report |
| --- | --- | --- | --- | --- | --- | --- | --- | --- | --- | --- | --- | --- | --- | --- | --- | --- | --- | --- |
| 432 | 206 | **Enhancements to LTE operation in unlicensed spectrum** | 458d? | 2017-03-15 A | 2018-12-15 | 47% | 241.57d? | 391d |  | R1 | 8384h | 2336.2h | LTE_unlic | 38 | Nokia | Rel-15 | 75 |  |
| 433 | 206.1 | Core part: Enhancements to LTE operation in unlicensed spectrum | 328d? | 2017-03-15 A | 2018-06-15 | 85% | 49.2d? | 521d | finish no earlier than 2018-06-15 | R1 | 2624h | 2230.4h | LTE_unlic-Core | 38 | Nokia | Rel-15 | 75 |  |
| 434 | 206.2 | Perf. part: Enhancements to LTE operation in unlicensed spectrum | 262d? | 2017-12-14 | 2018-12-15 |  |  | 391d | finish no earlier than 2018-12-15 | R4 | 2096h |  | LTE_unlic-Perf | 38 | Nokia | Rel-15 | 75 |  |
| 435 | 207 | **Further video enhancements for LTE** | 328d? | 2017-03-15 A | 2018-06-15 | 99% | 3.27d? | 521d |  | R2 | 5248h | 5195.59h | LTE_ViLTE_enh2 | 38 | CMCC | Rel-15 | 75 |  |
| 436 | 207.1 | Core part: Further video enhancements for LTE | 328d? | 2017-03-15 A | 2018-06-15 | 99% | 3.28d? | 521d | finish no earlier than 2018-06-15 | R2 | 2624h | 2597.76h | LTE_ViLTE_enh2-Core | 38 | CMCC | Rel-15 | 75 | RP-172381 |
| 437 | 208 | **Quality of Experience (QoE) Measurement Collection for streaming services in E-UTRAN** | 458d? | 2017-03-15 A | 2018-12-15 | 62% | 174.72d? | 391d |  | R2 | 7864h | 5195.59h | LTE_QMC_Streaming | 38 | China Unicom | Rel-15 | 75 |  |
| 438 | 208.1 | Core part:Quality of Experience (QoE) Measurement Collection for streaming services in E-UTRAN | 328d? | 2017-03-15 A | 2018-06-15 | 99% | 3.28d? | 521d | finish no earlier than 2018-06-15 | R2 | 2624h | 2597.76h | LTE_QMC_Streaming-Core | 38 | China Unicom | Rel-15 | 75 | RP-172192 |
| 439 | 208.2 | UE Conformance Test Aspects - Quality of Experience (QoE) Measurement Collection for streaming services in E-UTRAN | 197d? | 2018-03-15 | 2018-12-15 |  |  | 391d | finish no earlier than 2018-12-15 | R5 | 1576h |  | LTE_QMC_Streaming-UEConTest |  | China Unicom | Rel-15 | 79 |  |
| 440 | 209 | **Enhancing LTE CA Utilization** | 458d? | 2017-03-15 A | 2018-12-15 | 30% | 320.6d? | 391d |  | R2 | 8912h | 2099.17h | LTE_euCA | 38 | Nokia | Rel-15 | 75 |  |
| 441 | 209.1 | Core part: Enhancing LTE CA Utilization | 328d? | 2017-03-15 A | 2018-06-15 | 60% | 131.2d? | 521d | finish no earlier than 2018-06-15 | R2 | 2624h | 1574.4h | LTE_euCA-Core | 38 | Nokia | Rel-15 | 75 |  |
| 442 | 209.2 | Perf. part: Enhancing LTE CA Utilization | 328d? | 2017-09-13 | 2018-12-15 |  |  | 391d | finish no earlier than 2018-12-15 | R4 | 2624h |  | LTE_euCA-Perf | 38 | Nokia | Rel-15 | 75 |  |
| 443 | 210 | **450 MHz Band for LTE in Region 3** | 523d? | 2017-03-15 A | 2019-03-15 | 60% | 208.25d? | 326d |  | R4 | 9448h | 4748.01h | LTE450_Reg3 | 38 | China Unicom | Rel-15 | 75 |  |
| 444 | 210.1 | Core part: 450 MHz Band for LTE in Region 3 | 198d? | 2017-03-15 A | 2017-12-15 A | 100% |  |  | finish no earlier than 2017-12-15 | R4 | 1584h | 1584h | LTE450_Reg3-Core | 38 | China Unicom | Rel-15 | 75 |  |
| 445 | 210.2 | Perf. part: 450 MHz Band for LTE in Region 3 | 198d? | 2017-03-15 A | 2017-12-15 A | 100% |  |  | finish no earlier than 2017-12-15 | R4 | 1584h | 1584h | LTE450_Reg3-Perf | 38 | China Unicom | Rel-15 | 75 |  |
| 446 | 210.3 | UE Conformance Test Aspects - 450 MHz Band for LTE in Region 3 | 262d? | 2018-03-15 | 2019-03-15 |  |  | 326d | finish no earlier than 2019-03-15 | R5 | 2096h |  | LTE450_Reg3-UEConTest |  | China Unicom, Shi Yu | Rel-15 | 79 |  |
| 447 | 211 | **US 600 MHz Band for LTE** | 198d? | 2017-03-15 A | 2017-12-15 | 99% | 0d? | 0d |  | R4 | 4240h | 3720h | LTE600_US | 38 | Ericsson | Rel-15 | 75 |  |
| 448 | 211.1 | Core part: US 600 MHz Band for LTE | 133d? | 2017-03-15 A | 2017-09-15 A | 100% |  |  | finish no earlier than 2017-09-15 | R4 | 1064h | 1064h | LTE600_US-Core | 38 | Ericsson | Rel-15 | 75 |  |
| 449 | 211.2 | Perf. part: US 600 MHz Band for LTE | 133d? | 2017-03-15 A | 2017-09-15 A | 100% |  |  | finish no earlier than 2017-09-15 | R4 | 1064h | 1064h | LTE600_US-Perf | 38 | Ericsson | Rel-15 | 75 |  |
| 450 | 211.3 | UE Conformance Test Aspects - US 600 MHz Band for LTE (Band 71) | 66d? | 2017-09-15 A | 2017-12-15 A | 100% |  |  | finish no earlier than 2018-03-15 | R5 | 528h | 528h | LTE600_US-UEConTest | 39 | Dish Network | Rel-15 | 77 |  |
| 451 | 212 | **LAA/eLAA for the CBRS 3.5GHz band in the United States** | 198d? | 2017-03-15 A | 2017-12-15 A | 100% |  |  |  | R4 | 4752h | 4752h | LTE_3550_CBRS_US_LAA | 38 | AT&T | Rel-15 | 75 |  |
| 452 | 212.1 | Core part: LAA/eLAA for the CBRS 3.5GHz band in the United States | 198d? | 2017-03-15 A | 2017-12-15 A | 100% |  |  | start no earlier than 2017-03-15 | R4 | 1584h | 1584h | LTE_3550_CBRS_US_LAA-Core | 38 | AT&T | Rel-15 | 75 |  |
| 453 | 212.2 | Perf. part: LAA/eLAA for the CBRS 3.5GHz band in the United States | 198d? | 2017-03-15 A | 2017-12-15 A | 100% |  |  | start no earlier than 2017-03-15 | R4 | 1584h | 1584h | LTE_3550_CBRS_US_LAA-Perf | 38 | AT&T | Rel-15 | 75 |  |
| 454 | 213 | **Introduction new band support for 4Rx antenna ports for LTE for REL-15** | 262d? | 2017-06-15 A | 2018-06-15 | 45% | 144.1d? | 521d |  | R4 | 6288h | 2829.61h | LTE_4Rx_AP_DL_bands_R15 | 39 | Huawei | Rel-15 | 76 |  |
| 455 | 213.1 | Core part: Introduction new band support for 4Rx antenna ports for LTE for REL-15 | 262d? | 2017-06-15 A | 2018-06-15 | 90% | 26.2d? | 521d | finish no earlier than 2018-06-15 | R4 | 2096h | 1886.4h | LTE_4Rx_AP_DL_bands_R15-Core | 39 | Huawei | Rel-15 | 76 |  |
| 456 | 213.2 | Perf. part: Introduction new band support for 4Rx antenna ports for LTE for REL-15 | 262d? | 2017-06-15 | 2018-06-15 |  |  | 521d | finish no earlier than 2018-06-15 | R4 | 2096h |  | LTE_4Rx_AP_DL_bands_R15-Perf | 39 | Huawei | Rel-15 | 76 |  |

Notes:
- 432: note: The is actually a further LAA enhancement
- 433: note: The is actually a further LAA enhancement; 19/6/17: Compl:0%->15%; 19/6/17: CD:Fri 15...; 19/9/17: Compl:15%->30%; 8/1/18: Compl:30%->65%; ...; 27/3/18: Compl:65%->85%...; 27/3/18: 37.107 added; / Impacted TSs and TRs: 37.107; 37.106
- 434: 19/6/17: CD:Thu 15/03/18->Sat 15/12/18; 8/1/18: WID: RP-170848->RP-17284127/3/18: WID: RP-172841->RP-180402
- 435: no Perf. part; compare REL-14 WI LTE_VoLTE_ViLTE_enh
- 436: no Perf. part; compare REL-14 WI LTE_VoLTE_ViLTE_enh19/6/17: Compl:0%->15%19/6/17: W...; 19/9/17: Compl:15%->35%; 8/1/18: Compl:35%->99%; ...
- 437: compare REL-14 WI UMTS_QMC_Streaming-Core
- 438: compare REL-14 WI UMTS_QMC_Streaming-Core; 19/6/17: Compl:0%->25%; 19/6/17: WID: RP-...; 19/9/17: Compl:25%->45%; 8/1/18: Compl:45%->99%; ...
- 439: tested: REL-15 WI LTE_QMC_Streaming-Core; WI code to be used: LTE_QMC_Streaming-UEConTest
- 441: 19/9/17: Compl:0%->22%; 8/1/18: Compl:22%->40%; 16/3/18: FCD:12/17->06/1827/3/18: Compl:40%->60%27/3/18: WID: RP-170805->RP-180561
- 442: 16/3/18: FCD:12/17->12/18; 27/3/18: WID: RP-170805->RP-180561
- 443: 14/9/17: WID:RP-170159->RP-170952
- 444: ; 19/6/17: Compl:0%->30%; 19...; 12/7/17: 36.759 added;; 19/9/17: Compl:30%->80%; 8/1/18: Compl:80%->100% / Impacted TSs and TRs: 36.759
- 445: ; 19/6/17: WID: RP-170159->RP-170952; 8/1/18: Compl:0%->100%
- 446: Impacted TSs and TRs: 34.121-1; 36.508; 36.521-1; 36.521-2; 36.521-3; 36.523-2; 36.523-3; 37.571-1; 36.905
- 448: ; 19/6/17: Compl:0%->95%; 19...; 12/7/17: 36.755 added;19/9/17: Compl:95%->100% / Impacted TSs and TRs: 36.755
- 449: ; 19/6/17: Compl:0%->95%; 19...; 19/9/17: Compl:95%->100%
- 450: ; 8/1/18: Compl:0%->100%; ...
- 451: compare REL-14 WI LTE_TDD_3550_CBRS_US; related to LTE band 48, intending a new band definition; includes 2DL/2UL CA with B2 Acronym changed, was "LTE_TDD_3550_CBRS_US_LAA"
- 452: compare REL-14 WI LTE_TDD_3550_CBRS_US; related to LTE band 48, intending a new band definition; includes 2DL/2UL CA with B2;19/6/17: Com; Acronym changed, was "LTE_TDD_3550_CBRS_US_LAA-Core"; 12/7/17: 36.790 added;;...; ;... / Impacted TSs and TRs: 36.790
- 453: compare REL-14 WI LTE_TDD_3550_CBRS_US; related to LTE band 48, intending a new band definition; includes 2DL/2UL CA with B2; 19/6/17: C…; Acronym changed, was "LTE_TDD_3550_CBRS_US_LAA-Perf";...; ;...
- 455: 19/9/17: Compl:0%->99%; 8/1/18: WID: RP-171131->RP-17234727/3/18: Compl:99%->90%...
- 456: ; 8/1/18: WID: RP-171131->RP-172347; 27/3/18: WID: RP-172347->RP-180073

| ID | WBS | Task | Duration | Start | Finish | Complete | Remaining | Total slack | Constraint | Resources | Work | Actual work | Acronym | PCG approved | WI rapporteur name | Release | TSG approved | Impacted TSs and TRs |
| --- | --- | --- | --- | --- | --- | --- | --- | --- | --- | --- | --- | --- | --- | --- | --- | --- | --- | --- |
| 457 | 214 | **Addition of band 28 and 40 to LTE MTC cat.0** | 67d? | 2017-06-15 A | 2017-09-15 A | 100% |  |  |  | R4 | 1072h | 1072h | LC_MTC_LTE_cat0_B28_B40 | 39 | Huawei | Rel-15 | 76 |  |
| 458 | 214.1 | Core part: Addition of band 28 and 40 to LTE MTC cat.0 | 67d? | 2017-06-15 A | 2017-09-15 A | 100% |  |  | finish no earlier than 2017-09-15 | R4 | 536h | 536h | LC_MTC_LTE_cat0_B28_B40-Core | 39 | Huawei | Rel-15 | 76 |  |
| 459 | 215 | **LTE Advanced high power TDD UE (power class 2) for Rel-15** | 262d? | 2017-06-15 A | 2018-06-15 | 99% | 2.6d? | 521d |  | R4 | 4192h | 4150.2h | LTE_TDD_HPUE_R15 | 39 | Huawei | Rel-15 | 76 |  |
| 460 | 215.1 | Core part: LTE Advanced high power TDD UE (power class 2) for Rel-15 | 262d? | 2017-06-15 A | 2018-06-15 | 99% | 2.62d? | 521d | finish no earlier than 2018-06-15 | R4 | 2096h | 2075.04h | LTE_TDD_HPUE_R15-Core | 39 | Huawei | Rel-15 | 76 | 36.760 |
| 461 | 216 | **New LTE band for 3.3-3.4 GHz for Africa** | 196d? | 2017-06-15 A | 2018-03-15 A | 100% |  |  |  | R4 | 4704h | 4704h | LTE_TDD_3300_Africa | 39 | Huawei | Rel-15 | 76 |  |
| 462 | 216.1 | Core part: New LTE band for 3.3-3.4 GHz for Africa | 196d? | 2017-06-15 A | 2018-03-15 A | 100% |  |  | finish no earlier than 2018-03-15 | R4 | 1568h | 1568h | LTE_TDD_3300_Africa-Core | 39 | Huawei | Rel-15 | 76 | 36.758 |
| 463 | 216.2 | Perf. part: New LTE band for 3.3-3.4 GHz for Africa | 196d? | 2017-06-15 A | 2018-03-15 A | 100% |  |  | finish no earlier than 2018-03-15 | R4 | 1568h | 1568h | LTE_TDD_3300_Africa-Perf | 39 | Huawei | Rel-15 | 76 |  |
| 464 | 217 | **UE requirements for network-based CRS interference mitigation for LTE** | 392d? | 2017-06-15 A | 2018-12-15 | 28% | 282.07d? | 391d |  | R4 | 8368h | 2346.63h | LTE_NW_CRS_IM | 39 | Ericsson | Rel-15 | 76 |  |
| 465 | 217.1 | Core part: UE requirements for network-based CRS interference mitigation for LTE | 262d? | 2017-06-15 A | 2018-06-15 | 70% | 78.6d? | 521d | finish no earlier than 2018-06-15 | R4 | 2096h | 1467.2h | LTE_NW_CRS_IM-Core | 39 | Ericsson | Rel-15 | 76 |  |
| 466 | 217.2 | Perf. part: UE requirements for network-based CRS interference mitigation for LTE | 392d? | 2017-06-15 | 2018-12-15 |  |  | 391d | finish no earlier than 2018-12-15 | R4 | 3136h |  | LTE_NW_CRS_IM-Perf | 39 | Ericsson | Rel-15 | 76 |  |
| 467 | 218 | **Bluetooth/WLAN measurement collection in LTE Minimization of Drive Tests (MDT)** | 131d? | 2017-12-15 A | 2018-06-15 | 30% | 91.7d? | 521d |  | R2 | 2096h | 628.78h | LTE_MDT_BT_WLAN |  | CMCC | Rel-15 | 78 |  |
| 468 | 218.1 | Core part: Bluetooth/WLAN measurement collection in LTE Minimization of Drive Tests (MDT) | 131d? | 2017-12-15 A | 2018-06-15 | 30% | 91.7d? | 521d | finish no earlier than 2018-06-15 | R2 | 1048h | 314.4h | LTE_MDT_BT_WLAN-Core |  | CMCC | Rel-15 | 78 |  |
| 469 | 219 | **Enhanced LTE Support for Aerial Vehicles** | 328d? | 2017-03-15 A | 2018-06-15 | 66% | 111d? | 521d |  | R2 | 5256h | 3477.18h | LTE_Aerial |  | Ericsson | Rel-15 | 78 |  |
| 470 | 219.1 | Study on enhanced LTE Support for Aerial Vehicles | 198d? | 2017-03-15 A | 2017-12-15 A | 100% |  |  | finish no earlier than 2017-12-15 | R2 | 1584h | 1584h | FS_LTE_Aerial | 38 | NTT DOCOMO | Rel-15 | 75 | 36.777 |
| 471 | 219.2 | Core part: Enhanced LTE Support for Aerial Vehicles | 131d? | 2017-12-15 A | 2018-06-15 | 15% | 111.35d? | 521d | finish no earlier than 2018-06-15 | R2 | 1048h | 157.2h | LTE_Aerial-Core |  | Ericsson | Rel-15 | 78 |  |
| 472 | 220 | **Separation of CP and UP for Split Option 2 of NR** | 131d? | 2017-12-15 A | 2018-06-15 | 30% | 91.7d? | 521d |  | R3 | 2096h | 628.78h | NR_CPUP_Split |  | Ericsson | Rel-15 | 78 |  |
| 473 | 220.1 | Core part: Separation of CP and UP for Split Option 2 of NR | 131d? | 2017-12-15 A | 2018-06-15 | 30% | 91.7d? | 521d | finish no earlier than 2018-06-15 | R3 | 1048h | 314.4h | NR_CPUP_Split-Core |  | Ericsson | Rel-15 | 78 |  |
| 474 | 221 | **UE requirements for LTE DL 8Rx antenna ports** | 261d? | 2017-12-15 A | 2018-12-15 | 13% | 226.11d? | 391d |  | R4 | 5224h | 698.3h | LTE_8Rx_AP_DL |  | Huawei | Rel-15 | 78 |  |
| 475 | 221.1 | Core part: UE requirements for LTE DL 8Rx antenna ports | 131d? | 2017-12-15 A | 2018-06-15 | 40% | 78.6d? | 521d | finish no earlier than 2018-06-15 | R4 | 1048h | 419.2h | LTE_8Rx_AP_DL-Core |  | Huawei | Rel-15 | 78 |  |
| 476 | 221.2 | Perf. part: UE requirements for LTE DL 8Rx antenna ports | 261d? | 2017-12-15 | 2018-12-15 |  |  | 391d | finish no earlier than 2018-12-15 | R4 | 2088h |  | LTE_8Rx_AP_DL-Perf |  | Huawei | Rel-15 | 78 |  |
| 477 | 222 | **ProSe Support for Band 72 in LTE** | 1d? | 2017-12-15 | 2017-12-15 |  |  | 651d |  | R4 | 16h |  | LTE450_B72_Europe_ProSe |  | Airbus | Rel-15 | 78 |  |
| 478 | 222.1 | Core part: ProSe Support for Band 72 in LTE | 1d? | 2017-12-15 | 2017-12-15 |  |  | 651d | finish no earlier than 2017-12-15 | R4 | 8h |  | LTE450_B72_Europe_ProSe-Core |  | Airbus | Rel-15 | 78 |  |
| 479 | 223 | **LTE Advanced inter-band Carrier Aggregation Rel-15 for xDL/1UL with x>5** | 131d? | 2017-12-15 A | 2018-06-15 | 5% | 124.46d? | 521d |  | R4 | 3144h | 174.49h | LTE_CA_R15_xDL1UL |  | Qualcomm | Rel-15 | 78 |  |
| 480 | 223.1 | Core part:LTE Advanced inter-band Carrier Aggregation Rel-15 for xDL/1UL with x>5 | 131d? | 2017-12-15 A | 2018-06-15 | 10% | 117.9d? | 521d | finish no earlier than 2018-06-15 | R4 | 1048h | 104.8h | LTE_CA_R15_xDL1UL-Core |  | Qualcomm | Rel-15 | 78 | 36.715-00-01 |
| 481 | 223.2 | Perf. part:LTE Advanced inter-band Carrier Aggregation Rel-15 for xDL/1UL with x>5 | 131d? | 2017-12-15 | 2018-06-15 |  |  | 521d | finish no earlier than 2018-06-15 | R4 | 1048h |  | LTE_CA_R15_xDL1UL-Perf |  | Qualcomm | Rel-15 | 78 |  |

Notes:
- 458: 19/9/17: Compl:0%->100%
- 460: 19/9/17: Compl:0%->10%; ...; 15/12/17: 36.760 added;; 8/1/18: Compl:10%->40%27/3/18: Compl:40%->99%
- 462: 12/7/17: 36.758 added;19/9/17: Compl:0%->10%; ...; 8/1/18: Compl:10%->70%27/3/18: Compl:70%->100%;...
- 463: ; 19/9/17: WID: RP-171506->RP-171759; 27/3/18: Compl:0%->100%;...
- 465: ; 19/9/17: Compl:0%->15%; 8/1/18: Compl:15%->50%27/3/18: Compl:50%->70%
- 467: MDT = Minimization of Drive Tests; no Perf. part; may have SA5 impact
- 468: MDT = Minimization of Drive Tests; no Perf. part; may have SA5 impact27/3/18: Compl:0%->30%2...
- 469: follow-up WI of REL-15 SI FS_LTE_Aerial; no Perf. part
- 470: TR 36.7XX19/6/17: Compl:0%->15%;...; 30/6/17: 36.777 added;; 19/9/17: Compl:15%->30%; 8/1/18: Compl:30%->100%
- 471: follow-up WI of REL-15 SI FS_LTE_Aerial; no Perf. part; 27/3/18: Compl:0%->15%
- 472: follow-up WI of REL-15 SI FS_NR_CPUP_Split; introduction of E1 interface
- 473: follow-up WI of REL-15 SI FS_NR_CPUP_Split; introduction of E1 interface. 30/1/18: acronym updated27/3/18: Compl:0%->30%27/3/18: WID: RP-172831->RP-180326
- 474: follow-up WI of REL-15 SI FS_LTE_8Rx_AP_DL
- 475: follow-up WI of REL-15 SI FS_LTE_8Rx_AP_DL27/3/18: Compl:0%->40%
- 476: follow-up WI of REL-15 SI FS_LTE_8Rx_AP_DL
- 477: This WI was opened, a RAN4 CR RP-172572 was approved and the WI was completed all at RAN #78; compare REL-15 WI LTE450_Europe_PPDR-Core
- 478: This WI was opened, a RAN4 CR RP-172572 was approved and the WI was completed all at RAN #78; compare REL-15 WI LTE450_Europe_PPDR-Core
- 479: basket CA WI; TR 36.715-00-01
- 480: basket CA WI; TR 36.715-00-01; 27/3/18: Compl:0%->10%;...; 27/3/18: 36.715-00-01 added;
- 481: basket CA WI27/3/18: CD:Sat 15/12/18->Fri 15/06/18...

| ID | WBS | Task | Duration | Start | Finish | Complete | Remaining | Total slack | Constraint | Resources | Work | Actual work | Acronym | PCG approved | WI rapporteur name | Release | TSG approved | Impacted TSs and TRs |
| --- | --- | --- | --- | --- | --- | --- | --- | --- | --- | --- | --- | --- | --- | --- | --- | --- | --- | --- |
| 482 | 224 | **Performance requirements of interference cancellation receiver for LTE BS** | 67d? | 2017-06-15 A | 2017-09-15 A | 100% |  |  |  | R4 | 1072h | 1072h | LTE_IC_BS | 39 | China Telecom | Rel-15 | 76 |  |
| 483 | 224.1 | Perf. part: Performance requirements of interference cancellation receiver for LTE BS | 67d? | 2017-06-15 A | 2017-09-15 A | 100% |  |  | finish no earlier than 2017-09-15 | R4 | 536h | 536h | LTE_IC_BS-Perf | 39 | China Telecom | Rel-15 | 76 |  |
| 484 | 225 | **LTE CRS-Interference Mitigation performance requirements for single RX chain UEs** | 262d? | 2017-06-15 A | 2018-06-15 | 85% | 39.29d? | 521d |  | R4 | 4192h | 3563.24h | LTE_1RX_CRS_IM | 39 | Intel | Rel-15 | 76 |  |
| 485 | 225.1 | Perf. part: LTE CRS-Interference Mitigation performance requirements for single RX chain UEs | 262d? | 2017-06-15 A | 2018-06-15 | 85% | 39.3d? | 521d | finish no earlier than 2018-06-15 | R4 | 2096h | 1781.6h | LTE_1RX_CRS_IM-Perf | 39 | Intel | Rel-15 | 76 |  |
| 486 | 226 | **LTE Advanced intra-band Carrier Aggregation Rel-15 for xDL/yUL including contiguous and non-contiguous spectrum** | 262d? | 2017-06-15 A | 2018-06-15 | 67% | 86.47d? | 521d |  | R4 | 6288h | 3462.64h | LTE_CA_R15_intra | 39 | Ericsson | Rel-15 | 76 |  |
| 487 | 226.1 | Core part: LTE Advanced intra-band Carrier Aggregation Rel-15 for xDL/yUL including contiguous and non-contiguous spectrum | 262d? | 2017-06-15 A | 2018-06-15 | 67% | 86.46d? | 521d | finish no earlier than 2018-06-15 | R4 | 2096h | 1404.32h | LTE_CA_R15_intra-Core | 39 | Ericsson | Rel-15 | 76 | 36.715-00-00 |
| 488 | 226.2 | Perf. part: LTE Advanced intra-band Carrier Aggregation Rel-15 for xDL/yUL including contiguous and non-contiguous spectrum | 262d? | 2017-06-15 A | 2018-06-15 | 67% | 86.46d? | 521d | finish no earlier than 2018-06-15 | R4 | 2096h | 1404.32h | LTE_CA_R15_intra-Perf | 39 | Ericsson | Rel-15 | 76 |  |
| 489 | 227 | **LTE Advanced inter-band Carrier Aggregation Rel-15 for 2DL/1UL** | 262d? | 2017-06-15 A | 2018-06-15 | 40% | 157.2d? | 521d |  | R4 | 6288h | 2515.2h | LTE_CA_R15_2DL1UL | 39 | Qualcomm | Rel-15 | 76 |  |
| 490 | 227.1 | Core part:LTE Advanced inter-band Carrier Aggregation Rel-15 for 2DL/1UL | 262d? | 2017-06-15 A | 2018-06-15 | 40% | 157.2d? | 521d | finish no earlier than 2018-06-15 | R4 | 2096h | 838.4h | LTE_CA_R15_2DL1UL-Core | 39 | Qualcomm | Rel-15 | 76 | 36.715-02-01 |
| 491 | 227.2 | Perf. part:LTE Advanced inter-band Carrier Aggregation Rel-15 for 2DL/1UL | 262d? | 2017-06-15 A | 2018-06-15 | 40% | 157.2d? | 521d | finish no earlier than 2018-06-15 | R4 | 2096h | 838.4h | LTE_CA_R15_2DL1UL-Perf | 39 | Qualcomm | Rel-15 | 76 |  |
| 492 | 228 | **LTE Advanced inter-band Carrier Aggregation Rel-15 for 3DL/1UL** | 262d? | 2017-06-15 A | 2018-06-15 | 65% | 91.69d? | 521d |  | R4 | 6288h | 4087.24h | LTE_CA_R15_3DL1UL | 39 | Huawei | Rel-15 | 76 |  |
| 493 | 228.1 | Core part:LTE Advanced inter-band Carrier Aggregation Rel-15 for 3DL/1UL | 262d? | 2017-06-15 A | 2018-06-15 | 65% | 91.7d? | 521d | finish no earlier than 2018-06-15 | R4 | 2096h | 1362.4h | LTE_CA_R15_3DL1UL-Core | 39 | Huawei | Rel-15 | 76 | 36.715-03-01 |
| 494 | 228.2 | Perf. part:LTE Advanced inter-band Carrier Aggregation Rel-15 for 3DL/1UL | 262d? | 2017-06-15 A | 2018-06-15 | 65% | 91.7d? | 521d | finish no earlier than 2018-06-15 | R4 | 2096h | 1362.4h | LTE_CA_R15_3DL1UL-Perf | 39 | Huawei | Rel-15 | 76 |  |
| 495 | 229 | **LTE Advanced inter-band Carrier Aggregation Rel-15 for 4DL/1UL** | 262d? | 2017-06-15 A | 2018-06-15 | 63% | 96.95d? | 521d |  | R4 | 6288h | 4053.62h | LTE_CA_R15_4DL1UL | 39 | Ericsson | Rel-15 | 76 |  |
| 496 | 229.1 | Core part:LTE Advanced inter-band Carrier Aggregation Rel-15 for 4DL/1UL | 262d? | 2017-06-15 A | 2018-06-15 | 63% | 96.94d? | 521d | finish no earlier than 2018-06-15 | R4 | 2096h | 1320.48h | LTE_CA_R15_4DL1UL-Core | 39 | Ericsson | Rel-15 | 76 | 36.715-04-01 |
| 497 | 229.2 | Perf. part:LTE Advanced inter-band Carrier Aggregation Rel-15 for 4DL/1UL | 262d? | 2017-06-15 A | 2018-06-15 | 63% | 96.94d? | 521d | finish no earlier than 2018-06-15 | R4 | 2096h | 1320.48h | LTE_CA_R15_4DL1UL-Perf | 39 | Ericsson | Rel-15 | 76 |  |
| 498 | 230 | **LTE Advanced inter-band Carrier Aggregation Rel-15 for 5DL/1UL** | 262d? | 2017-06-15 A | 2018-06-15 | 75% | 65.5d? | 521d |  | R4 | 6288h | 3667.2h | LTE_CA_R15_5DL1UL | 39 | Nokia | Rel-15 | 76 |  |
| 499 | 230.1 | Core part:LTE Advanced inter-band Carrier Aggregation Rel-15 for 5DL/1UL | 262d? | 2017-06-15 A | 2018-06-15 | 75% | 65.5d? | 521d | finish no earlier than 2018-06-15 | R4 | 2096h | 1572h | LTE_CA_R15_5DL1UL-Core | 39 | Nokia | Rel-15 | 76 | 36.715-05-01 |
| 500 | 230.2 | Perf. part:LTE Advanced inter-band Carrier Aggregation Rel-15 for 5DL/1UL | 262d? | 2017-06-15 A | 2018-06-15 | 75% | 65.5d? | 521d | finish no earlier than 2018-06-15 | R4 | 2096h | 1572h | LTE_CA_R15_5DL1UL-Perf | 39 | Nokia | Rel-15 | 76 |  |
| 501 | 231 | **LTE Advanced inter-band Carrier Aggregation Rel-15 for 2DL/2UL** | 262d? | 2017-06-15 A | 2018-06-15 | 60% | 104.8d? | 521d |  | R4 | 6288h | 3772.8h | LTE_CA_R15_2DL2UL | 39 | Huawei | Rel-15 | 76 |  |
| 502 | 231.1 | Core part:LTE Advanced inter-band Carrier Aggregation Rel-15 for 2DL/2UL | 262d? | 2017-06-15 A | 2018-06-15 | 60% | 104.8d? | 521d | finish no earlier than 2018-06-15 | R4 | 2096h | 1257.6h | LTE_CA_R15_2DL2UL-Core | 39 | Huawei | Rel-15 | 76 | 36.715-02-02 |
| 503 | 231.2 | Perf. part:LTE Advanced inter-band Carrier Aggregation Rel-15 for 2DL/2UL | 262d? | 2017-06-15 A | 2018-06-15 | 60% | 104.8d? | 521d | finish no earlier than 2018-06-15 | R4 | 2096h | 1257.6h | LTE_CA_R15_2DL2UL-Perf | 39 | Huawei | Rel-15 | 76 |  |
| 504 | 232 | **LTE Advanced inter-band Carrier Aggregation Rel-15 for xDL/2UL with x=3,4,5** | 262d? | 2017-06-15 A | 2018-06-15 | 80% | 52.4d? | 521d |  | R4 | 6288h | 3586.32h | LTE_CA_R15_xDL2UL | 39 | LG Electronics | Rel-15 | 76 |  |
| 505 | 232.1 | Core part:LTE Advanced inter-band Carrier Aggregation Rel-15 for xDL/2UL with x=3,4,5 | 262d? | 2017-06-15 A | 2018-06-15 | 80% | 52.4d? | 521d | finish no earlier than 2018-06-15 | R4 | 2096h | 1676.8h | LTE_CA_R15_xDL2UL-Core | 39 | LG Electronics | Rel-15 | 76 | 36.715-00-02 |
| 506 | 232.2 | Perf. part:LTE Advanced inter-band Carrier Aggregation Rel-15 for xDL/2UL with x=3,4,5 | 262d? | 2017-06-15 A | 2018-06-15 | 80% | 52.4d? | 521d | finish no earlier than 2018-06-15 | R4 | 2096h | 1676.8h | LTE_CA_R15_xDL2UL-Perf | 39 | LG Electronics | Rel-15 | 76 |  |
| 507 | 233 | UE Conformance Test Aspects – Rel-15 CA configurations | 456d? | 2017-09-15 A | 2019-06-15 | 8% | 419.52d? | 261d | finish no earlier than 2019-06-15 | R5 | 3648h | 291.84h | LTE_CA_R15-UEConTest | 39 | Ericsson | Rel-15 | 77 |  |

Notes:
- 483: ; 19/9/17: Compl:0%->100%
- 485: ; 19/9/17: Compl:0%->20%; 19/9/17: WID: RP-171465->RP-171831; 8/1/18: Compl:20%->60%; 27/3/18: Compl:60%->85%;...
- 487: 12/7/17: 36.715-00-00 added;; 19/9/17: Compl:0%->25%...; 8/1/18: Compl:25%->70%; ;...27/3/18: Compl:70%->67%; ...
- 488: 19/9/17: Compl:0%->25%; ...; 8/1/18: Compl:25%->70%; 8/1/18:...27/3/18: Compl:70%->67%; ...
- 490: 12/7/17: 36.715-02-01 added;19/9/17: Compl:0%->20%; ...; 8/1/18: Compl:20%->30%; ;...; 27/3/18: Compl:30%->40%; ...
- 491: ; 19/9/17: Compl:0%->20%...; 8/1/18: Compl:20%->30%; ;...27/3/18: Compl:30%->40%...
- 493: 12/7/17: 36.715-03-01 added;; 19/9/17: Compl:0%->20%; ...; 8/1/18: Compl:20%->40%; ;...; 27/3/18: Compl:40%->65%; ...
- 494: ; 19/9/17: Compl:0%->20%; ...; 8/1/18: Compl:20%->40%; ;...27/3/18: Compl:40%->65%; ...
- 496: 12/7/17: 36.715-04-01 added;; 19/9/17: Compl:0%->54%...; 8/1/18: Compl:54%->65%; ;...27/3/18: Compl:65%->63%...
- 497: 19/9/17: Compl:0%->54%; ...; 8/1/18: Compl:54%->65%; ;...; 27/3/18: Compl:65%->63%...
- 499: 12/7/17: 36.715-05-01 added;19/9/17: Compl:0%->20%; ...; 8/1/18: Compl:20%->50%; ;...27/3/18: Compl:50%->75%...
- 500: ; 19/9/17: Compl:0%->20%...; 8/1/18: Compl:20%->50%; ;...; 27/3/18: Compl:50%->75%; ...
- 502: 12/7/17: 36.715-02-02 added;; 19/9/17: Compl:0%->20%; ...; 8/1/18: Compl:20%->40%; ;...27/3/18: Compl:40%->60%
- 503: ; 19/9/17: Compl:0%->20%; ...; 8/1/18: Compl:20%->40%; ;...27/3/18: Compl:40%->60%
- 505: 12/7/17: 36.715-00-02 added;; 19/9/17: Compl:0%->20%...; 8/1/18: Compl:20%->50%; ;...; 27/3/18: Compl:50%->80%; ...
- 506: 19/9/17: CD:Sat 15/09/18->Fri 15/06/18; ...; 8/1/18: Compl:0%->50%; ...27/3/18: Compl:50%->80%...
- 507: ; 8/1/18: Compl:0%->7%; ...27/3/18: Compl:7%->8%...

| ID | WBS | Task | Type | Duration | Start | Finish | Complete | Remaining | Baseline start | Baseline finish | Baseline duration | Total slack | Constraint | Resources | Work | Actual work | Acronym | PCG approved | Impacted TSs and TRs | WI rapporteur name | WI rapporteur e-mail | Release | TSG approved | MCC resp | Acronym_3GU_Export | Status Report |
| --- | --- | --- | --- | --- | --- | --- | --- | --- | --- | --- | --- | --- | --- | --- | --- | --- | --- | --- | --- | --- | --- | --- | --- | --- | --- | --- |
| 508 | 234 | **LTE UE Total Radiated Power (TRP) and Total Radiated Sensitivity (TRS) and UTRA Hand Phantom related UE TRP and TRS Requirements** |  | 1315d? | 2012-12-15 A | 2017-12-15 | 82% | 237.87d? | 2013-03-15 | 2015-06-12 | 591d? | 651d |  |  | 17816h | 14593.1h | LTE_UTRA_TRP_TRS | 30 | UTRA, LTE | Nokia | petri.j.vasenkari@nokia.com | Rel-15 | 58 | Issam | LTE_UTRA_TRP_TRS |  |
| 509 | 234.1 | Core part: LTE UE TRP and TRS and UTRA Hand Phantom related UE TRP and TRS Requirements |  | 1244d? | 2012-12-15 A | 2017-12-15 | 85% | 186.6d? | 2013-03-15 | 2014-09-12 | 393d? | 651d | finish no earlier than 2017-12-15 | R4 | 9952h | 8459.2h | LTE_UTRA_TRP_TRS-Core | 30 | 25.144, New TS 37.144 | Nokia | petri.j.vasenkari@nokia.com | Rel-15 | 58 | Issam | LTE_UTRA_TRP_TRS-Core |  |
| 510 | 234.2 | Test part: LTE UE TRP and TRS and UTRA Hand Phantom |  | 983d? | 2014-03-15 A | 2017-12-15 | 78% | 216.26d? | 2014-03-06 | 2015-06-12 | 332d? | 651d | finish no earlier than 2017-12-15 | R5 | 7864h | 6133.92h | LTE_UTRA_TRP_TRS-UEConTest | 32 | New TS 37.544 | ZTE | TAYLOR Carolyn (carolyn.tayl@zte.com.cn) | Rel-15 | 63 | Ingbert | LTE_UTRA_TRP_TRS-UEConTest |  |
| 511 | 235 | **Further enhancements for Extended Coverage GSM for support of Cellular Internet of Things** |  | 67d? | 2018-03-15 | 2018-06-15 |  |  |  |  |  | 521d |  | R6 | 1608h |  | CIoT_EC_GSM_fenh |  |  | Nokia |  | Rel-15 | 79 |  |  |  |
| 512 | 235.1 | Core part: Further enhancements for Extended Coverage GSM for support of Cellular Internet of Things |  | 67d? | 2018-03-15 | 2018-06-15 |  |  |  |  |  | 521d | finish no earlier than 2018-06-15 | R6 | 536h |  | CIoT_EC_GSM_fenh-Core |  |  | Nokia |  | Rel-15 | 79 |  |  |  |
| 513 | 235.2 | Perf. part: Further enhancements for Extended Coverage GSM for support of Cellular Internet of Things |  | 67d? | 2018-03-15 | 2018-06-15 |  |  |  |  |  | 521d | finish no earlier than 2018-06-15 | R6 | 536h |  | CIoT_EC_GSM_fenh-Perf |  |  | Nokia |  | Rel-15 | 79 |  |  |  |
| 514 | 236 | **eNB(s) Architecture Evolution for E-UTRAN and NG-RAN** |  | 67d? | 2018-03-15 | 2018-06-15 |  |  |  |  |  | 521d |  | R3 | 1072h |  | LTE_NR_arch_evo |  |  | China Unicom |  | Rel-15 | 79 |  |  |  |
| 515 | 236.1 | Core part: eNB(s) Architecture Evolution for E-UTRAN and NG-RAN |  | 67d? | 2018-03-15 | 2018-06-15 |  |  |  |  |  | 521d | finish no earlier than 2018-06-15 | R3 | 536h |  | LTE_NR_arch_evo-Core |  |  | China Unicom |  | Rel-15 | 79 |  |  |  |
| 516 | 237 | **LTE Advanced inter-band CA Rel-15 for xDL/3UL with x=3,4,5** |  | 67d? | 2018-03-15 | 2018-06-15 |  |  |  |  |  | 521d |  | R4 | 1072h |  | LTE_CA_R15_xDL3UL |  |  | KDDI |  | Rel-15 | 79 |  |  |  |
| 517 | 237.1 | Core part: LTE Advanced inter-band CA Rel-15 for xDL/3UL with x=3,4,5 |  | 67d? | 2018-03-15 | 2018-06-15 |  |  |  |  |  | 521d | finish no earlier than 2018-06-15 | R4 | 536h |  | LTE_CA_R15_xDL3UL-Core |  |  | KDDI |  | Rel-15 | 79 |  |  |  |
| 518 | 238 | Release 15 Studies | milestone | 0d? | 2016-06-09 A | 2016-06-09 A | 100% |  |  |  |  |  | finish no earlier than 2016-06-09 |  |  |  |  |  |  |  |  | Rel-15 |  |  |  |  |
| 519 | 239 | Release 15 Studies on 5G | milestone | 0d? | 2016-06-09 A | 2016-06-09 A | 100% |  |  |  |  |  | finish no earlier than 2016-06-09 |  |  |  |  |  |  |  |  | Rel-15 |  |  |  |  |
| 520 | 240 | Study on management aspects of virtualized network functions that are part of the NR |  | 325d? | 2016-09-19 A | 2017-12-15 A | 100% |  |  |  |  |  | finish no earlier than 2017-12-15 | S5 | 2600h | 2600h | FS_MA_RNVNF | 37 | TR 32.864 | Intel (Joey Chou | joey.chou@intel.com | Rel-15 | 73 |  |  |  |
| 521 | 241 | Study on 5G enhanced Mobile Broadband Media Distribution |  | 335d? | 2017-06-05 A | 2018-09-14 | 70% | 100.5d? |  |  |  | 456d | finish no earlier than 2018-09-14 | S4 | 2680h | 1876h | FS_5GMedia_Distribution | 39 | 26.8xx | Bouazizi, Imed, Samsung Electronics Co., Ltd., | i (dot) Bouazizi (at) Samsung (dot) com | Rel-15 | 76 |  |  |  |
| 522 | 242 | Study on Media Handling Aspects of Conversational Services in 5G Systems |  | 335d? | 2017-06-05 A | 2018-09-15 | 80% | 67d? |  |  |  | 456d | finish no earlier than 2018-09-15 | S4 | 2680h | 2144h | FS_5G_MEDIA_MTSI | 39 | 26.919 | Oyman, Ozgur, Company: Intel | ozgur.oyman@intel.com | Rel-15 | 76 |  |  |  |
| 523 | 243 | Study on CU-DU lower layer split for New Radio |  | 328d? | 2017-03-15 A | 2018-06-15 | 95% | 16.4d? |  |  |  | 521d | finish no earlier than 2018-06-15 | R3 | 2624h | 2492.8h | FS_NR_CU_DU_LLS | 38 | 38.816 | NTT DOCOMO |  | Rel-15 | 75 |  |  |  |
| 524 | 244 | Study of test methods for New Radio |  | 328d? | 2017-03-15 A | 2018-06-15 | 45% | 180.4d? |  |  |  | 521d | finish no earlier than 2018-06-15 | R4 | 2624h | 1180.8h | FS_NR_test_methods | 38 | 38.810 | Intel |  | Rel-15 | 75 |  |  |  |
| 525 | 245 | Study on NR-based access to unlicensed spectrum |  | 328d? | 2017-03-15 A | 2018-06-15 | 10% | 295.2d? |  |  |  | 521d | finish no earlier than 2018-06-15 | R1 | 2624h | 262.4h | FS_NR_unlic | 38 | 32.889 | Qualcomm |  | Rel-15 | 75 |  |  |  |
| 526 | 246 | Study on Non-Orthogonal Multiple Access (NOMA) for NR |  | 328d? | 2017-03-15 | 2018-06-15 |  |  |  |  |  | 521d | finish no earlier than 2018-06-15 | R1 | 2624h |  | FS_NR_NOMA | 38 | 32.812 | ZTE |  | Rel-15 | 75 |  |  |  |
| 527 | 247 | Study on integrated access and backhaul for NR |  | 328d? | 2017-03-15 A | 2018-06-15 | 20% | 262.4d? |  |  |  | 521d | finish no earlier than 2018-06-15 | R2 | 2624h | 524.8h | FS_NR_IAB | 38 | 38.874 | Qualcomm |  | Rel-15 | 75 |  |  |  |
| 528 | 248 | Study on NR to support non-terrestrial networks |  | 328d? | 2017-03-15 A | 2018-06-15 | 45% | 180.4d? |  |  |  | 521d | finish no earlier than 2018-06-15 | R1 | 2624h | 1180.8h | FS_NR_nonterr_nw | 38 | 38.811 | Thales |  | Rel-15 | 75 |  |  |  |
| 529 | 249 | STOPPED AT SA#77 - SA3 aspects on Study on Architecture and Security for Next Generation System |  | 467d? | 2016-03-01 A | 2017-12-12 A | 100% |  |  |  |  |  | finish no earlier than 2017-12-12 | S3 | 3736h | 3736h | FS_NSA | 36 | TR 33.899 | Vesa Torvinen, Ericsson | vesa.torvinen@ericsson.com | Rel-15 | 71 |  |  |  |
| 530 | 250 | Study on separation of CP and UP for split option 2 of NR |  | 132d? | 2017-06-15 A | 2017-12-15 A | 100% |  |  |  |  |  | finish no earlier than 2017-12-15 | R3 | 1056h | 1056h | FS_NR_CPUP_Split | 39 | 38.806 | Ericsson |  | Rel-15 | 76 |  |  |  |
| 531 | 251 | Release 15 Studies on 4G/LTE | milestone | 0d? | 2016-06-09 A | 2016-06-09 A | 100% |  |  |  |  |  | finish no earlier than 2016-06-09 |  |  |  |  |  |  |  |  | Rel-15 |  |  |  |  |
| 532 | 252 | Stopped - Study on LTE bandwidth flexibility enhancements |  | 263d? | 2016-03-15 A | 2017-03-15 A | 100% |  |  |  |  |  | finish no earlier than 2017-03-15 | R4 | 2104h | 2104h | FS_LTE_BW_flex | 36 | 36.740 | Huawei |  | Rel-15 | 71 |  |  |  |
| 533 | 253 | Study on interference cancellation receiver for LTE BS |  | 196d? | 2016-09-15 A | 2017-06-15 A | 100% |  |  |  |  |  | finish no earlier than 2017-06-15 | R4 | 1568h | 1568h | FS_LTE_IC_BS | 37 | 36.766 | China Telecom |  | Rel-15 | 73 |  |  |  |
| 534 | 254 | Study on uplink data compression in LTE |  | 197d? | 2016-12-15 A | 2017-09-15 A | 100% |  |  |  |  |  | finish no earlier than 2017-09-15 | R2 | 1576h | 1576h | FS_LTE_UDC | 38 | 36.754 | CATT |  | Rel-15 | 74 |  |  |  |
| 535 | 255 | Study on LTE DL 8Rx antenna ports |  | 132d? | 2017-06-15 A | 2017-12-15 A | 100% |  |  |  |  |  | finish no earlier than 2017-12-15 | R4 | 1056h | 1056h | FS_LTE_8Rx_AP_DL | 39 | 36.757 | Huawei |  | Rel-15 | 76 |  |  |  |
| 536 | 256 | Other Release 15 Studies |  | 136d? | 2017-09-08 A | 2018-03-16 |  | 136d? |  |  |  | 586d | finish no earlier than 2018-03-16 |  |  |  |  |  |  |  |  | Rel-15 |  |  |  |  |
| 537 | 257 | Study on EVS Float Conformance Non Bit-Exact |  | 266d? | 2017-09-08 A | 2018-09-14 | 70% | 79.8d? |  |  |  | 456d | finish no earlier than 2018-09-14 | S4 | 2128h | 1489.6h | FS_EVS_FCNBE | 39 | New; 26.843 | Fabrice Plante, Intel | fabrice.m.plante@intel.com | Rel-15 | 77 |  |  |  |
| 538 | 258 | Study on Update to fixed-point basic operators |  | 135d? | 2017-09-08 A | 2018-03-15 A | 100% |  |  |  |  |  | finish no earlier than 2018-03-15 | S4 | 1080h | 1080h | FS_BASOP | 39 | New; 26.973 | Jelinek, Milan, VoiceAge Corporation | Milan.Jelinek@USherbrooke.ca | Rel-15 | 77 |  |  |  |
| 539 | 259 | Study on further enhancements to LTE Device to Device (D2D), UE to network relays for IoT (Internet of Things) and wearables |  | 460d? | 2016-03-15 A | 2017-12-15 A | 100% |  |  |  |  |  | finish no earlier than 2017-12-15 | R2 | 3680h | 3680h | FS_feD2D_IoT_relay_wearable | 36 | 36.746 | Qualcomm |  | Rel-15 | 71 |  |  |  |
| 540 | 260 | Study on Energy Efficiency Aspects of 3GPP Standards |  | 327d? | 2016-03-11 A | 2017-06-09 A | 100% |  |  |  |  |  | finish no earlier than 2017-06-09 | SP | 2616h | 2616h | FS_ENEFF | 36 | TR 21.866 | Orange, Xiaobao Chen | xiaobao.chen@orange.com | Rel-15 | 71 |  |  | _SP-170533 |
| 541 | 261 | Study on system and functional aspects of Energy Efficiency in 5G networks |  | 400d? | 2017-06-05 A | 2018-12-14 | 65% | 140d? |  |  |  | 391d | finish no earlier than 2018-12-14 | S5 | 3200h | 2080h | FS_EE_5G | 39 | new; 32.872; 32.972 | CORNILY, Jean-Michel, ORANGE | jeanmichel.cornily@orange.com | Rel-15 | 76 |  |  |  |
| 542 | 262 | Study on OAM support for assessment of energy efficiency in mobile access networks |  | 421d? | 2015-11-02 A | 2017-06-09 A | 100% |  |  |  |  |  | finish no earlier than 2017-06-09 | S5 | 3368h | 3368h | FS_OAM_EE | 36 | TR 32.856 | Cornily,Jean-Michel, ORANGE | jeanmichel.cornily@orange.com | Rel-15 | 70 |  |  |  |
| 543 | 263 | Study on Long Term Key Update Procedures |  | 400d? | 2017-06-05 A | 2018-12-14 | 90% | 40d? |  |  |  | 391d | finish no earlier than 2018-12-14 | S3 | 3200h | 2880h | FS_LTKUP | 39 | Internal TR | Evans, Tim, Vodafone | tim.evans1@vodafone.com | Rel-15 | 76 |  |  |  |
| 544 | 264 | Study on evaluation methodology of new V2X use cases for LTE and NR |  | 328d? | 2017-03-15 A | 2018-06-15 | 30% | 229.6d? |  |  |  | 521d | finish no earlier than 2018-06-15 | R1 | 2624h | 787.2h | FS_LTE_NR_V2X_eval | 38 | 37.885 | LG Electronics |  | Rel-15 | 75 |  |  |  |
| 545 | 265 | Study on MBMS User Services for IoT |  | 335d? | 2017-06-05 A | 2018-09-14 | 90% | 33.5d? |  |  |  | 456d | finish no earlier than 2018-09-14 | S4 | 2680h | 2412h | FS_MBMS_IoT | 39 | 26.8xx | Cedric thienot, Expway | cedric (dot) thienot (at) expway (dot) com | Rel-15 | 76 |  |  |  |
| 546 | 266 | Study on FEC for MC Services |  | 204d? | 2017-06-05 A | 2018-03-15 A | 100% |  |  |  |  |  | finish no earlier than 2018-03-15 | S4 | 1632h | 1632h | FS_FEC_MCS | 39 | 26.881 | Lambrou, John - Motorola Solutions | john (dot) lambrou (at) motorolasolutions (dot) com | Rel-15 | 76 |  |  |  |
| 547 | 267 | Study on Enhanced Isolated E-UTRAN Operation for Public Safety |  | 205d? | 2016-03-07 A | 2016-12-15 A | 100% |  |  |  |  |  | finish no earlier than 2016-12-15 | S2 | 1640h | 1640h | FS_IOPS_LB | 36 | 23.798 | Antoine Mouquet, Orange | antoine.mouquet@orange.com | Rel-15 | 71 |  |  |  |
| 548 | 268 | Study on Management Enhancement of CUPS of EPC Nodes |  | 269d? | 2016-12-01 A | 2017-12-12 A | 100% |  |  |  |  |  | finish no earlier than 2017-12-12 | S5 | 2152h | 2152h | FS_MECUPS | 38 | 32.867 | Huawei; Jiang, Junyi | jiangjunyi@huawei.com | Rel-15 | 74 |  |  |  |
| 549 | 269 | Study on Technical Requirements for a new secure platform for 3GPP applications |  | 328d? | 2016-06-13 A | 2017-09-12 A | 100% |  |  |  |  |  | finish no earlier than 2017-09-12 | C6 | 2624h | 2624h | FS_NG_SP | 37 | TR 31.801 | Heiko Kruse | heiko.kruse@safrangroup.com | Rel-15 | 72 |  |  |  |
| 550 | 270 | Study on technical requirements for a new secure platform for 3GPP applications |  | 140d? | 2017-03-03 A | 2017-09-14 A | 100% |  |  |  |  |  | finish no earlier than 2017-09-14 | C6 | 1120h | 1120h | FS_NG_SP2 | 38 | 31.801 | Heiko Kruse | heiko.kruse@safrangroup.com | Rel-15 | 75 |  |  |  |
| 551 | 271 | Study on scheduling enhancements with carrier aggregation for UMTS |  | 67d? | 2017-03-15 A | 2017-06-15 A | 100% |  |  |  |  |  | finish no earlier than 2017-06-15 | R1 | 536h | 536h | FS_UTRA_CA_sched_enh | 38 | 25.708 | Huawei |  | Rel-15 | 75 |  |  |  |
| 552 | 272 | Study on Architecture Evolution for E-UTRAN |  | 262d? | 2017-03-15 A | 2018-03-15 A | 100% |  |  |  |  |  | finish no earlier than 2018-03-15 | R3 | 2096h | 2096h | FS_LTE_arch_evo | 38 | 36.756; 37.876 | China Unicom |  | Rel-15 | 75 |  |  |  |
| 553 | 273 | Study on Enhanced Acoustic Test Specifications |  | 1246d? | 2013-03-18 A | 2017-12-12 A | 100% |  | 2013-03-06 | 2014-09-17 | 401d? |  | finish no earlier than 2017-12-12 | S4 | 9968h | 9968h | FS_SEATS | 30 | 26.931 | Knowles, Intel | Scott Isabelle (Knowles), David Isherwood (Intel) | Rel-15 | 59 | Paolo | FS_SEATS |  |
| 554 | 274 | Study on User Services Enhancements in 3GPP for TV Services |  | 328d? | 2016-06-13 A | 2017-09-12 A | 100% |  |  |  |  |  | finish no earlier than 2017-09-12 | S4 | 2624h | 2624h | FS_USE_3GPP_4_TV | 37 | TR 26.9xx; 26.917 | Thomas Stockhammer, Qualcomm Incorporated | tsto@qti.qualcomm.com | Rel-15 | 72 |  |  |  |
| 555 | 275 | Study on Management aspects of selected IoT-related features |  | 322d? | 2016-09-19 A | 2017-12-12 A | 100% |  |  |  |  |  | finish no earlier than 2017-12-12 | S5 | 2576h | 2576h | FS_OAM_IOT | 37 | 32.857 | Cisco Systems / Yanover, Vladimir |  | Rel-15 | 73 |  |  |  |
| 556 | 276 | Study on Overload Control for Diameter Charging Applications |  | 653d? | 2015-06-18 A | 2017-12-15 A | 100% |  |  |  |  |  | finish no earlier than 2017-12-15 | S5 | 5224h | 5224h | FS_DOCME_CH | 35 | New TR 32.869 | GUO Wenjie, ZTE | guo.wenjie1@zte.com.cn | Rel-15 | 68 |  |  |  |
| 557 | 277 | Study on forward compatibility for 3GPP Diameter Charging Applications |  | 194d? | 2016-09-19 A | 2017-06-15 A | 100% |  |  |  |  |  | finish no earlier than 2017-06-15 | S5 | 1552h | 1552h | FS_FWDCA | 37 | 32.870 | Nokia, Maryse <dot> Gardella <at> Nokia <dot> com | Nokia, Maryse <dot> Gardella <at> Nokia <dot> com | Rel-15 | 73 |  |  |  |
| 558 | 278 | Study on OAM aspects of SON for AAS-based deployments |  | 421d? | 2015-11-02 A | 2017-06-09 A | 100% |  |  |  |  |  | finish no earlier than 2017-06-09 | S5 | 3368h | 3368h | FS_OAM_SON_AAS | 36 | TR (new) | Nokia Networks (Yizhi Yao) | Yizhi.yao@nokia.com | Rel-15 | 70 |  |  |  |
| 559 | 279 | Study on Implementation for the Partitioning of Itf-N |  | 534d? | 2016-03-01 A | 2018-03-15 A | 100% |  |  |  |  |  | finish no earlier than 2018-03-15 | S5 | 4272h | 4272h | FS_IMP_ITFN | 36 | New TR 32.880 | Hu, Yaxi, China Mobile | huyaxi@cmdi.chinamobile.com | Rel-15 | 71 |  |  |  |
| 560 | 280 | Study on Management Aspects of Next Generation Network architecture and features |  | 393d? | 2016-06-13 A | 2017-12-12 A | 100% |  |  |  |  |  | finish no earlier than 2017-12-12 | S5 | 3144h | 3144h | FS_MAN_NGNAF | 37 | TR (new); 28.802 | Nokia Networks, Yizhi Yao | Yizhi.yao@nokia.com | Rel-15 | 72 |  |  |  |
| 561 | 281 | Study on Management and Orchestration Architecture of Next Generation Network and Service |  | 393d? | 2016-06-13 A | 2017-12-12 A | 100% |  |  |  |  |  | finish no earlier than 2017-12-12 | S5 | 3144h | 3144h | FS_NGNS_MOA | 37 | TR xy.abc; 28.800 | Huawei Technologies, Zou Lan | zoulan@huawei.com | Rel-15 | 72 |  |  |  |
| 562 | 282 | Study on SON for eCoMP for LTE |  | 263d? | 2016-06-15 A | 2017-06-15 A | 100% |  |  |  |  |  | finish no earlier than 2017-06-15 | R3 | 2104h | 2104h | FS_LTE_SON_eCOMP | 37 |  | Nokia |  | Rel-15 | 72 |  |  |  |
| 563 | 283 | Stopped - Study on IMS Enhanced Spoofed Call Prevention and Detection |  | 849d? | 2014-09-19 A | 2017-12-15 A | 100% |  |  |  |  |  | finish no earlier than 2017-12-15 | S3 | 6792h | 6792h | FS_ESCAPADES | 33 | 33.832 | Sprint | Gregory.schumacher@sprint.com | Rel-15 | 64 |  | FS_ESCAPADES |  |
| 564 | 284 | Study on OAM aspects of LTE and WLAN integration |  | 204d? | 2017-06-05 A | 2018-03-15 A | 100% |  |  |  |  |  | finish no earlier than 2018-03-15 | S5 | 1632h | 1632h | FS_OAM_LWI | 39 | new; 32.868 | Yizhi Yao, Intel Corporation | yizhi.yao@intel.com | Rel-15 | 76 |  |  |  |
| 565 | 285 | Study on network policy management for mobile networks based on NFV scenarios |  | 269d? | 2017-06-05 A | 2018-06-14 A | 100% |  |  |  |  |  | finish no earlier than 2018-06-14 | S5 | 2152h | 2152h | FS_NETPOL | 39 | new; 32.871 | China Mobile Jinglei Liu | liujinglei@chinamobile.com | Rel-15 | 76 |  |  |  |
| 566 | 286 | Study on Volume Based Charging Aspects for VoLTE |  | 269d? | 2017-06-05 A | 2018-06-14 A | 100% |  |  |  |  |  | start no earlier than 2017-06-05 | S5 | 2152h | 2152h | FS_VBCLTE | 39 | new; 32.848 | Chen, Ai, China Mobile | chenai@chinamobile.com | Rel-15 | 76 |  |  |  |
| 567 | 287 | STOPPED - Study on UE characteristics and performance for Video |  | 339d? | 2016-03-01 A | 2017-06-15 A | 100% |  |  |  |  |  | finish no earlier than 2017-06-15 | S4 | 2712h | 2712h | FS_UE_VTPerf | 36 | TR 26.932 | Stéphane PROUST, Orange | stephane.proust@orange.com | Rel-15 | 71 |  |  |  |
| 568 | 288 | Study on self-evaluation towards IMT-2020 submission |  | 393d? | 2016-12-14 A | 2018-06-15 | 25% | 294.75d? |  |  |  | 521d | finish no earlier than 2018-06-15 | ITU-R AH | 3144h | 786h | FS_5G_eval | 38 |  | Huawei |  | Rel-15 | 75 |  |  |  |
| 569 | 289 | Study on 6 GHz for LTE and NR |  | 131d? | 2017-12-15 A | 2018-06-15 | 25% | 98.25d? |  |  |  | 521d | finish no earlier than 2018-06-15 | RP | 1048h | 262h | FS_6GHz_LTE_NR |  | 37.890; 37.107 | Ericsson |  | Rel-15 | 78 |  |  |  |
| 570 | 290 | Study on UE Application Layer Data Throughput Performance Expansion for Carrier Aggregation |  | 131d? | 2017-12-15 A | 2018-06-15 | 10% | 117.9d? |  |  |  | 521d | finish no earlier than 2018-06-15 | R5 | 1048h | 104.8h | FS_UE_App_Data_Perf_CA |  |  | PCTEST Engineering Lab |  | Rel-15 | 78 |  |  |  |
| 571 | 291 | Release 14 Features | milestone | 0d? | 2014-12-12 A | 2014-12-12 A | 100% |  |  |  |  |  | finish no earlier than 2014-12-12 |  |  |  |  |  |  |  |  | Rel-14 |  |  |  |  |
| 572 | 292 | Release 14 on Mission Critical | milestone | 0d? | 2016-06-09 A | 2016-06-09 A | 100% |  |  |  |  |  | finish no earlier than 2016-06-09 |  |  |  |  |  |  |  |  | Rel-14 |  |  |  |  |

Notes:
- 508: Triggered by Rel-11 TR 37.902 Study on Measurements of radio performances for LTE terminals - TRP and TRS test methodology (FS_LTE_OTA) UID_550022
- 509: ; CD:Wed 18/03/15->Sun 15/03/15; Rel-12->Rel-13; Stat Rep: RP-141158->RP-141973 1st Apr 15: Compl:35%->40% 1st Apr 15: Stat Rep: RP-141973->RP-150104 03/07/15: Stat Rep: RP-150104->RP-150615 29/09/15: Compl:40%->50% 29/09/15: Stat Rep: RP-150615->RP-15...; ; ; ; ; ; ; ; ; ; ; ; ; ; ; ; ; ; ; ; ; ; ; ; ; ; ; ; ; ; ; ; ; ; ; ; ; ; ; ; ; ; ; ; ; ; ; ; ; ; ; ; ; ; ; ; ; ; ; ; ; ; ; ; ; ; ; ; ; ; 8/1/18: CD:Thu 15/03/18->Fri 15/12/17
- 510: Stat Rep: RP-141132->RP-141848; Rel 12->Rel13 1st Apr 15: Compl:15%->20% 1st Apr 15: CD:Mon 15/06/15->Wed 15/06/16 1st Apr 15: WID: RP-140090->RP-150070 1st Apr 15: Stat Rep: RP-141848->RP-150069 03/07/15: Compl:20%->25% 03/07/15: Stat Rep: RP-150069->...; ; ; ; ; ; ; ; ; ; ; ; ; ; ; ; ; ; ; ; ; ; ; ; ; ; ; ; ; ; ; ; ; ; ; ; ; ; ; ; ; ; ; ; ; ; ; ; ; ; ; ; ; ; ; ; ; ; ; ; ; ; ; ; ; ; ; ; ; ; ; ; ; ; ; ; ; ; ; ; ; ; ; ; ; ; ; ; ; ; ; ; ; ; ; ; ; ; ; ; 8/1/18: CD:Fri 15/06/18->Fri 15/12/17
- 511: follow-up WI of REL-14 WI CIoT_EC_GSM_radio_enh
- 512: follow-up WI of REL-14 WI CIoT_EC_GSM_radio_enh
- 513: follow-up WI of REL-14 WI CIoT_EC_GSM_radio_enh
- 514: follow-up WI of REL-15 SI FS_LTE_arch_evo
- 515: follow-up WI of REL-15 SI FS_LTE_arch_evo
- 516: basket CA WI; no Perf. part
- 517: basket CA WI; no Perf. part
- 518: -
- 519: -
- 520: 6/10/16: Acronym FS_MA_RVNF ->FS_MA_RNVNF ; 6/10/16: 32.864 added; 1/12/16: 0%->5; 6/3/17: 5%->10; 7/6/17: 10%->40; 11/9/17: 40%->70; 15/12/17: 70%->100; 15/12/17: FCD:09/17->12/17
- 521: 11/9/17: 0%->10; 15/12/17: FCD:03/18->06/20; 15/12/17: 10%->25; 16/3/18: 25%->60; 7/6/18: 60%->70; 7/6/18: FCD:06/18->09/18
- 522: 11/9/17: 0%->5; 15/12/17: 5%->35; 16/3/18: 35%->55; 16/3/18: FCD:03/18->09/18; 7/6/18: 55%->80
- 523: CU = central unit, DU = distributed unit; results will be captured in existing TR 38.801; 19/9/17: Compl:0%->30%; 19/9/17: WID: RP-170818->RP-171717; 15/12/17: 38.816 added;; 8/1/18: Compl:30%->95%; 8/1/18: CD:Fr...
- 524: TR 38.8XX; 19/6/17: Compl:0%->10%; 19/6/17: WID: RP-170824->RP-171021; 30/6/17: 38.810 added;19/9/17: Compl:10%->15%19/9/17: WID: RP-171021->RP-171828; 8/1/18: Compl:15%->20%27/3/18: Compl:20%->45%27/3/18: CD:Thu 15/...
- 525: TR 38.8XX19/6/17: WID: RP-170828->RP-171416; 30/6/17: 32.889 added;; 19/9/17: WID: RP-171416->RP-17202127/3/18: Compl:0%->10%
- 526: TR 38.8XX; 19/6/17: WID: RP-170829->RP-171043; 30/6/17: 32.812 added;
- 527: TR 38.8XX; 30/6/17: 38.874 added;; 19/9/17: WID: RP-170831->RP-171880; 8/1/18: WID: RP-171880->RP-17229027/3/18: Compl:0%->20%
- 528: TR 38.8XX19/6/17: Compl:0%->25%19/6/17: CD:Fri 15/12/17->Thu 15/03/1819/6/17: WID: RP-170717->RP-171450; 30/6/17: 38.811 added;; 19/9/17: Compl:25%->40%; 8/1/18: CD:Thu 15/03/18->Fri 15/06/18; 27/3/18: Compl:40%->45%
- 529: 19/9/16: 0%->25; 22/9/16: WID:SP-160227->SP-160727; 22/9/16: FCD:12/16->03/17; 1/12/16: 25%->45; 6/3/17: 45%->60; 7/6/17: FCD:03/17->12/17 so Rel-14->Rel-15; 7/6/17: 60%->65; 11/9/17: 65%->100
- 530: 19/9/17: Compl:0%->45%19/9/17: WID: RP-171421->RP-171905; 15/12/17: 38.806 added;; 8/1/18: Compl:45%->100%
- 531: -
- 532: 1/7/16: Compl:0%->50%; 28/7/16: 36.740 added; 26/9/16: WID: RP-161328->RP-161670; 20/12/16: CD:Thu 15/0;21/3/17: CD:Fri 15...; 12/7/17: 50%->100 since declared as stopped
- 533: 6/10/16: 36.766 added; 20/12/16: Compl:0%->35% 21/3/17: Compl:35%->65%; 19/6/17: Compl:65%->100%
- 534: ; 21/3/17: WID: RP-162541->RP-170403; 21/3/17: 36.754 added;19/6/17: Compl:0%->90%; 19/9/17: Compl:90%->100...
- 535: 12/7/17: 36.757 added;; 19/9/17: Compl:0%->35%; ...; 8/1/18: Compl:35%->100%
- 536: -
- 537: 15/12/17: 26.843 added;; 15/12/17: 0%->50; 16/3/18: 50%->60; 16/3/18: FCD:03/18->06/18; 7/6/18: 60%->70; 7/6/18: FCD:06/18->09/18
- 538: 15/12/17: 26.973 added;; 15/12/17: 0%->80; 16/3/18: 80%->100
- 539: 1/7/16: Compl:0%->2%;26/9/16: Compl:2%->5%; 6/10/16: 36.746 added; 20/12/16: Compl:5%->15%;21/3/17: Compl:15%->35%…19/6/17:...; ;...; ;...
- 540: 28/7/16: 21.866 added;; 9/6/17: FCD:12/16->9/6/17 (Rel-14->Rel-15); 0%->100
- 541: 30/6/17: 32.872 added;; 11/9/17: 0%->5; 15/12/17: 32.972 added;; 15/12/17: 5%->40; 16/3/18: 40%->60; 7/6/18: 60%->65; 7/6/18: FCD:06/18->12/18
- 542: 13/6/16: WID:SP-150674->SP-160430; 13/6/16: 0%->55; 1/12/16: 55%->80; 6/3/17: FCD:03/17->06/17; 6/3/17: 80%->90; 21/3/17: moved from rel-14; 7/6/17: 90%->100
- 543: 11/9/17: 0%->10; 15/12/17: 10%->70; 15/12/17: FCD:12/17->03/18; 16/3/18: 70%->90; 16/3/18: FCD:03/18->06/18; 7/6/18: FCD:06/18->12/18
- 544: TR 38.8XX19/6/17: WID: RP-170837->RP-171093; 12/7/17: 37.885 added;19/9/17: Compl:0%->5%; 8/1/18: Compl:5%->10%; 8/1/18: CD:Fri 15/12/17->Thu 15/03/18; 27/3/18: Compl:10%->30%; 27/3/18: CD:Thu 15/03/18->Fri 15/06/18
- 545: 11/9/17: 0%->10; 15/12/17: 10%->30; 16/3/18: 30%->80; 16/3/18: FCD:03/18->06/18; 7/6/18: 80%->90; 7/6/18: FCD:06/18->09/18
- 546: 11/9/17: 0%->15; 15/12/17: 15%->60; 15/12/17: FCD:12/17->03/18; 16/3/18: 60%->100
- 547: 9/6/16: 0%->6; 28/7/16: 23.798 added; 1/12/16: FCD:09/16->12/16; 1/12/16: 6%->15. 7/12/16: Moved from Rel-14 according to SP-160806.; 6/3/17: 15%->50; 7/6/17: 50%->100
- 548: 6/3/17: 0%->5; 7/6/17: 5%->40; 7/6/17: FCD:09/17->12/17; 11/9/17: 40%->50; 15/12/17: 50%->100
- 549: 16/9/16: 0%->15. ; 5/6/17: 15%->70. 5/6/17: moved to Rel-15 (talks with P. Jolivet); 5/6/17: FCD:12/16->09/20; 15/12/17: 70%->100
- 550: 21/3/17: 31.801 added;; 11/9/17: 0%->70; 15/12/17: 70%->100
- 551: TR 25.7XX; 19/6/17: Compl:0%->100%; ...; 12/7/17: 25.708 added;
- 552: TR 36.8XX; 12/7/17: 36.756 added;19/9/17: Compl:0%->40%; ;...; 15/12/17: 37.876 added;; 8/1/18: Compl:40%->8...27/3/18: Compl:85%->100%
- 553: SP#65 completion 09/14=>12/14. Moved to Rel-13. Dec.14: 30->35%, CD 12/14->03/15. Mar.15: CD: 06/16. 40%; June2015: Compl:40%->45. . 15/4/16: moved from R...; 21/3/17: Moved from Rel-14 (not completed on time); 7/6/17: FCD:06/17->12/17; 11/9/17: 80%->85; 15/12/17: 85%->100
- 554: 19/9/16: 0%->30; 6/10/16: 26.917 added; 1/12/16: 30%->60; 1/12/16: FCD:12/16->03/17; 6/3/17: 60%->75; 6/3/17: FCD:03/17->06/17; 21/3/17: Moved from Rel-14 (not completed on time); 7/6/17: 75%->80; 7/6/17: FCD:06/17->09/17; 11/9/17: 80%->100
- 555: 6/10/16: 32.857 added; 1/12/16: 0%->5; 21/3/17: moved from Rel-14; 7/6/17: FCD:06/17->12/17; 7/6/17: 5%->20; 11/9/17: 20%->30; 15/12/17: 30%->45; 16/3/18: 45%->100
- 556: Aug2015: moved to Rel-14 (email CT and EG); 07/09/15: 0%->5; 7/3/16: 5%->10; 13/6/16: FCD:03/16->09/16; 19/9/16: FCD: 09/16->06/17; 6/3/17: FCD:03/17->12/17; 21/3/17: moved from rel-14; 7/6/17: 10%->25; 8/6/17: WID:SP-150310->SP-170481; 11/9/17: 25%->30; 15/12/17: 30%->100
- 557: 6/10/16: 32.870 added; 1/12/16: 0%->10; 21/3/17: moved from rel-14; 11/9/17: 10%->40; 15/12/17: 40%->100
- 558: 13/6/16: 0%->40; 19/9/16: FCD:09/16->12/16; 19/9/16: 40%->60; 1/12/16: FCD:12/16->03/17; 1/12/16: 60%->70; 6/3/17: FCD:03/17->06/17; 21/3/17: moved from rel-14; 7/6/17: 70%->100
- 559: 13/6/16: 0%->10; 19/9/16: 10%->35; 1/12/16: 35%->40; 6/3/17: FCD:03/17->03/18; 21/3/17: moved from rel-14; 7/6/17: 40%->60; 11/9/17: 60%->80; 15/12/17: 80%->100
- 560: 28/7/16: 28.802 added; 19/9/16: 0%->5; 1/12/16: 5%->10; 6/3/17: FCD:03/17->06/17; 6/3/17: 10%->40; 21/3/17: moved from rel-14; 7/6/17: FCD:06/17->12/17; 7/6/17: 40%->60; 11/9/17: 60%->70; 15/12/17: 70%->100
- 561: 28/7/16: 28.800 added; 19/9/16: 0%->10; 6/3/17: FCD:03/17->06/17; 21/3/17: moved from rel-14; 7/6/17: FCD:06/17->12/17; 7/6/17: 10%->25; 11/9/17: 25%->30; 15/12/17: 30%->100
- 562: 26/9/16: Compl:0%->10%. ; 20/12/16: Compl:10%->40%21/3/17: Compl:40%->60%;...; 19/6/17: Compl:60%->100%
- 563: Dec.14: TR number added. 3/3/15: 0->5%; June2015: Compl:5%->25; 9/12/15: 25%->30; 21/3/17: moved from Rel-13; 21/3/17: FCD:09/15->12/17; 7/6/17: Stopped (30%->100%)
- 564: 30/6/17: 32.868 added;; 11/9/17: 0%->10; 15/12/17: 10%->50; 16/3/18: 50%->90; 7/6/18: 90%->100
- 565: 30/6/17: 32.871 added;; 11/9/17: 0%->20; 15/12/17: 20%->30; 16/3/18: 30%->35; 7/6/18: 35%->100
- 566: 30/6/17: 32.848 added;; 11/9/17: 0%->5; 15/12/17: 5%->35; 16/3/18: 35%->45; 7/6/18: 45%->100
- 567: 11/6/16: 0%->10; 19/9/16: 10%->30, FCD: 12/16->06/17; 21/3/17: Moved from Rel-14 (not completed on time); 7/6/17: Stopped, so 30%->100
- 568: TR 38.9XX; 19/6/17: CD:Sat 15/09/18->Fri 15/06/18; 19/6/17: WID: RP-170832->RP-171451; 19/6/17: Release: Rel-16->Rel-15; 8/1/18: Compl:0%->15%27/3/18: Compl:15%->25%
- 569: SI under RAN leadership; TR 37.8XX27/3/18: Compl:0%->25%27/3/18: WID: RP-172804->RP-180168; 27/3/18: 37.890 added;; 27/3/18: 37.107 added;
- 570: compare REL-11 SI FS_UE_App_Data_Perf; note: SI FS_UE_App_Data_Perf_CA is addressing 2DL/1UL involving also an unlicensed carrier of REL-13 LTE_LAA; instead of a new TR, the TR 37.901 will be updated for REL-15; ...
- 571: -
- 572: -

| ID | WBS | Task | Duration | Start | Finish | Complete | Remaining | Total slack | Constraint | Resources | Work | Actual work | Acronym | PCG approved | Release | TSG approved | Impacted TSs and TRs | WI rapporteur name | WI rapporteur e-mail | Status Report |
| --- | --- | --- | --- | --- | --- | --- | --- | --- | --- | --- | --- | --- | --- | --- | --- | --- | --- | --- | --- | --- |
| 573 | 293 | **Mission Critical Improvements** | 1351d? | 2015-04-14 A | 2020-06-15 | 83% | 223.08d? | 0d |  |  | 31848h | 27144h | MCImp | 36 | Rel-14 | 70 |  |  |  |  |
| 574 | 293.1 | Mission Critical Push to Talk over LTE Realignment | 138d? | 2015-12-07 A | 2016-06-15 A | 100% |  |  | finish no earlier than 2016-06-15 | S1 | 1104h | 1104h | MCImp-MCPTTR | 36 | Rel-14 | 70 | 22.179 | Andrew Thiessen | andrew (at) its (dot) bldrdoc (dot) gov | SP-170406 |
| 575 | 293.2 | **Enhancements for Mission Critical Push To Talk** | 264d? | 2016-06-13 A | 2017-06-14 A | 100% |  |  |  |  | 5624h | 5624h | MCImp-eMCPTT | 37 | Rel-14 | 72 | TS 23.379, TS 23.280, TS 23.281, TS 23.282; 23.379 | Lazara, Dom | dom.lazara@motorolasolutions.com |  |
| 576 | 293.2.1 | Stage 2 of Enhancements for Mission Critical Push To Talk | 135d? | 2016-06-13 A | 2016-12-15 A | 100% |  |  | finish no earlier than 2016-12-15 | S6 | 1080h | 1080h | MCImp-eMCPTT | 37 | Rel-14 | 72 | TS 23.379, TS 23.280, TS 23.281, TS 23.282; 23.379 | Lazara, Dom | dom.lazara@motorolasolutions.com |  |
| 577 | 293.2.2 | **Stage 3 of Enhancements for Mission Critical Push To Talk** | 140d? | 2016-12-01 A | 2017-06-14 A | 100% |  |  |  | ct | 4544h | 4544h | MCImp-eMCPTT-CT | 38 | Rel-14 | 74 |  | FREDERICKS, Bob | bobfredericks@motorolasolutions.com |  |
| 578 | 293.2.2.1 | CT1 aspects of Enhancements for Mission Critical Push To Talk | 140d? | 2016-12-01 A | 2017-06-14 A | 100% |  |  | finish no earlier than 2017-06-14 | C1 | 1120h | 1120h | MCImp-eMCPTT-CT | 38 | Rel-14 | 74 | 24.379, 24.380, 24.381, 24.382, 24.383, 24.384 | FREDERICKS, Bob | bobfredericks@motorolasolutions.com |  |
| 579 | 293.2.2.2 | CT3 aspects of Enhancements for Mission Critical Push To Talk | 74d? | 2016-12-01 A | 2017-03-14 A | 100% |  |  | finish no earlier than 2017-03-14 | C3 | 592h | 592h | MCImp-eMCPTT-CT | 38 | Rel-14 | 74 | 29.165, 29.213, 29.214 | FREDERICKS, Bob | bobfredericks@motorolasolutions.com |  |
| 580 | 293.2.2.3 | CT4 aspects of Enhancements for Mission Critical Push To Talk | 74d? | 2016-12-01 A | 2017-03-14 A | 100% |  |  | finish no earlier than 2017-03-14 | C4 | 592h | 592h | MCImp-eMCPTT-CT | 38 | Rel-14 | 74 | 23.003, 29.228, 23.335, 29.283 | FREDERICKS, Bob | bobfredericks@motorolasolutions.com |  |
| 581 | 293.2.2.4 | CT6 aspects of Enhancements for Mission Critical Push To Talk | 140d? | 2016-12-01 A | 2017-06-14 A | 100% |  |  | finish no earlier than 2017-06-14 | C6 | 1120h | 1120h | MCImp-eMCPTT-CT | 38 | Rel-14 | 74 | 31.102, 31.103 | FREDERICKS, Bob | bobfredericks@motorolasolutions.com |  |
| 582 | 293.3 | Mission Critical Services Common Requirements | 138d? | 2015-12-07 A | 2016-06-15 A | 100% |  |  | finish no earlier than 2016-06-15 | S1 | 1104h | 1104h | MCImp-MCCoRe | 36 | Rel-14 | 70 | New TS 22.280 | Andrew Thiessen | andrew (at) its (dot) bldrdoc (dot) gov | SP-170407 |
| 583 | 293.4 | Common functional architecture to support mission critical services | 135d? | 2016-06-13 A | 2016-12-15 A | 100% |  |  | finish no earlier than 2016-12-15 | S6 | 1080h | 1080h | MCImp-MC_ARCH | 37 | Rel-14 | 72 | TS 23.280, TS 23.379, TS 23.281, TS 23.282; 23.280 | Niranth Amogh, Huawei Telecommunications India | namogh@huawei.com |  |
| 584 | 293.5 | **Mission Critical Video over LTE** | 568d? | 2015-04-14 A | 2017-06-14 A | 100% |  |  |  |  | 8528h | 8528h | MCImp-MCVideo | 36 | Rel-14 | 70 |  | Emmanuelle Villebrun | Emmanuelle.villebrun@gendarmerie.interieur.gouv.fr |  |
| 585 | 293.5.1 | Study on Mission Critical Video over LTE | 176d? | 2015-04-14 A | 2015-12-15 A | 100% |  |  | finish no earlier than 2015-12-15 | S1 | 1408h | 1408h | FS_MCVideo | 34 | Rel-14 | 67 | New TR 22.879 | Villebrun, Emmanuelle (French MoI) | emmanuelle.villebrun@gendarmerie.interieur.gouv.fr |  |
| 586 | 293.5.2 | Stage 1 of MCVideo | 138d? | 2015-12-07 A | 2016-06-15 A | 100% |  |  | finish no earlier than 2016-06-15 | S1 | 1104h | 1104h | MCImp-MCVideo | 36 | Rel-14 | 70 | New TR 22.281 | Emmanuelle Villebrun | Emmanuelle.villebrun@gendarmerie.interieur.gouv.fr |  |
| 587 | 293.5.3 | Stage 2 for MCVideo | 135d? | 2016-06-13 A | 2016-12-15 A | 100% |  |  | finish no earlier than 2016-12-15 | S6 | 1080h | 1080h | MCImp-MCVideo | 37 | Rel-14 | 72 | TS 23.281, TS 23.280, TS 23.379, TS 23.282; 23.281 | Niranth Amogh, Huawei Telecommunications India | namogh@huawei.com |  |
| 588 | 293.5.4 | MCVideo codecs and media handling | 47d? | 2017-01-11 A | 2017-03-16 A | 100% |  |  | finish no earlier than 2017-03-16 | S4 | 376h | 376h | MCImp-MCVideo | 38 | Rel-14 | 75 | 26.281 | John Lambrou (Motorola Solutions) | john (dot) lambrou (at) motorolasolutions (dot) com |  |
| 589 | 293.5.5 | **Stage 3 of MCVideo** | 140d? | 2016-12-01 A | 2017-06-14 A | 100% |  |  |  | ct | 4560h | 4560h | MCImp-MCVIDEO-CT | 38 | Rel-14 | 74 | 24.581, 24.281 | PATEL, Milan | milan.patel@huawei.com |  |
| 590 | 293.5.5.1 | CT1 aspects 3 of MCVideo | 140d? | 2016-12-01 A | 2017-06-14 A | 100% |  |  | finish no earlier than 2017-06-14 | C1 | 1120h | 1120h | MCImp-MCVIDEO-CT | 38 | Rel-14 | 74 | 24.381, 24.382, 24.383, 24.384 | PATEL, Milan | milan.patel@huawei.com |  |
| 591 | 293.5.5.2 | CT3 aspects 3 of MCVideo | 75d? | 2016-12-01 A | 2017-03-15 A | 100% |  |  | finish no earlier than 2017-03-15 | C3 | 600h | 600h | MCImp-MCVIDEO-CT | 38 | Rel-14 | 74 | 29.165, 29.213, 29.214 | PATEL, Milan | milan.patel@huawei.com |  |
| 592 | 293.5.5.3 | CT4 aspects 3 of MCVideo | 75d? | 2016-12-01 A | 2017-03-15 A | 100% |  |  | finish no earlier than 2017-03-15 | C4 | 600h | 600h | MCImp-MCVIDEO-CT | 38 | Rel-14 | 74 | 23.003, 23.335, 29.283 | PATEL, Milan | milan.patel@huawei.com |  |
| 593 | 293.5.5.4 | CT6 aspects 3 of MCVideo | 140d? | 2016-12-01 A | 2017-06-14 A | 100% |  |  | finish no earlier than 2017-06-14 | C6 | 1120h | 1120h | MCImp-MCVIDEO-CT | 38 | Rel-14 | 74 | 31.102, 31.103 | PATEL, Milan | milan.patel@huawei.com |  |
| 594 | 293.6 | **Mission Critical Data over LTE** | 568d? | 2015-04-14 A | 2017-06-14 A | 100% |  |  |  |  | 8152h | 8152h | MCImp-MCData | 36 | Rel-14 | 70 |  | Emmanuelle Villebrun | Emmanuelle.villebrun@gendarmerie.interieur.gouv.fr |  |
| 595 | 293.6.1 | Study on Mission Critical Data Communications | 176d? | 2015-04-14 A | 2015-12-15 A | 100% |  |  | finish no earlier than 2015-12-15 | S1 | 1408h | 1408h | FS_MCDATA | 34 | Rel-14 | 67 | New TR 22.880 | Villebrun, Emmanuelle (French MoI) | emmanuelle.villebrun@gendarmerie.interieur.gouv.fr |  |
| 596 | 293.6.2 | Stage 1 of MCData | 138d? | 2015-12-07 A | 2016-06-15 A | 100% |  |  | finish no earlier than 2016-06-15 | S1 | 1104h | 1104h | MCImp-MCData | 36 | Rel-14 | 70 | New TR 22.282 | Emmanuelle Villebrun | Emmanuelle.villebrun@gendarmerie.interieur.gouv.fr |  |
| 597 | 293.6.3 | Stage 2 for MCData | 135d? | 2016-06-13 A | 2016-12-15 A | 100% |  |  | start no earlier than 2016-06-13 | S6 | 1080h | 1080h | MCImp-MCData | 37 | Rel-14 | 72 | 23.282 | David Freeman (UK Home Office) | david@dnf-consulting.co.uk |  |

Notes:
- 573: Umbrella Feature
- 574: 2/3/16: FCD: 03/16->06/16. ES in SP-160102; 0->75%; 9/6/16: 75%->100
- 575: 28/7/16: 23.379 added; 19/9/16: 0%->35; 1/12/16: 35%->100
- 576: 28/7/16: 23.379 added; 19/9/16: 0%->35; 1/12/16: 35%->100
- 578: 6/3/17: 0%->20; 5/6/17: 20%->95; 14/9/17: 95%->97; 15/12/17: 97%->100
- 579: 5/6/17: 0%->100
- 580: 6/3/17: 0%->100
- 581: 5/6/17: 0%->100. No work identified for CT6.
- 582: 2/3/16: FCD: 03/16->06/16. ES in SP-160104; 0->75%; 9/6/16: 75%->100
- 583: 28/7/16: 23.280 added; 19/9/16: 0%->40; 1/12/16: 40%->95; 3/3/17: 95%->100
- 584: 2/3/16: FCD: 03/16->06/16. ES in SP-160106; 0->80%; 9/6/16: 80%->100
- 585: 1/4/15:TR number added; June2015: Compl:0%->50; 07/09/15: 50%->70; 7/12/15: 70%->100
- 586: 2/3/16: FCD: 03/16->06/16. ES in SP-160106; 0->80%; 9/6/16: 80%->100
- 587: 28/7/16: 23.281 added; 19/9/16: 0%->25; 1/12/16: 25%->95; 3/3/17: 95%->100
- 588: 6/3/17: 0%->100
- 590: 6/3/17: 0%->25; 5/6/17: 25%->90; 14/9/17: 90%->100
- 591: 5/6/17: 0%->100
- 592: 6/3/17: 0%->100
- 593: 5/6/17: 0%->100. No work identified for CT6.
- 594: 2/3/16: FCD: 03/16->06/16. ES in SP-160109; 0->80%; 9/6/16: 80%->100
- 595: 1/4/15:TR number added; June2015: Compl:0%->20; 07/09/15: 20%->90; 7/12/15: 90%->100
- 596: 2/3/16: FCD: 03/16->06/16. ES in SP-160109; 0->80%; 9/6/16: 80%->100
- 597: 28/7/16: 23.282 added; 19/9/16: 0%->10; 1/12/16: 10%->95; 3/3/17: 95%->100

| ID | WBS | Task | Type | Duration | Start | Finish | Complete | Remaining | Total slack | Constraint | Resources | Work | Actual work | Acronym | PCG approved | WI rapporteur name | WI rapporteur e-mail | Release | TSG approved | Status Report |
| --- | --- | --- | --- | --- | --- | --- | --- | --- | --- | --- | --- | --- | --- | --- | --- | --- | --- | --- | --- | --- |
| 598 | 293.6.4 | **Stage 3 of MCData** |  | 140d? | 2016-12-01 A | 2017-06-14 A | 100% |  |  |  | ct | 4560h | 4560h | MCImp-MCDATA-CT | 38 | HASON, Baruh | baruh.hason@motorolasolutions.com | Rel-14 | 74 |  |
| 599 | 293.6.4.1 | CT1 aspects of MCData |  | 140d? | 2016-12-01 A | 2017-06-14 A | 100% |  |  | finish no earlier than 2017-06-14 | C1 | 1120h | 1120h | MCImp-MCDATA-CT | 38 | HASON, Baruh | baruh.hason@motorolasolutions.com | Rel-14 | 74 |  |
| 600 | 293.6.4.2 | CT3 aspects of MCData |  | 75d? | 2016-12-01 A | 2017-03-15 A | 100% |  |  | finish no earlier than 2017-03-15 | C3 | 600h | 600h | MCImp-MCDATA-CT | 38 | HASON, Baruh | baruh.hason@motorolasolutions.com | Rel-14 | 74 |  |
| 601 | 293.6.4.3 | CT4 aspects of MCData |  | 75d? | 2016-12-01 A | 2017-03-15 A | 100% |  |  | finish no earlier than 2017-03-15 | C4 | 600h | 600h | MCImp-MCDATA-CT | 38 | HASON, Baruh | baruh.hason@motorolasolutions.com | Rel-14 | 74 |  |
| 602 | 293.6.4.4 | CT6 aspects of MCData |  | 140d? | 2016-12-01 A | 2017-06-14 A | 100% |  |  | finish no earlier than 2017-06-14 | C6 | 1120h | 1120h | MCImp-MCDATA-CT | 38 | HASON, Baruh | baruh.hason@motorolasolutions.com | Rel-14 | 74 |  |
| 603 | 293.7 | Security of the Mission Critical Service |  | 194d? | 2016-09-19 A | 2017-06-15 A | 100% |  |  | finish no earlier than 2017-06-15 | S3 | 1552h | 1552h | MCSec | 37 | Haigh, Peter, CESG | peter.haigh@cesg.gsi.gov.uk | Rel-14 | 73 |  |
| 604 | 293.8 | UE Conformance Test Aspects - Mission Critical Improvements |  | 588d? | 2018-03-15 | 2020-06-15 |  |  | 0d | finish no earlier than 2020-06-15 | R5 | 4704h |  | MCImp-UEConTest |  | NIST |  | Rel-14 | 79 |  |
| 605 | 294 | **Protocol enhancements for MCPTT over LTE** |  | 129d? | 2016-09-16 A | 2017-03-15 A | 100% |  |  |  | ct | 5160h | 5160h | MCPTTProtoc1 | 37 | Ricky Kaura | ricky.kaura@samsung.com | Rel-14 | 73 |  |
| 606 | 294.1 | CT1 aspects of MCPTTProtoc1 |  | 129d? | 2016-09-16 A | 2017-03-15 A | 100% |  |  | finish no earlier than 2017-03-15 | C1 | 1032h | 1032h | MCPTTProtoc1 | 37 | Ricky Kaura | ricky.kaura@samsung.com | Rel-14 | 73 |  |
| 607 | 294.2 | CT3 aspects of MCPTTProtoc1 |  | 129d? | 2016-09-16 A | 2017-03-15 A | 100% |  |  | finish no earlier than 2017-03-15 | C3 | 1032h | 1032h | MCPTTProtoc1 | 37 | Ricky Kaura | ricky.kaura@samsung.com | Rel-14 | 73 |  |
| 608 | 294.3 | CT4 aspects of MCPTTProtoc1 |  | 129d? | 2016-09-16 A | 2017-03-15 A | 100% |  |  | finish no earlier than 2017-03-15 | C4 | 1032h | 1032h | MCPTTProtoc1 | 37 | Ricky Kaura | ricky.kaura@samsung.com | Rel-14 | 73 |  |
| 609 | 294.4 | CT6 aspects of MCPTTProtoc1 |  | 129d? | 2016-09-16 A | 2017-03-15 A | 100% |  |  | finish no earlier than 2017-03-15 | C6 | 1032h | 1032h | MCPTTProtoc1 | 37 | Ricky Kaura | ricky.kaura@samsung.com | Rel-14 | 73 |  |
| 610 | 295 | Release 14 on V2X | milestone | 0d? | 2016-06-09 A | 2016-06-09 A | 100% |  |  | finish no earlier than 2016-06-09 |  |  |  |  |  |  |  | Rel-14 |  |  |
| 611 | 296 | **LTE support for V2X services** |  | 876d? | 2015-02-09 A | 2018-06-15 | 95% | 43.16d? | 521d |  |  | 20176h | 19232.8h | V2XLTE | 35 |  |  | Rel-14 | 68 |  |
| 612 | 296.1 | Stage 1 for LTE support for V2X services |  | 137d? | 2015-09-09 A | 2016-03-17 A | 100% |  |  | finish no earlier than 2016-03-17 | S1 | 1096h | 1096h | V2XLTE | 35 |  |  | Rel-14 | 68 |  |
| 613 | 296.2 | Architecture enhancements for LTE support of V2X services |  | 137d? | 2016-06-09 A | 2016-12-15 A | 100% |  |  | finish no earlier than 2016-12-15 | S2 | 1096h | 1096h | V2XARC | 37 | LG Electronics, LaeYoung Kim | laeyoung.kim@lge.com | Rel-14 | 72 |  |
| 614 | 296.3 | Security aspect of LTE support of V2X services |  | 141d? | 2016-12-01 A | 2017-06-15 A | 100% |  |  | finish no earlier than 2017-06-15 | S3 | 1128h | 1128h | V2XLTE-Sec | 38 | Huawei, Marcus Wong | mwong@huawei.com | Rel-14 | 74 |  |
| 615 | 296.4 | **RAN aspects of LTE-based V2X Services** |  | 524d? | 2016-06-15 A | 2018-06-15 | 85% | 78.4d? | 521d |  |  | 6304h | 5360.8h | LTE_V2X | 37 | LG Electronics |  | Rel-14 | 72 |  |
| 616 | 296.4.1 | Core part: LTE-based V2X Services |  | 197d? | 2016-06-15 A | 2017-03-15 A | 100% |  |  | finish no earlier than 2017-03-15 | R1 | 1576h | 1576h | LTE_V2X-Core | 37 | LG Electronics |  | Rel-14 | 72 | RP-170237 |
| 617 | 296.4.2 | Perf. part: LTE-based V2X Services |  | 329d? | 2016-06-15 A | 2017-09-15 A | 100% |  |  | finish no earlier than 2017-09-15 | R4 | 2632h | 2632h | LTE_V2X-Perf | 37 | LG Electronics |  | Rel-14 | 72 |  |
| 618 | 296.4.3 | UE Conformance Test Aspects - Support for LTE-based V2X Services |  | 262d? | 2017-06-15 A | 2018-06-15 | 55% | 117.9d? | 521d | finish no earlier than 2018-06-15 | R5 | 2096h | 1152.8h | LTE_V2X-UEConTest | 39 | Huawei |  | Rel-14 | 76 |  |
| 619 | 296.5 | **CT aspects of V2X Services** |  | 129d? | 2016-09-16 A | 2017-03-15 A | 100% |  |  |  | ct | 5160h | 5160h | V2X-CT | 37 | Taehun Kim | taehun78.kim@lge.com | Rel-14 | 73 |  |
| 620 | 296.5.1 | CT1 aspects of V2X Services |  | 129d? | 2016-09-16 A | 2017-03-15 A | 100% |  |  | finish no earlier than 2017-03-15 | C1 | 1032h | 1032h | V2X-CT | 37 | Taehun Kim | taehun78.kim@lge.com | Rel-14 | 73 |  |
| 621 | 296.5.2 | CT3 aspects of V2X Services |  | 129d? | 2016-09-16 A | 2017-03-15 A | 100% |  |  | finish no earlier than 2017-03-15 | C3 | 1032h | 1032h | V2X-CT | 37 | Taehun Kim | taehun78.kim@lge.com | Rel-14 | 73 |  |
| 622 | 296.5.3 | CT4 aspects of V2X Services |  | 129d? | 2016-09-16 A | 2017-03-15 A | 100% |  |  | finish no earlier than 2017-03-15 | C4 | 1032h | 1032h | V2X-CT | 37 | Taehun Kim | taehun78.kim@lge.com | Rel-14 | 73 |  |
| 623 | 296.5.4 | CT6 aspects of V2X Services |  | 129d? | 2016-09-16 A | 2017-03-15 A | 100% |  |  | finish no earlier than 2017-03-15 | C6 | 1032h | 1032h | V2X-CT | 37 | Taehun Kim | taehun78.kim@lge.com | Rel-14 | 73 |  |

Notes:
- 598: Impacted TSs and TRs: 24.582, 24.282
- 599: 6/3/17: 0%->10; 5/6/17: 10%->65; 5/6/17: 65%->90; 14/9/17: 90%->96; 15/12/17: 96%->100 / Impacted TSs and TRs: 24.381, 24.382, 24.383, 24.384
- 600: 5/6/17: 0%->100 / Impacted TSs and TRs: 29.165, 29.213, 29.214
- 601: 6/3/17: 0%->100 / Impacted TSs and TRs: 23.003, 23.335, 29.283
- 602: No work identified. / Impacted TSs and TRs: 31.102, 31.103
- 603: 6/10/16: 33.180 added; 1/12/16: 0%->25; 6/3/17: 25%->60; 7/6/17: 60%->85; 11/9/17: 85%->100 / Impacted TSs and TRs: 33.180
- 604: tested: REL-14 WI MCImp (SA/CT WI: Mission Critical Improvements); to provide conformance test specifications for the Rel-14 core requirements for improvements to Mission Critical Services (MCPTT, MCVideo and MCData).
- 605: This Feature is a stage-3 only feature that fixes/enhances MCPTT protocol level (not visible from stage2). Not to be confused with Rel-14 MCPTT Stage 3.
- 606: 6/3/17: 5%->100 / Impacted TSs and TRs: 24.229, 24.379, 24.380, 24.381, 24.382, 24.383, 24.384, 24.980
- 607: 2/12/16: 0%->20; 6/3/17: 20%->100 / Impacted TSs and TRs: 29.165, 29.212, 29.213, 29.214
- 608: 6/3/17: 0%->100 / Impacted TSs and TRs: 23.003, 23.008, 29.283
- 609: 5/6/17: 0%->100. No more work identified. / Impacted TSs and TRs: 31.102
- 610: -
- 611: 7/12/15: 0%->5; 28/1/16: 22.185 added; 2/3/16: 5%->90; 9/6/16: 90%->100 / Impacted TSs and TRs: 22.278; 22.185
- 612: 7/12/15: 0%->5; 28/1/16: 22.185 added; 2/3/16: 5%->90; 9/6/16: 90%->100 / Impacted TSs and TRs: 22.278; 22.185
- 613: 28/7/16: 23.285 added; 19/9/16: 0%->85; 1/12/16: FCD:09/16->12/16; 1/12/16: 85%->100 / Impacted TSs and TRs: 23.285
- 614: 6/3/17: 0%->75; 7/6/17: 75%->100 / Impacted TSs and TRs: 33.185
- 615: follow-up WI of REL-14 SI FS_LTE_V2X
- 616: follow-up WI of REL-14 SI FS_LTE_V2X26/9/16: Compl:0%->15%26/9/16: WID: RP-161298->RP-161894; 6/10/16: 36.786 added; 6/10/16: added; 20/12/16: Compl:15%->75% 21/3/17: Compl:75%->100%... / Impacted TSs and TRs: 36.786;
- 617: ; 26/9/16: WID: RP-161298->RP-161894; 20/12/16: WID: RP-161894->RP-162519; 20/12/16: Stat Rep: ->RP-162519; 19/6/17: Compl:0%->75%; 19/9/17: Compl:75%->100%
- 618: ; 19/9/17: Compl:0%->20%; 8/1/18: Compl:20%->40%; ...; 27/3/18: Compl:40%->55%
- 620: 6/10/16: 24.385 added; 6/10/16: 24.386 added; 2/12/16: 0%->65; 6/3/17: 65%->100 / Impacted TSs and TRs: 23.122, 24.301, 24.334; 24.385; 24.386
- 621: 6/10/16: 29.387 added; 2/12/16: 0%->40; 6/3/17: 40%->60; 5/6/17: 60%->100 / Impacted TSs and TRs: 29.212, 29.468; 29.387
- 622: 6/10/16: 29.388 added; 6/10/16: 29.389 added; 2/12/16: 0%->80; 6/3/17: 80%->100 / Impacted TSs and TRs: 23.003, 23.007, 23.008, 29.272; 29.388; 29.389
- 623: 7/3/17: 0%->100 / Impacted TSs and TRs: 31.102, 31.111

| ID | WBS | Task | Type | Duration | Start | Finish | Complete | Remaining | Total slack | Constraint | Resources | Work | Actual work | Acronym | PCG approved | WI rapporteur name | WI rapporteur e-mail | Release | TSG approved | Status Report |
| --- | --- | --- | --- | --- | --- | --- | --- | --- | --- | --- | --- | --- | --- | --- | --- | --- | --- | --- | --- | --- |
| 624 | 296.6 | **Study on LTE support for V2X services** |  | 355d? | 2015-02-09 A | 2016-06-17 A | 100% |  |  |  |  | 5392h | 5392h | FS_V2XLTE | 34 | Ki-Dong Lee (LG electronics) | kidong.lee@lge.com | Rel-14 | 67 |  |
| 625 | 296.6.1 | Study on Stage 1 of LTE support for V2X services |  | 1d? | 2015-02-09 A | 2015-02-09 A | 100% |  |  | start no earlier than 2015-09-07 | S1 | 8h | 8h | FS_V2XLTE_S1 | 34 | Ki-Dong Lee (LG electronics) | kidong.lee@lge.com | Rel-14 | 67 |  |
| 626 | 296.6.2 | Study on Stage 2 of LTE support for V2X services |  | 205d? | 2015-09-07 A | 2016-06-17 A | 100% |  |  | finish no earlier than 2016-06-17 | S2 | 1640h | 1640h | FS_V2XARC | 36 | LG Electronics, LaeYoung Kim | laeyoung.kim@lge.com | Rel-14 | 70 |  |
| 627 | 296.6.3 | Study on Security of LTE support for V2X services |  | 205d? | 2015-09-07 A | 2016-06-17 A | 100% |  |  | finish no earlier than 2016-06-17 | S3 | 1640h | 1640h | FS_V2XARC_S3 | 36 |  |  | Rel-14 | 70 |  |
| 628 | 296.6.4 | RAN1 Study on LTE-based V2X Services |  | 263d? | 2015-06-15 A | 2016-06-15 A | 100% |  |  | finish no earlier than 2016-09-15 | R1 | 2104h | 2104h | FS_LTE_V2X | 35 | LG Electronics |  | Rel-14 | 68 |  |
| 629 | 297 | **Support for V2V services based on LTE sidelink** |  | 655d? | 2015-12-15 A | 2018-06-15 | 91% | 57.01d? | 521d |  |  | 8400h | 7668.8h | LTE_SL_V2V | 36 | LG Electronics |  | Rel-14 | 70 |  |
| 630 | 297.1 | Core part: Support for V2V services based on LTE sidelink |  | 199d? | 2015-12-15 A | 2016-09-15 A | 100% |  |  | finish no earlier than 2016-09-15 | R1 | 1592h | 1592h | LTE_SL_V2V-Core | 36 | LG Electronics |  | Rel-14 | 70 |  |
| 631 | 297.2 | Perf. part: Support for V2V services based on LTE sidelink |  | 394d? | 2015-12-15 A | 2017-06-15 A | 100% |  |  | finish no earlier than 2017-06-15 | R4 | 3152h | 3152h | LTE_SL_V2V-Perf | 36 | LG Electronics |  | Rel-14 | 70 |  |
| 632 | 297.3 | UE Conformance Test Aspects - Support for V2V services based on LTE sidelink |  | 457d? | 2016-09-15 A | 2018-06-15 | 80% | 91.4d? | 521d | finish no earlier than 2018-06-15 | R5 | 3656h | 2924.8h | LTE_SL_V2V-UEConTest | 37 | Huawei |  | Rel-14 | 73 |  |
| 633 | 298 | Release 14 on CIoT | milestone | 0d? | 2016-06-09 A | 2016-06-09 A | 100% |  |  | finish no earlier than 2016-06-09 |  |  |  |  |  |  |  | Rel-14 |  |  |
| 634 | 299 | **Non-IP for Cellular Internet of Things (CIoT) for 2G/3G-GPRS(EC-EGPRS)** |  | 143d? | 2016-03-02 A | 2016-09-15 A | 100% |  |  |  |  | 4040h | 4040h | NonIP_GPRS | 36 |  |  | Rel-14 | 71 |  |
| 635 | 299.1 | Non-IP for Cellular IoT for EC-EGPRS |  | 76d? | 2016-03-02 A | 2016-06-15 A | 100% |  |  | start no earlier than 2016-03-02 | S2 | 608h | 608h | NonIP_GPRS | 36 | Hans Ronneke, Ericsson | hans . Ronneke (a) ericsson . Com | Rel-14 | 71 |  |
| 636 | 299.2 | **CT aspects for Non-IP for Cellular Internet of Things for EC-EGPRS** |  | 143d? | 2016-03-02 A | 2016-09-15 A | 100% |  |  |  |  | 3432h | 3432h | NonIP_GPRS-CT | 36 | Orange, Youssef CHADLI | youssef.chadli@orange.com | Rel-14 | 71 |  |
| 637 | 299.2.1 | CT1 aspects for Non-IP for Cellular Internet of Things for EC-EGPRS |  | 143d? | 2016-03-02 A | 2016-09-15 A | 100% |  |  | finish no earlier than 2016-09-15 | C1 | 1144h | 1144h | NonIP_GPRS-CT | 36 | Orange, Youssef CHADLI | youssef.chadli@orange.com | Rel-14 | 71 |  |
| 638 | 299.2.2 | CT3 aspects for Non-IP for Cellular Internet of Things for EC-EGPRS |  | 143d? | 2016-03-02 A | 2016-09-15 A | 100% |  |  | finish no earlier than 2016-09-15 | C3 | 1144h | 1144h | NonIP_GPRS-CT | 37 | Orange, Youssef CHADLI | youssef.chadli@orange.com | Rel-14 | 72 |  |
| 639 | 299.2.3 | CT4 aspects for Non-IP for Cellular Internet of Things for EC-EGPRS |  | 143d? | 2016-03-02 A | 2016-09-15 A | 100% |  |  | finish no earlier than 2016-09-15 | C4 | 1144h | 1144h | NonIP_GPRS-CT | 36 | Orange, Youssef CHADLI | youssef.chadli@orange.com | Rel-14 | 71 |  |
| 640 | 300 | **Further enhanced MTC for LTE** |  | 524d? | 2016-06-15 A | 2018-06-15 | 82% | 95.12d? | 521d |  |  | 6824h | 5585.28h | LTE_feMTC | 37 | Ericsson |  | Rel-14 | 72 |  |
| 641 | 300.1 | Core part: Further enhanced MTC for LTE |  | 263d? | 2016-06-15 A | 2017-06-15 A | 100% |  |  | finish no earlier than 2017-06-15 | R1 | 2104h | 2104h | LTE_feMTC-Core | 37 | Ericsson |  | Rel-14 | 72 | RP-171441 |
| 642 | 300.2 | Perf. part: Further enhanced MTC for LTE |  | 394d? | 2016-06-15 A | 2017-12-15 A | 100% |  |  | finish no earlier than 2017-12-15 | R4 | 3152h | 3152h | LTE_feMTC-Perf | 37 | Ericsson |  | Rel-14 | 72 |  |
| 643 | 300.3 | UE Conformance Test Aspects - Further enhanced MTC for LTE |  | 196d? | 2017-09-15 A | 2018-06-15 | 21% | 154.84d? | 521d | finish no earlier than 2018-06-15 | R5 | 1568h | 329.28h | LTE_feMTC-UEConTest | 39 | Ericsson |  | Rel-14 | 77 |  |
| 644 | 301 | **Enhancements of NB-IoT** |  | 654d? | 2016-06-15 A | 2018-12-15 | 77% | 151.82d? | 391d |  |  | 7864h | 6038.4h | NB_IOTenh | 37 | Huawei |  | Rel-14 | 72 |  |
| 645 | 301.1 | Core part: Enhancements of NB-IoT |  | 263d? | 2016-06-15 A | 2017-06-15 A | 100% |  |  | finish no earlier than 2017-06-15 | R1 | 2104h | 2104h | NB_IOTenh-Core | 37 | Huawei |  | Rel-14 | 72 | RP-171061 |
| 646 | 301.2 | Perf. part: Enhancements of NB-IoT |  | 394d? | 2016-06-15 A | 2017-12-15 A | 100% |  |  | finish no earlier than 2017-12-15 | R4 | 3152h | 3152h | NB_IOTenh-Perf | 37 | Huawei |  | Rel-14 | 72 |  |
| 647 | 301.3 | UE Conformance Test Aspects - Enhancements of NB-IoT |  | 326d? | 2017-09-15 A | 2018-12-15 | 30% | 228.2d? | 391d | finish no earlier than 2018-12-15 | R5 | 2608h | 782.4h | NB_IOTenh-UEConTest | 39 | Huawei |  | Rel-14 | 77 |  |
| 648 | 302 | AT Commands for CIoT |  | 65d? | 2016-09-16 A | 2016-12-15 A | 100% |  |  | finish no earlier than 2016-12-15 | C1 | 520h | 520h | AT_CIoT | 37 | John-Luc Bakker |  | Rel-14 | 73 |  |

Notes:
- 624: 1/4/15:TR number added; June2015: Compl:25%->50; 07/09/15: 50%->75 / Impacted TSs and TRs: New TR 22.885
- 625: 1/4/15:TR number added; June2015: Compl:25%->50; 07/09/15: 50%->75; 7/12/15: 75%->100 / Impacted TSs and TRs: New TR 22.885
- 626: 11/12/15: WID:SP-150625->SP-150743; 7/3/16: 10%->22; 7/3/16: WID:SP-150743->SP-150852; 9/6/16: 22%->80; 19/9/16: 80%->100 / Impacted TSs and TRs: TR 23.785
- 627: Introduced at 100% completion, as per SA3 report to SA#76 / Impacted TSs and TRs: TR 33.885
- 628: 29/09/15: Compl:0%->5% 29/09/15: Stat Rep: -->RP-151311 ; 28/1/16: 33.885 added;22/3/16: Compl:35%->50%22/3/16: CD:Wed 15/06/16->Thu 15/09/1622/3/16: WID: RP-15; / Impacted TSs and TRs: 33.885
- 630: 22/3/16: Compl:0%->15%22/3/16: WID: RP-152293->RP-1606491/7/16: Compl:15%->60%1/7/16: WID: RP-160649->RP-161272; 28/7/16: 36.785 added; 26/9/16: Compl:60%->100%; 26/9/16: WID: RP-161272->RP-161603 / Impacted TSs and TRs: 36.785
- 631: 22/3/16: WID: RP-152293->RP-1606491/7/16: WID: RP-160649->RP-16127226/9/16: WID: RP-161272->RP-161603; 20/12/16: Compl:0%->50% 21/3/17: Compl:50%->80% 21/3/17: CD:Wed 15/03/17->Thu 15/06/1719/6/17: Compl:80%->100%
- 632: ; 20/12/16: Compl:0%->5% 21/3/17: Compl:5%->15%19/9/17: Compl:15%-...; 8/1/18: Com...27/...
- 633: -
- 635: 9/6/16: 0%->50; 19/9/16: 50%->100 / Impacted TSs and TRs: 23.060, 23.682, 23.401?
- 636: 11/6/16: WID:CP-160161->CP-160293
- 637: 11/6/16: 0%->50; 11/6/16: WID:CP-160161->CP-160293; 16/9/16: 50%->65; 2/12/16: 65%->100 / Impacted TSs and TRs: 24.008
- 638: 11/6/16: WID:CP-160161->CP-160293; 13/6/16: 0%->65; 20/9/16: 0%->100 / Impacted TSs and TRs: 29.060, 29.274, 29.002, 29.303, 23.008, 29.128, 29.272, 23.007
- 639: 11/6/16: WID:CP-160161->CP-160293; 13/6/16: 0%->65; 2/12/16: 65%->100 / Impacted TSs and TRs: 29.060, 29.274, 29.002, 29.303, 23.008, 29.128, 29.272, 23.007
- 641: 26/9/16: Compl:0%->12%26/9/16: WID: RP-161321->RP-161464; 20/12/16: Compl:12%->70%; 20/12/16: WID: RP-161464->RP-16252021/3/17: Compl:70%->95% ; 21/3/17: CD...19/6/17: Compl:95%->100%...
- 642: ; 26/9/16: WID: RP-161321->RP-161464; 20/12/16: WID: RP-161464->RP-162520; 20/12/16: Stat Rep: ->RP-16252021/3/17: CD:Fri 15/09/17->Fri 15/12/1721/3/17...; 19/6/17: Compl:0%->35%19/9/17: Compl:35%->60%; 8/1/18: Compl:60%->100%
- 643: ; 8/1/18: Compl:0%->6%; 27/3/18: Compl:6%->21%; ...
- 645: 26/9/16: Compl:0%->13%26/9/16: WID: RP-161324->RP-161901; 20/12/16: Compl:13%->70%; 21/3/17: Compl:70%->95%; 21/3/17: CD:Wed 15/03/17->Thu 15/06/1719/6/17: Compl:95%->100%...
- 646: 26/9/16: WID: RP-161324->RP-16190121/3/17: CD:Fri 15/09/17->Fri 15/12/17; 19/6/17: Compl:0%->50%; 19/6/17: WID: RP-161901->RP-171060; 19/9/17: Compl:50%->60%; 8/1/18: Compl:60%->100%
- 647: ; 8/1/18: Compl:0%->5%27/3/18: Compl:5%->30%
- 648: 2/12/16: 10%->95; 6/3/17: 95%->100

| ID | WBS | Task | Duration | Start | Finish | Complete | Remaining | Total slack | Constraint | Resources | Work | Actual work | Acronym | PCG approved | WI rapporteur name | WI rapporteur e-mail | Release | TSG approved | Status Report |
| --- | --- | --- | --- | --- | --- | --- | --- | --- | --- | --- | --- | --- | --- | --- | --- | --- | --- | --- | --- |
| 649 | 303 | **Extended architecture support for Cellular Internet of Things** | 194d? | 2016-06-17 A | 2017-03-14 A | 100% |  |  |  |  | 3360h | 3360h | CIoT_Ext | 37 | Intel : Puneet Jain | puneet.jain@intel.com | Rel-14 | 73 |  |
| 650 | 303.1 | Study on extended architecture support for Cellular Internet of Things | 131d? | 2016-06-17 A | 2016-12-15 A | 100% |  |  | finish no earlier than 2016-12-15 | S2 | 1048h | 1048h | FS_CIoT_Ext | 37 | Intel : Puneet Jain | puneet.jain@intel.com | Rel-14 | 72 |  |
| 651 | 303.2 | Stage 2 of Extended architecture support for Cellular Internet of Things | 67d? | 2016-09-15 A | 2016-12-16 A | 100% |  |  | finish no earlier than 2016-12-16 | S2 | 536h | 536h | CIoT_Ext | 37 | Intel : Puneet Jain | puneet.jain@intel.com | Rel-14 | 73 |  |
| 652 | 303.3 | **Stage 3 of extended architecture enhancements for Cellular Internet of Things** | 74d? | 2016-12-01 A | 2017-03-14 A | 100% |  |  |  | ct | 1776h | 1776h | CIoT_Ext-CT | 38 | Intel, Vivek Gupta | vivek.g.gupta@intel.com | Rel-14 | 74 |  |
| 653 | 303.3.1 | CT1 aspects of extended architecture enhancements for Cellular Internet of Things | 74d? | 2016-12-01 A | 2017-03-14 A | 100% |  |  | finish no earlier than 2017-03-14 | C1 | 592h | 592h | CIoT_Ext-CT | 38 | Intel, Vivek Gupta | vivek.g.gupta@intel.com | Rel-14 | 74 |  |
| 654 | 303.3.2 | CT4 aspects of extended architecture enhancements for Cellular Internet of Things | 74d? | 2016-12-01 A | 2017-03-14 A | 100% |  |  | finish no earlier than 2017-03-14 | C4 | 592h | 592h | CIoT_Ext-CT | 38 | Intel, Vivek Gupta | vivek.g.gupta@intel.com | Rel-14 | 74 |  |
| 655 | 304 | **Radio Interface Enhancements for Extended Coverage GSM for support of Cellular Internet of Things** | 457d? | 2016-09-15 A | 2018-06-15 | 99% | 0d? | 0d |  | R6 | 5760h | 3672h | CIoT_EC_GSM_radio_enh | 37 | Nokia |  | Rel-14 | 73 |  |
| 656 | 304.1 | Core part: Radio Interface Enhancements for Extended Coverage GSM for support of Cellular Internet of Things | 196d? | 2016-09-15 A | 2017-06-15 A | 100% |  |  | finish no earlier than 2017-06-15 | R6 | 1568h | 1568h | CIoT_EC_GSM_radio_enh-Core | 37 | Nokia |  | Rel-14 | 73 | RP-171321 |
| 657 | 304.2 | Perf. part: Radio Interface Enhancements for Extended Coverage GSM for support of Cellular Internet of Things | 67d? | 2018-03-15 A | 2018-06-15 A | 100% |  |  |  | R6 | 536h | 536h | CIoT_EC_GSM_radio_enh-Perf | 37 | Nokia |  | Rel-14 | 73 |  |
| 658 | 305 | **New band support for Rel-14 Narrowband Internet of Things (NB-IOT)** | 262d? | 2016-09-15 A | 2017-09-15 | 99% | 0d? | 0d |  | R4 | 6296h | 5229.66h | NB_IOT_R14_bands | 37 | Ericsson |  | Rel-14 | 73 |  |
| 659 | 305.1 | Core part: New band support for Rel-14 Narrowband Internet of Things (NB-IOT) | 196d? | 2016-09-15 A | 2017-06-15 A | 100% |  |  | finish no earlier than 2017-06-15 | R4 | 1568h | 1568h | NB_IOT_R14_bands-Core | 37 | Ericsson |  | Rel-14 | 73 | RP-170970 |
| 660 | 305.2 | Perf. part: New band support for Rel-14 Narrowband Internet of Things (NB-IOT) | 196d? | 2016-09-15 A | 2017-06-15 A | 100% |  |  | finish no earlier than 2017-06-15 | R4 | 1568h | 1568h | NB_IOT_R14_bands-Perf | 37 | Ericsson |  | Rel-14 | 73 |  |
| 661 | 305.3 | UE Conformance Test Aspects - New band support for Rel-14 NB-IoT | 133d? | 2017-03-15 A | 2017-09-15 A | 100% |  |  | finish no earlier than 2017-12-15 | R5 | 1064h | 1064h | NB_IOT_R14_bands-UEConTest | 38 | Ericsson |  | Rel-14 | 75 |  |
| 662 | 306 | **Enhancements of Dedicated Core Networks selection mechanism** | 588d? | 2015-09-17 A | 2017-12-15 | 99% | 0d? | 0d |  |  | 7808h | 6232h | eDecor | 35 | Roland Gustafsson | Roland.Gustafsson@ericsson.com | Rel-14 | 69 | SP-170537 |
| 663 | 306.1 | Study on Enhancements of Dedicated Core Networks selection mechanism | 132d? | 2015-09-17 A | 2016-03-18 A | 100% |  |  | finish no earlier than 2016-03-18 | S2 | 1056h | 1056h | FS_eDecor | 35 | Roland Gustafsson | Roland.Gustafsson@ericsson.com | Rel-14 | 69 |  |
| 664 | 306.2 | Enhancements of Dedicated Core Networks selection mechanism | 72d? | 2016-06-09 A | 2016-09-15 A | 100% |  |  | finish no earlier than 2016-09-15 | S2 | 576h | 576h | eDecor | 37 | Roland Gustafsson | Roland.Gustafsson@ericsson.com | Rel-14 | 72 |  |
| 665 | 306.3 | **CT aspects of eDecor** | 65d? | 2016-09-16 A | 2016-12-15 A | 100% |  |  |  | ct | 2080h | 2080h | eDecor-CT | 37 | Mikael Wass | Mikael.wass@ericsson.com | Rel-14 | 73 |  |
| 666 | 306.3.1 | CT1 aspects of eDecor | 65d? | 2016-09-16 A | 2016-12-15 A | 100% |  |  | finish no earlier than 2016-12-15 | C1 | 520h | 520h | eDecor-CT | 37 | Mikael Wass | Mikael.wass@ericsson.com | Rel-14 | 73 |  |
| 667 | 306.3.2 | CT4 aspects of eDecor | 65d? | 2016-09-16 A | 2016-12-15 A | 100% |  |  | finish no earlier than 2016-12-15 | C4 | 520h | 520h | eDecor-CT | 37 | Mikael Wass | Mikael.wass@ericsson.com | Rel-14 | 73 |  |
| 668 | 306.3.3 | CT6 aspects of eDecor | 65d? | 2016-09-16 A | 2016-12-15 A | 100% |  |  | finish no earlier than 2016-12-15 | C6 | 520h | 520h | eDecor-CT | 37 | Mikael Wass | Mikael.wass@ericsson.com | Rel-14 | 73 |  |
| 669 | 306.4 | **RAN aspects of eDECOR for UMTS and LTE** | 262d? | 2016-12-15 A | 2017-12-15 | 99% | 0d? | 0d |  | R3 | 3672h | 2096h | eDECOR-UTRA_LTE | 38 | Ericsson |  | Rel-14 | 74 |  |
| 670 | 306.4.1 | Core part: RAN aspects of eDECOR for UMTS and LTE | 65d? | 2016-12-15 A | 2017-03-15 A | 100% |  |  | finish no earlier than 2017-03-15 | R3 | 520h | 520h | eDECOR-UTRA_LTE-Core | 38 | Ericsson |  | Rel-14 | 74 | RP-170547 |
| 671 | 306.4.2 | UE Conformance Test Aspects - Enhancements of Dedicated Core Networks for UTRA and LTE | 132d? | 2017-06-15 A | 2017-12-15 A | 100% |  |  | finish no earlier than 2017-12-15 | R5 | 1056h | 1056h | eDECOR-UTRA_LTE-UEConTest | 39 | Ericsson |  | Rel-14 | 76 |  |
| 672 | 306.5 | Deleted - GSM aspects of eDECOR | 53d? | 2017-04-04 A | 2017-06-15 A | 100% |  |  | start no earlier than 2017-04-04 | R6 | 424h | 424h | eDecor | 39 | Ericsson |  | Rel-14 | 76 |  |

Notes:
- 649: Impacted TSs and TRs: 23.401, 23.682, 23.060
- 650: 28/7/16: 23.730 added; 19/9/16: 0%->70; 1/12/16: FCD:03/17->12/16; 1/12/16: 70%->100 / Impacted TSs and TRs: 23.730
- 651: 1/12/16: 0%->100; 1/12/16: WID:SP-160732->SP-160830 / Impacted TSs and TRs: 23.401, 23.682, 23.060, 23.271
- 652: 21/3/17: 24.250 added; / Impacted TSs and TRs: 24.250
- 653: 6/3/17: 0%->50; 5/6/17: 50%->100 / Impacted TSs and TRs: 24.301, 24.008
- 654: 6/3/17: 0%->90; 5/6/17: 90%->100 / Impacted TSs and TRs: 23.008, 29.272, 29.002, 29.336, 29.128, 29.171, 29.172, 29.173
- 656: ; 20/12/16: Compl:0%->50% 21/3/17: Compl:50%->80%...19/6/17: Compl:80%->100%...
- 657: ; 20/12/16: Compl:0%->20% ; 21/3/17: Compl:20%->80%; ...; 19/6/17: Compl:80%->100%
- 659: ; 20/12/16: Compl:0%->99% 21/3/17: CD:Wed 15/03/17->Thu 15/06/17; ;...19/6/17: Compl:99%->100%19/6/17: Stat Rep: ->RP-170970
- 660: ; 20/12/16: Compl:0%->99% 21/3/17: Compl:99%->70% ...; 19/6/17: Compl:70%->100%
- 661: tested: REL-14 NB_IOT_R14_bands-Core (which got an exception at RAN #75 to still complete in REL-14 by RAN #76);...; ;...
- 662: 7/12/15: 0%->70; 7/3/16: 70%->80; 9/6/16: 80%->95 / Impacted TSs and TRs: 23.711
- 663: 7/12/15: 0%->70; 7/3/16: 70%->80; 9/6/16: 80%->95; 19/9/16: 95%->100 / Impacted TSs and TRs: 23.711
- 664: 19/9/16: 70%->100 / Impacted TSs and TRs: 23.401, 23.060, 23.251
- 666: 2/12/16: 0%->80; 6/3/17: 80%->95; 5/6/17: 95%->100 / Impacted TSs and TRs: 24.301, 24.008, 24.368
- 667: 2/12/16: 0%->10; 6/3/17: 10%->100 / Impacted TSs and TRs: 29.303, 23.003, 23.008
- 668: 14/12/16: 0%->15; 7/3/17: 15%->85; 5/6/17: 85%->100 / Impacted TSs and TRs: 31.102, 31.111
- 670: 21/3/17: Compl:0%->100%21/3/17: Stat Rep: ->RP-170547
- 671: ; 19/9/17: Compl:0%->50%; ...; 8/1/18: Compl:50%->100%
- 672: Verbal addition by Paolo U. 21/09/17: verbal deletion by Paolo / Impacted TSs and TRs: 44.060, 44.018, 48.018

| ID | WBS | Task | Type | Duration | Start | Finish | Complete | Constraint | Resources | Work | Actual work | Acronym | PCG approved | WI rapporteur name | Release | TSG approved | Impacted TSs and TRs | WI rapporteur e-mail | Status Report |
| --- | --- | --- | --- | --- | --- | --- | --- | --- | --- | --- | --- | --- | --- | --- | --- | --- | --- | --- | --- |
| 673 | 307 | **Addition of band 25 and 26 to LTE MTC cat.0** |  | 65d? | 2016-12-15 A | 2017-03-15 A | 100% |  | R4 | 1040h | 1040h | LC_MTC_LTE_cat0_B25_B26 | 38 | Sprint | Rel-14 | 74 |  |  |  |
| 674 | 307.1 | Core part: Addition of band 25 and 26 to LTE MTC cat.0 |  | 65d? | 2016-12-15 A | 2017-03-15 A | 100% | finish no earlier than 2017-03-15 | R4 | 520h | 520h | LC_MTC_LTE_cat0_B25_B26-Core | 38 | Sprint | Rel-14 | 74 |  |  |  |
| 675 | 308 | Addition of bands 25 and 40 to LTE MTC cat.1 |  | 65d? | 2016-12-15 A | 2017-03-15 A | 100% | finish no earlier than 2017-03-15 | R4 | 520h | 520h | LTE_MTCe2_L1_cat1_B25_B40-Core | 38 | Sprint | Rel-14 | 74 |  |  |  |
| 676 | 309 | Release 14 on WLAN | milestone | 0d? | 2016-06-09 A | 2016-06-09 A | 100% | finish no earlier than 2016-06-09 |  |  |  |  |  |  | Rel-14 |  |  |  |  |
| 677 | 310 | **EIR check for WLAN access to EPC** |  | 230d? | 2015-11-02 A | 2016-09-15 A | 100% |  |  | 3000h | 3000h | EWE | 36 | Alcatel-Lucent, Nicolas Drevon | Rel-14 | 70 | 23.002, 23.402 | Nicolas.Drevon@alcatel-lucent.com |  |
| 678 | 310.1 | Stage 2 of EWE |  | 165d? | 2015-11-02 A | 2016-06-17 A | 100% | finish no earlier than 2016-06-17 | S2 | 1320h | 1320h | EWE | 36 | Alcatel-Lucent, Nicolas Drevon | Rel-14 | 70 | 23.002, 23.402 | Nicolas.Drevon@alcatel-lucent.com |  |
| 679 | 310.2 | **CT aspects of EWE** |  | 70d? | 2016-06-13 A | 2016-09-15 A | 100% |  | ct | 1680h | 1680h | EWE-CT | 37 | Nokia, Bruno Landais | Rel-14 | 72 |  | bruno.landais@nokia.com |  |
| 680 | 310.2.1 | CT1 aspects of EWE |  | 70d? | 2016-06-13 A | 2016-09-15 A | 100% | finish no earlier than 2016-09-15 | C1 | 560h | 560h | EWE-CT | 37 | Nokia, Bruno Landais | Rel-14 | 72 | 24.302 | bruno.landais@nokia.com |  |
| 681 | 310.2.2 | CT4 aspects of EWE |  | 70d? | 2016-06-13 A | 2016-09-15 A | 100% | finish no earlier than 2016-09-15 | C4 | 560h | 560h | EWE-CT | 37 | Nokia, Bruno Landais | Rel-14 | 72 | 29.273 | bruno.landais@nokia.com |  |
| 682 | 311 | **Support of EAP Re-authentication Protocol for WLAN Interworking** |  | 130d? | 2016-09-16 A | 2017-03-16 A | 100% |  |  | 4152h | 4152h | ERP | 37 | ORANGE, Todor Gamishev | Rel-14 | 73 |  | Todor dot Gamishev at Orange dot com |  |
| 683 | 311.1 | Support of EAP Re-authentication Protocol for WLAN Interworking |  | 129d? | 2016-09-16 A | 2017-03-15 A | 100% | finish no earlier than 2017-03-15 | S3 | 1032h | 1032h | ERP | 37 | ORANGE, Todor Gamishev | Rel-14 | 73 | 33.402 | Todor dot Gamishev at Orange dot com |  |
| 684 | 311.2 | **CT aspects of ERP** |  | 130d? | 2016-09-16 A | 2017-03-16 A | 100% |  | ct | 3120h | 3120h | ERP-CT | 37 | Orange, Julien Bournelle | Rel-14 | 73 |  | Julien.bournelle@orange.com |  |
| 685 | 311.2.1 | CT1 aspects of ERP |  | 130d? | 2016-09-16 A | 2017-03-16 A | 100% | finish no earlier than 2017-03-16 | C1 | 1040h | 1040h | ERP-CT | 37 | Orange, Julien Bournelle | Rel-14 | 73 | 24.302 | Julien.bournelle@orange.com |  |
| 686 | 311.2.2 | CT4 aspects of ERP |  | 130d? | 2016-09-16 A | 2017-03-16 A | 100% | finish no earlier than 2017-03-16 | C4 | 1040h | 1040h | ERP-CT | 37 | Orange, Julien Bournelle | Rel-14 | 73 | 29.273, 23.008, 23.003 | Julien.bournelle@orange.com |  |
| 687 | 312 | **Phase 2 of the Support of Emergency services over WLAN** |  | 403d? | 2015-09-01 A | 2017-03-15 A | 100% |  |  | 5328h | 5328h | SEW2 | 37 | Nicolas Drevon | Rel-14 | 72 | new 23.771, TS 23.402, TS 23.167 | nicolas.drevon@nokia.com |  |
| 688 | 312.1 | Study on Phase 2 of the Support of Emergency services over WLAN |  | 208d? | 2015-09-01 A | 2016-06-16 A | 100% | finish no earlier than 2016-06-16 | S2 | 1664h | 1664h | FS_SEW2 | 34 | Laurent Thiebaut, Alcatel Lucent | Rel-14 | 67 | new 23.771 | Laurent.thiebaut@alcatel-lucent.com |  |
| 689 | 312.2 | Support of Emergency services over WLAN - phase 2 |  | 70d? | 2016-06-13 A | 2016-09-15 A | 100% | finish no earlier than 2016-09-15 | S2 | 560h | 560h | SEW2 | 37 | Nicolas Drevon | Rel-14 | 72 | TS 23.402, TS 23.167 | nicolas.drevon@nokia.com |  |
| 690 | 312.3 | **CT aspects of SEW2** |  | 129d? | 2016-09-16 A | 2017-03-15 A | 100% |  | ct | 3104h | 3104h | SEW2-CT | 37 | Jennifer Liu | Rel-14 | 73 |  | jennifer.liu@nokia.com |  |
| 691 | 312.3.1 | CT1 aspects of SEW2 |  | 129d? | 2016-09-16 A | 2017-03-15 A | 100% | finish no earlier than 2017-03-15 | C1 | 1032h | 1032h | SEW2-CT | 37 | Jennifer Liu | Rel-14 | 73 | 24.302, 24.312, 24.301, 24.244, 24.229, 24.237 | jennifer.liu@nokia.com |  |
| 692 | 312.3.2 | CT4 aspects of SEW2 |  | 129d? | 2016-09-16 A | 2017-03-15 A | 100% | finish no earlier than 2017-03-15 | C4 | 1032h | 1032h | SEW2-CT | 37 | Jennifer Liu | Rel-14 | 73 | 23.003, 29.272, 29.273, 29.274, 29.328 | jennifer.liu@nokia.com |  |
| 693 | 312.3.3 | Deleted - CT6 aspects of SEW2 |  | 1d? | 2016-12-14 A | 2016-12-14 A | 100% | finish no earlier than 2016-12-14 | C6 | 8h | 8h | SEW2-CT | 37 | Jennifer Liu | Rel-14 | 73 | 31.102 | jennifer.liu@nokia.com |  |
| 694 | 313 | T-ADS supporting WLAN Access |  | 134d? | 2016-03-15 A | 2016-09-15 A | 100% | finish no earlier than 2016-09-15 | S2 | 1072h | 1072h | TADS_WLAN | 37 | Jiang Yi | Rel-14 | 72 | TS 23.292, TS 23.221, TS 23.402 | jiangyi (at) chinamobile (dot) com | SP-170519 |
| 695 | 314 | **Enhanced LTE-WLAN Aggregation (LWA)** |  | 263d? | 2016-03-15 A | 2017-03-15 A | 100% |  | R2 | 4208h | 4208h | LTE_WLAN_aggr | 36 | Intel | Rel-14 | 71 |  |  |  |
| 696 | 314.1 | Core part: Enhanced LTE-WLAN Aggregation (LWA) |  | 263d? | 2016-03-15 A | 2017-03-15 A | 100% | finish no earlier than 2017-03-15 | R2 | 2104h | 2104h | LTE_WLAN_aggr-Core | 36 | Intel | Rel-14 | 71 |  |  | RP-170330 |
| 697 | 315 | Release 14 on IMS | milestone | 0d? | 2016-06-09 A | 2016-06-09 A | 100% | finish no earlier than 2016-06-09 |  |  |  |  |  |  | Rel-14 |  |  |  |  |

Notes:
- 674: ; 21/3/17: Compl:0%->100%
- 675: ; 21/3/17: Compl:0%->100%
- 676: -
- 677: 7/3/16: 45%->60; 9/6/16: 60%->100
- 678: 7/3/16: 45%->60; 9/6/16: 60%->100
- 680: 16/9/16: 0%->100
- 681: 2/12/16: 0%->100
- 683: 1/12/16: 0%->90; 6/3/17: 90%->100
- 685: 2/12/16: 0%->80; 6/3/17: 80%->95; 5/6/17: 95%->100
- 686: 2/12/16: 0%->50; 6/3/17: 50%->95; 5/6/17: 95%->100
- 688: June2015: Compl:0%->100, SP-150151->SP-150251; 7/12/15: 0%->30, FCD: 12/15->06/16; 7/3/16: 30%->75; 7/3/16: WID:SP-150251->SP-160173; 9/6/16: 75%->100
- 689: 11/6/16: 0%->45; 19/9/16: 45%->100
- 690: 5/12/16: WID:CP-160476->CP-160694
- 691: 2/12/16: 20%->95; 5/6/17: 95%->100
- 692: 2/12/16: 0%->100
- 693: Deleted at CT6#82
- 694: 19/9/16: 0%->100
- 695: follow-up WI of REL-13 WI LTE_WLAN_radio; no Perf. part
- 696: follow-up WI of REL-13 WI LTE_WLAN_radio; no Perf. part1/7/16: Compl:0%->25%1/7/16: WID: RP-160600->RP-160923; 26/9/16: Compl:25%->45%; 20/12/16: Compl:45%->75%; 20/12/16: Stat Rep: --> ; 21/3/17: Compl:75%->100% ; 21/3/17...
- 697: -

| ID | WBS | Task | Type | Duration | Start | Finish | Complete | Remaining | Baseline start | Baseline finish | Baseline duration | Total slack | Constraint | Resources | Work | Actual work | Acronym | PCG approved | Impacted TSs and TRs | WI rapporteur name | Release | TSG approved | Status Report | WI rapporteur e-mail | MCC resp | Acronym_3GU_Export |
| --- | --- | --- | --- | --- | --- | --- | --- | --- | --- | --- | --- | --- | --- | --- | --- | --- | --- | --- | --- | --- | --- | --- | --- | --- | --- | --- |
| 698 | 316 | **Evolution to and Interworking with eCall in IMS** |  | 745d? | 2015-05-11 A | 2018-03-15 A | 100% |  |  |  |  |  |  |  | 6288h | 6288h | EIEI | 35 | 22.101 | Kurt Bischinger | Rel-14 | 68 | SP-170538 |  |  |  |
| 699 | 316.1 | Stage 1 of Evolution to and Interworking with eCall in IMS |  | 30d? | 2015-05-11 A | 2015-06-19 A | 100% |  |  |  |  |  | start no earlier than 2015-05-11 | S1 | 240h | 240h | EIEI | 35 | 22.101 | Kurt Bischinger | Rel-14 | 68 |  |  |  |  |
| 700 | 316.2 | Stage 2 of Evolution to and Interworking with eCall in IMS |  | 131d? | 2015-12-11 A | 2016-06-10 A | 100% |  |  |  |  |  | finish no earlier than 2016-06-10 | S2 | 1048h | 1048h | EIEI | 35 | 23.167, 23.401 | Haris Zisimopoulos, Qualcomm Incorporated | Rel-14 | 68 |  | harisz@qti.qualcomm.com |  |  |
| 701 | 316.3 | **CT aspects of evolution to and interworking with eCall in IMS** |  | 143d? | 2016-03-02 A | 2016-09-15 A | 100% |  |  |  |  |  |  |  | 3432h | 3432h | EIEI-CT | 36 |  | Lena Chaponniere | Rel-14 | 71 |  | lguellec@qti.qualcomm.com |  |  |
| 702 | 316.3.1 | CT1 aspects of evolution to and interworking with eCall in IMS |  | 143d? | 2016-03-02 A | 2016-09-15 A | 100% |  |  |  |  |  | finish no earlier than 2016-09-15 | C1 | 1144h | 1144h | EIEI-CT | 36 | 24.229, 24.301 | Lena Chaponniere | Rel-14 | 71 |  | lguellec@qti.qualcomm.com |  |  |
| 703 | 316.3.2 | (IETF) Next-Generation Pan-European eCall (draft-ietf-ecrit-ecall) |  | 143d? | 2016-03-02 A | 2016-09-15 A | 100% |  |  |  |  |  | finish no earlier than 2016-09-15 | C1-IETF | 1144h | 1144h | EIEI-CT | 37 | draft-ietf-ecrit-ecall |  | Rel-14 | 72 |  |  |  |  |
| 704 | 316.3.3 | CT6 aspects of evolution to and interworking with eCall in IMS |  | 143d? | 2016-03-02 A | 2016-09-15 A | 100% |  |  |  |  |  | finish no earlier than 2016-09-15 | C6 | 1144h | 1144h | EIEI-CT | 36 | 31.102 | Lena Chaponniere | Rel-14 | 71 |  | lguellec@qti.qualcomm.com |  |  |
| 705 | 316.4 | UE Conformance Test Aspects - Evolution to and Interworking with eCall in IMS (EIEI) |  | 196d? | 2017-06-15 A | 2018-03-15 A | 100% |  |  |  |  |  | finish no earlier than 2018-03-15 | R5 | 1568h | 1568h | EIEI-UEConTest | 39 |  | Qualcomm | Rel-14 | 76 |  |  |  |  |
| 706 | 317 | **Password based service activation for IMS Multimedia Telephony service** |  | 463d? | 2015-03-11 A | 2016-12-15 A | 100% |  |  |  |  |  |  |  | 3264h | 3264h | PWDIMS | 34 | 22.173 | Peter Bleckert (Ericsson) | Rel-14 | 67 | SP-170536 |  |  |  |
| 707 | 317.1 | Stage 1 for PWDIMS |  | 3d? | 2015-03-11 A | 2015-03-13 A | 100% |  |  |  |  |  | finish no earlier than 2015-03-13 | S1 | 24h | 24h | PWDIMS | 34 | 22.173 | Peter Bleckert (Ericsson) | Rel-14 | 67 |  |  |  |  |
| 708 | 317.2 | **CT aspects for PWDIMS** |  | 135d? | 2016-06-13 A | 2016-12-15 A | 100% |  |  |  |  |  |  | ct | 3240h | 3240h | PWDIMS-CT | 37 |  | Axell, Jörgen | Rel-14 | 72 |  |  |  |  |
| 709 | 317.2.1 | CT1 aspects for PWDIMS |  | 135d? | 2016-06-13 A | 2016-12-15 A | 100% |  |  |  |  |  | finish no earlier than 2016-12-15 | C1 | 1080h | 1080h | PWDIMS-CT | 37 | 24.623, 24.611 | Axell, Jörgen | Rel-14 | 72 |  |  |  |  |
| 710 | 317.2.2 | CT3 aspects for PWDIMS |  | 135d? | 2016-06-13 A | 2016-12-15 A | 100% |  |  |  |  |  | finish no earlier than 2016-12-15 | C3 | 1080h | 1080h | PWDIMS-CT | 37 | 29.292 | Axell, Jörgen | Rel-14 | 72 |  |  |  |  |
| 711 | 318 | **IMS Signalling Activated Trace** |  | 531d? | 2014-03-05 A | 2016-03-11 | 75% | 133.29d? | 2014-03-05 | 2014-09-12 | 138d? | 1112d |  |  | 22056h | 16519.4h | ISAT | 32 |  | Vodafone | Rel-14 | 63 |  | peter.dawes @vodafone.com | Frederic | ISAT |
| 712 | 318.1 | CT1 part of IMS Signalling Activated Trace |  | 528d? | 2014-03-10 A | 2016-03-11 A | 100% |  | 2014-03-05 | 2014-09-12 | 138d? |  | finish no earlier than 2016-03-11 | C1 | 4224h | 4224h | ISAT | 32 | 24.229, 24.323 | Vodafone | Rel-14 | 63 |  | peter.dawes @vodafone.com | Frederic |  |
| 713 | 318.2 | (IETF) IMS Signalling Activated Trace (draft-dawes-sipping-debug) |  | 391d? | 2014-09-12 A | 2016-03-11 | 28% | 281.52d? |  |  |  | 1112d | finish no earlier than 2016-03-11 | C1-IETF | 3128h | 875.84h | ISAT | 33 | draft-dawes-sipping-debug | Vodafone | Rel-14 | 65 |  | peter.dawes @vodafone.com |  |  |
| 714 | 318.3 | (IETF) IMS Signalling Activated Trace (draft-dawes-sipping-debug) |  | 391d? | 2014-09-12 A | 2016-03-11 | 25% | 293.25d? |  |  |  | 1112d | finish no earlier than 2016-03-11 | C3-IETF | 3128h | 782h | ISAT | 33 | draft-dawes-sipping-debug | Vodafone | Rel-14 | 65 |  | peter.dawes @vodafone.com |  |  |
| 715 | 318.4 | (IETF) IMS Signalling Activated Trace (draft-dawes-sipping-debug) |  | 391d? | 2014-09-12 A | 2016-03-11 | 70% | 117.3d? |  |  |  | 1112d | finish no earlier than 2016-03-11 | C4-IETF | 3128h | 2189.6h | ISAT | 33 | draft-dawes-sipping-debug | Vodafone | Rel-14 | 65 |  | peter.dawes @vodafone.com |  |  |
| 716 | 318.5 | CT3 part of IMS Signalling Activated Trace |  | 528d? | 2014-03-10 A | 2016-03-11 A | 100% |  | 2014-03-05 | 2014-06-13 | 73d? |  | finish no earlier than 2016-03-11 | C3 | 4224h | 4224h | ISAT | 32 | 29.165 | Vodafone | Rel-14 | 63 |  | peter.dawes @vodafone.com | Adrian |  |
| 717 | 318.6 | CT4 part of IMS Signalling Activated Trace |  | 528d? | 2014-03-05 A | 2016-03-11 A | 100% |  | 2014-03-05 | 2014-09-12 | 138d? |  | finish no earlier than 2016-03-11 | C4 | 4224h | 4224h | ISAT | 32 | 23.008, 29.228, 29.229, 29.328, 29.329 | Vodafone | Rel-14 | 63 |  | peter.dawes @vodafone.com | Kimmo |  |
| 718 | 319 | Other Release 14 | milestone | 0d? | 2016-06-09 A | 2016-06-09 A | 100% |  |  |  |  |  | finish no earlier than 2016-06-09 |  |  |  |  |  |  |  | Rel-14 |  |  |  |  |  |
| 719 | 320 | **User Controlled Spoofed Call Treatment** |  | 474d? | 2016-08-23 A | 2018-06-15 A | 100% |  |  |  |  |  |  |  | 2856h | 2856h | SPECTRE | 37 |  | Greg Schumacher, Sprint | Rel-14 | 73 |  |  |  |  |
| 720 | 320.1 | Stage 1 of User Controlled Spoofed Call Treatment |  | 20d? | 2016-08-23 A | 2016-09-19 A | 100% |  |  |  |  |  | finish no earlier than 2016-09-19 | S1 | 160h | 160h | SPECTRE | 37 | 22.228, 22.173 | Greg Schumacher, Sprint | Rel-14 | 73 |  |  |  |  |
| 721 | 320.2 | Stage 3 of User Controlled Spoofed Call Treatment |  | 74d? | 2016-12-01 A | 2017-03-14 A | 100% |  |  |  |  |  | finish no earlier than 2017-03-14 | C1 | 592h | 592h | SPECTRE-CT | 38 | 24.229, 29.165 | Dolly, Martin | Rel-14 | 74 |  | md3135@att.com |  |  |
| 722 | 320.3 | (IETF) A SIP Response Code for Unwanted Calls (draft-ietf-sipcore-status-unwanted) |  | 1d? | 2017-03-14 A | 2017-03-14 A | 100% |  |  |  |  |  | finish no earlier than 2017-03-14 | C1-IETF | 8h | 8h | SPECTRE-CT_IETF | 38 |  | Ericsson | Rel-14 | 75 |  |  |  |  |
| 723 | 320.4 | (IETF) Authenticated Identity Management in SIP (draft-ietf-stir-rfc4474bis) |  | 262d? | 2017-06-15 A | 2018-06-15 A | 100% |  |  |  |  |  | finish no earlier than 2018-06-15 | C1-IETF | 2096h | 2096h | SPECTRE-CT_IETF2 |  |  | Christer Holmberg | Rel-14 | 78 |  | christer.holmberg@ericsson.com |  |  |

Notes:
- 698: 12/15: created by MCC to distinguish Stage 1 from Stage 2
- 700: 7/3/16: 0%->20; 9/6/16: 20%->100. FCD: 03/16->06/16
- 702: 11/6/16: 0%->35; 16/9/16: 35%->85; 2/12/16: 85%->100
- 703: 18/12/17: 30%->100
- 704: 16/9/16: 0%->100
- 705: ; 19/9/17: Compl:0%->45%; 8/1/18: Compl:45%->80%; ...27/3/18: Compl:80%->100%
- 706: 1/4/15: rapporteur added, Impacted TS added. 31/07/15: 100%
- 707: 1/4/15: rapporteur added, Impacted TS added. 31/07/15: 100%
- 709: 2/12/16: 0%->15; 6/3/17: 15%->100
- 710: 5/6/17: 0%->100
- 711: Mar 15: WID: CP-140195->CP-150091. ES in CP-150637. 8/3/16: Moved from Rel-13 at CT#71
- 712: CP66: moved to Rel-13. Mar 15: WID: CP-140195->CP-150091. ES in CP-150728; 5/6/17: 0%->100
- 713: CP66: moved to Rel-13. Mar 15: WID: CP-140195->CP-150091. ES in CP-150637; 13/6/16: 25%->28
- 714: CP66: moved to Rel-13. Mar 15: WID: CP-140195->CP-150091. ES in CP-150637
- 715: CP66: moved to Rel-13. Mar 15: WID: CP-140195->CP-150091. ES in CP-150637; 5/6/17: 25%->70
- 716: CP66: moved to Rel-13. Mar 15: WID: CP-140195->CP-150091. ES in CP-150637; 5/6/17: 0%->100
- 717: CP66: moved to Rel-13. Mar.15: 90%. ES in CP-150615. 7/3/16: Rel-13->Rel-14; 5/6/17: 90%->100
- 718: -
- 719: 1/12/16: moved from Rel-15 to Rel-14; 1/12/16: WID:SP-160729->SP-160898
- 720: 1/12/16: moved from Rel-15 to Rel-14; 1/12/16: WID:SP-160729->SP-160898
- 721: 2/12/16: 0%->25; 6/3/17: 25%->100
- 722: 18/12/17: 20%->100
- 723: 22/3/18: 0%->100

| ID | WBS | Task | Duration | Start | Finish | Complete | Remaining | Total slack | Constraint | Resources | Work | Actual work | Acronym | PCG approved | WI rapporteur name | WI rapporteur e-mail | Release | TSG approved | Status Report |
| --- | --- | --- | --- | --- | --- | --- | --- | --- | --- | --- | --- | --- | --- | --- | --- | --- | --- | --- | --- |
| 724 | 321 | **Enhancement for TV service** | 565d? | 2015-04-14 A | 2017-06-09 A | 100% |  |  |  |  | 7800h | 7800h | EnTV | 36 | Zhiming Li | Lizhiming@huawei.com | Rel-14 | 70 | SP-170532 |
| 725 | 321.1 | Study on 3GPP Enhancement for TV Video service | 176d? | 2015-04-14 A | 2015-12-15 A | 100% |  |  | finish no earlier than 2015-12-15 | S1 | 1408h | 1408h | FS_EnTV | 34 | Zhiming Li (Huawei) | lizhiming@huawei.com | Rel-14 | 67 |  |
| 726 | 321.2 | **System Architecture Enhancements to eMBMS for TV Video Service** | 201d? | 2016-03-11 A | 2016-12-15 A | 100% |  |  |  |  | 1736h | 1736h | AE_enTV | 36 |  |  | Rel-14 | 71 |  |
| 727 | 321.2.1 | Study on System Architecture Enhancements to eMBMS for TV Video Service | 136d? | 2016-03-11 A | 2016-09-15 A | 100% |  |  | finish no earlier than 2016-09-15 | S2 | 1088h | 1088h | FS_AE_enTV | 36 | Miguel Griot, Qualcomm | mgriot@qti.qualcomm.com | Rel-14 | 71 |  |
| 728 | 321.2.2 | System Architecture Enhancements for TV service | 81d? | 2016-08-25 A | 2016-12-15 A | 100% |  |  | finish no earlier than 2016-12-15 | S2 | 648h | 648h | AE_enTV | 37 | Miguel Griot, Qualcomm | mgriot@qti.qualcomm.com | Rel-14 | 73 |  |
| 729 | 321.3 | Mobile Network Interface for MBMS Delivery of Media and TV services | 80d? | 2016-08-22 A | 2016-12-09 A | 100% |  |  | finish no earlier than 2016-12-09 | S4 | 640h | 640h | AE_enTV-MI_MTV | 37 | Thorsten Lohmar | Thorsten.lohmar@ericsson.com | Rel-14 | 73 |  |
| 730 | 321.4 | Codec aspects for eMBMS Delivery of Media and TV Services | 132d? | 2016-12-08 A | 2017-06-09 A | 100% |  |  | finish no earlier than 2017-06-09 | S4 | 1056h | 1056h | AE_enTV-S4 | 38 | Imed Bouazizi | i.bouazizi@samsung.com | Rel-14 | 74 |  |
| 731 | 321.5 | **Stage 3 of system architecture enhancements for TV service** | 74d? | 2016-12-01 A | 2017-03-14 A | 100% |  |  |  | ct | 2960h | 2960h | AE_enTV-CT | 38 | Catovic, Amer | amerc@qti.qualcomm.com | Rel-14 | 74 |  |
| 732 | 321.5.1 | CT1 aspects of system architecture enhancements for TV service | 74d? | 2016-12-01 A | 2017-03-14 A | 100% |  |  | finish no earlier than 2017-03-14 | C1 | 592h | 592h | AE_enTV-CT | 38 | Catovic, Amer | amerc@qti.qualcomm.com | Rel-14 | 74 |  |
| 733 | 321.5.2 | CT3 aspects of system architecture enhancements for TV service | 74d? | 2016-12-01 A | 2017-03-14 A | 100% |  |  | finish no earlier than 2017-03-14 | C3 | 592h | 592h | AE_enTV-CT | 38 | Catovic, Amer | amerc@qti.qualcomm.com | Rel-14 | 74 |  |
| 734 | 321.5.3 | CT4 aspects of system architecture enhancements for TV service | 74d? | 2016-12-01 A | 2017-03-14 A | 100% |  |  | finish no earlier than 2017-03-14 | C4 | 592h | 592h | AE_enTV-CT | 38 | Catovic, Amer | amerc@qti.qualcomm.com | Rel-14 | 74 |  |
| 735 | 321.5.4 | CT6 aspects of system architecture enhancements for TV service | 74d? | 2016-12-01 A | 2017-03-14 A | 100% |  |  | finish no earlier than 2017-03-14 | C6 | 592h | 592h | AE_enTV-CT | 38 | Catovic, Amer | amerc@qti.qualcomm.com | Rel-14 | 74 |  |
| 736 | 322 | MBMS Transport Protocol and APIs | 330d? | 2015-12-11 A | 2017-03-15 A | 100% |  |  | finish no earlier than 2017-03-15 | S4 | 2640h | 2640h | TRAPI | 36 | Samsung, Imed Bouazizi | i.bouazizi@samsung.com | Rel-14 | 70 |  |
| 737 | 323 | Multimedia Priority Service Modifications | 331d? | 2015-03-11 A | 2016-06-15 A | 100% |  |  | finish no earlier than 2016-06-15 | S1 | 2648h | 2648h | MPS_Mods | 34 | Ray P. Singh (Applied Communications Science) | rsingh@appcomsci.com | Rel-14 | 67 |  |
| 738 | 324 | Lawful Interception Rel-14 | 394d? | 2016-06-15 A | 2017-12-15 A | 100% |  |  | finish no earlier than 2017-12-15 | S3LI | 3152h | 3152h | LI14 | 37 | Koen JASPERS, PIDS |  | Rel-14 | 72 |  |
| 739 | 325 | **SIP Reason header extension** | 455d? | 2016-09-16 A | 2018-06-14 | 75% | 114.41d? | 522d |  | ct | 7792h | 4136.02h | REAS_EXT | 37 | Mohali, Marianne | marianne.mohali@orange.com | Rel-14 | 73 | CP-171175 |
| 740 | 325.1 | CT1 aspects of SIP Reason header extension | 129d? | 2016-09-16 A | 2017-03-15 A | 100% |  |  | finish no earlier than 2017-03-15 | C1 | 1032h | 1032h | REAS_EXT | 37 | Mohali, Marianne | marianne.mohali@orange.com | Rel-14 | 73 |  |
| 741 | 325.2 | (IETF) ISUP Cause Location Parameter for the SIP Reason Header Field (draft-ietf-sipcore-reason-q850-loc) | 261d? | 2017-06-15 A | 2018-06-14 | 50% | 130.5d? | 522d | finish no earlier than 2018-06-14 | C1-IETF | 2088h | 1044h | REAS_EXT |  | Michael KREIPL, Deutsche Telekom | michael(dot)kreipl(at)telekom(dot)de | Rel-14 | 78 |  |
| 742 | 325.3 | CT3 aspects of SIP Reason header extension | 129d? | 2016-09-16 A | 2017-03-15 A | 100% |  |  | finish no earlier than 2017-03-15 | C3 | 1032h | 1032h | REAS_EXT | 37 | Mohali, Marianne | marianne.mohali@orange.com | Rel-14 | 73 |  |
| 743 | 326 | Enhancements to User Location Reporting Support | 73d? | 2015-09-09 A | 2015-12-18 A | 100% |  |  | finish no earlier than 2015-12-18 | S1 | 584h | 584h | eULRS | 35 |  |  | Rel-14 | 68 |  |
| 744 | 327 | **Diameter Load Control Mechanism** | 597d? | 2014-12-03 A | 2017-03-15 | 98% | 10.85d? | 848d |  | ct | 8032h | 7448.03h | DLoCMe | 37 | Nokia, Ulrich Wiehe | ulrich.wiehe@nokia.com | Rel-14 | 73 | CP-171049 |
| 745 | 327.1 | CT3 aspects of Diameter Load Control Mechanism | 65d? | 2016-09-16 A | 2016-12-15 A | 100% |  |  | finish no earlier than 2016-12-15 | C3 | 520h | 520h | DLoCMe | 37 | Nokia, Ulrich Wiehe | ulrich.wiehe@nokia.com | Rel-14 | 73 |  |
| 746 | 327.2 | CT4 aspects of Diameter Load Control Mechanism | 65d? | 2016-09-16 A | 2016-12-15 A | 100% |  |  | finish no earlier than 2016-12-15 | C4 | 520h | 520h | DLoCMe | 37 | Nokia, Ulrich Wiehe | ulrich.wiehe@nokia.com | Rel-14 | 73 |  |
| 747 | 327.3 | (IETF) Diameter Load Information Conveyance (draft-ietf-dime-load-03) | 74d? | 2016-12-02 A | 2017-03-15 | 90% | 7.4d? | 848d | finish no earlier than 2017-03-15 | C4-IETF | 592h | 532.8h | DLoCMe | 38 |  |  | Rel-14 | 74 |  |
| 748 | 327.4 | Study on Diameter Load Control Mechanisms | 203d? | 2014-12-03 A | 2015-09-11 A | 100% |  |  | finish no earlier than 2015-09-11 | C4 | 1624h | 1624h | FS_DLoCME | 34 | Alcatel-Lucent |  | Rel-13 | 66 |  |

Notes:
- 724: 2/3/16: 0%->100 / Impacted TSs and TRs: 22.101
- 725: 1/4/15:TR number added; June2015: Compl:0%->20; 07/09/15: 20%->75; 7/12/15: 75%->100 / Impacted TSs and TRs: TR 22.816
- 727: 9/6/16: 0%->70; 28/7/16: 23.746 added; 19/9/16: 70%->100 / Impacted TSs and TRs: TR 23.746
- 728: 19/9/16: 0%->85; 1/12/16: FCD:09/16->12/16; 1/12/16: 85%->100 / Impacted TSs and TRs: TS 23.246
- 729: 06/10/16: Acronym: SA_enTV-MI_MTV -> AE_enTV-MI_MTV; 1/12/16: FCD:09/16->2/16; 1/12/16: 0%->50; 8/12/16: 50%->100 / Impacted TSs and TRs: 26.346
- 730: 6/3/17: 0%->20; 6/3/17: FCD:03/17->06/17; 7/6/17: 20%->100 / Impacted TSs and TRs: 26.347, 26.346
- 731: 21/3/17: 29.116 added; / Impacted TSs and TRs: 24.116, 24.117; 29.116
- 732: 2/12/16: 0%->40; 6/3/17: 40%->75; 5/6/17: 75%->100 / Impacted TSs and TRs: 24.008
- 733: 6/3/17: 0%->80; 6/3/17: 80%->100 / Impacted TSs and TRs: 29.061
- 734: 5/6/17: 0%->100 / Impacted TSs and TRs: 29.274, 23.003
- 735: 7/3/17: 0%->100 / Impacted TSs and TRs: 31.102
- 736: 28/1/16: 26.347 added; 7/3/16: 0%->20; 11/6/16: 20%->35; 19/9/16: 35%->60. FCD: 09/16->03/17; 1/12/16: 60%->70; 6/3/17: 70%->100 / Impacted TSs and TRs: 26.346, 26.852, New TS; 26.347
- 737: 1/4/15: rapporteur added, Impacted TS added. 6/15: 0->25%; 07/09/15: 25%->40; 7/12/15: 40%->70; 2/3/16: 70%->80; 9/6/16: 80%->100 / Impacted TSs and TRs: 22.153
- 738: 1/12/16: 0%->10; 2/3/17: WID:SP-160375->SP-1570038; 3/3/17: 8%->15; 6/3/17: 15%->20; 9/3/17: WID:SP-1570038->SP-170038; 7/6/17: 20%->50; 11/9/17: 50%->80; 15/12/17: 80%->100
- 740: 2/12/16: 0%->50; 6/3/17: 50%->85; 5/6/17: 85%->100 / Impacted TSs and TRs: 24.229
- 742: 5/6/17: 0%->100 / Impacted TSs and TRs: 29.163, 29.292
- 743: 2/3/16: 0%->100
- 744: 5/12/16: WID:CP-160412->CP-160645
- 745: 2/12/16: 0%->100 / Impacted TSs and TRs: 29.272, 29.273, 29.228, 29.229, 29.328, 29.329, 29.336, 29.344, 29.345, 29.128, 29.283
- 746: 2/12/16: 0%->100 / Impacted TSs and TRs: 29.153, 29.154, 29.212, 29.214, 29.215, 29.217, 29.219, 29.213
- 747: 2/12/16: 0%->90
- 748: 0->5%. Mar. 15: 10%; 7/12/15: 10%->40; 13/6/16: 40%->100 / Impacted TSs and TRs: New 29.810

| ID | WBS | Task | Duration | Start | Finish | Complete | Remaining | Total slack | Constraint | Resources | Work | Actual work | Acronym | PCG approved | WI rapporteur e-mail | Release | TSG approved | Status Report | TSG stopped |
| --- | --- | --- | --- | --- | --- | --- | --- | --- | --- | --- | --- | --- | --- | --- | --- | --- | --- | --- | --- |
| 749 | 328 | **Diameter Base Protocol Specification Update** | 74d? | 2016-12-01 A | 2017-03-14 A | 100% |  |  |  |  | 2352h | 2352h | DBPU | 38 | Peter.Schmitt@huawei.com | Rel-14 | 74 |  |  |
| 750 | 328.1 | **CT aspects of Diameter Base Protocol Specification Update** | 74d? | 2016-12-01 A | 2017-03-14 A | 100% |  |  |  | ct | 1776h | 1776h | DBPU | 38 | Peter.Schmitt@huawei.com | Rel-14 | 74 |  |  |
| 751 | 328.1.1 | CT3 aspects of Diameter Base Protocol Specification Update | 74d? | 2016-12-01 A | 2017-03-14 A | 100% |  |  | finish no earlier than 2017-03-14 | C3 | 592h | 592h | DBPU | 38 | Peter.Schmitt@huawei.com | Rel-14 | 74 |  |  |
| 752 | 328.1.2 | CT4 aspects of Diameter Base Protocol Specification Update | 74d? | 2016-12-01 A | 2017-03-14 A | 100% |  |  | finish no earlier than 2017-03-14 | C4 | 592h | 592h | DBPU | 38 | Peter.Schmitt@huawei.com | Rel-14 | 74 |  |  |
| 753 | 328.2 | Charging aspects for Diameter Base Protocol Specification Update | 72d? | 2016-12-01 A | 2017-03-10 A | 100% |  |  | finish no earlier than 2017-03-10 | S5 | 576h | 576h | DBPU-CH | 38 | Nokia, Maryse <dot> Gardella <at> Nokia <dot> com | Rel-14 | 74 |  |  |
| 754 | 329 | **Enhancements to Multi-stream Multiparty Conferencing Media Handling** | 276d? | 2016-03-02 A | 2017-03-21 | 99% | 0.35d? | 844d |  |  | 10320h | 10091.4h | MMCMH_Enh | 37 | nleung@qti.qualcomm.com | Rel-14 | 72 | SP-170528 |  |
| 755 | 329.1 | Overall aspects of MMCMH_Enh | 196d? | 2016-06-13 A | 2017-03-10 A | 100% |  |  | finish no earlier than 2017-03-10 | S4 | 1568h | 1568h | MMCMH_Enh | 37 | nleung@qti.qualcomm.com | Rel-14 | 72 |  |  |
| 756 | 329.2 | **CT aspects of MMCMH_Enh** | 276d? | 2016-03-02 A | 2017-03-21 | 99% | 0.44d? | 844d |  | ct | 8752h | 8523.39h | MMCMH_Enh-CT | 37 | nevenka.biondic@ericsson.com | Rel-14 | 72 |  |  |
| 757 | 329.2.1 | CT1 aspects of MMCMH_Enh | 272d? | 2016-03-02 A | 2017-03-15 A | 100% |  |  | finish no earlier than 2017-03-15 | C1 | 2176h | 2176h | MMCMH_Enh-CT | 37 | nevenka.biondic@ericsson.com | Rel-14 | 72 |  |  |
| 758 | 329.2.2 | CT3 aspects of MMCMH_Enh | 272d? | 2016-03-02 A | 2017-03-15 A | 100% |  |  | finish no earlier than 2017-03-15 | C3 | 2176h | 2176h | MMCMH_Enh-CT | 37 | nevenka.biondic@ericsson.com | Rel-14 | 72 |  |  |
| 759 | 329.2.3 | CT4 aspects of MMCMH_Enh | 272d? | 2016-03-02 A | 2017-03-15 A | 100% |  |  | finish no earlier than 2017-03-15 | C4 | 2176h | 2176h | MMCMH_Enh-CT | 37 | nevenka.biondic@ericsson.com | Rel-14 | 72 |  |  |
| 760 | 329.2.4 | (IETF) Using Simulcast in SDP and RTP Sessions (draft-ietf-mmusic-sdp-simulcast) | 1d? | 2017-03-21 A | 2017-03-21 | 50% | 0.5d? | 844d | start no earlier than 2017-03-21 | C1-IETF | 8h | 4h | MMCMH_Enh-CT | 38 | tomas.frankkila@ericsson.com | Rel-14 | 75 |  |  |
| 761 | 329.2.5 | (IETF) RTP Payload Format Restrictions (draft-ietf-mmusic-rid) | 1d? | 2017-03-21 A | 2017-03-21 | 20% | 0.8d? | 844d | start no earlier than 2017-03-21 | C1-IETF | 8h | 1.6h | MMCMH_Enh-CT | 38 |  | Rel-14 | 75 |  |  |
| 762 | 330 | **Deleted - CT aspects of (or "Enhancements of") MTSI Extension on Multi-stream** | 143d? | 2016-03-02 A | 2016-09-15 A | 100% |  |  |  | ct | 4576h | 4576h | MMCMH-CT | 36 | nevenka.biondic@ericsson.com | Rel-14 | 71 |  | CP-72 |
| 763 | 330.1 | deleted -CT1 aspects of MTSI Extension on Multi-stream | 143d? | 2016-03-02 A | 2016-09-15 A | 100% |  |  | start no earlier than 2016-03-02 | C1 | 1144h | 1144h | MMCMH-CT | 36 | nevenka.biondic@ericsson.com | Rel-14 | 71 |  | CP-72 |
| 764 | 330.2 | deleted -CT3 aspects of MTSI Extension on Multi-stream | 143d? | 2016-03-02 A | 2016-09-15 A | 100% |  |  | start no earlier than 2016-03-02 | C3 | 1144h | 1144h | MMCMH-CT | 36 | nevenka.biondic@ericsson.com | Rel-14 | 71 |  | CP-72 |
| 765 | 330.3 | deleted -CT4 aspects of MTSI Extension on Multi-stream | 143d? | 2016-03-02 A | 2016-09-15 A | 100% |  |  | start no earlier than 2016-03-02 | C4 | 1144h | 1144h | MMCMH-CT | 36 | nevenka.biondic@ericsson.com | Rel-14 | 71 |  | CP-72 |
| 766 | 331 | **Control and User Plane Separation of EPC nodes** | 391d? | 2015-09-17 A | 2017-03-15 A | 100% |  |  |  |  | 5248h | 5248h | CUPS | 35 | mirko.schramm@huawei.com | Rel-14 | 69 | SP-170520 |  |
| 767 | 331.1 | Study on Control and User Plane Separation of EPC nodes | 197d? | 2015-09-17 A | 2016-06-17 A | 100% |  |  | finish no earlier than 2016-06-17 | S2 | 1576h | 1576h | FS_CUPS | 35 | mirko.schramm@huawei.com | Rel-14 | 69 |  |  |
| 768 | 331.2 | Control and User Plane Separation of EPC nodes | 72d? | 2016-06-09 A | 2016-09-15 A | 100% |  |  | finish no earlier than 2016-09-15 | S2 | 576h | 576h | CUPS | 37 | mirko.schramm@huawei.com | Rel-14 | 72 |  |  |
| 769 | 331.3 | **CT aspects for CUPS** | 129d? | 2016-09-16 A | 2017-03-15 A | 100% |  |  |  | ct | 3096h | 3096h | CUPS-CT | 37 | peter.schmitt@huawei.com | Rel-14 | 73 |  |  |
| 770 | 331.3.1 | CT3 aspects for CUPS | 129d? | 2016-09-16 A | 2017-03-15 A | 100% |  |  | finish no earlier than 2017-03-15 | C3 | 1032h | 1032h | CUPS-CT | 37 | peter.schmitt@huawei.com | Rel-14 | 73 |  |  |
| 771 | 331.3.2 | CT4 aspects for CUPS | 129d? | 2016-09-16 A | 2017-03-15 A | 100% |  |  | finish no earlier than 2017-03-15 | C4 | 1032h | 1032h | CUPS-CT | 37 | peter.schmitt@huawei.com | Rel-14 | 73 |  |  |
| 772 | 332 | **OAM14 Rel-14 Operations, Administration, Maintenance and Provisioning (OAM&P)** | 720d? | 2015-03-12 A | 2017-12-12 A | 100% |  |  |  | S5 | 35193.6h | 35193.6h | OAM14 | 35 |  | Rel-14 | 68 |  |  |
| 773 | 332.1 | **Management of mobile networks that include virtualized network functions** | 653d? | 2015-06-15 A | 2017-12-12 A | 100% |  |  |  | S5 | 23968h | 23968h | OAM14-MAMO_VNF | 35 | liujinglei@chinamobile.com | Rel-14 | 68 |  |  |
| 774 | 332.1.1 | Management concept, architecture and requirements for mobile networks that include virtualized network functions | 395d? | 2015-06-15 A | 2016-12-15 A | 100% |  |  | finish no earlier than 2016-12-15 | S5 | 3160h | 3160h | OAM14-MAMO_VNF-MCAR | 35 | liujinglei@chinamobile.com | Rel-14 | 68 |  |  |
| 775 | 332.1.2 | Configuration Management for mobile networks that include virtualized network functions | 454d? | 2015-09-16 A | 2017-06-09 A | 100% |  |  | finish no earlier than 2017-06-09 | S5 | 3632h | 3632h | OAM14-MAMO_VNF-CM | 35 | zhu.weihong@zte.com.cn | Rel-14 | 69 |  |  |
| 776 | 332.1.3 | Fault Management for mobile networks that include virtualized network functions | 454d? | 2015-09-16 A | 2017-06-09 A | 100% |  |  | finish no earlier than 2017-06-09 | S5 | 3632h | 3632h | OAM14-MAMO_VNF-FM | 35 | kai.zhangkai@huawei.com | Rel-14 | 69 |  |  |
| 777 | 332.1.4 | Performance management for mobile networks that include virtualized network functions | 586d? | 2015-09-16 A | 2017-12-12 A | 100% |  |  | finish no earlier than 2017-12-12 | S5 | 4688h | 4688h | OAM14-MAMO_VNF-PM | 35 | joey.chou@intel.com | Rel-14 | 69 |  |  |
| 778 | 332.1.5 | Lifecycle management for mobile networks that include virtualized network functions | 454d? | 2015-09-16 A | 2017-06-09 A | 100% |  |  | finish no earlier than 2017-06-09 | S5 | 3632h | 3632h | OAM14-MAMO_VNF-LCM | 35 | anatoly.andrianov@nokia.com | Rel-14 | 69 |  |  |
| 779 | 332.2 | Filtering of PM measurements and data volume | 199d? | 2016-03-01 A | 2016-12-01 A | 100% |  |  | start no earlier than 2016-03-01 | S5 | 1592h | 1592h | OAM14-FILMEAS | 36 | robert.petersen@ericsson.com | Rel-14 | 71 |  |  |
| 780 | 332.3 | Study on OAM support for Licensed Shared Access (LSA) | 262d? | 2015-03-12 A | 2016-03-11 A | 100% |  |  | finish no earlier than 2016-03-11 | S5 | 2096h | 2096h | FS_OAM_LSA | 34 | anatoly<dot>andrianov<at>nokia<dot>com | Rel-14 | 67 |  |  |
| 781 | 332.4 | OAM support for Licensed Shared Access (LSA) | 262d? | 2016-06-13 A | 2017-06-12 A | 100% |  |  | start no earlier than 2016-06-13 | S5 | 2096h | 2096h | OAM14-LSA | 37 |  | Rel-14 | 72 |  |  |
| 782 | 333 | Development of super-wideband and fullband P.835 | 524d? | 2015-06-16 A | 2017-06-15 A | 100% |  |  | finish no earlier than 2017-06-15 | S4 | 4192h | 4192h | DESUDAPS | 35 | sisabelle@audience.com | Rel-14 | 68 | SP-170346 |  |
| 783 | 334 | Enhancing Location Capabilities for Indoor and Outdoor Emergency Communications | 200d? | 2015-03-11 A | 2015-12-15 A | 100% |  |  | finish no earlier than 2015-12-15 | S1 | 1600h | 1600h | ELIOT | 34 | Gregory.schumacher@sprint.com | Rel-14 | 67 | SP-170553 |  |
| 784 | 335 | Enhancements to Domain Selection between VoLTE and CDMA CS | 69d? | 2015-03-11 A | 2015-06-15 A | 100% |  |  | finish no earlier than 2015-06-15 | S1 | 552h | 552h | eDSVCC | 34 | zhuhongmei@gsta.com | Rel-14 | 67 |  |  |
| 785 | 336 | Control of Applications when Third party Servers encounter difficulties | 93d? | 2015-05-11 A | 2015-09-16 A | 100% |  |  | finish no earlier than 2015-09-16 | S1 | 744h | 744h | CATS | 35 | er-yoshida (at) kddi (dot) com | Rel-14 | 68 | SP-170338 |  |

Notes:
- 749: WI rapporteur name: Huawei, Peter Schmitt
- 750: WI rapporteur name: Huawei, Peter Schmitt
- 751: 6/3/17: 0%->100 / Impacted TSs and TRs: 29.061, 29.153, 29.154, 29.212, 29.214, 29.215, 29.217, 29.219, 29.368, 29.468, 29.213, 29.155, 29.201 / WI rapporteur name: Huawei, Peter Schmitt
- 752: 2/12/16: 0%->10; 6/3/17: 10%->100 / Impacted TSs and TRs: 29.109, 29.128, 29.172, 29.173, 29.228, 29.229, 29.272, 29.273, 29.283, 29.328, 29.329, 29.336, 29.337, 29.338, 29.343, 29.344, 29.345 / WI rapporteur name: Huawei, Peter Schmitt
- 753: 6/3/17: 0%->100 / Impacted TSs and TRs: 32.240, 32.251, 32.260, 32.270, 32.271, 32.272, 32.273, 32.274, 32.275, 32.278, 32.280, 32.295, 32.296, 32.297, 32.299 / WI rapporteur name: Nokia
- 754: Impacted TSs and TRs: TS 26.114 / WI rapporteur name: Nikolai Leung
- 755: 19/9/16: WID:SP-160272->SP-160785; 19/9/16: 0%->50; 1/12/16: 50%->80; 1/12/16: FCD:12/16->03/17; 6/3/17: 80%->100 / Impacted TSs and TRs: TS 26.114, TR 26.980 / WI rapporteur name: Nikolai Leung
- 756: To be checked at SA4 if a part can stay in Rel-13 (now Stages 1 and 2 by SA4 in UID660050), while the CT aspects are in Rel-14. 06/16: Name changed from "CT aspects of (or "Enhancements of") MTSI Extension on Multi-stream". Acronym changed from "MMCMH- / WI rapporteur name: Ericsson, Nevenka Biondic
- 757: Name changed from "CT1 aspects of MTSI Extension on Multi-stream". Acronym changed from "MMCMH-CT"; 13/6/16: WID:CP-160117->CP-160250. FCD: 09/16->03/17; 13/6/16: WID:CP-160250->CP-160369; 2/12/16: 0%->95; 6/3/17: 95%->100 / Impacted TSs and TRs: 24.229 / WI rapporteur name: Ericsson, Nevenka Biondic
- 758: Acronym changed from "MMCMH-CT"; 13/6/16: WID:CP-160117->CP-160250. FCD: 09/16->03/17; 13/6/16: WID:CP-160250->CP-160369; 6/3/17: 0%->100 / Impacted TSs and TRs: 29.162, 29.213, 29.214, 29.165 / WI rapporteur name: Ericsson, Nevenka Biondic
- 759: 3/6/16: WID:CP-160117->CP-160250. FCD: 09/16->03/17; 13/6/16: WID:CP-160250->CP-160369; 2/12/16: 0%->35; 6/3/17: 35%->75; 5/6/17: 75%->100 / Impacted TSs and TRs: 23.333, 29.333, 23.334, 29.334, 29.238 / WI rapporteur name: Ericsson, Nevenka Biondic
- 760: WI rapporteur name: Ericsson
- 761: WI rapporteur name: Ericsson
- 762: Deleted, "replaced" by MMCMH_Enh-CT / WI rapporteur name: Ericsson, Nevenka Biondic
- 763: Deleted, "replaced" by MMCMH_Enh-CT / Impacted TSs and TRs: 24.229 / WI rapporteur name: Ericsson, Nevenka Biondic
- 764: Deleted, "replaced" by MMCMH_Enh-CT / Impacted TSs and TRs: 29.162, 29.213, 29.214, 29.165 / WI rapporteur name: Ericsson, Nevenka Biondic
- 765: Deleted, "replaced" by MMCMH_Enh-CT / Impacted TSs and TRs: 23.333, 29.333, 23.334, 29.334, 29.238 / WI rapporteur name: Ericsson, Nevenka Biondic
- 766: 7/12/15: 0%->20; 7/3/16: 20%->40; 9/6/16: 40%->100; 28/7/16: 23.214 added; / Impacted TSs and TRs: 23.714; 23.214 / WI rapporteur name: Huawei, Mirko Schramm
- 767: 7/12/15: 0%->20; 7/3/16: 20%->40; 9/6/16: 40%->100 / Impacted TSs and TRs: 23.714 / WI rapporteur name: Huawei, Mirko Schramm
- 768: 19/9/16: 0%->80; 1/12/16: 80%->100 / Impacted TSs and TRs: 23.214, 23.002, 23.203, 23.401, 23.402 / WI rapporteur name: Huawei, Mirko Schramm
- 769: WI rapporteur name: Huawei, Peter Schmitt
- 770: 8/6/17: 0%->100 / Impacted TSs and TRs: 29.212, 29.213 / WI rapporteur name: Huawei, Peter Schmitt
- 771: 2/12/16: 0%->40; 6/3/17: 40%->75; 5/6/17: 75%->100 / Impacted TSs and TRs: 23.007, 29.274, 29.281, 29.303, 23.008 / WI rapporteur name: Huawei, Peter Schmitt
- 773: June2015: WID:SP-150308->SP-150362 / WI rapporteur name: Jinglei Liu, China Mobile
- 774: June2015: WID:SP-150309->SP-150363. Aug2015: FCD: Mar 2016; 07/09/15: 0%->20. 15/09/15: FCD: Mar 16->Dec 16, moved to Rel-14; 7/12/15: 20%->40; 7/3/16: 40%->50; 7/3/16: WID:SP-150363->SP-160023 ( FCD: Dec16->Sep16); 13/6/16: 50%->70; 19/9/16: FCD:09/16; 22/3/17: 90%->100 / Impacted TSs and TRs: 28.xyz, 32.101 / WI rapporteur name: Jinglei Liu, China Mobile (liujinglei@chinamobile.com)
- 775: 5/10/15: 28.513; 28.512; 28.511; 28.510 added; 7/12/15: 0%->15; 7/3/16: 15%->20; 13/6/16: 20%->30; 19/9/16: 30%->50; 1/12/16: 50%->60; 1/12/16: FCD:12/16->03/17; 6/3/17: FCD:03/17->06/17; 6/3/17: 60%->80; 7/6/17: 80%->100 / Impacted TSs and TRs: 28.513; 28.512; 28.511; 28.510; 28.621, 28.622, 28.623, 28.704, 28.707 / WI rapporteur name: ZTE Corporation (Zhu Weihong, zhu.weihong@zte.com.cn)
- 776: 5/10/15: 28.518; 28.517; 28.516; 28.515 added; 7/12/15: 0%->10; 7/3/16: 10%->15; 13/6/16: 15%->50; 13/6/16: WID:SP-150404->SP-160403; 19/9/16: 50%->75; 1/12/16: 75%->80; 1/12/16: 80%->; 1/12/16: FCD:12/16->03/17; 6/3/17: FCD:03/17->06/17; 6/3/17: 80%->90; 7/6/17: 90%->100 / Impacted TSs and TRs: 28.515, 28.516, 28.517, 28.518, 32.111-1, 32.111-2, 32.111-6 / WI rapporteur name: Huawei (Kai ZHANG, kai.zhangkai@huawei.com)
- 777: 5/10/15: 28.523; 28.522; 28.521; 28.520 added; 7/12/15: 0%->10; 7/3/16: 10%->15; 13/6/16: 15%->30; 13/6/16: WID:SP-150401->SP-160402; 19/9/16: 30%->60; 1/12/16: FCD:12/16->03/17; 6/3/17: FCD:03/17->06/17; 6/3/17: 60%->75; 7/6/17: 75%->90; 7/6/17: FCD:0...; 11/9/17: 90%->100 / Impacted TSs and TRs: 28.523; 28.522; 28.521; 28.520; 32.426, 32.409, 32.401 / WI rapporteur name: Intel (Joey Chou, joey.chou@intel.com)
- 778: 5/10/15: 28.528; 28.527; 28.526; 28.525 added; 7/12/15: 0%->10; 7/3/16: 10%->15; 13/6/16: 15%->25; 13/6/16: WID:SP-150403->SP-160427; 19/9/16: 25%->40; 1/12/16: 40%->60; 1/12/16: FCD:12/16->03/17; 6/3/17: FCD:03/17->06/17; 6/3/17: 60%->80; 7/6/17: 80%->100 / Impacted TSs and TRs: 28.525, 28.526, 28.527, 28.528, 28.704, 28.705, 28.706, 28.707, 28.708, 28.709 / WI rapporteur name: Anatoly Andrianov (anatoly.andrianov@nokia.com), Nokia Networks
- 779: 13/6/16: 0%->15; 19/9/16: WID:SP-160022->SP-160610; 19/9/16: 15%->60; 1/12/16: 60%->95; 6/3/17: 95%->100 / Impacted TSs and TRs: New 32.817, 32.425, 32.412, 32.416, 32.130 / WI rapporteur name: Ericsson: Robert Petersen
- 780: June2015: Compl:0%->15; 07/09/15: 15%->70; 7/12/15: 70%->75; 7/3/16: 75%->100. 22/3/16: FCD: 09/15->03/16. Rel-13->Rel-14; 28/7/16: 28.303 added; 28/7/16: 28.302 added; 28/7/16: 28.301 added; 28/7/16: 33.250 added; 28/7/16: added; / Impacted TSs and TRs: 28.303; 28.302; 28.301; / WI rapporteur name: Nokia Networks, Anatoly Andrianov
- 781: 28/7/16: 28.303 added; 28/7/16: 28.302 added; 28/7/16: 28.301 added; 19/9/16: 0%->20; 1/12/16: 20%->30; 6/3/17: 30%->40; 7/6/17: 40%->100 / Impacted TSs and TRs: 32.101; 28.303; 28.302; 28.301 / WI rapporteur name: Nokia: Olaf Pollakowski
- 782: 06/15: FCD corrected to Dec.15; Aug2015: 0%->5; 07/09/15: 5%->20, FCD: 12/15->06.16; 7/12/15: 20%->40, MOVED TO REL-14; 7/3/16: 40%->50. 15/4/16: 6/16->12/16; 11/6/16: 50%->60; 19/9/16: 60%->70, fcd: 12/16->06/17; 1/12/16: 70%->75; 6/3/17: 75%->80; 7/6/17: 80%->100 / Impacted TSs and TRs: 26.131, 26.132 / WI rapporteur name: Scott Isabelle (Knowles, Inc.)
- 783: 1/4/15: rapporteur added, Impacted TS added; June2015: Compl:0%->25; 07/09/15: 25%->80; 2/3/16: 80%->100 / Impacted TSs and TRs: 22.101, 22.071 / WI rapporteur name: Greg Schumacher
- 784: 1/4/15: rapporteur added, Impacted TS added; June2015: Compl:0%->100 / Impacted TSs and TRs: 22.101 / WI rapporteur name: China Telecom, Hongmei Zhu
- 785: 07/09/15: 0%->100 / Impacted TSs and TRs: 22.011 / WI rapporteur name: Eriko Yoshida, KDDI

| ID | WBS | Task | Duration | Start | Finish | Complete | Remaining | Total slack | Constraint | Resources | Work | Actual work | Acronym | PCG approved | WI rapporteur name | WI rapporteur e-mail | Release | TSG approved | Status Report |
| --- | --- | --- | --- | --- | --- | --- | --- | --- | --- | --- | --- | --- | --- | --- | --- | --- | --- | --- | --- |
| 786 | 337 | **PS Data Off Services** | 416d? | 2015-11-09 A | 2017-06-09 A | 100% |  |  |  |  | 5416h | 5416h | PS_Data_Off | 36 | Orange, Bruno Tossou | bruno.tossou@orange.com | Rel-14 | 70 | SP-170708 |
| 787 | 337.1 | PS Data Off Services | 92d? | 2015-11-09 A | 2016-03-15 A | 100% |  |  | finish no earlier than 2016-03-15 | S1 | 736h | 736h | PS_Data_Off | 36 | Orange, Bruno Tossou | bruno.tossou@orange.com | Rel-14 | 70 |  |
| 788 | 337.2 | Study on Stage 2 of PS Data off function | 131d? | 2016-06-17 A | 2016-12-15 A | 100% |  |  | finish no earlier than 2016-12-15 | S2 | 1048h | 1048h | FS_PS_DATA_OFF | 37 | Orange, david <dot> cailliere <at> orange <dot> com | david <dot> cailliere <at> orange <dot> com | Rel-14 | 72 |  |
| 789 | 337.3 | Stage 2 of PS Data Off | 21d? | 2016-11-17 A | 2016-12-15 A | 100% |  |  | finish no earlier than 2016-12-15 | S2 | 168h | 168h | PS_DATA_OFF | 38 | Christophe Petit (Orange) | kris (dot) petit (at) orange (dot) com | Rel-14 | 74 |  |
| 790 | 337.4 | **Stage 3 of PS Data Off** | 74d? | 2016-12-01 A | 2017-03-14 A | 100% |  |  |  | ct | 2368h | 2368h | PS_DATA_OFF-CT | 38 | Herrero Veron, Christian (Huawei) | Christian.Herrero at huawei.com | Rel-14 | 74 |  |
| 791 | 337.4.1 | CT1 aspects of PS Data Off | 74d? | 2016-12-01 A | 2017-03-14 A | 100% |  |  | finish no earlier than 2017-03-14 | C1 | 592h | 592h | PS_DATA_OFF-CT | 38 | Herrero Veron, Christian (Huawei) | Christian.Herrero at huawei.com | Rel-14 | 74 |  |
| 792 | 337.4.2 | CT3 aspects of PS Data Off | 74d? | 2016-12-01 A | 2017-03-14 A | 100% |  |  | finish no earlier than 2017-03-14 | C3 | 592h | 592h | PS_DATA_OFF-CT | 38 | Herrero Veron, Christian (Huawei) | Christian.Herrero at huawei.com | Rel-14 | 74 |  |
| 793 | 337.4.3 | CT6 aspects of PS Data Off | 74d? | 2016-12-01 A | 2017-03-14 A | 100% |  |  | finish no earlier than 2017-03-14 | C6 | 592h | 592h | PS_DATA_OFF-CT | 38 | Herrero Veron, Christian (Huawei) | Christian.Herrero at huawei.com | Rel-14 | 74 |  |
| 794 | 337.5 | Charging Aspect for 3GPP PS Data off Function | 137d? | 2016-12-01 A | 2017-06-09 A | 100% |  |  | finish no earlier than 2017-06-09 | S5 | 1096h | 1096h | PS_DATA_OFF-CH | 38 | Huawei， Chen, Shan | chenshan@huawei.com | Rel-14 | 74 |  |
| 795 | 338 | SCC AS Restoration | 208d? | 2016-03-02 A | 2016-12-15 A | 100% |  |  | finish no earlier than 2016-12-15 | C4 | 1664h | 1664h | SCCAS_RES | 36 | China Mobile, Hao Zhang, | zhanghao@chinamobile.com | Rel-14 | 71 |  |
| 796 | 339 | Paging Policy Enhancements and Procedure | 22d? | 2016-02-01 A | 2016-03-01 A | 100% |  |  | finish no earlier than 2016-03-01 | S1 | 176h | 176h | PPEPO_LTE | 36 | China Unicom, Zhuoyun Zhang | zhangzy910@chinaunicom.cn | Rel-14 | 71 | SP-170549 |
| 797 | 340 | **Enhancement to Flexible Mobile Service Steering** | 355d? | 2015-05-11 A | 2016-09-15 A | 100% |  |  |  |  | 1968h | 1968h | eFMSS | 37 | China Mobile, Lu Lu | lulu@chinamobile.com | Rel-14 | 72 |  |
| 798 | 340.1 | Study on enhancement to FMSS for Rel 14 | 158d? | 2015-05-11 A | 2015-12-16 A | 100% |  |  | finish no earlier than 2015-12-16 | S1 | 1264h | 1264h | FS_eFMSS | 35 | Lu Lu, China Mobile | lulu@chinamobile.com | Rel-14 | 68 |  |
| 799 | 340.2 | Stage 1 of Enhancement to Flexible Mobile Service Steering | 22d? | 2016-02-01 A | 2016-03-01 A | 100% |  |  | start no earlier than 2016-02-01 | S1 | 176h | 176h | eFMSS | 36 | China Mobile, Lu Lu | lulu@chinamobile.com | Rel-14 | 71 |  |
| 800 | 340.3 | Stage 2 of Enhancement to Flexible Mobile Service Steering | 66d? | 2016-06-17 A | 2016-09-15 A | 100% |  |  | finish no earlier than 2016-09-15 | S2 | 528h | 528h | eFMSS | 37 | ZTE, Tricci So |  | Rel-14 | 72 |  |
| 801 | 341 | **Media Handling Extensions of IMS-based Telepresence** | 199d? | 2016-03-01 A | 2016-12-01 | 50% | 99.5d? | 922d |  |  | 3184h | 1592h | IMS_TELEP_EXT | 36 | Ozgur Oyman, Intel | ozgur.oyman@intel.com | Rel-14 | 71 | SP-170515 |
| 802 | 341.1 | S4 aspects of Media Handling Extensions of IMS-based Telepresence | 199d? | 2016-03-01 A | 2016-12-01 A | 100% |  |  | finish no earlier than 2016-12-01 | S4 | 1592h | 1592h | IMS_TELEP_EXT | 37 | Ozgur Oyman, Intel | ozgur.oyman@intel.com | Rel-14 | 72 |  |
| 803 | 341.2 | (IETF) Other IETF aspects of IMS_TELEP_EXT | 199d? | 2016-03-01 | 2016-12-01 |  |  | 922d | finish no earlier than 2016-12-01 | S4-IETF | 1592h |  | IMS_TELEP_EXT | 37 |  | ozgur.oyman@intel.com | Rel-14 | 72 |  |
| 804 | 342 | Improved Streaming QoE Reporting in 3GPP | 273d? | 2016-03-01 A | 2017-03-15 A | 100% |  |  | finish no earlier than 2017-03-15 | S4 | 2184h | 2184h | IQoE | 36 | Zhiming Li, Huawei | Lizhiming@huawei.com | Rel-14 | 71 | SP-170521 |
| 805 | 343 | New GPRS algorithms for EASE | 67d? | 2016-03-15 A | 2016-06-15 A | 100% |  |  | start no earlier than 2016-03-15 | S3 | 536h | 536h | EASE_ALGOs_SA3 | 36 | Tim Evans, Vodafone |  | Rel-14 | 71 |  |
| 806 | 344 | **S8 Home Routing Architecture for VoLTE** | 518d? | 2015-06-18 A | 2017-06-09 A | 100% |  |  |  |  | 7832h | 7832h | V8 | 36 |  |  | Rel-14 | 71 | SP-170522 |
| 807 | 344.1 | Study on S8 Home Routing Architecture | 191d? | 2015-06-18 A | 2016-03-10 A | 100% |  |  | finish no earlier than 2016-03-10 | S2 | 1528h | 1528h | FS_V8 | 35 | Motohiro ABE | motohiro(dot)abe(dot)cu(at) nttdocomo (dot) com | Rel-14 | 68 |  |
| 808 | 344.2 | Study on LI in S8 Home Routing Architecture for VoLTE | 197d? | 2015-09-17 A | 2016-06-17 A | 100% |  |  | finish no earlier than 2016-06-17 | S3 | 1576h | 1576h | FS_LIV8 | 35 | Greg Schumacher (SPRINT) Gregory | Schumacher@sprint.com | Rel-14 | 69 |  |
| 809 | 344.3 | S8 Home Routing Architecture for VoLTE | 135d? | 2016-06-13 A | 2016-12-15 A | 100% |  |  | finish no earlier than 2016-12-15 | S2 | 1080h | 1080h | V8 | 37 | Motohiro ABE | motohiro(dot)abe(dot)cu(at) nttdocomo (dot) com | Rel-14 | 72 |  |

Notes:
- 786: 2/3/16: 0%->100 / Impacted TSs and TRs: 22.030
- 787: 2/3/16: 0%->100 / Impacted TSs and TRs: 22.030
- 788: 28/7/16: 23.702 added; 19/9/16: 0%->60; 1/12/16: FCD:09/16->12/16; 1/12/16: 60%->100 / Impacted TSs and TRs: TR 23.702
- 789: 1/12/16: 0%->100 / Impacted TSs and TRs: 23.401, 23.203, 23.060, 23.228, 23.292, 23.221
- 791: 6/3/17: 0%->95; 5/6/17: 95%->100 / Impacted TSs and TRs: 24.008, 24.301, 27.007, 24.229, 24.368, 24.167
- 792: 6/3/17: 0%->60; 8/6/17: 60%->100 / Impacted TSs and TRs: 29.212, 29.213
- 793: 7/3/17: 0%->100 / Impacted TSs and TRs: 31.102, 31.103, 31.111
- 794: 6/3/17: 0%->70; 6/3/17: FCD:03/17->06/17; 7/6/17: 70%->100 / Impacted TSs and TRs: TS 32.251, TS 32.298, TS 32.299
- 795: 13/6/16: 0%->100 / Impacted TSs and TRs: 23.380
- 796: Impacted TSs and TRs: 22.101
- 797: Impacted TSs and TRs: 22.115, 22.101
- 798: 7/12/15: 70%->100 / Impacted TSs and TRs: 22.808
- 799: Impacted TSs and TRs: 22.115, 22.101
- 800: 19/9/16: 0%->100 / Impacted TSs and TRs: 23.203
- 801: 11/6/16: 0%->10 / Impacted TSs and TRs: 26.223
- 802: 11/6/16: 0%->10; 19/9/16: 10%->60; 1/12/16: 60%->100 / Impacted TSs and TRs: 26.223
- 803: Impacted TSs and TRs: draft-ietf-payload-rtp-h265, -flexible-fec-scheme , draft-ietf-clue-framework , -datachannel, -signalling, -data-model-schema, -protocol, -rtp-mapping, draft-ietf-mmusic-sctp-sdp, -data-channel-sdpneg, draft-ietf-tsvwg-sctp-dtls-encaps
- 804: 11/6/16: 0%->10; 19/9/16: 10%->55. FDC: 12/16->03/17; 1/12/16: 55%->65; 6/3/17: 65%->100 / Impacted TSs and TRs: New 26.909, 26.247, 26.346
- 805: Discussion whether it should be Rel-13. To be concluded at SA#72.; 13/6/16: 0%->60; 1/12/16: 60%->70; 6/3/17: 70%->100 / Impacted TSs and TRs: 55.241, 55.242, 55.243, 55.251, 55.252, 55.253
- 806: Umbrella, created by MCC to group SA2 and SA3 activities
- 807: 07/09/15: 0%->10; 07/09/15: 10%->100; 7/12/15: 100%->10% (mistake?) then 10%->70, FCD: 12/15-?03/16; 7/3/16: 70%->80; 9/6/16: 80%->100 / Impacted TSs and TRs: New TR 23.xxx
- 808: 7/12/15: 0%->45; 28/1/16: 33.827 added; 7/3/16: 45%->55; 19/9/16: 55%->65; 15/12/17: 65%->100 / Impacted TSs and TRs: TR 33.827
- 809: 11/6/16: 0%->60; 19/9/16: 60%->95; 1/12/16: FCD:09/16->12/16; 1/12/16: 95%->100 / Impacted TSs and TRs: TS 23.228, TS 23.167, TS 23.203

| ID | WBS | Task | Duration | Start | Finish | Complete | Constraint | Resources | Work | Actual work | Acronym | PCG approved | WI rapporteur name | WI rapporteur e-mail | Release | TSG approved | Status Report |
| --- | --- | --- | --- | --- | --- | --- | --- | --- | --- | --- | --- | --- | --- | --- | --- | --- | --- |
| 810 | 344.4 | **CT Aspects of V8** | 65d? | 2016-09-16 A | 2016-12-15 A | 100% |  | ct | 1560h | 1560h | V8-CT | 37 | Tsuyoshi Takakura (NTT DOCOMO) | tsuyoshi.takakura.ey@s1.nttdocomo.com | Rel-14 | 73 |  |
| 811 | 344.4.1 | CT1 Aspects of V8 | 65d? | 2016-09-16 A | 2016-12-15 A | 100% | finish no earlier than 2016-12-15 | C1 | 520h | 520h | V8-CT | 37 | Tsuyoshi Takakura (NTT DOCOMO) | tsuyoshi.takakura.ey@s1.nttdocomo.com | Rel-14 | 73 |  |
| 812 | 344.4.2 | CT3 Aspects of V8 | 65d? | 2016-09-16 A | 2016-12-15 A | 100% | finish no earlier than 2016-12-15 | C3 | 520h | 520h | V8-CT | 37 | Tsuyoshi Takakura (NTT DOCOMO) | tsuyoshi.takakura.ey@s1.nttdocomo.com | Rel-14 | 73 |  |
| 813 | 344.5 | Charging Aspects of S8 Home Routing Architecture for VoLTE | 261d? | 2016-06-13 A | 2017-06-09 A | 100% | finish no earlier than 2017-06-09 | S5 | 2088h | 2088h | CH14-V8 | 37 | Chen, Ai (China Mobile) | chenai(at) chinamobile (dot) com | Rel-14 | 72 |  |
| 814 | 345 | **Improvements of awareness of user location change** | 453d? | 2015-09-17 A | 2017-06-09 A | 100% |  |  | 5256h | 5256h | AULC | 37 | Yang Xu | xuyang49@chinaunicom.cn | Rel-14 | 72 | SP-170524 |
| 815 | 345.1 | Study on improvement of awareness of user location change | 197d? | 2015-09-17 A | 2016-06-17 A | 100% | finish no earlier than 2016-06-17 | S2 | 1576h | 1576h | FS_AULC | 35 | Yang Xu | xuyang49@chinaunicom.cn | Rel-14 | 69 |  |
| 816 | 345.2 | Improvements of awareness of user location change | 75d? | 2016-06-06 A | 2016-09-15 A | 100% | finish no earlier than 2016-09-15 | S2 | 600h | 600h | AULC | 37 | Yang Xu | xuyang49@chinaunicom.cn | Rel-14 | 72 |  |
| 817 | 345.3 | **CT Aspect of AULC** | 65d? | 2016-09-16 A | 2016-12-15 A | 100% |  | ct | 1560h | 1560h | AULC-CT | 37 | Huawei, Wu Yizhuang | wuyizhuang@huawei.com | Rel-14 | 73 |  |
| 818 | 345.3.1 | CT3 Aspect of AULC | 65d? | 2016-09-16 A | 2016-12-15 A | 100% | finish no earlier than 2016-12-15 | C3 | 520h | 520h | AULC-CT | 37 | Huawei, Wu Yizhuang | wuyizhuang@huawei.com | Rel-14 | 73 |  |
| 819 | 345.3.2 | CT4 Aspect of AULC | 65d? | 2016-09-16 A | 2016-12-15 A | 100% | finish no earlier than 2016-12-15 | C4 | 520h | 520h | AULC-CT | 37 | Huawei, Wu Yizhuang | wuyizhuang@huawei.com | Rel-14 | 73 |  |
| 820 | 345.4 | Charging Aspects of Improvements of AULC | 190d? | 2016-09-19 A | 2017-06-09 A | 100% | finish no earlier than 2017-06-09 | S5 | 1520h | 1520h | AULC-CH | 37 | Huawei， Chen, Shan | chenshan@huawei.com | Rel-14 | 73 |  |
| 821 | 346 | **Service Domain Centralization** | 232d? | 2015-11-02 A | 2016-09-19 A | 100% |  | S2 | 3896h | 3896h | SeDoC | 37 | Chris Joul (T-Mobile USA) | chris (dot) joul (at) t (dash) mobile (dot) com | Rel-14 | 72 |  |
| 822 | 346.1 | Study on Service Domain Centralization | 230d? | 2015-11-02 A | 2016-09-15 A | 100% | finish no earlier than 2016-09-15 | S2 | 1840h | 1840h | FS_SeDoC | 36 | Chris Joul (T-Mobile USA) | chris (dot) joul (at) t (dash) mobile (dot) com | Rel-14 | 70 |  |
| 823 | 346.2 | Service Domain Centralization | 25d? | 2016-08-16 A | 2016-09-19 A | 100% | finish no earlier than 2016-09-19 | S2 | 200h | 200h | SeDoC | 37 | Chris Joul (T-Mobile USA) | chris (dot) joul (at) t (dash) mobile (dot) com | Rel-14 | 73 |  |
| 824 | 347 | **Sponsored data connectivity improvements** | 295d? | 2015-11-02 A | 2016-12-15 A | 100% |  |  | 2880h | 2880h | SDCI | 37 | Yang Xu | xuyang49@chinaunicom.cn | Rel-14 | 72 | SP-170523 |
| 825 | 347.1 | Study on sponsored data connectivity improvements | 160d? | 2015-11-02 A | 2016-06-10 A | 100% | finish no earlier than 2016-06-10 | S2 | 1280h | 1280h | FS_SDCI | 36 | Yang Xu | xuyang49@chinaunicom.cn | Rel-14 | 70 |  |
| 826 | 347.2 | Sponsored data connectivity improvements | 70d? | 2016-06-13 A | 2016-09-15 A | 100% | finish no earlier than 2016-09-15 | S2 | 560h | 560h | SDCI | 37 | Yang Xu | xuyang49@chinaunicom.cn | Rel-14 | 72 |  |
| 827 | 347.3 | **CT Aspects of SDCI** | 65d? | 2016-09-16 A | 2016-12-15 A | 100% |  | ct | 1040h | 1040h | SDCI-CT | 37 | China Unicom, Xu, Yang | xuyang49@chinaunicom.cn | Rel-14 | 73 |  |
| 828 | 347.3.1 | CT3 Aspects of SDCI | 65d? | 2016-09-16 A | 2016-12-15 A | 100% | finish no earlier than 2016-12-15 | C3 | 520h | 520h | SDCI-CT | 37 | China Unicom, Xu, Yang | xuyang49@chinaunicom.cn | Rel-14 | 73 |  |
| 829 | 348 | **Stage-3 SAE Protocol Development - Phase 5** | 272d? | 2016-03-02 A | 2017-03-15 A | 100% |  | C1 | 8704h | 8704h | SAES5 | 36 | Interdigital, Aghili, Behrouz | Behrouz.aghili@interdigital.com | Rel-14 | 71 |  |
| 830 | 348.1 | SAES5 CS Fallback in EPS | 272d? | 2016-03-02 A | 2017-03-15 A | 100% | start no earlier than 2016-03-02 | C1 | 2176h | 2176h | SAES5-CSFB | 36 | Interdigital, Aghili, Behrouz | Behrouz.aghili@interdigital.com | Rel-14 | 71 |  |
| 831 | 348.2 | SAES5 for support for non-3GPP accesses | 272d? | 2016-03-02 A | 2017-03-15 A | 100% | start no earlier than 2016-03-02 | C1 | 2176h | 2176h | SAES5-non3GPP | 36 | Interdigital, Aghili, Behrouz | Behrouz.aghili@interdigital.com | Rel-14 | 71 |  |
| 832 | 348.3 | SAE Protocol Development (Stage 3) - Phase 5 | 272d? | 2016-03-02 A | 2017-03-15 A | 100% | start no earlier than 2016-03-02 | C1 | 2176h | 2176h | SAES5 | 37 |  |  | Rel-14 | 72 |  |
| 833 | 349 | **Group based enhancements in the network capability exposure functions** | 296d? | 2015-11-02 A | 2016-12-16 A | 100% |  | S2 | 4752h | 4752h | GENCEF | 36 | Samsung, Sung Hwan Won | sunghwan.won@samsung.com | Rel-14 | 70 | SP-170517 |
| 834 | 349.1 | Study on group based enhancements in the network capability exposure functions | 160d? | 2015-11-02 A | 2016-06-10 A | 100% | start no earlier than 2015-11-02 | S2 | 1280h | 1280h | FS_GENCEF | 36 | Samsung, Sung Hwan Won | sunghwan.won@samsung.com | Rel-14 | 70 |  |
| 835 | 349.2 | Group based enhancements in the network capability exposure functions | 138d? | 2016-06-09 A | 2016-12-16 A | 100% | finish no earlier than 2016-12-16 | S2 | 1104h | 1104h | GENCEF | 37 | Samsung, Sunghoon Kim | s.hun.kim@samsung.com | Rel-14 | 72 |  |

Notes:
- 811: 2/12/16: 40%->100 / Impacted TSs and TRs: 24.229
- 812: 2/12/16: 40%->100 / Impacted TSs and TRs: 29.212, 29.213, 29.214
- 813: 19/9/16: 0%->15; 1/12/16: FCD:12/16->03/17; 1/12/16: 15%->60; 1/12/16: WID:SP-160429->SP-160838; 6/3/17: FCD:03/17->06/17; 7/6/17: 60%->100 / Impacted TSs and TRs: 32.240, 32.251, 32.260
- 815: 7/12/15: 0%->40; 7/3/16: 40%->70; 9/6/16: 70%->100 / Impacted TSs and TRs: 23.710
- 816: 11/6/16: 0%->10; 19/9/16: 10%->100 / Impacted TSs and TRs: 23.401, 23.203, 23.060
- 818: 2/12/16: 0%->10; 6/3/17: 10%->100 / Impacted TSs and TRs: 29.212, 29.213
- 819: 2/12/16: 0%->95; 6/3/17: 95%->100 / Impacted TSs and TRs: 29.274
- 820: 1/12/16: 0%->40; 6/3/17: 40%->80; 6/3/17: FCD:03/17->06/17; 7/6/17: 80%->100 / Impacted TSs and TRs: TS32.251, TS32.298, TS32.299
- 822: Comes back from previous release; 28/1/16: 23.719 added; 7/3/16: 0%->30; 7/3/16: WID:SP-150626->SP-1601679/6/16: 30%->70; 11/6/16: WID:SP-160167->SP-160306. FCD: 06/16->09/16; 1/12/16: 70%->100 / Impacted TSs and TRs: 23.719
- 823: 19/9/16: 0%->100 / Impacted TSs and TRs: 23.292, 23.167
- 825: 28/1/16: 23.721 added; 7/3/16: 10%->40; 9/6/16: 40%->100 / Impacted TSs and TRs: 23.721
- 826: 19/9/16: 0%->100 / Impacted TSs and TRs: 23.203, 23.682
- 827: 6/10/16: 29.251 added; / Impacted TSs and TRs: 29.251
- 828: 6/10/16: 29.250 added; 2/12/16: 10%->30; 6/3/17: 30%->80; 5/6/17: 80%->100 / Impacted TSs and TRs: 29.212, 29.213, 29.214, 29.201, 29.250
- 829: Impacted TSs and TRs: 23.122, 24.008, 24.167, 24.229, 24.301, 24.302, 24.303, 24.304, 24.305, 24.312, 29.018, 29.118
- 830: 11/6/16: 0%->5; 16/9/16: 5%->20; 2/12/16: 20%->70; 6/3/17: 70%->100 / Impacted TSs and TRs: 23.122, 24.008, 24.167, 24.229, 24.301, 24.302, 24.303, 24.304, 24.305, 24.312, 29.018, 29.118
- 831: 11/6/16: 0%->15; 16/9/16: 15%->20; 2/12/16: 20%->85; 6/3/17: 85%->100 / Impacted TSs and TRs: 23.122, 24.008, 24.167, 24.229, 24.301, 24.302, 24.303, 24.304, 24.305, 24.312, 29.018, 29.118
- 832: Added following CT1's chair e-mail 14/06/16; 16/9/16: 0%->20; 2/12/16: 20%->85; 6/3/17: 85%->100
- 834: 28/1/16: 23.773 added; 28/1/16: 23.742 added; 7/3/16: 0%->10; 9/6/16: 10%->100 / Impacted TSs and TRs: 23.xyz; 23.773; 23.742
- 835: 19/9/16: 0%->90; 1/12/16: FCD:09/16->12/16; 1/12/16: 90%->100 / Impacted TSs and TRs: 23.682

| ID | WBS | Task | Duration | Start | Finish | Complete | Remaining | Total slack | Constraint | Resources | Work | Actual work | Acronym | PCG approved | Release | TSG approved | WI rapporteur name | WI rapporteur e-mail | Status Report |
| --- | --- | --- | --- | --- | --- | --- | --- | --- | --- | --- | --- | --- | --- | --- | --- | --- | --- | --- | --- |
| 836 | 350 | **Robust Call Setup for VoLTE subscriber in LTE** | 686d? | 2015-11-02 A | 2018-06-15 | 90% | 71.07d? | 521d |  |  | 10736h | 7386.4h | RobVoLTE | 37 | Rel-14 | 72 |  |  |  |
| 837 | 350.1 | Study on Robust Call Setup for VoLTE subscriber in LTE | 160d? | 2015-11-02 A | 2016-06-10 A | 100% |  |  | start no earlier than 2015-11-02 | S2 | 1280h | 1280h | FS_RobVoLTE | 36 | Rel-14 | 70 | Xiaobo Wu, Huawei | wuxiaobo@ huawei.com |  |
| 838 | 350.2 | Robust Call Setup for VoLTE subscriber in LTE | 66d? | 2016-06-17 A | 2016-09-15 A | 100% |  |  | finish no earlier than 2016-09-15 | S2 | 528h | 528h | RobVoLTE |  | Rel-14 | 72 | Xiaobo Wu, Huawei | wuxiaobo@ huawei.com |  |
| 839 | 350.3 | CT Aspects of RobVoLTE | 130d? | 2016-09-16 A | 2017-03-16 A | 100% |  |  | finish no earlier than 2017-03-16 | C1 | 1040h | 1040h | RobVoLTE-CT | 37 | Rel-14 | 73 | PATEL, Milan | Milan.Patel@huawei.com |  |
| 840 | 350.4 | **Voice and Video Enhancement for LTE** | 457d? | 2016-09-15 A | 2018-06-15 | 77% | 106.9d? | 521d |  | R2 | 6792h | 3442.4h | LTE_VoLTE_ViLTE_enh | 37 | Rel-14 | 73 | CMCC |  |  |
| 841 | 350.4.1 | Core part: Voice and Video Enhancement for LTE | 130d? | 2016-09-15 A | 2017-03-15 A | 100% |  |  | finish no earlier than 2017-03-15 | R2 | 1040h | 1040h | LTE_VoLTE_ViLTE_enh-Core | 37 | Rel-14 | 73 | CMCC |  | RP-170323 |
| 842 | 350.4.2 | UE Conformance Test Aspects –Voice and Video Enhancement for LTE | 262d? | 2017-06-15 A | 2018-06-15 | 65% | 91.7d? | 521d | finish no earlier than 2018-06-15 | R5 | 2096h | 1362.4h | LTE_VoLTE_ViLTE_enh-UEConTest | 39 | Rel-14 | 76 | CATT |  |  |
| 843 | 350.5 | RAN-Assisted Codec Adaptation in MTSI | 137d? | 2016-12-01 A | 2017-06-09 A | 100% |  |  | finish no earlier than 2017-06-09 | S4 | 1096h | 1096h | LTE_VoLTE_ViLTE_enh-S4 | 38 | Rel-14 | 74 | Ozgur Oyman, Intel | ozgur.oyman@intel.com | SP-170516 |
| 844 | 351 | Extension of UE Delay test methods and requirements | 261d? | 2016-06-13 A | 2017-06-09 A | 100% |  |  | finish no earlier than 2017-06-09 | S4 | 2088h | 2088h | EXT_UED | 37 | Rel-14 | 72 | Stéphane Ragot, ORANGE | stephane.ragot@orange.com | SP-170345 |
| 845 | 352 | **Improved operator control using new UE configuration parameters** | 199d? | 2016-06-13 A | 2017-03-15 A | 100% |  |  |  |  | 3184h | 3184h | IOC_UE_conf | 37 | Rel-14 | 72 | Sedlacek, Ivo | ivo.sedlacek@ericsson.com | CP-171176 |
| 846 | 352.1 | CT1 aspects of IOC_UE_conf | 199d? | 2016-06-13 A | 2017-03-15 A | 100% |  |  | finish no earlier than 2017-03-15 | C1 | 1592h | 1592h | IOC_UE_conf | 37 | Rel-14 | 72 | Sedlacek, Ivo | ivo.sedlacek@ericsson.com |  |
| 847 | 352.2 | CT6 aspects of IOC_UE_conf | 199d? | 2016-06-13 A | 2017-03-15 A | 100% |  |  | finish no earlier than 2017-03-15 | C6 | 1592h | 1592h | IOC_UE_conf | 37 | Rel-14 | 72 | Adrian Buckley | abuckley@blackberry.com |  |
| 848 | 353 | Shared Subscription Data Update | 135d? | 2016-06-13 A | 2016-12-15 A | 100% |  |  | finish no earlier than 2016-12-15 | C4 | 1080h | 1080h | eSDU | 37 | Rel-14 | 72 | Nokia, Ulrich Wiehe | ulrich.wiehe@nokia.com | CP-171050 |
| 849 | 354 | **Rel-14 Charging** | 335d? | 2016-03-01 A | 2017-06-09 A | 100% |  |  |  | S5 | 8544h | 8544h | CH14 | 36 | Rel-14 | 71 |  |  |  |
| 850 | 354.1 | Resource Optimization for PS Domain Online | 335d | 2016-03-01 A | 2017-06-09 A | 100% |  |  | finish no earlier than 2017-06-09 | S5 | 2680h | 2680h | CH14-ROPOCH | 36 | Rel-14 | 71 | Shrader, David(Ericsson) | david.shrader@ericsson.com |  |
| 851 | 354.2 | Charging for SMS via T4 | 137d? | 2016-12-01 A | 2017-06-09 A | 100% |  |  | finish no earlier than 2017-06-09 | S5 | 1096h | 1096h | CH14-SMST4 | 38 | Rel-14 | 74 | Nokia | Maryse <dot> Gardella <at> Nokia <dot> com |  |
| 852 | 354.3 | Charging Aspects of Enhanced Proximity-based Services | 261d? | 2016-06-13 A | 2017-06-09 A | 100% |  |  | finish no earlier than 2017-06-09 | S5 | 2088h | 2088h | CH14-ProSe | 37 | Rel-14 | 72 | Chen, Shan | chenshan@huawei.com | SP-170408 |
| 853 | 355 | **Determination of Completeness of Charging Information in IMS** | 261d? | 2016-06-13 A | 2017-06-09 A | 100% |  |  |  | S5 | 5952h | 5952h | CH14-DCCII | 37 | Rel-14 | 72 | Jesske, Roland (Deutsche Telekom) |  |  |
| 854 | 355.1 | Determination of Completeness of Charging Information in IMS | 261d? | 2016-06-13 A | 2017-06-09 A | 100% |  |  | finish no earlier than 2017-06-09 | S5 | 2088h | 2088h | CH14-DCCII | 37 | Rel-14 | 72 | Jesske, Roland (Deutsche Telekom) |  | SP-170344 |
| 855 | 355.2 | **CT Aspects of Determination of Completeness of Charging Information in IMS** | 74d? | 2016-12-01 A | 2017-03-14 A | 100% |  |  |  | ct | 1776h | 1776h | CH14-DCCII-CT | 38 | Rel-14 | 74 | Michael KREIPL, Deutsche Telekom | michael(dot)kreipl(at)telekom(dot)de | CP-171048 |
| 856 | 355.2.1 | CT1 Aspects of Determination of Completeness of Charging Information in IMS | 74d? | 2016-12-01 A | 2017-03-14 A | 100% |  |  | finish no earlier than 2017-03-14 | C1 | 592h | 592h | CH14-DCCII-CT | 38 | Rel-14 | 74 | Michael KREIPL, Deutsche Telekom | michael(dot)kreipl(at)telekom(dot)de |  |
| 857 | 355.2.2 | CT3 Aspects of Determination of Completeness of Charging Information in IMS | 74d? | 2016-12-01 A | 2017-03-14 A | 100% |  |  | finish no earlier than 2017-03-14 | C3 | 592h | 592h | CH14-DCCII-CT | 38 | Rel-14 | 74 | Michael KREIPL, Deutsche Telekom | michael(dot)kreipl(at)telekom(dot)de |  |
| 858 | 356 | **Enhanced LAA for LTE** | 655d? | 2015-12-15 A | 2018-06-15 | 89% | 72.12d? | 521d |  |  | 9960h | 8863.2h | LTE_eLAA | 36 | Rel-14 | 70 | Ericsson |  |  |
| 859 | 356.1 | Core part: Enhanced LAA for LTE | 328d? | 2015-12-15 A | 2017-03-15 A | 100% |  |  | finish no earlier than 2017-03-15 | R1 | 2624h | 2624h | LTE_eLAA-Core | 36 | Rel-14 | 70 | Ericsson |  | RP-170269 |
| 860 | 356.2 | Perf. part: Enhanced LAA for LTE | 460d? | 2015-12-15 A | 2017-09-15 A | 100% |  |  | finish no earlier than 2017-09-15 | R4 | 3680h | 3680h | LTE_eLAA-Perf | 36 | Rel-14 | 70 | Ericsson |  |  |
| 861 | 356.3 | UE Conformance Test Aspects - Enhanced LAA for LTE | 457d? | 2016-09-15 A | 2018-06-15 | 70% | 137.1d? | 521d | finish no earlier than 2018-06-15 | R5 | 3656h | 2559.2h | LTE_eLAA-UEConTest | 37 | Rel-14 | 73 | Intel |  |  |

Notes:
- 837: 28/1/16: 23.750 added; 7/3/16: 0%->20; 9/6/16: 20%->100 / Impacted TSs and TRs: 23.8xx; 23.750
- 838: 19/9/16: 0%->100. 1/12/16: UID changed: 720085 -> 720301 (720085 was also used for RP-161181) / Impacted TSs and TRs: 23.228, 23.237
- 839: 2/12/16: 0%->80; 6/3/17: 80%->100 / Impacted TSs and TRs: 24.229, 24.292
- 841: ; 20/12/16: Compl:0%->80%; 21/3/17: Compl:80%->100%; 21/3/17: Stat Rep: ->RP-170323
- 842: ; 19/9/17: Compl:0%->20%; 8/1/18: Compl:20%->60%; ...; 27/3/18: Compl:60...
- 843: 6/3/17: 0%->65; 6/3/17: FCD:03/17->06/17; 7/6/17: 65%->100
- 844: 19/9/16: WID:SP-160271->SP-160600; 19/9/16: 0%->20; 1/12/16: 20%->30; 14/12/16: 30%->50; 6/3/17: 50%->60; 6/3/17: FCD:03/17->06/17; 7/6/17: 60%->100 / Impacted TSs and TRs: TR 26.954, 26.131, 26.132
- 845: 11/6/16: 0%->10; 17/10/16: WID:CP-160296->CP-160374; 5/12/16: WID:CP-160374->CP-160828 / Impacted TSs and TRs: 24.167, 24.229, 24.301, 24.302, 24.312, 24.341, 24.368, 24.607, 24.623, TS 24.XXX, TS 24.YYY
- 846: 11/6/16: 0%->10; 16/9/16: 10%->20; 17/10/16: WID:CP-160296->CP-160374; 2/12/16: 20%->75; 6/3/17: 75%->100 / Impacted TSs and TRs: 24.167, 24.229, 24.301, 24.302, 24.312, 24.341, 24.368, 24.607, 24.623, 24.275
- 847: 11/6/16: 0%->10; 14/12/16: 0%->15; 7/3/17: 15%->85; 5/6/17: 85%->100 / Impacted TSs and TRs: 31.102, 31.103
- 848: 13/6/16: 0%->25; 2/12/16: 25%->100; 5/12/16: WID:CP-160243->CP-160644 / Impacted TSs and TRs: 29.272, 29.002, 29.305, 29.230
- 849: Umbrella Feature
- 850: 13/6/16: 0%->10. FCD:09/16->03/17; 19/9/16: FCD: 09/16->03/17; 19/9/16: 10%->20; 1/12/16: 20%->50; 6/3/17: 50%->80; 6/3/17: FCD:03/17->06/20; 7/6/17: 80%->100 / Impacted TSs and TRs: 32.251, 32.299
- 851: 6/3/17: 0%->20; 6/3/17: FCD:03/17->06/17; 7/6/17: 20%->100 / Impacted TSs and TRs: TS 32.274, TS 32.250 , TS 32.298, TS 32.299
- 852: 19/9/16: 0%->40; 1/12/16: 40%->60; 6/3/17: FCD:03/17->06/17; 6/3/17: 60%->80; 7/6/17: 80%->100 / Impacted TSs and TRs: 32.240, 32.251, 32.277, 32.298, 32.299
- 853: 19/9/16: 0%->10 / Impacted TSs and TRs: 32.240, 32.260, 32.298, 32.299
- 854: 19/9/16: 0%->10; 6/3/17: FCD:03/17->06/17; 7/6/17: 10%->100 / Impacted TSs and TRs: 32.240, 32.260, 32.298, 32.299
- 856: 2/12/16: 0%->10; 6/3/17: 10%->35; 5/6/17: 35%->100 / Impacted TSs and TRs: 24.229
- 857: 8/6/17: 0%->100 / Impacted TSs and TRs: 29.165
- 859: 22/3/16: Compl:0%->20%22/3/16: WID: RP-152272->RP-1604071/7/16: Compl:20%->60%1/7/16: WID: RP-160407->RP-160881; 26/9/16: Compl:60%->92%; 26/9/16: CD:Thu 15/09/16->Thu 15/12/16; 26/9/16: WID: ; 20/12/16: Compl:92%->97%; 20/12/16:21/3/17: Compl:...
- 860: 22/3/16: WID: RP-152272->RP-160407; 1/7/16: WID: RP-160407->RP-16088126/9/16: CD:Wed 15/03/17->Thu 15/06/1726/9/16: WID: RP-160881->RP-161832; 20/12/16: WID: RP-161832->RP-162235;21/3/17: Compl:0%->33%; 19/6/17: Compl:33%->50%; ...; ;...
- 861: ; 21/3/17: Compl:0%->5% ;...19/6/17: Compl:5%->6%; 19/9/17: Compl...; 8/1/18: C...2...

| ID | WBS | Task | Duration | Start | Finish | Complete | Remaining | Total slack | Constraint | Resources | Work | Actual work | Acronym | PCG approved | WI rapporteur name | Release | TSG approved | Status Report | Impacted TSs and TRs |
| --- | --- | --- | --- | --- | --- | --- | --- | --- | --- | --- | --- | --- | --- | --- | --- | --- | --- | --- | --- |
| 862 | 357 | **RRC optimization for UMTS** | 199d? | 2015-12-15 A | 2016-09-15 A | 100% |  |  |  | R2 | 3184h | 3184h | UTRA_RRCopt | 36 | Ericsson | Rel-14 | 70 |  |  |
| 863 | 357.1 | Core part: RRC optimization for UMTS | 199d? | 2015-12-15 A | 2016-09-15 A | 100% |  |  | finish no earlier than 2016-09-15 | R2 | 1592h | 1592h | UTRA_RRCopt-Core | 36 | Ericsson | Rel-14 | 70 | RP-172758 |  |
| 864 | 358 | **DTX/DRX enhancements in CELL_FACH** | 264d? | 2015-12-15 A | 2016-12-15 A | 100% |  |  |  | R2 | 4224h | 4224h | FACH_DTXDRX | 36 | Huawei | Rel-14 | 70 |  |  |
| 865 | 358.1 | Core part: DTX/DRX enhancements in CELL_FACH | 264d? | 2015-12-15 A | 2016-12-15 A | 100% |  |  | finish no earlier than 2016-12-15 | R2 | 2112h | 2112h | FACH_DTXDRX-Core | 36 | Huawei | Rel-14 | 70 | RP-162132 |  |
| 866 | 359 | **AWS-3/4 Band for LTE** | 264d? | 2015-12-15 A | 2016-12-15 A | 100% |  |  |  |  | 2640h | 2640h | LTE_AWS_3_4 | 36 | Dish Network | Rel-14 | 70 |  |  |
| 867 | 359.1 | Core part: AWS-3/4 Band for LTE | 132d? | 2015-12-15 A | 2016-06-15 A | 100% |  |  | finish no earlier than 2016-09-15 | R4 | 1056h | 1056h | LTE_AWS_3_4-Core | 36 | Dish Network | Rel-14 | 70 |  | 36.749 |
| 868 | 359.2 | Perf. part: AWS-3/4 Band for LTE | 132d? | 2015-12-15 A | 2016-06-15 A | 100% |  |  | finish no earlier than 2016-09-15 | R4 | 1056h | 1056h | LTE_AWS_3_4-Perf | 36 | Dish Network | Rel-14 | 70 |  |  |
| 869 | 359.3 | UE Conformance Test Aspects – AWS-3/4 Band for LTE (Band 70) | 66d? | 2016-09-15 A | 2016-12-15 A | 100% |  |  | finish no earlier than 2017-03-15 | R5 | 528h | 528h | LTE_AWS_3_4-UEConTest | 37 | Dish Network | Rel-14 | 73 |  |  |
| 870 | 360 | **LTE FDD in the Bands 1980-2010 MHz and 2170-2200MHz for Region 3** | 1d? | 2015-12-15 | 2015-12-15 |  |  | 1175d |  | R4 | 16h |  | LTE_1980_2170_REG3 | 36 | KT Corp. | Rel-14 | 70 |  |  |
| 871 | 360.1 | Core part: LTE FDD in the Bands 1980-2010 MHz and 2170-2200MHz for Region 3 | 1d? | 2015-12-15 | 2015-12-15 |  |  | 1175d | finish no earlier than 2015-12-15 | R4 | 8h |  | LTE_1980_2170_REG3-Core | 36 | KT Corp. | Rel-14 | 70 |  |  |
| 872 | 361 | **Addition of 1.4 and 3 MHz Channel Bandwidth to E-UTRA operating band 65 for CGC (Complementary Ground Component) operations in Region 1** | 197d? | 2016-12-15 A | 2017-09-15 | 99% | 0d? | 0d |  | R4 | 2632h | 1576h | LTE_1980_2170_REG1_addBWs | 38 | Hughes Network Systems | Rel-14 | 74 |  |  |
| 873 | 361.1 | Core part: Addition of 1.4 and 3 MHz Channel Bandwidth to E-UTRA operating band 65 for CGC (Complementary Ground Component) operations in Region 1 | 65d? | 2016-12-15 A | 2017-03-15 A | 100% |  |  | finish no earlier than 2017-03-15 | R4 | 520h | 520h | LTE_1980_2170_REG1_addBWs-Core | 38 | Hughes Network Systems | Rel-14 | 74 |  |  |
| 874 | 361.2 | UE Conformance Test Aspects – Addition of 1.4 and 3 MHz Channel Bandwidth to E-UTRA operating band 65 for CGC (Complementary Ground Component) operations in Region 1 | 67d? | 2017-06-15 A | 2017-09-15 A | 100% |  |  | finish no earlier than 2017-09-15 | R5 | 536h | 536h | LTE_1980_2170_REG1_addBWs-UEConTest | 39 | Dish Network | Rel-14 | 76 |  |  |
| 875 | 362 | **LTE 2.6 GHz FDD Supplemental DL band (2570-2620 MHz) and LTE Carrier Aggregation (2DL/1UL) with Band 3 for region 1** | 525d? | 2015-12-15 A | 2017-12-15 | 99% | 0d? | 0d |  | R4 | 7896h | 4748.02h | LTE_FDD_2600_CA_B3 | 36 | Orange | Rel-14 | 70 |  |  |
| 876 | 362.1 | Core part: LTE 2.6 GHz FDD Supplemental DL band (2570-2620 MHz) and LTE Carrier Aggregation (2DL/1UL) with Band 3 for region 1 | 132d? | 2015-12-15 A | 2016-06-15 A | 100% |  |  | finish no earlier than 2016-09-15 | R4 | 1056h | 1056h | LTE_FDD_2600_CA_B3-Core | 36 | Orange | Rel-14 | 70 |  | 36.858 |
| 877 | 362.2 | Perf. part: LTE 2.6 GHz FDD Supplemental DL band (2570-2620 MHz) and LTE Carrier Aggregation (2DL/1UL) with Band 3 for region 1 | 132d? | 2015-12-15 A | 2016-06-15 A | 100% |  |  | finish no earlier than 2016-09-15 | R4 | 1056h | 1056h | LTE_FDD_2600_CA_B3-Perf | 36 | Orange | Rel-14 | 70 |  |  |
| 878 | 362.3 | UE Conformance Test Aspects - LTE 2.6 GHz FDD SDL band (2570-2620 MHz) and LTE Carrier Aggregation (2DL/1UL) with Band 3 for Region 1 (Band 69) | 198d? | 2017-03-15 A | 2017-12-15 A | 100% |  |  | finish no earlier than 2017-12-15 | R5 | 1584h | 1584h | LTE_FDD_2600_CA_B3-UEConTest |  | Bureau Veritas | Rel-14 |  |  |  |
| 879 | 363 | **Multi-Band Base Station testing with three or more bands** | 264d? | 2015-12-15 A | 2016-12-15 A | 100% |  |  |  | R4 | 6336h | 6336h | MB_BS_test_3B | 36 | Alcatel-Lucent | Rel-14 | 70 |  |  |
| 880 | 363.1 | Core part: Multi-Band Base Station testing with three or more bands | 264d? | 2015-12-15 A | 2016-12-15 A | 100% |  |  | finish no earlier than 2016-12-15 | R4 | 2112h | 2112h | MB_BS_test_3B-Core | 36 | Alcatel-Lucent | Rel-14 | 70 | RP-162032 | 37.871 |
| 881 | 363.2 | Perf. part: Multi-Band Base Station testing with three or more bands | 264d? | 2015-12-15 A | 2016-12-15 A | 100% |  |  | finish no earlier than 2016-12-15 | R4 | 2112h | 2112h | MB_BS_test_3B-Perf | 36 | Alcatel-Lucent | Rel-14 | 70 |  |  |
| 882 | 364 | **Performance enhancements for high speed scenario in LTE** | 655d? | 2015-12-15 A | 2018-06-15 | 90% | 65.37d? | 521d |  | R4 | 13128h | 9686.63h | LTE_high_speed | 36 | NTT DOCOMO | Rel-14 | 70 |  |  |
| 883 | 364.1 | Core part: Performance enhancements for high speed scenario in LTE | 264d? | 2015-12-15 A | 2016-12-15 A | 100% |  |  | finish no earlier than 2016-12-15 | R4 | 2112h | 2112h | LTE_high_speed-Core | 36 | NTT DOCOMO | Rel-14 | 70 | RP-162222 |  |
| 884 | 364.2 | Perf. part: Performance enhancements for high speed scenario in LTE | 394d? | 2015-12-15 A | 2017-06-15 A | 100% |  |  | finish no earlier than 2017-06-15 | R4 | 3152h | 3152h | LTE_high_speed-Perf | 36 | NTT DOCOMO | Rel-14 | 70 |  |  |
| 885 | 364.3 | UE Conformance Test Aspects - Performance enhancements for high speed scenario in LTE | 328d? | 2017-03-15 A | 2018-06-15 | 70% | 98.4d? | 521d | finish no earlier than 2018-06-15 | R5 | 2624h | 1836.8h | LTE_high_speed-UEConTest | 38 | CMCC | Rel-14 | 75 |  |  |

Notes:
- 863: 22/3/16: Compl:0%->8%; 1/7/16: Compl:8%->70%26/9/16: Compl:70%->100%; 8/1/18: Stat Rep: ->RP-172758
- 865: 22/3/16: Compl:0%->20%; 1/7/16: Compl:20%->50%26/9/16: Compl:50%->65%; 20/12/16: Compl:65%->100%;
- 867: ; 22/3/16: Compl:0%->60%; 1/7/16: Compl:60%->100%; 1/7/16: CD:Th
- 868: 1/7/16: Compl:0%->100%1/7/16: CD:Thu 15/09/16->Wed 15/06
- 869: ; 20/12/16: Compl:0%->100%;
- 873: ; 21/3/17: Compl:0%->100% ; 2...
- 874: ; 19/9/17: Compl:0%->100%
- 876: 28/1/16: 36.858 added;22/3/16: Compl:0%->40%22/3/16: WID: RP-152253->RP-160378; 1/7/16: Compl:40%->100%;
- 877: ; 22/3/16: WID: RP-152253->RP-1603781/7/16: Compl:0%->100%1/7/16
- 878: ; 19/9/17: Compl:43%->96%; ;...; 8/1/18: Compl:96%->100%; ...
- 880: 22/3/16: Compl:0%->50%22/3/16: WID: RP-152205->RP-1600631/7/16: Compl:50%->90%; 26/9/16: Compl:90%->95%; 26/9/16; 20/12/16: Compl:95%->100%;
- 881: 22/3/16: Compl:0%->5%22/3/16: WID: RP-152205->RP-160063; 1/7/16: Compl:5%->30%26/9/16: Compl:30%->60%26/; 20/12/16: Compl:60%->100%;
- 883: 22/3/16: Compl:0%->5%22/3/16: WID: RP-152263->RP-160172; 1/7/16: Compl:5%->25%26/9/16: Compl:25%->45%20/12/16: Compl:45%->100%20/12/16: Stat Rep: ->RP-162222
- 884: 22/3/16: WID: RP-152263->RP-1601721/7/16: Compl:0%->20%; 26/9/16: Compl:20%->25%; 20/12/16: Compl:25%->35% ; 21/3/17: Compl:35%->70%; 19/6/17: Compl:70%->100%; 19/6/17: WID: RP-160172->RP-171039
- 885: tested: REL-14 LTE_high_speed-Core;; 19/6/17: Compl:...; 1...; 8/1/18:...27/3/...

| ID | WBS | Task | Duration | Start | Finish | Complete | Remaining | Total slack | Constraint | Resources | Work | Actual work | Acronym | PCG approved | WI rapporteur name | Release | TSG approved | Status Report |
| --- | --- | --- | --- | --- | --- | --- | --- | --- | --- | --- | --- | --- | --- | --- | --- | --- | --- | --- |
| 886 | 365 | **Further Indoor Positioning Enhancements for UTRA and LTE** | 460d? | 2016-03-15 A | 2017-12-15 | 99% | 0d? | 0d |  | R2 | 9488h | 6351.77h | UTRA_LTE_iPos_enh2 | 36 | Huawei | Rel-14 | 71 |  |
| 887 | 365.1 | Core part: Further Indoor Positioning Enhancements for UTRA and LTE | 199d? | 2016-03-15 A | 2016-12-15 A | 100% |  |  | finish no earlier than 2016-12-15 | R2 | 1592h | 1592h | UTRA_LTE_iPos_enh2-Core | 36 | Huawei | Rel-14 | 71 | RP-162506 |
| 888 | 365.2 | Perf. part: Further Indoor Positioning Enhancements for UTRA and LTE | 329d? | 2016-03-15 A | 2017-06-15 A | 100% |  |  | finish no earlier than 2017-06-15 | R4 | 2632h | 2632h | UTRA_LTE_iPos_enh2-Perf | 36 | Huawei | Rel-14 | 71 |  |
| 889 | 365.3 | UE Conformance Test Aspects - RAT Independent Further Indoor Positioning Enhancements for LTE | 198d? | 2017-03-15 A | 2017-12-15 A | 100% |  |  | finish no earlier than 2017-12-15 | R5 | 1584h | 1584h | LTE_iPos_enh2_RI-UEConTest | 38 | NextNav | Rel-14 | 75 |  |
| 890 | 366 | **Radiated performance requirements for the verification of multi-antenna reception of UEs in LTE** | 524d? | 2016-03-15 A | 2018-03-15 | 99% | 0d? | 0d |  | R4 | 10480h | 6603.52h | LTE_MIMO_OTA | 36 | Intel | Rel-14 | 71 |  |
| 891 | 366.1 | Core part: Radiated performance requirements for the verification of multi-antenna reception of UEs in LTE | 395d? | 2016-03-15 A | 2017-09-15 A | 100% |  |  | finish no earlier than 2017-09-15 | R4 | 3160h | 3160h | LTE_MIMO_OTA-Core | 36 | Intel | Rel-14 | 71 |  |
| 892 | 366.2 | UE Conformance Test Aspects - Radiated Performance of Multiple-antenna Receivers in the LTE UE | 391d? | 2016-09-15 A | 2018-03-15 A | 100% |  |  | finish no earlier than 2018-03-15 | R5 | 3128h | 3128h | LTE_MIMO_OTA-UEConTest | 37 | Intel | Rel-14 | 73 |  |
| 893 | 367 | **Enhancements on Full-Dimension (FD) MIMO for LTE** | 460d? | 2016-03-15 A | 2017-12-15 | 99% | 0d? | 0d |  | R1 | 9464h | 8374.91h | LTE_eFDMIMO | 36 | Samsung | Rel-14 | 71 |  |
| 894 | 367.1 | Core part: Enhancements on Full-Dimension (FD) MIMO for LTE | 263d? | 2016-03-15 A | 2017-03-15 A | 100% |  |  | finish no earlier than 2017-03-15 | R1 | 2104h | 2104h | LTE_eFDMIMO-Core | 36 | Samsung | Rel-14 | 71 | RP-170173 |
| 895 | 367.2 | Perf. part: Enhancements on Full-Dimension (FD) MIMO for LTE | 460d? | 2016-03-15 A | 2017-12-15 A | 100% |  |  | finish no earlier than 2017-12-15 | R4 | 3680h | 3680h | LTE_eFDMIMO-Perf | 36 | Samsung | Rel-14 | 71 |  |
| 896 | 368 | **Further mobility enhancements in LTE** | 329d? | 2016-03-15 A | 2017-06-15 A | 100% |  |  |  | R2 | 5784h | 5784h | LTE_eMob | 36 | ZTE | Rel-14 | 71 |  |
| 897 | 368.1 | Core part: Further mobility enhancements in LTE | 263d? | 2016-03-15 A | 2017-03-15 A | 100% |  |  | finish no earlier than 2017-03-15 | R2 | 2104h | 2104h | LTE_eMob-Core | 36 | ZTE | Rel-14 | 71 | RP-170369 |
| 898 | 368.2 | Perf. Part: Further mobility enhancements in LTE | 131d? | 2016-12-15 A | 2017-06-15 A | 100% |  |  | finish no earlier than 2017-06-15 | R4 | 1048h | 1048h | LTE_eMob-Perf |  | ZTE | Rel-14 |  |  |
| 899 | 369 | **Uplink Capacity Enhancements for LTE** | 720d? | 2016-03-15 A | 2018-12-15 | 74% | 188.12d? | 391d |  | R1 | 13112h | 8591.04h | LTE_UL_CAP_enh | 36 | Ericsson | Rel-14 | 71 |  |
| 900 | 369.1 | Core part: Uplink Capacity Enhancements for LTE | 263d? | 2016-03-15 A | 2017-03-15 A | 100% |  |  | finish no earlier than 2017-03-15 | R1 | 2104h | 2104h | LTE_UL_CAP_enh-Core | 36 | Ericsson | Rel-14 | 71 | RP-170115 |
| 901 | 369.2 | Perf. part: Uplink Capacity Enhancements for LTE | 395d? | 2016-03-15 A | 2017-09-15 A | 100% |  |  | finish no earlier than 2017-09-15 | R4 | 3160h | 3160h | LTE_UL_CAP_enh-Perf | 36 | Ericsson | Rel-14 | 71 |  |
| 902 | 369.3 | UE Conformance Test Aspects - Uplink capacity enhancements for LTE | 261d? | 2017-12-15 A | 2018-12-15 | 8% | 240.12d? | 391d | finish no earlier than 2018-12-15 | R5 | 2088h | 167.04h | LTE_UL_CAP_enh-UEConTest |  | Ericsson | Rel-14 | 78 |  |
| 903 | 370 | **L2 latency reduction techniques for LTE** | 524d? | 2016-03-15 A | 2018-03-15 | 99% | 0d? | 0d |  | R2 | 5784h | 2664h | LTE_LATRED_L2 | 36 | Ericsson | Rel-14 | 71 |  |
| 904 | 370.1 | Core part: L2 latency reduction techniques for LTE | 134d? | 2016-03-15 A | 2016-09-15 A | 100% |  |  | finish no earlier than 2016-09-15 | R2 | 1072h | 1072h | LTE_LATRED_L2-Core | 36 | Ericsson | Rel-14 | 71 | RP-172559 |
| 905 | 370.2 | UE Conformance Test Aspects - L2 latency reduction techniques for LTE | 65d? | 2017-12-15 A | 2018-03-15 A | 100% |  |  | finish no earlier than 2018-06-15 | R5 | 520h | 520h | LTE_LATRED_L2-UEConTest |  | Ericsson | Rel-14 | 78 |  |
| 906 | 371 | **eMBMS enhancements for LTE** | 395d? | 2016-03-15 A | 2017-09-15 | 99% | 0d? | 0d |  | R1 | 9480h | 6487.64h | MBMS_LTE_enh2 | 36 | Ericsson | Rel-14 | 71 | RP-171628 |
| 907 | 371.1 | Core part: eMBMS enhancements for LTE | 395d? | 2016-03-15 A | 2017-09-15 A | 100% |  |  | finish no earlier than 2017-09-15 | R1 | 3160h | 3160h | MBMS_LTE_enh2-Core | 36 | Ericsson | Rel-14 | 71 |  |
| 908 | 371.2 | Perf. part: eMBMS enhancements for LTE | 395d? | 2016-03-15 A | 2017-09-15 A | 100% |  |  | finish no earlier than 2017-09-15 | R4 | 3160h | 3160h | MBMS_LTE_enh2-Perf | 36 | Ericsson | Rel-14 | 71 |  |
| 909 | 372 | **SRS (sounding reference signal) switching between LTE component carriers** | 590d? | 2016-03-15 A | 2018-06-15 | 79% | 124.34d? | 521d |  | R1 | 11568h | 6610.5h | LTE_SRS_switch | 36 | Huawei | Rel-14 | 71 |  |
| 910 | 372.1 | Core part: SRS (sounding reference signal) switching between LTE component carriers | 199d? | 2016-03-15 A | 2016-12-15 A | 100% |  |  | finish no earlier than 2016-12-15 | R1 | 1592h | 1592h | LTE_SRS_switch-Core | 36 | Huawei | Rel-14 | 71 | RP-162137 |
| 911 | 372.2 | Perf. part: SRS (sounding reference signal) switching between LTE component carriers | 329d? | 2016-03-15 A | 2017-06-15 A | 100% |  |  | finish no earlier than 2017-06-15 | R4 | 2632h | 2632h | LTE_SRS_switch-Perf | 36 | Huawei | Rel-14 | 71 |  |
| 912 | 372.3 | UE Conformance Test Aspects - SRS (sounding reference signal) switching between LTE component carriers | 328d? | 2017-03-15 A | 2018-06-15 | 45% | 180.4d? | 521d | finish no earlier than 2018-06-15 | R5 | 2624h | 1180.8h | LTE_SRS_switch-UEConTest | 38 | Huawei | Rel-14 | 75 |  |

Notes:
- 886: follow-up WI of REL-13 WI UTRA_LTE_iPos_enh
- 887: follow-up WI of REL-13 WI UTRA_LTE_iPos_enh1/7/16: Compl:0%->30%; 26/9/16: Compl:30%->60%; 26/9/16: WID:; 20/12/16: Compl:60%->100%;
- 888: 26/9/16: CD:Wed 15/03/17->Thu 15/06/1726/9/16: WID: RP-160538->RP-161850; 20/12/16: Compl:0%->30%; 20/12/16: WI21/3/17: Compl:30%->50%19/6/17: Compl:50%->100%
- 889: tested: REL-14 UTRA_LTE_iPos_enh2-Core (but only RAT independent aspects for LTE);; ...; ;...; ;...
- 890: follow-up WI of REL-13 WI UTRA_LTE_MIMO_OTA-Core; no Perf. part
- 891: follow-up WI of REL-13 WI UTRA_LTE_MIMO_OTA-Core; no Perf. part1/7/16: Compl:0%->10%1/7/16: WID: RP-160603->RP-16091426/9/16: Compl:10%->15%; 20/12/16: Compl:15%->25%; 20/12/16: WID: RP-160914->RP-162306;21/3/17: Compl:25%->33%;...1...; ;...
- 892: ; 20/12/16: Compl:0%->5%21/3/17: Compl:5%->20%19/6/17: Compl:20%...; 1...; 8/1/18: C...27/3/...
- 894: ; 1/7/16: Compl:0%->25%26/9/16: Compl:25%->40%; 20/12/16: Compl:40%->80%; 20/12/16: Stat Rep: -->; 21/3/17: Compl:80%->100%; 21/3/17: Stat Rep: ->RP-170173
- 895: ; 20/12/16: Stat Rep: -->; 19/6/17: Compl:0%->50%19/9/17: Compl:50%->70%19/9/17: CD:Fri 15/09/17->Fri 15/12/17; 8/1/18: Compl:70%->100%
- 896: no Perf. part
- 897: no Perf. part; 1/7/16: Compl:0%->25%; 1/7/16: WID: RP-160636->RP-160921; 26/9/16: Compl:25%->50%; 20/12/16: Compl:50%->90%; 20/12/16: CD:Thu 15/12/16->Wed 15/03/1721/3/17: Compl:90%->100%; 21/3/17: St...
- 900: 1/7/16: Compl:0%->25%26/9/16: Compl:25%->40%; 20/12/16: Compl:40%->85%; 20/12/16: WID: RP-160664->RP-162488; 20/12/16: Stat Rep: -->21/3/17: Compl:85%->100%21/3/17: Stat Rep: ->RP-170115
- 901: ; 20/12/16: WID: RP-160664->RP-162488; 20/12/16: Stat Rep: -->;21/3/17: Compl:0%->20%19/6/17: Compl:20%->75%; 19/9/17: Compl:75%->100%
- 902: tested: REL-14 WI LTE_UL_CAP_enh-Core; related to UL 256 QAM27/3...
- 903: no Perf. part; follow-up WI of SI FS_LTE_LATRED
- 904: no Perf. part; follow-up WI of SI FS_LTE_LATRED; 1/7/16: Compl:0%->80%; 26/9/16: Compl:80%->100%8/1/18: Stat Rep: -->RP-172559
- 905: tested: REL-14 WI LTE_LATRED_L2-Core27/3/18: Compl:0%->100%; ;...
- 907: 1/7/16: Compl:0%->10%1/7/16: CD:Tue 15/03/16->Wed 15/03/171/7/16: WID: RP-160675->RP-16129726/9/16: Compl:10%->55%; 20/12/16: Compl:55%->80%; 20/12/16: WID: RP-161297->RP-162231 ; 21/3/17: Compl:80%->90% ;...; 19/6/17: Compl:90...; ;...
- 908: ; 1/7/16: CD:Wed 15/06/16->Fri 15/09/17; 1/7/16: WID: RP-160675->RP-161297; 20/12/16: WID: RP-161297->RP-162231; 20/12/16: Stat Rep: --> ; 21/3/17: WID: RP-162231->RP-17019919/6/17: Compl:0%->70%; 19/9/17: Compl:70%->100%
- 910: 1/7/16: Compl:0%->35%1/7/16: WID: RP-160676->RP-160935; 26/9/16: Compl:35%->55%; 20/12/16: Compl:55%->100%; 20/12/16: Stat Rep: -->RP-162137
- 911: 1/7/16: WID: RP-160676->RP-160935; 20/12/16: Stat Rep: --> 21/3/17: Compl:0%->25% 21/3/17: CD:Wed 15/03/17->Thu 15/06/17; 19/6/17: Compl:25%->100%
- 912: tested: REL-14 LTE_SRS_switch-Core;; 19/6/17: Compl:0%->5%; 8/1/18: Compl:...27/3/...

| ID | WBS | Task | Duration | Start | Finish | Complete | Remaining | Total slack | Constraint | Resources | Work | Actual work | Acronym | PCG approved | WI rapporteur name | Release | TSG approved | Status Report | WI rapporteur e-mail |
| --- | --- | --- | --- | --- | --- | --- | --- | --- | --- | --- | --- | --- | --- | --- | --- | --- | --- | --- | --- |
| 913 | 373 | **Downlink Multiuser Superposition Transmission for LTE** | 329d? | 2016-03-15 A | 2017-06-15 A | 100% |  |  |  | R1 | 6856h | 6856h | LTE_MUST | 36 | MediaTek | Rel-14 | 71 |  |  |
| 914 | 373.1 | Core part: Downlink Multiuser Superposition Transmission for LTE | 199d? | 2016-03-15 A | 2016-12-15 A | 100% |  |  | finish no earlier than 2016-12-15 | R1 | 1592h | 1592h | LTE_MUST-Core | 36 | MediaTek | Rel-14 | 71 | RP-162504 |  |
| 915 | 373.2 | Perf. part: Downlink Multiuser Superposition Transmission for LTE | 329d? | 2016-03-15 A | 2017-06-15 A | 100% |  |  | finish no earlier than 2017-06-15 | R4 | 2632h | 2632h | LTE_MUST-Perf | 36 | MediaTek | Rel-14 | 71 |  |  |
| 916 | 374 | **IMS Stage-3 IETF Protocol Alignment** | 198d? | 2016-06-14 A | 2017-03-15 A | 100% |  |  |  | C1 | 6336h | 6336h | IMSProtoc8 | 37 |  | Rel-14 | 72 |  |  |
| 917 | 374.1 | CT1 aspects of IMS Stage-3 IETF Protocol Alignment | 198d? | 2016-06-14 A | 2017-03-15 A | 100% |  |  | finish no earlier than 2017-03-15 | C1 | 1584h | 1584h | IMSProtoc8 | 37 | Alcatel-Lucent | Rel-14 | 72 |  | Keith Drage |
| 918 | 374.2 | (IETF) CT1 aspects of IMS Stage-3 IETF Protocol Alignment | 198d? | 2016-06-14 A | 2017-03-15 A | 100% |  |  | start no earlier than 2016-06-14 | C1-IETF | 1584h | 1584h | IMSProtoc8 | 37 | Alcatel-Lucent | Rel-14 | 72 |  | Keith Drage |
| 919 | 374.3 | CT3 aspects of IMS Stage-3 IETF Protocol Alignment | 198d? | 2016-06-14 A | 2017-03-15 A | 100% |  |  | start no earlier than 2016-06-14 | C3 | 1584h | 1584h | IMSProtoc8 | 37 | Alcatel-Lucent | Rel-14 | 72 |  | Keith Drage |
| 920 | 375 | **Multi-Carrier Enhancements for UMTS** | 264d? | 2015-12-15 A | 2016-12-15 A | 100% |  |  |  | R2 | 4232h | 4232h | UTRA_MCe | 37 | Huawei, HiSilicon | Rel-14 | 72 |  |  |
| 921 | 375.1 | Study on Multi-Carrier Enhancements for UMTS | 132d? | 2015-12-15 A | 2016-06-15 A | 100% |  |  | finish no earlier than 2016-06-15 | R1 | 1056h | 1056h | FS_UTRA_MCe | 36 | Huawei | Rel-14 | 70 |  |  |
| 922 | 375.2 | Core part: Multi-Carrier Enhancements for UMTS | 133d? | 2016-06-15 A | 2016-12-15 A | 100% |  |  | finish no earlier than 2016-12-15 | R2 | 1064h | 1064h | UTRA_MCe-Core | 37 | Huawei, HiSilicon | Rel-14 | 72 | RP-162129 |  |
| 923 | 376 | **Citizens Broadband Radio Service (CBRS) 3.5GHz band for LTE in the United States** | 263d? | 2016-06-15 A | 2017-06-15 A | 100% |  |  |  | R4 | 5280h | 5280h | LTE_TDD_3550_CBRS_US | 37 | Nokia | Rel-14 | 72 |  |  |
| 924 | 376.1 | Core part: Citizens Broadband Radio Service (CBRS) 3.5GHz band for LTE in the United States | 133d? | 2016-06-15 A | 2016-12-15 A | 100% |  |  | finish no earlier than 2016-12-15 | R4 | 1064h | 1064h | LTE_TDD_3550_CBRS_US-Core | 37 | Nokia | Rel-14 | 72 |  |  |
| 925 | 376.2 | Perf. part: Citizens Broadband Radio Service (CBRS) 3.5GHz band for LTE in the United States | 133d? | 2016-06-15 A | 2016-12-15 A | 100% |  |  | finish no earlier than 2016-12-15 | R4 | 1064h | 1064h | LTE_TDD_3550_CBRS_US-Perf | 37 | Nokia | Rel-14 | 72 |  |  |
| 926 | 376.3 | UE Conformance Test Aspects – Citizens Broadband Radio Service (CBRS) 3.5GHz Band for LTE in the United States (Band 48) | 131d? | 2016-12-15 A | 2017-06-15 A | 100% |  |  | finish no earlier than 2017-06-15 | R5 | 1048h | 1048h | LTE_TDD_3550_CBRS_US-UEConTest | 38 | Nokia | Rel-14 | 74 |  |  |
| 927 | 377 | **LTE Band 41 UE power class 2 operation** | 197d? | 2016-06-15 A | 2017-03-15 A | 100% |  |  |  | R4 | 4744h | 4744h | LTE_B41_UE_PC2 | 37 | Sprint | Rel-14 | 72 |  |  |
| 928 | 377.1 | Core part: LTE Band 41 UE power class 2 operation | 133d? | 2016-06-15 A | 2016-12-15 A | 100% |  |  | finish no earlier than 2016-12-15 | R4 | 1064h | 1064h | LTE_B41_UE_PC2-Core | 37 | Sprint | Rel-14 | 72 |  |  |
| 929 | 377.2 | Perf. part: LTE Band 41 UE power class 2 operation | 133d? | 2016-06-15 A | 2016-12-15 A | 100% |  |  | finish no earlier than 2016-12-15 | R4 | 1064h | 1064h | LTE_B41_UE_PC2-Perf | 37 | Sprint | Rel-14 | 72 |  |  |
| 930 | 377.3 | UE Conformance Test Aspects – LTE Band 41 UE power class 2 operation | 130d? | 2016-09-15 A | 2017-03-15 A | 100% |  |  | finish no earlier than 2017-03-15 | R5 | 1040h | 1040h | LTE_B41_UE_PC2-UEConTest | 37 | Sprint | Rel-14 | 73 |  |  |
| 931 | 378 | **Dedicated Core Networks for GERAN** | 68d? | 2016-06-15 A | 2016-09-15 A | 100% |  |  |  | R6 | 1088h | 1088h | DECOR_GERAN | 37 | Ericsson | Rel-14 | 72 |  |  |
| 932 | 378.1 | Core part: Dedicated Core Networks for GERAN | 68d? | 2016-06-15 A | 2016-09-15 A | 100% |  |  | finish no earlier than 2016-12-15 | R6 | 544h | 544h | DECOR_GERAN-Core | 37 | Ericsson | Rel-14 | 72 | RP-170194 |  |
| 933 | 379 | **Positioning Enhancements for GERAN** | 263d? | 2016-06-15 A | 2017-06-15 A | 100% |  |  |  | R6 | 6312h | 6312h | ePOS_GERAN | 37 | Ericsson | Rel-14 | 72 |  |  |
| 934 | 379.1 | Core part: Positioning Enhancements for GERAN | 263d? | 2016-06-15 A | 2017-06-15 A | 100% |  |  | finish no earlier than 2017-06-15 | R6 | 2104h | 2104h | ePOS_GERAN-Core | 37 | Ericsson | Rel-14 | 72 | RP-170920 |  |
| 935 | 379.2 | Perf. part: Positioning Enhancements for GERAN | 263d? | 2016-06-15 A | 2017-06-15 A | 100% |  |  | finish no earlier than 2017-06-15 | R6 | 2104h | 2104h | ePOS_GERAN-Perf | 37 | Ericsson | Rel-14 | 72 |  |  |
| 936 | 380 | **Quality of Experience (QoE) Measurement Collection for streaming services in UTRAN** | 858d? | 2014-12-03 A | 2018-03-15 | 99% | 0d? | 0d |  | R2 | 12664h | 10576h | UMTS_QMC_Streaming | 37 | China Unicom | Rel-14 | 73 |  |  |
| 937 | 380.1 | Study on KQIs for Service Experience | 333d? | 2014-12-03 A | 2016-03-11 A | 100% |  |  | finish no earlier than 2016-03-11 | S5 | 2664h | 2664h | FS_KQISE | 34 | Li, Hui (hui.li(at)huawei.com) | Rel-14 | 66 |  | hui.li(at)huawei.com |
| 938 | 380.2 | Core part:Quality of Experience (QoE) Measurement Collection for streaming services in UTRAN | 130d? | 2016-09-15 A | 2017-03-15 A | 100% |  |  | finish no earlier than 2017-03-15 | R2 | 1040h | 1040h | UMTS_QMC_Streaming-Core | 37 | China Unicom | Rel-14 | 73 | RP-170259 |  |
| 939 | 380.3 | UE Conformance Test Aspects -Quality of Experience (QoE) Measurement Collection for streaming services in UTRAN | 262d? | 2017-03-15 A | 2018-03-15 A | 100% |  |  | finish no earlier than 2018-03-15 | R5 | 2096h | 2096h | UMTS_QMC_Streaming-UEConTest | 38 | Huawei | Rel-14 | 75 |  |  |

Notes:
- 914: ; 1/7/16: Compl:0%->40%; 1/7/16: WID: RP-160680->RP-16101926/9/16: Compl:40%->60%; 20/12/16: Compl:60%->100%; 20/12/16: Stat Rep: -->RP-162504
- 915: 1/7/16: WID: RP-160680->RP-161019; 26/9/16: CD:Fri 15/09/17->Thu 15/06/17; 20/12/16: Stat Rep: --> ; 21/3/17: Compl:0%->25%19/6/17: Compl:25%->100%
- 916: 11/6/16: 0%->15; 5/6/17: 67%->100
- 917: Mar.15: 0->10%; June2015: Compl:10%->30; 07/09/15: 30%->70; 7/12/15: 70%->100; 16/9/16: 0%->30; 2/12/16: 30%->75; 6/3/17: 75%->100
- 918: Impacted TSs and TRs: draft-ietf-mmusic-dtls-sdp, draft-ietf-mmusic-4572-update (became RFC 8122)
- 919: 2/4/15: added, following CT3 chair's info that the WID also has a CT3 part; June2015: Compl:0%->20; 07/09/15: 20%->40; 7/12/15: 40%->100; 20/9/16: 0%->10; 2/12/16: 10%->30; 6/3/17: 30%->100
- 920: no Perf. part; follow-up WI of REL-14 SI FS_UTRA_MCe
- 921: 22/3/16: Compl:0%->20%; 1/7/16: Compl:20%->100%; 28/7/16: 25.707 added; / Impacted TSs and TRs: 25.707
- 922: no Perf. part; follow-up WI of REL-14 SI FS_UTRA_MCe; 26/9/16: Compl:0%->35%; 20/12/16: Compl:35%->100%;
- 924: 26/9/16: Compl:0%->70%; 6/10/16: 36.744 added; 20/12/16: Compl:70%->100%; / Impacted TSs and TRs: 36.744
- 925: ; 20/12/16: Compl:0%->100%;
- 926: 21/3/17: Compl:0%->60% ; ...; 19/6/17: Compl:60%->100%
- 927: follow-up WI of SI FS_LTE_B41_HPUE
- 928: follow-up WI of SI FS_LTE_B41_HPUE; 26/9/16: Compl:0%->80%; 20/12/16: Compl:80%->100%
- 929: 26/9/16: Compl:0%->80%; 20/12/16: Compl:80%->100%
- 930: ; 20/12/16: Compl:0%->65% 21/3/17: Compl:65%->100%
- 931: no Perf. part; DECOR was a REL-13 SA2 feature
- 932: no Perf. part; DECOR was a REL-13 SA2 feature; 26/9/16: Compl:0%->100%21/3/17: Stat Rep: ->RP-170194
- 934: 26/9/16: Compl:0%->30%; 20/12/16: Compl:30%->50% 21/3/17: Compl:50%->80% ; ...19/6/17: Compl:80%->100%;...
- 935: ; 20/12/16: Compl:0%->50% ; 21/3/17: Compl:50%->80%;...; 19/6/17: Compl:80%->100%; ...
- 937: Mar 15: 0->5%; June2015: Compl:0%->40; 07/09/15: 40%->50; 14/09/15: WID:SP-140784->SP-150405; 7/12/15: 50%->75; 7/12/15: WID:SP-150405->SP-150676 ; 7/3/16: 75%->100. 22/3/16: FCD: 09/15->03/16. Rel-13->Rel-14 / Impacted TSs and TRs: TR 32.8xy
- 938: ; 20/12/16: Compl:0%->60% ; 21/3/17: Compl:60%->100%...
- 939: tested: REL-14 UMTS_QMC_Streaming-Core;19/6/17: Comp...; 19/...; 8/1/18:...; 27/3/...

| ID | WBS | Task | Duration | Start | Finish | Complete | Remaining | Total slack | Constraint | Resources | Work | Actual work | Acronym | PCG approved | WI rapporteur name | Release | TSG approved | Impacted TSs and TRs | Status Report |
| --- | --- | --- | --- | --- | --- | --- | --- | --- | --- | --- | --- | --- | --- | --- | --- | --- | --- | --- | --- |
| 940 | 381 | **Flexible eNB-ID and Cell-ID in E-UTRAN** | 263d? | 2016-03-15 A | 2017-03-15 A | 100% |  |  |  | R3 | 4216h | 4216h | LTE_FNBID | 37 | China Telecom | Rel-14 | 73 |  |  |
| 941 | 381.1 | Study on flexible eNB-ID and Cell-ID in E-UTRAN | 134d? | 2016-03-15 A | 2016-09-15 A | 100% |  |  | finish no earlier than 2016-09-15 | R3 | 1072h | 1072h | FS_LTE_FNBID | 36 | China Telecom | Rel-14 | 71 | New TR 36.896 |  |
| 942 | 381.2 | Core part: Flexible eNB-ID and Cell-ID in E-UTRAN | 130d? | 2016-09-15 A | 2017-03-15 A | 100% |  |  | finish no earlier than 2017-03-15 | R3 | 1040h | 1040h | LTE_FNBID-Core | 37 | China Telecom | Rel-14 | 73 |  | RP-170478 |
| 943 | 382 | **4 receiver (4Rx) antenna ports with Carrier Aggregation (CA) for LTE downlink (DL)** | 457d? | 2016-09-15 A | 2018-06-15 | 87% | 57.14d? | 521d |  | R4 | 13088h | 7606.15h | LTE_4Rx_AP_DL_CA | 37 | Ericsson | Rel-14 | 73 |  |  |
| 944 | 382.1 | Core part: 4 receiver (RX) antenna ports with Carrier Aggregation (CA) for LTE downlink (DL) | 66d? | 2016-09-15 A | 2016-12-15 A | 100% |  |  | finish no earlier than 2016-12-15 | R4 | 528h | 528h | LTE_4Rx_AP_DL_CA-Core | 37 | Ericsson | Rel-14 | 73 |  | RP-162059 |
| 945 | 382.2 | Perf. part: 4 receiver (RX) antenna ports with Carrier Aggregation (CA) for LTE downlink (DL) | 262d? | 2016-09-15 A | 2017-09-15 A | 100% |  |  | finish no earlier than 2017-09-15 | R4 | 2096h | 2096h | LTE_4Rx_AP_DL_CA-Perf | 37 | Ericsson | Rel-14 | 73 |  |  |
| 946 | 382.3 | **Introduction of new band support for 4Rx antenna ports for LTE** | 392d? | 2016-12-15 A | 2018-06-15 | 79% | 84.04d? | 521d |  | R4 | 6808h | 3723.27h | LTE_4Rx_AP_DL_bands | 38 | Huawei | Rel-14 | 74 |  |  |
| 947 | 382.3.1 | Core part: Introduction of new band support for 4Rx antenna ports for LTE | 131d? | 2016-12-15 A | 2017-06-15 A | 100% |  |  | finish no earlier than 2017-06-15 | R4 | 1048h | 1048h | LTE_4Rx_AP_DL_bands-Core | 38 | Huawei | Rel-14 | 74 |  |  |
| 948 | 382.3.2 | UE Conformance Test Aspects - 4 Rx antenna ports with CA for LTE DL | 328d? | 2017-03-15 A | 2018-06-15 | 70% | 98.4d? | 521d | finish no earlier than 2018-06-15 | R5 | 2624h | 1836.8h | LTE_4Rx_AP_DL_CA-UEConTest | 38 | Ericsson | Rel-14 | 75 |  |  |
| 949 | 383 | **Requirements for a new UE category with single receiver based on Category 1 for LTE** | 457d? | 2016-09-15 A | 2018-06-15 | 89% | 49.88d? | 521d |  | R4 | 9416h | 5757.42h | LTE_UE_cat_1RX | 37 | Qualcomm | Rel-14 | 73 |  |  |
| 950 | 383.1 | Core part: Requirements for a new UE category with single receiver based on Category 1 for LTE | 196d? | 2016-09-15 A | 2017-06-15 A | 100% |  |  | finish no earlier than 2017-06-15 | R4 | 1568h | 1568h | LTE_UE_cat_1RX-Core | 37 | Qualcomm | Rel-14 | 73 |  | RP-171317 |
| 951 | 383.2 | Perf. part: Requirements for a new UE category with single receiver based on Category 1 for LTE | 262d? | 2016-09-15 A | 2017-09-15 A | 100% |  |  | finish no earlier than 2017-09-15 | R4 | 2096h | 2096h | LTE_UE_cat_1RX-Perf | 37 | Qualcomm | Rel-14 | 73 |  |  |
| 952 | 383.3 | UE Conformance Test Aspects – Requirements for a new UE category 1bis with single receiver based on category 1 for LTE | 262d? | 2017-06-15 A | 2018-06-15 | 70% | 78.6d? | 521d | finish no earlier than 2018-06-15 | R5 | 2096h | 1467.2h | LTE_UE_cat_1RX-UEConTest | 39 | Qualcomm | Rel-14 | 76 |  |  |
| 953 | 384 | **Enhanced LTE WLAN Radio Level Integration with IPsec Tunnel (eLWIP)** | 130d? | 2016-09-15 A | 2017-03-15 A | 100% |  |  |  | R3 | 2080h | 2080h | LTE_WLAN_eLWIP | 37 | Nokia | Rel-14 | 73 |  |  |
| 954 | 384.1 | Core part: Enhanced LTE WLAN Radio Level Integration with IPsec Tunnel (eLWIP) | 130d? | 2016-09-15 A | 2017-03-15 A | 100% |  |  | finish no earlier than 2017-03-15 | R3 | 1040h | 1040h | LTE_WLAN_eLWIP-Core | 37 | Nokia | Rel-14 | 73 |  | RP-170706 |
| 955 | 385 | **LTE Measurement Gap Enhancement** | 329d? | 2016-03-15 A | 2017-06-15 A | 100% |  |  |  |  | 5264h | 5264h | LTE_meas_gap_enh | 36 | Intel | Rel-14 | 71 |  |  |
| 956 | 385.1 | Core part: LTE Measurement Gap Enhancement | 329d? | 2016-03-15 A | 2017-06-15 A | 100% |  |  | finish no earlier than 2017-06-15 | R4 | 2632h | 2632h | LTE_meas_gap_enh-Core | 36 | Intel | Rel-14 | 71 |  | RP-171330 |
| 957 | 385.2 | Perf. part: LTE Measurement Gap Enhancement | 329d? | 2016-03-15 A | 2017-06-15 A | 100% |  |  | finish no earlier than 2017-06-15 | R4 | 2632h | 2632h | LTE_meas_gap_enh-Perf | 36 | Intel | Rel-14 | 71 |  |  |
| 958 | 386 | **Enhanced CRS and SU-MIMO Interference Mitigation Performance Requirements for LTE** | 262d? | 2016-09-15 A | 2017-09-15 A | 100% |  |  |  |  | 2096h | 2096h | LTE_eCRSIM_eSUMIMO | 37 | Intel | Rel-14 | 73 | 39.747 |  |
| 959 | 386.1 | Perf. part: Enhanced CRS and SU-MIMO Interference Mitigation Performance Requirements for LTE | 262d? | 2016-09-15 A | 2017-09-15 A | 100% |  |  | finish no earlier than 2017-09-15 | R4 | 2096h | 2096h | LTE_eCRSIM_eSUMIMO-Perf | 37 | Intel | Rel-14 | 73 | 36.176 |  |
| 960 | 387 | **Miscellaneous IETF dependencies** | 197d? | 2017-03-15 A | 2017-12-14 | 72% | 55.23d? | 652d |  |  | 4216h | 3034h | TEI14_IETF |  |  | Rel-14 | 78 |  |  |
| 961 | 387.1 | (IETF) SDP Offer/Answer Clarifications for RTP/RTCP Multiplexing [RFC 5761 (was draft-ietf-avtcore-5761-update)] | 133d? | 2017-03-15 A | 2017-09-15 A | 100% |  |  | finish no earlier than 2017-09-15 | CT1-IETF | 1064h | 1064h | TEI14_IETF |  |  | Rel-14 | 78 |  |  |
| 962 | 387.2 | (IETF) T.140 Text Conversation over Data Channels (draft-schwarz-mmusic-t140-usage-data-channel) | 197d? | 2017-03-15 A | 2017-12-14 | 25% | 147.75d? | 652d | finish no earlier than 2017-12-14 | CT1-IETF | 1576h | 394h | TEI14_IETF |  |  | Rel-14 | 78 |  |  |
| 963 | 387.3 | (IETF) BFCP floor control signalling over Data Channels (draft-schwarz-mmusic-bfcp-usage-data-channel) | 197d? | 2017-03-15 A | 2017-12-14 A | 100% |  |  | finish no earlier than 2017-12-14 | CT1-IETF | 1576h | 1576h | TEI14_IETF |  |  | Rel-14 | 78 |  |  |

Notes:
- 941: 1/7/16: Compl:0%->60%26/9/16: Compl:60%->100%
- 942: ; 20/12/16: Compl:0%->80%21/3/17: Compl:80%->100%21/3/17: Stat Rep: ->RP-170478
- 944: ; 20/12/16: Compl:0%->100%; 20/12/16: Stat Rep: ->RP-162059
- 945: ; 20/12/16: Compl:0%->30%;21/3/17: Compl:30%->50%19/6/17: Compl:50%->90%; 19/9/17: Compl:90%->100%
- 946: Pending acronym
- 947: ; 21/3/17: Compl:0%->80% ; 21...19/6/17: Compl:80%->100%
- 948: tested: REL-14 LTE_4Rx_AP_DL_CA-Core; 19/6/17: C...; 1...; 8/1/18: C...; 27/3/...
- 950: ; 20/12/16: Compl:0%->70%; 20/12/16: CD:Thu 15/12/16->Wed 15/03/17 ; 21/3/17: Compl:70%->95% 21/3/17: CD:Wed 15/03/17->Thu 15/06/1...; 19/6/17: Compl:95%->100%;...
- 951: ; 20/12/16: Compl:0%->20%; 20/12/16: CD:Thu 15/06/17->Fri 15/09/17 21/3/17: Compl:20%->70% ; 21/3/17: WID: RP-162570->RP-17079119/6/17: Compl:70%->100%;...
- 952: ; 19/9/17: Compl:0%->5%; 8/1/18: Compl:5%->45%27/3/18: Compl:45%->70%; ;...
- 954: ; 20/12/16: Compl:0%->60% 21/3/17: Compl:60%->100% 21/3/17: Stat Rep: ->RP-170706
- 956: ; 1/7/16: Compl:0%->10%; 1/7/16: CD:Thu 15/06/17->Wed 15/03/17; 1/7/16: WID: RP-160678->RP-160912; 26/9/16: Compl:10%->25%26/9/16: R; 20/12/16: Compl:25%->60% 21/3/17: Compl:60%->95%...; 19/6/17: Compl:95%->100%...
- 957: 1/7/16: WID: RP-160678->RP-1609121/7/16: Release: Rel-15->Rel-14; 20/12/16: Stat Rep: -->; 20/12/16: Release: Rel-15->Rel-14 21/3/17: Compl:0%->20% 21/3/17: Release: Rel...19/6/17: Compl:20%->100%
- 959: 6/10/16: 36.176 added; 20/12/16: Compl:0%->30%21/3/17: Compl:30%->50% ; 21/3/17: Release: Rel-15->Rel-14; 19/6/17: Compl:50%->85%19/9/17: Compl:85%->100%
- 960: Created upon demand of RAN5
- 963: 22/3/18: 25%->100

| ID | WBS | Task | Duration | Start | Finish | Complete | Remaining | Baseline start | Baseline finish | Baseline duration | Total slack | Constraint | Resources | Work | Actual work | Acronym | PCG approved | Impacted TSs and TRs | WI rapporteur name | WI rapporteur e-mail | Release | TSG approved | MCC resp | Acronym_3GU_Export | Special Focus Doc |
| --- | --- | --- | --- | --- | --- | --- | --- | --- | --- | --- | --- | --- | --- | --- | --- | --- | --- | --- | --- | --- | --- | --- | --- | --- | --- |
| 964 | 388 | **Security Assurance Specification for 3GPP network products** | 924d? | 2013-12-09 A | 2017-06-15 A | 100% |  | 2013-12-09 | 2015-03-18 | 334d? |  |  | S3 | 23192h | 23192h | SCAS | 32 | 33.199; 33.926, 33.117; 33.250 | NTT DOCOMO | Alf Zugenmaier (alf.zugenmaier@hm.edu) | Rel-14 | 62 | Mirko | SCAS |  |
| 965 | 388.1 | STOPPED - TR on Pilot development of Security Assurance Specification for MME network product class | 266d? | 2013-12-09 A | 2014-12-12 A | 100% |  | 2013-12-09 | 2014-12-10 | 264d? |  | finish no earlier than 2014-12-12 | S3 | 2120h | 2120h | SCAS-SA3Pil_TR | 32 | New TR 33.806 | NTT DOCOMO | Alf Zugenmaier (alf.zugenmaier@hm.edu) | Rel-14 | 62 | Mirko |  |  |
| 966 | 388.2 | TR on Security Assurance scheme for 3GPP network products | 791d? | 2013-12-09 A | 2016-12-15 A | 100% |  | 2013-12-09 | 2014-12-10 | 264d? |  | finish no earlier than 2016-12-15 | S3 | 6320h | 6320h | SCAS-SA3TR | 32 | New TR 33.916; 33.216 | NTT DOCOMO | Alf Zugenmaier (alf.zugenmaier@hm.edu) | Rel-14 | 62 | Mirko |  |  |
| 967 | 388.3 | Security Assurance Specification for 3GPP network product classes | 920d? | 2013-12-13 A | 2017-06-15 A | 100% |  | 2013-12-10 | 2015-03-18 | 333d? |  | finish no earlier than 2017-06-15 | S3 | 7360h | 7360h | SCAS-SA3 | 32 | New TS 33.116, 33.117; 33.250 | China Mobile | Judy Zhu (zhuhongru@chinamobile.com) | Rel-14 | 62 | Mirko |  |  |
| 968 | 389 | (Small) Technical Enhancements and Improvements for Rel-14 | 29d? | 2015-05-11 A | 2015-06-18 A | 100% |  |  |  |  |  | start no earlier than 2015-05-11 | SP; CP; RP; R4 | 928h | 928h | TEI14 | 35 |  |  |  | Rel-14 | 68 |  |  |  |
| 969 | 390 | (Small) Test Technical Enhancements and Improvements for Rel-14 | 593d? | 2016-09-13 A | 2018-12-20 A | 100% |  |  |  |  |  | start no earlier than 2016-09-13 | SP; CP; RP; GP | 18976h | 18976h | TEI14_Test |  |  |  |  | Rel-14 |  |  |  |  |
| 970 | 391 | **Rel-14 LTE Carrier Aggregation** | 131d? | 2015-09-15 A | 2016-03-15 | 90% | 13.09d? | 2014-03-06 | 2015-06-12 | 332d? | 1110d |  | R4 | 9968h | 8897.13h | LTE_CA_Rel14 | 30 |  |  |  | Rel-14 | 58 | Issam | LTE_CA_Rel-13 | CA |
| 971 | 391.1 | **LTE Advanced 4 Band Carrier Aggregation (4DL/1UL) of Band 4, Band 5, Band 12 and Band 12** | 131d? | 2015-09-15 A | 2016-03-15 | 90% | 13.09d? |  |  |  | 1110d |  | R4 | 3144h | 2829.72h | LTE_CA_B4_B5_B12_B12 | PCG-35 |  | US Cellular |  | Rel-14 | RP-69 |  |  |  |
| 972 | 391.1.1 | Core part: LTE Advanced 4 Band Carrier Aggregation (4DL/1UL) of Band 4, Band 5, Band 12 and Band 12 | 131d? | 2015-09-15 A | 2016-03-15 | 90% | 13.1d? |  |  |  | 1110d | finish no earlier than 2016-03-15 | R4 | 1048h | 943.2h | LTE_CA_B4_B5_B12_B12-Core | PCG-35 |  | US Cellular |  | Rel-14 | RP-69 |  |  |  |
| 973 | 391.1.2 | Perf. part: LTE Advanced 4 Band Carrier Aggregation (4DL/1UL) of Band 4, Band 5, Band 12 and Band 12 | 131d? | 2015-09-15 A | 2016-03-15 | 90% | 13.1d? |  |  |  | 1110d | finish no earlier than 2016-03-15 | R4 | 1048h | 943.2h | LTE_CA_B4_B5_B12_B12-Perf | PCG-35 |  | US Cellular |  | Rel-14 | RP-69 |  |  |  |
| 974 | 391.2 | **LTE Advanced 4 Band Carrier Aggregation (4DL/1UL) of Band 4, Band 4, Band 12 and Band 12** | 131d? | 2015-09-15 A | 2016-03-15 | 90% | 13.09d? |  |  |  | 1110d |  | R4 | 3144h | 2829.72h | LTE_CA_B4_B4_B12_B12 | PCG-35 |  | US Cellular |  | Rel-14 | RP-69 |  |  |  |
| 975 | 391.2.1 | Core part: LTE Advanced 4 Band Carrier Aggregation (4DL/1UL) of Band 4, Band 4, Band 12 and Band 12 | 131d? | 2015-09-15 A | 2016-03-15 | 90% | 13.1d? |  |  |  | 1110d | finish no earlier than 2016-03-15 | R4 | 1048h | 943.2h | LTE_CA_B4_B4_B12_B12-Core | PCG-35 |  | US Cellular |  | Rel-14 | RP-69 |  |  |  |
| 976 | 391.2.2 | Perf. part: LTE Advanced 4 Band Carrier Aggregation (4DL/1UL) of Band 4, Band 4, Band 12 and Band 12 | 131d? | 2015-09-15 A | 2016-03-15 | 90% | 13.1d? |  |  |  | 1110d | finish no earlier than 2016-03-15 | R4 | 1048h | 943.2h | LTE_CA_B4_B4_B12_B12-Perf | PCG-35 |  | US Cellular |  | Rel-14 | RP-69 |  |  |  |
| 977 | 391.3 | **LTE Advanced 4 Band Carrier Aggregation (4DL/1UL) of Band 2, Band 4, Band 12 and Band 12** | 131d? | 2015-09-15 A | 2016-03-15 | 90% | 13.09d? |  |  |  | 1110d |  | R4 | 3144h | 2829.72h | LTE_CA_B2_B4_B12_B12 | PCG-35 |  | US Cellular |  | Rel-14 | RP-69 |  |  |  |
| 978 | 391.3.1 | Core part: LTE Advanced 4 Band Carrier Aggregation (4DL/1UL) of Band 2, Band 4, Band 12 and Band 12 | 131d? | 2015-09-15 A | 2016-03-15 | 90% | 13.1d? |  |  |  | 1110d | finish no earlier than 2016-03-15 | R4 | 1048h | 943.2h | LTE_CA_B2_B4_B12_B12-Core | PCG-35 |  | US Cellular |  | Rel-14 | RP-69 |  |  |  |
| 979 | 391.3.2 | Perf. part: LTE Advanced 4 Band Carrier Aggregation (4DL/1UL) of Band 2, Band 4, Band 12 and Band 12 | 131d? | 2015-09-15 A | 2016-03-15 | 90% | 13.1d? |  |  |  | 1110d | finish no earlier than 2016-03-15 | R4 | 1048h | 943.2h | LTE_CA_B2_B4_B12_B12-Perf | PCG-35 |  | US Cellular |  | Rel-14 | RP-69 |  |  |  |
| 980 | 392 | **Rel-14LTE Advanced inter-band Carrier Aggregation** | 785d? | 2015-12-15 A | 2018-12-15 | 78% | 170.11d? | 2014-03-06 | 2015-06-12 | 332d? | 391d |  | R4 | 85064h | 60382.4h | LTE_AIBCA_Rel14 | 30 |  |  |  | Rel-14 | 58 | Issam | LTE_CA_Rel-13 | CA |
| 981 | 392.1 | **LTE Advanced inter-band Carrier Aggregation Rel-14 for 5DL/1UL** | 394d? | 2015-12-15 A | 2017-06-15 | 95% | 19.69d? |  |  |  | 782d |  | R4 | 9456h | 8416.04h | LTE_CA_R14_5DL1UL | PCG-36 |  | Nokia Networks |  | Rel-14 | RP-70 |  |  |  |
| 982 | 392.1.1 | Core part: LTE Advanced inter-band Carrier Aggregation Rel-14 for 5DL/1UL | 394d? | 2015-12-15 A | 2017-06-15 | 95% | 19.7d? |  |  |  | 782d | finish no earlier than 2017-06-15 | R4 | 3152h | 2994.4h | LTE_CA_R14_5DL1UL-Core | PCG-36 | 36.714-05-01 | Nokia Networks |  | Rel-14 | RP-70 |  |  |  |
| 983 | 392.1.2 | Perf. part: LTE Advanced inter-band Carrier Aggregation Rel-14 for 5DL/1UL | 394d? | 2015-12-15 A | 2017-06-15 | 95% | 19.7d? |  |  |  | 782d | finish no earlier than 2017-06-15 | R4 | 3152h | 2994.4h | LTE_CA_R14_5DL1UL-Perf | PCG-36 |  | Nokia Networks |  | Rel-14 | RP-70 |  |  |  |
| 984 | 392.2 | **LTE Advanced inter-band Carrier Aggregation Rel-14 for 2DL/1UL** | 394d? | 2015-12-15 A | 2017-06-15 | 80% | 78.8d? |  |  |  | 782d |  | R4 | 9456h | 7076.85h | LTE_CA_R14_2DL1UL | PCG-36 |  | Qualcomm |  | Rel-14 | RP-70 |  |  |  |
| 985 | 392.2.1 | Core part: LTE Advanced inter-band Carrier Aggregation Rel-14 for 2DL/1UL | 394d? | 2015-12-15 A | 2017-06-15 | 80% | 78.8d? |  |  |  | 782d | finish no earlier than 2017-06-15 | R4 | 3152h | 2521.6h | LTE_CA_R14_2DL1UL-Core | PCG-36 | 36.714-02-01 | Qualcomm |  | Rel-14 | RP-70 |  |  |  |
| 986 | 392.2.2 | Perf. part: LTE Advanced inter-band Carrier Aggregation Rel-14 for 2DL/1UL | 394d? | 2015-12-15 A | 2017-06-15 | 80% | 78.8d? |  |  |  | 782d | finish no earlier than 2017-06-15 | R4 | 3152h | 2521.6h | LTE_CA_R14_2DL1UL-Perf | PCG-36 |  | Qualcomm |  | Rel-14 | RP-70 |  |  |  |
| 987 | 392.3 | **LTE Advanced inter-band Carrier Aggregation Rel-14 for 2DL/2UL** | 394d? | 2015-12-15 A | 2017-06-15 | 90% | 39.4d? |  |  |  | 782d |  | R4 | 9456h | 7904.07h | LTE_CA_R14_2DL2UL | PCG-36 |  | Huawei |  | Rel-14 | RP-70 |  |  |  |
| 988 | 392.3.1 | Core part: LTE Advanced inter-band Carrier Aggregation Rel-14 for 2DL/2UL | 394d? | 2015-12-15 A | 2017-06-15 | 90% | 39.4d? |  |  |  | 782d | finish no earlier than 2017-06-15 | R4 | 3152h | 2836.8h | LTE_CA_R14_2DL2UL-Core | PCG-36 | 36.714-02-02 | Huawei |  | Rel-14 | RP-70 |  |  |  |
| 989 | 392.3.2 | Perf. part: LTE Advanced inter-band Carrier Aggregation Rel-14 for 2DL/2UL | 394d? | 2015-12-15 A | 2017-06-15 | 90% | 39.4d? |  |  |  | 782d | finish no earlier than 2017-06-15 | R4 | 3152h | 2836.8h | LTE_CA_R14_2DL2UL-Perf | PCG-36 |  | Huawei |  | Rel-14 | RP-70 |  |  |  |

Notes:
- 964: Triggered by Rel-12 TR 33.805 Study on Security Assurance Methodology for 3GPP Network Elements (FS_SECAM); June2015: WID:SP-130718->SP-150292. Aug 15: TR numb added; 28/1/16: 33.926 added; 28/7/16: 33.250 added;06/10/16: moved to Rel-14 as per John/Mir
- 965: This TR collects input for the new TS 33.116. Dec.14: 55->70%. 3/3/15: 70->55%. 10/03/15: 55->75%; June2015: Compl:75%->80; 7/12/15: STOPPED AT 80% (marked as 100% here since no more work expected)
- 966: This TR contains results of the second WID objective. Dec.14: 75->85%; June2015: Compl:85%->90; 7/12/15: 90%->92; 10/12/15: WID:SP-130718->SP-150716; 19/9/16: 92%->98. FCD set to 12.16 (was 03/16); 6/10/16: 33.216 added; 1/12/16: 81%->100
- 967: June2015: 0%->5; 7/12/15: 5%->72.; 10/12/15: WID:SP-130718->SP-150716; 7/3/16: 72%->75; 28/7/16: 33.250 added; 19/9/16: 75%->90. FCD set to 12.16 (was 03/16). 6/3/17: moved from Rel-14.; 15/2/18: moved back to Rel-14
- 969: Created upon demand of RAN5
- 970: Acronym changed from "LTE_CA_Rel-13" to "LTE_CA_Rel13"
- 980: Acronym changed from "LTE_CA_Rel-13" to "LTE_CA_Rel13"
- 982: 28/1/16: 36.714-05-01 added; 22/3/16: Compl:0%->15%; 22/3/16: WID: RP-151671->RP-1606151/7/16: Compl:15%->40%; 26/9/16: Compl:40%->60%; 20/12/16: Compl ; 21/3/17...
- 983: 22/3/16: WID: RP-151671->RP-1606151/7/16: WID: RP-160615->RP-16105226/9/16: WID: RP-161052->RP-161496; 20/12/16: Compl:0%->90% ; 21/3/17: Compl:90%->95%;...
- 985: 28/1/16: 36.714-02-01 added; 22/3/16: Compl:0%->20%; 22/3/16: WID: RP-152196->RP-160616; 1/7/16: Compl:20%->30%; 1/7/16: WI26/9/16: Compl:30%->50%; 20/12/16: Com 21/3/17: ...
- 986: 22/3/16: WID: RP-152196->RP-1606161/7/16: Compl:0%->30%1/7/16: WID: RP-160616->RP-161202; 26/9/16: Compl:30%->50% 20/12/16: Compl:50%->75% 21/3/17: Compl:75%->80%; ;...
- 988: 28/1/16: 36.714-02-02 added;22/3/16: Compl:0%->20%22/3/16: WID: RP-152237->RP-160192; 1/7/16: Compl:20%->40%; 26/9/16: Compl:40%->60%; 20/12/16: C ; 21/3/17:...
- 989: ; 22/3/16: WID: RP-152237->RP-1601921/7/16: WID: RP-160192->RP-16094726/9/16: WID: RP-160947->RP-161676; 20/12/16: Compl:0%->80%; 21/3/17: Compl:80%->90...

| ID | WBS | Task | Type | Duration | Start | Finish | Complete | Remaining | Baseline start | Baseline finish | Baseline duration | Total slack | Constraint | Resources | Work | Actual work | Acronym | PCG approved | WI rapporteur name | Release | TSG approved | Impacted TSs and TRs | WI rapporteur e-mail | MCC resp | Acronym_3GU_Export | Special Focus Doc |
| --- | --- | --- | --- | --- | --- | --- | --- | --- | --- | --- | --- | --- | --- | --- | --- | --- | --- | --- | --- | --- | --- | --- | --- | --- | --- | --- |
| 990 | 392.4 | **LTE Advanced inter-band Carrier Aggregation Rel-14 for 3DL/3UL** |  | 328d? | 2015-12-15 A | 2017-03-15 A | 100% |  |  |  |  |  |  | R4 | 7872h | 7872h | LTE_CA_R14_3DL3UL | PCG-36 | Nokia Networks | Rel-14 | RP-70 |  |  |  |  |  |
| 991 | 392.4.1 | Core part: LTE Advanced inter-band Carrier Aggregation Rel-14 for 3DL/3UL |  | 328d? | 2015-12-15 A | 2017-03-15 A | 100% |  |  |  |  |  | finish no earlier than 2017-03-15 | R4 | 2624h | 2624h | LTE_CA_R14_3DL3UL-Core | PCG-36 | Nokia Networks | Rel-14 | RP-70 | 36.714-03-03 |  |  |  |  |
| 992 | 392.4.2 | Perf. part: LTE Advanced inter-band Carrier Aggregation Rel-14 for 3DL/3UL |  | 328d? | 2015-12-15 A | 2017-03-15 A | 100% |  |  |  |  |  | finish no earlier than 2017-03-15 | R4 | 2624h | 2624h | LTE_CA_R14_3DL3UL-Perf | PCG-36 | Nokia Networks | Rel-14 | RP-70 |  |  |  |  |  |
| 993 | 392.5 | **LTE Advanced inter-band Carrier Aggregation Rel-14 for xDL/2UL with x=3,4,5** |  | 394d? | 2015-12-15 A | 2017-06-15 | 48% | 206.85d? |  |  |  | 782d |  | R4 | 9456h | 4240.77h | LTE_CA_R14_xDL2UL | PCG-36 | LG Electronics | Rel-14 | RP-70 |  |  |  |  |  |
| 994 | 392.5.1 | Core part: LTE Advanced inter-band Carrier Aggregation Rel-14 for xDL/2UL with x=3,4,5 |  | 394d? | 2015-12-15 A | 2017-06-15 | 95% | 19.7d? |  |  |  | 782d | finish no earlier than 2017-06-15 | R4 | 3152h | 2994.4h | LTE_CA_R14_xDL2UL-Core | PCG-36 | LG Electronics | Rel-14 | RP-70 | 36.714-00-02 |  |  |  |  |
| 995 | 392.5.2 | Perf. part: LTE Advanced inter-band Carrier Aggregation Rel-14 for xDL/2UL with x=3,4,5 |  | 394d? | 2015-12-15 | 2017-06-15 |  |  |  |  |  | 782d | finish no earlier than 2017-06-15 | R4 | 3152h |  | LTE_CA_R14_xDL2UL-Perf | PCG-36 | LG Electronics | Rel-14 | RP-70 |  |  |  |  |  |
| 996 | 392.6 | **LTE Advanced inter-band Carrier Aggregation Rel-14 for 4DL/1UL** |  | 394d? | 2015-12-15 A | 2017-06-15 | 95% | 19.69d? |  |  |  | 782d |  | R4 | 9456h | 8481.62h | LTE_CA_R14_4DL1UL | PCG-36 | Ericsson | Rel-14 | RP-70 |  |  |  |  |  |
| 997 | 392.6.1 | Core part: LTE Advanced inter-band Carrier Aggregation Rel-14 for 4DL/1UL |  | 394d? | 2015-12-15 A | 2017-06-15 | 95% | 19.7d? |  |  |  | 782d | finish no earlier than 2017-06-15 | R4 | 3152h | 2994.4h | LTE_CA_R14_4DL1UL-Core | PCG-36 | Ericsson | Rel-14 | RP-70 | 36.714-04-01 |  |  |  |  |
| 998 | 392.6.2 | Perf. part: LTE Advanced inter-band Carrier Aggregation Rel-14 for 4DL/1UL |  | 394d? | 2015-12-15 A | 2017-06-15 | 95% | 19.7d? |  |  |  | 782d | finish no earlier than 2017-06-15 | R4 | 3152h | 2994.4h | LTE_CA_R14_4DL1UL-Perf | PCG-36 | Ericsson | Rel-14 | RP-70 |  |  |  |  |  |
| 999 | 392.7 | **LTE Advanced intra-band Carrier Aggregation for xDL/yUL including contiguous and non-contiguous spectrum** |  | 394d? | 2015-12-15 A | 2017-06-15 | 82% | 70.92d? |  |  |  | 782d |  | R4 | 9456h | 7084.9h | LTE_CA_R14_intra | PCG-36 | Ericsson | Rel-14 | RP-70 |  |  |  |  |  |
| 1000 | 392.7.1 | Core part: LTE Advanced intra-band Carrier Aggregation for xDL/yUL including contiguous and non-contiguous spectrum |  | 394d? | 2015-12-15 A | 2017-06-15 | 82% | 70.92d? |  |  |  | 782d | finish no earlier than 2017-06-15 | R4 | 3152h | 2584.64h | LTE_CA_R14_intra-Core | PCG-36 | Ericsson | Rel-14 | RP-70 | 36.714-00-00 |  |  |  |  |
| 1001 | 392.7.2 | Perf. part: LTE Advanced intra-band Carrier Aggregation for xDL/yUL including contiguous and non-contiguous spectrum |  | 394d? | 2015-12-15 A | 2017-06-15 | 82% | 70.92d? |  |  |  | 782d | finish no earlier than 2017-06-15 | R4 | 3152h | 2584.64h | LTE_CA_R14_intra-Perf | PCG-36 | Ericsson | Rel-14 | RP-70 |  |  |  |  |  |
| 1002 | 392.8 | **LTE Advanced inter-band Carrier Aggregation Rel-14 for 3DL/1UL** |  | 394d? | 2015-12-15 A | 2017-06-15 | 90% | 39.4d? |  |  |  | 782d |  | R4 | 9456h | 7904.07h | LTE_CA_R14_3DL1UL | PCG-36 | Huawei | Rel-14 | RP-70 |  |  |  |  |  |
| 1003 | 392.8.1 | Core part: LTE Advanced inter-band Carrier Aggregation Rel-14 for 3DL/1UL |  | 394d? | 2015-12-15 A | 2017-06-15 | 90% | 39.4d? |  |  |  | 782d | finish no earlier than 2017-06-15 | R4 | 3152h | 2836.8h | LTE_CA_R14_3DL1UL-Core | PCG-36 | Huawei | Rel-14 | RP-70 | 36.714-03-01 |  |  |  |  |
| 1004 | 392.8.2 | Perf. part: LTE Advanced inter-band Carrier Aggregation Rel-14 for 3DL/1UL |  | 394d? | 2015-12-15 A | 2017-06-15 | 90% | 39.4d? |  |  |  | 782d | finish no earlier than 2017-06-15 | R4 | 3152h | 2836.8h | LTE_CA_R14_3DL1UL-Perf | PCG-36 | Huawei | Rel-14 | RP-70 |  |  |  |  |  |
| 1005 | 392.9 | UE Conformance Test Aspects – Rel-14 CA configurations |  | 654d? | 2016-06-15 A | 2018-12-15 | 19% | 529.74d? |  |  |  | 391d | finish no earlier than 2018-12-15 | R5 | 5232h | 994.08h | LTE_CA_R14-UEConTest | PCG-37 | Ericsson | Rel-14 | TSG#72 |  |  |  |  |  |
| 1006 | 393 | Release 14 Studies |  | 323d? | 2014-09-17 A | 2015-12-11 A | 100% |  |  |  |  |  | finish no earlier than 2015-12-11 | SP; RP; CP; GP | 10336h | 10336h |  |  |  | Rel-14 |  |  |  |  |  |  |
| 1007 | 394 | Study on channel model for frequency spectrum above 6 GHz |  | 197d? | 2015-09-15 A | 2016-06-15 A | 100% |  |  |  |  |  | finish no earlier than 2016-06-15 | R1 | 1576h | 1576h | FS_6GHz_CH_model | 35 | Samsung | Rel-14 | 69 | 38.900 |  |  |  |  |
| 1008 | 395 | Study on Scenarios and Requirements for Next Generation Access Technologies |  | 264d? | 2015-12-15 A | 2016-12-15 A | 100% |  |  |  |  |  | finish no earlier than 2016-12-15 | RP | 2112h | 2112h | FS_NG_SReq | 36 | CMCC | Rel-14 | 70 | 38.xxx |  |  |  |  |
| 1009 | 396 | Study on NB-IoT RF requirement for coexistence with CDMA |  | 133d? | 2016-06-15 A | 2016-12-15 A | 100% |  |  |  |  |  | finish no earlier than 2016-12-15 | R4 | 1064h | 1064h | FS_NB_IOT_CDMA_coex | 37 | China Telecom | Rel-14 | 72 | 36.752 |  |  |  |  |
| 1010 | 397 | Study on need for Multiple Access Point Names |  | 464d? | 2013-09-12 A | 2015-06-19 A | 100% |  | 2013-09-12 | 2014-12-10 | 327d? |  | finish no earlier than 2015-06-19 | S1 | 3704h | 3704h | FS_MAPN | 31 | Giesecke & Devrient | Rel-14 | 61 | 22.802 | Ilario.macchi@gi-de.com | Alain | FS_MAPN |  |
| 1011 | 398 | Study on Multimedia Broadcast Supplement for Public Warning System |  | 264d? | 2013-12-11 A | 2014-12-12 A | 100% |  | 2013-12-11 | 2014-09-17 | 202d? |  | finish no earlier than 2014-12-12 | S1 | 2104h | 2104h | FS_MBSP | 32 | Qualcomm | Rel-14 | 62 | 22.815 | Eddy Hall (edhall@qti.qualcomm.com) | Alain | FS_MBSP | Public Safety (I-A) |
| 1012 | 399 | Study on service aspects for dealing with User Control over spoofed calls |  | 271d? | 2014-03-07 A | 2015-03-20 A | 100% |  | 2014-03-07 | 2014-12-10 | 199d? |  | finish no earlier than 2015-03-20 | S1 | 2168h | 2168h | FS_UC_SPOOF | 32 | Sprint | Rel-14 | 63 | 22.898 | Gregory.schumacher@sprint.com | Alain | FS_UC_SPOOF |  |
| 1013 | 400 | Study on User Location Reporting Support enhancements |  | 261d? | 2014-06-19 A | 2015-06-17 A | 100% |  | 2014-06-18 | 2015-06-17 | 261d? |  | finish no earlier than 2015-06-17 | S1 | 2088h | 2088h | FS_eULRS | 33 | China Unicom | Rel-14 | 64 | 22.899 | Zhuoyun Zhang ( zhangzy910@chinaunicom.cn) |  | FS_eULRS |  |
| 1014 | 401 | Study on Control of Applications when Third party Servers encounter difficulties |  | 259d? | 2014-06-19 A | 2015-06-15 A | 100% |  | 2014-06-18 | 2014-12-10 | 126d? |  | finish no earlier than 2015-06-15 | S1 | 2072h | 2072h | FS_CATS | 33 | KDDI | Rel-14 | 64 | 22.818 | Eriko Yoshida (er-yoshida@kddi.com) |  | FS_CATS |  |
| 1015 | 402 | Study on Paging Policy Enhancements and Procedure Optimizations in LTE |  | 176d? | 2015-04-14 A | 2015-12-15 A | 100% |  |  |  |  |  | finish no earlier than 2015-12-15 | S1 | 1408h | 1408h | FS_PPEPO_LTE | 34 | Zhuoyun Zhang (China Unicom) | Rel-14 | 67 | New TR 22.838 | zhangzy910@chinaunicom.cn |  |  |  |
| 1016 | 403 | Study on Latency reduction techniques for LTE |  | 328d? | 2015-03-16 A | 2016-06-15 A | 100% |  |  |  |  |  | finish no earlier than 2016-06-15 | R2 | 2624h | 2624h | FS_LTE_LATRED | 34 | Ericsson | Rel-14 | 67 | 36.881 |  |  |  |  |
| 1017 | 404 | Study on High Power LTE UE for Band 41 |  | 263d? | 2015-06-15 A | 2016-06-15 A | 100% |  |  |  |  |  | finish no earlier than 2016-12-15 | R4 | 2104h | 2104h | FS_LTE_B41_HPUE | 35 | Sprint | Rel-14 | 68 | 36.886 |  |  |  |  |
| 1018 | 405 | Study on Media and Quality Aspects of SRVCC Enhancements |  | 192d? | 2015-06-18 A | 2016-03-11 A | 100% |  |  |  |  |  | finish no earlier than 2016-03-11 | S4 | 1536h | 1536h | FS_SETA_S4 | 35 | Frédéric Gabin, Ericsson LM | Rel-14 | 68 | New TR 26.916, TS 26.114 | frederic . gabin @ ericsson . com |  |  |  |
| 1019 | 406 | Deleted - Study on SON for eCoMP for LTE |  | 3d? | 2016-06-14 A | 2016-06-16 A | 100% |  |  |  |  |  | start no earlier than 2016-06-14 | R3 | 24h | 24h | delFS_LTE_SON_eCOMP | 37 | Nokia | Rel-14 | 72 | 23.228, 23.237 |  |  |  |  |
| 1020 | 407 | Study on UICC power optimization for MTC |  | 133d? | 2016-06-15 A | 2016-12-15 A | 100% |  |  |  |  |  |  | C6 | 1064h | 1064h | FS_UICC_MTC_OPT | 36 | Berionne, Michele | Rel-14 | 70 | 31.970 | micheleb [at] qti [dot] qualcomm [dot] com |  |  |  |
| 1021 | 408 | Study on Server and Network Assisted DASH for 3GPP |  | 209d? | 2016-03-01 A | 2016-12-15 A | 100% |  |  |  |  |  | finish no earlier than 2016-12-15 | S4 | 1672h | 1672h | FS_SAND | 36 | Ozgur Oyman, Intel | Rel-14 | 71 | TR26.957 | ozgur.oyman@intel.com |  |  |  |
| 1022 | 409 | Study on MBMS usage for mission critical communication services | milestone | 0d? | 2016-03-01 A | 1984-10-18 A | 100% |  |  |  |  |  | finish no earlier than 2016-12-15 |  |  |  | FS_MBMS_MCservices | 36 | Magnus Tränk, Ericsson LM | Rel-14 | 71 | TR 23.780 | magnus.trank@ericsson.com |  |  |  |
| 1023 | 410 | Study on enhancement of VoLTE |  | 134d? | 2016-03-15 A | 2016-09-15 A | 100% |  |  |  |  |  | finish no earlier than 2016-09-15 | R2 | 1072h | 1072h | FS_LTE_eVoLTE | 36 | CMCC | Rel-14 | 71 | 36.750 |  |  |  |  |
| 1024 | 411 | Study on HSPA and LTE Joint Operation |  | 199d? | 2016-03-15 A | 2016-12-15 A | 100% |  |  |  |  |  | finish no earlier than 2016-12-15 | R3 | 1592h | 1592h | FS_UTRA_LTE_JOP | 36 | China Unicom | Rel-14 | 71 | New 37.805 |  |  |  |  |
| 1025 | 412 | Study on LTE Advanced Carrier Aggregation of Band 3 and Band 39 |  | 263d? | 2016-03-15 A | 2017-03-15 A | 100% |  |  |  |  |  | finish no earlier than 2017-03-15 | R4 | 2104h | 2104h | FS_LTE_CA_B3_B39 | 36 | ZTE | Rel-14 | 71 |  |  |  |  |  |
| 1026 | 413 | Study on Context Aware Service Delivery in RAN for LTE |  | 263d? | 2016-03-15 A | 2017-03-15 A | 100% |  |  |  |  |  | finish no earlier than 2017-03-15 | R3 | 2104h | 2104h | FS_LTE_context | 36 | CMCC | Rel-14 | 71 |  |  |  |  |  |
| 1027 | 414 | Study on further enhancements to Coordinated Multi-Point (CoMP) Operation for LTE |  | 263d? | 2016-03-15 A | 2017-03-15 A | 100% |  |  |  |  |  | finish no earlier than 2017-03-15 | R1 | 2104h | 2104h | FS_feCOMP_LTE | 36 | Intel | Rel-14 | 71 |  |  |  |  |  |
| 1028 | 415 | Study on Determination of Completeness of Charging Information in IMS |  | 267d? | 2015-03-05 A | 2016-03-11 A | 100% |  |  |  |  |  | finish no earlier than 2016-03-11 | S5 | 2136h | 2136h | FS_DCCHII | 34 | Jesske, Roland | Rel-14 | 67 | 32.xyz | r.jesske@telekom.de |  |  |  |
| 1029 | 416 | Study on Interactivity Support for 3GPP-based Streaming and Download Services |  | 587d? | 2014-12-12 A | 2017-03-10 A | 100% |  |  |  |  |  | finish no earlier than 2017-03-10 | S4 | 4696h | 4696h | FS_IS3 | 34 | Lo, Charles, Qualcomm | Rel-14 | 66 | 26.953 | clo@qti.qualcomm.com |  |  |  |
| 1030 | 417 | Study on MBMS usage and codecs for MCPTT call and MC Video Service |  | 199d? | 2016-06-13 A | 2017-03-15 A | 100% |  |  |  |  |  | finish no earlier than 2017-03-15 | S4 | 1592h | 1592h | FS_MCP_V | 37 | Zhiming Li, Huawei | Rel-14 | 72 | 26.880 | lizhiming@huawei.com |  |  |  |
| 1031 | 418 | Study on MBMS Extensions for Provisioning and Content Ingestion |  | 196d? | 2016-06-13 A | 2017-03-10 A | 100% |  |  |  |  |  | finish no earlier than 2017-03-10 | S4 | 1568h | 1568h | FS_xMBMS | 37 | Kyungmo Park, sk telecom | Rel-14 | 72 | TR 26.981 | kyungmo.park@sk.com |  |  |  |
| 1032 | 419 | Study on global application of LTE Band 11 and of LTE Band 21 UEs |  | 133d? | 2016-06-15 A | 2016-12-15 A | 100% |  |  |  |  |  | finish no earlier than 2016-12-15 | R4 | 1064h | 1064h | FS_LTE_B11_B21_global | 37 | SoftBank | Rel-14 | 72 | 36.745 |  |  |  |  |
| 1033 | 420 | Study on Downlink MIMO for GERAN |  | 68d? | 2016-06-15 A | 2016-09-15 A | 100% |  |  |  |  |  | finish no earlier than 2016-09-15 | R6 | 544h | 544h | FS_DOMIMO_RAN6 | 37 | Nokia, Alcatel-Lucent Shanghai Bell | Rel-14 | 72 |  |  |  |  |  |
| 1034 | 421 | Release 14 studies on 5G MObile Network for Advanced communications |  | 490d? | 2015-02-02 A | 2016-12-15 A | 100% |  |  |  |  |  |  | S1 | 2160h | 2160h |  | 34 | Adrian Neal (Vodafone) | Rel-14 | 67 | New TR 22.891 | adrian.neal@vodafone.com |  |  |  |

Notes:
- 991: 28/1/16: 36.714-03-03 added;22/3/16: Compl:0%->1%1/7/16: Compl:1%->15%; 21/3/17: Compl:15%->100%
- 992: ; 1/7/16: Compl:0%->15%21/3/17: Compl:15%->100%
- 994: 28/1/16: 36.714-00-02 added; 22/3/16: Compl:0%->10%; 22/3/16: WID: RP-152246->RP-160148; 1/7/16: Compl:10%->40%; 26/9/16: Compl:40%->70%; 20/; 21/3/17: ...
- 995: 22/3/16: WID: RP-152246->RP-1601481/7/16: WID: RP-160148->RP-160748; 26/9/16: WID: RP-160748->RP-161487; 20/12/16: WID: RP-161487->RP-16203621/3/17:...
- 997: 28/1/16: 36.714-04-01 added;22/3/16: Compl:0%->30%22/3/16: WID: RP-152249->RP-1606141/7/16: Compl:30%->38%; 26/9/16: Compl:38%->74%; 20/12/16: Compl:74%->9521/3/1...
- 998: ; 22/3/16: WID: RP-152249->RP-160614; 1/7/16: Compl:0%->38%; 1/7/16: WID: RP-160614->RP-16082126/9/16: Compl:38%->0%; 20/12/16: Compl:0%->95% ; 21/3/17: CD:Wed 1...
- 1000: 28/1/16: 36.714-00-00 added;22/3/16: Compl:0%->60%22/3/16: WID: RP-152250->RP-160613; 1/7/16: Compl:60%->50%; 1/7/16: WID: RP-160613; 26/9/16: Compl:50%->44%; 20/12/16:21/3/1...
- 1001: ; 22/3/16: WID: RP-152250->RP-1606131/7/16: Compl:0%->50%1/7/16: WID: RP-160613->RP-16082226/9/16: WID: RP-160822->RP-161473; 20/12/16: Compl:50%->64% 21/3/17: Compl:64%->...
- 1003: 28/1/16: 36.714-03-01 added;22/3/16: Compl:0%->15%22/3/16: WID: RP-152278->RP-1605821/7/16: Compl:15%->40%1/7/1626/9/16: Compl:40%->60%; 20/12/16: Compl:60%->80 21/3/1...
- 1004: 22/3/16: WID: RP-152278->RP-160582; 1/7/16: WID: RP-160582->RP-160945; 26/9/16: WID: RP-160945->RP-161674; 20/12/16: Compl:0%->80%21/3/17: Compl:80%->90%;...
- 1005: testing REL-14 CA basket WIs: LTE_CA_R14_intra-Core, LTE_CA_R14_2DL1UL-Core, LTE_CA_R14_3DL1UL-Core, LTE_CA_R14_4DL1UL-Core, LTE_CA_R14_5DL1UL-Core, LTE_CA_R14_2DL2UL-Core, LTE_CA_R14_xDL2UL-Core, LTE_CA_R14_3DL3UL-Core...; ...
- 1006: -
- 1007: will start only in RAN in Q4/15; 28/1/16: 38.900 added; 22/3/16: Compl:10%->20%; 22/3/16: WID: RP-151606->RP-160210; 1/7/16: Compl:20%->100%. 2/12/16: Moved to Rel-15 according JMM email to move all 38.xxx related WIDs to Rel-15; 21/3/17: Stat Rep: -->; 21/3/17: Release: Rel-15->Rel-14
- 1008: 22/3/16: Compl:0%->80%1/7/16: WID: RP-152257->RP-160811. 18/9/16: FCD: Sept 16, 80->95%26/9/16: Compl:95%->100%; 14/12/16: FCD:09/16->12/16; 14/12/16: 100%->9820/12/16: Compl:98%->100%20/12/16: CD:Mon 12/12/16->Thu 15/12/1620/12/16: Release: Rel-15->Re
- 1009: ; 26/9/16: Compl:0%->35%; 6/10/16: 36.752 added; 20/12/16: Compl:35%->100%
- 1010: SP#65 moved to Rel-14. Completion 12/14=>03/15. Triggered by S1-133134 LS on GSMA Connected Living Programme Request for APN Storage in the SIM. Dec.14: 50->70%, CD: 03/15->06/15. Mar.15: 90%; June2015: Compl:90%->100
- 1011: SP#65 completion 09/14=>12/14. Moved to Rel-14. TR 22.815v100 for Information. Linked to Rel-9 Feature PWS. Dec.14:70->100%
- 1012: SP#65 moved to Rel-14. Linked to SA3 Rel-11 TR 33.838 PUCI and Rel-12 ongoing study TR 33.831 (FS_SPOOF). Dec.14: 70->90, CD: 12/14->03/15. Mar.15: 100%
- 1013: SP#65 moved to Rel-14. Linked to Rel-12 SA2 TR 23.843 Study on Core Network Overload solutions (FS_CNO) and Rel-13 Feature Service Exposure and Enablement Support (SEES). Dec.14: 30->70%. Mar.15: 90%; June2015: Compl:90%->100
- 1014: SP#65 completion 12/14=>03/15. Moved to Rel-14. Linked to Rel-13 Feature SEES and Rel-13 TR 22.806 (FS_ACDC). Dec.14: 30->60%, WID SP-140246->SP-140758, CD: 12/14->03/15. Mar.15: CD: 03/13->06/15. 60->90%; June2015: Compl:90%->100
- 1015: 1/4/15:TR number added; June2015: Compl:0%->40; 07/09/15: 40%->60; 7/12/15: 60%->100
- 1016: 03/07/15: Compl:0%->10% 03/07/15: Stat Rep: -->RP-150780 03/07/15: Release: Rel-13->Rel-14 29/09/15: Compl:10%->25% 29/09/15: Stat Rep: RP-150780->RP-151286 22/3/16: Compl:50%->60%;
- 1017: 7/9/15: TR added 29/09/15: Compl:0%->1% 29/09/15: Stat Rep: -->RP-151436 ; 22/3/16: Compl:10%->40%; 22/3/16: WID: RP-151104->RP-1600921/7/16: Compl
- 1018: Aug2015: 0%->25; 07/09/15: 25%->30; 7/12/15: 30%->80, FCD: 12/15->03/16, MOVED TO REL-14; 7/3/16: 80%->100
- 1019: 26/9/16: Compl:0%->10%. 1/12/16: Deleted: 720085 was allocated twice: to FS_LTE_SON-ECOMP (now in 720063) and to ROBVOLTE (now in 720301)
- 1020: 7/3/16: 0%->100; 5/6/17: 71%->100
- 1021: 11/6/16: 0%->10; 19/9/16: 10%->60; 1/12/16: 60%->100
- 1022: 11/6/16: 0%->35. Name corrected; 19/9/16: WID:SP-160201->SP-160525; FCD: 09/16->12/16; 19/9/16: 35%->60; 23/9/16: WID:SP-160525->SP-160728; 1/12/16: 60%->95; 3/3/17: 95%->100
- 1023: 1/7/16: Compl:0%->75%1/7/16: WI; 28/7/16: 36.750 added; 26/9/16: Compl:75%->100%
- 1024: ; 1/7/16: Compl:0%->30%; 26/9/16: Compl:30%->80%; 20/12/16: Compl:80%->100%;
- 1025: intention to capture results in existing TR 36.714-02-01 ; 1/7/16: Compl:0%->30%; 26/9/16: Compl:30%->50%; 20/12/16: Compl ; 21/3/17: Compl:8...
- 1026: 1/7/16: Compl:0%->25%1/26/9/16: Compl:25%->40%; 20/12/16: Compl:40%->70% ; 21/3/17: Compl:70%->100%
- 1027: ; 1/7/16: Compl:0%->15%; 26/9/16: Compl:15%->30%; 20/12/16: Compl:30%->80%21/3/17: Compl:80%->100%
- 1028: 11/03/15: WID changed from FS_DCCII to FS_DCCHII as per SA5 chair request; June2015: Compl:0%->7; 07/09/15: 7%->15; 7/12/15: 15%->60, FCD: 09/15->03/16; 7/3/16: 60%->100. 22/3/16: Rel-13->Rel-14
- 1029: TR number added. Mar. 15: 0->5%; June2015: Compl:5%->10; Aug2015: 10%->15; 07/09/15: 15%->30, FCD: 12/15->03/16; 7/3/16: 30%->40. 15/4/16: moved from Rel-13. FCD: 11/3/16->23/9/16; 11/6/16: 40%->50; 19/9/16: 50%->70, FCD:09/16->12/16; 1/12/16: 70%->80;; 6/3/17: 80%->100
- 1030: 28/7/16: 26.880 added; 19/9/16: 0%->30, FCD: 12/16->03/17; 1/12/16: 30%->60; 6/3/17: 60%->100
- 1031: 28/7/16: 26.981 added; 19/9/16: 0%->30; 1/12/16: 30%->50; 1/12/16: FCD:12/16->03/17; 6/3/17: 50%->100
- 1032: 26/9/16: Compl:0%->30%; 6/10/16: 36.745 added; 20/12/16: Compl:30%->100%
- 1033: continuation of GERAN SI UID 590034, DOMIMO under RAN626/9/16: Compl:0%->100%
- 1034: 11/3: WID: SP-150050->150142; June2015: Compl:0%->20; 07/09/15: 20%->60. 07/12/15: Created by MCC as BB to dissociate SA1 versus SA2 aspects

| ID | WBS | Task | Type | Duration | Start | Finish | Complete | Remaining | Baseline start | Baseline finish | Baseline duration | Total slack | Constraint | Resources | Work | Actual work | Acronym | PCG approved | Impacted TSs and TRs | WI rapporteur name | WI rapporteur e-mail | Release | TSG approved | MCC resp | Special Focus Doc | Acronym_3GU_Export | Status Report | TSG stopped |
| --- | --- | --- | --- | --- | --- | --- | --- | --- | --- | --- | --- | --- | --- | --- | --- | --- | --- | --- | --- | --- | --- | --- | --- | --- | --- | --- | --- | --- |
| 1035 | 422 | **Study on Stage 1 for New Services and Markets Technology Enablers** |  | 355d? | 2015-02-02 A | 2016-06-10 A | 100% |  |  |  |  |  |  | S1 | 10120h | 10120h | FS_SMARTER | 34 | New TR 22.891 | Adrian Neal (Vodafone) | adrian.neal@vodafone.com | Rel-14 | 67 |  |  |  |  |  |
| 1036 | 422.1 | General aspects of FS_SMARTER SA1 |  | 270d? | 2015-02-02 A | 2016-02-12 A | 100% |  |  |  |  |  | finish no earlier than 2016-02-12 | S1 | 2160h | 2160h | FS_SMARTER | 34 | New TR 22.891 | Adrian Neal (Vodafone) | adrian.neal@vodafone.com | Rel-14 | 67 |  |  |  |  |  |
| 1037 | 422.2 | FS_SMARTER – massive Internet of Things |  | 160d? | 2015-11-02 A | 2016-06-10 A | 100% |  |  |  |  |  | finish no earlier than 2016-06-10 | S1 | 1280h | 1280h | FS_SMARTER-mIoT | 36 | New TR 22.861 | Adrian Neal (Vodafone) | adrian.neal@vodafone.com | Rel-14 | 70 |  |  |  |  |  |
| 1038 | 422.3 | FS_SMARTER – Critical Communications |  | 160d? | 2015-11-02 A | 2016-06-10 A | 100% |  |  |  |  |  | finish no earlier than 2016-06-10 | S1 | 1280h | 1280h | FS_SMARTER-CRIC | 36 | New TR 22.862 | Kanerva, Mikko | mikko.kanerva@nokia.com | Rel-14 | 70 |  |  |  |  |  |
| 1039 | 422.4 | FS_SMARTER – enhanced Mobile Broadband |  | 160d? | 2015-11-02 A | 2016-06-10 A | 100% |  |  |  |  |  | finish no earlier than 2016-06-10 | S1 | 1280h | 1280h | FS_SMARTER-eMBB | 36 | New TR 22.863 | Laurence Meriau | laurence.meriau@huawei.com | Rel-14 | 70 |  |  |  |  |  |
| 1040 | 422.5 | FS_SMARTER – Network Operation |  | 160d? | 2015-11-02 A | 2016-06-10 A | 100% |  |  |  |  |  | finish no earlier than 2016-06-10 | S1 | 1280h | 1280h | FS_SMARTER-NEO | 36 | New TR 22.864 | Lu Lu | lulu@chinamobile.com | Rel-14 | 70 |  |  |  |  |  |
| 1041 | 423 | SA2 aspects on Study on Architecture and Security for next Generation System |  | 270d? | 2015-12-07 A | 2016-12-15 A | 100% |  |  |  |  |  | finish no earlier than 2016-12-15 | S2 | 2160h | 2160h | FS_NextGen | 36 | TR 23.799 | suntao@chinamobile.com, devaki.chandramouli@nokia.com | suntao@chinamobile.com, devaki.chandramouli@nokia.com | Rel-14 | 70 |  |  |  |  |  |
| 1042 | 424 | Study on New Radio (NR) Access Technology |  | 263d? | 2016-03-15 A | 2017-03-15 A | 100% |  |  |  |  |  | finish no earlier than 2017-03-15 | R1 | 2104h | 2104h | FS_NR_newRAT | 36 | TR 38.801, TR 38.912; 38.802; 38.901; 38.805 | NTT DOCOMO |  | Rel-14 | 71 |  |  |  |  |  |
| 1043 | 425 | Release 13 Features |  | 253.25d? | 2013-12-11 A | 2014-11-25 A | 100% |  | 2015-04-14 | 2015-12-25 | 183.25d? |  |  | SP; RP; CP; GP | 8104h | 8104h |  |  |  |  |  | Rel-13 |  |  |  |  |  |  |
| 1044 | 426 | **Mission Critical Push To Talk over LTE (MCPTT)** |  | 1183d? | 2013-12-11 A | 2018-06-15 | 96% | 49.14d? | 2013-12-11 | 2015-06-17 | 397d? | 521d |  |  | 38576h | 35662.7h | MCPTT | 32 | Stage 1/2; | NIST | david.cypher@nist.gov | Rel-13 | 62 | Alain | Public Safety (A-A) | MCPTT |  |  |
| 1045 | 426.1 | Study on Application Architecture to support MCPTT |  | 326d? | 2014-06-23 A | 2015-09-16 A | 100% |  | 2014-06-18 | 2014-12-10 | 126d? |  | finish no earlier than 2015-09-16 | S6 | 2608h | 2608h | MCPTT | 33 | New TR 23.779 | Yannick Lair | yannick.lair@lge.com | Rel-13 | 64 |  | Public Safety (A-A) |  |  |  |
| 1046 | 426.2 | SA2 Study on Architecture Enhancements at the EPS and IMS Level to Support MCPTT |  | 69d? | 2015-03-13 A | 2015-06-17 A | 100% |  |  |  |  |  | finish no earlier than 2015-06-17 | S2 | 552h | 552h | MCPTT | 34 |  | Randy Bloomfield (randy@its.bldrdoc.gov) | Randy Bloomfield (randy@its.bldrdoc.gov) | Rel-13 | 67 |  |  |  |  |  |
| 1047 | 426.3 | Study on Security Enhancements for MCPTT |  | 261d? | 2015-03-13 A | 2016-03-11 A | 100% |  |  |  |  |  | finish no earlier than 2016-03-11 | S3 | 2088h | 2088h | MCPTT | 34 | 33.879; 33.280; 39.880 | Peter Haigh (peter.haigh at cesg.gsi.gov.uk) | Peter Haigh (peter.haigh at cesg.gsi.gov.uk) | Rel-13 | 67 |  |  |  |  |  |
| 1048 | 426.4 | Study on media, codecs and MBMS enhancements for MCPTT |  | 326d? | 2014-12-12 A | 2016-03-11 | 85% | 48.9d? |  |  |  | 1112d | finish no earlier than 2016-03-11 | S4 | 2608h | 2216.8h | MCPTT | 34 | New TR 26.879 | Zhiming Li (lizhiming@huawei.com) | Zhiming Li (lizhiming@huawei.com) | Rel-13 | 67 |  |  |  |  |  |
| 1049 | 426.5 | Stage 1 for MCPTT |  | 263d? | 2013-12-11 A | 2014-12-12 A | 100% |  | 2013-12-11 | 2014-12-10 | 261d? |  | finish no earlier than 2014-12-12 | S1 | 2104h | 2104h | MCPTT | 32 | New TS 22.179 | NIST | david.cypher@nist.gov | Rel-13 | 62 | Alain | Public Safety (A-A) |  | SP-140502 |  |
| 1050 | 426.6 | Functional architecture and information flows to support MCPTT |  | 127d? | 2015-06-18 A | 2015-12-11 A | 100% |  | 2014-06-18 | 2014-12-10 | 126d? |  | finish no earlier than 2015-12-11 | S6 | 1016h | 1016h | MCPTT | 33 | New TS 23.179 | Yannick Lair | yannick.lair@lge.com | Rel-13 | 64 |  | Public Safety (A-A) |  |  |  |
| 1051 | 426.7 | Security of MCPTT |  | 326d? | 2014-12-12 A | 2016-03-11 A | 100% |  |  |  |  |  | finish no earlier than 2016-03-11 | S3 | 2608h | 2608h | MCPTT | 34 | TS 33.179 | Peter Haigh (peter.haigh at cesg.gsi.gov.uk) | Peter Haigh (peter.haigh at cesg.gsi.gov.uk) | Rel-13 | 66 |  |  |  |  |  |
| 1052 | 426.8 | MCPTT Codecs and media handling |  | 267d? | 2015-03-05 A | 2016-03-11 | 85% | 40.05d? |  |  |  | 1112d | finish no earlier than 2016-03-11 | S4 | 2136h | 1815.6h | MCPTT | 34 | 26.346, new TS 26.179 | Zhiming Li (lizhiming@huawei.com) | Zhiming Li (lizhiming@huawei.com) | Rel-13 | 67 |  |  |  |  |  |
| 1053 | 426.9 | **MCPTT protocol aspects** |  | 215d? | 2015-09-07 A | 2016-06-30 | 96% | 9.64d? |  |  |  | 1032d |  | ct | 16584h | 14539h | MCPTT-CT | 35 |  | Keith Drage, Alcatel-Lucent |  | Rel-13 | 69 |  |  |  |  |  |
| 1054 | 426.9.1 | **CT1 aspects for MCPTT protocol aspects** |  | 135d? | 2015-09-07 A | 2016-03-11 A | 100% |  |  |  |  |  |  | C1 | 10800h | 10800h | MCPTT-CT | 35 | 24.379, 24.380 24.38, 24.382, 24.383, 24.384, 24.229 | Samsung, Ricky Kaura | ricky.kaura@samsung.com | Rel-13 | 69 |  |  |  |  |  |
| 1055 | 426.9.1.1 | Call Control – On Network |  | 135d? | 2015-09-07 A | 2016-03-11 A | 100% |  |  |  |  |  | finish no earlier than 2016-03-11 | C1 | 1080h | 1080h | MCPTT-CT | 35 | 24.379 | Samsung, Ricky Kaura | ricky.kaura@samsung.com | Rel-13 | 69 |  |  |  |  |  |
| 1056 | 426.9.1.2 | Call Control – Off Network |  | 135d? | 2015-09-07 A | 2016-03-11 A | 100% |  |  |  |  |  | finish no earlier than 2016-03-11 | C1 | 1080h | 1080h | MCPTT-CT | 35 | 24.379 | Samsung, Ricky Kaura | ricky.kaura@samsung.com | Rel-13 | 69 |  |  |  |  |  |
| 1057 | 426.9.1.3 | Floor Control – On Network |  | 135d? | 2015-09-07 A | 2016-03-11 A | 100% |  |  |  |  |  | finish no earlier than 2016-03-11 | C1 | 1080h | 1080h | MCPTT-CT | 35 | 24.380 | Samsung, Ricky Kaura | ricky.kaura@samsung.com | Rel-13 | 69 |  |  |  |  |  |
| 1058 | 426.9.1.4 | Floor Control – Off Network |  | 135d? | 2015-09-07 A | 2016-03-11 A | 100% |  |  |  |  |  | finish no earlier than 2016-03-11 | C1 | 1080h | 1080h | MCPTT-CT | 35 | 24.380 | Samsung, Ricky Kaura | ricky.kaura@samsung.com | Rel-13 | 69 |  |  |  |  |  |
| 1059 | 426.9.1.5 | Broadcast – Call Control and Floor Control |  | 135d? | 2015-09-07 A | 2016-03-11 A | 100% |  |  |  |  |  | finish no earlier than 2016-03-11 | C1 | 1080h | 1080h | MCPTT-CT | 35 | 24.379, 24.380 | Samsung, Ricky Kaura | ricky.kaura@samsung.com | Rel-13 | 69 |  |  |  |  |  |
| 1060 | 426.9.1.6 | Group management |  | 135d? | 2015-09-07 A | 2016-03-11 A | 100% |  |  |  |  |  | finish no earlier than 2016-03-11 | C1 | 1080h | 1080h | MCPTT-CT | 35 | 24.381 | Samsung, Ricky Kaura | ricky.kaura@samsung.com | Rel-13 | 69 |  |  |  |  |  |
| 1061 | 426.9.1.7 | Identity management |  | 135d? | 2015-09-07 A | 2016-03-11 A | 100% |  |  |  |  |  | finish no earlier than 2016-03-11 | C1 | 1080h | 1080h | MCPTT-CT | 35 | 24.382 | Samsung, Ricky Kaura | ricky.kaura@samsung.com | Rel-13 | 69 |  |  |  |  |  |
| 1062 | 426.9.1.8 | Management Object |  | 135d? | 2015-09-07 A | 2016-03-11 A | 100% |  |  |  |  |  | finish no earlier than 2016-03-11 | C1 | 1080h | 1080h | MCPTT-CT | 35 | 24.383 | Samsung, Ricky Kaura | ricky.kaura@samsung.com | Rel-13 | 69 |  |  |  |  |  |
| 1063 | 426.9.1.9 | Configuration management |  | 135d? | 2015-09-07 A | 2016-03-11 A | 100% |  |  |  |  |  | start no earlier than 2015-09-07 | C1 | 1080h | 1080h | MCPTT-CT | 36 | 24.384 | Samsung, Ricky Kaura | ricky.kaura@samsung.com | Rel-13 | 71 |  |  |  |  |  |
| 1064 | 426.9.2 | CT3 aspects for MCPTT protocol aspects |  | 135d? | 2015-09-07 A | 2016-03-11 A | 100% |  |  |  |  |  | finish no earlier than 2016-03-11 | C3 | 1080h | 1080h | MCPTT-CT | 35 | 29.165 | Alcatel-Lucent, Keith Drage | keith.drage@alcatel-lucent.com | Rel-13 | 69 |  |  |  |  |  |
| 1065 | 426.9.3 | CT4 aspects for MCPTT protocol aspects |  | 135d? | 2015-09-07 A | 2016-03-11 A | 100% |  |  |  |  |  | finish no earlier than 2016-03-11 | C4 | 1080h | 1080h | MCPTT-CT | 35 | 23.003, 23.008, 29.283 | Alcatel-Lucent, Keith Drage | keith.drage@alcatel-lucent.com | Rel-13 | 69 |  |  |  |  |  |
| 1066 | 426.9.4 | CT6 aspects for MCPTT protocol aspects |  | 135d? | 2015-09-07 A | 2016-03-11 A | 100% |  |  |  |  |  | finish no earlier than 2016-03-11 | C6 | 1080h | 1080h | MCPTT-CT | 36 | 31.102, 31.103 | Alcatel-Lucent, Keith Drage | keith.drage@alcatel-lucent.com | Rel-13 | 70 |  |  |  |  |  |
| 1067 | 426.9.5 | (IETF) IANA Registration of New SIP Resource- Priority Namespace for MCPTT |  | 103d? | 2016-02-10 A | 2016-06-30 | 25% | 77.25d? |  |  |  | 1032d | start no earlier than 2016-02-10 | C1-IETF | 824h | 206h | MCPTT-CT | 36 | draft-holmberg-dispatch-mcptt-rp-namespace | Ericsson | christer.holmberg@ericsson.com | Rel-13 | 71 |  |  |  |  |  |
| 1068 | 426.10 | IMS Profile to support MCPTT |  | 130d? | 2015-09-14 A | 2016-03-11 A | 100% |  |  |  |  |  | finish no earlier than 2016-03-11 | C1 | 1040h | 1040h | MCPTT-Prof | 35 | 24.980 | Huawei, PATEL Milan | Milan.Patel@huawei.com | Rel-13 | 69 |  |  |  |  |  |
| 1069 | 426.11 | UE Conformance Test Aspects - Support for Mission Critical Push To Talk over LTE (MCPTT) |  | 392d? | 2016-12-15 A | 2018-06-15 | 95% | 19.6d? |  |  |  | 521d | finish no earlier than 2018-06-15 | R5 | 3136h | 2979.2h | MCPTT-ConTest | 38 | 36.579-5 | US Department of Commerce |  | Rel-13 | 74 |  |  |  |  |  |
| 1070 | 426.12 | Deleted: SA2 aspects for MCPTT |  | 1d? | 2015-03-13 A | 2015-03-13 A | 100% |  | 2014-06-18 | 2015-06-17 | 261d? |  | finish no earlier than 2015-03-13 | S2 | 8h | 8h | MCPTT | 33 | New TS 23.179 | Randy Bloomfield (randy@its.bldrdoc.gov) | Randy Bloomfield (randy@its.bldrdoc.gov) | Rel-13 | 64 |  | Public Safety (A-A) |  |  | SP-69 |
| 1071 | 426.13 | Deleted (duplicated): Application Architecture to support MCPTT | milestone | 0d? | 2015-03-13 A | 2015-03-13 A | 100% |  |  |  |  |  | finish no earlier than 2015-03-13 | S6 |  |  | MCPTT | 34 |  | U.S. Department of Commerce | Randy Bloomfield (randy@its.bldrdoc.gov) | Rel-13 | 67 |  |  |  |  | SP-69 |
| 1072 | 426.14 | Deleted (duplicated): SA6 aspects for MCPTT |  | 261d? | 2014-12-12 A | 2015-12-11 A | 100% |  |  |  |  |  | finish no earlier than 2015-12-11 | S6 | 2088h | 2088h | MCPTT | 34 |  | David Cypher (david.cypher at nist.gov) | David Cypher (david.cypher at nist.gov) | Rel-13 | 66 |  |  |  |  | SP-69 |

Notes:
- 1036: 7/12/15: 60%->85; 2/3/16: 85%->95; 7/6/17: 95%->100
- 1037: 2/3/16: 35%->65; 9/6/16: 65%->100
- 1038: 2/3/16: 15%->60; 9/6/16: 60%->95; 7/6/17: 95%->100
- 1039: 2/3/16: 40%->75; 9/6/16: 75%->100
- 1040: 2/3/16: 30%->60; 19/9/16: 60%->100
- 1041: 28/1/16: 23.799 added; Acronym corrected ("NexGen"->"NextGen"); 7/3/16: 5%->15; 10/3/16: WID:SP-150853->SP-160200. Name changed from "Study on Architecture for next Generation System"; 9/6/16: 15%->35; 19/9/16: 35%->64; 22/9/16: WID:SP-160227->SP-16072
- 1042: includes RAN TR 38.801; 1/7/16: Compl:0%->10%; 1/7/16: CD:Thu 15/06/17->Wed 15/03/17; 1/7/16: WID: RP-160671->RP-161214; 1/7/16: Release: Rel-15->Rel-14; 28/7/16: 38.802 added; 26/9/16: Compl:10%->20%; 26/9/16: WID: RP-161214->RP-161596. 2/12/16: Moved...; 21/3/17: 38.805 added;
- 1043: -
- 1044: SP#65 updated WID SP-140276=>SP-140435. Mar 15: WID: SP-140879->SP-150164. 4/15: S4 added. 6/15: WID updated
- 1045: SP#65 completion 12/14=>06/15. Updated WID SP-140276=>SP-140435. Dec.14: 2->20%. Mar 15: WID: SP-140879->SP-150095. Mar15: 30%. Transferred to SA6. June 15: FCD shifted to Sept,WID updated; June2015: Compl:24%->50; June2015: Compl:50%->70. 3/8/15: Rapp
- 1046: Mar 2015: WID: SP-140879->SP-150164.; June2015: Compl:0%->30, WID updated; 07/09/15: 30%->100, "To be confirmed" deleted, since SA2 has completed it.
- 1047: Mar 2015: WID: SP-140879->SP-150164. Name clarified.6/15: WID updated; 7/12/15: 0%->75; 10/12/15: FCD->March, ES in SP-150729; 7/3/16: 75%->80; 28/7/16: 33.280 added; 28/7/16: 39.880 added; 1/12/16: 80%->100
- 1048: Mar 2015: WID: SP-140879->SP-150164. Name clarified. 5/5/15: TR number added; June2015: Compl:0%->5, WID updated; Aug2015: 5%->15; 07/09/15: 15%->40; 7/12/15: 40%->80, FCD: 12/15->03/16; 7/3/16: 80%->85
- 1049: SP#65 completion 09/14=>12/14. Exception in SP-140502. TS 22.179v100 for Information. Completed. Mar 15: WID: SP-140879->SP-150164. 6/15: WID updated
- 1050: June2015: added as per SP-150356; June2015: Compl:0%->15. 31 July: Rapporteur corrected. 3/8/15: name aligned to the WID; 07/09/15: 15%->50; 07/09/15: 50%->85. 15/09/15: FCD: 09/15->12/15; 7/3/16: 85%->100
- 1051: Mar 2015: WID: SP-140879->SP-150164. Name clarified. FCD: 03/2016->12/2015; June2015: Compl:5%->15, WID updated. 7/9/15: TS number added; 7/12/15: 15%->60. FCD -> 03/16, ES in SP-150729; 7/3/16: 60%->85; 1/12/16: 85%->98; 6/3/17: 98%->100
- 1052: Mar 2015: WID: SP-140879->SP-150164. Name clarified. FCD: 03/2016->12/2015; June2015: Compl:0%->5, WID updated; Aug2015: 5%->15; 07/09/15: 15%->40. ES in SP-150663; 7/3/16: 40%->85
- 1053: 7/12/15: WID:CP-150587->CP-150793; 28/1/16: 24.384 added;
- 1054: 7/12/15: WID:CP-150587->CP-150793; 7/3/16: WID:CP-150863->CP-160160; 5/12/16: WID:CP-160160->CP-160817
- 1055: Proposed by Atle after some talks with several interested parties; 7/12/15: 0%->50; 7/12/15: WID:CP-150587->CP-150863. FCD->03/16, ES in CP-150721; 7/3/16: 50%->100; 7/3/16: WID:CP-150863->CP-160160; 5/12/16: WID:CP-160160->CP-160817
- 1056: Proposed by Atle after some talks with several interested parties; 7/12/15: 0%->75; 7/12/15: WID:CP-150587->CP-150863. FCD->03/16, ES in CP-150721; 7/3/16: 75%->100; 7/3/16: WID:CP-150863->CP-160160; 5/12/16: WID:CP-160160->CP-160817
- 1057: Proposed by Atle after some talks with several interested parties; 7/12/15: 0%->80; 7/12/15: WID:CP-150587->CP-150863. FCD->03/16, ES in CP-150721; 7/3/16: 80%->100; 7/3/16: WID:CP-150863->CP-160160; 5/12/16: WID:CP-160160->CP-160817
- 1058: Proposed by Atle after some talks with several interested parties; 7/12/15: 0%->85; 7/12/15: WID:CP-150587->CP-150863. FCD->03/16, ES in CP-150721; 7/3/16: 85%->100; 7/3/16: WID:CP-150863->CP-160160; 5/12/16: WID:CP-160160->CP-160817
- 1059: Proposed by Atle after some talks with several interested parties; 7/12/15: 0%->50; 7/12/15: WID:CP-150587->CP-150863. FCD->03/16, ES in CP-150721; 7/3/16: 50%->100; 7/3/16: WID:CP-150863->CP-160160; 5/12/16: WID:CP-160160->CP-160817
- 1060: Proposed by Atle after some talks with several interested parties; 7/12/15: 0%->75; 7/12/15: WID:CP-150587->CP-150863. FCD->03/16, ES in CP-150721; 7/3/16: 75%->100; 7/3/16: WID:CP-150863->CP-160160; 5/12/16: WID:CP-160160->CP-160817
- 1061: Proposed by Atle after some talks with several interested parties; 7/12/15: WID:CP-150587->CP-150863. FCD->03/16, ES in CP-150721; 7/3/16: 0%->100; 7/3/16: WID:CP-150863->CP-160160; 5/12/16: WID:CP-160160->CP-160817
- 1062: Proposed by Atle after some talks with several interested parties; 7/12/15: 0%->10; 7/12/15: WID:CP-150587->CP-150863. FCD->03/16, ES in CP-150721; 7/3/16: 10%->100. Name changed from "Configuration management"; 7/3/16: WID:CP-150863->CP-160160; 5/12/1
- 1063: Introduced from CT1 WP update in 03/16; 7/3/16: WID:CP-150863->CP-160160; 5/12/16: WID:CP-160160->CP-160817
- 1064: 7/12/15: 0%->70; 7/12/15: WID:CP-150587->CP-150863. FCD -> 03/16, ES in CP-150643; 7/3/16: 70%->100; 7/3/16: WID:CP-150863->CP-160160; 5/12/16: WID:CP-160160->CP-160817
- 1065: 7/12/15: WID:CP-150587->CP-150863. FCD -> 03/16, ES in CP-150864; 7/3/16: 0%->100; 7/3/16: WID:CP-150863->CP-160160; 5/12/16: WID:CP-160160->CP-160817
- 1066: 7/12/15: WID:CP-150587->CP-150863. FCD -> 03/16, ES in CP-150866; 7/3/16: 0%->100; 7/3/16: WID:CP-150863->CP-160160; 5/12/16: WID:CP-160160->CP-160817
- 1067: 5/12/16: WID:CP-160160->CP-160817
- 1068: 12/15: TR # added; 7/12/15: 0%->60; 7/12/15: WID:CP-150500->CP-150794. FCD -> 03/16, ES in CP-150722; 7/3/16: 60%->100
- 1069: 6/1/17: acronym changed from "MCPTT-UEConTest" ; 21/3/17: Compl:0%->5%; 21/3/17: 36.579-5 added;...; ;...; ;...;...
- 1070: Mar 2015: transferred to SA6. Was 06/14 to 06/15. 6/15: WID updated
- 1071: Mar 2015: WID: SP-140879->SP-150164. Name clarified.6/15: WID updated. 7/15: removed since duplicates 640143 and 660054 (only 640143 is kept)
- 1072: Mar 2015: WID: SP-140879->SP-150164. Name clarified. 6/15: WID updated. 31 July: deleted since duplicates 640143 and 670031 (only 640143 is kept)

| ID | WBS | Task | Duration | Start | Finish | Complete | Baseline start | Baseline finish | Baseline duration | Constraint | Resources | Work | Actual work | Acronym | PCG approved | Impacted TSs and TRs | WI rapporteur name | WI rapporteur e-mail | Release | TSG approved | MCC resp | Status Report | Special Focus Doc | Acronym_3GU_Export |
| --- | --- | --- | --- | --- | --- | --- | --- | --- | --- | --- | --- | --- | --- | --- | --- | --- | --- | --- | --- | --- | --- | --- | --- | --- |
| 1073 | 427 | **MBMS Extensions and Profiling** | 202d? | 2015-03-05 A | 2015-12-11 A | 100% |  |  |  |  | S4 | 4848h | 4848h | MEPRO | 34 | 26.346, new TR 26.852 | Imed Bouazizi, Samsung and Thorsten Lohmar, Ericsson | i.bouazizi@samsung.com, thorsten.lohmar@ericsson.com | Rel-13 | 67 |  |  |  |  |
| 1074 | 427.1 | TR on Profiling and Extensions of MBMS | 202d? | 2015-03-05 A | 2015-12-11 A | 100% |  |  |  | finish no earlier than 2015-12-11 | S4 | 1616h | 1616h | MEPRO | 34 | new TR 26.852 | Imed Bouazizi, Samsung and Thorsten Lohmar, Ericsson | i.bouazizi@samsung.com, thorsten.lohmar@ericsson.com | Rel-13 | 67 |  |  |  |  |
| 1075 | 427.2 | Specification of MBMS Extensions and Profiling | 202d? | 2015-03-05 A | 2015-12-11 A | 100% |  |  |  | start no earlier than 2015-03-05 | S4 | 1616h | 1616h | MEPRO | 34 | 26.346 | Imed Bouazizi, Samsung and Thorsten Lohmar, Ericsson | i.bouazizi@samsung.com, thorsten.lohmar@ericsson.com | Rel-13 | 67 |  |  |  |  |
| 1076 | 428 | **Isolated E-UTRAN Operation for Public Safety** | 529d? | 2014-03-07 A | 2016-03-11 A | 100% | 2014-03-07 | 2014-09-17 | 139d? |  | S1 | 8600h | 8600h | IOPS | 32 | New TS 22.346 | General Dynamics | paul.piggin@gd-broadband.com | Rel-13 | 63 | Alain | S1-143304 | Public Safety (A-A) | IOPS |
| 1077 | 428.1 | Stage 1 fo Isolated E-UTRAN Operation for Public Safety | 140d? | 2014-03-07 A | 2014-09-17 A | 100% | 2014-03-07 | 2014-09-17 | 139d? | finish no earlier than 2014-09-17 | S1 | 1120h | 1120h | IOPS | 32 | New TS 22.346 | General Dynamics | paul.piggin@gd-broadband.com | Rel-13 | 63 | Alain | S1-143304 | Public Safety (A-A) | IOPS |
| 1078 | 428.2 | Stage 2 for Isolated E-UTRAN Operation for Public Safety | 140d? | 2015-06-18 A | 2015-12-30 A | 100% | 2014-03-07 | 2014-09-17 | 139d? | start no earlier than 2015-06-18 | S2 | 1120h | 1120h | IOPS | 32 | 23.401 | Phil Young | phil.young@gd-broadband.com | Rel-13 | 63 | Alain |  | Public Safety (A-A) | IOPS |
| 1079 | 428.3 | Security aspects for Isolated E-UTRAN Operation for Public Safety | 76d? | 2015-09-16 A | 2015-12-30 A | 100% | 2014-03-07 | 2014-09-17 | 139d? | start no earlier than 2015-09-16 | S3 | 608h | 608h | IOPS | 32 | TS 33.401 | General Dynamics | paul.piggin@gd-ms.uk | Rel-13 | 63 | Alain |  | Public Safety (A-A) | IOPS |
| 1080 | 428.4 | **CT aspects for IOPS** | 95d? | 2015-11-02 A | 2016-03-11 A | 100% |  |  |  |  | C6 | 1520h | 1520h | IOPS-CT | 36 |  | Heiko Kruse, Morpho Cards GmbH | heiko.kruse@mrpho.com | Rel-13 | 70 |  |  |  |  |
| 1081 | 428.4.1 | CT6 aspects for IOPS | 95d? | 2015-11-02 A | 2016-03-11 A | 100% |  |  |  | finish no earlier than 2016-03-11 | C6 | 760h | 760h | IOPS-CT | 36 | 31.102 | Heiko Kruse, Morpho Cards GmbH | heiko.kruse@mrpho.com | Rel-13 | 70 |  |  |  |  |
| 1082 | 429 | Service Requirements Maintenance for Group Communication System Enablers for LTE | 67d? | 2014-06-18 A | 2014-09-17 A | 100% | 2014-06-18 | 2014-09-17 | 66d? | finish no earlier than 2014-09-17 | S1 | 536h | 536h | SRM_GCSE_LTE | 33 | 22.468 | Nokia Networks | Juergen.Merkel@nsn.com | Rel-13 | 64 |  | S1-143307 | Public Safety (A-A) | SRM_GCSE_LTE |
| 1083 | 430 | Enhanced Calling Information Presentation | 330d? | 2014-09-15 A | 2015-12-16 A | 100% | 2013-12-11 | 2014-09-17 | 201d? | finish no earlier than 2015-12-16 | S1 | 2640h | 2640h | ECIP | 32 | 22.182 (CAT), 22.183 (CRS) | China Mobile | LI Xiaofan (lixiaofan@chinamobile.com | Rel-13 | 62 | Alain | S1-143311 |  | ECIP |
| 1084 | 431 | **Flexible Mobile Service Steering** | 392d? | 2014-09-15 A | 2016-03-11 A | 100% | 2013-12-11 | 2014-09-17 | 202d? |  | S1; S2 | 7943.76h | 6367.76h | FMSS | 33 | 22.101 | China Mobile | Lu Lu (lulu@chinamobile.com) | Rel-13 | 65 | Alain | S1-143310 |  | FMSS |
| 1085 | 431.1 | Stage 1 for Flexible Mobile Service Steering | 3d? | 2014-09-15 A | 2014-09-17 A | 100% | 2013-12-11 | 2014-09-17 | 202d? | start no earlier than 2014-09-15 | S1 | 23.85h | 23.85h | FMSS-ST1 | 33 | 22.101 | China Mobile | Lu Lu (lulu@chinamobile.com) | Rel-13 | 65 | Alain | S1-143310 |  | FMSS |
| 1086 | 431.2 | Flexible Mobile Service Steering TR Phase | 134d? | 2014-12-12 A | 2015-06-17 A | 100% |  |  |  | finish no earlier than 2015-06-17 | S2 | 1072h | 1072h | FMSS-SA2TR | 34 | 23.718 | Lu Lu, China Mobile | lulu@chinamobile.com | Rel-13 | 66 |  |  |  |  |
| 1087 | 431.3 | Flexible Mobile Service Steering - Stage 2 | 134d? | 2014-12-12 A | 2015-06-17 A | 100% |  |  |  | start no earlier than 2014-12-12 | S2 | 1072h | 1072h | FMSS-SA2 | 34 |  | Lu Lu, China Mobile | lulu@chinamobile.com | Rel-13 | 66 |  |  |  |  |
| 1088 | 431.4 | CT3 Aspect of Flexible Mobile Service Steering | 133d? | 2015-09-09 A | 2016-03-11 A | 100% |  |  |  | finish no earlier than 2016-03-11 | C3 | 1064h | 1064h | FMSS-CT | 35 | 29.abc, 29.212, 29.213 | ZTE,Zhou Xiaoyun | zhou.xiaoyun@zte.com.cn | Rel-13 | 69 |  |  |  |  |
| 1089 | 432 | GERAN UTRAN Sharing Enhancements | 63d? | 2014-09-19 A | 2014-12-12 A | 100% |  |  |  | finish no earlier than 2014-12-12 | S1 | 504h | 504h | GUSH | 33 | 22.101 | Telefónica | chris.friel@telefonica.com | Rel-13 | 65 |  | SP-140515 |  | GUSH |
| 1090 | 433 | **Application specific Congestion control for Data Communication** | 456d? | 2014-06-18 A | 2016-03-11 A | 100% | 2014-06-18 | 2014-09-17 | 66d? |  | S1; C1 | 17920h | 14808h | ACDC | 33 | 22.011 | NTT DOCOMO | Atsushi Minokuchi (minokuchi@nttdocomo.co.jp) | Rel-13 | 64 |  | S1-143305 |  | ACDC |
| 1091 | 433.1 | Stage 1 for Application specific Congestion control for Data Communication | 67d? | 2014-06-18 A | 2014-09-17 A | 100% | 2014-06-18 | 2014-09-17 | 66d? | finish no earlier than 2014-09-17 | S1 | 536h | 536h | ACDC-ST1 | 33 | 22.011 | NTT DOCOMO | Atsushi Minokuchi (minokuchi@nttdocomo.co.jp) | Rel-13 | 64 |  | S1-143305 |  | ACDC |
| 1092 | 433.2 | **Stage 3 for Application specific Congestion control for Data Communication** | 332d? | 2014-12-04 A | 2016-03-11 A | 100% |  |  |  |  | C1 | 7472h | 7472h | ACDC-CT | 34 | TS 24.105, 24.301, 24.008, 27.007, 31.102 | Kim, Jaehyun, LGE | jaehyun7.kim@lge.com | Rel-13 | 66 |  |  |  |  |
| 1093 | 433.2.1 | CT1 part of Stage 3 for Application specific Congestion control for Data Communication | 270d? | 2014-12-04 A | 2015-12-16 A | 100% |  |  |  | finish no earlier than 2015-12-16 | C1 | 2160h | 2160h | ACDC-CT | 34 | 24.105, 24.301, 24.008, 27.007, 23.122 | Kim, Jaehyun, LGE | jaehyun7.kim@lge.com | Rel-13 | 66 |  |  |  |  |
| 1094 | 433.2.2 | CT6 part of Stage 3 for Application specific Congestion control for Data Communication | 332d? | 2014-12-04 A | 2016-03-11 A | 100% |  |  |  | finish no earlier than 2016-03-11 | C6 | 2656h | 2656h | ACDC-CT | 34 | 31.102 | Kim, Jaehyun, LGE | jaehyun7.kim@lge.com | Rel-13 | 66 |  |  |  |  |
| 1095 | 433.3 | **RAN aspects of Application specific Congestion control for Data Communication** | 197d? | 2015-03-16 A | 2015-12-15 A | 100% |  |  |  |  | R2 | 3152h | 3152h | ACDC-RAN | 34 |  | LG Electronics |  | Rel-13 | 67 |  |  |  |  |
| 1096 | 433.3.1 | Core part: RAN aspects of Application specific Congestion control for Data Communication | 197d? | 2015-03-16 A | 2015-12-15 A | 100% |  |  |  | finish no earlier than 2015-12-15 | R2 | 1576h | 1576h | ACDC-RAN-Core | 34 |  | LG Electronics |  | Rel-13 | 67 |  | RP-151275 |  |  |

Notes:
- 1073: 1/4/15: TS number added; 14/09/15: WID:SP-150099->SP-150439
- 1074: 8/4/15: line added; June2015: Compl:0%->10; Aug2015: 10%->15; 07/09/15: 15%->40; 14/09/15: WID:SP-150099->SP-150439; 7/12/15: 40%->100
- 1075: 8/4/15: line added; June2015: Compl:0%->10; Aug2015: 10%->15; 07/09/15: 15%->40; 14/09/15: WID:SP-150099->SP-150439; 7/12/15: 40%->100
- 1076: SP#65 completed. TS 22.346v100 for 1-step Approval. Triggered by Rel-13 TR 22.897 (FS_IOPS); 14/09/15: WID:SP 150358->SP-150463
- 1077: SP#65 completed. TS 22.346v100 for 1-step Approval. Triggered by Rel-13 TR 22.897 (FS_IOPS); 14/09/15: WID:SP 150358->SP-150463
- 1078: 07/09/15: 0%->100; 14/09/15: WID:SP 150358->SP-150463
- 1079: 07/09/15: 0%->100; 11/12/15: 0%->100
- 1081: ES in CP-150837; 7/3/16: 0%->100
- 1082: SP#65 completed. Some Rel-12 service reqs have no Stage 2/3 implementation
- 1083: SP#65 approved WID & completed. Triggered by Rel-13 TR 22.810. Linked to Multimedia Telephony Service for IMS (UID_7038), Customized Alerting Tone (CAT) UID_370028, Customized Ringing Signal (CRS) UID_380067. 31/07/15: 100%
- 1084: SP#65 WID approved & completed. Triggered by Rel-13 TR 22.808 (FS_FMSS)
- 1085: SP#65 WID approved & completed. Triggered by Rel-13 TR 22.808 (FS_FMSS). Dec.14: moved from Feature to S1 BB
- 1086: 3/3: TR number added.Mar15: 15->20%; June2015: Compl:20%->85; 07/09/15: 85%->100
- 1087: 07/09/15: 0%->90; 07/09/15: 90%->100
- 1088: 07/09/15: 0%->20; 14/09/15: WID:CP-150488->CP-150577; 7/12/15: 20%->90; 7/12/15: WID:CP-150577->CP-150799. FCD -> 03/16. ES in CP-150646; 7/3/16: 90%->100
- 1089: SP#65 exception in SP-140515. Triggered by TR 22.852 (FS_RSE and FS_GUSH). Completed.
- 1090: SP#65 completed. Triggered by Rel-13 Study TR 22.806
- 1091: Results from MCC Split of the SA1 feature into F+BB for stage 1
- 1092: Presented at CT#66. June 2015: FCD: June->Dec 2015, WID: CP-140999-> CP-150282
- 1093: Presented at CT#66; June2015: Compl:0%->10. June 2015: FCD: June->Dec 2015, WID: CP-140999-> CP-150282; 07/09/15: 5%->70; 7/12/15: 70%->100
- 1094: Presented at CT#66. June 2015: FCD: June->Dec 2015, WID: CP-140999-> CP-150282. 12/15: FCD -> 03/16, ES in CP-150838; 7/3/16: 0%->100
- 1096: 03/07/15: Compl:0%->25% 03/07/15: WID: RP-150512->RP-150662 03/07/15: Stat Rep: ->RP-150661 29/09/15: Compl:25%->70% 29/09/15: Stat Rep: RP-150661->RP-151275; 1/1/16: Compl:70%->100%

| ID | WBS | Task | Duration | Start | Finish | Complete | Remaining | Baseline start | Baseline finish | Baseline duration | Total slack | Constraint | Resources | Work | Actual work | Acronym | PCG approved | WI rapporteur name | WI rapporteur e-mail | Release | TSG approved | MCC resp | Acronym_3GU_Export | PCG stopped | TSG stopped | Status Report |
| --- | --- | --- | --- | --- | --- | --- | --- | --- | --- | --- | --- | --- | --- | --- | --- | --- | --- | --- | --- | --- | --- | --- | --- | --- | --- | --- |
| 1097 | 434 | **User Plane Congestion management** | 667d? | 2012-09-12 A | 2015-03-18 A | 100% |  | 2012-02-02 | 2015-06-17 | 890d? |  |  | S1; S2; C3; C4 | 39368h | 39368h | UPCON | 29 | KDDI | Eriko Yoshida (er-yoshida@kddi.com) | Rel-13 | 57 | Alain | UPCON |  |  |  |
| 1098 | 434.1 | Stage 1 for User Plane Congestion management | 129d? | 2012-09-12 A | 2013-03-06 A | 100% |  | 2012-02-02 | 2013-03-06 | 289d? |  | start no earlier than 2012-09-12 | S1 | 1032h | 1032h | UPCON-ST1 | 29 | KDDI | Eriko Yoshida (er-yoshida@kddi.com) | Rel-13 | 57 | Alain |  |  |  |  |
| 1099 | 434.2 | TR on Stage 2 for User Plane Congestion management | 595d? | 2012-12-12 A | 2015-03-18 A | 100% |  | 2012-12-12 | 2014-12-10 | 525d? |  | finish no earlier than 2015-03-18 | S2 | 4760h | 4760h | UPCON-SA2TR | 30 | Allot | Alla Goldner (agoldner@allot.com) | Rel-13 | 58 | Maurice |  |  |  |  |
| 1100 | 434.3 | Deleted - Stage 2 for User Plane Congestion management | 261d? | 2012-12-19 A | 2013-12-11 A | 100% |  | 2012-12-19 | 2013-12-11 | 261d? |  | finish no earlier than 2013-12-11 | S2 | 2088h | 2088h | UPCON-SA2Del | 30 | NEC | andreas.maeder@neclab.eu | Rel-13 | 58 | Maurice |  | PCG-32 | SP-62 |  |
| 1101 | 434.4 | **BB1: RAN Downlink Traffic Differentiation, Congestion Detection and Reporting** | 269d? | 2014-03-07 A | 2015-03-13 A | 100% |  | 2014-03-07 | 2015-06-17 | 334d? |  |  | S2 | 10048h | 10048h | UPCON-DOTCON | 32 | Allot | Alla Goldner (agoldner@allot.com) | Rel-13 | 63 | Maurice | UPCON-DOTCON |  |  |  |
| 1102 | 434.4.1 | Stage 2 for RAN Downlink Traffic Differentiation, Congestion Detection and Reporting | 201d? | 2014-03-07 A | 2014-12-12 A | 100% |  | 2014-03-07 | 2015-06-17 | 334d? |  | finish no earlier than 2014-12-12 | S2 | 1608h | 1608h | UPCON-DOTCON-SA2 | 32 | Allot | Alla Goldner (agoldner@allot.com) | Rel-13 | 63 | Maurice |  |  |  |  |
| 1103 | 434.4.2 | **CT aspects of User Plane Congestion Management for BB1** | 262d? | 2014-03-18 A | 2015-03-13 A | 100% |  |  |  |  |  |  | C3 | 6288h | 6288h | UPCON-DOTCON-CT | 33 | Huawei | Xia Haitao (xiahaitao@huawei.com) | Rel-13 | 65 |  | UPCON-DOTCON-CT |  |  |  |
| 1104 | 434.4.2.1 | CT3 part of CT aspects of User Plane Congestion Management for BB1 | 262d? | 2014-03-18 A | 2015-03-13 A | 100% |  |  |  |  |  | finish no earlier than 2015-03-13 | C3 | 2096h | 2096h | UPCON-DOTCON-CT | 33 | Huawei | Xia Haitao (xiahaitao@huawei.com) | Rel-13 | 65 |  |  |  |  |  |
| 1105 | 434.4.2.2 | CT4 part of CT aspects of User Plane Congestion Management for BB1 | 262d? | 2014-03-18 A | 2015-03-13 A | 100% |  |  |  |  |  | finish no earlier than 2015-03-13 | C4 | 2096h | 2096h | UPCON-DOTCON-CT | 33 | Huawei | Xia Haitao (xiahaitao@huawei.com) | Rel-13 | 65 |  |  |  |  |  |
| 1106 | 434.5 | Deleted - BB2: Application and Content Prioritization | 140d? | 2014-03-07 A | 2014-09-17 A | 100% |  | 2014-03-07 | 2015-06-17 | 334d? |  | finish no earlier than 2014-09-17 | S2 | 1120h | 1120h | UPCON-CONDEL | 32 | Allot | Alla Goldner (agoldner@allot.com) | Rel-13 | 63 | Maurice | UPCON-CON | PCG-33 | SP-65 |  |
| 1107 | 434.6 | Deleted - BB3: Uplink traffic and attended/unattended traffic | 140d? | 2014-03-07 A | 2014-09-17 A | 100% |  | 2014-03-07 | 2015-06-17 | 334d? |  | finish no earlier than 2014-09-17 | S2 | 1120h | 1120h | UPCON-TRAFDEL | 32 | Allot | Alla Goldner (agoldner@allot.com) | Rel-13 | 63 | Maurice | UPCON-TRAF | PCG-33 | SP-65 |  |
| 1108 | 435 | **Media Handling Aspects of IMS-based Telepresence** | 660d? | 2014-09-09 A | 2017-03-15 | 79% | 136.04d? |  |  |  | 848d |  | S4 | 20696h | 14892.8h | IMS_TELEP_S4 | 33 | Intel | ozgur.oyman@intel.com | Rel-13 | 65 |  | IMS_TELEP_S4 |  |  |  |
| 1109 | 435.1 | TR on Media Handling Aspects of IMS-based Telepresence | 269d? | 2014-09-09 A | 2015-09-16 A | 100% |  |  |  |  |  | finish no earlier than 2015-09-16 | S4 | 2152h | 2152h | IMS_TELEP_S4 | 33 | Intel | ozgur.oyman@intel.com | Rel-13 | 65 |  |  |  |  |  |
| 1110 | 435.2 | Specification on Media Handling Aspects of IMS-based Telepresence | 334d? | 2014-09-09 A | 2015-12-16 A | 100% |  |  |  |  |  | finish no earlier than 2015-12-16 | S4 | 2672h | 2672h | IMS_TELEP_S4 | 33 | Intel | ozgur.oyman@intel.com | Rel-13 | 65 |  |  |  |  |  |
| 1111 | 435.3 | (IETF) CLUE Protocol (draft-ietf-clue-protocol) | 331d? | 2015-12-10 A | 2017-03-15 | 60% | 132.4d? |  |  |  | 848d | finish no earlier than 2017-03-15 | S4-IETF | 2648h | 1588.8h | IMS_TELEP_S4 | 36 | Intel | ozgur.oyman@intel.com | Rel-13 | 71 |  |  |  |  |  |
| 1112 | 435.4 | (IETF) Mapping RTP streams to CLUE media captures (draft-ietf-clue-rtp-mapping) | 331d? | 2015-12-10 A | 2017-03-15 | 60% | 132.4d? |  |  |  | 848d | finish no earlier than 2017-03-15 | S4-IETF | 2648h | 1588.8h | IMS_TELEP_S4 | 36 | Intel | ozgur.oyman@intel.com | Rel-13 | 71 |  |  |  |  |  |
| 1113 | 435.5 | Deleted - (IETF) DTLS Encapsulation of SCTP Packets (draft-ietf-tsvwg-sctp-dtls-encaps) | 331d? | 2015-12-10 A | 2017-03-15 A | 100% |  |  |  |  |  | finish no earlier than 2017-03-15 | S4-IETF | 2648h | 2648h | IMS_TELEP_S4 | 36 | Intel | ozgur.oyman@intel.com | Rel-13 | 71 |  |  |  |  |  |
| 1114 | 435.6 | (IETF) Using Simulcast in SDP and RTP Sessions (draft-ietf-mmusic-sdp-simulcast) | 331d? | 2015-12-10 A | 2017-03-15 | 60% | 132.4d? |  |  |  | 848d | finish no earlier than 2017-03-15 | S4-IETF | 2648h | 1588.8h | IMS_TELEP_S4 | 36 | Ericsson | tomas.frankkila@ericsson.com | Rel-13 | 71 |  |  |  |  |  |
| 1115 | 436 | **RAN Sharing Enhancements** | 657d? | 2013-06-19 A | 2015-12-15 A | 100% |  | 2013-06-19 | 2013-12-11 | 129d? |  |  | S1; R3 | 16824h | 16824h | RSE | 31 | NEC | joerg.swetina@neclab.eu | Rel-13 | 60 | Alain | RSE |  |  |  |
| 1116 | 436.1 | Stage 1 for RAN Sharing Enhancements | 129d? | 2013-06-19 A | 2013-12-11 A | 100% |  | 2013-06-19 | 2013-12-11 | 129d? |  |  | S1 | 1032h | 1032h | RSE-SA1 | 31 | NEC | joerg.swetina@neclab.eu | Rel-13 | 60 | Alain |  |  |  |  |
| 1117 | 436.2 | **RAN aspects of RAN Sharing Enhancements for LTE** | 330d? | 2014-09-12 A | 2015-12-15 A | 100% |  | 2014-06-13 | 2015-06-12 | 261d? |  |  | R3 | 5280h | 5280h | RSE-RAN_LTE | 33 | NEC | Siva.Vakeesar@emea.nec.com | Rel-13 | 65 |  | RSE-RAN_LTE |  |  |  |
| 1118 | 436.2.1 | Core part: RAN aspects of RAN Sharing Enhancements for LTE | 330d? | 2014-09-12 A | 2015-12-15 A | 100% |  | 2014-06-13 | 2015-06-12 | 261d? |  | finish no earlier than 2015-12-15 | R3 | 2640h | 2640h | RSE-RAN_LTE-Core | 33 | NEC | Siva.Vakeesar@emea.nec.com | Rel-13 | 65 |  | RSE-RAN_LTE-Core |  |  | RP-151295 |
| 1119 | 437 | **Enhancements to WEBRTC interoperability** | 529d? | 2014-03-07 A | 2016-03-11 | 95% | 24.12d? | 2014-03-07 | 2015-06-17 | 334d? | 1112d |  | S1; S2; S3 | 27336h | 16630.6h | eWebRTCi | 32 | Alcatel-Lucent | betsy.covell@alcatel-lucent.com | Rel-13 | 63 | Alain | eWebRTCi |  |  |  |
| 1120 | 437.1 | Stage 1 for Enhancements to WEBRTC interoperability | 139d? | 2014-03-07 A | 2014-09-17 A | 100% |  | 2014-03-07 | 2014-09-17 | 139d? |  | finish no earlier than 2014-09-17 | S1 | 1112h | 1112h | eWebRTCi | 32 | Alcatel-Lucent | betsy.covell@alcatel-lucent.com | Rel-13 | 63 | Alain |  |  |  | S1-143303 |
| 1121 | 437.2 | TR on Stage 2 for Enhancements to WEBRTC interoperability | 196d? | 2014-06-19 A | 2015-03-18 A | 100% |  | 2014-06-18 | 2015-03-18 | 196d? |  | finish no earlier than 2015-03-18 | S2 | 1568h | 1568h | eWebRTCi | 33 | China Mobile | Yu Qing (yuqing@chinamobile.com) | Rel-13 | 64 |  |  |  |  |  |
| 1122 | 437.3 | Stage 2 for Enhancements to WEBRTC interoperability | 261d? | 2014-06-23 A | 2015-06-17 A | 100% |  | 2014-06-18 | 2015-06-17 | 261d? |  | finish no earlier than 2015-06-17 | S2 | 2088h | 2088h | eWebRTCi | 33 | China Mobile | Yu Qing (yuqing@chinamobile.com) | Rel-13 | 64 |  |  |  |  |  |
| 1123 | 437.4 | TR on Security for Enhancements to WEBRTC interoperability | 273d? | 2014-09-17 A | 2015-09-30 A | 100% |  |  |  |  |  | start no earlier than 2014-09-17 | S3 | 2184h | 2184h | eWebRTCi | 33 | Ericsson | vesa.lehtovirta@ericsson.com | Rel-13 | 65 |  |  |  |  |  |
| 1124 | 437.5 | Security for Enhancements to WEBRTC interoperability | 273d? | 2014-09-17 A | 2015-09-30 A | 100% |  |  |  |  |  | start no earlier than 2014-09-17 | S3 | 2184h | 2184h | eWebRTCi | 33 | Ericsson | vesa.lehtovirta@ericsson.com | Rel-13 | 65 |  |  |  |  |  |
| 1125 | 437.6 | (IETF) Session Traversal Utilities for NAT (STUN) Extension for Third Party Authorization (draft-ietf-tram-turn-third-party-authz) | 198d? | 2014-09-17 A | 2015-08-12 A | 100% |  |  |  |  |  | start no earlier than 2014-09-17 | S3-IET | 1584h | 1584h | eWebRTCi | 35 | Alcatel-Lucent |  | Rel-13 | 69 |  |  |  |  |  |

Notes:
- 1097: SP#65 updated WID SP-140153=>SP-140631 (BBII & BBIII stopped). Triggered by Rel-12 TR 22.805 Study on User Plane Congestion management (FS_UPCON) / Impacted TSs and TRs: Stage 1/2/3
- 1098: SP#63 moved to Rel-13 updated WID SP-120890=>SP-140153. SP#59 completed. Convert TR 22.805 clause 6 consolidated requirements to normative requirements in 22.101. 3/3/15: start date corrected (was Mar 12) / Impacted TSs and TRs: 22.101
- 1099: SP#65 updated WID SP-140153=>SP-140631. TR 23.705v100 for Information. Dec.14: 87->98%. Mar15: 100% / Impacted TSs and TRs: new TR 23.705
- 1100: SP#62 stopped at 0% completion / Impacted TSs and TRs: TBD
- 1101: SP#65 updated WID SP-140153=>SP-140631. IncludES in CP-150RAN Congestion Detection: , RAN Traffic Differentiation, RAN Congestion Reporting, CN Congestion Mitigation mechanisms, Dynamic Policy Control
- 1102: SP#65 updated WID SP-140153=>S2-142850 (added impacted specs). Dec.14: 70->100% only if RAN agrees to standardize the FPI / Impacted TSs and TRs: 23.060, 23.203, 23.401
- 1103: Stage 3; WID: CP-140734->CP-140929. June 2015: WID: CP-140929-> CP-150365. / Impacted TSs and TRs: Stage 3
- 1104: Dec.14: 0->60; WID: CP-140734->CP-140929. Mar.15: 60->95%; June2015: Compl:95%->100. WID: CP-140929-> CP-150365. / Impacted TSs and TRs: 29.201, 29.212, 29.213, 29.214, 29.215, 29.219, New TS 29.217 (PCC over Np)
- 1105: Dec.14: 0->20; WID: CP-140734->CP-140929. Mar. 15: 50%; June2015: Compl:50%->90. WID: CP-140929-> CP-150365.; 07/09/15: 90%->100 / Impacted TSs and TRs: 23.003, 29.303, New TS 29.405 (UPCON over Nq)
- 1106: SP#65 updated WID SP-140153=>SP-140631 (BBII & BBIII stopped). IncludES in CP-150Content specific UP prioritization (Video), Application specific UP prioritization / Impacted TSs and TRs: TBD
- 1107: SP#65 updated WID SP-140153=>SP-140631 (BBII & BBIII stopped). IncludES in CP-150Uplink Congestion Management, Un/Attended UE Information / Impacted TSs and TRs: TBD
- 1108: Can be seen as an "enhancement" of Rel-12 IMS-based Telepresence (IMS_TELEP) UID_530042. Mar. 15: 20%
- 1109: Dec.14: 0->10%. 8/4/15: 20%; June2015: Compl:20%->30; Aug2015: 30%->35; 07/09/15: 35%->60; 7/12/15: 60%->100 / Impacted TSs and TRs: New TR 26.9xy
- 1110: Dec.14: 0->10%. 8/4/15: 20%; June2015: Compl:20%->30; 07/09/15: 30%->60; 7/12/15: 60%->100 / Impacted TSs and TRs: New TS 26.1xy
- 1111: Impacted TSs and TRs: 26.22
- 1112: Impacted TSs and TRs: 26.22
- 1113: 22/3/18: 95%->100. 07/06/18: deleted as per SP-180260 / Impacted TSs and TRs: 26.22
- 1114: Impacted TSs and TRs: 26.114, 26.223
- 1115: Triggered by Rel-12 TR 22.852 Study on RAN Sharing Enhancements (FS_RSE)
- 1116: SP#62 completed / Impacted TSs and TRs: 22.101
- 1117: Triggered by TR 36.856 Study on RAN aspects of RAN Sharing Enhancements for LTE (FS_RSE-RAN_LTE) & SA1 22.101 Stage 1 / Impacted TSs and TRs: LTE
- 1118: ; CD:Mon 15/06/15->Tue 15/09/15; Stat Rep: -->RP-141891 1st Apr 15: Compl:15%->20% 1st Apr 15: Stat Rep: RP-141891->RP-150289 03/07/15: Compl:20%->75% 03/07/15: Stat Rep: RP-150289->RP-150875 29/09/15: Compl:75%->80% 29/09/15: CD:Tue 15/09/15->Tue 15/1 / Impacted TSs and TRs: 36.300, 36.413, 36.423
- 1119: SP#65 updated WID SP-14028=>SP-140630 (added SA3 part, SA1 change). Add enhanced interoperability support for WebRTC to Rel-12 Web Real Time Communication (WebRTC) Access to IMS. / Impacted TSs and TRs: Stage 1/2
- 1120: SP#65 completed. Updated WID SP-140286=>SP-140630 / Impacted TSs and TRs: 22.228
- 1121: SP#65 updated WID SP-14028=>SP-140630 (added SA3 part). Dec.14: 9->55%; June2015: Compl:55%->85; 07/09/15: 85%->100 / Impacted TSs and TRs: New TR 23.706
- 1122: SP#65 updated WID SP-14028=>SP-140630 (added SA3 part); June2015: Compl:0%->85; 07/09/15: 85%->100 / Impacted TSs and TRs: 23.228
- 1123: SP#65 updated WID SP-14028=>SP-140630 (added SA3 part). Dec.14: 0->20%, TR number added. 3/3/15: 30%.; June2015: Compl:30%->75; 11/12/15: 54%->100; 11/12/15: 100%->100 / Impacted TSs and TRs: New TR 33.872
- 1124: SP#65 updated WID SP-14028=>SP-140630 (added SA3 part). Dec.14: 0->20%; 11/12/15: 15%->100 / Impacted TSs and TRs: 33.203, 33.328
- 1125: TS 33.203 CR0235draft-ietf-tram-turn-third-party-authz; 7/3/16: 10%->100 / Impacted TSs and TRs: 33.203, RRC 7635 (was draft-ietf-tram-turn-third-party-authz)

| ID | WBS | Task | Type | Duration | Start | Finish | Complete | Remaining | Baseline start | Baseline finish | Baseline duration | Total slack | Constraint | Resources | Work | Actual work | Acronym | PCG approved | WI rapporteur name | WI rapporteur e-mail | Release | TSG approved | Impacted TSs and TRs | MCC resp | Acronym_3GU_Export | Special Focus Doc |
| --- | --- | --- | --- | --- | --- | --- | --- | --- | --- | --- | --- | --- | --- | --- | --- | --- | --- | --- | --- | --- | --- | --- | --- | --- | --- | --- |
| 1126 | 437.7 | **Stage 3 for Enhancements to WebRTC interoperability** |  | 135d? | 2015-09-07 A | 2016-03-11 | 84% | 21.09d? |  |  |  | 1112d |  | ct | 6048h | 4340h | eWebRTCi-CT | 35 | China Mobile, Song Yue | songyue@chinamobile.com | Rel-13 | 69 |  |  |  |  |
| 1127 | 437.7.1 | CT1 aspects 3 for Enhancements to WebRTC interoperability |  | 75d? | 2015-09-07 A | 2015-12-18 A | 100% |  |  |  |  |  | finish no earlier than 2015-12-18 | C1 | 600h | 600h | eWebRTCi-CT | 35 | China Mobile, Song Yue | songyue@chinamobile.com | Rel-13 | 69 | 24.371, 24.229 |  |  |  |
| 1128 | 437.7.2 | CT3 aspects for Enhancements to WebRTC interoperability |  | 135d? | 2015-09-07 A | 2016-03-11 A | 100% |  |  |  |  |  | finish no earlier than 2016-03-11 | C3 | 1080h | 1080h | eWebRTCi-CT | 35 | China Mobile, Song Yue | songyue@chinamobile.com | Rel-13 | 69 | 29.214 |  |  |  |
| 1129 | 437.7.3 | CT4 aspects for Enhancements to WebRTC interoperability |  | 135d? | 2015-09-07 A | 2016-03-11 A | 100% |  |  |  |  |  | finish no earlier than 2016-03-11 | C4 | 1080h | 1080h | eWebRTCi-CT | 35 | China Mobile, Song Yue | songyue@chinamobile.com | Rel-13 | 69 | 29.228, 23.334, 29.334, 23.008 |  |  |  |
| 1130 | 437.7.4 | (IETF) SDP-based Data Channel Negotiation (draft-ietf-mmusic-data-channel-sdpneg) |  | 69d? | 2015-12-08 A | 2016-03-11 | 75% | 17.25d? |  |  |  | 1112d | finish no earlier than 2016-03-11 | C1-IETF; SA4-IETF | 1104h | 828h | eWebRTCi-CT | 36 | Ericsson | christer.holmberg@ericsson.com | Rel-13 | 71 | 24.371, 24.229 |  |  |  |
| 1131 | 437.7.5 | (IETF) MSRP over Data Channels (draft-ietf-mmusic-msrp-usage-data-channel) |  | 69d? | 2015-12-08 A | 2016-03-11 | 75% | 17.25d? |  |  |  | 1112d | start no earlier than 2015-12-08 | C1-IETF | 552h | 414h | eWebRTCi-CT | 36 | Ericsson | christer.holmberg@ericsson.com | Rel-13 | 71 | 24.371, 24.229, 26.223 |  |  |  |
| 1132 | 437.7.6 | (IETF) A Language for Rules Describing JSON Content (draft-newton-json-content-rules) |  | 69d? | 2015-12-08 A | 2016-03-11 | 25% | 51.75d? |  |  |  | 1112d | start no earlier than 2015-12-08 | C3-IETF | 552h | 138h | eWebRTCi-CT | 36 | Ericsson | christer.holmberg@ericsson.com | Rel-13 | 71 | 24.371, 24.229, 26.223 |  |  |  |
| 1133 | 438 | **Improvements to CS/PS coordination in UTRAN/GERAN Shared Networks** |  | 573d? | 2014-03-07 A | 2016-05-12 A | 100% |  | 2014-03-07 | 2014-12-10 | 199d? |  |  | S2 | 9768h | 9768h | CSPS_Coord | 32 | Ericsson | roland.gustafsson@ericsson.com | Rel-13 | 63 | Stage 2 | Maurice | CSPS_Coord |  |
| 1134 | 438.1 | TR on Stage 2 for Improvements to CS/PS coordination in UTRAN/GERAN Shared Networks |  | 140d? | 2014-03-07 A | 2014-09-17 A | 100% |  | 2014-03-07 | 2014-12-10 | 199d? |  | finish no earlier than 2014-09-17 | S2 | 1120h | 1120h | CSPS_Coord-SA2TR | 32 | Ericsson | roland.gustafsson@ericsson.com | Rel-13 | 63 | New TR 23.704 | Maurice |  |  |
| 1135 | 438.2 | Stage 2 for Improvements to CS/PS coordination in UTRAN/GERAN Shared Networks |  | 201d? | 2014-03-12 A | 2014-12-12 A | 100% |  | 2014-03-07 | 2014-12-10 | 199d? |  | finish no earlier than 2014-12-12 | S2 | 1608h | 1608h | CSPS_Coord-SA2 | 32 | Ericsson | roland.gustafsson@ericsson.com | Rel-13 | 63 | 23.216, 23.251, 23.272 | Maurice |  |  |
| 1136 | 438.3 | RAN aspects for improvements to CS/PS coordination in GERAN Shared Networks |  | 307d? | 2015-03-11 A | 2016-05-12 A | 100% |  |  |  |  |  | finish no earlier than 2016-05-12 | G2 | 2456h | 2456h | CSPS_Coord_GERAN |  | Nicklas Johansson, Ericsson LM | Nicklas.Johansson@Ericsson.com | Rel-13 | 65 | 48.008, 48.018 |  |  |  |
| 1137 | 439 | **Enhancements to Proximity-based Services** |  | 788d? | 2013-03-18 A | 2016-03-11 A | 100% |  | 2014-06-18 | 2015-06-12 | 258d? |  |  | S1; S2; S3 | 30792h | 27152h | eProSe | 33 | Qualcomm | Eddy Hall (edhall@qti.qualcomm.com) | Rel-13 | 64 | Stage 1/2 |  | eProSe | Public Safety (A-A) |
| 1138 | 439.1 | Stage 1 for Enhancements to Proximity-based Services |  | 66d? | 2014-06-19 A | 2014-09-17 A | 100% |  | 2014-06-18 | 2014-09-17 | 66d? |  | finish no earlier than 2014-09-17 | S1 | 528h | 528h | eProSe-SA1 | 33 | Qualcomm | Eddy Hall (edhall@qti.qualcomm.com) | Rel-13 | 64 | 22.115, 22.278 |  |  | Public Safety (A-A) |
| 1139 | 439.2 | Stage 2 for Enhancements to Proximity-based Services - Extensions |  | 326d? | 2014-06-23 A | 2015-09-16 A | 100% |  | 2014-06-18 | 2015-06-12 | 258d? |  | finish no earlier than 2015-09-16 | S2 | 2608h | 2608h | eProSe-Ext-SA2 | 33 | Qualcomm | Haris Zisimopoulos (harisz@qti.qualcomm.com) | Rel-13 | 64 | 23.303, TBD |  | eProSe-Ext | Public Safety (A-A) |
| 1140 | 439.3 | TR on Stage 2 for Enhancements to Proximity-based Services - Extensions |  | 193d? | 2014-06-18 A | 2015-03-13 A | 100% |  | 2014-06-18 | 2015-03-13 | 193d? |  | finish no earlier than 2015-03-13 | S2 | 1544h | 1544h | eProSe-Ext-SA2TR | 33 | Qualcomm | Haris Zisimopoulos (harisz@qti.qualcomm.com) | Rel-13 | 64 | New TR 23.713 |  |  | Public Safety (A-A) |
| 1141 | 439.4 | Security for Enhancements to Proximity-based Services - Extensions |  | 388d? | 2014-09-19 A | 2016-03-11 A | 100% |  |  |  |  |  | finish no earlier than 2016-03-11 | S3 | 3104h | 3104h | eProSe-Ext-SA3 | 33 | Qualcomm | Adrian Escott (aescott@qti.qualcomm.com) | Rel-13 | 65 | 33.303 |  |  | Public Safety (A-A) |
| 1142 | 439.5 | **CT aspects of enhancements to Proximity-based** |  | 195d? | 2015-06-15 A | 2016-03-11 A | 100% |  |  |  |  |  |  | C1 | 7304h | 7304h | eProSe-Ext-CT | 35 | Lena Chaponniere | lguellec@qti.qualcomm.com | Rel-13 | 68 | 23.122, 24.301, 24.333, 24.334 |  |  |  |
| 1143 | 439.5.1 | CT1 aspects of enhancements to Proximity-based |  | 195d? | 2015-06-15 A | 2016-03-11 A | 100% |  |  |  |  |  | finish no earlier than 2016-03-11 | C1 | 1560h | 1560h | eProSe-Ext-CT | 35 | Lena Chaponniere | lguellec@qti.qualcomm.com | Rel-13 | 68 | 29.343 |  |  |  |
| 1144 | 439.5.2 | CT3 aspects of enhancements to Proximity-based |  | 133d? | 2015-06-15 A | 2015-12-16 A | 100% |  |  |  |  |  | start no earlier than 2015-06-15 | C3 | 1064h | 1064h | eProSe-Ext-CT | 35 | Lena Chaponniere | lguellec@qti.qualcomm.com | Rel-13 | 68 | 23.003, 23.008, 29.272, 29.344, 29.345 |  |  |  |
| 1145 | 439.5.3 | CT4 aspects of enhancements to Proximity-based |  | 195d? | 2015-06-15 A | 2016-03-11 A | 100% |  |  |  |  |  | finish no earlier than 2016-03-11 | C4 | 1560h | 1560h | eProSe-Ext-CT | 35 | Lena Chaponniere | lguellec@qti.qualcomm.com | Rel-13 | 68 | 31.102, 31.111 |  |  |  |
| 1146 | 439.5.4 | CT6 aspects of enhancements to Proximity-based |  | 195d? | 2015-06-15 A | 2016-03-11 A | 100% |  |  |  |  |  | finish no earlier than 2016-03-11 | C6 | 1560h | 1560h | eProSe-Ext-CT | 35 | Lena Chaponniere | lguellec@qti.qualcomm.com | Rel-13 | 68 | 31.102, 31.111 |  |  |  |
| 1147 | 439.6 | Study on Security for Proximity-based Services |  | 596d? | 2013-03-18 A | 2015-06-17 A | 100% |  | 2013-03-07 | 2014-09-17 | 401d? |  | finish no earlier than 2015-06-17 | S3 | 4768h | 4768h | FS_ProSe_Sec | 30 | Qualcomm | Adrian Escott (aescott@qti.qualcomm.com) | Rel-13 | 59 | 33.833 | Mirko | FS_ProSe_Sec | Public Safety (A-A) |
| 1148 | 439.7 | Note: Charging Aspects done in Rel-14 under CH14-Prose (UID 720049) | milestone | 0d? | 2015-06-17 A | 2015-06-17 A | 100% |  |  |  |  |  | start no earlier than 2015-06-17 | S5 |  |  | eProSe |  |  |  | Rel-13 |  |  |  |  |  |
| 1149 | 440 | **voice over E-UTRAN Paging Policy Differentiation** |  | 133d? | 2014-06-16 A | 2014-12-12 A | 100% |  | 2014-06-16 | 2014-12-10 | 128d? |  |  | S1; S2; C4; C1; C3 | 9244.75h | 9244.75h | voE_UTRAN_PPD | 33 | Alcatel-Lucent | (betsy.covell@alcatel-lucent.com) | Rel-13 | 64 | Stage 1/2 |  | voE_UTRAN_PPD |  |
| 1150 | 440.1 | Stage 1 for voice over E-UTRAN Paging Policy Differentiation |  | 3d? | 2014-06-16 A | 2014-06-18 A | 100% |  | 2014-06-16 | 2014-06-18 | 3d? |  | finish no earlier than 2014-06-18 | S1 | 24h | 24h | voE_UTRA-N_PPD-SA1 | 33 | Alcatel-Lucent | betsy.covell@alcatel-lucent.com | Rel-13 | 64 | 22.228, 22.278 |  |  |  |
| 1151 | 440.2 | Stage 2 for voice over E-UTRAN Paging Policy Differentiation |  | 128d? | 2014-06-18 A | 2014-12-12 A | 100% |  | 2014-06-18 | 2014-12-10 | 126d? |  | finish no earlier than 2014-12-12 | S2 | 1024h | 1024h | voE_UTRAN_PPD-SA2 | 33 | Alcatel-Lucent | laurent.thiebaut@alcatel-lucent.com | Rel-13 | 64 | 23.228, 23.401 |  |  |  |

Notes:
- 1126: 7/12/15: WID:CP-150498->CP-150790->CP-150767
- 1127: 7/12/15: 0%->100; 7/12/15: WID:CP-150498->CP-150790->CP-150767
- 1128: 7/12/15: WID:CP-150498->CP-150790->CP-150767. ES in CP-150644; 7/3/16: 0%->100
- 1129: 7/12/15: WID:CP-150498->CP-150790->CP-150767. ES in CP-150623; 7/3/16: 0%->100
- 1130: 7/3/16: Introduced by IETF updates
- 1131: 7/3/16: Introduced by IETF updates
- 1132: 7/3/16: Introduced by IETF updates
- 1133: Provide improvements to the solutions for CS/PS coordination in TS 23.251 to ensure that CS/PS coordination can be achieved for all mobility scenarios
- 1134: SP#65 completed. TR 23.704v200 for Approval
- 1135: Dec.14: 0->100%
- 1136: June2015: Compl:0%->35; 07/09/15: 35%->50, FCD:08/15->11/15; 7/12/15: 50%->95, FCD: 12/15->02/16. 02/03/16: FCD: 02/16->05/16; 13/6/16: 95%->100
- 1137: -
- 1138: SP#65 completed. Some Rel-12 ProSe service requirements have not been implemented at Stage 2/3 level. These are taken up in Rel-13 Stage 2/3 and need Stage 1 appropriate service requirements. No new service requirements are introduced.
- 1139: SP#65 updated WID SP-140385=>SP-140573 (added SA3 part). Mar15: WID: SP-140573 ->SP-150028; June2015: Compl:0%->30. FCD: June->Sept. 07/09/15: 24->70%; 07/09/15: 70%->90; 7/12/15: 90%->100
- 1140: SP#65 updated WID SP-140385=>SP-140573 (added SA3 part). Acronym corrected: eProSe-Ex-SA2TRt->eProSe-Ext-SA2TR. Mar15: 60% Mar15: WID: SP-140573 ->SP-150028; June2015: Compl:60%->90; 07/09/15: 90%->95; 07/09/15: 95%->100
- 1141: SP#65 updated WID SP-140385=>SP-140573 (added SA3 part). Acronym corrected: eProSe-Ex-SA3t->eProSe-Ext-SA3. Mar15: WID: SP-140573 ->SP-150028; 7/12/15: 0%->75; 10/12/15: FCD ->03/16, ES in SP-150714; 7/3/16: 75%->100
- 1143: 07/09/15: 0%->40; 7/12/15: 40%->90. FCD -> 03/16, ES in CP-150724; 7/3/16: 90%->100
- 1144: 07/09/15: 0%->60; 8/3/16: 60%->100
- 1145: 07/09/15: 0%->10; 7/12/15: 10%->80. FCD->03/16. ES in CP-150616; 7/3/16: 80%->100
- 1146: 7/12/15: FCD -> 03/16, ES in CP-150839. FCD->03/16. ES in CP-150616; 7/3/16: 0%->95; 8/3/16: 95%->100
- 1147: SP#65 updated WID SP-140300=>SP-140629 (Moved the TR phase to Rel-13 as a stand-alone Study). Completion 09/14=>06/15. SP#64 TR 33.833 v100 for Information. 4/3/15: 95%->70% (more topics to be included); June2015: Compl:70%->75; 7/12/15: 75%->95; 7/3/1
- 1149: -
- 1150: SP#64 approved WID & completed
- 1151: Architectural enhancements allowing a differentiated paging policy for IMS voice calls over E-UTRAN. Dec.14: 25->100%

| ID | WBS | Task | Duration | Start | Finish | Complete | Baseline start | Baseline finish | Baseline duration | Constraint | Resources | Work | Actual work | Acronym | PCG approved | WI rapporteur name | Release | TSG approved | Acronym_3GU_Export |
| --- | --- | --- | --- | --- | --- | --- | --- | --- | --- | --- | --- | --- | --- | --- | --- | --- | --- | --- | --- |
| 1152 | 440.3 | **CT aspects of voice over E-UTRAN Paging Policy Differentiation** | 63d? | 2014-09-16 A | 2014-12-09 A | 100% |  |  |  |  | C4; C1; C3 | 3024h | 3024h | voE_UTRAN_PPD-CT | 33 | Alcatel-Lucent | Rel-13 | 65 |  |
| 1153 | 440.3.1 | CT4 part of CT aspects of voice over E-UTRAN Paging Policy Differentiation | 63d? | 2014-09-16 A | 2014-12-09 A | 100% |  |  |  | finish no earlier than 2014-12-09 | C4 | 504h | 504h | voE_UTRAN_PPD-CT | 33 | Alcatel-Lucent | Rel-13 | 65 |  |
| 1154 | 440.3.2 | CT1 part of CT aspects of voice over E-UTRAN Paging Policy Differentiation | 63d? | 2014-09-16 A | 2014-12-09 A | 100% |  |  |  | finish no earlier than 2014-12-09 | C1 | 504h | 504h | voE_UTRAN_PPD-CT | 33 | Alcatel-Lucent | Rel-13 | 65 |  |
| 1155 | 440.3.3 | CT3 part of CT aspects of voice over E-UTRAN Paging Policy Differentiation | 63d? | 2014-09-16 A | 2014-12-09 A | 100% |  |  |  | finish no earlier than 2014-12-09 | C3 | 504h | 504h | voE_UTRAN_PPD-CT | 33 | Alcatel-Lucent | Rel-13 | 65 |  |
| 1156 | 441 | **IP Flow Mobility support for S2a and S2b Interfaces** | 524d? | 2014-06-18 A | 2016-06-15 A | 100% | 2014-06-18 | 2015-06-17 | 261d? |  | S2 | 15656h | 15656h | NBIFOM | 33 | Tricci So, ZTE | Rel-13 | 64 | NBIFOM |
| 1157 | 441.1 | TR for IP Flow Mobility support for S2a and S2b Interfaces | 193d? | 2014-06-18 A | 2015-03-13 A | 100% | 2014-06-18 | 2015-03-13 | 193d? | finish no earlier than 2015-03-13 | S2 | 1544h | 1544h | NBIFOM-SA2TR | 33 | Tricci So, ZTE | Rel-13 | 64 |  |
| 1158 | 441.2 | Stage 2 for IP Flow Mobility support for S2a and S2b Interfaces | 326d? | 2014-06-23 A | 2015-09-16 A | 100% | 2014-06-18 | 2015-06-17 | 261d? | finish no earlier than 2015-09-16 | S2 | 2608h | 2608h | NBIFOM-SA2 |  | Tricci So, ZTE | Rel-13 | 64 |  |
| 1159 | 441.3 | Charging Aspects of IP Flow Mobility support for S2a and S2b Interfaces (NBIFOM) | 196d? | 2015-09-16 A | 2016-06-15 A | 100% | 2014-06-18 | 2015-06-17 | 261d? | finish no earlier than 2016-06-15 | S5 | 1568h | 1568h | NBIFOM-CH | 35 | GUO Wenjie, ZTE | Rel-13 | 69 |  |
| 1160 | 441.4 | **CT aspects of IP Flow Mobility support for S2a and S2b Interfaces** | 195d? | 2015-06-15 A | 2016-03-11 A | 100% |  |  |  |  | C1 | 5744h | 5744h | NBIFOM-CT | 35 | Xingyue(Joy) Zhou, ZTECorporation | Rel-13 | 68 |  |
| 1161 | 441.4.1 | CT1 aspects of IP Flow Mobility support for S2a and S2b Interfaces | 195d? | 2015-06-15 A | 2016-03-11 A | 100% |  |  |  | finish no earlier than 2016-03-11 | C1 | 1560h | 1560h | NBIFOM-CT | 35 | Xingyue(Joy) Zhou, ZTECorporation. ES in 641 | Rel-13 | 68 |  |
| 1162 | 441.4.2 | CT3 aspects of IP Flow Mobility support for S2a and S2b Interfaces | 195d? | 2015-06-15 A | 2016-03-11 A | 100% |  |  |  | finish no earlier than 2016-03-11 | C3 | 1560h | 1560h | NBIFOM-CT | 35 | 680001Xingyue(Joy) Zhou, ZTECorporation. ES in 641 | Rel-13 | 68 |  |
| 1163 | 441.4.3 | CT4 aspects of IP Flow Mobility support for S2a and S2b Interfaces | 133d? | 2015-06-15 A | 2015-12-16 A | 100% |  |  |  | start no earlier than 2015-06-15 | C4 | 1064h | 1064h | NBIFOM-CT | 35 | Xingyue(Joy) Zhou, ZTECorporation | Rel-13 | 68 |  |
| 1164 | 442 | **Double Resource Reuse for Multiple Media Sessions** | 264d? | 2014-03-14 A | 2015-03-13 A | 100% | 2014-03-14 | 2015-03-13 | 261d? |  | S2 | 5952h | 5952h | DRuMS | 33 | Ericsson | Rel-13 | 64 | DRuMS |
| 1165 | 442.1 | Stage 2 for Double Resource Reuse for Multiple Media Sessions | 264d? | 2014-03-14 A | 2015-03-13 A | 100% | 2014-03-14 | 2015-03-13 | 261d? | finish no earlier than 2015-03-13 | S2 | 2088h | 2088h | DRuMS-SA2 | 33 | Ericsson | Rel-13 | 64 |  |
| 1166 | 442.2 | **CT aspects of Double Resource Reuse for Multiple Media Sessions** | 73d? | 2014-12-03 A | 2015-03-13 A | 100% |  |  |  |  | C3 | 1752h | 1752h | DRuMS-CT | 34 | Ericsson | Rel-13 | 66 |  |
| 1167 | 442.2.1 | CT1 aspects of Double Resource Reuse for Multiple Media Sessions | 73d? | 2014-12-03 A | 2015-03-13 A | 100% |  |  |  | start no earlier than 2014-12-03 | C1 | 584h | 584h | DRuMS-CT | 34 | Ericsson | Rel-13 | 66 |  |
| 1168 | 442.2.2 | CT3 aspects of Double Resource Reuse for Multiple Media Sessions | 73d? | 2014-12-03 A | 2015-03-13 A | 100% |  |  |  | start no earlier than 2014-12-03 | C3 | 584h | 584h | DRuMS-CT | 34 | Ericsson | Rel-13 | 66 |  |
| 1169 | 443 | Lawful Interception in the 3GPP Rel-13 | 656d? | 2014-06-18 A | 2016-12-15 A | 100% | 2014-06-18 | 2015-12-09 | 386d? | finish no earlier than 2016-12-15 | S3 | 5248h | 5248h | LI13 | 33 | PIDS, Alcatel-Lucent | Rel-13 | 64 | LI13 |
| 1170 | 444 | STOPPED - Study on Lawful Interception Service Evolution | 386d? | 2014-06-23 A | 2015-12-09 A | 100% | 2014-06-18 | 2015-12-09 | 386d? | finish no earlier than 2015-12-09 | S3 | 3088h | 3088h | FS_LISE | 33 | Alcatel-Lucent | Rel-13 | 64 | FS_LISE |
| 1171 | 445 | **Video enhancements by Region-Of-Interest information signalling** | 394d? | 2014-06-18 A | 2015-12-16 A | 100% | 2014-06-18 | 2015-06-17 | 261d? |  | S4 | 10016h | 10016h | ROI | 33 | Intel | Rel-13 | 64 | ROI |
| 1172 | 445.1 | SA4 aspects of Video enhancements by Region-Of-Interest information signalling | 329d? | 2014-06-18 A | 2015-09-16 A | 100% |  |  |  | finish no earlier than 2015-09-16 | S4 | 2632h | 2632h | ROI | 33 | Intel | Rel-13 | 64 |  |
| 1173 | 445.2 | **CT Aspects of Video Enhancements by Region-Of-Interest information signalling** | 133d? | 2015-06-15 A | 2015-12-16 A | 100% |  |  |  |  | C4 | 4256h | 4256h | ROI-CT | 35 | Vivek Gupta, Intel | Rel-13 | 68 |  |
| 1174 | 445.2.1 | CT1 Aspects of Video Enhancements by Region-Of-Interest information signalling | 133d? | 2015-06-15 A | 2015-12-16 A | 100% |  |  |  | start no earlier than 2015-06-15 | C1 | 1064h | 1064h | ROI-CT | 35 | Vivek Gupta, Intel | Rel-13 | 68 |  |
| 1175 | 445.2.2 | CT3 Aspects of Video Enhancements by Region-Of-Interest information signalling | 133d? | 2015-06-15 A | 2015-12-16 A | 100% |  |  |  | start no earlier than 2015-06-15 | C3 | 1064h | 1064h | ROI-CT | 35 | Vivek Gupta, Intel | Rel-13 | 68 |  |
| 1176 | 445.2.3 | CT4 Aspects of Video Enhancements by Region-Of-Interest information signalling | 133d? | 2015-06-15 A | 2015-12-16 A | 100% |  |  |  | start no earlier than 2015-06-15 | C4 | 1064h | 1064h | ROI-CT | 35 | Vivek Gupta, Intel | Rel-13 | 68 |  |

Notes:
- 1152: Stage 3 / Impacted TSs and TRs: Stage 3 / WI rapporteur e-mail: bruno.landais@alcatel-lucent.com
- 1153: Mar.15: 0->100% / Impacted TSs and TRs: 29.274, 29.281 / WI rapporteur e-mail: bruno.landais@alcatel-lucent.com
- 1154: Dec.14: 0->50%; 07/09/15: 50%->50; 7/12/15: 50%->100 / Impacted TSs and TRs: 24.229 / WI rapporteur e-mail: bruno.landais@alcatel-lucent.com
- 1155: Mar.15: 0->100% / Impacted TSs and TRs: 29.061 / WI rapporteur e-mail: bruno.landais@alcatel-lucent.com
- 1156: 06/15: WID: SP-140279->SP-150250 / Impacted TSs and TRs: Stage 2 / WI rapporteur e-mail: tso@zte.com.cn
- 1157: Revived the Rel-12 DRAFT TR 23.861 stopped at SP#59 (at 40% completion). Dec.14: 20->60%; June2015: Compl:60%->90, WID: SP-140279->SP-150250 / Impacted TSs and TRs: New TR 23.861 / WI rapporteur e-mail: tso@zte.com.cn
- 1158: June2015: Compl:0%->65, WID: SP-140279->SP-150250; 07/09/15: 52%->100 / Impacted TSs and TRs: 23.402, New TS 23.203 / WI rapporteur e-mail: tso@zte.com.cn
- 1159: 7/12/15: 0%->50. ES in SP-150710 (wrong UID mentioned in the ES); 7/3/16: 50%->85%, FCD:03/16->06/16; 13/6/16: 85%->100 / Impacted TSs and TRs: 32.251, 32.298, 32.299 / WI rapporteur e-mail: guo.wenjie1@zte.com.cn
- 1160: 14/09/15: WID:CP-150285->CP-150497; 7/12/15: WID:CP-150497->CP-150791->874 / Impacted TSs and TRs: 24.161 / WI rapporteur e-mail: zhou.xingyue@zte.com.cn
- 1161: 07/09/15: 0%->25; 14/09/15: WID:CP-150285->CP-150497; 7/12/15: 25%->75; 7/12/15: WID:CP-150497->CP-150791->874. FCD -> 03/16. ES in CP-150725; 7/3/16: 75%->100 / Impacted TSs and TRs: 24.301, 24.302, 24.244, 24.008 / WI rapporteur e-mail: zhou.xingyue@zte.com.cn
- 1162: 07/09/15: 0%->40; 14/09/15: WID:CP-150285->CP-150497; 7/12/15: 40%->95; 7/12/15: WID:CP-150497->CP-150791->874. FCD -> 03/16. ES in CP-150725; 7/3/16: 95%->100 / Impacted TSs and TRs: 29.212, 29.213, 29.214, 29.215 / WI rapporteur e-mail: zhou.xingyue@zte.com.cn
- 1163: 07/09/15: 0%->20; 14/09/15: WID:CP-150285->CP-150497; 7/12/15: 20%->100; 7/12/15: WID:CP-150497->CP-150791->874 / Impacted TSs and TRs: 29.274, 23.008 / WI rapporteur e-mail: zhou.xingyue@zte.com.cn
- 1164: - / Impacted TSs and TRs: Stage 2 / WI rapporteur e-mail: George.Foti@ericsson.com
- 1165: Dec.14: 49->95%. Mar15: 100% / Impacted TSs and TRs: 23.203, 23.228 / WI rapporteur e-mail: George.Foti@ericsson.com
- 1166: Impacted TSs and TRs: 24.229, 24.615, 24.610, 24.605, 29.212, 29.213, 29.214, 29.215
- 1167: 5/5/15: C3 corrected in C1; June2015: Compl:65%->90; 07/09/15: 90%->100 / Impacted TSs and TRs: 24.229, 24.615, 24.610, 24.605
- 1168: Mar.15: 65->95%; June2015: Compl:95%->100 / Impacted TSs and TRs: 29.212, 29.213, 29.214, 29.215 / WI rapporteur e-mail: Jan Holm
- 1169: SP#65 updated WID SP-140400=>SP-140578. 2/4/15: WID SP-140815->SP-150111; June2015: Compl:0%->10. WID: SP-150111->SP-150290; 14/09/15: WID:SP-150290->SP-150460; 7/12/15: 10%->15; 7/3/16: 13%->20; 7/3/16: WID:SP-150460->SP-160043; 19/9/16: 20%->60. FCD / Impacted TSs and TRs: 33.106, 33.107, 33.108 / WI rapporteur e-mail: Koen Jaspers (k.b.jaspers@minjus.nl), terry.jacobson@alcatel-lucent.com
- 1170: Linked to LI13 which defines existing LI service requirements in TS 33.106 as well as existing HI1, HI2 & HI3 reference points. 3/3/15: 0->5%; 7/12/15: 5%->10. Stoppped at 10% in March 2017.; 6/3/17: 10%->100 / Impacted TSs and TRs: 33.826 / WI rapporteur e-mail: terry.jacobson@alcatel-lucent.com
- 1171: Dec.14: 5->20%. Mar.15: 40%; 07/09/15: 43%->100 / Impacted TSs and TRs: 26.114 / WI rapporteur e-mail: ozgur.oyman@intel.com
- 1172: Created by MCC as the structure of the Feature get expanded to include CT aspects; June2015: Compl:40%->90, FCD: 06/15->09/15; Aug2015: Compl:90%->95 / Impacted TSs and TRs: 26.114 / WI rapporteur e-mail: ozgur.oyman@intel.com
- 1173: 14/09/15: WID:CP-150241->CP-150425 / WI rapporteur e-mail: vivek.g.gupta@intel.com
- 1174: 07/09/15: 100%->50; 14/09/15: WID:CP-150241->CP-150425; 7/12/15: 50%->100 / Impacted TSs and TRs: 24.229 / WI rapporteur e-mail: vivek.g.gupta@intel.com
- 1175: 07/09/15: 100%->10; 14/09/15: WID:CP-150241->CP-150425; 7/12/15: 10%->100 / Impacted TSs and TRs: 29.162 / WI rapporteur e-mail: vivek.g.gupta@intel.com
- 1176: 07/09/15: 100%->5; 14/09/15: WID:CP-150241->CP-150425; 7/12/15: 5%->100 / Impacted TSs and TRs: 23.334, 29.334, 29.238 / WI rapporteur e-mail: vivek.g.gupta@intel.com

| ID | WBS | Task | Duration | Start | Finish | Complete | Remaining | Baseline start | Baseline finish | Baseline duration | Total slack | Constraint | Resources | Work | Actual work | Acronym | PCG approved | WI rapporteur name | Release | TSG approved | Acronym_3GU_Export | Status Report | MCC resp |
| --- | --- | --- | --- | --- | --- | --- | --- | --- | --- | --- | --- | --- | --- | --- | --- | --- | --- | --- | --- | --- | --- | --- | --- |
| 1177 | 446 | **TV video profile** | 396d? | 2014-09-09 A | 2016-03-11 A | 100% |  |  |  |  |  |  | S4 | 9504h | 9504h | TVProf | 33 | Orange | Rel-13 | 65 | TVProf |  |  |
| 1178 | 446.1 | TR on TV video profile | 396d? | 2014-09-09 A | 2016-03-11 A | 100% |  |  |  |  |  | finish no earlier than 2016-03-11 | S4 | 3168h | 3168h | TVProf-SA4TR | 33 | Orange | Rel-13 | 65 |  |  |  |
| 1179 | 446.2 | Specification on TV video profile | 396d? | 2014-09-09 A | 2016-03-11 A | 100% |  |  |  |  |  | finish no earlier than 2016-03-11 | S4 | 3168h | 3168h | TVProf-SA4 | 33 | Orange | Rel-13 | 65 |  |  |  |
| 1180 | 447 | Enhanced LTE UE Delay test methods and requirements | 464d? | 2014-09-09 A | 2016-06-15 A | 100% |  |  |  |  |  | finish no earlier than 2016-06-15 | S4 | 3712h | 3712h | E_LTE_UED | 33 | Orange | Rel-13 | 65 | E_LTE_UED |  |  |
| 1181 | 448 | HTML5 Presentation Layer | 334d? | 2014-09-09 A | 2015-12-16 A | 100% |  |  |  |  |  | finish no earlier than 2015-12-16 | S4 | 2672h | 2672h | HTML5 | 33 | Samsung | Rel-13 | 65 | HTML5 |  |  |
| 1182 | 449 | **Support of EVS in 3G Circuit-Switched networks** | 396d? | 2014-09-09 A | 2016-03-11 A | 100% |  |  |  |  |  |  | S4; C4; C1; C3; R1; R2; R3 | 42757.6h | 24952h | EVSoCS | 33 | Qualcomm | Rel-13 | 65 | EVSoCS |  |  |
| 1183 | 449.1 | SA4 aspects of EVS in 3G Circuit-Switched networks | 396d? | 2014-09-09 A | 2016-03-11 A | 100% |  |  |  |  |  | finish no earlier than 2016-03-11 | S4 | 3168h | 3168h | EVSoCS-S4 | 33 | Qualcomm | Rel-13 | 65 | EVSoCS |  |  |
| 1184 | 449.2 | **CT aspects of EVS in 3G Circuit-Switched Networks** | 268d? | 2015-03-04 A | 2016-03-11 A | 100% |  |  |  |  |  |  | C4; C1; C3 | 12344h | 12344h | EVSoCS-CT | 34 | Qualcomm, Lena Chaponniere | Rel-13 | 67 |  |  |  |
| 1185 | 449.2.1 | CT1 aspects of EVS in 3G Circuit-Switched Networks | 203d? | 2015-03-04 A | 2015-12-11 A | 100% |  |  |  |  |  | finish no earlier than 2015-12-11 | C1 | 1624h | 1624h | EVSoCS-CT | 34 | Qualcomm, Lena Chaponniere | Rel-13 | 67 |  |  |  |
| 1186 | 449.2.2 | CT3 aspects of EVS in 3G Circuit-Switched Networks | 268d? | 2015-03-04 A | 2016-03-11 A | 100% |  |  |  |  |  | finish no earlier than 2016-03-11 | C3 | 2144h | 2144h | EVSoCS-CT | 34 | Qualcomm, Lena Chaponniere | Rel-13 | 67 |  |  |  |
| 1187 | 449.2.3 | CT4 aspects of EVS in 3G Circuit-Switched Networks | 268d? | 2015-03-04 A | 2016-03-11 A | 100% |  |  |  |  |  | finish no earlier than 2016-03-11 | C4 | 2144h | 2144h | EVSoCS-CT | 34 | Qualcomm, Lena Chaponniere | Rel-13 | 67 |  |  |  |
| 1188 | 449.3 | **Support of EVS over UTRAN CS** | 130.67d? | 2015-06-16 A | 2015-12-15 A | 100% |  |  |  |  |  |  | R2; R1; R3 | 6272h | 6272h | EVSoCS_UTRAN | 34 | Qualcomm | Rel-13 | 66 |  |  |  |
| 1189 | 449.3.1 | Core part: Support of EVS over UTRAN CS | 130.67d? | 2015-06-16 A | 2015-12-15 A | 100% |  |  |  |  |  | finish no earlier than 2015-12-15 | R2; R1; R3 | 3136h | 3136h | EVSoCS_UTRAN-Core | 34 | Francesco Pica - Qualcomm Incorporated | Rel-13 | 66 |  | RP-151282 |  |
| 1190 | 450 | Enhanced DASH (Dynamic Adaptive Streaming over HTTP in 3GPP) | 334d? | 2014-09-09 A | 2015-12-16 A | 100% |  |  |  |  |  | finish no earlier than 2015-12-16 | S4 | 2672h | 2672h | eDASH | 33 | Qualcomm, Huawei | Rel-13 | 65 | eDASH |  |  |
| 1191 | 451 | **QoS End-to-end Multimedia Telephony Service for IMS (MTSI) extensions (Stage 3)** | 796d? | 2013-03-06 A | 2016-03-11 A | 100% |  | 2013-03-06 | 2015-03-13 | 533d? |  |  | S4; C3; C1; C4 | 53457.8h | 53457.8h | QOSE2EMTSI | 30 | Ericsson | Rel-13 | 59 | QOSE2EMTSI |  | Paolo |
| 1192 | 451.1 | TR on improved end-to-end QoS handling for MTSI | 589d? | 2013-12-11 A | 2016-03-11 A | 100% |  | 2013-12-11 | 2015-03-13 | 329d? |  | finish no earlier than 2016-03-11 | S4 | 4705.83h | 4705.83h | QOSE2EMTSI | 32 | Ericsson | Rel-13 | 62 |  |  | Paolo |
| 1193 | 451.2 | SA4 part of QoS End-to-end Multimedia Telephony Service for IMS (MTSI) extensions (Stage 3) | 792d? | 2013-03-06 A | 2016-03-11 A | 100% |  | 2013-03-06 | 2015-03-13 | 532d? |  | finish no earlier than 2016-03-11 | S4 | 6336h | 6336h | QOSE2EMTSI | 30 | Ericsson | Rel-13 | 59 |  |  | Paolo |
| 1194 | 451.3 | **CT Aspects of QoS End-to-End MTSI Extensions** | 353d? | 2014-11-05 A | 2016-03-11 A | 100% |  |  |  |  |  |  | C3; C1; C4 | 16944h | 16944h | QOSE2EMTSI-CT | 34 | Ericsson | Rel-13 | 66 |  |  |  |
| 1195 | 451.3.1 | CT3 Aspects of QoS End-to-End MTSI Extensions | 353d? | 2014-11-05 A | 2016-03-11 A | 100% |  |  |  |  |  | finish no earlier than 2016-03-11 | C3 | 2824h | 2824h | QOSE2EMTSI-CT | 34 | Ericsson | Rel-13 | 66 |  |  |  |
| 1196 | 451.3.2 | CT1 Aspects of QoS End-to-End MTSI Extensions | 353d? | 2014-11-05 A | 2016-03-11 A | 100% |  |  |  |  |  | finish no earlier than 2016-03-11 | C1 | 2824h | 2824h | QOSE2EMTSI-CT | 34 | Ericsson | Rel-13 | 66 |  |  |  |
| 1197 | 451.3.3 | CT4 Aspects of QoS End-to-End MTSI Extensions | 353d? | 2014-11-05 A | 2016-03-11 A | 100% |  |  |  |  |  | finish no earlier than 2016-03-11 | C4 | 2824h | 2824h | QOSE2EMTSI-CT | 34 | Ericsson | Rel-13 | 66 |  |  |  |
| 1198 | 452 | **MTSI Extension on Multi-stream Multiparty** | 322d? | 2014-12-12 A | 2016-03-07 | 83% | 53.53d? |  |  |  | 1116d |  | S4 | 5752h | 5216.24h | MMCMH | 34 | Tomas Frankkila, Ericsson LM | Rel-13 | 66 |  |  |  |
| 1199 | 452.1 | Codec aspects for MMCMH | 265d? | 2014-12-12 A | 2015-12-17 A | 100% |  |  |  |  |  | finish no earlier than 2015-12-17 | S4 | 2120h | 2120h | MMCMH | 34 | Tomas Frankkila, Ericsson LM | Rel-13 | 66 |  |  |  |
| 1200 | 452.2 | (IETF) RTP Stream Pause and Resume (RFC 7728) | 66d? | 2015-12-07 A | 2016-03-07 A | 100% |  |  |  |  |  | finish no earlier than 2016-03-07 | S4-IETF | 528h | 528h | MMCMH | 36 | Ericsson | Rel-13 | 71 |  |  |  |
| 1201 | 452.3 | (IETF) draft-ietf-mmusic-sdp-simulcast | 66d? | 2015-12-07 | 2016-03-07 |  |  |  |  |  | 1116d | start no earlier than 2015-12-07 | S4-IETF | 528h |  | MMCMH | 37 |  | Rel-13 | 72 |  |  |  |

Notes:
- 1177: Mar. 15: 5->15% / WI rapporteur e-mail: gilles.teniou@orange.com
- 1178: Dec.14: 0->5%; June2015: Compl:15%->30; Aug2015: 30%->45; 07/09/15: 45%->70; 7/12/15: 70%->85, FCD: 12/15->03/16; 7/3/16: 85%->100 / Impacted TSs and TRs: New TR 26.9xy. ES in SP-150650 / WI rapporteur e-mail: gilles.teniou@orange.com
- 1179: Dec.14: 0->5%; June2015: Compl:15%->30; Aug2015: 30%->45; 07/09/15: 45%->70; 7/12/15: 70%->85, FCD: 12/15->03/16. ES in SP-150650; 7/3/16: 85%->100 / Impacted TSs and TRs: 26.234, 26.244, 26.346, 26.247, New TS 26.xyz. ES in SP-150650 / WI rapporteur e-mail: gilles.teniou@orange.com
- 1180: Mar. 15: 0->5%; June2015: Compl:5%->10; Aug2015: 10%->15; 07/09/15: 15%->50; 7/12/15: 50%->80, FCD: 12/15->03/16. ES in SP-150652; 7/3/16: FCD: 03/16->06/16; 11/6/16: 80%->100 / Impacted TSs and TRs: 26.131, 26.132 / WI rapporteur e-mail: stephane.ragot@orange.com
- 1181: Triggered by Rel-12 TR 26.907 (Study of HTML5 and 3GPP User Services). Dec.14: 0->5%. Mar. 15: 10%; June2015: Compl:10%->20; Aug2015: 20%->40; 07/09/15: 40%->70; 7/12/15: 70%->100 / Impacted TSs and TRs: 26.140, 26.234, 26.247, 26.346, New TS 26.xyz / WI rapporteur e-mail: Imed Bouazizi (i.bouazizi@samsung.com)
- 1182: Provide CS support of EVS to enhance voice quality in CS services over UTRAN (3G WCDMA). Dec.14: 0->5%; 28/1/16: 26.454 added; 28/1/16: 26.453 added; / Impacted TSs and TRs: 26.103, 28.062, New TS 26.454; New TS 26.453 / WI rapporteur e-mail: Imre Varga (ivarga@qti.qualcomm.com)
- 1183: Created by MCC (duplicated from previously single-line Feature) due to the introduction of the CT BB. Mar. 15: 10%; Aug2015: 10%->20; 07/09/15: 20%->40; 7/12/15: 40%->60, FCD:12/15->03/16. ES in SP-150655; 28/1/16: 26.454 added; 28/1/16: 26.453 added; / Impacted TSs and TRs: 26.103, 28.062, New TS 26.454; New TS 26.453 / WI rapporteur e-mail: Imre Varga (ivarga@qti.qualcomm.com)
- 1184: WI rapporteur e-mail: lguellec@qti.qualcomm.com
- 1185: 07/09/15: 0%->90; 7/12/15: 90%->100 / Impacted TSs and TRs: 24.008 / WI rapporteur e-mail: lguellec@qti.qualcomm.com
- 1186: June2015: Compl:0%->10; 07/09/15: 10%->15; 7/12/15: 15%->90. FCD -> 03/16, ES in CP-150638; 7/3/16: 90%->100 / Impacted TSs and TRs: 29.163, 29.414, 29.415 / WI rapporteur e-mail: lguellec@qti.qualcomm.com
- 1187: June2015: Compl:0%->95. FCD -> 03/16, ES in CP-150618; 7/3/16: 95%->100 / Impacted TSs and TRs: 23.153, 23.334, 29.002, 29.231, 29.232, 29.332, 29.334 / WI rapporteur e-mail: lguellec@qti.qualcomm.com
- 1188: WI rapporteur e-mail: Qualcomm
- 1189: Rapporteur details and involved WGs updated 1st Apr 15: Compl:0%->10% 1st Apr 15: Stat Rep: ->RP-150128. 5/5/15: 0->10% 03/07/15: Compl:10%->25% 03/07/15: Stat Rep: RP-150128->RP-150759 29/09/15: Compl:25%->50% 29/09/15: CD:Tue 15/09/15->Tue 15/12/15 2 / WI rapporteur e-mail: fpica@qti.qualcomm.com
- 1190: Triggered by Rel-12 Dec.14: 0->10%. Mar. 15: 15%; June2015: Compl:15%->25. WID updated; Aug2015: 25%->30; 07/09/15: 30%->60; 14/09/15: WID:SP-150211->SP-150448; 7/12/15: 60%->100 / Impacted TSs and TRs: 26.233, 26.234, 26.244, 26.247, 26.938, TS 26.346, TR 26.946 / WI rapporteur e-mail: Thomas Stockhammer (tsto@qti.qualcomm.com), Li Zhiming (lizhiming@huawei.com)
- 1191: SP#65 updated WID SP-130670=>SP-140601 (moved work from Rel-12 incl. new TR to Rel-13). Co-ordinate with SA2, CT1/3/4, IETF MMUSIC. Linked to SA4 Rel-7 Media handling and interaction in MTSI (MTSI-MHI) UID_7040 / WI rapporteur e-mail: tomas.frankkila@ericsson.com
- 1192: SP#65 updated WID SP-130670=>SP-140601 (moved work from Rel12 incl. new TR to Rel-13). Completion 03/15=>06/15. Mar15: 26.924 for info. 8/4/15: 50%; Aug2015: 50%->60; 7/12/15: 75%->90, FCD: 06/15->03/16; 7/3/16: 90%->100 / Impacted TSs and TRs: new TR 26.924 / WI rapporteur e-mail: tomas.frankkila@ericsson.com
- 1193: SP#65: WID SP-130670=>SP-140601 (moved from Rel12 incl. new TR to Rel-13). FCD 03/15=>06/15. St1 in TS 22.173. 12/14: 70->40%, CD: 06/15->09/15. 03/15: 50%. June 15: FCD: 09/15->12/15; 08/15: 60%; 09/15: 75%; 7/12. ES in SP-150658; 7/3/16: 90%->100 / Impacted TSs and TRs: 26.114 / WI rapporteur e-mail: tomas.frankkila@ericsson.com
- 1195: 7/12/15: 0%->70. FCD -> 03/16, ES in CP-150636; 7/3/16: 70%->100 / Impacted TSs and TRs: 29.162, 29.163, 29.213, 29.214
- 1196: FCD -> 03/16, ES in CP-150726; 7/3/16: 0%->100 / Impacted TSs and TRs: 24.229
- 1197: FCD -> 03/16, ES in CP-150620; 7/3/16: 0%->100 / Impacted TSs and TRs: 23.333, 23.334, 29.238, 29.332, 29.333, 29.334
- 1198: Mar. 15: 0->10%. WID: SP-140738->SP-150097; June2015: Compl:10%->30; Aug2015: 30%->50, FCD: sep->Dec 2015; 07/09/15: 50%->60; 7/12/15: 60%->100; 10/12/15: WID:SP-150097->SP-150660. Might be moved to Rel-14 (see note in UID710002) / Impacted TSs and TRs: 26.114, New TR 26.980 / WI rapporteur e-mail: tomas.frankkila@ericsson.com
- 1199: Introduced by MCC to dissociate S4 from IeTF aspects / Impacted TSs and TRs: 26.114, New TR 26.980 / WI rapporteur e-mail: tomas.frankkila@ericsson.com
- 1200: 02/2016: published as RFC 7728 / Impacted TSs and TRs: (IETF) RTP Stream Pause and Resume (RFC 7728) / WI rapporteur e-mail: tomas.frankkila@ericsson.com

| ID | WBS | Task | Duration | Start | Finish | Complete | Remaining | Baseline start | Baseline finish | Baseline duration | Total slack | Constraint | Resources | Work | Actual work | Acronym | PCG approved | Release | TSG approved | MCC resp | Special Focus Doc | Acronym_3GU_Export |
| --- | --- | --- | --- | --- | --- | --- | --- | --- | --- | --- | --- | --- | --- | --- | --- | --- | --- | --- | --- | --- | --- | --- |
| 1202 | 453 | **Video Telephony Robustness Improvements Extensions** | 196d? | 2014-12-12 A | 2015-09-11 | 70% | 58.8d? |  |  |  | 1242d |  | S4 | 6272h | 4390.4h | VTRI_EXT | 34 | Rel-13 | 66 |  |  |  |
| 1203 | 453.1 | TR on Video Telephony Robustness Improvements | 196d? | 2014-12-12 A | 2015-09-11 A | 100% |  |  |  |  |  | finish no earlier than 2015-09-11 | S4 | 1568h | 1568h | VTRI_EXT | 34 | Rel-13 | 66 |  |  |  |
| 1204 | 453.2 | Specification on Video Telephony Robustness Improvements | 196d? | 2014-12-12 A | 2015-09-11 A | 100% |  |  |  |  |  | finish no earlier than 2015-09-11 | S4 | 1568h | 1568h | VTRI_EXT | 34 | Rel-13 | 66 |  |  |  |
| 1205 | 453.3 | (IETF) RTP Payload Format for Non-Interleaved and Interleaved Parity Forward Error Correction (FEC) (draft-ietf-payload-flexible-fec-scheme) | 196d? | 2014-12-12 A | 2015-09-11 | 10% | 176.4d? |  |  |  | 1242d | finish no earlier than 2015-09-11 | S4-IETF | 1568h | 156.8h | VTRI_EXT | 35 | Rel-13 | 69 |  |  |  |
| 1206 | 454 | Acoustic Test methods and Performance Objectives for Speakerphone Performance in Noisy Environments | 326d? | 2014-12-12 A | 2016-03-11 A | 100% |  |  |  |  |  | finish no earlier than 2016-03-11 | S4 | 2608h | 2608h | ATeMPO_SPINE | 34 | Rel-13 | 66 |  |  |  |
| 1207 | 455 | **Rel-13 Operations, Administration, Maintenance and Provisioning (OAM&P)** | 985d? | 2012-06-20 A | 2016-03-11 A | 100% |  | 2014-09-17 | 2015-12-11 | 323d? |  |  | S5 | 57504h | 57504h | OAM13 | 32 | Rel-13 | 63 | Mirko | SON | OAM13 |
| 1208 | 455.1 | Enhanced Network Management (NM) centralized Coverage and Capacity Optimization | 319d? | 2014-09-19 A | 2015-12-11 A | 100% |  | 2014-09-17 | 2015-12-11 | 319d? |  | finish no earlier than 2015-12-11 | S5 | 2552h | 2552h | SON-NM-CCO | 29 | Rel-13 | 56 | Mirko | SON | SON-NM-CCO |
| 1209 | 455.2 | **Compliance of 3GPP SA5 specifications to the NGMN Top Operational Efficiency (OPE) Recommendations** | 728d? | 2012-06-20 A | 2015-03-18 A | 100% |  | 2012-06-20 | 2014-09-17 | 595d? |  |  | S5 | 17368h | 17368h | OAM-NGMN_OPE | 29 | Rel-13 | 56 | Mirko |  | OAM-NGMN_OPE |
| 1210 | 455.2.1 | TR on Compliance of 3GPP SA5 specifications to the NGMN Top Operational Efficiency (OPE) Recommendations | 723d? | 2012-06-20 A | 2015-03-18 A | 100% |  | 2012-06-20 | 2014-09-17 | 593d? |  | finish no earlier than 2015-03-18 | S5 | 5784h | 5784h | OAM-NGMN_OPE | 29 | Rel-13 | 56 | Mirko |  |  |
| 1211 | 455.2.2 | TS work on Compliance of 3GPP SA5 specifications to the NGMN Top Operational Efficiency (OPE) Recommendations | 720d? | 2012-06-25 A | 2015-03-18 A | 100% |  | 2012-06-25 | 2014-09-17 | 590d? |  | finish no earlier than 2015-03-18 | S5 | 5760h | 5760h | OAM-NGMN_OPE | 29 | Rel-13 | 56 | Mirko |  |  |
| 1212 | 455.3 | Converged management Performance Management Interface Definitions | 910d? | 2012-06-20 A | 2015-12-11 A | 100% |  | 2012-06-20 | 2014-09-17 | 588d? |  | finish no earlier than 2015-12-11 | S5 | 7280h | 7280h | OAM-PMID | 29 | Rel-13 | 56 | Mirko |  | OAM-PMID |
| 1213 | 455.4 | **WLAN Management** | 788d? | 2012-06-27 A | 2015-06-17 A | 100% |  | 2012-06-20 | 2014-09-17 | 595d? |  |  | S5 | 18848h | 18848h | WLAN-OAM | 29 | Rel-13 | 56 | Mirko | WLAN | WLAN-OAM |
| 1214 | 455.4.1 | WLAN Network Resource Model for Type-2 interface | 784d? | 2012-06-27 A | 2015-06-17 A | 100% |  | 2012-06-27 | 2014-09-17 | 589d? |  | finish no earlier than 2015-06-17 | S5 | 6272h | 6272h | WLAN-OAM-SA5 | 29 | Rel-13 | 56 | Mirko | WLAN |  |
| 1215 | 455.4.2 | WLAN measurements defined in IEEE and IETF WLAN performance measurements for use on Type-2 interface | 784d? | 2012-06-27 A | 2015-06-17 A | 100% |  | 2012-06-27 | 2014-09-17 | 589d? |  | finish no earlier than 2015-06-17 | S5 | 6272h | 6272h | WLAN-OAM-SA5ietf | 29 | Rel-13 | 56 | Mirko | WLAN |  |
| 1216 | 455.5 | Energy Efficiency related Performance Measurements | 713d? | 2013-06-21 A | 2016-03-11 A | 100% |  | 2013-06-21 | 2014-09-17 | 326d? |  | finish no earlier than 2016-03-11 | S5 | 5704h | 5704h | OAM-PM_EE | 31 | Rel-13 | 60 | Mirko |  | OAM-PM_EE |
| 1217 | 455.6 | Multi-Broadcast Single Frequency Network (MBSFN) Minimization of Drive Tests (MDT) enhancement | 1d? | 2014-12-12 A | 2014-12-12 A | 100% |  |  |  |  |  | start no earlier than 2014-12-12 | S5 | 8h | 8h | MBSFN_MDT | 34 | Rel-13 | 66 |  |  |  |
| 1218 | 456 | **Rel-13 Charging** | 393d? | 2014-06-19 A | 2015-12-16 A | 100% |  | 2014-06-18 | 2015-12-09 | 386d? |  |  | S5 | 16236h | 16236h | CH13 | 33 | Rel-13 | 64 |  |  | CH13 |
| 1219 | 456.1 | **Inter-PLMN PS domain online charging** | 393d? | 2014-06-19 A | 2015-12-16 A | 100% |  | 2014-06-18 | 2015-12-09 | 386d? |  |  | S5 | 8360h | 8360h | iPLMN-PS-OCH | 33 | Rel-13 | 64 |  |  | iPLMN-PS-OCH |
| 1220 | 456.1.1 | TR on Inter-PLMN PS domain online charging | 261d? | 2014-06-19 A | 2015-06-17 A | 100% |  | 2014-06-18 | 2015-06-17 | 261d? |  | finish no earlier than 2015-06-17 | S5 | 2088h | 2088h | iPLMN-PS-OCH | 33 | Rel-13 | 64 |  |  |  |
| 1221 | 456.1.2 | Specification of Inter-PLMN PS domain online charging | 391d? | 2014-06-23 A | 2015-12-16 A | 100% |  | 2014-06-18 | 2015-12-09 | 386d? |  | finish no earlier than 2015-12-16 | S5 | 3128h | 3128h | iPLMN-PS-OCH | 33 | Rel-13 | 64 |  |  |  |
| 1222 | 456.2 | ULI and release causes for charging enhancement for VoLTE | 257d? | 2014-12-12 A | 2015-12-07 A | 100% |  |  |  |  |  | finish no earlier than 2015-12-07 | S5 | 2056h | 2056h | ULRELC-CH | 34 | Rel-13 | 66 |  |  |  |
| 1223 | 456.3 | Charging on enhancements for IMS Service Continuity | 135d? | 2015-03-05 A | 2015-09-09 A | 100% |  |  |  |  |  | finish no earlier than 2015-12-11 | S5 | 1080h | 1080h | CHeISC | 34 | Rel-13 | 67 |  |  |  |
| 1224 | 456.4 | Announcements for IMS Online Charging | 131d? | 2015-06-15 A | 2015-12-14 A | 100% |  |  |  |  |  | start no earlier than 2015-06-14 | S5 | 1048h | 1048h | ANIMO | 35 | Rel-13 | 68 |  |  |  |
| 1225 | 456.5 | Enhanced S2a Mobility Over Trusted WLAN access to EPC - Charging | 68.5d? | 2015-06-15 A | 2015-09-17 A | 100% |  |  |  |  |  | start no earlier than 2015-06-15 | S5 | 548h | 548h | eSaMOG-CH | 35 | Rel-13 | 68 |  |  |  |

Notes:
- 1202: New TR added. 3/3/15: "extensions" added in the title. Mar. 15: 0->10% / Impacted TSs and TRs: 26.922 (new), 26.114 / WI rapporteur name: Muhammed Coban, Qualcomm Incorporated / WI rapporteur e-mail: mcoban@qti.qualcomm.com
- 1203: 3/3/15: created to distinguish TR and TS tasks; June2015: Compl:10%->40; Aug2015: 40%->95; 07/09/15: 95%->100 / Impacted TSs and TRs: 26.922 (new), 26.114 / WI rapporteur name: Muhammed Coban, Qualcomm Incorporated / WI rapporteur e-mail: mcoban@qti.qualcomm.com
- 1204: 3/3/15: created to distinguish TR and TS tasks; June2015: Compl:10%->40; Aug2015: 40%->95; 07/09/15: 95%->100 / Impacted TSs and TRs: 26.922 (new), 26.114 / WI rapporteur name: Muhammed Coban, Qualcomm Incorporated / WI rapporteur e-mail: mcoban@qti.qualcomm.com
- 1205: 26.114, draft-ietf-payload-flexible-fec-scheme. 7/10/15: rapporteur added / Impacted TSs and TRs: 26.114, draft-ietf-payload-flexible-fec-scheme / WI rapporteur name: Muhammed Coban, Qualcomm Incorporated / WI rapporteur e-mail: mcoban@qti.qualcomm.com
- 1206: June2015: Compl:0%->10. Aug: FCD: Jun->Sep15; 07/09/15: 10%->30, FCD:09/15->12/15; 7/12/15: 40%->80, FCD: 12/15->03/16. ES in SP-150642; 7/3/16: 80%->100 / Impacted TSs and TRs: 26.131, 26.132 / WI rapporteur name: Andre Schevciw, Qualcomm Incorporated; Scott Isabelle, Audience Inc. / WI rapporteur e-mail: aschevci@qti.qualcomm.com; sisabelle@audience.com
- 1207: OAM13 is an umbrella Feature for changes that are not part of any other dedicated feature/WI; June2015: WID:-->SP-150305; 5/10/15: 28.683 added; / Impacted TSs and TRs: 28.683
- 1208: SP#64 work not started. Dec.14: 0->20, cd: 06/15->12/15. Mar 15: 20->30%; June2015: Compl:30%->50; 07/09/15: 50%->60; 7/12/15: 60%->100 / Impacted TSs and TRs: 28.627, 28.628, 32.103, 32.422, 32.425, 32.442 / WI rapporteur name: Ericsson / WI rapporteur e-mail: robert.petersen@ericsson.com
- 1209: SP#65 updated WID SP-120349=>SP-140538. Completion 12/14=>03/15. Moved to Rel-13. Source of external requirements: NGMN Top OPE Recommendations 1.0 / WI rapporteur name: Huawei / WI rapporteur e-mail: christian.toche@huawei.com
- 1210: SP#65 updated WID SP-120349=>SP-140538. Completion 12/14=>03/15. Moved to Rel-13.. Dec.14: 72->78. Mar 15: 80%; June2015: Compl:80%->85; 07/09/15: 85%->90; 7/12/15: 90%->100 / Impacted TSs and TRs: New TR 32.838 / WI rapporteur name: Huawei / WI rapporteur e-mail: christian.toche@huawei.com
- 1211: SP#65 updated WID SP-120349=>SP-140538. Completion 12/14=>03/15. Moved to Rel-13; 7/12/15: 50%->100 / Impacted TSs and TRs: 32.101/2/3,32.111-1,32.111-2,32.111-6,32.15x,32.401,32.411,32.412,32.421,32.422,32.423,32.431,32.432,32.436,32.441,32.442,32.446,32.500,32.501,32.502,32.506,32.521,32.522,32.526,32.531,32.532,32.536,32.551,32.691,32.692,32.696,32.762 / WI rapporteur name: Huawei / WI rapporteur e-mail: christian.toche@huawei.com
- 1212: SP#65 updated WID SP-130641=>SP-140613. Completion 09/14=>12/15. Moved to Rel-13. Completion 09/14=>12/15. Dec.14: 20->30; June2015: Compl:30%->60; 07/09/15: 60%->80; 7/12/15: 80%->100; 7/12/15: WID:SP-140613->SP-150678 / Impacted TSs and TRs: new TSs 32.863 / WI rapporteur name: Huawei / WI rapporteur e-mail: christian.toche@huawei.com
- 1213: SP#65 moved to Rel-13. Updated WID SP-130042=>SP-140535 (split into Rel-12 Study & Rel-13 normative WI). TR 32.841 was completed as a Rel-12 Study and has triggered this normative work / WI rapporteur name: Intel / WI rapporteur e-mail: joey.chou@intel.com
- 1214: SP#65 updated WID SP-130042=>SP-140535. Completion 09/14=>06/15. Moved to Rel-13. Dec.14: 10->20; June2015: Compl:20%->70; 07/09/15: 70%->80; 7/12/15: 80%->100 / Impacted TSs and TRs: new TS (28.680, 28.682), 28.681 / WI rapporteur name: Intel / WI rapporteur e-mail: joey.chou@intel.com
- 1215: SP#65 updated WID SP-130042=>SP-140535. Completion 09/14=>06/15. Moved to Rel-13. 22/01:Acronym modified; June2015: Compl:5%->20; 07/09/15: 20%->60; 7/12/15: 60%->100 / Impacted TSs and TRs: new TS 28.403 / WI rapporteur name: Intel / WI rapporteur e-mail: joey.chou@intel.com
- 1216: SP#65 updated WID SP-130263=>SP-140612. Completion 09/14=>06/15. Moved to Rel-13; June2015: Compl:25%->40; 07/09/15: 40%->50. ES in SP-150708; 7/3/16: 50%->100 / Impacted TSs and TRs: 32.425 / WI rapporteur name: Nokia Networks / WI rapporteur e-mail: Yizhi.yao@nsn.com
- 1217: Mar 15: 0->15%; June2015: Compl:15%->100 / Impacted TSs and TRs: 32.421, 32.422, 32.423, 32.441, 32.442, 32.446 / WI rapporteur name: Padma Sudarsan (Alcatel-Lucent) / WI rapporteur e-mail: padma.sudarsan<AT>alcatel-lucent<DOT>com
- 1218: CH13 is an umbrella Feature for changes that are not part of any other dedicated feature/WI; June2015: WID:-->SP-150307
- 1219: Study and specify Gy Reference Point service data flows based online charging for inter-PLMN situations / Impacted TSs and TRs: Stage 2/3 / WI rapporteur name: Alcatel-Lucent / WI rapporteur e-mail: maryse.gardella@alcatel-lucent.com
- 1220: Dec.14: 10->25%. Mar15: 20->60%. 06/15: 100%; 7/12/15: 100%->100 / Impacted TSs and TRs: New TR 32.843 / WI rapporteur name: Alcatel-Lucent / WI rapporteur e-mail: maryse.gardella@alcatel-lucent.com
- 1221: 07/09/15: 0%->80; 7/12/15: 80%->100 / Impacted TSs and TRs: 32.251, 32.299 / WI rapporteur name: Alcatel-Lucent / WI rapporteur e-mail: maryse.gardella@alcatel-lucent.com
- 1222: Acronym changed to ULRELC-CH. Mar15: 0->5%. CD: 12/14->09/15. 06/15: 20%; 07/09/15: 20%->40; 7/12/15: 40%->100, FCD: 09/15->12/15 / Impacted TSs and TRs: 32.251, 32.260, 32.299, 32.298, / WI rapporteur name: Alcatel-Lucent, Maryse Gardella / WI rapporteur e-mail: Alcatel-Lucent, Maryse <dot> Gardella <at> Alcatel-Lucent <dot> com
- 1223: 06/15: 0->50%; 07/09/15: 50%->100. FCD: 12/15->09/15 / Impacted TSs and TRs: 32.260, 32.299, 32.298 / WI rapporteur name: Gerald Goermer / WI rapporteur e-mail: Gerald <dot> Goermer <at> nsn <dot> com
- 1224: 07/09/15: 0%->30; 7/12/15: 30%->100; 7/12/15: WID:SP-150307->SP-150675 / Impacted TSs and TRs: 32.260, 32.275, 32.299, 32.240, 32.281 / WI rapporteur name: Amdocs, Naceur <dot> Lagha <at> Amdocs <dot> com
- 1225: 07/09/15: 0%->30; 7/12/15: 30%->100 / Impacted TSs and TRs: 32.240, 32.251, 32.299, 32.298 / WI rapporteur name: Alcatel-Lucent, Maryse <dot> Gardella <at> Alcatel-Lucent <dot> com

| ID | WBS | Task | Duration | Start | Finish | Complete | Remaining | Baseline start | Baseline finish | Baseline duration | Total slack | Constraint | Resources | Work | Actual work | Acronym | PCG approved | WI rapporteur name | WI rapporteur e-mail | Release | TSG approved | MCC resp | Acronym_3GU_Export | Status Report |
| --- | --- | --- | --- | --- | --- | --- | --- | --- | --- | --- | --- | --- | --- | --- | --- | --- | --- | --- | --- | --- | --- | --- | --- | --- |
| 1226 | 457 | **Support of Real-time Transport Protocol (RTP) / Real-time Transport Control Protocol (RTCP) multiplexing (signalling) in IMS** | 595d? | 2013-09-09 A | 2015-12-11 A | 100% |  | 2013-09-09 | 2014-09-12 | 267d? |  |  | C4; C1; C3 | 28464h | 28464h | RTCP_MUX | 31 | Alcatel-Lucent | Albrecht.Schwarz@alcatel-lucent.com | Rel-13 | 61 | Kimmo | RTCP_MUX |  |
| 1227 | 457.1 | CT4 part of Support of RTP / RTCP multiplexing (signalling) in IMS | 591d? | 2013-09-09 A | 2015-12-11 A | 100% |  | 2013-09-09 | 2014-09-12 | 266d? |  | finish no earlier than 2015-12-11 | C4 | 4728h | 4728h | RTCP_MUX | 31 | Alcatel-Lucent | Albrecht.Schwarz@alcatel-lucent.com | Rel-13 | 61 | Kimmo |  |  |
| 1228 | 457.2 | CT1 part of Support of RTP / RTCP multiplexing (signalling) in IMS | 591d? | 2013-09-13 A | 2015-12-11 A | 100% |  | 2013-09-10 | 2014-09-12 | 266d? |  | finish no earlier than 2015-12-11 | C1 | 4728h | 4728h | RTCP_MUX | 31 | Alcatel-Lucent | Albrecht.Schwarz@alcatel-lucent.com | Rel-13 | 61 | Frederic |  |  |
| 1229 | 457.3 | CT3 part of Support of RTP / RTCP multiplexing (signalling) in IMS | 591d? | 2013-09-13 A | 2015-12-11 A | 100% |  | 2013-09-10 | 2014-06-13 | 201d? |  | finish no earlier than 2015-12-11 | C3 | 4728h | 4728h | RTCP_MUX | 31 | Alcatel-Lucent | Albrecht.Schwarz@alcatel-lucent.com | Rel-13 | 61 | Adrian |  |  |
| 1230 | 458 | **LTE in the 1670-1675 MHz Band for US (on hold till 12/2014)** | 868d? | 2012-03-05 A | 2015-06-12 | 8% | 801.54d? | 2012-03-05 | 2015-06-12 | 865d? | 1307d |  | R4; R2; R3 | 35264h | 2347.6h | LTE_FDD_1670_US | 28 | LightSquared | masoud.olfat@lightsquared.com | Rel-13 | 55 | Issam | LTE_FDD_1670_US |  |
| 1231 | 458.1 | Core part: LTE in the 1670-1675 MHz Band for US (on hold till 12/2014) | 313d? | 2013-08-06 A | 2015-03-13 | 15% | 266.05d? | 2013-08-06 | 2015-03-13 | 313d? | 1372d | finish no earlier than 2015-03-13 | R4; R2; R3 | 7512h | 1126.8h | LTE_FDD_1670_US-Core | 28 | LightSquared | masoud.olfat@lightsquared.com | Rel-13 | 55 | Issam | LTE_FDD_1670_US-Core | RP-141452 |
| 1232 | 458.2 | Perf. Part: LTE in the 1670-1675 MHz Band for US (on hold till 12/2014) | 865d? | 2012-03-05 A | 2015-06-12 | 5% | 821.75d? | 2012-03-05 | 2015-06-12 | 865d? | 1307d | finish no earlier than 2015-06-12 | R4 | 6920h | 346h | LTE_FDD_1670_US-Perf | 28 | LightSquared | masoud.olfat@lightsquared.com | Rel-13 | 55 | Issam | LTE_FDD_1670_US-Perf | RP-141452 |
| 1233 | 459 | **Enhanced Signalling for Inter-eNB Coordinated Multi-Point (CoMP) for LTE** | 328d? | 2014-06-18 A | 2015-09-15 A | 100% |  | 2014-06-13 | 2014-12-05 | 126d? |  |  | R3 | 5248h | 5248h | COMP_LTE_IeNB_sig | 33 | Samsung | sunghwan.won@samsung.com | Rel-13 | 64 |  | COMP_LTE_IeNB_sig |  |
| 1234 | 459.1 | Core part: Enhanced Signalling for Inter-eNB Coordinated Multi-Point (CoMP) for LTE | 328d? | 2014-06-18 A | 2015-09-15 A | 100% |  | 2014-06-13 | 2014-12-05 | 126d? |  | finish no earlier than 2015-09-15 | R3 | 2624h | 2624h | COMP_LTE_IeNB_sig-Core | 33 | Samsung | sunghwan.won@samsung.com | Rel-13 | 64 |  | COMP_LTE_IeNB_sig-Core | RP-151213 |
| 1235 | 460 | **2GHz FDD LTE in Region 1 (1980-2010MHz and 2170-2200MHz Bands)** | 592d? | 2014-06-17 A | 2016-09-15 A | 100% |  | 2014-06-13 | 2015-06-12 | 261d? |  |  | R4 | 12096h | 12096h | LTE_1980_2170_REG1 | 33 | DISH Network | johny.kim@dish.com, mariam.sorond@dish.com | Rel-13 | 64 |  | LTE_1980_2170_REG1 |  |
| 1236 | 460.1 | Core part: 2GHz FDD LTE in Region 1 (1980-2010MHz and 2170-2200MHz Bands) | 393d? | 2014-06-17 A | 2015-12-15 A | 100% |  | 2014-06-13 | 2015-06-12 | 261d? |  | finish no earlier than 2015-12-15 | R4 | 3144h | 3144h | LTE_1980_2170_REG1-Core | 33 | DISH Network | johny.kim@dish.com, mariam.sorond@dish.com | Rel-13 | 64 |  | LTE_1980_2170_REG1-Core | RP-151299 |
| 1237 | 460.2 | Perf. Part: 2GHz FDD LTE in Region 1 (1980-2010MHz and 2170-2200MHz Bands) | 393d? | 2014-06-18 A | 2015-12-15 A | 100% |  | 2014-06-13 | 2015-06-12 | 261d? |  | finish no earlier than 2015-12-15 | R4 | 3144h | 3144h | LTE_1980_2170_REG1-Perf | 33 | DISH Network | johny.kim@dish.com, mariam.sorond@dish.com | Rel-13 | 64 |  | LTE_1980_2170_REG1-Perf | RP-151299 |
| 1238 | 460.3 | UE Conformance Test Aspects - FDD LTE band 1980-2010 MHz and 2170-2200MHz (band 65) in Region1 and Region 3 | 134d? | 2016-03-15 A | 2016-09-15 A | 100% |  |  |  |  |  | finish no earlier than 2016-09-15 | R5 | 1072h | 1072h | LTE_1980_2170_REG1_REG3-UEConTest | 36 | Dish Network |  | Rel-13 | 71 |  |  |  |
| 1239 | 461 | **Self Organizing Networks (SON) for Active Antenna System (AAS) based deployments** | 199d? | 2014-09-12 A | 2015-06-15 A | 100% |  | 2014-06-13 | 2015-06-12 | 261d? |  |  | R3; G2 | 4776h | 4776h | UTRA_LTE_SON_AAS | 33 | Nokia Networks | krzysztof.kordybach@nsn.com | Rel-13 | 65 |  | UTRA_LTE_SON_AAS |  |
| 1240 | 461.1 | Core part: Self Organizing Networks (SON) for Active Antenna System (AAS) based deployments | 199d? | 2014-09-12 A | 2015-06-15 A | 100% |  | 2014-06-13 | 2015-06-12 | 261d? |  | finish no earlier than 2015-06-15 | R3 | 1592h | 1592h | UTRA_LTE_SON_AAS-Core | 33 | Nokia Networks | krzysztof.kordybach@nsn.com | Rel-13 | 65 |  | UTRA_LTE_SON_AAS-Core | RP-150727 |
| 1241 | 462 | **Usage Monitoring Control PCC Extension** | 140d? | 2014-12-03 A | 2015-06-16 A | 100% |  |  |  |  |  |  | S2 | 2824h | 2824h | eUMONC | 34 | CTBRI |  | Rel-13 | 66 |  |  |  |
| 1242 | 462.1 | Stage 2 of Usage Monitoring Control PCC Extension | 140d? | 2014-12-03 A | 2015-06-16 A | 100% |  |  |  |  |  | finish no earlier than 2015-06-16 | S2 | 1120h | 1120h | eUMONC-SA2 | 34 | China Telecom, Jinyan Li | lijy@ctbri.com.cn | Rel-13 | 66 |  |  |  |
| 1243 | 462.2 | CT3 Aspect of Usage Monitoring Control extension | 73d? | 2014-12-03 A | 2015-03-13 A | 100% |  |  |  |  |  | finish no earlier than 2015-03-13 | C3 | 584h | 584h | eUMONC-CT3 | 34 | ZTE |  | Rel-13 | 66 |  |  |  |
| 1244 | 463 | **Enhanced P-CSCF discovery using signalling for access to EPC via WLAN** | 115d? | 2014-10-06 A | 2015-03-13 A | 100% |  |  |  |  |  |  | C1 | 2424h | 2424h | ePCSCF_WLAN | 34 | Ericsson |  | Rel-13 | 66 |  |  |  |
| 1245 | 463.1 | CT1 aspects of Enhanced P-CSCF discovery using signalling for access to EPC via WLAN | 73d? | 2014-12-03 A | 2015-03-13 A | 100% |  |  |  |  |  | finish no earlier than 2015-03-13 | C1 | 584h | 584h | ePCSCF_WLAN | 34 | Ericsson |  | Rel-13 | 66 |  |  |  |
| 1246 | 463.2 | CT4 aspects of Enhanced P-CSCF discovery using signalling for access to EPC via WLAN | 115d? | 2014-10-06 A | 2015-03-13 A | 100% |  |  |  |  |  | finish no earlier than 2015-03-13 | C4 | 920h | 920h | ePCSCF_WLAN | 34 | Ericsson |  | Rel-13 | 66 |  |  |  |
| 1247 | 464 | **P-CSCF Restoration Enhancements with WLAN** | 268.05d? | 2014-12-03 A | 2015-12-14 A | 100% |  |  |  |  |  |  | C4 | 6432.4h | 6432.4h | PCSCF_RES_WLAN | 34 | Jean-Jacques Trottin, Alcatel-Lucent | jean-jacques.trottin@alcatel-lucent.com | Rel-13 | 66 |  |  |  |
| 1248 | 464.1 | CT1 aspects of P-CSCF Restoration Enhancements with WLAN | 268d? | 2014-12-03 A | 2015-12-14 A | 100% |  |  |  |  |  | finish no earlier than 2015-12-11 | C1 | 2144h | 2144h | PCSCF_RES_WLAN | 34 | Jean-Jacques Trottin, Alcatel-Lucent | jean-jacques.trottin@alcatel-lucent.com | Rel-13 | 66 |  |  |  |
| 1249 | 464.2 | CT4 aspects of P-CSCF Restoration Enhancements with WLAN | 268d? | 2014-12-03 A | 2015-12-11 A | 100% |  |  |  |  |  | finish no earlier than 2015-12-11 | C4 | 2144h | 2144h | PCSCF_RES_WLAN | 34 | Jean-Jacques Trottin, Alcatel-Lucent | jean-jacques.trottin@alcatel-lucent.com | Rel-13 | 66 |  |  |  |

Notes:
- 1226: CP#65 moved to Rel-13. Stage 2/3 / Impacted TSs and TRs: Stage 2/3
- 1227: CP#65 moved to Rel-13. Completion 09/14=>12/15. Dec.14: 10->100 / Impacted TSs and TRs: 23.334, 29.334
- 1228: CP#65 moved to Rel-13. Completion 09/14=>12/15; 7/12/15: 0%->100 / Impacted TSs and TRs: 24.229
- 1229: CP#65 moved to Rel-13. Completion 09/14=>12/15; 8/12/15: 0%->100 / Impacted TSs and TRs: 29.213, 29.214
- 1230: RP#65 FS_LTE_FDD_1670_US is extended to 12/14 and this WI (LTE_FDD_1670_US) is on hold till 12/14 / Impacted TSs and TRs: LTE
- 1231: RP#65 completion 03/15=>06/15. On hold till 12/2014 / Impacted TSs and TRs: 25.101, 25.104, 25.113, 25.133, 25.306, 25.307, 25.331, 25.461, 25.466, 34.124, 36.101, 36.104, 36.113, 36.124, 36.133, 36.307, new TR 36.832
- 1232: RP#65 completion 06/15=>09/15. . On hold till 12/2014 / Impacted TSs and TRs: 25.133, 25.306, 25.307, 25.331, 25.461, 25.466, 34.124, 36.113, 36.124, 36.133, 36.141, 36.307
- 1233: Triggered by TR 36.874 Study on Coordinated Multi-Point (CoMP) operation for LTE with Non-Ideal Backhaul (UID_600015) / Impacted TSs and TRs: LTE
- 1234: CD:Thu 11/12/14->Mon 15/06/15; Compl:0%->15%; Stat Rep: -->RP-141805 1st Apr 15: Compl:15%->30% 1st Apr 15: Stat Rep: RP-141805->RP-150162 03/07/15: Compl:30%->90% 03/07/15: CD:Mon 15/06/15->Tue 15/09/15 03/07/15: Stat Rep: RP-150162->RP-150846 29/09/1 / Impacted TSs and TRs: 36.300, 36.423
- 1235: Triggered by TR 37.846 Study on 2GHz FDD for UTRA and LTE in Region 1 (1980-2010MHz and 2170-2200MHz Bands) FS_UTRA_LTE_1980_2170_REG1 / Impacted TSs and TRs: LTE
- 1236: CD:Fri 12/06/15->Mon 15/06/15; Compl:5%->15%; Stat Rep: RP-141627->RP-141795 1st Apr 15: Compl:15%->35% 1st Apr 15: WID: RP-141710->RP-150424 1st Apr 15: Stat Rep: RP-141795->RP-150106 03/07/15: Compl:35%->70% 03/07/15: CD:Mon 15/06/15->Tue 15/12/15 03 / Impacted TSs and TRs: 36.101, 36.104, 36.133, 36.141, 36.307, generic TR 36.853 (3 Band CA with 1UL), New TR 36.862 (Technical Report for 2 GHz Band in Region 1)
- 1237: CD:Fri 12/06/15->Mon 15/06/15; Compl:0%->0%; Stat Rep: RP-141627->RP-141795 1st Apr 15: WID: RP-141710->RP-150424 1st Apr 15: Stat Rep: RP-141795->RP-150106 03/07/15: CD:Mon 15/06/15->Tue 15/12/15 03/07/15: Stat Rep: RP-150106->RP-150705 29/09/15: Stat / Impacted TSs and TRs: 36.101, 36.104, 36.133, 36.141, 36.307, 36.862
- 1238: testing REL-13 LTE_1980_2170_REG1-Core and LTE_1980_2170_REG3-Core;
- 1239: Triggered by TR 37.822 Study on Next-Generation SON for UTRA and LTE (FS_UTRA_LTE_NG_SON) / Impacted TSs and TRs: LTE
- 1240: CD:Tue 16/06/15->Mon 15/06/15; Compl:0%->15%; Stat Rep: -->RP-141854 1st Apr 15: Compl:15%->25% 1st Apr 15: Stat Rep: RP-141854->RP-150110 03/07/15: Compl:25%->100% 03/07/15: Stat Rep: RP-150110->RP-150727 / Impacted TSs and TRs: 36.300, 36.423, 36.413, 25.413
- 1242: June2015: Compl:6%->100. Verbal indication from SA2 chair / Impacted TSs and TRs: 23.203
- 1243: Mar.15: 10->100% / Impacted TSs and TRs: 29.212, 29.215
- 1245: . 12/12:0->100%. 5/5/15: acronym changed from ePCSCF_WLAN-CT1 to ePCSCF_WLAN / Impacted TSs and TRs: 24.229, 24.302
- 1246: Mar.15: 0->100%. 5/5/15: acronym changed from ePCSCF_WLAN-CT1 to ePCSCF_WLAN / Impacted TSs and TRs: 29.274, 29.275
- 1247: WID added, acronym. June 2015: WID: CP-140995-> CP-150275
- 1248: CT4->CT1. 2/4/15: acronym changed to PCSCF_RES_WLAN; June2015: Compl:0%->10. June 2015: WID: CP-140995-> CP-150275; 07/09/15: 10%->70; 7/12/15: 70%->100 / Impacted TSs and TRs: 24.302, 24.229, 24.244, 24.008
- 1249: Dec.14: 0->5%. Mar.15: 5->100%. 2/4/15: acronym changed to PCSCF_RES_WLAN; June2015: Compl:100%->75. June 2015: WID: CP-140995-> CP-150275; 07/09/15: 75%->85; 7/12/15: 85%->100 / Impacted TSs and TRs: New 29.8xy, 23.380, 29.273, 29.274, 29.275, 23.008

| ID | WBS | Task | Duration | Start | Finish | Complete | Remaining | Total slack | Constraint | Resources | Work | Actual work | Acronym | PCG approved | WI rapporteur name | WI rapporteur e-mail | Release | TSG approved |
| --- | --- | --- | --- | --- | --- | --- | --- | --- | --- | --- | --- | --- | --- | --- | --- | --- | --- | --- |
| 1250 | 465 | **Mobile Equipment Identity signalling over WLAN** | 69d? | 2015-06-15 A | 2015-09-17 A | 100% |  |  |  | C4 | 1656h | 1656h | MEI_WLAN | 35 | Bruno Landais, Alcatel-Lucent | bruno.landais@alcatel-lucent.com | Rel-13 | 68 |
| 1251 | 465.1 | CT1 aspects of Mobile Equipment Identity signalling over WLAN | 69d? | 2015-06-15 A | 2015-09-17 A | 100% |  |  | start no earlier than 2015-06-15 | C1 | 552h | 552h | MEI_WLAN | 35 | Bruno Landais, Alcatel-Lucent | bruno.landais@alcatel-lucent.com | Rel-13 | 68 |
| 1252 | 465.2 | CT4 aspects of Mobile Equipment Identity signalling over WLAN | 69d? | 2015-06-15 A | 2015-09-17 A | 100% |  |  | start no earlier than 2015-06-15 | C4 | 552h | 552h | MEI_WLAN | 35 | Bruno Landais, Alcatel-Lucent | bruno.landais@alcatel-lucent.com | Rel-13 | 68 |
| 1253 | 466 | Authentication Signalling Improvements for WLAN | 195d? | 2015-06-15 A | 2016-03-11 A | 100% |  |  | finish no earlier than 2016-03-11 | C1 | 1560h | 1560h | ASI_WLAN | 35 | Youyang Yu | yuyouyang@huawei.com | Rel-13 | 68 |
| 1254 | 467 | **Stage-3 SAE Protocol Development - Phase 4** | 268d? | 2014-12-03 A | 2015-12-11 A | 100% |  |  |  | C1 | 8576h | 8576h | SAES4 | 34 | interdigital |  | Rel-13 | 66 |
| 1255 | 467.1 | SAE Protocol Development (Stage 3) - Phase 4 | 268d? | 2014-12-03 A | 2015-12-11 A | 100% |  |  | start no earlier than 2014-12-03 | C1 | 2144h | 2144h | SAES4 | 34 | interdigital |  | Rel-13 | 66 |
| 1256 | 467.2 | CS Fallback in EPS - Phase 4 | 268d? | 2014-12-03 A | 2015-12-11 A | 100% |  |  | start no earlier than 2014-12-03 | C1 | 2144h | 2144h | SAES4-CSFB | 34 | interdigital |  | Rel-13 | 66 |
| 1257 | 467.3 | SAE for support for non-3GPP accesses - Phase 4 | 268d? | 2014-12-03 A | 2015-12-11 A | 100% |  |  | start no earlier than 2014-12-03 | C1 | 2144h | 2144h | SAES4-non3GPP | 34 | interdigital |  | Rel-13 | 66 |
| 1258 | 468 | **Interworking solution for Called IN number and original called IN number ISUP parameters** | 73d? | 2014-12-03 A | 2015-03-13 | 74% | 19.1d? | 1372d |  | C1; C3 | 2354.5h | 1738.34h | INNB_IW | 34 | Orange |  | Rel-13 | 66 |
| 1259 | 468.1 | Interworking solution for Called IN number and original called IN number ISUP parameters | 73d? | 2014-12-03 A | 2015-03-13 A | 100% |  |  | start no earlier than 2014-12-03 | C1 | 584h | 584h | INNB_IW | 34 | Orange |  | Rel-13 | 66 |
| 1260 | 468.2 | (IETF) CT1 part of Interworking solution for Called IN number and original called IN number ISUP parameters | 51.75d? | 2014-12-03 | 2015-03-10 |  |  | 1375d | finish no earlier than 2015-03-10 | C1-IETF | 414h |  | INNB_IW | 34 | Orange |  | Rel-13 | 66 |
| 1261 | 468.3 | CT3 aspects of Interworking solution for Called IN number and original called IN number ISUP parameters | 73d? | 2014-12-03 A | 2015-03-13 A | 100% |  |  | finish no earlier than 2015-03-13 | C3 | 584h | 584h | INNB_IW | 34 | Orange |  | Rel-13 | 66 |
| 1262 | 469 | **Warning Status Report in EPS** | 204d? | 2014-12-03 A | 2015-09-14 A | 100% |  |  |  | C4 | 4896h | 4896h | WSR_EPS | 34 | one2many |  | Rel-13 | 66 |
| 1263 | 469.1 | CT1 aspects of Warning Status Report in EPS | 204d? | 2014-12-03 A | 2015-09-14 A | 100% |  |  | start no earlier than 2014-12-03 | C1 | 1632h | 1632h | WSR_EPS | 34 | one2many |  | Rel-13 | 66 |
| 1264 | 469.2 | CT4 aspects of Warning Status Report in EPS | 204d? | 2014-12-03 A | 2015-09-14 A | 100% |  |  | finish no earlier than 2015-09-14 | C4 | 1632h | 1632h | WSR_EPS | 34 | one2many |  | Rel-13 | 66 |
| 1265 | 470 | Shared Data Update for Multiple Subscriber | 1d? | 2014-12-03 A | 2014-12-03 A | 100% |  |  | start no earlier than 2014-12-03 | C4 | 8h | 8h | SHARED_SubData_UPD | 34 | Huawei, Susan Shi | susan.shishufeng@huawei.com | Rel-13 | 66 |
| 1266 | 471 | **IMS Stage-3 IETF Protocol Alignment** | 666d? | 2014-12-03 A | 2017-06-20 | 70% | 199.79d? | 779d |  | C1 | 11760h | 6003.22h | IMSProtoc7 | 34 | Alcatel-Lucent | Keith Drage | Rel-13 | 66 |
| 1267 | 471.1 | CT1 aspects of IMS Stage-3 IETF Protocol Alignment | 268d? | 2014-12-03 A | 2015-12-11 A | 100% |  |  | finish no earlier than 2015-12-11 | C1 | 2144h | 2144h | IMSProtoc7 | 34 | Alcatel-Lucent | Keith Drage | Rel-13 | 66 |
| 1268 | 471.2 | (IETF) CT1 aspects of IMS Stage-3 IETF Protocol Alignment | 268d? | 2016-06-13 A | 2017-06-20 | 10% | 241.2d? | 779d | finish no earlier than 2015-12-11 | C1 | 2144h | 214.4h | IMSProtoc7 | 34 | Alcatel-Lucent | Keith Drage | Rel-13 | 66 |
| 1269 | 471.3 | CT3 aspects of IMS Stage-3 IETF Protocol Alignment | 268d? | 2014-12-03 A | 2015-12-11 A | 100% |  |  | start no earlier than 2014-12-03 | C3 | 2144h | 2144h | IMSProtoc7 | 34 | Alcatel-Lucent | Keith Drage | Rel-13 | 67 |
| 1270 | 472 | Retry restriction for Improving System Efficiency | 205d? | 2015-03-04 A | 2015-12-15 A | 100% |  |  | finish no earlier than 2015-12-15 | C1 | 1640h | 1640h | RISE | 34 | Huawei, Lin Shu | shulin@huawei.com | Rel-13 | 67 |
| 1271 | 473 | **H.248 Aspects of WebRTC Data Channel on IMS Access Gateway** | 268d? | 2015-03-04 A | 2016-03-11 A | 100% |  |  |  | C4 | 4288h | 4288h | WebRTCH248DC | 34 | China Mobile, Xiaoning Du | duxiaoning@chinamobile.com | Rel-13 | 67 |
| 1272 | 473.1 | CT4 Aspect of H.248 Aspects of WebRTC Data Channel on IMS Access Gateway | 268d? | 2015-03-04 A | 2016-03-11 A | 100% |  |  | finish no earlier than 2016-03-11 | C4 | 2144h | 2144h | WebRTCH248DC | 34 | China Mobile, Xiaoning Du. ES in 639 | duxiaoning@chinamobile.com | Rel-13 | 67 |
| 1273 | 474 | Continuation of the Overload Control for PCC based Diameter applications | 203d? | 2015-03-04 A | 2015-12-11 A | 100% |  |  | finish no earlier than 2015-12-11 | C3 | 1624h | 1624h | cDOCME_PCC | 34 | ZTE, Zhou Xiaoyun | zhou.xiaoyun@zte.com.cn | Rel-13 | 67 |
| 1274 | 475 | Review of dedicated 3GPP UICC features | 200d? | 2015-03-09 A | 2015-12-11 A | 100% |  |  | finish no earlier than 2015-12-11 | C6 | 1600h | 1600h | Red_UCe | 34 | Blackberry, Adrian Buckley | abuckley@blackberry.com | Rel-13 | 67 |

Notes:
- 1250: Impacted TSs and TRs: 24.244, 24.302, 29.273, 29.274, 29.275, 23.008
- 1251: 07/09/15: 0%->80; 7/12/15: 80%->100 / Impacted TSs and TRs: 24.244, 24.302
- 1252: 07/09/15: 0%->90; 7/12/15: 90%->100 / Impacted TSs and TRs: 29.273, 29.274, 29.275, 23.008
- 1253: 07/09/15: 0%->40; 7/12/15: 40%->95. FCD -> 03/16, ES in CP-150727; 7/3/16: 95%->100 / Impacted TSs and TRs: 24.302, 24.244
- 1254: WP Structure created 24/03/15 to avoid confusion in Acronyms / Impacted TSs and TRs: 23.12, 24.008, 24.167, 24.229, 24.301, 24.302, 24.303, 24.304, 24.305, 24.312, 29.018, 29.118
- 1255: WP Structure created 24/03/15 to avoid confusion in Acronyms. 5/5/15: acronym changed from "SAES4-CT1"; June2015: Compl:0%->30; 07/09/15: 30%->70; 7/12/15: 70%->100
- 1256: WP Structure created 24/03/15 to avoid confusion in Acronyms; June2015: Compl:0%->30; 07/09/15: 30%->70; 7/12/15: 70%->100
- 1257: WP Structure created 24/03/15 to avoid confusion in Acronyms; June2015: Compl:0%->30; 07/09/15: 30%->50; 7/12/15: 50%->100
- 1259: 5/5/15: created; June2015: Compl:0%->70; 07/09/15: 70%->100 / Impacted TSs and TRs: 24.229
- 1260: Mar15: resp WG:C1->C1-IETF. WID changed from INNB_IW-CT1 / Impacted TSs and TRs: draft-mohali-dispatch-cause-for-service-number
- 1261: Mar.15: 80->90%. WID changed from INNB_IW-CT3; June2015: Compl:0%->98; 07/09/15: 98%->99; 7/12/15: 99%->100
- 1262: 5/5/15: acronym changed from "WSR_EP"; 7/12/15: WID:CP-140998->CP-150792
- 1263: 2/4/15: acronym changed to WSR_EP. 5/5/15: acronym changed from "WSR_EP"; 07/09/15: 0%->25; 7/12/15: 25%->100; 7/12/15: WID:CP-140998->CP-150792 / Impacted TSs and TRs: New TR 23.712
- 1264: 2/4/15: acronym changed to WSR_EP. 5/5/15: acronym changed from "WSR_EP"; 7/12/15: 0%->100; 7/12/15: WID:CP-140998->CP-150792
- 1265: Mar.15: 0->50%, WID: CP-140804->CP-150013; June2015: Compl:50%->95; 07/09/15: 95%->100 / Impacted TSs and TRs: 29.328, 29.364
- 1266: Mar.15: 0->10% / Impacted TSs and TRs: 23.218, 24.998, 24.930
- 1267: Mar.15: 0->10%; June2015: Compl:10%->30; 07/09/15: 30%->70; 7/12/15: 70%->100
- 1268: Impacted TSs and TRs: draft-ietf-mmusic-dtls-sdp, draft-ietf-mmusic-4572-update
- 1269: 2/4/15: added, following CT3 chair's info that the WID also has a CT3 part; June2015: Compl:0%->20; 07/09/15: 20%->40; 7/12/15: 40%->100
- 1270: Continuation of Rel-12 SINE UID 620006. 5/5/15: acronym changed from "RISE"; June2015: Compl:0%->10; 07/09/15: 10%->70; 14/09/15: WID:CP-150092->CP-150495; 7/12/15: 70%->100
- 1271: Impacted TSs and TRs: 23.334
- 1272: June2015: Compl:0%->10; 07/09/15: 10%->20; 7/12/15: 20%->90; 7/3/16: 90%->100 / Impacted TSs and TRs: 23.334
- 1273: Relates to UID 580026 (Study on Diameter overload control mechanism); June2015: Compl:0%->100 / Impacted TSs and TRs: 29.212, 29.215, 29.219, 29.217
- 1274: Results from the homonymous Study; June2015: Compl:0%->60; 07/09/15: 60%->75; 7/3/16: 75%->100 / Impacted TSs and TRs: 31.102, 31.111, 31.121, 31.124

| ID | WBS | Task | Type | Duration | Start | Finish | Complete | Baseline start | Baseline finish | Baseline duration | Constraint | Resources | Work | Actual work | Acronym | PCG approved | WI rapporteur name | WI rapporteur e-mail | Release | TSG approved | Status Report | Acronym_3GU_Export | TSG stopped | MCC resp |
| --- | --- | --- | --- | --- | --- | --- | --- | --- | --- | --- | --- | --- | --- | --- | --- | --- | --- | --- | --- | --- | --- | --- | --- | --- |
| 1275 | 476 | **Controlling IMS Media Plane with SDP Capability** |  | 195d? | 2015-06-15 A | 2016-03-11 A | 100% |  |  |  |  | C4 | 4680h | 4680h | SDPCN_IMS | 35 | Weiwei(Tommy) Yang, Huawei. ES in 640 | tommy@huawei.com | Rel-13 | 68 |  |  |  |  |
| 1276 | 476.1 | CT3 aspects of Controlling IMS Media Plane with SDP Capability |  | 195d? | 2015-06-15 A | 2016-03-11 A | 100% |  |  |  | finish no earlier than 2016-03-11 | C3 | 1560h | 1560h | SDPCN_IMS | 35 | Weiwei(Tommy) Yang, Huawei. ES in 640 | tommy@huawei.com | Rel-13 | 68 |  |  |  |  |
| 1277 | 476.2 | CT4 aspects of Controlling IMS Media Plane with SDP Capability |  | 195d? | 2015-06-15 A | 2016-03-11 A | 100% |  |  |  | finish no earlier than 2016-03-11 | C4 | 1560h | 1560h | SDPCN_IMS | 35 | Weiwei(Tommy) Yang, Huawei. ES in 640 | tommy@huawei.com | Rel-13 | 68 |  |  |  |  |
| 1278 | 477 | **(SA66: on hold) Co-ordinated packet data network gateway (P-GW) change for SIPTO** |  | 66d? | 2014-06-18 A | 2014-09-16 A | 100% | 2014-06-18 | 2014-09-17 | 66d? |  | S1 | 1056h | 1056h | CSIPTO | 33 | Intel | Eric.siow@intel.com | Rel-13 | 64 | S1-143306 | CSIPTO |  |  |
| 1279 | 477.1 | Stage 1 for Co-ordinated packet data network gateway (P-GW) change for SIPTO |  | 66d? | 2014-06-18 A | 2014-09-16 A | 100% | 2014-06-18 | 2014-09-17 | 66d? | finish no earlier than 2014-09-17 | S1 | 528h | 528h | CSIPTO-ST1 | 33 | Intel | Eric.siow@intel.com | Rel-13 | 64 | S1-143306 | CSIPTO |  |  |
| 1280 | 478 | **Enhanced CS Fallback (CSFB)** |  | 196d? | 2014-06-18 A | 2015-03-13 A | 100% | 2014-06-18 | 2015-03-18 | 196d? |  | S2; S3 | 4168h | 2600h | eCSFB | 33 | China Unicom | Yang Xu (xuyang49@chinaunicom.cn) | Rel-13 | 64 |  | eCSFB |  |  |
| 1281 | 478.1 | TR for Enhanced CS Fallback (CSFB) |  | 128d? | 2014-06-18 A | 2014-12-12 A | 100% | 2014-06-18 | 2014-12-10 | 126d? | finish no earlier than 2014-12-12 | S2 | 1024h | 1024h | eCSFB | 33 | China Unicom | Yang Xu (xuyang49@chinaunicom.cn) | Rel-13 | 64 |  |  |  |  |
| 1282 | 478.2 | Deleted - Stage 2 for Enhanced CS Fallback (CSFB) | milestone | 0d? | 2015-03-13 A | 2015-03-13 A | 100% | 2014-06-18 | 2015-03-18 | 196d? | start no earlier than 2015-03-13 | S2 |  |  | eCSFB | 33 | China Unicom | Yang Xu (xuyang49@chinaunicom.cn) | Rel-13 | 64 |  |  | SP-69 |  |
| 1283 | 478.3 | Deleted - Security for Enhanced CS Fallback (CSFB) |  | 1d? | 2014-09-18 A | 2014-09-18 A | 100% |  |  |  | start no earlier than 2014-09-17 | S3 | 8h | 8h | eCSFB | 33 | China Unicom | Feng Gao (gaofeng149@chinaunicom.cn) | Rel-13 | 65 |  |  | SP-69 |  |
| 1284 | 479 | **SRVCC Enhancements for Transcoding Avoidance** |  | 196d? | 2014-09-19 A | 2015-06-17 A | 100% |  |  |  |  | S2 | 2592h | 2592h | SETA | 33 | Ericsson | George.Foti@ericsson.com | Rel-13 | 65 |  | SETA |  |  |
| 1285 | 479.1 | TR for SRVCC Enhancements for Transcoding Avoidance |  | 128d? | 2014-09-19 A | 2015-03-13 A | 100% |  |  |  | finish no earlier than 2015-03-13 | S2 | 1024h | 1024h | SETA-SA2TR | 33 | Ericsson | George.Foti@ericsson.com | Rel-13 | 65 |  |  |  |  |
| 1286 | 479.2 | Deleted - Stage 2 for SRVCC Enhancements for Transcoding Avoidance | milestone | 0d? | 2015-06-17 A | 2015-06-17 A | 100% |  |  |  | start no earlier than 2015-06-17 | S2 |  |  | SETA-SA2 | 33 | Ericsson | George.Foti@ericsson.com | Rel-13 | 65 |  |  | SP-69 |  |
| 1287 | 480 | **Base Station (BS) RF requirements for Active Antenna System (AAS)** |  | 933d? | 2013-03-04 A | 2016-09-15 A | 100% | 2013-03-04 | 2014-12-05 | 465d? |  | R4 | 21184h | 21184h | AAS_BS_LTE_UTRA | 30 | Huawei | ronnie.zhang@huawei.com | Rel-13 | 59 |  | AAS_BS_LTE_UTRA |  | Issam |
| 1288 | 480.1 | Core part: Base Station (BS) RF requirements for Active Antenna System (AAS) |  | 793d? | 2013-03-04 A | 2016-03-15 A | 100% | 2013-03-04 | 2014-09-12 | 401d? | finish no earlier than 2016-03-15 | R4 | 6344h | 6344h | AAS_BS_LTE_UTRA-Core | 30 | Huawei | ronnie.zhang@huawei.com | Rel-13 | 59 | RP-151241 | AAS_BS_LTE_UTRA-Core |  | Issam |
| 1289 | 480.2 | Perf. part: Base Station (BS) RF requirements for Active Antenna System (AAS) |  | 922d? | 2013-03-15 A | 2016-09-15 A | 100% | 2013-03-07 | 2014-12-05 | 461d? | finish no earlier than 2016-09-15 | R4 | 7376h | 7376h | AAS_BS_LTE_UTRA-Perf | 30 | Huawei | ronnie.zhang@huawei.com | Rel-13 | 59 | RP-151241 | AAS_BS_LTE_UTRA-Perf |  | Issam |
| 1290 | 481 | **Enhanced LTE Device to Device Proximity Services** |  | 460d? | 2014-12-15 A | 2016-09-15 A | 100% |  |  |  |  | R2 | 11016h | 11016h | LTE_eD2D_Prox | 34 | Qualcomm | Qualcomm | Rel-13 | 66 |  |  |  |  |
| 1291 | 481.1 | Core part: Enhanced LTE Device to Device Proximity Services |  | 152.33d? | 2015-08-14 A | 2016-03-15 A | 100% |  |  |  | finish no earlier than 2016-03-15 | R2; R1; R3 | 3656h | 3656h | LTE_eD2D_Prox-Core | 34 | Qualcomm Incorporated, Shailesh Patil | patil@qti.qualcomm.com | Rel-13 | 66 | RP-151337 |  |  |  |
| 1292 | 481.2 | Perf. part: Enhanced LTE Device to Device Proximity Services |  | 460d? | 2014-12-15 A | 2016-09-15 A | 100% |  |  |  | finish no earlier than 2016-09-15 | R4 | 3680h | 3680h | LTE_eD2D_Prox-Perf | 34 | Qualcomm | Qualcomm | Rel-13 | 66 | RP-151337 |  |  |  |
| 1293 | 482 | **Radiated requirements for the verification of multi-antenna reception performance of UEs** |  | 327d? | 2014-12-15 A | 2016-03-15 A | 100% |  |  |  |  | R4 | 5232h | 5232h | UTRA_LTE_MIMO_OTA | 34 | Intel | Intel | Rel-13 | 66 | RP-171826 |  |  |  |
| 1294 | 482.1 | Core part: Radiated requirements for the verification of multi-antenna reception performance of UEs |  | 327d? | 2014-12-15 A | 2016-03-15 A | 100% |  |  |  | finish no earlier than 2016-03-15 | R4 | 2616h | 2616h | UTRA_LTE_MIMO_OTA-Core | 34 | Intel | Intel | Rel-13 | 66 | RP-151573 |  |  |  |
| 1295 | 483 | **UE core requirements for uplink 64 QAM** |  | 197d? | 2014-12-15 A | 2015-09-15 A | 100% |  |  |  |  | R4 | 3152h | 3152h | LTE_UL64QAM | 34 | Huawei | Huawei | Rel-13 | 66 |  |  |  |  |
| 1296 | 483.1 | Core part: UE core requirements for uplink 64 QAM |  | 197d? | 2014-12-15 A | 2015-09-15 A | 100% |  |  |  | finish no earlier than 2015-09-15 | R4 | 1576h | 1576h | LTE_UL64QAM-Core | 34 | Huawei | Huawei | Rel-13 | 66 | RP-151244 |  |  |  |
| 1297 | 484 | UE Conformance Test Aspects - Core Requirements for Uplink 64QAM for E-UTRA |  | 132d? | 2015-06-15 A | 2015-12-15 A | 100% |  |  |  | finish no earlier than 2015-12-15 | R5 | 1056h | 1056h | LTE_UL64QAM-UEConTest | 35 | CMCC |  | Rel-13 | 68 | RP-151174 |  |  |  |
| 1298 | 485 | **Performance requirements of MMSE-IRC receiver for LTE BS** |  | 393d? | 2014-12-15 A | 2016-06-15 A | 100% |  |  |  |  | R4 | 6288h | 6288h | LTE_MMSE_IRC_BS | 34 | China Telecom | China Telecom | Rel-13 | 66 |  |  |  |  |
| 1299 | 485.1 | Perf. part: Performance requirements of MMSE-IRC receiver for LTE BS |  | 393d? | 2014-12-15 A | 2016-06-15 A | 100% |  |  |  | finish no earlier than 2016-06-15 | R4 | 3144h | 3144h | LTE_MMSE_IRC_BS-Perf | 34 | China Telecom | China Telecom | Rel-13 | 66 | RP-151215 |  |  |  |

Notes:
- 1275: Impacted TSs and TRs: 23.334, 29.334, 29.162, 29.238, 23.333, 29.333, 29.163, 29.332, 29.292, 29.232, 29.235
- 1276: 7/12/15: 0%->90. FCD->03/16. ES in CP-150614; 7/3/16: 90%->100 / Impacted TSs and TRs: 29.162, 29.163, 29.292, 29.235
- 1277: 07/09/15: 0%->5; 7/12/15: 5%->70. FCD->03/16. ES in CP-150614; 7/3/16: 70%->100 / Impacted TSs and TRs: 23.334, 29.334, 29.238, 23.333, 29.333, 29.332, 29.232
- 1278: SP#65 completed. Updated WID SP-140235=>SP-140509. Triggered by Rel-13 Study TR 22.828 (FS_CSIPTO) / Impacted TSs and TRs: 22.101
- 1279: SP#65 completed. Updated WID SP-140235=>SP-140509. Triggered by Rel-13 Study TR 22.828 (FS_CSIPTO). Dec.14: former S1-only feature split / Impacted TSs and TRs: 22.101
- 1280: SP#65 updated ID SP-140285=>SP-140579 (added SA3 part). Linked to Rel-8 WIs Single Radio Voice Call Continuity for 3GPP (SAES-SRVCC) and CS Fallback in EPS (SAES-CSFB) / Impacted TSs and TRs: Stage 2
- 1281: SP#65 updated ID SP-140285=>SP-140579 (added SA3 part). Dec.14: 35->85%; 14/09/15: 85%->100. SA#69: decision not to continue the work on this. No normative work. / Impacted TSs and TRs: New TR 23.772
- 1282: SP#65 updated ID SP-140285=>SP-140579 (added SA3 part) / Impacted TSs and TRs: 23.272
- 1283: SP#65 updated ID SP-140285=>SP-140579; 14/09/15: 0%->100. SA#69: deleted, since SA2 has stopped the work.
- 1284: Enhance chances for end-to-end transcoder free operation (TrFo) where possible/ ensure proper CS radio resources are reserved for optimal RAN codec. Address TrFo of EVS codecs during SRVCC that are not covered by Rel-12 / Impacted TSs and TRs: Stage 2
- 1285: Dec.14: 0->70%; 14/09/15: 70%->100. Stopped without conclusion, no intention to continue the study nor to do any mormative work. / Impacted TSs and TRs: New TR 23.7xy
- 1286: SA#69: stop the work on this. / Impacted TSs and TRs: 23.216, 23.237
- 1287: Triggered by Rel-12 TR 37.840 Study of RF and EMC Requirements for Active Antenna Array System BS (FS_AAS_BS_LTE_UTRA) / Impacted TSs and TRs: UTRA, LTE, GERAN
- 1288: ; CD:Thu 11/12/14->Tue 15/12/15; WID: RP-141966->RP-142235; Stat Rep: RP-141249->RP-141908; Release: Rel-12->Rel-13 03/07/15: Stat Rep: RP-141908->RP-150687 29/09/15: Compl:75%->80% 29/09/15: Stat Rep: RP-150687->RP-151241; / Impacted TSs and TRs: New TS 37.142 (AAS BS Tx & Rx), New TR 37.842, 37.114, 37.145-1, 37.145-2
- 1289: ; CD:Sat 18/06/16->Wed 15/06/16; WID: RP-141966->RP-142235; Stat Rep: RP-141249->RP-141908; Release: Rel-12->Rel-13 03/07/15: Stat Rep: RP-141908->RP-150687 29/09/15: Stat Rep: RP-150687->RP-151241 22/3/16: Compl:2 26/9/16: Compl:95%->100% / Impacted TSs and TRs: New TS 37.1xy (AAS BS conformance testing)
- 1291: Rapporteur details and involved WGs updated 1st Apr 15: WID: RP-142311->RP-150441 1st Apr 15: Stat Rep: ->RP-150095 03/07/15: Compl:0%->32% 03/07/15: Stat Rep: RP-150095->RP-150795 29/09/15: Compl:32%->55% 29/09/15: Stat Rep: RP-150795->RP-151337;
- 1292: 1st Apr 15: WID: RP-142311->RP-150441 1st Apr 15: Stat Rep: ->RP-150095 03/07/15: Stat Rep: RP-150095->RP-150795 29/09/15: Stat Rep: RP-150795->RP-151337; 1/1/16: CD; 22/3/16: Compl:0%->10%;26/9/16: Compl:85%->100%
- 1294: 1st Apr 15: Compl:0%->5% 1st Apr 15: WID: RP-142221->RP-150261 1st Apr 15: Stat Rep: ->RP-150260 03/07/15: Compl:5%->15% 03/07/15: Stat Rep: RP-150260->RP-150746 29/09/15: Compl:15%->25% 29/09/15: WID: RP-150261->RP-151574 29/09/15: Stat Rep: RP-15074
- 1296: 1st Apr 15: Compl:0%->10% 1st Apr 15: Stat Rep: ->RP-150232 03/07/15: Compl:10%->90% 03/07/15: WID: RP-142222->RP-150691 03/07/15: Stat Rep: RP-150232->RP-150688 29/09/15: Compl:90%->100% 29/09/15: Stat Rep: RP-150688->RP-151244
- 1297: tested Core part: LTE_UL64QAM-Core which is not yet completed 29/09/15: Compl:0%->5% 29/09/15: Stat Rep: -->RP-151174 1/1/16: Compl:5%->100%
- 1299: 1st Apr 15: Compl:0%->10% 1st Apr 15: WID: RP-142223->RP-150206 1st Apr 15: Stat Rep: ->RP-150204 03/07/15: Compl:10%->35% 03/07/15: Stat Rep: RP-150204->RP-150630 29/09/15: Compl:35%->50% 29/09/15: Stat Rep: RP-150630->RP-151215;

| ID | WBS | Task | Duration | Start | Finish | Complete | Remaining | Total slack | Constraint | Resources | Work | Actual work | Acronym | PCG approved | WI rapporteur name | WI rapporteur e-mail | Release | TSG approved | Status Report |
| --- | --- | --- | --- | --- | --- | --- | --- | --- | --- | --- | --- | --- | --- | --- | --- | --- | --- | --- | --- |
| 1300 | 486 | **CRS Interference Mitigation for LTE Homogenous Deployments** | 327d? | 2014-12-15 A | 2016-03-15 A | 100% |  |  |  | R4 | 5232h | 5232h | LTE_CRSIM | 34 | Ericsson | Ericsson | Rel-13 | 66 |  |
| 1301 | 486.1 | Perf. part: CRS Interference Mitigation for LTE Homogenous Deployments | 327d? | 2014-12-15 A | 2016-03-15 A | 100% |  |  | finish no earlier than 2016-03-15 | R4 | 2616h | 2616h | LTE_CRSIM-Perf | 34 | Ericsson | Ericsson | Rel-13 | 66 | RP-151171 |
| 1302 | 487 | **Dual Connectivity enhancements for LTE** | 328d? | 2015-03-16 A | 2016-06-15 A | 100% |  |  |  | R2 | 6824h | 6824h | LTE_dualC_enh | 34 | NTT DOCOMO |  | Rel-13 | 67 |  |
| 1303 | 487.1 | Core part: Dual Connectivity enhancements for LTE | 197d? | 2015-03-16 A | 2015-12-15 A | 100% |  |  | finish no earlier than 2015-12-15 | R2 | 1576h | 1576h | LTE_dualC_enh-Core | 34 | NTT DOCOMO |  | Rel-13 | 67 | RP-151330 |
| 1304 | 487.2 | Perf. part: Dual Connectivity enhancements for LTE | 328d? | 2015-03-16 A | 2016-06-15 A | 100% |  |  | finish no earlier than 2016-06-15 | R4 | 2624h | 2624h | LTE_dualC_enh-Perf | 34 | NTT DOCOMO |  | Rel-13 | 67 | RP-151330 |
| 1305 | 488 | **Multicarrier Load Distribution of UEs in LTE** | 395d? | 2015-03-16 A | 2016-09-15 A | 100% |  |  |  | R2 | 7896h | 7896h | LTE_MC_load | 34 | ZTE |  | Rel-13 | 67 |  |
| 1306 | 488.1 | Core part: Multicarrier Load Distribution of UEs in LTE | 197d? | 2015-03-16 A | 2015-12-15 A | 100% |  |  | finish no earlier than 2015-12-15 | R2 | 1576h | 1576h | LTE_MC_load-Core | 34 | ZTE |  | Rel-13 | 67 | RP-151190 |
| 1307 | 488.2 | Perf. part: Multicarrier Load Distribution of UEs in LTE | 395d? | 2015-03-16 A | 2016-09-15 A | 100% |  |  | finish no earlier than 2016-09-15 | R4 | 3160h | 3160h | LTE_MC_load-Perf | 34 | ZTE |  | Rel-13 | 67 | RP-151190 |
| 1308 | 489 | **LTE-WLAN Radio Level Integration and Interworking Enhancement** | 916d? | 2015-03-16 A | 2018-09-15 | 77% | 213.72d? | 456d |  | R2 | 16760h | 7822.2h | LTE_WLAN_radio | 34 | Intel |  | Rel-13 | 67 |  |
| 1309 | 489.1 | Core part: LTE-WLAN Radio Level Integration and Interworking Enhancement | 262d? | 2015-03-16 A | 2016-03-15 A | 100% |  |  | finish no earlier than 2016-03-15 | R2 | 2096h | 2096h | LTE_WLAN_radio-Core | 34 | Intel |  | Rel-13 | 67 | RP-151563 |
| 1310 | 489.2 | Perf. part: LTE-WLAN Radio Level Integration and Interworking Enhancement | 262d? | 2015-03-16 A | 2016-03-15 A | 100% |  |  | finish no earlier than 2016-03-15 | R4 | 2096h | 2096h | LTE_WLAN_radio-Perf | 34 | Intel |  | Rel-13 | 67 | RP-151563 |
| 1311 | 489.3 | UE Conformance Test Aspects - WLAN/3GPP Radio Level Integration and Interworking Enhancement Interworking | 655d? | 2016-03-15 A | 2018-09-15 | 58% | 275.1d? | 456d | finish no earlier than 2018-09-15 | R5 | 5240h | 3039.2h | LTE_WLAN_radio-UEConTest | 36 | Intel |  | Rel-13 | 71 |  |
| 1312 | 490 | **RAN aspects for improvements to CS/PS coordination in UTRAN Shared Network** | 197d? | 2015-03-16 A | 2015-12-15 A | 100% |  |  |  | R3 | 3152h | 3152h | CSPS_Coord-UTRA | 34 | Ericsson |  | Rel-13 | 67 |  |
| 1313 | 490.1 | Core part: RAN aspects for improvements to CS/PS coordination in UTRAN Shared Network | 197d? | 2015-03-16 A | 2015-12-15 A | 100% |  |  | finish no earlier than 2015-12-15 | R3 | 1576h | 1576h | CSPS_Coord-UTRA-Core | 34 | Ericsson |  | Rel-13 | 67 | RP-151289 |
| 1314 | 491 | **LTE DL 4 Rx antenna ports** | 4639d? | 2000-01-03 A | 2017-09-15 | 99% | 0d? | 0d |  | R4 | 77392h | 46967.7h | LTE_4Rx_AP_DL | 34 | Ericsson |  | Rel-13 | 67 |  |
| 1315 | 491.1 | Core part: LTE DL 4 Rx antenna ports | 197d? | 2015-03-16 A | 2015-12-15 A | 100% |  |  | finish no earlier than 2015-12-15 | R4 | 1576h | 1576h | LTE_4Rx_AP_DL-Core | 34 | Ericsson |  | Rel-13 | 67 | RP-151265 |
| 1316 | 491.2 | Perf. part: LTE DL 4 Rx antenna ports | 4378d? | 2000-01-03 A | 2016-09-15 A | 100% |  |  | finish no earlier than 2016-09-15 | R4 | 35024h | 35024h | LTE_4Rx_AP_DL-Perf | 34 | Ericsson |  | Rel-13 | 67 | RP-151265 |
| 1317 | 491.3 | UE Conformance Test Aspects - LTE DL 4 Rx antenna ports | 460d? | 2015-12-15 A | 2017-09-15 A | 100% |  |  | finish no earlier than 2017-09-15 | R5 | 3680h | 3680h | LTE_4Rx_AP_DL-UEConTest | 36 | Ericsson |  | Rel-13 | 70 |  |
| 1318 | 492 | **AWS-Extension Band for LTE** | 395d? | 2015-03-16 A | 2016-09-15 A | 100% |  |  |  | R4 | 7904h | 7904h | LTE_AWS_EXT | 34 | Ericsson |  | Rel-13 | 67 |  |
| 1319 | 492.1 | Core part: AWS-Extension Band for LTE | 197d? | 2015-03-16 A | 2015-12-15 A | 100% |  |  | finish no earlier than 2015-12-15 | R4 | 1576h | 1576h | LTE_AWS_EXT-Core | 34 | Ericsson |  | Rel-13 | 67 | RP-151343 |
| 1320 | 492.2 | Perf. part: AWS-Extension Band for LTE | 197d? | 2015-03-16 A | 2015-12-15 A | 100% |  |  | finish no earlier than 2015-12-15 | R4 | 1576h | 1576h | LTE_AWS_EXT-Perf | 34 | Ericsson |  | Rel-13 | 67 | RP-151343 |
| 1321 | 492.3 | UE Conformance Test Aspects - AWS-Extension Band for LTE (Band 66) | 199d? | 2015-12-15 A | 2016-09-15 A | 100% |  |  | finish no earlier than 2016-09-15 | R5 | 1592h | 1592h | LTE_AWS_EXT-UEConTest | 36 | Ericsson |  | Rel-13 | 70 |  |
| 1322 | 493 | **Additional bandwidth combination set for LTE Advanced inter-band Carrier Aggregation of Band 5 and Band 7** | 66d? | 2015-03-16 A | 2015-06-15 A | 100% |  |  |  | R4 | 1584h | 1584h | LTE_CA_B5_B7_BWset | 34 | Nokia Networks |  | Rel-13 | 67 |  |
| 1323 | 493.1 | Core part: Additional bandwidth combination set for LTE Advanced inter-band Carrier Aggregation of Band 5 and Band 7 | 66d? | 2015-03-16 A | 2015-06-15 A | 100% |  |  | finish no earlier than 2015-06-15 | R4 | 528h | 528h | LTE_CA_B5_B7_BWset-Core | 34 | Nokia Networks |  | Rel-13 | 67 | RP-150536 |
| 1324 | 493.2 | Perf. part: Additional bandwidth combination set for LTE Advanced inter-band Carrier Aggregation of Band 5 and Band 7 | 66d? | 2015-03-16 A | 2015-06-15 A | 100% |  |  | finish no earlier than 2015-06-15 | R4 | 528h | 528h | LTE_CA_B5_B7_BWset-Perf | 34 | Nokia Networks |  | Rel-13 | 67 | RP-150536 |

Notes:
- 1301: 1st Apr 15: Compl:0%->10% 1st Apr 15: CD:Mon 15/06/15->Tue 15/03/16 1st Apr 15: Stat Rep: ->RP-150061 03/07/15: Compl:10%->20% 03/07/15: Stat Rep: RP-150061->RP-150584 29/09/15: Compl:20%->30% 29/09/15: Stat Rep: RP-150584->RP-151171
- 1303: 03/07/15: Compl:0%->25% 03/07/15: Stat Rep: ->RP-150744 29/09/15: Compl:25%->55% 29/09/15: Stat Rep: RP-150744->RP-151330 1/1/16: Compl:55%->100%
- 1304: 03/07/15: Stat Rep: ->RP-150744 29/09/15: Stat Rep: RP-150744->RP-151330 ; 1/1/16: WID: RP-150490->RP-15173922/3/16: Compl:0%->50%;
- 1306: 03/07/15: Compl:0%->40% 03/07/15: WID: RP-150491->RP-150611 03/07/15: Stat Rep: ->RP-150610 29/09/15: Compl:40%->55% 29/09/15: WID: RP-150611->RP-151206 29/09/15: Stat Rep: RP-150610->RP-151190
- 1307: 03/07/15: WID: RP-150491->RP-150611 03/07/15: Stat Rep: ->RP-150610 29/09/15: WID: RP-150611->RP-151206 29/09/15: Stat Rep: RP-150610->RP-1511901/1/16:22/3/16: Compl:70%->75%; 26/9/16: Compl:90%->100%; 26/9/16: WID: RP-152181
- 1309: 03/07/15: Compl:0%->30% 03/07/15: WID: RP-150510->RP-151114 03/07/15: Stat Rep: ->RP-151081, 07/08/15: impacted TSs added 29/09/15: Compl:30%->35% 29/09/15: Stat Rep: RP-151081->RP-151563; / Impacted TSs and TRs: 36.461, 36.462, 36.463, 36.464, 36.465, 36.622, 36.623, 36.624, 36.625, 36.360
- 1310: 03/07/15: WID: RP-150510->RP-151114 03/07/15: Stat Rep: ->RP-151081 29/09/15: Stat Rep: RP-151081->RP-1515631/1/16: Compl:0%->10% ; 22/3/16: Compl:10%->100%;
- 1311: testing REL-13 LTE_WLAN_radio-Core; 1/7/16: Compl:0%->5%; 20/21/3/17: Compl:20...; ;...; ;...27/3/18: ...
- 1313: 03/07/15: Compl:0%->45% 03/07/15: Stat Rep: ->RP-150842 29/09/15: Compl:45%->80% 29/09/15: CD:Tue 15/09/15->Tue 15/12/15 29/09/15: Stat Rep: RP-150842->RP-1512891/1/16: Compl:80%->100%
- 1315: 03/07/15: Compl:0%->25% 03/07/15: Stat Rep: ->RP-150803 29/09/15: Compl:25%->50% 29/09/15: Stat Rep: RP-150803->RP-151265; 1/1/16: Compl:50%->100%
- 1316: 03/07/15: Compl:0%->15% 03/07/15: CD:Mon 02/10/00->Wed 15/06/16 03/07/15: Stat Rep: ->RP-150803 29/09/15: Compl:15%->35% 29/09/15: Stat Rep: RP-150803->RP-15126522/3/16: Compl:60%-;26/9/16: Compl:90%->100%
- 1317: ; 22/3/16: Compl:0%->10%; 1/7/16: Compl:10%->25%; 26/9/16: 21/3/17: Compl:60%->70...; ;...; ;...
- 1319: 03/07/15: Compl:0%->20% 03/07/15: WID: RP-150428->RP-150800 03/07/15: Stat Rep: ->RP-150796 29/09/15: Compl:20%->50% 29/09/15: Stat Rep: RP-150796->RP-151343
- 1320: 03/07/15: WID: RP-150428->RP-150800 03/07/15: Stat Rep: ->RP-150796 29/09/15: Stat Rep: RP-150796->RP-151343;
- 1321: ; 22/3/16: Compl:0%->10%1/7/16: Compl:10%->65%26/9/16: Comp
- 1323: 03/07/15: Compl:0%->100% 03/07/15: WID: RP-150171->RP-150602 03/07/15: Stat Rep: ->RP-150536
- 1324: 03/07/15: Compl:0%->100% 03/07/15: WID: RP-150171->RP-150602 03/07/15: Stat Rep: ->RP-150536

| ID | WBS | Task | Duration | Start | Finish | Complete | Constraint | Resources | Work | Actual work | Acronym | PCG approved | WI rapporteur name | Release | TSG approved | Status Report | WI rapporteur e-mail | TSG stopped |
| --- | --- | --- | --- | --- | --- | --- | --- | --- | --- | --- | --- | --- | --- | --- | --- | --- | --- | --- |
| 1325 | 494 | **Additional bandwidth combination set for LTE Advanced inter-band Carrier Aggregation of Band 3 and Band 5** | 66d? | 2015-03-16 A | 2015-06-15 A | 100% |  | R4 | 1584h | 1584h | LTE_CA_B3_B5_BWset | 34 | Samsung | Rel-13 | 67 |  |  |  |
| 1326 | 494.1 | Core part: Additional bandwidth combination set for LTE Advanced inter-band Carrier Aggregation of Band 3 and Band 5 | 66d? | 2015-03-16 A | 2015-06-15 A | 100% | finish no earlier than 2015-06-15 | R4 | 528h | 528h | LTE_CA_B3_B5_BWset-Core | 34 | Samsung | Rel-13 | 67 | RP-150536 |  |  |
| 1327 | 494.2 | Perf. part: Additional bandwidth combination set for LTE Advanced inter-band Carrier Aggregation of Band 3 and Band 5 | 66d? | 2015-03-16 A | 2015-06-15 A | 100% | finish no earlier than 2015-06-15 | R4 | 528h | 528h | LTE_CA_B3_B5_BWset-Perf | 34 | Samsung | Rel-13 | 67 | RP-150536 |  |  |
| 1328 | 495 | **Multiflow Enhancements for UTRA** | 132d? | 2015-03-16 A | 2015-09-15 A | 100% |  | R2 | 2112h | 2112h | HSDPA_MFTX_enh | 34 | Nokia | Rel-13 | 67 |  | alexander.sayenko@nokia.com |  |
| 1329 | 495.1 | Core part: Multiflow Enhancements for UTRA | 132d? | 2015-03-16 A | 2015-09-15 A | 100% | finish no earlier than 2015-09-15 | R2 | 1056h | 1056h | HSDPA_MFTX_enh-Core | 34 | Nokia | Rel-13 | 67 | RP-151302 | alexander.sayenko@nokia.com |  |
| 1330 | 496 | **Message interworking during PS to CS SRVCC** | 68d? | 2015-06-15 A | 2015-09-16 A | 100% |  | C1 | 1632h | 1632h | mSRVCC | 35 | Ivo Sedlacek, Ericsson | Rel-13 | 68 |  | ivo.sedlacek@ericsson.com |  |
| 1331 | 496.1 | CT1 aspects of Message interworking during PS to CS SRVCC | 68d? | 2015-06-15 A | 2015-09-16 A | 100% | start no earlier than 2015-06-15 | C1 | 544h | 544h | mSRVCC | 35 | Ivo Sedlacek, Ericsson | Rel-13 | 68 |  | ivo.sedlacek@ericsson.com |  |
| 1332 | 496.2 | CT3 aspects of Message interworking during PS to CS SRVCC | 68d? | 2015-06-15 A | 2015-09-16 A | 100% | finish no earlier than 2015-09-16 | C3 | 544h | 544h | mSRVCC | 35 | Ivo Sedlacek, Ericsson | Rel-13 | 68 |  | ivo.sedlacek@ericsson.com |  |
| 1333 | 497 | **Support of Emergency services over WLAN – phase 1** | 192d? | 2015-06-18 A | 2016-03-11 A | 100% |  | S2 | 5896h | 5896h | SEW1 | 35 | Laurent thiebaut | Rel-13 | 68 |  | Laurent.thiebaut@alcatel-lucent.com |  |
| 1334 | 497.1 | Stage 2 of Support of Emergency services over WLAN - phase 1 | 65d? | 2015-06-18 A | 2015-09-16 A | 100% | finish no earlier than 2015-09-16 | S2 | 520h | 520h | SEW1 | 35 | Laurent thiebaut | Rel-13 | 68 |  | Laurent.thiebaut@alcatel-lucent.com |  |
| 1335 | 497.2 | **CT aspects of Support of Emergency services over WLAN – phase 1** | 135d? | 2015-09-07 A | 2016-03-11 A | 100% |  | ct | 3840h | 3840h | SEW1-CT | 35 | Alcatel-Lucent, Jennifer Liu (CT1) | Rel-13 | 69 |  | jennifer.liu@alcatel-lucent.com |  |
| 1336 | 497.2.1 | CT1 aspects of Support of Emergency services over WLAN – phase 1 | 135d? | 2015-09-07 A | 2016-03-11 A | 100% | finish no earlier than 2016-03-11 | C1 | 1080h | 1080h | SEW1-CT | 35 | Alcatel-Lucent, Jennifer Liu (CT1) | Rel-13 | 69 |  | jennifer.liu@alcatel-lucent.com |  |
| 1337 | 497.2.2 | CT3 aspects of Support of Emergency services over WLAN – phase 1 | 70d? | 2015-09-07 A | 2015-12-11 A | 100% | finish no earlier than 2015-12-11 | C3 | 560h | 560h | SEW1-CT | 35 | Alcatel-Lucent, Jennifer Liu (CT1) | Rel-13 | 69 |  | jennifer.liu@alcatel-lucent.com |  |
| 1338 | 497.2.3 | CT4 aspects of Support of Emergency services over WLAN – phase 1 | 70d? | 2015-09-07 A | 2015-12-11 A | 100% | finish no earlier than 2015-12-11 | C4 | 560h | 560h | SEW1-CT | 35 | Alcatel-Lucent, Jennifer Liu (CT1) | Rel-13 | 69 |  | jennifer.liu@alcatel-lucent.com |  |
| 1339 | 497.2.4 | CT6 aspects of Support of Emergency services over WLAN – phase 1 | 70d? | 2015-09-07 A | 2015-12-11 A | 100% | finish no earlier than 2015-12-11 | C6 | 560h | 560h | SEW1-CT | 35 | Alcatel-Lucent, Jennifer Liu (CT1) | Rel-13 | 69 |  | jennifer.liu@alcatel-lucent.com |  |
| 1340 | 498 | **MBMS Enhancements** | 264d? | 2014-12-03 A | 2015-12-07 A | 100% |  | S2 | 4320h | 4320h | MBMS_enh | 34 | Nokia Networks, Curt Wong | Rel-13 | 66 |  |  |  |
| 1341 | 498.1 | MBMS Enhancements TR Phase | 204d? | 2014-12-03 A | 2015-09-14 A | 100% | finish no earlier than 2015-09-14 | S2 | 1632h | 1632h | FS_MBMS_enh_TR | 34 | Nokia Networks, Curt Wong | Rel-13 | 66 |  |  |  |
| 1342 | 498.2 | MBMS Enhancements | 28d? | 2015-08-10 A | 2015-09-16 A | 100% | finish no earlier than 2015-09-16 | S2 | 224h | 224h | MBMS_enh_St2 | 35 | Nokia Networks, Curt Wong | Rel-13 | 69 |  |  |  |
| 1343 | 498.3 | **CT aspects of MBMS Enhancements** | 21d? | 2015-11-09 A | 2015-12-07 A | 100% |  | C3 | 344h | 344h | MBMS_enh-CT | 36 | Nokia Networks, Thomas Belling | Rel-13 | 70 |  |  |  |
| 1344 | 498.3.1 | CT3 aspects of MBMS enhancements | 21d? | 2015-11-09 A | 2015-12-07 A | 100% | start no earlier than 2015-11-09 | C3 | 168h | 168h | MBMS_enh-CT | 36 | Nokia Networks, Thomas Belling | Rel-13 | 70 |  |  |  |
| 1345 | 498.3.2 | CT4 aspects of MBMS enhancements | 21d? | 2015-11-09 A | 2015-12-07 A | 100% | finish no earlier than 2015-12-07 | C4 | 168h | 168h | MBMS_enh-CT | 36 | Nokia Networks, Thomas Belling | Rel-13 | 70 |  |  |  |
| 1346 | 498.4 | Deleted (not approved) - MBMS Enhancements - Stage 2 | 1d? | 2015-03-13 A | 2015-03-13 A | 100% | finish no earlier than 2015-03-13 | S2 | 8h | 8h | MBMS_enh_TS | 34 | Rainer Liebhart | Rel-13 | 66 |  |  | SP-69 |
| 1347 | 499 | **EPC Signalling Improvements for race scenarios** | 135d? | 2015-09-07 A | 2016-03-11 A | 100% |  | C4 | 2760h | 2760h | EPC_SIG_RACE | 35 | Huawei, Peter Schmitt | Rel-13 | 69 |  | Huawei, Peter Schmitt, Peter.Schmitt@HUAWEI.COM |  |
| 1348 | 499.1 | CT3 aspects for EPC Signalling Improvements for race scenarios | 135d? | 2015-09-07 A | 2016-03-11 A | 100% | finish no earlier than 2016-03-11 | C3 | 1080h | 1080h | EPC_SIG_RACE | 35 | Huawei, Peter Schmitt | Rel-13 | 69 |  | Huawei, Peter Schmitt, Peter.Schmitt@HUAWEI.COM |  |
| 1349 | 499.2 | CT4 aspects for EPC Signalling Improvements for race scenarios | 75d? | 2015-09-07 A | 2015-12-18 A | 100% | finish no earlier than 2015-12-18 | C4 | 600h | 600h | EPC_SIG_RACE | 35 | Huawei, Peter Schmitt | Rel-13 | 69 |  | Huawei, Peter Schmitt, Peter.Schmitt@HUAWEI.COM |  |

Notes:
- 1326: 03/07/15: Compl:0%->100% 03/07/15: Stat Rep: ->RP-150536
- 1327: 03/07/15: Compl:0%->100% 03/07/15: Stat Rep: ->RP-150536
- 1329: 03/07/15: Compl:0%->80% 03/07/15: WID: RP-150288->RP-151021 03/07/15: Stat Rep: ->RP-150827 29/09/15: Compl:80%->100% 29/09/15: Stat Rep: RP-150827->RP-151302
- 1331: 07/09/15: 0%->25; 7/12/15: 25%->100 / Impacted TSs and TRs: 24.237, 24.292
- 1332: 07/09/15: 0%->70; 7/12/15: 70%->100 / Impacted TSs and TRs: 29.292
- 1333: 07/09/15: 0%->100 / Impacted TSs and TRs: TS 23.402, TS 23.167, TS 23.271, TS 23.203, TS 23.228
- 1334: 07/09/15: 0%->100 / Impacted TSs and TRs: TS 23.402, TS 23.167, TS 23.271, TS 23.203, TS 23.228
- 1336: 7/12/15: 60%->95. FCD -> 03/16, ES in CP-150729; 7/3/16: 95%->100 / Impacted TSs and TRs: 24.302, 24.229
- 1337: 7/12/15: 0%->100 / Impacted TSs and TRs: 29.212, 29.214
- 1338: 7/12/15: 0%->100 / Impacted TSs and TRs: 23.003, 23.008, 29.273, 29.274
- 1339: 7/3/16: 0%->100 / Impacted TSs and TRs: 31.102
- 1340: . 3/3: WID tdoc number updated; 14/09/15: WID:SP-140883->SP-150516
- 1341: Acronym changed from "MBMS_enh-SA2TR". Mar15: 0->10%; June2015: Compl:10%->50; 07/09/15: 50%->70. acronym changed from "MBMS_enh" to "MBMS_enh_TR"; 07/09/15: 70%->100; 14/09/15: WID:SP-140883->SP-150516 / Impacted TSs and TRs: TR 23.8xy
- 1342: SA#69: no normative work, moved as Study only. 14/10/15: corrected: was mentioned as FS_ / Impacted TSs and TRs: TS 23.246, TS 23.468
- 1344: 8/12/15: 0%->100 / Impacted TSs and TRs: 29.061, 29.468
- 1345: Impacted TSs and TRs: 29.274, 23.008, 29.230
- 1346: Commented during RAN#67 that it should have never beeen here. 07/09/15: "undeleted", acronym changed from "MBMS_enh-del" to "MBMS_enh_TS". 14/10/15: SP-140883 was never approved so this line should have never appeared in the WP. / Impacted TSs and TRs: TS 23.246, TS 23.468
- 1348: 7/12/15: FCD -> 03/16, ES in CP-150861; 8/12/15: 0%->100 / Impacted TSs and TRs: 29.212, 29.213
- 1349: 7/12/15: 95%->100 / Impacted TSs and TRs: 29.274, 29.274, 29.275, 29.282, 29.273, 29.230, 23.008, 29.273

| ID | WBS | Task | Duration | Start | Finish | Complete | Remaining | Total slack | Constraint | Resources | Work | Actual work | Acronym | PCG approved | WI rapporteur name | WI rapporteur e-mail | Release | TSG approved | Status Report |
| --- | --- | --- | --- | --- | --- | --- | --- | --- | --- | --- | --- | --- | --- | --- | --- | --- | --- | --- | --- |
| 1350 | 500 | **Diameter Message Priority** | 164d? | 2015-11-02 A | 2016-06-16 A | 100% |  |  |  | C4 | 3736h | 3736h | DiaPri | 36 | Alcatel-Lucent, Jean-Jacques Trottin | jean-jacques.trottin@alcatel-lucent.com | Rel-13 | 70 |  |
| 1351 | 500.1 | CT3 aspects of DiaPri | 95d? | 2015-11-02 A | 2016-03-11 A | 100% |  |  | finish no earlier than 2016-03-11 | C3 | 760h | 760h | DiaPri | 36 | Intel, Vivek Gupta |  | Rel-13 | 70 |  |
| 1352 | 500.2 | CT4 aspects of DiaPri | 95d? | 2015-11-02 A | 2016-03-11 A | 100% |  |  | finish no earlier than 2016-03-11 | C4 | 760h | 760h | DiaPri | 36 | Alcatel-Lucent, Jean-Jacques Trottin | jean-jacques.trottin@alcatel-lucent.com | Rel-13 | 70 |  |
| 1353 | 500.3 | (IETF) Diameter Routing Message Priority (draft-ietf-dime- | 138d? | 2015-12-08 A | 2016-06-16 A | 100% |  |  | finish no earlier than 2016-06-16 | C4-IETF | 1104h | 1104h | DiaPri | 36 | Alcatel-Lucent, Jean-Jacques Trottin | jean-jacques.trottin@alcatel-lucent.com | Rel-13 | 71 |  |
| 1354 | 501 | **Downlink TPC Enhancements for UMTS** | 197d? | 2015-06-15 A | 2016-03-15 A | 100% |  |  |  | R1 | 4208h | 4208h | UTRA_EDL_TPC | 35 | Huawei |  | Rel-13 | 68 |  |
| 1355 | 501.1 | Core part: Downlink TPC Enhancements for UMTS | 44d? | 2015-10-15 A | 2015-12-15 A | 100% |  |  | finish no earlier than 2015-12-15 | R1; R2; R3 | 1056h | 1056h | UTRA_EDL_TPC-Core | 35 | Huawei |  | Rel-13 | 68 | RP-151564 |
| 1356 | 501.2 | Perf. part: Downlink TPC Enhancements for UMTS | 197d? | 2015-06-15 A | 2016-03-15 A | 100% |  |  | finish no earlier than 2016-03-15 | R4 | 1576h | 1576h | UTRA_EDL_TPC-Perf | 35 | Huawei |  | Rel-13 | 68 | RP-151564 |
| 1357 | 502 | **Licensed-Assisted Access using LTE** | 591d? | 2015-06-15 A | 2017-09-15 | 99% | 0d? | 0d |  | R1 | 12624h | 8599.11h | LTE_LAA | 35 | Ericsson |  | Rel-13 | 68 |  |
| 1358 | 502.1 | Core part: Licensed-Assisted Access using LTE | 132d? | 2015-06-15 A | 2015-12-15 A | 100% |  |  | finish no earlier than 2015-12-15 | R1 | 1056h | 1056h | LTE_LAA-Core | 35 | Ericsson |  | Rel-13 | 68 | RP-151390 |
| 1359 | 502.2 | Perf. part: Licensed-Assisted Access using LTE | 395d? | 2015-06-15 A | 2016-12-15 A | 100% |  |  | finish no earlier than 2016-12-15 | R4 | 3160h | 3160h | LTE_LAA-Perf | 35 | Ericsson |  | Rel-13 | 68 |  |
| 1360 | 502.3 | UE Conformance Test Aspects - Licensed-Assisted Access using LTE | 460d? | 2015-12-15 A | 2017-09-15 A | 100% |  |  | finish no earlier than 2017-09-15 | R5 | 3680h | 3680h | LTE_LAA-UEConTest | 36 | Motorola Mobility |  | Rel-13 | 70 |  |
| 1361 | 503 | **Elevation Beamforming/Full-Dimension (FD) MIMO for LTE** | 786d? | 2015-06-15 A | 2018-06-15 | 73% | 210.72d? | 521d |  | R1 | 11552h | 6492.8h | LTE_EBF_FDMIMO | 35 | Samsung |  | Rel-13 | 68 |  |
| 1362 | 503.1 | Core part: Elevation Beamforming/Full-Dimension (FD) MIMO for LTE | 132d? | 2015-06-15 A | 2015-12-15 A | 100% |  |  | finish no earlier than 2015-12-15 | R1 | 1056h | 1056h | LTE_EBF_FDMIMO-Core | 35 | Samsung |  | Rel-13 | 68 | RP-151565 |
| 1363 | 503.2 | Perf. part: Elevation Beamforming/Full-Dimension (FD) MIMO for LTE | 330d? | 2015-06-15 A | 2016-09-15 A | 100% |  |  | finish no earlier than 2016-09-15 | R4 | 2640h | 2640h | LTE_EBF_FDMIMO-Perf | 35 | Samsung |  | Rel-13 | 68 | RP-151565 |
| 1364 | 503.3 | UE Conformance Test Aspects - Elevation Beamforming/Full-Dimension MIMO for LTE | 196d? | 2017-09-15 A | 2018-06-15 | 10% | 176.4d? | 521d | finish no earlier than 2018-06-15 | R5 | 1568h | 156.8h | LTE_EBF_FDMIMO-UEConTest | 39 | Ericsson |  | Rel-13 | 77 |  |
| 1365 | 504 | **L2/L3 Downlink enhancements for UMTS** | 132d? | 2015-06-15 A | 2015-12-15 A | 100% |  |  |  | R2 | 2112h | 2112h | UTRA_EDL_L23 | 35 | Huawei |  | Rel-13 | 68 |  |
| 1366 | 504.1 | Core part: L2/L3 Downlink enhancements for UMTS | 132d? | 2015-06-15 A | 2015-12-15 A | 100% |  |  | finish no earlier than 2015-12-15 | R2 | 1056h | 1056h | UTRA_EDL_L23-Core | 35 | Huawei |  | Rel-13 | 68 | RP-151238 |
| 1367 | 505 | **Support of single-cell point-to-multipoint transmission in LTE** | 330d? | 2015-06-15 A | 2016-09-15 A | 100% |  |  |  | R2 | 5824h | 5824h | LTE_SC_PTM | 35 | Huawei |  | Rel-13 | 68 |  |
| 1368 | 505.1 | Core part: Support of single-cell point-to-multipoint transmission in LTE | 132d? | 2015-06-15 A | 2015-12-15 A | 100% |  |  | finish no earlier than 2015-12-15 | R2 | 1056h | 1056h | LTE_SC_PTM-Core | 35 | Huawei |  | Rel-13 | 68 | RP-151237 |
| 1369 | 505.2 | Perf. part: Support of single-cell point-to-multipoint transmission in LTE | 132d? | 2015-06-15 A | 2015-12-15 A | 100% |  |  | finish no earlier than 2016-06-15 | R4 | 1056h | 1056h | LTE_SC_PTM-Perf | 35 | Huawei |  | Rel-13 | 68 | RP-151237 |
| 1370 | 505.3 | UE Conformance Test Aspects - Support of single-cell point-to-multipoint transmission in LTE | 134d? | 2016-03-15 A | 2016-09-15 A | 100% |  |  | finish no earlier than 2016-12-15 | R5 | 1072h | 1072h | LTE_SC_PTM-UEConTest | 36 | Huawei |  | Rel-13 | 71 |  |
| 1371 | 506 | **Extension of Dual Connectivity in E-UTRAN** | 132d? | 2015-06-15 A | 2015-12-15 A | 100% |  |  |  | R3 | 2112h | 2112h | LTE_dualC_ext | 35 | Samsung |  | Rel-13 | 68 |  |
| 1372 | 506.1 | Core part: Extension of Dual Connectivity in E-UTRAN | 132d? | 2015-06-15 A | 2015-12-15 A | 100% |  |  | finish no earlier than 2015-12-15 | R3 | 1056h | 1056h | LTE_dualC_ext-Core | 35 | Samsung |  | Rel-13 | 68 | RP-151214 |
| 1373 | 507 | **RAN sharing enhancements for UMTS** | 132d? | 2015-06-15 A | 2015-12-15 A | 100% |  |  |  | R3 | 2112h | 2112h | RSE_UTRA_GUSH | 35 | Huawei |  | Rel-13 | 68 |  |
| 1374 | 507.1 | Core part: RAN sharing enhancements for UMTS | 132d? | 2015-06-15 A | 2015-12-15 A | 100% |  |  | finish no earlier than 2015-12-15 | R3 | 1056h | 1056h | RSE_UTRA_GUSH-Core | 35 | Huawei |  | Rel-13 | 68 | RP-151239 |

Notes:
- 1351: ES in CP-150645; 7/3/16: 65%->100 / Impacted TSs and TRs: 29.153, 29.154, 29.201, 29.212, 29.213, 29.214, 29.215, 29.217, 29.219
- 1352: ES in CP-150622; 7/3/16: 70%->100 / Impacted TSs and TRs: 29.228, 29.229, 29.272, 29.273, 29.328, 29.329, 29.336, 29.337, 29.338, 29.344, 29.345
- 1353: 02/2016: publication requested; 2/12/16: 85%->100 / Impacted TSs and TRs: 29.227, 29.272, 29.273, 29.229
- 1354: follow-up WI of REL-13 SI FS_UTRA_EDL; TPC = Transmit Power Control
- 1355: follow-up WI of REL-13 SI FS_UTRA_EDL; TPC = Transmit Power Control 29/09/15: Compl:0%->35% 29/09/15: Stat Rep: -->RP-1515641/1/16: Compl:35%->100%1/1/16: WID:
- 1356: follow-up WI of REL-13 SI FS_UTRA_EDL; TPC = Transmit Power Control 29/09/15: Stat Rep: -->RP-151564; 1/1/16: Compl:0%->80%; 1/1/16: WID: RP-151044->RP-151880
- 1357: follow-up WI of REL-13 SI FS_LTE_LAA
- 1358: follow-up WI of REL-13 SI FS_LTE_LAA 29/09/15: Compl:0%->25% 29/09/15: Stat Rep: -->RP-1513901/1/16: Compl:25%->100%
- 1359: follow-up WI of REL-13 SI FS_LTE_LAA 29/09/15: Stat Rep: -->RP-15139022/3/16: Compl:0%->33%; 1/7/16: Compl:3; 26/9/16: Compl:50%->90%; 20/12/16: Compl:90%->100%; 20/12/16: Stat Rep: RP-151390->
- 1360: ; 22/3/16: Compl:0%->5%1/7/16: Compl:5%->8%26/9/16: Compl:8%->15%; 20/21/3/17: Com...; ;...; ;...
- 1361: follow-up WI of REL-13 SI FS_LTE_EBF_FDMIMO
- 1362: follow-up WI of REL-13 SI FS_LTE_EBF_FDMIMO 29/09/15: Compl:0%->25% 29/09/15: Stat Rep: -->RP-151565 1/1/16: Compl:25%->100%
- 1363: follow-up WI of REL-13 SI FS_LTE_EBF_FDMIMO 29/09/15: Stat Rep: -->RP-151565 ; 1/1/16: Compl:0%->5%; 22/3/16: Compl:5%->35%;26/9/16: Compl:70%->100%
- 1364: ; 8/1/18: Compl:0%->5%; ...27/3/18: Compl:5%->10%
- 1365: no Perf. part; follow-up of Rel-13 SI FS_UTRA_EDL
- 1366: no Perf. part; follow-up of Rel-13 SI FS_UTRA_EDL 29/09/15: Compl:0%->35% 29/09/15: WID: RP-151043->RP-151249 29/09/15: Stat Rep: -->RP-1512381/1/16: Compl:35%->100% ;
- 1367: follow-up WI of REL-13 SI FS_LTE_SC_PTM
- 1368: follow-up WI of REL-13 SI FS_LTE_SC_PTM 29/09/15: Compl:0%->30% 29/09/15: Stat Rep: -->RP-151237 1/1/16: Compl:30%->100%
- 1369: follow-up WI of REL-13 SI FS_LTE_SC_PTM 29/09/15: Stat Rep: -->RP-1512371/1/16: Compl:0%->100%
- 1370: testing REL-13 LTE_SC_PTM-Core1/7/16: Compl:0%->40%26/9/16
- 1371: no Perf. part; follow-up WI of REL-13 SI FS_LTE_dualC_ext;
- 1372: no Perf. part; follow-up WI of REL-13 SI FS_LTE_dualC_ext; 29/09/15: Compl:0%->30% 29/09/15: Stat Rep: -->RP-151214; 1/1/16: Compl:3
- 1373: no Perf. part; follow-up WI for Rel-13 SI FS_RSE_UTRA_GUSH; note: GUSH was a REL-13 SA1 WI; there is an ongoing REL-13 WI for LTE: RSE-RAN_LTE;
- 1374: no Perf. part; follow-up WI for Rel-13 SI FS_RSE_UTRA_GUSH; note: GUSH was a REL-13 SA1 WI; there is an ongoing REL-13 WI for LTE: RSE-RAN_LTE; 29/09/15: Compl:0%->30% 29/09/15: WID: RP-151086->RP-151251 29/09/15: Stat Rep: -->RP-151239 ;

| ID | WBS | Task | Duration | Start | Finish | Complete | Remaining | Total slack | Constraint | Resources | Work | Actual work | Acronym | PCG approved | WI rapporteur name | Release | TSG approved | Status Report | Impacted TSs and TRs | WI rapporteur e-mail |
| --- | --- | --- | --- | --- | --- | --- | --- | --- | --- | --- | --- | --- | --- | --- | --- | --- | --- | --- | --- | --- |
| 1375 | 508 | **Interference mitigation for downlink control channels of LTE** | 851d? | 2015-06-15 A | 2018-09-15 | 90% | 86.65d? | 456d |  | R4 | 12056h | 6817.52h | LTE_IM_DLCCH | 35 | Intel | Rel-13 | 68 |  |  |  |
| 1376 | 508.1 | Perf. part: Interference mitigation for downlink control channels of LTE | 263d? | 2015-06-15 A | 2016-06-15 A | 100% |  |  | finish no earlier than 2016-06-15 | R4 | 2104h | 2104h | LTE_IM_DLCCH-Perf | 35 | Intel | Rel-13 | 68 | RP-151301 |  |  |
| 1377 | 508.2 | UE Conformance Test Aspects - Interference Mitigation for Downlink Control Channels of LTE | 393d? | 2017-03-15 A | 2018-09-15 | 83% | 66.81d? | 456d | finish no earlier than 2018-09-15 | R5 | 3144h | 2609.52h | LTE_IM_DLCCH-UEConTest | 38 | Intel | Rel-13 | 75 |  |  |  |
| 1378 | 509 | **Network-Assisted Interference Cancellation and Suppression for UMTS** | 66d? | 2015-09-15 A | 2015-12-15 A | 100% |  |  |  | R1 | 1056h | 1056h | UTRA_NAICS | 35 | Huawei | Rel-13 | 69 |  |  |  |
| 1379 | 509.1 | Core part: Network-Assisted Interference Cancellation and Suppression for UMTS | 66d? | 2015-09-15 A | 2015-12-15 A | 100% |  |  | finish no earlier than 2015-12-15 | R1 | 528h | 528h | UTRA_NAICS-Core | 35 | Huawei | Rel-13 | 69 |  |  |  |
| 1380 | 510 | **Dual Carrier HSUPA Enhancements for UTRAN CS** | 66d? | 2015-09-15 A | 2015-12-15 A | 100% |  |  |  | R2 | 1056h | 1056h | DC_HSUPA_CS | 35 | Nokia Networks | Rel-13 | 69 |  |  |  |
| 1381 | 510.1 | Core part: Dual Carrier HSUPA Enhancements for UTRAN CS | 66d? | 2015-09-15 A | 2015-12-15 A | 100% |  |  | finish no earlier than 2015-12-15 | R2 | 528h | 528h | DC_HSUPA_CS-Core | 35 | Nokia Networks | Rel-13 | 69 |  |  |  |
| 1382 | 511 | **Further Enhancements of Minimization of Drive Tests for E-UTRAN** | 524d? | 2015-03-16 A | 2017-03-15 A | 100% |  |  |  | R2 | 6304h | 6304h | LTE_eMDT2 | 35 | CMCC | Rel-13 | 69 |  |  |  |
| 1383 | 511.1 | Study on further Enhancements of Minimization of Drive Tests for E-UTRAN | 132d? | 2015-03-16 A | 2015-09-15 A | 100% |  |  | finish no earlier than 2015-09-15 | R2 | 1056h | 1056h | FS_LTE_eMDT2 | 34 | CMCC | Rel-13 | 67 | RP-151181 | 36.880 |  |
| 1384 | 511.2 | Core part: Further Enhancements of Minimization of Drive Tests for E-UTRAN | 66d? | 2015-09-15 A | 2015-12-15 A | 100% |  |  | finish no earlier than 2015-12-15 | R2 | 528h | 528h | LTE_eMDT2-Core | 35 | CMCC | Rel-13 | 69 |  |  |  |
| 1385 | 511.3 | UE Conformance Test Aspects – Further Enhancements of Minimization of Drive Tests for E-UTRAN | 197d? | 2016-06-15 A | 2017-03-15 A | 100% |  |  | finish no earlier than 2017-03-15 | R5 | 1576h | 1576h | LTE_eMDT2-UEConTest | 37 | Intel | Rel-13 | 72 |  |  |  |
| 1386 | 512 | **LTE-WLAN RAN Level Integration supporting legacy WLAN** | 131d? | 2015-09-15 A | 2016-03-15 A | 100% |  |  |  | R2 | 2096h | 2096h | LTE_WLAN_radio_legacy | 35 | Alcatel-Lucent | Rel-13 | 69 |  |  |  |
| 1387 | 512.1 | Core part: LTE-WLAN RAN Level Integration supporting legacy WLAN | 131d? | 2015-09-15 A | 2016-03-15 A | 100% |  |  | finish no earlier than 2016-03-15 | R2 | 1048h | 1048h | LTE_WLAN_radio_legacy-Core | 35 | Alcatel-Lucent | Rel-13 | 69 |  | 36.361 |  |
| 1388 | 513 | **Indoor Positioning enhancements for UTRA and LTE** | 393d? | 2015-09-15 A | 2017-03-15 A | 100% |  |  |  | R2 | 7152h | 7152h | UTRA_LTE_iPos_enh | 35 | NextNav | Rel-13 | 69 |  |  |  |
| 1389 | 513.1 | Core part: Indoor Positioning enhancements for UTRA and LTE | 66d? | 2015-09-15 A | 2015-12-15 A | 100% |  |  | finish no earlier than 2015-12-15 | R2 | 528h | 528h | UTRA_LTE_iPos_enh-Core | 35 | NextNav | Rel-13 | 69 |  |  |  |
| 1390 | 513.2 | Perf. part: Indoor Positioning enhancements for UTRA and LTE | 197d? | 2015-09-15 A | 2016-06-15 A | 100% |  |  | finish no earlier than 2016-06-15 | R4 | 1576h | 1576h | UTRA_LTE_iPos_enh-Perf | 35 | NextNav | Rel-13 | 69 |  | 37.171; 37.958 |  |
| 1391 | 513.3 | **CT aspects of Indoor Positionning** | 41d? | 2015-10-12 A | 2015-12-07 A | 100% |  |  |  | C4 | 328h | 328h | UTRA_LTE_iPos_enh-CT | 36 | Ericsson, Jesús de Gregorio | Rel-13 | 70 |  | 29.171, 29.172, 29.230, 29.002 | jesus.de.gregorio@ericsson.com |
| 1392 | 513.3.1 | CT4 aspects of Indoor Positionning | 41d? | 2015-10-12 A | 2015-12-07 A | 100% |  |  | finish no earlier than 2015-12-07 | C4 | 328h | 328h | UTRA_LTE_iPos_enh-CT | 36 | Ericsson, Jesús de Gregorio | Rel-13 | 70 |  | 29.171, 29.172, 29.230, 29.002 | jesus.de.gregorio@ericsson.com |
| 1393 | 513.4 | UE Conformance Test Aspects – Indoor Positioning Enhancement Support for LTE and UMTS | 197d? | 2016-06-15 A | 2017-03-15 A | 100% |  |  | finish no earlier than 2017-06-15 | R5 | 1576h | 1576h | UTRA_LTE_iPos_enh-UEConTest | 37 | NextNav | Rel-13 | 72 |  |  |  |
| 1394 | 514 | **Power saving enhancements for UMTS** | 197d? | 2015-06-15 A | 2016-03-15 A | 100% |  |  |  | R2 | 3160h | 3160h | UTRA_SDATA_POWSAV | 35 | Ericsson | Rel-13 | 68 |  |  |  |
| 1395 | 514.1 | Core part: Power saving enhancements for UMTS | 132d? | 2015-06-15 A | 2015-12-15 A | 100% |  |  | finish no earlier than 2015-12-15 | R2 | 1056h | 1056h | UTRA_SDATA_POWSAV-Core | 35 | Ericsson | Rel-13 | 68 | RP-151291 |  |  |
| 1396 | 514.2 | Perf. Part: Power saving enhancements for UMTS | 66d? | 2015-12-15 A | 2016-03-15 A | 100% |  |  | finish no earlier than 2016-03-15 | R4 | 528h | 528h | UTRA_SDATA_POWSAV-Perf | 36 | Ericsson | Rel-13 | 70 |  |  |  |
| 1397 | 515 | **700MHz E-UTRA FDD Band for Arab Region** | 197d? | 2015-06-15 A | 2016-03-15 A | 100% |  |  |  | R4 | 4728h | 4728h | LTE_FDD_700_ARAB | 35 | Etisalat | Rel-13 | 68 |  |  |  |
| 1398 | 515.1 | Core part: 700MHz E-UTRA FDD Band for Arab Region | 197d? | 2015-06-15 A | 2016-03-15 A | 100% |  |  | finish no earlier than 2016-03-15 | R4 | 1576h | 1576h | LTE_FDD_700_ARAB-Core | 35 | Etisalat | Rel-13 | 68 | RP-151207 | 36.893 |  |
| 1399 | 515.2 | Perf. part: 700MHz E-UTRA FDD Band for Arab Region | 197d? | 2015-06-15 A | 2016-03-15 A | 100% |  |  | finish no earlier than 2016-03-15 | R4 | 1576h | 1576h | LTE_FDD_700_ARAB-Perf | 35 | Etisalat | Rel-13 | 68 | RP-151207 |  |  |

Notes:
- 1375: only Perf. part, no Core part;
- 1376: only Perf. part, no Core part; 29/09/15: CD:Tue 15/03/16->Wed 15/06/16 29/09/15: Stat Rep: -->RP-1513011/1/16: Compl:0%->40%22/3/16: Compl:40%->70%
- 1377: tested: REL-13 LTE_IM_DLCCH-Perf (note: WI had no Core part);19/6/17...1...; 8/1/18: C...; 27/3/18...
- 1378: no Perf. part; follow-up WI REL-13 RAN1 SI FS_UTRA_NAICS
- 1379: no Perf. part; follow-up WI REL-13 RAN1 SI FS_UTRA_NAICS ; 1/1/16: Compl:0%->100% ; 1/1/16: WID: RP-151577->RP-151879
- 1380: no Perf. part; compare REL-13 WI HSUPA_DB_MC
- 1381: no Perf. part; compare REL-13 WI HSUPA_DB_MC 1/1/16: Compl:0%->100% 1/1/16: WID: RP-151607->RP-151780
- 1382: no Perf. part; follow-up WI of REL-13 SI FS_LTE_eMDT2
- 1383: 03/07/15: Compl:0%->70% 03/07/15: Stat Rep: -->RP-150806 29/09/15: Compl:70%->100% 29/09/15: Stat Rep: RP-150806->RP-151181
- 1384: no Perf. part; follow-up WI of REL-13 SI FS_LTE_eMDT2; 1/1/16: Compl:0%->100%
- 1385: tested REL-13 WI: LTE_eMDT2-Core26/9/16: Com;21/3/17: Compl:5%->100%
- 1386: no Perf. part; compare REL-13 WI LTE_WLAN_radio
- 1387: no Perf. part; compare REL-13 WI LTE_WLAN_radio1/1/16: Compl:0%->95% 22/3/16: Compl:95%->100%; 28/7/16: 36.361 added;
- 1388: follow-up WI of REL-13 SI FS_UTRA_LTE_iPos_enh
- 1389: follow-up WI of REL-13 SI FS_UTRA_LTE_iPos_enh1/1/16: Compl:0%->100%1/1/16: WID: RP-151624->RP-15225122/3/16: WID: RP-152251->RP-160332
- 1390: follow-up WI of REL-13 SI FS_UTRA_LTE_iPos_enh 1/1/16: Compl:0%->10% 1/1/16: WID: RP-151624->RP-152251; 22/3/16: Compl:10%->20%; 22/3/16: WID: RP-152251->RP-160332 28/7/16: 37.171 added; 28/7/16: 37.958 added;
- 1392: 8/12/15: 0%->100
- 1393: tested REL-13 WI: UTRA_LTE_iPos_enh-Core; 26/9/1; 20/12/16:21/3/17: Compl:...
- 1394: no Perf. part; follow-up WI of SI FS_UTRA_SDATA
- 1395: no Perf. part; follow-up WI of SI FS_UTRA_SDATA 29/09/15: Compl:0%->25% 29/09/15: CD:Tue 15/03/16->Tue 15/12/15 29/09/15: WID: RP-151092->RP-151292 29/09/15: Stat Rep: -->RP-151291 29/09/15: Release: Rel-14->Rel-13
- 1396: ; 22/3/16: Compl:0%->100%
- 1397: REL-independent from REL-9
- 1398: REL-independent from REL-9. Aug 15: TR numb added 29/09/15: Compl:0%->15% 29/09/15: CD:Tue 15/03/16->Tue 15/12/15 29/09/15: Stat Rep: -->RP-151207 29/09/15: Release: Rel-14->Rel-13;
- 1399: REL-independent from REL-9 29/09/15: CD:Tue 15/03/16->Tue 15/12/15 29/09/15: Stat Rep: -->RP-151207 29/09/15: Release: Rel-14->Rel-13

| ID | WBS | Task | Duration | Start | Finish | Complete | Remaining | Baseline start | Baseline finish | Baseline duration | Total slack | Constraint | Resources | Work | Actual work | Acronym | PCG approved | WI rapporteur name | Release | TSG approved | Status Report | WI rapporteur e-mail | MCC resp | Special Focus Doc | Acronym_3GU_Export |
| --- | --- | --- | --- | --- | --- | --- | --- | --- | --- | --- | --- | --- | --- | --- | --- | --- | --- | --- | --- | --- | --- | --- | --- | --- | --- |
| 1400 | 516 | **European 700 Supplemental Downlink band (738-758 MHz) in E-UTRA and LTE Carrier Aggregation (2DL/1UL) with Band 20** | 132d? | 2015-06-15 A | 2015-12-15 A | 100% |  |  |  |  |  |  | R4 | 3168h | 3168h | LTE_CA_700EU_B20 | 35 | TeliaSonera | Rel-13 | 68 |  |  |  |  |  |
| 1401 | 516.1 | Core part: European 700 Supplemental Downlink band (738-758 MHz) in E-UTRA and LTE Carrier Aggregation (2DL/1UL) with Band 20 | 132d? | 2015-06-15 A | 2015-12-15 A | 100% |  |  |  |  |  | finish no earlier than 2015-12-15 | R4 | 1056h | 1056h | LTE_CA_700EU_B20-Core | 35 | TeliaSonera | Rel-13 | 68 | RP-151232 |  |  |  |  |
| 1402 | 516.2 | Perf. part: European 700 Supplemental Downlink band (738-758 MHz) in E-UTRA and LTE Carrier Aggregation (2DL/1UL) with Band 20 | 132d? | 2015-06-15 A | 2015-12-15 A | 100% |  |  |  |  |  | finish no earlier than 2016-03-15 | R4 | 1056h | 1056h | LTE_CA_700EU_B20-Perf | 35 | TeliaSonera | Rel-13 | 68 | RP-151232 |  |  |  |  |
| 1403 | 517 | Release 13 Features on Internet of Things (IoT) | 438.25d? | 2013-09-12 A | 2015-05-12 A | 100% |  | 2015-04-14 | 2015-12-25 | 183.25d? |  |  | SP; RP; CP; GP | 14024h | 14024h |  |  |  | Rel-13 |  |  |  |  |  |  |
| 1404 | 518 | Service Requirements Maintenance for Machine-Type Communications (MTC) | 194d? | 2015-09-15 A | 2016-06-10 A | 100% |  | 2013-12-12 | 2014-12-10 | 261d? |  |  | S1 | 1552h | 1552h | SRMMTC | 32 | KPN | Rel-13 | 62 |  | toon.norp@tno.nl | Alain | MTC, M2M | SRMMTC |
| 1405 | 519 | **Cellular (Narrowband) Internet of Things** | 590d? | 2015-09-15 A | 2017-12-15 A | 100% |  |  |  |  |  |  |  | 16648h | 16648h | CIoT | 36 |  | Rel-13 | 70 |  |  |  |  |  |
| 1406 | 519.1 | Stage 2 of CIoT | 1d? | 2015-10-05 A | 2015-10-05 A | 100% |  |  |  |  |  | start no earlier than 2015-10-05 | S2 | 8h | 8h | CIoT | 36 | Intel, Puneet Jain | Rel-13 | 70 |  | puneet.jain@intel.com |  |  |  |
| 1407 | 519.2 | Security Aspects of CIoT (aka NB-IoT) | 160d? | 2015-11-02 A | 2016-06-10 A | 100% |  |  |  |  |  | finish no earlier than 2016-06-10 | S3 | 1280h | 1280h | CIoT | 36 | Tim Evans, Vodafone | Rel-13 | 70 |  |  |  |  |  |
| 1408 | 519.3 | **CT aspects of CIoT** | 138d? | 2015-12-07 A | 2016-06-15 A | 100% |  |  |  |  |  |  | C1 | 4976h | 4976h | CIoT-CT | 36 | Intel, Vivek Gupta | Rel-13 | 70 |  | vivek.g.gupta@intel.com |  |  |  |
| 1409 | 519.3.1 | CT1 aspects of CIoT | 70d? | 2015-12-07 A | 2016-03-11 A | 100% |  |  |  |  |  | finish no earlier than 2016-03-11 | C1 | 560h | 560h | CIoT-CT | 36 | Intel, Vivek Gupta | Rel-13 | 70 |  | vivek.g.gupta@intel.com |  |  |  |
| 1410 | 519.3.2 | CT3 aspects of CIoT | 138d? | 2015-12-07 A | 2016-06-15 A | 100% |  |  |  |  |  | finish no earlier than 2016-06-15 | C3 | 1104h | 1104h | CIoT-CT | 36 | Intel, Vivek Gupta | Rel-13 | 70 |  | vivek.g.gupta@intel.com |  |  |  |
| 1411 | 519.3.3 | CT4 aspects of CIoT | 138d? | 2015-12-07 A | 2016-06-15 A | 100% |  |  |  |  |  | finish no earlier than 2016-06-15 | C4 | 1104h | 1104h | CIoT-CT | 36 | Intel, Vivek Gupta | Rel-13 | 70 |  | vivek.g.gupta@intel.com |  |  |  |
| 1412 | 519.3.4 | CT6 aspects of CIoT | 138d? | 2015-12-07 A | 2016-06-15 A | 100% |  |  |  |  |  | finish no earlier than 2016-06-15 | C6 | 1104h | 1104h | CIoT-CT | 36 | Intel, Vivek Gupta | Rel-13 | 70 |  | vivek.g.gupta@intel.com |  |  |  |
| 1413 | 519.4 | Charging Aspects of CIoT | 23d? | 2016-05-12 A | 2016-06-13 A | 100% |  |  |  |  |  | finish no earlier than 2016-06-13 | S5 | 184h | 184h | CIoT-CH | 37 | Gardella, Maryse (Nokia) | Rel-13 | 72 |  | Gardella, Maryse (Nokia) |  |  |  |
| 1414 | 519.5 | **RAN aspects of CIoT aka Narrowband Internet of Things (IOT)** | 329d? | 2015-09-15 A | 2016-12-15 A | 100% |  |  |  |  |  |  | R1 | 6320h | 6320h | NB_IOT | 35 | Vodafone | Rel-13 | 69 |  |  |  |  |  |
| 1415 | 519.5.1 | Core part: Narrowband Internet of Things (IOT) | 197d? | 2015-09-15 A | 2016-06-15 A | 100% |  |  |  |  |  | finish no earlier than 2016-06-15 | R1 | 1576h | 1576h | NB_IOT-Core | 35 | Vodafone | Rel-13 | 69 |  |  |  |  |  |
| 1416 | 519.5.2 | Perf. part: Narrowband Internet of Things (IOT) | 264d? | 2015-12-15 A | 2016-12-15 A | 100% |  |  |  |  |  | finish no earlier than 2016-12-15 | R4 | 2112h | 2112h | NB_IOT-Perf | 36 | Vodafone | Rel-13 | 70 |  |  |  |  |  |
| 1417 | 519.6 | Management for NB-IoT | 25d? | 2016-05-12 A | 2016-06-15 A | 100% |  |  |  |  |  | finish no earlier than 2016-06-15 | S5 | 200h | 200h | NB_IOT-OAM | 37 | Huawei, Kai ZHANG | Rel-13 | 72 |  | kai.zhangkai@huawei.com |  |  |  |
| 1418 | 519.7 | UE Conformance Test Aspects - Narrowband Internet of Things (NB-IOT) | 460d? | 2016-03-15 A | 2017-12-15 A | 100% |  |  |  |  |  | finish no earlier than 2017-12-15 | R5 | 3680h | 3680h | NB_IOT-UEConTest | 36 | CMCC | Rel-13 | 71 |  |  |  |  |  |
| 1419 | 520 | **Extended Coverage GSM (EC-GSM) for support of Cellular Internet of Things** | 255.5d? | 2015-09-25 A | 2016-09-15 | 69% | 77.98d? |  |  |  | 977d |  | G1; G2 | 8864h | 4044.7h | CIoT_EC_GSM | 35 | Marteen Sunberg, Ericsson | Rel-13 | 69 |  | Marteen.Sunberg@Ericsson.com |  |  |  |
| 1420 | 520.1 | Extended Coverage GSM (EC-GSM) for support of Cellular Internet of Things Core part | 164.5d? | 2015-09-25 A | 2016-05-12 A | 100% |  |  |  |  |  | finish no earlier than 2016-05-12 | G1; G2 | 2632h | 2632h | CIoT_EC_GSM-Core | 36 | Marteen Sunberg, Ericsson | Rel-13 | 70 |  | Marteen.Sunberg@Ericsson.com |  |  |  |
| 1421 | 520.2 | Test for CIoT_EC_GSM | 132d? | 2015-11-11 | 2016-05-12 |  |  |  |  |  | 1068d | start no earlier than 2015-11-11 | G3 | 1056h |  | CIoT_EC_GSM_GERAN3new | 36 | Sierra Wireless S.A | Rel-13 | 70 |  | Marteen.Sunberg@Ericsson.com |  |  |  |
| 1422 | 520.3 | Perf. Part: Extended Coverage GSM (EC-GSM) for support of Cellular Internet of Things | 68d? | 2016-06-15 A | 2016-09-15 A | 100% |  |  |  |  |  | finish no earlier than 2016-09-15 | R6 | 544h | 544h | CIoT_EC_GSM-Perf | 37 | Ericsson | Rel-13 | 72 |  |  |  |  |  |
| 1423 | 520.4 | MS Conformance Test Aspects - Extended Coverage GSM (EC-GSM) for support of Cellular Internet of Things | 68d? | 2016-06-15 A | 2016-09-15 A | 100% |  |  |  |  |  | finish no earlier than 2016-09-15 | R5 | 544h | 544h | CIoT_EC_GSM-MSConTest | 37 | Ericsson | Rel-13 | 72 |  |  |  |  |  |

Notes:
- 1400: introduction of new DL only band and 2DL/1UL CA with it
- 1401: introduction of new DL only band and 2DL/1UL CA with it. Aug 15: TR numb added 29/09/15: Compl:0%->80% 29/09/15: CD:Tue 15/03/16->Tue 15/12/15 29/09/15: WID: RP-150861->RP-151228 29/09/15: Stat Rep: -->RP-151232 29/09/15: Release: Rel-14->Rel-13 / Impacted TSs and TRs: 36.895
- 1402: introduction of new DL only band and 2DL/1UL CA with it 29/09/15: WID: RP-150861->RP-151228 29/09/15: Stat Rep: -->RP-151232 29/09/15: Release: Rel-14->Rel-13
- 1403: -
- 1404: SP#65 completed. Linked to Rel-13 SEES, Rel-12 Support for Interworking with M2M Service Enablement (MTCe-SIMSE), Service Requirement Maintenance (MTCe-SRM). Decide which MTC reqs with no Stage 2 should be removed/maintained in Rel-13. / Impacted TSs and TRs: 22.368
- 1406: 7/3/16: 0%->95 / Impacted TSs and TRs: 23.401, 23.682, 23.251
- 1407: 7/3/16: 0%->39; 19/9/16: 39%->100 / Impacted TSs and TRs: 33.401
- 1408: 11/6/16: WID:CP-150795->CP-160292
- 1409: 7/3/16: 0%->35; 11/6/16: 35%->100; 11/6/16: WID:CP-150795->CP-160292 / Impacted TSs and TRs: 24.301, 24.008, 23.122
- 1410: 7/3/16: 0%->90; 11/6/16: WID:CP-150795->CP-160292; 13/6/16: 90%->100 / Impacted TSs and TRs: 29.061, 29.212
- 1411: 7/3/16: 0%->65; 11/6/16: WID:CP-150795->CP-160292; 13/6/16: 65%->100 / Impacted TSs and TRs: 29.272, 29.274, 23.008, 23.007, 29.128, 29.275, 29.230, 29.336, 29.281, 29.002, 29.303
- 1412: 11/6/16: WID:CP-150795->CP-160292; 13/6/16: 0%->100 / Impacted TSs and TRs: 31.102
- 1413: 32.25x; 13/6/16: 0%->100 / Impacted TSs and TRs: 32.25x, 32.240, 32.251, 32.274, 32.299, 32.298, 32.297
- 1414: no Perf. part; note: WI only stays in REL-13 because of PCG decision
- 1415: no Perf. part; note: WI only stays in REL-13 because of PCG decision1/1/16: Compl:0%->25% 22/3/16: Compl:25%->75%;1/7/16: Com / Impacted TSs and TRs: 36.802
- 1416: 22/3/16: WID: RP-152284->RP-160656; 1/7/16: WID: RP-160656->RP-16093326/9/16: Compl:0%->60%26/9/16: CD:Thu 15/09/16->Thu 15/12/16; 20/12/16: Compl:60%->100%; 20/12/16: WID: RP-160933->RP-162134
- 1417: 13/6/16: 0%->100 / Impacted TSs and TRs: 28.657, 28.658, 28.659, 32.425
- 1418: testing REL-13 NB_IOT-Core1/7/16: Compl:0%->5%; 26/9; 20/12/1; 21/3/17: Compl:...; ;...; ;...; ;...
- 1419: 7/12/15: 0%->60
- 1420: 7/12/15:created by MCC to distinguish core versus test parts. 2/3/16: FCD: 11/15->05/16, 40->90%; 13/6/16: 90%->100
- 1421: 7/12/15: created GERAN. 2/3/16: G1,G2->G3, Acronym: CIoT_EC_GSM-Test->CIoT_EC_GSM_GERAN3new
- 1422: related to GERAN REL-13 WI CIoT_EC_GSM-Core26/9/16: Compl:0%->100%
- 1423: tested REL-13 WI: CIoT_EC_GSM-Core26/9/16: Compl

| ID | WBS | Task | Duration | Start | Finish | Complete | Remaining | Baseline start | Baseline finish | Baseline duration | Total slack | Constraint | Resources | Work | Actual work | Acronym | PCG approved | WI rapporteur name | WI rapporteur e-mail | Release | TSG approved | Status Report | Acronym_3GU_Export |
| --- | --- | --- | --- | --- | --- | --- | --- | --- | --- | --- | --- | --- | --- | --- | --- | --- | --- | --- | --- | --- | --- | --- | --- |
| 1424 | 521 | **Extended DRX cycle for Power Consumption** | 468d? | 2014-12-03 A | 2016-09-15 | 93% | 31.26d? |  |  |  | 977d |  | S2; R2; G2 | 27696h | 16791.6h | eDRX | 35 | Miguel Griot | mgriot@qti.qualcomm.com | Rel-13 | 68 |  |  |
| 1425 | 521.1 | Study on Extended DRX cycle for Power Consumption Optimization | 268d? | 2014-12-03 A | 2015-12-11 A | 100% |  |  |  |  |  | finish no earlier than 2015-12-11 | S2 | 2144h | 2144h | FS_eDRX | 34 | Miguel Griot, Qualcomm | mgriot@qti.qualcomm.com | Rel-13 | 66 |  |  |
| 1426 | 521.2 | Stage 2 for Extended DRX cycle for Power Consumption | 133d? | 2015-06-15 A | 2015-12-16 A | 100% |  |  |  |  |  | finish no earlier than 2015-12-16 | S2 | 1064h | 1064h | eDRX | 35 | Miguel Griot | mgriot@qti.qualcomm.com | Rel-13 | 68 |  |  |
| 1427 | 521.3 | **CT aspects of extended DRX cycle** | 135d? | 2015-09-07 A | 2016-03-11 A | 100% |  |  |  |  |  |  | ct | 4912h | 4912h | eDRX-CT | 35 | Catovic, Amer, Qualcomm | Catovic, Amer, Qualcomm | Rel-13 | 69 |  |  |
| 1428 | 521.3.1 | CT1 aspects of extended DRX cycle | 135d? | 2015-09-07 A | 2016-03-11 A | 100% |  |  |  |  |  | finish no earlier than 2016-03-11 | C1 | 1080h | 1080h | eDRX-CT | 35 | Catovic, Amer, Qualcomm | Catovic, Amer, Qualcomm | Rel-13 | 69 |  |  |
| 1429 | 521.3.2 | CT3 aspects of extended DRX cycle | 135d? | 2015-09-07 A | 2016-03-11 A | 100% |  |  |  |  |  | finish no earlier than 2016-03-11 | C3 | 1080h | 1080h | eDRX-CT | 35 | Catovic, Amer, Qualcomm | Catovic, Amer, Qualcomm | Rel-13 | 69 |  |  |
| 1430 | 521.3.3 | CT4 aspects of extended DRX cycle | 74d? | 2015-09-07 A | 2015-12-17 A | 100% |  |  |  |  |  | finish no earlier than 2015-12-17 | C4 | 592h | 592h | eDRX-CT | 35 | Catovic, Amer, Qualcomm | Catovic, Amer, Qualcomm | Rel-13 | 69 |  |  |
| 1431 | 521.3.4 | CT6 aspects of extended DRX cycle | 135d? | 2015-09-07 A | 2016-03-11 A | 100% |  |  |  |  |  | finish no earlier than 2016-03-11 | C6 | 1080h | 1080h | eDRX-CT | 36 | Catovic, Amer, Qualcomm | Catovic, Amer, Qualcomm | Rel-13 | 70 |  |  |
| 1432 | 521.4 | **RAN enhancements for extended DRX in LTE** | 262d? | 2015-03-16 A | 2016-03-15 A | 100% |  |  |  |  |  |  | R2 | 4192h | 4192h | LTE_extDRX | 34 | Qualcomm |  | Rel-13 | 67 |  |  |
| 1433 | 521.4.1 | Core part: RAN enhancements for extended DRX in LTE | 262d? | 2015-03-16 A | 2016-03-15 A | 100% |  |  |  |  |  | finish no earlier than 2016-03-15 | R2 | 2096h | 2096h | LTE_extDRX-Core | 34 | Qualcomm |  | Rel-13 | 67 | RP-151338 |  |
| 1434 | 521.5 | UE Conformance Test Aspects - RAN enhancements for extended DRX in LTE | 134d? | 2016-03-15 A | 2016-09-15 A | 100% |  |  |  |  |  | finish no earlier than 2016-12-15 | R5 | 1072h | 1072h | LTE_extDRX-UEConTest | 36 | Qualcomm |  | Rel-13 | 71 |  |  |
| 1435 | 521.6 | **Extended DRX (eDRX) for GSM** | 184.5d? | 2015-08-28 A | 2016-05-12 | 44% | 102.46d? |  |  |  | 1068d |  | G2; G1 | 4832h | 2072.8h | eDRX_GSM | 35 | John Diachina, Ericsson LM | John.Diachina@Ericsson.com | Rel-13 | 69 |  |  |
| 1436 | 521.6.1 | Core Part: Extended DRX (eDRX) for GSM | 60.5d? | 2015-08-28 A | 2015-11-20 A | 100% |  |  |  |  |  | finish no earlier than 2015-11-20 | G2; G1 | 968h | 968h | eDRX_GSM-Core | 36 | John Diachina, Ericsson LM | John.Diachina@Ericsson.com | Rel-13 | 70 |  |  |
| 1437 | 521.6.2 | MS test: Extended DRX (eDRX) for GSM | 114d? | 2015-12-07 A | 2016-05-12 | 15% | 96.9d? |  |  |  | 1068d | start no earlier than 2015-12-07 | G3 | 912h | 136.8h | eDRX_GSM_GERAN3new | 36 | Sierra Wireless S.A | John.Diachina@Ericsson.com | Rel-13 | 70 |  |  |
| 1438 | 522 | **Optimizations to Support High Latency Communications** | 326d? | 2014-09-19 A | 2015-12-16 A | 100% |  |  |  |  |  |  | S2 | 5824h | 5824h | HLcom | 34 | Ericsson, Hans Rönneke | hans.ronneke(at)ericsson.com | Rel-13 | 67 |  |  |
| 1439 | 522.1 | Study on Optimizations to support High Latency communications | 196d? | 2014-09-19 A | 2015-06-17 A | 100% |  |  |  |  |  | finish no earlier than 2015-06-17 | S2 | 1568h | 1568h | FS_HLcom | 33 | Ericsson | hans.ronneke@ericsson.com | Rel-13 | 65 |  | FS_HLcom |
| 1440 | 522.2 | Optimizations to Support High Latency Communications | 73d? | 2015-03-05 A | 2015-06-15 A | 100% |  |  |  |  |  | finish no earlier than 2015-06-15 | S2 | 584h | 584h | HLcom | 34 | Ericsson, Hans Rönneke | hans.ronneke(at)ericsson.com | Rel-13 | 67 |  |  |
| 1441 | 522.3 | CT aspects of Optimizations to Support High Latency | 133d? | 2015-06-15 A | 2015-12-16 A | 100% |  |  |  |  |  | finish no earlier than 2015-12-16 | C4 | 1064h | 1064h | HLcom-CT | 35 | Yong Yang, Ericsson | frank.yong.yang@ericsson.com | Rel-13 | 68 |  |  |
| 1442 | 523 | **Further LTE Physical Layer Enhancements for MTC** | 789d? | 2014-09-12 A | 2017-09-15 | 99% | 0d? | 2014-06-13 | 2015-06-12 | 261d? | 0d |  | R1; R4; R2 | 36320h | 23979.1h | LTE_MTCe2_L1 | 33 | Ericsson | johan.bergman@ericsson.com | Rel-13 | 65 |  | LTE_MTCe2_L1 |
| 1443 | 523.1 | Core part: Further LTE Physical Layer Enhancements for MTC | 395d? | 2014-09-12 A | 2016-03-15 A | 100% |  | 2014-06-13 | 2015-06-12 | 261d? |  | finish no earlier than 2016-03-15 | R1; R2; R4 | 9480h | 9480h | LTE_MTCe2_L1-Core | 33 | Ericsson | johan.bergman@ericsson.com | Rel-13 | 65 | RP-151186 | LTE_MTCe2_L1-Core |
| 1444 | 523.2 | Perf. Part: Further LTE Physical Layer Enhancements for MTC | 593d? | 2014-09-12 A | 2016-12-15 A | 100% |  | 2014-06-13 | 2015-06-12 | 261d? |  | finish no earlier than 2016-12-15 | R4 | 4744h | 4744h | LTE_MTCe2_L1-Perf | 33 | Ericsson | johan.bergman@ericsson.com | Rel-13 | 65 |  | LTE_MTCe2_L1-Perf |
| 1445 | 523.3 | UE Conformance Test Aspects - Further LTE Physical Layer Enhancements for MTC | 395d? | 2016-03-15 A | 2017-09-15 A | 100% |  |  |  |  |  | finish no earlier than 2017-09-15 | R5 | 3160h | 3160h | LTE_MTCe2_L1-UEConTest | 36 | Ericsson |  | Rel-13 | 71 |  |  |
| 1446 | 524 | EGPRS Access Security Enhancements in relation to Cellular IoT | 128d? | 2015-09-16 A | 2016-03-11 A | 100% |  |  |  |  |  | finish no earlier than 2016-03-11 | S3 | 1024h | 1024h | EASE_EC_GSM | 35 | Vesa Torvinen, Ericsson |  | Rel-13 | 69 |  |  |
| 1447 | 525 | **Group based Enhancements** | 394d? | 2014-06-18 A | 2015-12-16 A | 100% |  | 2014-06-18 | 2015-09-16 | 326d? |  |  | S2; S3 | 18676.8h | 18676.8h | GROUPE | 33 | Huawei | ZhangWanqiang@huawei.com | Rel-13 | 64 |  | GROUPE |
| 1448 | 525.1 | TR for Group based Enhancements | 196d? | 2014-06-18 A | 2015-03-18 A | 100% |  | 2014-06-18 | 2015-03-18 | 196d? |  | finish no earlier than 2015-03-18 | S2 | 1568h | 1568h | GROUPE | 33 | Huawei, Wanqiang Zhang | ZhangWanqiang@huawei.com | Rel-13 | 64 |  |  |
| 1449 | 525.2 | Stage 2 for Group based Enhancements | 261d? | 2014-06-23 A | 2015-06-17 A | 100% |  | 2014-06-18 | 2015-06-17 | 261d? |  | finish no earlier than 2015-06-17 | S2 | 2088h | 2088h | GROUPE | 33 | Huawei | ZhangWanqiang@huawei.com | Rel-13 | 64 |  |  |
| 1450 | 525.3 | TR on Security for Group based Enhancements | 231.6d? | 2014-06-18 A | 2015-06-12 A | 100% |  | 2014-06-18 | 2015-06-17 | 231.6d? |  | start no earlier than 2014-06-18 | S3 | 1852.8h | 1852.8h | GROUPE | 33 | Samsung | Rajavelsamy R (rajvel@samsung.com) | Rel-13 | 64 |  |  |
| 1451 | 525.4 | Security for Group based Enhancements | 326d? | 2014-06-23 A | 2015-09-16 A | 100% |  | 2014-06-18 | 2015-09-16 | 326d? |  | finish no earlier than 2015-09-16 | S3 | 2608h | 2608h | GROUPE | 33 | Samsung | Rajavelsamy R (rajvel@samsung.com) | Rel-13 | 64 |  |  |

Notes:
- 1424: June2015: WID:SP-150254->SP-150369 / Impacted TSs and TRs: 23.401, 23.060, 23.682, 23.271, 23.272
- 1425: No Ran aspects yet. GERAN in FS_uPoD.29/1: TS number added Mar15: 0->30%; June2015: Compl:30%->95, Exc S granted in SP-150352; 07/09/15: 95%->100 / Impacted TSs and TRs: 23.770
- 1426: June2015: WID:SP-150254->SP-150369; 07/09/15: 0%->95; 7/12/15: 95%->99 / Impacted TSs and TRs: 23.401, 23.060, 23.682, 23.271, 23.272
- 1427: 14/09/15: WID:CP-150499->CP-150541
- 1428: 14/09/15: WID:CP-150499->CP-150541; 7/12/15: 25%->80. FCD ->03/16. ES in CP-150723; 7/3/16: 80%->100 / Impacted TSs and TRs: 24.301, 24.008, 29.118
- 1429: 14/09/15: WID:CP-150499->CP-150541. FCD ->03/16. ES in CP-150723; 8/12/15: 0%->100 / Impacted TSs and TRs: 29.338, 23.007, 29.274, 29.060, 29.172
- 1430: 14/09/15: WID:CP-150499->CP-150541; 7/12/15: 40%->100; 8/12/15: 100%->95; 8/3/16: 95%->100 / Impacted TSs and TRs: 29.212
- 1431: 7/12/15: Added. FCD ->03/16. ES in CP-150723; 8/3/16: 0%->100
- 1433: 03/07/15: Compl:0%->15% 03/07/15: Stat Rep: ->RP-150798 29/09/15: Compl:15%->35% 29/09/15: WID: RP-150493->RP-151339 29/09/15: Stat Rep: RP-150798->RP-151338 ; 22/3/16: Compl:95%->100%
- 1434: testing REL-13 LTE_extDRX-Core and CT1 feature eDRX-CT;
- 1435: 07/09/15: 0%->40; 7/12/15: 40%->100 / Impacted TSs and TRs: 43.064, 44.018, 44.060, 45.008, 48.018, 43.022
- 1436: 7/12/15: created by MCC to distinguish Core versus test parts / Impacted TSs and TRs: 43.064, 44.018, 44.060, 45.008, 48.018, 43.022
- 1437: 7/12/15: created by GERAN. 2/3/16: G1,G2->G3. Acronym: eDRX_GSM-Test -> eDRX_GSM_GERAN3new (to conform to WID); 0->15%
- 1438: Impacted TSs and TRs: 23.401, 23.060, 23.682
- 1439: Dec.14: 0->30%. Mar15: 70%; June2015: Compl:70%->100 / Impacted TSs and TRs: New TR 23.709
- 1440: June 2015: created by MCC as a result of the split of the one-line Feature into a several-lines Feature (now Stage 2 and Stage 3 aspects); June2015: Compl:0%->100. WID: SP-150030->SP-150252 / Impacted TSs and TRs: 23.401, 23.060, 23.682
- 1441: 07/09/15: 0%->80; 7/12/15: 80%->100 / Impacted TSs and TRs: 29.274, 29.060, 29.281, 23.008, 29.272, 29.230, 29.002, 29.336, 29.xyz
- 1442: Triggered by Rel-12 TR 36.888 Study on Provision of low-cost MTC UEs based on LTE (FS_LC_MTC_LTE) and Low cost & enhanced coverage MTC UE for LTE (LC_MTC_UE) / Impacted TSs and TRs: LTE
- 1443: 3/3/15: WID: RP-141865; Stat Rep: -->RP-141785 1st Apr 15: Compl:10%->25% 1st Apr 15: WID: RP-141865->RP-150492 1st Apr 15: Stat Rep: RP-141785->RP-150495 03/07/15: Compl:25%->45% 03/07/15: Stat Rep: RP-150495->RP-150583 29/09/15: Compl:45%->65% 29/09 / Impacted TSs and TRs: 36.101, 36.104, 36.133, 36.201, 36.211, 36.212, 36.213, 36.214, 36.300, 36.302, 36.306, 36.321, 36.331
- 1444: ; WID: RP-142043->RP-141865; Stat Rep: -->RP-141785 1st Apr 15: WID: RP-141865->RP-150492 1st Apr 15: Stat Rep: RP-141785->RP-150495 03/07/15: Stat Rep: RP-150495->RP-150583 29/09/15: Stat Rep: RP-150583->RP-151186 ;26/9/16: Compl:70%-; / Impacted TSs and TRs: 36.101, 36.104, 36.133
- 1445: testing REL-13 LTE_MTCe2_L1-Core; 1/7/16: Compl:0%->6%; 26/; 2; 21/3/17: Compl:70%...; ;...; ;...
- 1446: 7/12/15: 0%->5; 28/1/16: 33.420 added; 7/3/16: 5%->80; 11/6/16: 80%->98; 19/9/16: 98%->99; 21/3/17: 99%->100->99%; 7/6/17: 99%->100 / Impacted TSs and TRs: New 33.420
- 1447: - / Impacted TSs and TRs: Stage 2
- 1448: Dec.14: 20->70%. Mar15: 90%; June2015: Compl:90%->100 / Impacted TSs and TRs: New TR 23.769
- 1449: Mar15: 0->20%; June2015: Compl:20%->100 / Impacted TSs and TRs: 23.682, TBD
- 1450: TR 33.8xy will capture requirements, solution alternatives, evaluations and conclusions for the AESE, MONTE and GROUPE WIDs. 3/3/15: 5->10%.; June2015: Compl:10%->60; 11/12/15: 60%->100 / Impacted TSs and TRs: New TR 33.889
- 1451: -; 11/12/15: 0%->100 / Impacted TSs and TRs: 33.187

| ID | WBS | Task | Duration | Start | Finish | Complete | Baseline start | Baseline finish | Baseline duration | Constraint | Resources | Work | Actual work | Acronym | PCG approved | WI rapporteur name | WI rapporteur e-mail | Release | TSG approved | Acronym_3GU_Export | Status Report | MCC resp | Special Focus Doc |
| --- | --- | --- | --- | --- | --- | --- | --- | --- | --- | --- | --- | --- | --- | --- | --- | --- | --- | --- | --- | --- | --- | --- | --- |
| 1452 | 525.5 | **CT aspects of Group based Enhancements** | 133d? | 2015-06-15 A | 2015-12-16 A | 100% |  |  |  |  | C4 | 4256h | 4256h | GROUPE-CT | 35 | Peter Schmitt, Huawei | Peter.Schmitt@huawei.com | Rel-13 | 68 |  |  |  |  |
| 1453 | 525.5.1 | CT1 aspects of Group based Enhancements | 133d? | 2015-06-15 A | 2015-12-16 A | 100% |  |  |  | start no earlier than 2015-06-15 | C1 | 1064h | 1064h | GROUPE-CT | 35 | Peter Schmitt, Huawei | Peter.Schmitt@huawei.com | Rel-13 | 68 |  |  |  |  |
| 1454 | 525.5.2 | DELETED: CT3 aspects of Group based Enhancements | 133d? | 2015-06-15 A | 2015-12-16 A | 100% |  |  |  | start no earlier than 2015-06-15 | C3 | 1064h | 1064h | GROUPE-CT | 35 | Peter Schmitt, Huawei | Peter.Schmitt@huawei.com | Rel-13 | 68 |  |  |  |  |
| 1455 | 525.5.3 | CT4 aspects of Group based Enhancements | 133d? | 2015-06-15 A | 2015-12-16 A | 100% |  |  |  | start no earlier than 2015-06-15 | C4 | 1064h | 1064h | GROUPE-CT | 35 | Peter Schmitt, Huawei | Peter.Schmitt@huawei.com | Rel-13 | 68 |  |  |  |  |
| 1456 | 526 | **Monitoring Enhancements** | 456d? | 2014-06-18 A | 2016-03-11 A | 100% | 2014-06-18 | 2015-09-16 | 326d? |  | S2; S3 | 21684.8h | 21684.8h | MONTE | 33 | Intel | puneet.jain@intel.com | Rel-13 | 64 | MONTE |  |  |  |
| 1457 | 526.1 | TR for Monitoring Enhancements | 196d? | 2014-09-17 A | 2015-06-17 A | 100% | 2014-09-17 | 2015-06-17 | 196d? | finish no earlier than 2015-06-17 | S2 | 1568h | 1568h | MONTE | 33 | Intel, Puneet Jain | puneet.jain@intel.com | Rel-13 | 64 |  |  |  |  |
| 1458 | 526.2 | Stage 2 for Monitoring Enhancements | 261d? | 2014-06-23 A | 2015-06-17 A | 100% | 2014-06-18 | 2015-06-17 | 261d? | finish no earlier than 2015-06-17 | S2 | 2088h | 2088h | MONTE | 33 | Intel, Puneet Jain | puneet.jain@intel.com | Rel-13 | 64 |  |  |  |  |
| 1459 | 526.3 | TR on Security for Monitoring Enhancements | 231.6d? | 2014-06-18 A | 2015-06-12 A | 100% | 2014-06-18 | 2015-06-17 | 231.6d? | start no earlier than 2014-06-18 | S3 | 1852.8h | 1852.8h | MONTE | 33 | Samsung | Rajavelsamy R (rajvel@samsung.com) | Rel-13 | 64 |  |  |  |  |
| 1460 | 526.4 | Security for Monitoring Enhancements | 326d? | 2014-06-23 A | 2015-09-16 A | 100% | 2014-06-18 | 2015-09-16 | 326d? | finish no earlier than 2015-09-16 | S3 | 2608h | 2608h | MONTE | 33 | Samsung | Rajavelsamy R (rajvel@samsung.com) | Rel-13 | 64 |  |  |  |  |
| 1461 | 526.5 | Charging aspects of MONTE | 128d? | 2015-09-16 A | 2016-03-11 A | 100% | 2014-06-18 | 2015-09-16 | 326d? | finish no earlier than 2016-03-11 | S5 | 1024h | 1024h | MONTE-CH | 35 | Huawei(Li Li, jasmine.li@huawei.com) | jasmine.li@huawei.com | Rel-13 | 69 |  |  |  |  |
| 1462 | 526.6 | **Monitoring Enhancements CT aspects** | 195d? | 2015-06-15 A | 2016-03-11 A | 100% |  |  |  |  | C4 | 5248h | 5248h | MONTE-CT | 35 | Peter Schmitt, Huawei | peter.schmitt@huawei.com | Rel-13 | 68 |  |  |  |  |
| 1463 | 526.6.1 | CT1 aspects of Monitoring Enhancements | 133d? | 2015-06-15 A | 2015-12-16 A | 100% |  |  |  | start no earlier than 2015-06-15 | C1 | 1064h | 1064h | MONTE-CT | 35 | Peter Schmitt, Huawei | peter.schmitt@huawei.com | Rel-13 | 68 |  |  |  |  |
| 1464 | 526.6.2 | CT3 aspects of Monitoring Enhancements | 133d? | 2015-06-15 A | 2015-12-16 A | 100% |  |  |  | start no earlier than 2015-06-15 | C3 | 1064h | 1064h | MONTE-CT | 35 | Peter Schmitt, Huawei | peter.schmitt@huawei.com | Rel-13 | 68 |  |  |  |  |
| 1465 | 526.6.3 | CT4 aspects of Monitoring Enhancements | 195d? | 2015-06-15 A | 2016-03-11 A | 100% |  |  |  | finish no earlier than 2016-03-11 | C4 | 1560h | 1560h | MONTE-CT | 35 | Peter Schmitt, Huawei | peter.schmitt@huawei.com | Rel-13 | 68 |  |  |  |  |
| 1466 | 527 | **Dedicated Core Networks** | 456d? | 2014-06-18 A | 2016-03-11 A | 100% | 2014-06-18 | 2015-03-18 | 196d? |  | S2 | 11518.4h | 11518.4h | DECOR | 33 | NTT DOCOMO | Daisuke Fujishima (fujishimad@nttdocomo.co.jp) | Rel-13 | 64 | DECOR |  |  |  |
| 1467 | 527.1 | TR for Dedicated Core Networks | 128d? | 2014-06-18 A | 2014-12-12 A | 100% | 2014-06-18 | 2014-12-10 | 126d? | finish no earlier than 2014-12-12 | S2 | 1024h | 1024h | DECOR | 33 | NTT DOCOMO | Daisuke Fujishima (fujishimad@nttdocomo.co.jp) | Rel-13 | 64 |  |  |  |  |
| 1468 | 527.2 | Stage 2 for Dedicated Core Networks | 196d? | 2014-06-23 A | 2015-03-18 A | 100% | 2014-06-18 | 2015-03-18 | 196d? | finish no earlier than 2015-03-18 | S2 | 1568h | 1568h | DECOR | 33 | NTT DOCOMO | Daisuke Fujishima (fujishimad@nttdocomo.co.jp) | Rel-13 | 64 |  |  |  |  |
| 1469 | 527.3 | **CT aspects of Dedicated Core Networks** | 186.8d? | 2015-06-25 A | 2016-03-11 A | 100% |  |  |  |  | ct | 3166.4h | 3166.4h | DECOR-CT | 35 | Huawei, Xiaoyan SHI (Sean.shixiaoyan@huawei.com) | Huawei, Xiaoyan SHI (Sean.shixiaoyan@huawei.com) | Rel-13 | 69 |  |  |  |  |
| 1470 | 527.3.1 | CT1 aspects for Dedicated Core Networks CT aspects | 74d? | 2015-09-07 A | 2015-12-17 A | 100% |  |  |  | finish no earlier than 2015-12-17 | C1 | 592h | 592h | DECOR-CT | 35 | Huawei |  | Rel-13 | 69 |  |  |  |  |
| 1471 | 527.3.2 | CT4 aspects for Dedicated Core Networks CT aspects | 135d? | 2015-06-25 A | 2016-03-11 A | 100% |  |  |  | finish no earlier than 2016-03-11 | C4 | 1080h | 1080h | DECOR-CT | 35 |  |  | Rel-13 | 69 |  |  |  |  |
| 1472 | 527.4 | **Dedicated Core Networks RAN Aspects** | 132d? | 2015-06-15 A | 2015-12-15 A | 100% |  |  |  |  | R3 | 2112h | 2112h | DECOR-UTRA_LTE | 35 | Ericsson |  | Rel-13 | 68 |  |  |  |  |
| 1473 | 527.4.1 | Core part: Dedicated Core Networks | 132d? | 2015-06-15 A | 2015-12-15 A | 100% |  |  |  | finish no earlier than 2015-12-15 | R3 | 1056h | 1056h | DECOR-UTRA_LTE-Core | 35 | Ericsson |  | Rel-13 | 68 |  | RP-151290 |  |  |
| 1474 | 528 | **Service Exposure and Enablement Support** | 268d? | 2013-09-12 A | 2014-09-17 A | 100% | 2013-09-12 | 2014-09-17 | 267d? |  | S1 | 5880h | 5880h | SEES | 31 | KPN | toon.norp@tno.nl | Rel-13 | 61 | SEES | S1-143301 | Alain | MTC, M2M |
| 1475 | 528.1 | TR on Stage 1 for Service Exposure and Enablement Support | 202d? | 2013-09-12 A | 2014-06-18 A | 100% | 2013-09-12 | 2014-06-18 | 202d? | finish no earlier than 2014-06-18 | S1 | 1608h | 1608h | SEES | 31 | KPN | toon.norp@tno.nl | Rel-13 | 61 |  | S1-143301 | Alain | MTC, M2M |
| 1476 | 528.2 | Stage 1 for Service Exposure and Enablement Support | 266d? | 2013-09-12 A | 2014-09-17 A | 100% | 2013-09-12 | 2014-09-17 | 266d? | finish no earlier than 2014-09-17 | S1 | 2128h | 2128h | SEES | 31 | KPN | toon.norp@tno.nl | Rel-13 | 61 |  | S1-143301 | Alain | MTC, M2M |

Notes:
- 1452: 7/12/15: WID:CP-150240->CP-150816 / Impacted TSs and TRs: 24.008, 24.301, 29.468, 29.272, 23.008, 29.336, 29.303, 29.002, 29.230, 29.305, 23.003
- 1453: 07/09/15: 0%->15; 7/12/15: 15%->100; 7/12/15: WID:CP-150240->CP-150816 / Impacted TSs and TRs: 24.008, 24.301
- 1454: 7/12/15: WID:CP-150240->CP-150816. CT3 task removed / Impacted TSs and TRs: 29.468
- 1455: 07/09/15: 0%->80; 7/12/15: 80%->100; 7/12/15: WID:CP-150240->CP-150816 / Impacted TSs and TRs: 29.272, 23.008, 29.336, 29.303, 29.002, 29.230, 29.305, 23.003
- 1456: Linked to Rel-13 Feature Architecture Enhancements for Service Exposure (AESE). Although service requirements (TS 22.368 clause 7.2.8) are motivated by MTC, the solution may apply to normal UEs; 5/10/15: 32.278 added; / Impacted TSs and TRs: 32.278
- 1457: Dec.14: 25->85%. Mar15: 100% / Impacted TSs and TRs: New TR 23.789
- 1458: -; June2015: Compl:0%->100 / Impacted TSs and TRs: 23.682, TBD
- 1459: TR 33.8xy will capture requirements, solution alternatives, evaluations and conclusions for the AESE, MONTE and GROUPE WIDs.3/3/15: 5->10%.; June2015: Compl:10%->15; 11/12/15: 15%->100 / Impacted TSs and TRs: New TR 33.889
- 1460: -; 11/12/15: 0%->100 / Impacted TSs and TRs: 33.187
- 1461: 7/10/15: acronym changed from "MONTE" to "MONTE-CH"; 7/12/15: 0%->50. ES in SP-150709 (wrong UID in the ES); 7/3/16: 25%->100 / Impacted TSs and TRs: 32.27x, 32.240, 32.299, 32.298
- 1462: 14/09/15: WID:CP-150396->CP-150422
- 1463: 07/09/15: 0%->95; 14/09/15: WID:CP-150396->CP-150422; 7/12/15: 95%->100 / Impacted TSs and TRs: 24.301, 24.008
- 1464: 07/09/15: 0%->100; 14/09/15: WID:CP-150396->CP-150422 / Impacted TSs and TRs: 29.214, 29.213, 29.201
- 1465: 61907/09/15: 0%->50; 14/09/15: WID:CP-150396->CP-150422; 7/12/15: 50%->85. FCD -> 03/16, ES in CP-150619; 7/3/16: 85%->100 / Impacted TSs and TRs: New TS 29.128, 29.272, 29.002, 29.336, 29.230, 23.008
- 1466: 06/15: WID: SP-140707-> SP-150249 / Impacted TSs and TRs: Stage 2
- 1467: Dec.14: 30->100%. 06/15: WID: SP-140707-> SP-150249 / Impacted TSs and TRs: New TR 23.707
- 1468: Mar15: 0->70%; June2015: Compl:70%->100, WID: SP-140707-> SP-150249 / Impacted TSs and TRs: 23.060, 23.401, 23.236
- 1470: 7/12/15: 0%->100 / Impacted TSs and TRs: 24.301, 24.008
- 1471: 7/12/15: 70%->90. FCD -> 03/16, ES CP-150617; 7/3/16: 90%->100 / Impacted TSs and TRs: 29.274, 29.060, 23.003, 29.272, 29.002, 29.305, 23.008, 29.230, 29.303, 23.007
- 1472: no Perf. part; note: DECOR is a REL-13 SA2 WI;
- 1473: no Perf. part; note: DECOR is a REL-13 SA2 WI; 29/09/15: Compl:0%->30% 29/09/15: Stat Rep: -->RP-1512901/1/16: Compl:30%->100%
- 1474: SP#62 completion 06/14=>09/14. Linked to Rel-12 Study TR 22.888 (FS_MTCe) and to Features Rel-11 SIMTC & Rel-12 MTCe and MOSAP / Impacted TSs and TRs: Stage 1
- 1475: SP#64 completed. TR 22.853v200 for Approval. External requirements from oneM2M TR0001(oneM2M Use Case collection), TS0002 (M2M Requirements) / Impacted TSs and TRs: New TR 22.853
- 1476: SP#65 completed / Impacted TSs and TRs: 22.101, 22.115, 22.368, TBD

| ID | WBS | Task | Duration | Start | Finish | Complete | Remaining | Baseline start | Baseline finish | Baseline duration | Total slack | Constraint | Resources | Work | Actual work | Acronym | PCG approved | WI rapporteur name | WI rapporteur e-mail | Release | TSG approved | Acronym_3GU_Export | MCC resp | Special Focus Doc | Status Report |
| --- | --- | --- | --- | --- | --- | --- | --- | --- | --- | --- | --- | --- | --- | --- | --- | --- | --- | --- | --- | --- | --- | --- | --- | --- | --- |
| 1477 | 529 | **Architecture Enhancements for Service capability Exposure** | 456d? | 2014-06-18 A | 2016-03-11 A | 100% |  | 2014-06-18 | 2015-09-16 | 326d? |  |  | S2; S3 | 19675.2h | 16027.2h | AESE | 33 | Intel | puneet.jain@intel.com | Rel-13 | 64 | AESE |  |  |  |
| 1478 | 529.1 | TR for Architecture Enhancements for Service capability Exposure | 196d? | 2014-06-18 A | 2015-03-18 A | 100% |  | 2014-06-18 | 2015-03-18 | 196d? |  | finish no earlier than 2015-03-18 | S2 | 1568h | 1568h | AESE | 33 | Intel, Puneet Jain | puneet.jain@intel.com | Rel-13 | 64 |  |  |  |  |
| 1479 | 529.2 | Stage 2 for Architecture Enhancements for Service capability Exposure | 261d? | 2014-06-23 A | 2015-06-17 A | 100% |  | 2014-06-18 | 2015-06-17 | 261d? |  | finish no earlier than 2015-06-17 | S2 | 2088h | 2088h | AESE | 33 | Intel, Puneet Jain | puneet.jain@intel.com | Rel-13 | 64 |  |  |  |  |
| 1480 | 529.3 | TR on Security for Architecture Enhancements for Service capability Exposure | 241.4d? | 2014-06-23 A | 2015-06-17 A | 100% |  | 2014-06-18 | 2015-06-17 | 241.4d? |  | finish no earlier than 2015-06-17 | S3 | 1931.2h | 1931.2h | AESE | 33 | Samsung | Rajavelsamy R (rajvel@samsung.com) | Rel-13 | 64 |  |  |  |  |
| 1481 | 529.4 | Security for Architecture Enhancements for Service capability Exposure | 326d? | 2014-06-23 A | 2015-09-16 A | 100% |  | 2014-06-18 | 2015-09-16 | 326d? |  | finish no earlier than 2015-09-16 | S3 | 2608h | 2608h | AESE | 33 | Samsung | Rajavelsamy R (rajvel@samsung.com) | Rel-13 | 64 |  |  |  |  |
| 1482 | 529.5 | **CT aspects of Architecture Enhancements for Service capability Exposure** | 195d? | 2015-06-15 A | 2016-03-11 A | 100% |  |  |  |  |  |  | C3 | 4184h | 4184h | AESE-CT | 35 | Yizhuang Wu, Huawei | wuyizhuang@huawei.com | Rel-13 | 68 |  |  |  |  |
| 1483 | 529.5.1 | CT3 aspects of Architecture Enhancements for Service capability Exposure | 195d? | 2015-06-15 A | 2016-03-11 A | 100% |  |  |  |  |  | finish no earlier than 2016-03-11 | C3 | 1560h | 1560h | AESE-CT | 35 | Yizhuang Wu, Huawei. FCD+3, ES in 642 | wuyizhuang@huawei.com | Rel-13 | 68 |  |  |  |  |
| 1484 | 529.5.2 | CT4 aspects of Architecture Enhancements for Service capability Exposure | 133d? | 2015-06-15 A | 2015-12-16 A | 100% |  |  |  |  |  | start no earlier than 2015-06-15 | C4 | 1064h | 1064h | AESE-CT | 35 | Yizhuang Wu, Huawei | wuyizhuang@huawei.com | Rel-13 | 68 |  |  |  |  |
| 1485 | 530 | **Rel-13 LTE Carrier Aggregation** | 1250d? | 2013-12-09 A | 2018-09-15 | 93% | 81.3d? | 2014-03-06 | 2015-06-12 | 332d? | 456d |  | R4 | 555056h | 508537h | LTE_CA_Rel13 | 30 |  |  | Rel-13 | 58 | LTE_CA_Rel-13 | Issam | CA |  |
| 1486 | 530.1 | **LTE Advanced 4 Band Carrier Aggregation (4DL/1UL) of Band 4, Band 4, Band 5 and Band 12** | 66d? | 2015-09-15 A | 2015-12-15 A | 100% |  |  |  |  |  |  | R4 | 1584h | 1584h | LTE_CA_B4_B4_B5_B12 | 35 | US Cellular |  | Rel-13 | 69 |  |  |  |  |
| 1487 | 530.1.1 | Core part:LTE Advanced 4 Band Carrier Aggregation (4DL/1UL) of Band 4, Band 4, Band 5 and Band 12 | 66d? | 2015-09-15 A | 2015-12-15 A | 100% |  |  |  |  |  | finish no earlier than 2016-03-15 | R4 | 528h | 528h | LTE_CA_B4_B4_B5_B12-Core | 35 | US Cellular |  | Rel-13 | 69 |  |  |  |  |
| 1488 | 530.1.2 | Perf. part:LTE Advanced 4 Band Carrier Aggregation (4DL/1UL) of Band 4, Band 4, Band 5 and Band 12 | 66d? | 2015-09-15 A | 2015-12-15 A | 100% |  |  |  |  |  | finish no earlier than 2016-03-15 | R4 | 528h | 528h | LTE_CA_B4_B4_B5_B12-Perf | 35 | US Cellular |  | Rel-13 | 69 |  |  |  |  |
| 1489 | 530.2 | **LTE Advanced 4 Band Carrier Aggregation (4DL/1UL) of Band 2, Band 4, Band 4 and Band 5** | 66d? | 2015-09-15 A | 2015-12-15 A | 100% |  |  |  |  |  |  | R4 | 1584h | 1584h | LTE_CA_B2_B4_B4_B5 | 35 | US Cellular |  | Rel-13 | 69 |  |  |  |  |
| 1490 | 530.2.1 | Core part:LTE Advanced 4 Band Carrier Aggregation (4DL/1UL) of Band 2, Band 4, Band 4 and Band 5 | 66d? | 2015-09-15 A | 2015-12-15 A | 100% |  |  |  |  |  | finish no earlier than 2016-03-15 | R4 | 528h | 528h | LTE_CA_B2_B4_B4_B5-Core | 35 | US Cellular |  | Rel-13 | 69 |  |  |  |  |
| 1491 | 530.2.2 | Perf. part:LTE Advanced 4 Band Carrier Aggregation (4DL/1UL) of Band 2, Band 4, Band 4 and Band 5 | 66d? | 2015-09-15 A | 2015-12-15 A | 100% |  |  |  |  |  | finish no earlier than 2016-03-15 | R4 | 528h | 528h | LTE_CA_B2_B4_B4_B5-Perf | 35 | US Cellular |  | Rel-13 | 69 |  |  |  |  |
| 1492 | 530.3 | **LTE Advanced inter-band Carrier Aggregation of Band 8 and Band 27** | 531d? | 2013-12-09 A | 2015-12-15 | 30% | 371.7d? | 2013-12-09 | 2014-12-11 | 265d? | 1175d |  | R4 | 12696h | 2643.08h | LTE_CA_B8_B27 | 32 | KT | ilwhan.kim@kt.com | Rel-13 | 62 | LTE_CA_B8_B27 | Issam | CA |  |
| 1493 | 530.3.1 | Core part:LTE Advanced inter-band Carrier Aggregation of Band 8 and Band 27 | 528d? | 2013-12-09 A | 2015-12-15 | 30% | 369.6d? | 2013-12-09 | 2014-12-11 | 265d? | 1175d | finish no earlier than 2015-12-15 | R4 | 4224h | 1267.2h | LTE_CA_B8_B27-Core | 32 | KT | ilwhan.kim@kt.com | Rel-13 | 62 | LTE_CA_B8_B27-Core | Issam | CA | RP-151131 |
| 1494 | 530.3.2 | Perf. part:LTE Advanced inter-band Carrier Aggregation of Band 8 and Band 27 | 528d? | 2013-12-09 A | 2015-12-15 | 30% | 369.6d? | 2013-12-09 | 2014-12-11 | 265d? | 1175d | finish no earlier than 2015-12-15 | R4 | 4224h | 1267.2h | LTE_CA_B8_B27-Perf | 32 | KT | ilwhan.kim@kt.com | Rel-13 | 62 | LTE_CA_B8_B27-Perf | Issam | CA | RP-151131 |
| 1495 | 530.4 | **LTE Advanced 3 band Carrier Aggregation (3DL/1UL) for Band 3, Band 8 and Band 27** | 531d? | 2013-12-09 A | 2015-12-15 | 25% | 398.25d? | 2013-12-09 | 2014-12-05 | 261d? | 1175d |  | R4 | 12696h | 2384h | LTE_CA_B3_B8_B27 | 32 | KT | Chungwoo HWANG (cwhwang@kt.com) | Rel-13 | 62 | LTE_CA_B3_B8_B27 | Issam | CA |  |
| 1496 | 530.4.1 | Core part:LTE Advanced 3 band Carrier Aggregation (3DL/1UL) for Band 3, Band 8 and Band 27 | 528d? | 2013-12-09 A | 2015-12-15 | 25% | 396d? | 2013-12-09 | 2014-12-05 | 261d? | 1175d | finish no earlier than 2015-12-15 | R4 | 4224h | 1056h | LTE_CA_B3_B8_B27-Core | 32 | KT | Chungwoo HWANG (cwhwang@kt.com) | Rel-13 | 62 | LTE_CA_B3_B8_B27-Core | Issam | CA | RP-151131 |
| 1497 | 530.4.2 | Perf. part:LTE Advanced 3 band Carrier Aggregation (3DL/1UL) for Band 3, Band 8 and Band 27 | 528d? | 2013-12-09 A | 2015-12-15 | 25% | 396d? | 2013-12-09 | 2014-12-05 | 261d? | 1175d | finish no earlier than 2015-12-15 | R4 | 4224h | 1056h | LTE_CA_B3_B8_B27-Perf | 32 | KT | Chungwoo HWANG (cwhwang@kt.com) | Rel-13 | 62 | LTE_CA_B3_B8_B27-Perf | Issam | CA | RP-151131 |
| 1498 | 530.5 | **LTE Advanced inter-band Carrier Aggregation of Band 7 and Band 22** | 336d? | 2014-03-06 A | 2015-06-15 A | 100% |  | 2014-03-06 | 2014-12-05 | 197d? |  |  | R4 | 8016h | 8016h | LTE_CA_B7_B22 | 32 | Orange, Ericsson | erika.tejedor@ericsson.com | Rel-13 | 63 | LTE_CA_B7_B22 | Issam | CA |  |
| 1499 | 530.5.1 | Core part:LTE Advanced inter-band Carrier Aggregation of Band 7 and Band 22 | 333d? | 2014-03-06 A | 2015-06-15 A | 100% |  | 2014-03-06 | 2014-12-05 | 197d? |  | finish no earlier than 2015-06-15 | R4 | 2664h | 2664h | LTE_CA_B7_B22-Core | 32 | Orange, Ericsson | erika.tejedor@ericsson.com | Rel-13 | 63 | LTE_CA_B7_B22-Core | Issam | CA | RP-150536 |
| 1500 | 530.5.2 | Perf. part:LTE Advanced inter-band Carrier Aggregation of Band 7 and Band 22 | 333d? | 2014-03-11 A | 2015-06-15 A | 100% |  | 2014-03-06 | 2014-12-05 | 197d? |  | finish no earlier than 2015-06-15 | R4 | 2664h | 2664h | LTE_CA_B7_B22-Perf | 32 | Orange, Ericsson | erika.tejedor@ericsson.com | Rel-13 | 63 | LTE_CA_B7_B22-Perf | Issam | CA | RP-150536 |

Notes:
- 1477: - / Impacted TSs and TRs: Stage 2
- 1478: Dec.14: 30->65%. Mar15: 75%; June2015: Compl:75%->100 / Impacted TSs and TRs: New TR 23.708
- 1479: -; June2015: Compl:0%->100 / Impacted TSs and TRs: TS 23.682, TS 33.187
- 1480: TR 33.8xy will capture requirements, solution alternatives, evaluations and conclusions for the AESE, MONTE and GROUPE WIDs. Dec.14: 0->40%. 3/3/15: 45%.; June2015: Compl:45%->60; 11/12/15: 60%->100 / Impacted TSs and TRs: New TR 33.889
- 1481: -; 11/12/15: 0%->100 / Impacted TSs and TRs: 33.187
- 1482: 14/09/15: WID:CP-150402->CP-150487->CP-150576
- 1483: 07/09/15: 0%->35; 14/09/15: WID:CP-150402->CP-150487->CP-150576; 7/12/15: 35%->90; 7/3/16: 90%->100 / Impacted TSs and TRs: 29.154
- 1484: 07/09/15: 0%->40; 14/09/15: WID:CP-150402->CP-150487->CP-150576; 7/12/15: 40%->100 / Impacted TSs and TRs: 29.201, 29.336, 29.230, 29.272, 23.008
- 1485: Acronym changed from "LTE_CA_Rel-13" to "LTE_CA_Rel13"
- 1486: 13/6/16: moved from Rel-14 to Rel-13 (was a mistake)
- 1487: 13/6/16: moved from Rel-14 to Rel-13 (was a mistake)
- 1488: 13/6/16: moved from Rel-14 to Rel-13 (was a mistake)
- 1489: 13/6/16: moved from Rel-14 to Rel-13 (was a mistake)
- 1490: 13/6/16: moved from Rel-14 to Rel-13 (was a mistake)
- 1491: 13/6/16: moved from Rel-14 to Rel-13 (was a mistake)
- 1492: Inter-band CA 2DL/1UL / Impacted TSs and TRs: LTE
- 1493: CD:Thu 18/06/15->Mon 15/06/15; Compl:10%->10%; Stat Rep: RP-141084->RP-141732 1st Apr 15: Compl:10%->15% 1st Apr 15: Stat Rep: RP-141732->RP-150013 03/07/15: Compl:15%->30% 03/07/15: CD:Mon 15/06/15->Tue 15/12/15 03/07/15: Stat Rep: RP-150013->RP-15053 / Impacted TSs and TRs: 36.101, 36.104, 36.133, generic TR 36.851
- 1494: CD:Thu 18/06/15->Mon 15/06/15; Compl:10%->10%; Stat Rep: RP-141084->RP-141732 1st Apr 15: Compl:10%->15% 1st Apr 15: Stat Rep: RP-141732->RP-150013 03/07/15: Compl:15%->30% 03/07/15: CD:Mon 15/06/15->Tue 15/12/15 03/07/15: Stat Rep: RP-150013->RP-15053 / Impacted TSs and TRs: 36.141, 36.307
- 1495: Inter-band CA 3DL / Impacted TSs and TRs: LTE
- 1496: CD:Thu 18/06/15->Mon 15/06/15; Compl:25%->25%; Stat Rep: RP-141084->RP-141732 1st Apr 15: Compl:25%->30% 1st Apr 15: Stat Rep: RP-141732->RP-150013 03/07/15: Compl:30%->25% 03/07/15: CD:Mon 15/06/15->Tue 15/12/15 03/07/15: Stat Rep: RP-150013->RP-15053 / Impacted TSs and TRs: 36.101, 36.104, 36.133, 36.141, 36.307, new generic TR 36.853 (3 Band CA with 1UL)
- 1497: CD:Thu 18/06/15->Mon 15/06/15; Compl:25%->25%; Stat Rep: RP-141084->RP-141732 1st Apr 15: Compl:25%->30% 1st Apr 15: Stat Rep: RP-141732->RP-150013 03/07/15: Compl:30%->25% 03/07/15: CD:Mon 15/06/15->Tue 15/12/15 03/07/15: Stat Rep: RP-150013->RP-15053 / Impacted TSs and TRs: 36.101, 36.104, 36.133, 36.141, 36.307
- 1498: Inter-band CA 2DL / Impacted TSs and TRs: LTE
- 1499: CD:Thu 11/12/14->Mon 15/06/15; Compl:10%->10%; Stat Rep: RP-141084->RP-141732 03/07/15: Compl:10%->100% 03/07/15: Stat Rep: RP-141732->RP-150536 / Impacted TSs and TRs: 36.101, 36.104, 36.133, generic TR 36.851 (2 Band CA with 1UL),
- 1500: CD:Thu 11/12/14->Mon 15/06/15; Compl:0%->0%; Stat Rep: RP-141084->RP-141732 03/07/15: Compl:0%->100% 03/07/15: Stat Rep: RP-141732->RP-150536 / Impacted TSs and TRs: 36.141, 36.307

| ID | WBS | Task | Duration | Start | Finish | Complete | Baseline start | Baseline finish | Baseline duration | Constraint | Resources | Work | Actual work | Acronym | PCG approved | WI rapporteur name | WI rapporteur e-mail | Release | TSG approved | Special Focus Doc | Acronym_3GU_Export | Status Report |
| --- | --- | --- | --- | --- | --- | --- | --- | --- | --- | --- | --- | --- | --- | --- | --- | --- | --- | --- | --- | --- | --- | --- |
| 1501 | 530.6 | **LTE Advanced 3 Band Carrier Aggregation (3DL/1UL) for Band 2, Band 2 and Band 12** | 262d? | 2014-06-18 A | 2015-06-15 A | 100% | 2014-06-13 | 2015-03-13 | 196d? |  | R4 | 6288h | 6288h | LTE_CA_B2_B2_B12 | 33 | U.S. Cellular | sebastian.thalanany@uscellular.com | Rel-13 | 64 | CA | LTE_CA_B2_B2_B12 |  |
| 1502 | 530.6.1 | Core part:LTE Advanced 3 Band Carrier Aggregation (3DL/1UL) for Band 2, Band 2 and Band 12 | 262d? | 2014-06-18 A | 2015-06-15 A | 100% | 2014-06-13 | 2014-12-05 | 126d? | finish no earlier than 2015-06-15 | R4 | 2096h | 2096h | LTE_CA_B2_B2_B12-Core | 33 | U.S. Cellular | sebastian.thalanany@uscellular.com | Rel-13 | 64 | CA | LTE_CA_B2_B2_B12-Core | RP-150536 |
| 1503 | 530.6.2 | Perf. Part:LTE Advanced 3 Band Carrier Aggregation (3DL/1UL) for Band 2, Band 2 and Band 12 | 262d? | 2014-06-18 A | 2015-06-15 A | 100% | 2014-06-13 | 2015-03-13 | 196d? | finish no earlier than 2015-06-15 | R4 | 2096h | 2096h | LTE_CA_B2_B2_B12-Perf | 33 | U.S. Cellular | sebastian.thalanany@uscellular.com | Rel-13 | 64 | CA | LTE_CA_B2_B2_B12-Perf | RP-150536 |
| 1504 | 530.7 | **LTE Advanced 3 Band Carrier Aggregation (3DL/1UL) of Band 3, Band 3 and Band 8** | 264d? | 2014-06-16 A | 2015-06-15 A | 100% | 2014-06-13 | 2015-06-12 | 261d? |  | R4 | 6304h | 6304h | LTE_CA_B3_B3_B8 | 33 | CHTTL | Po-Han Hsieh (pohanhsieh@cht.com.tw) | Rel-13 | 64 | CA | LTE_CA_B3_B3_B8 |  |
| 1505 | 530.7.1 | Core part:LTE Advanced 3 Band Carrier Aggregation (3DL/1UL) of Band 3, Band 3 and Band 8 | 262d? | 2014-06-16 A | 2015-06-15 A | 100% | 2014-06-13 | 2015-06-12 | 261d? | finish no earlier than 2015-06-15 | R4 | 2096h | 2096h | LTE_CA_B3_B3_B8-Core | 33 | CHTTL | Po-Han Hsieh (pohanhsieh@cht.com.tw) | Rel-13 | 64 | CA | LTE_CA_B3_B3_B8-Core | RP-150536 |
| 1506 | 530.7.2 | Perf. Part:LTE Advanced 3 Band Carrier Aggregation (3DL/1UL) of Band 3, Band 3 and Band 8 | 262d? | 2014-06-18 A | 2015-06-15 A | 100% | 2014-06-13 | 2015-06-12 | 261d? | finish no earlier than 2015-06-15 | R4 | 2096h | 2096h | LTE_CA_B3_B3_B8-Perf | 33 | CHTTL | Po-Han Hsieh (pohanhsieh@cht.com.tw) | Rel-13 | 64 | CA | LTE_CA_B3_B3_B8-Perf | RP-150536 |
| 1507 | 530.8 | **LTE Advanced 3 Band Carrier Aggregation (3DL/1UL) of Band 41, Band 42 and Band 42** | 264d? | 2014-06-16 A | 2015-06-15 A | 100% | 2014-06-13 | 2014-12-05 | 126d? |  | R4 | 6304h | 6304h | LTE_CA_B41_B42_B42 | 33 | Huawei | leo.liuye@huawei.com | Rel-13 | 64 | CA | LTE_CA_B41_B42_B42 |  |
| 1508 | 530.8.1 | Core part:LTE Advanced 3 Band Carrier Aggregation (3DL/1UL) of Band 41, Band 42 and Band 42 | 262d? | 2014-06-16 A | 2015-06-15 A | 100% | 2014-06-13 | 2014-12-05 | 126d? | finish no earlier than 2015-06-15 | R4 | 2096h | 2096h | LTE_CA_B41_B42_B42-Core | 33 | Huawei | leo.liuye@huawei.com | Rel-13 | 64 | CA | LTE_CA_B41_B42_B42-Core | RP-150536 |
| 1509 | 530.8.2 | Perf. Part:LTE Advanced 3 Band Carrier Aggregation (3DL/1UL) of Band 41, Band 42 and Band 42 | 262d? | 2014-06-18 A | 2015-06-15 A | 100% | 2014-06-13 | 2014-12-05 | 126d? | finish no earlier than 2015-06-15 | R4 | 2096h | 2096h | LTE_CA_B41_B42_B42-Perf | 33 | Huawei | leo.liuye@huawei.com | Rel-13 | 64 | CA | LTE_CA_B41_B42_B42-Perf | RP-150536 |
| 1510 | 530.9 | **LTE Advanced inter-band Carrier Aggregation of Band 3 and Band 38** | 198d? | 2014-09-15 A | 2015-06-15 A | 100% | 2014-06-13 | 2015-03-13 | 196d? |  | R4 | 4752h | 4752h | LTE_CA_B3_B38 | 33 | Nokia Networks | iwajlo.angelow@nsn.com | Rel-13 | 65 | CA | LTE_CA_B3_B38 |  |
| 1511 | 530.9.1 | Core part:LTE Advanced inter-band Carrier Aggregation of Band 3 and Band 38 | 198d? | 2014-09-15 A | 2015-06-15 A | 100% | 2014-06-13 | 2015-03-13 | 196d? | finish no earlier than 2015-06-15 | R4 | 1584h | 1584h | LTE_CA_B3_B38-Core | 33 | Nokia Networks | iwajlo.angelow@nsn.com | Rel-13 | 65 | CA | LTE_CA_B3_B38-Core | RP-150536 |
| 1512 | 530.9.2 | Perf. Part:LTE Advanced inter-band Carrier Aggregation of Band 3 and Band 38 | 198d? | 2014-09-15 A | 2015-06-15 A | 100% | 2014-06-13 | 2015-03-13 | 196d? | finish no earlier than 2015-06-15 | R4 | 1584h | 1584h | LTE_CA_B3_B38-Perf | 33 | Nokia Networks | iwajlo.angelow@nsn.com | Rel-13 | 65 | CA | LTE_CA_B3_B38-Perf | RP-150536 |
| 1513 | 530.10 | **LTE Advanced inter-band Carrier Aggregation of Band 2 and Band 28** | 198d? | 2014-09-15 A | 2015-06-15 A | 100% | 2014-06-13 | 2015-03-13 | 196d? |  | R4 | 4752h | 4752h | LTE_CA_B2_B28 | 33 | Huawei | alf.ahlstrom@huawei.com | Rel-13 | 65 | CA | LTE_CA_B2_B28 |  |
| 1514 | 530.10.1 | Core part:LTE Advanced inter-band Carrier Aggregation of Band 2 and Band 28 | 198d? | 2014-09-15 A | 2015-06-15 A | 100% | 2014-06-13 | 2015-03-13 | 196d? | finish no earlier than 2015-06-15 | R4 | 1584h | 1584h | LTE_CA_B2_B28-Core | 33 | Huawei | alf.ahlstrom@huawei.com | Rel-13 | 65 | CA | LTE_CA_B2_B28-Core | RP-150536 |
| 1515 | 530.10.2 | Perf. Part:LTE Advanced inter-band Carrier Aggregation of Band 2 and Band 28 | 198d? | 2014-09-15 A | 2015-06-15 A | 100% | 2014-06-13 | 2015-03-13 | 196d? | finish no earlier than 2015-06-15 | R4 | 1584h | 1584h | LTE_CA_B2_B28-Perf | 33 | Huawei | alf.ahlstrom@huawei.com | Rel-13 | 65 | CA | LTE_CA_B2_B28-Perf | RP-150536 |
| 1516 | 530.11 | **LTE Advanced inter-band Carrier Aggregation of Band 4 and Band 28** | 198d? | 2014-09-15 A | 2015-06-15 A | 100% | 2014-06-13 | 2015-03-13 | 196d? |  | R4 | 4752h | 4752h | LTE_CA_B4_B28 | 33 | Huawei | alf.ahlstrom@huawei.com | Rel-13 | 65 | CA | LTE_CA_B4_B28 |  |
| 1517 | 530.11.1 | Core part:LTE Advanced inter-band Carrier Aggregation of Band 4 and Band 28 | 198d? | 2014-09-15 A | 2015-06-15 A | 100% | 2014-06-13 | 2015-03-13 | 196d? | finish no earlier than 2015-06-15 | R4 | 1584h | 1584h | LTE_CA_B4_B28-Core | 33 | Huawei | alf.ahlstrom@huawei.com | Rel-13 | 65 | CA | LTE_CA_B4_B28-Core | RP-150536 |
| 1518 | 530.11.2 | Perf. Part:LTE Advanced inter-band Carrier Aggregation of Band 4 and Band 28 | 198d? | 2014-09-15 A | 2015-06-15 A | 100% | 2014-06-13 | 2015-03-13 | 196d? | finish no earlier than 2015-06-15 | R4 | 1584h | 1584h | LTE_CA_B4_B28-Perf | 33 | Huawei | alf.ahlstrom@huawei.com | Rel-13 | 65 | CA | LTE_CA_B4_B28-Perf | RP-150536 |
| 1519 | 530.12 | **LTE Advanced inter-band Carrier Aggregation of Band 20 and Band 40** | 330d? | 2014-09-12 A | 2015-12-15 A | 100% | 2014-06-13 | 2015-03-13 | 196d? |  | R4 | 7912h | 7912h | LTE_CA_B20_B40 | 33 | Ericsson | imadur.rahman@ericsson.com | Rel-13 | 65 | CA | LTE_CA_B20_B40 |  |
| 1520 | 530.12.1 | Core part:LTE Advanced inter-band Carrier Aggregation of Band 20 and Band 40 | 330d? | 2014-09-12 A | 2015-12-15 A | 100% | 2014-06-13 | 2015-03-13 | 196d? | finish no earlier than 2015-12-15 | R4 | 2640h | 2640h | LTE_CA_B20_B40-Core | 33 | Ericsson | imadur.rahman@ericsson.com | Rel-13 | 65 | CA | LTE_CA_B20_B40-Core | RP-151131 |
| 1521 | 530.12.2 | Perf. Part:LTE Advanced inter-band Carrier Aggregation of Band 20 and Band 40 | 329d? | 2014-09-15 A | 2015-12-15 A | 100% | 2014-06-13 | 2015-03-13 | 196d? | finish no earlier than 2015-12-15 | R4 | 2632h | 2632h | LTE_CA_B20_B40-Perf | 33 | Ericsson | imadur.rahman@ericsson.com | Rel-13 | 65 | CA | LTE_CA_B20_B40-Perf | RP-151131 |
| 1522 | 530.13 | **LTE Advanced inter-band Carrier Aggregation of Band 1 and Band 40** | 329d? | 2014-09-15 A | 2015-12-15 A | 100% | 2014-06-13 | 2015-03-13 | 196d? |  | R4 | 7896h | 7896h | LTE_CA_B1_B40 | 33 | KT | ilwhan.kim@kt.com | Rel-13 | 65 | CA | LTE_CA_B1_B40 |  |
| 1523 | 530.13.1 | Core part:LTE Advanced inter-band Carrier Aggregation of Band 1 and Band 40 | 329d? | 2014-09-15 A | 2015-12-15 A | 100% | 2014-06-13 | 2015-03-13 | 196d? | finish no earlier than 2015-12-15 | R4 | 2632h | 2632h | LTE_CA_B1_B40-Core | 33 | KT | ilwhan.kim@kt.com | Rel-13 | 65 | CA | LTE_CA_B1_B40-Core | RP-151131 |
| 1524 | 530.13.2 | Perf. Part:LTE Advanced inter-band Carrier Aggregation of Band 1 and Band 40 | 329d? | 2014-09-15 A | 2015-12-15 A | 100% | 2014-06-13 | 2015-03-13 | 196d? | finish no earlier than 2015-12-15 | R4 | 2632h | 2632h | LTE_CA_B1_B40-Perf | 33 | KT | ilwhan.kim@kt.com | Rel-13 | 65 | CA | LTE_CA_B1_B40-Perf | RP-151131 |

Notes:
- 1501: Inter-band CA 3DL/1UL / Impacted TSs and TRs: LTE
- 1502: CD:Thu 12/03/15->Sun 15/03/15; Compl:0%->40%; Stat Rep: RP-141084->RP-141732 1st Apr 15: Compl:40%->99% 1st Apr 15: CD:Sun 15/03/15->Mon 15/06/15 1st Apr 15: Stat Rep: RP-141732->RP-150013 03/07/15: Compl:99%->100% 03/07/15: Stat Rep: RP-150013->RP-150536 / Impacted TSs and TRs: 36.101, 36.104, 36.133, 36.141, 36.307, generic new Rel-13 TR36.8xy [similar to Rel-12 TR 36.853 (3 Band CA with 1UL)]
- 1503: CD:Thu 18/06/15->Mon 15/06/15; Compl:0%->10%; Stat Rep: RP-141084->RP-141732 1st Apr 15: Compl:10%->99% 1st Apr 15: Stat Rep: RP-141732->RP-150013 03/07/15: Compl:99%->100% 03/07/15: Stat Rep: RP-150013->RP-150536 / Impacted TSs and TRs: 36.101, 36.104, 36.133, 36.141, 36.307
- 1504: Inter-band CA 3DL/1UL / Impacted TSs and TRs: LTE
- 1505: ; WID: RP-142043->RP-141832; Stat Rep: RP-141084->RP-141732 1st Apr 15: Compl:60%->99% 1st Apr 15: Stat Rep: RP-141732->RP-150013 03/07/15: Compl:99%->100% 03/07/15: WID: RP-141832->RP-150874 03/07/15: Stat Rep: RP-150013->RP-150536 / Impacted TSs and TRs: 36.101, 36.133, generic TR 36.853 (3 Band CA with 1UL)
- 1506: ; WID: RP-142043->RP-141832; Stat Rep: RP-141084->RP-141732 1st Apr 15: Compl:0%->99% 1st Apr 15: Stat Rep: RP-141732->RP-150013 03/07/15: Compl:99%->100% 03/07/15: WID: RP-141832->RP-150874 03/07/15: Stat Rep: RP-150013->RP-150536 / Impacted TSs and TRs: 36.307
- 1507: Inter-band CA 3DL/1UL / Impacted TSs and TRs: LTE
- 1508: CD:Thu 11/12/14->Sun 15/03/15; Compl:30%->50%; Stat Rep: RP-141084->RP-141732 1st Apr 15: Compl:50%->60% 1st Apr 15: CD:Sun 15/03/15->Mon 15/06/15 1st Apr 15: Stat Rep: RP-141732->RP-150013 03/07/15: Compl:60%->100% 03/07/15: Stat Rep: RP-150013->RP-15 / Impacted TSs and TRs: 36.101, 36.104, 36.133, generic TR 36.853 (3 Band CA with 1UL)
- 1509: CD:Thu 11/12/14->Sun 15/03/15; Compl:0%->0%; Stat Rep: RP-141084->RP-141732 1st Apr 15: Compl:0%->60% 1st Apr 15: CD:Sun 15/03/15->Mon 15/06/15 1st Apr 15: Stat Rep: RP-141732->RP-150013 03/07/15: Compl:60%->100% 03/07/15: Stat Rep: RP-150013->RP-150536 / Impacted TSs and TRs: 36.141, 36.307
- 1510: Inter-band CA 2DL/1UL / Impacted TSs and TRs: LTE
- 1511: CD:Thu 11/12/14->Sun 15/03/15; Compl:0%->90%; Stat Rep: -->RP-141732 1st Apr 15: CD:Sun 15/03/15->Mon 15/06/15 1st Apr 15: Stat Rep: RP-141732->RP-150013 03/07/15: Compl:90%->100% 03/07/15: WID: RP-141129->RP-150717 03/07/15: Stat Rep: RP-150013->RP-15 / Impacted TSs and TRs: 36.101, 36.104, New TR 36.8xx
- 1512: CD:Thu 11/12/14->Sun 15/03/15; Compl:0%->90%; Stat Rep: -->RP-141732 1st Apr 15: CD:Sun 15/03/15->Mon 15/06/15 1st Apr 15: Stat Rep: RP-141732->RP-150013 03/07/15: Compl:90%->100% 03/07/15: WID: RP-141129->RP-150717 03/07/15: Stat Rep: RP-150013->RP-15 / Impacted TSs and TRs: 36.141, 36.307
- 1513: Inter-band CA 2DL/1UL / Impacted TSs and TRs: LTE
- 1514: CD:Fri 11/12/15->Sun 15/03/15; Compl:0%->50%; Stat Rep: -->RP-141732 1st Apr 15: Compl:50%->99% 1st Apr 15: CD:Sun 15/03/15->Mon 15/06/15 1st Apr 15: Stat Rep: RP-141732->RP-150013 03/07/15: Compl:99%->100% 03/07/15: Stat Rep: RP-150013->RP-150536 / Impacted TSs and TRs: 36.101, 36.104, New TR 36.8xx
- 1515: CD:Thu 12/03/15->Sun 15/03/15; Compl:0%->0%; Stat Rep: -->RP-141732 1st Apr 15: Compl:0%->99% 1st Apr 15: CD:Sun 15/03/15->Mon 15/06/15 1st Apr 15: Stat Rep: RP-141732->RP-150013 03/07/15: Compl:99%->100% 03/07/15: Stat Rep: RP-150013->RP-150536 / Impacted TSs and TRs: 36.141, 36.307
- 1516: Inter-band CA 2DL/1UL / Impacted TSs and TRs: LTE
- 1517: CD:Fri 11/12/15->Sun 15/03/15; Compl:0%->35%; Stat Rep: -->RP-141732 1st Apr 15: Compl:35%->99% 1st Apr 15: CD:Sun 15/03/15->Mon 15/06/15 1st Apr 15: Stat Rep: RP-141732->RP-150013 03/07/15: Compl:99%->100% 03/07/15: Stat Rep: RP-150013->RP-150536 / Impacted TSs and TRs: 36.101, 36.104, New TR 36.8xx
- 1518: CD:Thu 12/03/15->Sun 15/03/15; Compl:0%->0%; Stat Rep: -->RP-141732 1st Apr 15: Compl:0%->99% 1st Apr 15: CD:Sun 15/03/15->Mon 15/06/15 1st Apr 15: Stat Rep: RP-141732->RP-150013 03/07/15: Compl:99%->100% 03/07/15: Stat Rep: RP-150013->RP-150536 / Impacted TSs and TRs: 36.141, 36.307
- 1519: Inter-band CA 2DL/1UL / Impacted TSs and TRs: LTE
- 1520: CD:Wed 11/03/15->Sun 15/03/15; Compl:0%->30%; Stat Rep: -->RP-141732 1st Apr 15: Compl:30%->70% 1st Apr 15: CD:Sun 15/03/15->Mon 15/06/15 1st Apr 15: Stat Rep: RP-141732->RP-150013 03/07/15: CD:Mon 15/06/15->Tue 15/09/15 03/07/15: Stat Rep: RP-150013-> / Impacted TSs and TRs: 36.101, 36.104, 36.133, New TR 36.8xx
- 1521: CD:Thu 12/03/15->Sun 15/03/15; Compl:0%->0%; Stat Rep: -->RP-141732 1st Apr 15: CD:Sun 15/03/15->Mon 15/06/15 1st Apr 15: Stat Rep: RP-141732->RP-150013 03/07/15: Compl:0%->70% 03/07/15: CD:Mon 15/06/15->Tue 15/09/15 03/07/15: Stat Rep: RP-150013->RP-1 / Impacted TSs and TRs: 36.141, 36.307
- 1522: Inter-band CA 2DL/1UL / Impacted TSs and TRs: LTE
- 1523: CD:Fri 12/06/15->Mon 15/06/15; Compl:0%->70%; Stat Rep: -->RP-141732 1st Apr 15: Compl:70%->80% 1st Apr 15: Stat Rep: RP-141732->RP-150013 03/07/15: Compl:80%->70% 03/07/15: CD:Mon 15/06/15->Tue 15/12/15 03/07/15: Stat Rep: RP-150013->RP-150536 29/09/1 / Impacted TSs and TRs: 36.101, 36.104, 36.133, New TR 36.8xx
- 1524: CD:Fri 11/12/15->Mon 15/06/15; Compl:0%->70%; Stat Rep: -->RP-141732 1st Apr 15: Compl:70%->80% 1st Apr 15: Stat Rep: RP-141732->RP-150013 03/07/15: Compl:80%->70% 03/07/15: CD:Mon 15/06/15->Tue 15/12/15 03/07/15: Stat Rep: RP-150013->RP-150536 29/09/1 / Impacted TSs and TRs: 36.141, 36.307

| ID | WBS | Task | Duration | Start | Finish | Complete | Baseline start | Baseline finish | Baseline duration | Constraint | Resources | Work | Actual work | Acronym | PCG approved | WI rapporteur name | WI rapporteur e-mail | Release | TSG approved | Special Focus Doc | Acronym_3GU_Export | Status Report |
| --- | --- | --- | --- | --- | --- | --- | --- | --- | --- | --- | --- | --- | --- | --- | --- | --- | --- | --- | --- | --- | --- | --- |
| 1525 | 530.14 | **LTE Advanced inter-band Carrier Aggregation of Band 3 and Band 40** | 198d? | 2014-09-15 A | 2015-06-15 A | 100% | 2014-06-13 | 2015-03-13 | 196d? |  | R4 | 4752h | 4752h | LTE_CA_B3_B40 | 33 | KT | Chungwoo HWANG (cwhwang@kt.com) | Rel-13 | 65 | CA | LTE_CA_B3_B40 |  |
| 1526 | 530.14.1 | Core part:LTE Advanced inter-band Carrier Aggregation of Band 3 and Band 40 | 198d? | 2014-09-15 A | 2015-06-15 A | 100% | 2014-06-13 | 2015-03-13 | 196d? | finish no earlier than 2015-06-15 | R4 | 1584h | 1584h | LTE_CA_B3_B40-Core | 33 | KT | Chungwoo HWANG (cwhwang@kt.com) | Rel-13 | 65 | CA | LTE_CA_B3_B40-Core | RP-150536 |
| 1527 | 530.14.2 | Perf. Part:LTE Advanced inter-band Carrier Aggregation of Band 3 and Band 40 | 198d? | 2014-09-15 A | 2015-06-15 A | 100% | 2014-06-13 | 2015-03-13 | 196d? | finish no earlier than 2015-06-15 | R4 | 1584h | 1584h | LTE_CA_B3_B40-Perf | 33 | KT | Chungwoo HWANG (cwhwang@kt.com) | Rel-13 | 65 | CA | LTE_CA_B3_B40-Perf | RP-150536 |
| 1528 | 530.15 | **LTE Advanced inter-band Carrier Aggregation of Band 20 and Band 31** | 198d? | 2014-09-15 A | 2015-06-15 A | 100% | 2014-06-13 | 2015-03-13 | 196d? |  | R4 | 4752h | 4752h | LTE_CA_B20_B31 | 33 | Huawei | Liu Liehai (liuliehai@huawei.com) | Rel-13 | 65 | CA | LTE_CA_B20_B31 |  |
| 1529 | 530.15.1 | Core part:LTE Advanced inter-band Carrier Aggregation of Band 20 and Band 31 | 198d? | 2014-09-15 A | 2015-06-15 A | 100% | 2014-06-13 | 2015-03-13 | 196d? | finish no earlier than 2015-06-15 | R4 | 1584h | 1584h | LTE_CA_B20_B31-Core | 33 | Huawei | Liu Liehai (liuliehai@huawei.com) | Rel-13 | 65 | CA | LTE_CA_B20_B31-Core | RP-150536 |
| 1530 | 530.15.2 | Perf. Part:LTE Advanced inter-band Carrier Aggregation of Band 20 and Band 31 | 198d? | 2014-09-15 A | 2015-06-15 A | 100% | 2014-06-13 | 2015-03-13 | 196d? | finish no earlier than 2015-06-15 | R4 | 1584h | 1584h | LTE_CA_B20_B31-Perf | 33 | Huawei | Liu Liehai (liuliehai@huawei.com) | Rel-13 | 65 | CA | LTE_CA_B20_B31-Perf | RP-150536 |
| 1531 | 530.16 | **LTE Advanced inter-band Carrier Aggregation of Band 3 and Band 31** | 198d? | 2014-09-15 A | 2015-06-15 A | 100% | 2014-06-13 | 2015-03-13 | 196d? |  | R4 | 4752h | 4752h | LTE_CA_B3_B31 | 33 | Huawei | Liu Liehai (liuliehai@huawei.com) | Rel-13 | 65 | CA | LTE_CA_B3_B31 |  |
| 1532 | 530.16.1 | Core part:LTE Advanced inter-band Carrier Aggregation of Band 3 and Band 31 | 198d? | 2014-09-15 A | 2015-06-15 A | 100% | 2014-06-13 | 2015-03-13 | 196d? | finish no earlier than 2015-06-15 | R4 | 1584h | 1584h | LTE_CA_B3_B31-Core | 33 | Huawei | Liu Liehai (liuliehai@huawei.com) | Rel-13 | 65 | CA | LTE_CA_B3_B31-Core | RP-150536 |
| 1533 | 530.16.2 | Perf. Part:LTE Advanced inter-band Carrier Aggregation of Band 3 and Band 31 | 198d? | 2014-09-15 A | 2015-06-15 A | 100% | 2014-06-13 | 2015-03-13 | 196d? | finish no earlier than 2015-06-15 | R4 | 1584h | 1584h | LTE_CA_B3_B31-Perf | 33 | Huawei | Liu Liehai (liuliehai@huawei.com) | Rel-13 | 65 | CA | LTE_CA_B3_B31-Perf | RP-150536 |
| 1534 | 530.17 | **LTE Advanced inter-band Carrier Aggregation of Band 5 and Band 40** | 199d? | 2014-09-12 A | 2015-06-15 A | 100% | 2014-06-13 | 2015-03-13 | 196d? |  | R4 | 4768h | 4768h | LTE_CA_B5_B40 | 33 | SK Telecom | haesung.park@sk.com | Rel-13 | 65 | CA | LTE_CA_B5_B40 |  |
| 1535 | 530.17.1 | Core part:LTE Advanced inter-band Carrier Aggregation of Band 5 and Band 40 | 199d? | 2014-09-12 A | 2015-06-15 A | 100% | 2014-06-13 | 2015-03-13 | 196d? | finish no earlier than 2015-06-15 | R4 | 1592h | 1592h | LTE_CA_B5_B40-Core | 33 | SK Telecom | haesung.park@sk.com | Rel-13 | 65 | CA | LTE_CA_B5_B40-Core | RP-150536 |
| 1536 | 530.17.2 | Perf. Part:LTE Advanced inter-band Carrier Aggregation of Band 5 and Band 40 | 198d? | 2014-09-15 A | 2015-06-15 A | 100% | 2014-06-13 | 2015-03-13 | 196d? | finish no earlier than 2015-06-15 | R4 | 1584h | 1584h | LTE_CA_B5_B40-Perf | 33 | SK Telecom | haesung.park@sk.com | Rel-13 | 65 | CA | LTE_CA_B5_B40-Perf | RP-150536 |
| 1537 | 530.18 | **LTE Advanced intra-band contiguous Carrier Aggregation in Band 42 for 3DL** | 198d? | 2014-09-15 A | 2015-06-15 A | 100% | 2014-06-13 | 2015-03-13 | 196d? |  | R4 | 4752h | 4752h | LTE_CA_C_B42_3DL | 33 | CATT | Yuexia Song (songyuexia@catt.cn) | Rel-13 | 65 | CA | LTE_CA_C_B42_3DL |  |
| 1538 | 530.18.1 | Core part: LTE Advanced intra-band contiguous Carrier Aggregation in Band 42 for 3DL | 198d? | 2014-09-15 A | 2015-06-15 A | 100% | 2014-06-13 | 2015-03-13 | 196d? | finish no earlier than 2015-06-15 | R4 | 1584h | 1584h | LTE_CA_C_B42_3DL-Core | 33 | CATT | Yuexia Song (songyuexia@catt.cn) | Rel-13 | 65 | CA | LTE_CA_C_B42_3DL-Core | RP-150536 |
| 1539 | 530.18.2 | Perf. Part: LTE Advanced intra-band contiguous Carrier Aggregation in Band 42 for 3DL | 198d? | 2014-09-15 A | 2015-06-15 A | 100% | 2014-06-13 | 2015-03-13 | 196d? | finish no earlier than 2015-06-15 | R4 | 1584h | 1584h | LTE_CA_C_B42_3DL-Perf | 33 | CATT | Yuexia Song (songyuexia@catt.cn) | Rel-13 | 65 | CA | LTE_CA_C_B42_3DL-Perf | RP-150536 |
| 1540 | 530.19 | **LTE Advanced 3 Band Carrier Aggregation (3DL/1UL) of Band 8, Band 41 and Band 41** | 199d? | 2014-09-12 A | 2015-06-15 A | 100% | 2014-06-13 | 2015-03-13 | 196d? |  | R4 | 4768h | 4768h | LTE_CA_B8_B41_B41 | 33 | China Mobile | PAN, Qun (panqun@chinamobile.com) | Rel-13 | 65 | CA | LTE_CA_B8_B41_B41 |  |
| 1541 | 530.19.1 | Core part:LTE Advanced 3 Band Carrier Aggregation (3DL/1UL) of Band 8, Band 41 and Band 41 | 198d? | 2014-09-15 A | 2015-06-15 A | 100% | 2014-06-13 | 2015-03-13 | 196d? | finish no earlier than 2015-06-15 | R4 | 1584h | 1584h | LTE_CA_B8_B41_B41-Core | 33 | China Mobile | PAN, Qun (panqun@chinamobile.com) | Rel-13 | 65 | CA | LTE_CA_B8_B41_B41-Core | RP-150536 |
| 1542 | 530.19.2 | Perf. Part:LTE Advanced 3 Band Carrier Aggregation (3DL/1UL) of Band 8, Band 41 and Band 41 | 199d? | 2014-09-12 A | 2015-06-15 A | 100% | 2014-06-13 | 2015-03-13 | 196d? | finish no earlier than 2015-06-15 | R4 | 1592h | 1592h | LTE_CA_B8_B41_B41-Perf | 33 | China Mobile | PAN, Qun (panqun@chinamobile.com) | Rel-13 | 65 | CA | LTE_CA_B8_B41_B41-Perf | RP-150536 |
| 1543 | 530.20 | **LTE Advanced 3 Band Carrier Aggregation (3DL/1UL) of Band 38, Band 40 and Band 40** | 198d? | 2014-09-15 A | 2015-06-15 A | 100% | 2014-06-13 | 2015-03-13 | 196d? |  | R4 | 4752h | 4752h | LTE_CA_B38_B40_B40 | 33 | Samsung | xutao.zhou@samsung.com | Rel-13 | 65 | CA | LTE_CA_B38_B40_B40 |  |
| 1544 | 530.20.1 | Core part:LTE Advanced 3 Band Carrier Aggregation (3DL/1UL) of Band 38, Band 40 and Band 40 | 198d? | 2014-09-15 A | 2015-06-15 A | 100% | 2014-06-13 | 2015-03-13 | 196d? | finish no earlier than 2015-06-15 | R4 | 1584h | 1584h | LTE_CA_B38_B40_B40-Core | 33 | Samsung | xutao.zhou@samsung.com | Rel-13 | 65 | CA | LTE_CA_B38_B40_B40-Core | RP-150536 |
| 1545 | 530.20.2 | Perf. Part:LTE Advanced 3 Band Carrier Aggregation (3DL/1UL) of Band 38, Band 40 and Band 40 | 198d? | 2014-09-15 A | 2015-06-15 A | 100% | 2014-06-13 | 2015-03-13 | 196d? | finish no earlier than 2015-06-15 | R4 | 1584h | 1584h | LTE_CA_B38_B40_B40-Perf | 33 | Samsung | xutao.zhou@samsung.com | Rel-13 | 65 | CA | LTE_CA_B38_B40_B40-Perf | RP-150536 |
| 1546 | 530.21 | **LTE Advanced 3 Band Carrier Aggregation (3DL/1UL) of Band 2, Band 5 and Band 29** | 198d? | 2014-09-15 A | 2015-06-15 A | 100% | 2014-06-13 | 2015-03-13 | 196d? |  | R4 | 4752h | 4752h | LTE_CA_B2_B5_B29 | 33 | Huawei | SHAN Huiping (shanhuiping@huawei.com) | Rel-13 | 65 | CA | LTE_CA_B2_B5_B29 |  |
| 1547 | 530.21.1 | Core part:LTE Advanced 3 Band Carrier Aggregation (3DL/1UL) of Band 2, Band 5 and Band 29 | 198d? | 2014-09-15 A | 2015-06-15 A | 100% | 2014-06-13 | 2015-03-13 | 196d? | finish no earlier than 2015-06-15 | R4 | 1584h | 1584h | LTE_CA_B2_B5_B29-Core | 33 | Huawei | SHAN Huiping (shanhuiping@huawei.com) | Rel-13 | 65 | CA | LTE_CA_B2_B5_B29-Core | RP-150536 |
| 1548 | 530.21.2 | Perf. Part:LTE Advanced 3 Band Carrier Aggregation (3DL/1UL) of Band 2, Band 5 and Band 29 | 198d? | 2014-09-15 A | 2015-06-15 A | 100% | 2014-06-13 | 2015-03-13 | 196d? | finish no earlier than 2015-06-15 | R4 | 1584h | 1584h | LTE_CA_B2_B5_B29-Perf | 33 | Huawei | SHAN Huiping (shanhuiping@huawei.com) | Rel-13 | 65 | CA | LTE_CA_B2_B5_B29-Perf | RP-150536 |

Notes:
- 1525: Inter-band CA 2DL/1UL / Impacted TSs and TRs: LTE
- 1526: CD:Fri 11/12/15->Mon 15/06/15; Compl:0%->70%; Stat Rep: -->RP-141732 1st Apr 15: Compl:70%->80% 1st Apr 15: Stat Rep: RP-141732->RP-150013 03/07/15: Compl:80%->100% 03/07/15: WID: RP-141674->RP-150832 03/07/15: Stat Rep: RP-150013->RP-150536 / Impacted TSs and TRs: 36.101, 36.104, 36.133, New TR 36.8xx
- 1527: CD:Fri 12/06/15->Mon 15/06/15; Compl:0%->70%; Stat Rep: -->RP-141732 1st Apr 15: Compl:70%->80% 1st Apr 15: Stat Rep: RP-141732->RP-150013 03/07/15: Compl:80%->100% 03/07/15: WID: RP-141674->RP-150832 03/07/15: Stat Rep: RP-150013->RP-150536 / Impacted TSs and TRs: 36.141, 36.307
- 1528: Inter-band CA 2DL/1UL / Impacted TSs and TRs: LTE
- 1529: ; WID: RP-142043->RP-142007; Stat Rep: -->RP-141732 1st Apr 15: Compl:75%->99% 1st Apr 15: CD:Sun 15/03/15->Mon 15/06/15 1st Apr 15: Stat Rep: RP-141732->RP-150013 03/07/15: Compl:99%->100% 03/07/15: Stat Rep: RP-150013->RP-150536 / Impacted TSs and TRs: 36.101, 36.104, New TR 36.8xx
- 1530: ; WID: RP-142043->RP-142007; Stat Rep: -->RP-141732 1st Apr 15: Compl:0%->99% 1st Apr 15: CD:Sun 15/03/15->Mon 15/06/15 1st Apr 15: Stat Rep: RP-141732->RP-150013 03/07/15: Compl:99%->100% 03/07/15: Stat Rep: RP-150013->RP-150536 / Impacted TSs and TRs: 36.141, 36.307
- 1531: Inter-band CA 2DL/1UL / Impacted TSs and TRs: LTE
- 1532: CD:Fri 11/12/15->Sun 15/03/15; Compl:0%->50%; Stat Rep: -->RP-141732 1st Apr 15: Compl:50%->75% 1st Apr 15: CD:Sun 15/03/15->Mon 15/06/15 1st Apr 15: WID: RP-141337->RP-150318 1st Apr 15: Stat Rep: RP-141732->RP-150013 03/07/15: Compl:75%->100% 03/07/1 / Impacted TSs and TRs: 36.101, 36.104, New TR 36.8xx
- 1533: CD:Thu 12/03/15->Sun 15/03/15; Compl:0%->0%; Stat Rep: -->RP-141732 1st Apr 15: CD:Sun 15/03/15->Mon 15/06/15 1st Apr 15: WID: RP-141337->RP-150318 1st Apr 15: Stat Rep: RP-141732->RP-150013 03/07/15: Compl:0%->100% 03/07/15: Stat Rep: RP-150013->RP-15 / Impacted TSs and TRs: 36.141, 36.307
- 1534: Inter-band CA 2DL/1UL / Impacted TSs and TRs: LTE
- 1535: ; WID: RP-142043->RP-141888; Stat Rep: -->RP-141732 1st Apr 15: Compl:0%->80% 1st Apr 15: WID: RP-141888->RP-150285 1st Apr 15: Stat Rep: RP-141732->RP-150013 03/07/15: Compl:80%->100% 03/07/15: Stat Rep: RP-150013->RP-150536 / Impacted TSs and TRs: 36.101, 36.104, New TR 36.8xx
- 1536: ; WID: RP-142043->RP-141888; Stat Rep: -->RP-141732 1st Apr 15: Compl:0%->80% 1st Apr 15: WID: RP-141888->RP-150285 1st Apr 15: Stat Rep: RP-141732->RP-150013 03/07/15: Compl:80%->100% 03/07/15: Stat Rep: RP-150013->RP-150536 / Impacted TSs and TRs: 36.141, 36.307
- 1537: Intra-band contig. CA 3DL / Impacted TSs and TRs: LTE
- 1538: CD:Fri 12/06/15->Mon 15/06/15; Compl:0%->70%; Stat Rep: -->RP-141732 1st Apr 15: Compl:70%->99% 1st Apr 15: WID: RP-141677->RP-150319 1st Apr 15: Stat Rep: RP-141732->RP-150013 03/07/15: Compl:99%->100% 03/07/15: WID: RP-150319->RP-151027 03/07/15: Sta / Impacted TSs and TRs: 36.101, 36.104, 36.133, New TR 36.833-5-42
- 1539: CD:Fri 12/06/15->Mon 15/06/15; Compl:0%->0%; Stat Rep: -->RP-141732 1st Apr 15: Compl:0%->99% 1st Apr 15: WID: RP-141677->RP-150319 1st Apr 15: Stat Rep: RP-141732->RP-150013 03/07/15: Compl:99%->100% 03/07/15: WID: RP-150319->RP-151027 03/07/15: Stat / Impacted TSs and TRs: 36.141, 36.307
- 1540: Inter-band CA 3DL/1UL / Impacted TSs and TRs: LTE
- 1541: ; WID: RP-142043->RP-141845; Stat Rep: -->RP-141732 1st Apr 15: Compl:80%->99% 1st Apr 15: CD:Sun 15/03/15->Mon 15/06/15 1st Apr 15: Stat Rep: RP-141732->RP-150013 03/07/15: Compl:99%->100% 03/07/15: Stat Rep: RP-150013->RP-150536 / Impacted TSs and TRs: 36.101, 36.104, 36.133, New TR 36.8xx
- 1542: ; WID: RP-142043->RP-141845; Stat Rep: -->RP-141732 1st Apr 15: Compl:0%->99% 1st Apr 15: CD:Sun 15/03/15->Mon 15/06/15 1st Apr 15: Stat Rep: RP-141732->RP-150013 03/07/15: Compl:99%->100% 03/07/15: Stat Rep: RP-150013->RP-150536 / Impacted TSs and TRs: 36.141, 36.307
- 1543: Inter-band CA 3DL/1UL / Impacted TSs and TRs: LTE
- 1544: CD:Fri 12/06/15->Mon 15/06/15; Compl:0%->0%; Stat Rep: -->RP-141732 1st Apr 15: Compl:0%->70% 1st Apr 15: Stat Rep: RP-141732->RP-150013 03/07/15: Compl:70%->100% 03/07/15: Stat Rep: RP-150013->RP-150536 / Impacted TSs and TRs: 36.101, 36.104, 36.133, New TR 36.8xx
- 1545: CD:Fri 12/06/15->Mon 15/06/15; Compl:0%->0%; Stat Rep: -->RP-141732 1st Apr 15: Compl:0%->70% 1st Apr 15: Stat Rep: RP-141732->RP-150013 03/07/15: Compl:70%->100% 03/07/15: Stat Rep: RP-150013->RP-150536 / Impacted TSs and TRs: 36.141, 36.307
- 1546: Inter-band CA 3DL/1UL / Impacted TSs and TRs: LTE
- 1547: CD:Fri 11/12/15->Mon 15/06/15; Compl:0%->50%; Stat Rep: -->RP-141732 1st Apr 15: Compl:50%->99% 1st Apr 15: Stat Rep: RP-141732->RP-150013 03/07/15: Compl:99%->100% 03/07/15: Stat Rep: RP-150013->RP-150536 / Impacted TSs and TRs: 36.101, 36.104, 36.133, New TR 36.8xy (inter-band CA 2DL/1UL (introduce CA_B5-B29), New TR 36.8xz (inter-band CA 3DL/1UL)
- 1548: CD:Fri 12/06/15->Mon 15/06/15; Compl:0%->0%; Stat Rep: -->RP-141732 1st Apr 15: Compl:0%->99% 1st Apr 15: Stat Rep: RP-141732->RP-150013 03/07/15: Compl:99%->100% 03/07/15: Stat Rep: RP-150013->RP-150536 / Impacted TSs and TRs: 36.141, 36.307

| ID | WBS | Task | Duration | Start | Finish | Complete | Remaining | Total slack | Constraint | Resources | Work | Actual work | Acronym | PCG approved | WI rapporteur name | WI rapporteur e-mail | Release | TSG approved | Status Report |
| --- | --- | --- | --- | --- | --- | --- | --- | --- | --- | --- | --- | --- | --- | --- | --- | --- | --- | --- | --- |
| 1549 | 530.22 | **LTE Carrier Aggregation Enhancement Beyond 5 Carriers** | 981d? | 2014-12-15 A | 2018-09-15 | 65% | 348.05d? | 456d |  |  | 9416h | 6075.2h | LTE_CA_enh_b5C | 34 | Nokia Networks | Nokia | Rel-13 | 66 |  |
| 1550 | 530.22.1 | Core part: LTE Carrier Aggregation Enhancement Beyond 5 Carriers | 262d? | 2014-12-15 A | 2015-12-15 A | 100% |  |  | finish no earlier than 2015-12-15 | R1 | 2096h | 2096h | LTE_CA_enh_b5C-Core | 34 | Nokia Networks | Nokia | Rel-13 | 66 | RP-151285 |
| 1551 | 530.22.2 | Perf. part: LTE Carrier Aggregation Enhancement Beyond 5 Carriers | 393d? | 2014-12-15 A | 2016-06-15 A | 100% |  |  | finish no earlier than 2016-06-15 | R4 | 3144h | 3144h | LTE_CA_enh_b5C-Perf | 34 | Nokia Networks | Nokia | Rel-13 | 66 | RP-151285 |
| 1552 | 530.22.3 | UE Conformance Test Aspects - LTE Carrier Aggregation Enhancement Beyond 5 Carriers: PUCCH on Scell | 522d? | 2016-09-15 A | 2018-09-15 | 20% | 417.6d? | 456d | finish no earlier than 2018-09-15 | R5 | 4176h | 835.2h | LTE_CA_enh_b5C_PUCCH-UEConTest |  | Huawei |  | Rel-13 | 66 |  |
| 1553 | 530.23 | **HSPA Dual-Band UL carrier aggregation** | 327d? | 2014-12-15 A | 2016-03-15 A | 100% |  |  |  | R4 | 7328h | 7328h | HSUPA_DB_MC | 34 | Qualcomm | Qualcomm | Rel-13 | 66 |  |
| 1554 | 530.23.1 | Core part: HSPA Dual-Band UL carrier aggregation | 262d? | 2014-12-15 A | 2015-12-15 A | 100% |  |  | finish no earlier than 2015-12-15 | R4 | 2096h | 2096h | HSUPA_DB_MC-Core | 34 | Qualcomm | Qualcomm | Rel-13 | 66 | RP-151281 |
| 1555 | 530.23.2 | Perf. part: HSPA Dual-Band UL carrier aggregation | 327d? | 2014-12-15 A | 2016-03-15 A | 100% |  |  | finish no earlier than 2016-03-15 | R4 | 2616h | 2616h | HSUPA_DB_MC-Perf | 34 | Qualcomm | Qualcomm | Rel-13 | 66 | RP-151281 |
| 1556 | 530.24 | **LTE Advanced inter-band Carrier Aggregation of Band 25 and Band 26** | 131d? | 2014-12-15 A | 2015-06-15 A | 100% |  |  |  | R4 | 3144h | 3144h | LTE_CA_B25_B26 | 34 | Sprint | Sprint | Rel-13 | 66 |  |
| 1557 | 530.24.1 | Core part:LTE Advanced inter-band Carrier Aggregation of Band 25 and Band 26 | 131d? | 2014-12-15 A | 2015-06-15 A | 100% |  |  | finish no earlier than 2015-06-15 | R4 | 1048h | 1048h | LTE_CA_B25_B26-Core | 34 | Sprint | Sprint | Rel-13 | 66 | RP-150536 |
| 1558 | 530.24.2 | Perf. part:LTE Advanced inter-band Carrier Aggregation of Band 25 and Band 26 | 131d? | 2014-12-15 A | 2015-06-15 A | 100% |  |  | finish no earlier than 2015-06-15 | R4 | 1048h | 1048h | LTE_CA_B25_B26-Perf | 34 | Sprint | Sprint | Rel-13 | 66 | RP-150536 |
| 1559 | 530.25 | **LTE Advanced inter-band Carrier Aggregation of Band 3 and Band 41** | 262d? | 2014-12-15 A | 2015-12-15 A | 100% |  |  |  | R4 | 6288h | 6288h | LTE_CA_B3_B41 | 34 | China Telecom | China Telecom | Rel-13 | 66 |  |
| 1560 | 530.25.1 | Core part:LTE Advanced inter-band Carrier Aggregation of Band 3 and Band 41 | 262d? | 2014-12-15 A | 2015-12-15 A | 100% |  |  | finish no earlier than 2015-12-15 | R4 | 2096h | 2096h | LTE_CA_B3_B41-Core | 34 | China Telecom | China Telecom | Rel-13 | 66 | RP-151131 |
| 1561 | 530.25.2 | Perf. part:LTE Advanced inter-band Carrier Aggregation of Band 3 and Band 41 | 262d? | 2014-12-15 A | 2015-12-15 A | 100% |  |  | finish no earlier than 2015-12-15 | R4 | 2096h | 2096h | LTE_CA_B3_B41-Perf | 34 | China Telecom | China Telecom | Rel-13 | 66 | RP-151131 |
| 1562 | 530.26 | **LTE Advanced 3 band Carrier Aggregation (3DL/1UL) of Band 1, Band 3 and Band 3** | 197d? | 2014-12-15 A | 2015-09-15 A | 100% |  |  |  | R4 | 4728h | 4728h | LTE_CA_B1_B3_B3 | 34 | China Unicom | China Unicom | Rel-13 | 66 |  |
| 1563 | 530.26.1 | Core part:LTE Advanced 3 band Carrier Aggregation (3DL/1UL) of Band 1, Band 3 and Band 3 | 197d? | 2014-12-15 A | 2015-09-15 A | 100% |  |  | finish no earlier than 2015-09-15 | R4 | 1576h | 1576h | LTE_CA_B1_B3_B3-Core | 34 | China Unicom | China Unicom | Rel-13 | 66 | RP-151131 |
| 1564 | 530.26.2 | Perf. part:LTE Advanced 3 band Carrier Aggregation (3DL/1UL) of Band 1, Band 3 and Band 3 | 197d? | 2014-12-15 A | 2015-09-15 A | 100% |  |  | finish no earlier than 2015-09-15 | R4 | 1576h | 1576h | LTE_CA_B1_B3_B3-Perf | 34 | China Unicom | China Unicom | Rel-13 | 66 | RP-151131 |
| 1565 | 530.27 | **LTE Advanced 3 Band Carrier Aggregation (3DL/1UL) of Band 1, Band 19 and Band 28** | 197d? | 2014-12-15 A | 2015-09-15 A | 100% |  |  |  | R4 | 4728h | 4728h | LTE_CA_B1_B19_B28 | 34 | NTT DOCOMO | NTT DOCOMO | Rel-13 | 66 |  |
| 1566 | 530.27.1 | Core part:LTE Advanced 3 Band Carrier Aggregation (3DL/1UL) of Band 1, Band 19 and Band 28 | 197d? | 2014-12-15 A | 2015-09-15 A | 100% |  |  | finish no earlier than 2015-09-15 | R4 | 1576h | 1576h | LTE_CA_B1_B19_B28-Core | 34 | NTT DOCOMO | NTT DOCOMO | Rel-13 | 66 | RP-151131 |
| 1567 | 530.27.2 | Perf. part:LTE Advanced 3 Band Carrier Aggregation (3DL/1UL) of Band 1, Band 19 and Band 28 | 197d? | 2014-12-15 A | 2015-09-15 A | 100% |  |  | finish no earlier than 2015-09-15 | R4 | 1576h | 1576h | LTE_CA_B1_B19_B28-Perf | 34 | NTT DOCOMO | NTT DOCOMO | Rel-13 | 66 | RP-151131 |
| 1568 | 530.28 | **LTE Advanced 3 Band Carrier Aggregation (3DL/1UL) of Band 21, Band 42 and Band 42** | 131d? | 2014-12-15 A | 2015-06-15 A | 100% |  |  |  | R4 | 3144h | 3144h | LTE_CA_B21_B42_B42 | 34 | NTT DOCOMO | NTT DOCOMO | Rel-13 | 66 |  |
| 1569 | 530.28.1 | Core part:LTE Advanced 3 Band Carrier Aggregation (3DL/1UL) of Band 21, Band 42 and Band 42 | 131d? | 2014-12-15 A | 2015-06-15 A | 100% |  |  | finish no earlier than 2015-06-15 | R4 | 1048h | 1048h | LTE_CA_B21_B42_B42-Core | 34 | NTT DOCOMO | NTT DOCOMO | Rel-13 | 66 | RP-150536 |
| 1570 | 530.28.2 | Perf. part:LTE Advanced 3 Band Carrier Aggregation (3DL/1UL) of Band 21, Band 42 and Band 42 | 131d? | 2014-12-15 A | 2015-06-15 A | 100% |  |  | finish no earlier than 2015-06-15 | R4 | 1048h | 1048h | LTE_CA_B21_B42_B42-Perf | 34 | NTT DOCOMO | NTT DOCOMO | Rel-13 | 66 | RP-150536 |
| 1571 | 530.29 | **LTE Advanced 3 Band Carrier Aggregation (3DL/1UL) of Band 7, Band 40 and Band 40** | 197d? | 2014-12-15 A | 2015-09-15 A | 100% |  |  |  | R4 | 4728h | 4728h | LTE_CA_B7_B40_B40 | 34 | ZTE | ZTE | Rel-13 | 66 |  |
| 1572 | 530.29.1 | Core part:LTE Advanced 3 Band Carrier Aggregation (3DL/1UL) of Band 7, Band 40 and Band 40 | 197d? | 2014-12-15 A | 2015-09-15 A | 100% |  |  | finish no earlier than 2015-09-15 | R4 | 1576h | 1576h | LTE_CA_B7_B40_B40-Core | 34 | ZTE | ZTE | Rel-13 | 66 | RP-151131 |
| 1573 | 530.29.2 | Perf. part:LTE Advanced 3 Band Carrier Aggregation (3DL/1UL) of Band 7, Band 40 and Band 40 | 197d? | 2014-12-15 A | 2015-09-15 A | 100% |  |  | finish no earlier than 2015-09-15 | R4 | 1576h | 1576h | LTE_CA_B7_B40_B40-Perf | 34 | ZTE | ZTE | Rel-13 | 66 | RP-151131 |

Notes:
- 1549: FCD: 06/16->12/15, Rel-14?->Rel-13
- 1550: FCD: 06/16->12/15, Rel-14?->Rel-13 1st Apr 15: Compl:0%->10% 1st Apr 15: WID: RP-142286->RP-150277 1st Apr 15: Stat Rep: ->RP-150272 03/07/15: Compl:10%->40% 03/07/15: WID: RP-150277->RP-150771 03/07/15: Stat Rep: RP-150272->RP-150769 29/09/15: Compl:4
- 1551: 1st Apr 15: WID: RP-142286->RP-150277 1st Apr 15: Stat Rep: ->RP-150272 03/07/15: WID: RP-150277->RP-150771 03/07/15: Stat Rep: RP-150272->RP-150769 29/09/15: Stat Rep: RP-150769->RP-151285; 22/3/16: ;
- 1552: ; 20/12/16: Compl:0%->5%19/6/17: Compl:5%->8%; ;...; 19/9/17: Compl:8%->15%; ;...; 8/1/18:...; 27/3/18...
- 1554: 1st Apr 15: Compl:0%->10% 1st Apr 15: WID: RP-142237->RP-150129 1st Apr 15: Stat Rep: ->RP-150127 03/07/15: Compl:10%->40% 03/07/15: Stat Rep: RP-150127->RP-150761 29/09/15: Compl:40%->50% 29/09/15: Stat Rep: RP-150761->RP-151281;
- 1555: 1st Apr 15: WID: RP-142237->RP-150129 1st Apr 15: Stat Rep: ->RP-150127 03/07/15: Stat Rep: RP-150127->RP-150761 29/09/15: Stat Rep: RP-150761->RP-1512811/1/16: Compl:0%->90% ;
- 1557: 1st Apr 15: Compl:0%->95% 1st Apr 15: CD:Tue 15/12/15->Mon 15/06/15 1st Apr 15: WID: RP-142020->RP-150115 1st Apr 15: Stat Rep: ->RP-150013 03/07/15: Compl:95%->100% 03/07/15: Stat Rep: RP-150013->RP-150536
- 1558: 1st Apr 15: Compl:0%->95% 1st Apr 15: CD:Tue 15/12/15->Mon 15/06/15 1st Apr 15: WID: RP-142020->RP-150115 1st Apr 15: Stat Rep: ->RP-150013 03/07/15: Compl:95%->100% 03/07/15: Stat Rep: RP-150013->RP-150536
- 1560: 1st Apr 15: Compl:0%->20% 1st Apr 15: Stat Rep: ->RP-150013 03/07/15: Compl:20%->65% 03/07/15: Stat Rep: RP-150013->RP-150536 29/09/15: CD:Tue 15/09/15->Tue 15/12/15 29/09/15: WID: RP-142239->RP-151446 29/09/15: Stat Rep: RP-150536->RP-151131; 29/09/1
- 1561: 1st Apr 15: Compl:0%->20% 1st Apr 15: Stat Rep: ->RP-150013 03/07/15: Compl:20%->65% 03/07/15: Stat Rep: RP-150013->RP-150536 29/09/15: CD:Tue 15/09/15->Tue 15/12/15 29/09/15: WID: RP-142239->RP-151446 29/09/15: Stat Rep: RP-150536->RP-151131; 29/09/1
- 1563: 1st Apr 15: Compl:0%->50% 1st Apr 15: Stat Rep: ->RP-150013 03/07/15: Compl:50%->90% 03/07/15: CD:Mon 15/06/15->Tue 15/09/15 03/07/15: Stat Rep: RP-150013->RP-150536 29/09/15: Compl:90%->100% 29/09/15: Stat Rep: RP-150536->RP-151131
- 1564: 03/07/15: Compl:0%->90% 03/07/15: CD:Mon 15/06/15->Tue 15/09/15 03/07/15: Stat Rep: ->RP-150536 29/09/15: Compl:90%->100% 29/09/15: Stat Rep: RP-150536->RP-151131
- 1566: 1st Apr 15: Compl:0%->50% 1st Apr 15: Stat Rep: ->RP-150013 03/07/15: Compl:50%->90% 03/07/15: CD:Mon 15/06/15->Tue 15/09/15 03/07/15: WID: RP-141791->RP-150639 03/07/15: Stat Rep: RP-150013->RP-150536 29/09/15: Compl:90%->100% 29/09/15: Stat Rep: RP-
- 1567: 03/07/15: CD:Mon 15/06/15->Tue 15/09/15 03/07/15: WID: RP-141791->RP-150639 03/07/15: Stat Rep: ->RP-150536 29/09/15: Compl:0%->100% 29/09/15: Stat Rep: RP-150536->RP-151131
- 1569: 1st Apr 15: Compl:0%->90% 1st Apr 15: Stat Rep: ->RP-150013 03/07/15: Compl:90%->100% 03/07/15: WID: RP-141792->RP-150640 03/07/15: Stat Rep: RP-150013->RP-150536
- 1570: 03/07/15: Compl:0%->100% 03/07/15: WID: RP-141792->RP-150640 03/07/15: Stat Rep: ->RP-150536
- 1572: 1st Apr 15: Compl:0%->40% 1st Apr 15: Stat Rep: ->RP-150013 03/07/15: Compl:40%->75% 03/07/15: CD:Mon 15/06/15->Tue 15/09/15 03/07/15: WID: RP-141802->RP-150614 03/07/15: Stat Rep: RP-150013->RP-150536 29/09/15: Compl:75%->100% 29/09/15: Stat Rep: RP-
- 1573: 1st Apr 15: Compl:0%->40% 1st Apr 15: Stat Rep: ->RP-150013 03/07/15: Compl:40%->75% 03/07/15: CD:Mon 15/06/15->Tue 15/09/15 03/07/15: WID: RP-141802->RP-150614 03/07/15: Stat Rep: RP-150013->RP-150536 29/09/15: Compl:75%->100% 29/09/15: Stat Rep: RP-

| ID | WBS | Task | Duration | Start | Finish | Complete | Remaining | Total slack | Constraint | Resources | Work | Actual work | Acronym | PCG approved | WI rapporteur name | WI rapporteur e-mail | Release | TSG approved | Status Report |
| --- | --- | --- | --- | --- | --- | --- | --- | --- | --- | --- | --- | --- | --- | --- | --- | --- | --- | --- | --- |
| 1574 | 530.30 | **LTE Advanced 3 band Carrier Aggregation (3DL/1UL) of Band 1, Band 8 and Band 28** | 327d? | 2014-12-15 A | 2016-03-15 | 40% | 196.2d? | 1110d |  | R4 | 7848h | 2723.2h | LTE_CA_B1_B8_B28 | 34 | Softbank Mobile | Softbank Mobile | Rel-13 | 66 |  |
| 1575 | 530.30.1 | Core part:LTE Advanced 3 band Carrier Aggregation (3DL/1UL) of Band 1, Band 8 and Band 28 | 327d? | 2014-12-15 A | 2016-03-15 | 40% | 196.2d? | 1110d | finish no earlier than 2016-03-15 | R4 | 2616h | 1046.4h | LTE_CA_B1_B8_B28-Core | 34 | Softbank Mobile | Softbank Mobile | Rel-13 | 66 | RP-151131 |
| 1576 | 530.30.2 | Perf. part:LTE Advanced 3 band Carrier Aggregation (3DL/1UL) of Band 1, Band 8 and Band 28 | 327d? | 2014-12-15 A | 2016-03-15 | 40% | 196.2d? | 1110d | finish no earlier than 2016-03-15 | R4 | 2616h | 1046.4h | LTE_CA_B1_B8_B28-Perf | 34 | Softbank Mobile | Softbank Mobile | Rel-13 | 66 | RP-151131 |
| 1577 | 530.31 | **LTE Advanced 3 Band Carrier Aggregation (3DL/1UL) of Band 3, Band 7 and Band 7** | 131d? | 2014-12-15 A | 2015-06-15 A | 100% |  |  |  | R4 | 3144h | 3144h | LTE_CA_B3_B7_B7_Bwset | 34 | Ericsson | Ericsson | Rel-13 | 66 |  |
| 1578 | 530.31.1 | Core part: Additional bandwidth combination set for LTE Advanced 3 Band Carrier Aggregation (3DL/1UL) of Band 3, Band 7 and Band 7 | 131d? | 2014-12-15 A | 2015-06-15 A | 100% |  |  | finish no earlier than 2015-06-15 | R4 | 1048h | 1048h | LTE_CA_B3_B7_B7_Bwset-Core | 34 | Ericsson | Ericsson | Rel-13 | 66 | RP-150536 |
| 1579 | 530.31.2 | Perf. Part: Additional bandwidth combination set for LTE Advanced 3 Band Carrier Aggregation (3DL/1UL) of Band 3, Band 7 and Band 7 | 131d? | 2014-12-15 A | 2015-06-15 A | 100% |  |  | finish no earlier than 2015-06-15 | R4 | 1048h | 1048h | LTE_CA_B3_B7_B7_BWset-Perf | 34 | Ericsson | Ericsson | Rel-13 | 66 | RP-150536 |
| 1580 | 530.32 | **LTE Advanced 3 Band Carrier Aggregation (3DL/1UL) of Band 7, Band 7 and Band 28** | 131d? | 2014-12-15 A | 2015-06-15 A | 100% |  |  |  | R4 | 3144h | 3144h | LTE_CA_B7_B7_B28 | 34 | Ericsson | Ericsson | Rel-13 | 66 |  |
| 1581 | 530.32.1 | Core part:LTE Advanced 3 Band Carrier Aggregation (3DL/1UL) of Band 7, Band 7 and Band 28 | 131d? | 2014-12-15 A | 2015-06-15 A | 100% |  |  | finish no earlier than 2015-06-15 | R4 | 1048h | 1048h | LTE_CA_B7_B7_B28-Core | 34 | Ericsson | Ericsson | Rel-13 | 66 | RP-150536 |
| 1582 | 530.32.2 | Perf. part:LTE Advanced 3 Band Carrier Aggregation (3DL/1UL) of Band 7, Band 7 and Band 28 | 131d? | 2014-12-15 A | 2015-06-15 A | 100% |  |  | finish no earlier than 2015-06-15 | R4 | 1048h | 1048h | LTE_CA_B7_B7_B28-Perf | 34 | Ericsson | Ericsson | Rel-13 | 66 | RP-150536 |
| 1583 | 530.33 | **LTE Advanced 3 band Carrier Aggregation (3DL/1UL) of Band 1, Band 3 and Band 40** | 262d? | 2014-12-15 A | 2015-12-15 A | 100% |  |  |  | R4 | 6288h | 6288h | LTE_CA_B1_B3_B40 | 34 | KT | KT | Rel-13 | 66 |  |
| 1584 | 530.33.1 | Core part:LTE Advanced 3 band Carrier Aggregation (3DL/1UL) of Band 1, Band 3 and Band 40 | 262d? | 2014-12-15 A | 2015-12-15 A | 100% |  |  | finish no earlier than 2015-12-15 | R4 | 2096h | 2096h | LTE_CA_B1_B3_B40-Core | 34 | KT | KT | Rel-13 | 66 | RP-151131 |
| 1585 | 530.33.2 | Perf. part:LTE Advanced 3 band Carrier Aggregation (3DL/1UL) of Band 1, Band 3 and Band 40 | 262d? | 2014-12-15 A | 2015-12-15 A | 100% |  |  | finish no earlier than 2015-12-15 | R4 | 2096h | 2096h | LTE_CA_B1_B3_B40-Perf | 34 | KT | KT | Rel-13 | 66 | RP-151131 |
| 1586 | 530.34 | **LTE Advanced 3 band Carrier Aggregation (3DL/1UL) of Band 1, Band 8 and Band 40** | 262d? | 2014-12-15 A | 2015-12-15 A | 100% |  |  |  | R4 | 6288h | 6288h | LTE_CA_B1_B8_B40 | 34 | KT | KT | Rel-13 | 66 |  |
| 1587 | 530.34.1 | Core part:LTE Advanced 3 band Carrier Aggregation (3DL/1UL) of Band 1, Band 8 and Band 40 | 262d? | 2014-12-15 A | 2015-12-15 A | 100% |  |  | finish no earlier than 2015-12-15 | R4 | 2096h | 2096h | LTE_CA_B1_B8_B40-Core | 34 | KT | KT | Rel-13 | 66 | RP-151131 |
| 1588 | 530.34.2 | Perf. part:LTE Advanced 3 band Carrier Aggregation (3DL/1UL) of Band 1, Band 8 and Band 40 | 262d? | 2014-12-15 A | 2015-12-15 A | 100% |  |  | finish no earlier than 2015-12-15 | R4 | 2096h | 2096h | LTE_CA_B1_B8_B40-Perf | 34 | KT | KT | Rel-13 | 66 | RP-151131 |
| 1589 | 530.35 | **LTE Advanced 3 band Carrier Aggregation (3DL/1UL) of Band 3, Band 8 and Band 40** | 262d? | 2014-12-15 A | 2015-12-15 A | 100% |  |  |  | R4 | 6288h | 6288h | LTE_CA_B3_B8_B40 | 34 | KT | KT | Rel-13 | 66 |  |
| 1590 | 530.35.1 | Core part:LTE Advanced 3 band Carrier Aggregation (3DL/1UL) of Band 3, Band 8 and Band 40 | 262d? | 2014-12-15 A | 2015-12-15 A | 100% |  |  | finish no earlier than 2015-12-15 | R4 | 2096h | 2096h | LTE_CA_B3_B8_B40-Core | 34 | KT | KT | Rel-13 | 66 | RP-151131 |
| 1591 | 530.35.2 | Perf. part:LTE Advanced 3 band Carrier Aggregation (3DL/1UL) of Band 3, Band 8 and Band 40 | 262d? | 2014-12-15 A | 2015-12-15 A | 100% |  |  | finish no earlier than 2015-12-15 | R4 | 2096h | 2096h | LTE_CA_B3_B8_B40-Perf | 34 | KT | KT | Rel-13 | 66 | RP-151131 |
| 1592 | 530.36 | **LTE Advanced 3 Band Carrier Aggregation (3DL) of Band 3, Band 7 and Band 8** | 131d? | 2014-12-15 A | 2015-06-15 A | 100% |  |  |  | R4 | 3144h | 3144h | LTE_CA_B3_B7_B8 | 34 | Ericsson | Ericsson | Rel-13 | 66 |  |
| 1593 | 530.36.1 | Core part:LTE Advanced 3 Band Carrier Aggregation (3DL) of Band 3, Band 7 and Band 8 | 131d? | 2014-12-15 A | 2015-06-15 A | 100% |  |  | finish no earlier than 2015-06-15 | R4 | 1048h | 1048h | LTE_CA_B3_B7_B8-Core | 34 | Ericsson | Ericsson | Rel-13 | 66 | RP-150536 |
| 1594 | 530.36.2 | Perf. part:LTE Advanced 3 Band Carrier Aggregation (3DL) of Band 3, Band 7 and Band 8 | 131d? | 2014-12-15 A | 2015-06-15 A | 100% |  |  | finish no earlier than 2015-06-15 | R4 | 1048h | 1048h | LTE_CA_B3_B7_B8-Perf | 34 | Ericsson | Ericsson | Rel-13 | 66 | RP-150536 |
| 1595 | 530.37 | **LTE Advanced 3 Band Carrier Aggregation (3DL/1UL) of Band 1, Band 3 and Band 28** | 131d? | 2014-12-15 A | 2015-06-15 A | 100% |  |  |  | R4 | 3144h | 3144h | LTE_CA_B1_B3_B28 | 34 | Nokia Networks | Nokia Networks | Rel-13 | 66 |  |
| 1596 | 530.37.1 | Core part:LTE Advanced 3 Band Carrier Aggregation (3DL/1UL) of Band 1, Band 3 and Band 28 | 131d? | 2014-12-15 A | 2015-06-15 A | 100% |  |  | finish no earlier than 2015-06-15 | R4 | 1048h | 1048h | LTE_CA_B1_B3_B28-Core | 34 | Nokia Networks | Nokia Networks | Rel-13 | 66 | RP-150536 |
| 1597 | 530.37.2 | Perf. part:LTE Advanced 3 Band Carrier Aggregation (3DL/1UL) of Band 1, Band 3 and Band 28 | 131d? | 2014-12-15 A | 2015-06-15 A | 100% |  |  | finish no earlier than 2015-06-15 | R4 | 1048h | 1048h | LTE_CA_B1_B3_B28-Perf | 34 | Nokia Networks | Nokia Networks | Rel-13 | 66 | RP-150536 |

Notes:
- 1575: 1st Apr 15: Compl:0%->20% 1st Apr 15: WID: RP-141826->RP-150447 1st Apr 15: Stat Rep: ->RP-150013 03/07/15: Compl:20%->40% 03/07/15: Stat Rep: RP-150013->RP-150536 29/09/15: CD:Tue 15/09/15->Tue 15/12/15 29/09/15: Stat Rep: RP-150536->RP-151131
- 1576: 1st Apr 15: Compl:0%->20% 1st Apr 15: WID: RP-141826->RP-150447 1st Apr 15: Stat Rep: ->RP-150013 03/07/15: Compl:20%->40% 03/07/15: Stat Rep: RP-150013->RP-150536 29/09/15: CD:Tue 15/09/15->Tue 15/12/15 29/09/15: Stat Rep: RP-150536->RP-151131
- 1577: Acronym changed from LTE_CA_B3_B7_B7
- 1578: Acronym changed from LTE_CA_B3_B7_B7-Core 1st Apr 15: Compl:0%->99% 1st Apr 15: CD:Sun 15/03/15->Mon 15/06/15 1st Apr 15: Stat Rep: ->RP-150013 03/07/15: Compl:99%->100% 03/07/15: Stat Rep: RP-150013->RP-150536
- 1579: Acronym changed from LTE_CA_B3_B7_B7-Perf 1st Apr 15: Compl:0%->99% 1st Apr 15: CD:Sun 15/03/15->Mon 15/06/15 1st Apr 15: Stat Rep: ->RP-150013 03/07/15: Compl:99%->100% 03/07/15: Stat Rep: RP-150013->RP-150536
- 1581: 1st Apr 15: Compl:0%->99% 1st Apr 15: CD:Sun 15/03/15->Mon 15/06/15 1st Apr 15: Stat Rep: ->RP-150013 03/07/15: Compl:99%->100% 03/07/15: Stat Rep: RP-150013->RP-150536
- 1582: 1st Apr 15: Compl:0%->99% 1st Apr 15: CD:Sun 15/03/15->Mon 15/06/15 1st Apr 15: Stat Rep: ->RP-150013 03/07/15: Compl:99%->100% 03/07/15: Stat Rep: RP-150013->RP-150536
- 1584: 1st Apr 15: Compl:0%->10% 1st Apr 15: Stat Rep: ->RP-150013 03/07/15: Compl:10%->60% 03/07/15: CD:Tue 15/09/15->Tue 15/12/15 03/07/15: Stat Rep: RP-150013->RP-150536 29/09/15: Compl:60%->80% 29/09/15: WID: RP-141946->RP-151258 29/09/15: Stat Rep: RP-1
- 1585: 1st Apr 15: Compl:0%->10% 1st Apr 15: Stat Rep: ->RP-150013 03/07/15: Compl:10%->60% 03/07/15: CD:Tue 15/09/15->Tue 15/12/15 03/07/15: Stat Rep: RP-150013->RP-150536 29/09/15: Compl:60%->80% 29/09/15: WID: RP-141946->RP-151258 29/09/15: Stat Rep: RP-1
- 1587: 1st Apr 15: Compl:0%->10% 1st Apr 15: Stat Rep: ->RP-150013 03/07/15: Compl:10%->60% 03/07/15: CD:Tue 15/09/15->Tue 15/12/15 03/07/15: Stat Rep: RP-150013->RP-150536 29/09/15: Compl:60%->80% 29/09/15: WID: RP-141947->RP-151259 29/09/15: Stat Rep: RP-1
- 1588: 1st Apr 15: Compl:0%->10% 1st Apr 15: Stat Rep: ->RP-150013 03/07/15: Compl:10%->60% 03/07/15: CD:Tue 15/09/15->Tue 15/12/15 03/07/15: Stat Rep: RP-150013->RP-150536 29/09/15: Compl:60%->80% 29/09/15: WID: RP-141947->RP-151259 29/09/15: Stat Rep: RP-1
- 1590: 1st Apr 15: Compl:0%->10% 1st Apr 15: Stat Rep: ->RP-150013 03/07/15: Compl:10%->60% 03/07/15: CD:Tue 15/09/15->Tue 15/12/15 03/07/15: Stat Rep: RP-150013->RP-150536 29/09/15: Compl:60%->95% 29/09/15: WID: RP-141949->RP-151261 29/09/15: Stat Rep: RP-1
- 1591: 1st Apr 15: Compl:0%->10% 1st Apr 15: Stat Rep: ->RP-150013 03/07/15: Compl:10%->60% 03/07/15: CD:Tue 15/09/15->Tue 15/12/15 03/07/15: Stat Rep: RP-150013->RP-150536 29/09/15: Compl:60%->90% 29/09/15: WID: RP-141949->RP-151261 29/09/15: Stat Rep: RP-1
- 1593: 1st Apr 15: Compl:0%->95% 1st Apr 15: Stat Rep: ->RP-150013 03/07/15: Compl:95%->100% 03/07/15: Stat Rep: RP-150013->RP-150536
- 1594: 1st Apr 15: Compl:0%->99% 1st Apr 15: Stat Rep: ->RP-150013 03/07/15: Compl:99%->100% 03/07/15: Stat Rep: RP-150013->RP-150536
- 1596: 1st Apr 15: Compl:0%->99% 1st Apr 15: CD:Sun 15/03/15->Mon 15/06/15 1st Apr 15: Stat Rep: ->RP-150013 03/07/15: Compl:99%->100% 03/07/15: WID: RP-142038->RP-150719 03/07/15: Stat Rep: RP-150013->RP-150536
- 1597: 1st Apr 15: Compl:0%->99% 1st Apr 15: CD:Sun 15/03/15->Mon 15/06/15 1st Apr 15: Stat Rep: ->RP-150013 03/07/15: Compl:99%->100% 03/07/15: WID: RP-142038->RP-150719 03/07/15: Stat Rep: RP-150013->RP-150536

| ID | WBS | Task | Duration | Start | Finish | Complete | Remaining | Total slack | Constraint | Resources | Work | Actual work | Acronym | PCG approved | WI rapporteur name | WI rapporteur e-mail | Release | TSG approved | Status Report |
| --- | --- | --- | --- | --- | --- | --- | --- | --- | --- | --- | --- | --- | --- | --- | --- | --- | --- | --- | --- |
| 1598 | 530.38 | **LTE Advanced 3 band Carrier Aggregation (3DL/1UL) of Band 3, Band 8 and Band 28** | 327d? | 2014-12-15 A | 2016-03-15 | 40% | 196.2d? | 1110d |  | R4 | 7848h | 2332.07h | LTE_CA_B3_B8_B28 | 34 | Softbank Mobile | Softbank Mobile | Rel-13 | 66 |  |
| 1599 | 530.38.1 | Core part:LTE Advanced 3 band Carrier Aggregation (3DL/1UL) of Band 3, Band 8 and Band 28 | 327d? | 2014-12-15 A | 2016-03-15 | 40% | 196.2d? | 1110d | finish no earlier than 2016-03-15 | R4 | 2616h | 1046.4h | LTE_CA_B3_B8_B28-Core | 34 | Softbank Mobile | Softbank Mobile | Rel-13 | 66 | RP-151131 |
| 1600 | 530.38.2 | Perf. part:LTE Advanced 3 band Carrier Aggregation (3DL/1UL) of Band 3, Band 8 and Band 28 | 327d? | 2014-12-15 A | 2016-03-15 | 40% | 196.2d? | 1110d | finish no earlier than 2016-03-15 | R4 | 2616h | 1046.4h | LTE_CA_B3_B8_B28-Perf | 34 | Softbank Mobile | Softbank Mobile | Rel-13 | 66 | RP-151131 |
| 1601 | 530.39 | **LTE Advanced 3 Band Carrier Aggregation (3DL/1UL) of Band 8, Band 42 and Band 42** | 327d? | 2014-12-15 A | 2016-03-15 A | 100% |  |  |  | R4 | 7848h | 7848h | LTE_CA_B8_B42_B42 | 34 | Softbank Mobile | Softbank Mobile | Rel-13 | 66 |  |
| 1602 | 530.39.1 | Core part:LTE Advanced 3 Band Carrier Aggregation (3DL/1UL) of Band 8, Band 42 and Band 42 | 327d? | 2014-12-15 A | 2016-03-15 A | 100% |  |  | finish no earlier than 2016-03-15 | R4 | 2616h | 2616h | LTE_CA_B8_B42_B42-Core | 34 | Softbank Mobile | Softbank Mobile | Rel-13 | 66 | RP-151131 |
| 1603 | 530.39.2 | Perf. part:LTE Advanced 3 Band Carrier Aggregation (3DL/1UL) of Band 8, Band 42 and Band 42 | 327d? | 2014-12-15 A | 2016-03-15 A | 100% |  |  | finish no earlier than 2016-03-15 | R4 | 2616h | 2616h | LTE_CA_B8_B42_B42-Perf | 34 | Softbank Mobile | Softbank Mobile | Rel-13 | 66 | RP-151131 |
| 1604 | 530.40 | **LTE Advanced 3 Band Carrier Aggregation (3DL/1UL) of Band 28, Band 40 and Band 40** | 262d? | 2014-12-15 A | 2015-12-15 A | 100% |  |  |  | R4 | 6288h | 6288h | LTE_CA_B28_B40_B40 | 34 | Huawei | Huawei | Rel-13 | 66 |  |
| 1605 | 530.40.1 | Core part:LTE Advanced 3 Band Carrier Aggregation (3DL/1UL) of Band 28, Band 40 and Band 40 | 262d? | 2014-12-15 A | 2015-12-15 A | 100% |  |  | finish no earlier than 2015-12-15 | R4 | 2096h | 2096h | LTE_CA_B28_B40_B40-Core | 34 | Huawei | Huawei | Rel-13 | 66 | RP-151131 |
| 1606 | 530.40.2 | Perf. part:LTE Advanced 3 Band Carrier Aggregation (3DL/1UL) of Band 28, Band 40 and Band 40 | 262d? | 2014-12-15 A | 2015-12-15 A | 100% |  |  | finish no earlier than 2015-12-15 | R4 | 2096h | 2096h | LTE_CA_B28_B40_B40-Perf | 34 | Huawei | Huawei | Rel-13 | 66 | RP-151131 |
| 1607 | 530.41 | **LTE Advanced 3 Band Carrier Aggregation (3DL/1UL) of Band 3, Band 40 and Band 40** | 131d? | 2014-12-15 A | 2015-06-15 A | 100% |  |  |  | R4 | 3144h | 3144h | LTE_CA_B3_B40_B40 | 34 | Huawei | Huawei | Rel-13 | 66 |  |
| 1608 | 530.41.1 | Core part:LTE Advanced 3 Band Carrier Aggregation (3DL/1UL) of Band 3, Band 40 and Band 40 | 131d? | 2014-12-15 A | 2015-06-15 A | 100% |  |  | finish no earlier than 2015-06-15 | R4 | 1048h | 1048h | LTE_CA_B3_B40_B40-Core | 34 | Huawei | Huawei | Rel-13 | 66 | RP-150536 |
| 1609 | 530.41.2 | Perf. part:LTE Advanced 3 Band Carrier Aggregation (3DL/1UL) of Band 3, Band 40 and Band 40 | 131d? | 2014-12-15 A | 2015-06-15 A | 100% |  |  | finish no earlier than 2015-06-15 | R4 | 1048h | 1048h | LTE_CA_B3_B40_B40-Perf | 34 | Huawei | Huawei | Rel-13 | 66 | RP-150536 |
| 1610 | 530.42 | **LTE Advanced 3 Band Carrier Aggregation (3DL/1UL) of Band 1, Band 7 and Band 28** | 131d? | 2014-12-15 A | 2015-06-15 A | 100% |  |  |  | R4 | 3144h | 3144h | LTE_CA_B1_B7_B28 | 34 | Huawei | Huawei | Rel-13 | 66 |  |
| 1611 | 530.42.1 | Core part:LTE Advanced 3 Band Carrier Aggregation (3DL/1UL) of Band 1, Band 7 and Band 28 | 131d? | 2014-12-15 A | 2015-06-15 A | 100% |  |  | finish no earlier than 2015-06-15 | R4 | 1048h | 1048h | LTE_CA_B1_B7_B28-Core | 34 | Huawei | Huawei | Rel-13 | 66 | RP-150536 |
| 1612 | 530.42.2 | Perf. part:LTE Advanced 3 Band Carrier Aggregation (3DL/1UL) of Band 1, Band 7 and Band 28 | 131d? | 2014-12-15 A | 2015-06-15 A | 100% |  |  | finish no earlier than 2015-06-15 | R4 | 1048h | 1048h | LTE_CA_B1_B7_B28-Perf | 34 | Huawei | Huawei | Rel-13 | 66 | RP-150536 |
| 1613 | 530.43 | **LTE Advanced 3 Band Carrier Aggregation (3DL/1UL) of Band 1, Band 3 and Band 7** | 262d? | 2014-12-15 A | 2015-12-15 A | 100% |  |  |  | R4 | 6288h | 6288h | LTE_CA_B1_B3_B7 | 34 | Huawei | Huawei | Rel-13 | 66 |  |
| 1614 | 530.43.1 | Core part:LTE Advanced 3 Band Carrier Aggregation (3DL/1UL) of Band 1, Band 3 and Band 7 | 262d? | 2014-12-15 A | 2015-12-15 A | 100% |  |  | finish no earlier than 2015-12-15 | R4 | 2096h | 2096h | LTE_CA_B1_B3_B7-Core | 34 | Huawei | Huawei | Rel-13 | 66 | RP-151131 |
| 1615 | 530.43.2 | Perf. part:LTE Advanced 3 Band Carrier Aggregation (3DL/1UL) of Band 1, Band 3 and Band 7 | 262d? | 2014-12-15 A | 2015-12-15 A | 100% |  |  | finish no earlier than 2015-12-15 | R4 | 2096h | 2096h | LTE_CA_B1_B3_B7-Perf | 34 | Huawei | Huawei | Rel-13 | 66 | RP-151131 |
| 1616 | 530.44 | **LTE Advanced 3 Band Carrier Aggregation (3DL/1UL) of Band 3, Band 3 and Band 5** | 131d? | 2014-12-15 A | 2015-06-15 A | 100% |  |  |  | R4 | 3144h | 3144h | LTE_CA_B3_B3_B5 | 34 | Intel | Intel | Rel-13 | 66 |  |
| 1617 | 530.44.1 | Core part:LTE Advanced 3 Band Carrier Aggregation (3DL/1UL) of Band 3, Band 3 and Band 5 | 131d? | 2014-12-15 A | 2015-06-15 A | 100% |  |  | finish no earlier than 2015-09-15 | R4 | 1048h | 1048h | LTE_CA_B3_B3_B5-Core | 34 | Intel | Intel | Rel-13 | 66 | RP-150536 |
| 1618 | 530.44.2 | Perf. part:LTE Advanced 3 Band Carrier Aggregation (3DL/1UL) of Band 3, Band 3 and Band 5 | 131d? | 2014-12-15 A | 2015-06-15 A | 100% |  |  | finish no earlier than 2015-09-15 | R4 | 1048h | 1048h | LTE_CA_B3_B3_B5-Perf | 34 | Intel | Intel | Rel-13 | 66 | RP-150536 |
| 1619 | 530.45 | **LTE Advanced 3 Band Carrier Aggregation (3DL/1UL) of Band 3, Band 7 and Band 28** | 131d? | 2014-12-15 A | 2015-06-15 A | 100% |  |  |  | R4 | 3144h | 3144h | LTE_CA_B3_B7_B28 | 34 | Ericsson | Ericsson | Rel-13 | 66 |  |
| 1620 | 530.45.1 | Core part:LTE Advanced 3 Band Carrier Aggregation (3DL/1UL) of Band 3, Band 7 and Band 28 | 131d? | 2014-12-15 A | 2015-06-15 A | 100% |  |  | finish no earlier than 2015-06-15 | R4 | 1048h | 1048h | LTE_CA_B3_B7_B28-Core | 34 | Ericsson | Ericsson | Rel-13 | 66 | RP-150536 |
| 1621 | 530.45.2 | Perf. part:LTE Advanced 3 Band Carrier Aggregation (3DL/1UL) of Band 3, Band 7 and Band 28 | 131d? | 2014-12-15 A | 2015-06-15 A | 100% |  |  | finish no earlier than 2015-06-15 | R4 | 1048h | 1048h | LTE_CA_B3_B7_B28-Perf | 34 | Ericsson | Ericsson | Rel-13 | 66 | RP-150536 |

Notes:
- 1599: 1st Apr 15: Compl:0%->20% 1st Apr 15: CD:Tue 15/12/15->Tue 15/09/15 1st Apr 15: Stat Rep: ->RP-150013 03/07/15: Compl:20%->40% 03/07/15: Stat Rep: RP-150013->RP-150536 29/09/15: CD:Tue 15/09/15->Tue 15/12/15 29/09/15: Stat Rep: RP-150536->RP-151131;
- 1600: 1st Apr 15: Compl:0%->20% 1st Apr 15: Stat Rep: ->RP-150013 03/07/15: Compl:20%->40% 03/07/15: Stat Rep: RP-150013->RP-150536 29/09/15: CD:Tue 15/09/15->Tue 15/12/15 29/09/15: Stat Rep: RP-150536->RP-151131
- 1602: 1st Apr 15: Compl:0%->20% 1st Apr 15: CD:Tue 15/12/15->Mon 15/06/15 1st Apr 15: Stat Rep: ->RP-150013 03/07/15: Compl:20%->40% 03/07/15: CD:Mon 15/06/15->Tue 15/09/15 03/07/15: Stat Rep: RP-150013->RP-150536 29/09/15: CD:Tue 15/09/15->Tue 15/12/15 29
- 1603: 1st Apr 15: Compl:0%->20% 1st Apr 15: Stat Rep: ->RP-150013 03/07/15: Compl:20%->40% 03/07/15: CD:Mon 15/06/15->Tue 15/09/15 03/07/15: Stat Rep: RP-150013->RP-150536 29/09/15: CD:Tue 15/09/15->Tue 15/12/15 29/09/15: Stat Rep: RP-150536->RP-151131;
- 1605: 1st Apr 15: Compl:0%->30% 1st Apr 15: CD:Tue 15/12/15->Mon 15/06/15 1st Apr 15: WID: RP-142206->RP-150233 1st Apr 15: Stat Rep: ->RP-150013 03/07/15: Compl:30%->60% 03/07/15: CD:Mon 15/06/15->Tue 15/12/15 03/07/15: WID: RP-150233->RP-150676 03/07/15:
- 1606: 1st Apr 15: WID: RP-142206->RP-150233 1st Apr 15: Stat Rep: ->RP-150013 03/07/15: CD:Mon 15/06/15->Tue 15/12/15 03/07/15: WID: RP-150233->RP-150676 03/07/15: Stat Rep: RP-150013->RP-150536 29/09/15: Stat Rep: RP-150536->RP-151131;
- 1608: 1st Apr 15: Compl:0%->50% 1st Apr 15: CD:Tue 15/12/15->Mon 15/06/15 1st Apr 15: Stat Rep: ->RP-150013 03/07/15: Compl:50%->100% 03/07/15: WID: RP-142207->RP-151071 03/07/15: Stat Rep: RP-150013->RP-150536
- 1609: 03/07/15: Compl:0%->100% 03/07/15: WID: RP-142207->RP-151071 03/07/15: Stat Rep: ->RP-150536
- 1611: 1st Apr 15: Compl:0%->50% 1st Apr 15: CD:Tue 15/12/15->Mon 15/06/15 1st Apr 15: WID: RP-142208->RP-150234 1st Apr 15: Stat Rep: ->RP-150013 03/07/15: Compl:50%->100% 03/07/15: Stat Rep: RP-150013->RP-150536
- 1612: 1st Apr 15: WID: RP-142208->RP-150234 1st Apr 15: Stat Rep: ->RP-150013 03/07/15: Compl:0%->100% 03/07/15: Stat Rep: RP-150013->RP-150536
- 1614: 1st Apr 15: Compl:0%->30% 1st Apr 15: CD:Tue 15/12/15->Mon 15/06/15 1st Apr 15: Stat Rep: ->RP-150013 03/07/15: Compl:30%->40% 03/07/15: CD:Mon 15/06/15->Tue 15/09/15 03/07/15: Stat Rep: RP-150013->RP-150536 29/09/15: Compl:40%->50% 29/09/15: CD:Tue 1
- 1615: 03/07/15: CD:Mon 15/06/15->Tue 15/09/15 03/07/15: Stat Rep: ->RP-150536 29/09/15: CD:Tue 15/09/15->Tue 15/12/15 29/09/15: Stat Rep: RP-150536->RP-151131
- 1617: 1st Apr 15: Compl:0%->10% 1st Apr 15: Stat Rep: ->RP-150013 03/07/15: Compl:10%->100% 03/07/15: CD:Tue 15/09/15->Mon 15/06/15 03/07/15: Stat Rep: RP-150013->RP-150536
- 1618: 03/07/15: Compl:0%->100% 03/07/15: CD:Tue 15/09/15->Mon 15/06/15 03/07/15: Stat Rep: ->RP-150536
- 1620: 1st Apr 15: Compl:0%->99% 1st Apr 15: CD:Sun 15/03/15->Mon 15/06/15 1st Apr 15: Stat Rep: ->RP-150013 03/07/15: Compl:99%->100% 03/07/15: Stat Rep: RP-150013->RP-150536
- 1621: 1st Apr 15: Compl:0%->99% 1st Apr 15: CD:Sun 15/03/15->Mon 15/06/15 1st Apr 15: Stat Rep: ->RP-150013 03/07/15: Compl:99%->100% 03/07/15: Stat Rep: RP-150013->RP-150536

| ID | WBS | Task | Duration | Start | Finish | Complete | Constraint | Resources | Work | Actual work | Acronym | PCG approved | WI rapporteur name | WI rapporteur e-mail | Release | TSG approved | Status Report |
| --- | --- | --- | --- | --- | --- | --- | --- | --- | --- | --- | --- | --- | --- | --- | --- | --- | --- |
| 1622 | 530.46 | **LTE Advanced 4 Band Carrier Aggregation (4DL/1UL) of Band 2, Band 2, Band 12 and Band 30** | 262d? | 2014-12-15 A | 2015-12-15 A | 100% |  | R4 | 6288h | 6288h | LTE_CA_B2_B2_B12_B30 | 34 | AT&T | AT&T | Rel-13 | 66 |  |
| 1623 | 530.46.1 | Core part:LTE Advanced 4 Band Carrier Aggregation (4DL/1UL) of Band 2, Band 2, Band 12 and Band 30 | 262d? | 2014-12-15 A | 2015-12-15 A | 100% | finish no earlier than 2015-12-15 | R4 | 2096h | 2096h | LTE_CA_B2_B2_B12_B30-Core | 34 | AT&T | AT&T | Rel-13 | 66 | RP-151131 |
| 1624 | 530.46.2 | Perf. part:LTE Advanced 4 Band Carrier Aggregation (4DL/1UL) of Band 2, Band 2, Band 12 and Band 30 | 262d? | 2014-12-15 A | 2015-12-15 A | 100% | finish no earlier than 2015-12-15 | R4 | 2096h | 2096h | LTE_CA_B2_B2_B12_B30-Perf | 34 | AT&T | AT&T | Rel-13 | 66 | RP-151131 |
| 1625 | 530.47 | **LTE Advanced 4 Band Carrier Aggregation (4DL/1UL) of Band 2, Band 2, Band 5 and Band 30** | 262d? | 2014-12-15 A | 2015-12-15 A | 100% |  | R4 | 6288h | 6288h | LTE_CA_B2_B2_B5_B30 | 34 | AT&T | AT&T | Rel-13 | 66 |  |
| 1626 | 530.47.1 | Core part:LTE Advanced 4 Band Carrier Aggregation (4DL/1UL) of Band 2, Band 2, Band 5 and Band 30 | 262d? | 2014-12-15 A | 2015-12-15 A | 100% | finish no earlier than 2015-12-15 | R4 | 2096h | 2096h | LTE_CA_B2_B2_B5_B30-Core | 34 | AT&T | AT&T | Rel-13 | 66 | RP-151131 |
| 1627 | 530.47.2 | Perf. part:LTE Advanced 4 Band Carrier Aggregation (4DL/1UL) of Band 2, Band 2, Band 5 and Band 30 | 262d? | 2014-12-15 A | 2015-12-15 A | 100% | finish no earlier than 2015-12-15 | R4 | 2096h | 2096h | LTE_CA_B2_B2_B5_B30-Perf | 34 | AT&T | AT&T | Rel-13 | 66 | RP-151131 |
| 1628 | 530.48 | **LTE Advanced 4 Band Carrier Aggregation (4DL/1UL) of Band 2, Band 2 Band 29 and Band 30** | 262d? | 2014-12-15 A | 2015-12-15 A | 100% |  | R4 | 6288h | 6288h | LTE_CA_B2_B2_B29_B30 | 34 | AT&T | AT&T | Rel-13 | 66 |  |
| 1629 | 530.48.1 | Core part:LTE Advanced 4 Band Carrier Aggregation (4DL/1UL) of Band 2, Band 2 Band 29 and Band 30 | 262d? | 2014-12-15 A | 2015-12-15 A | 100% | finish no earlier than 2015-12-15 | R4 | 2096h | 2096h | LTE_CA_B2_B2_B29_B30-Core | 34 | AT&T | AT&T | Rel-13 | 66 | RP-151131 |
| 1630 | 530.48.2 | Perf. part:LTE Advanced 4 Band Carrier Aggregation (4DL/1UL) of Band 2, Band 2 Band 29 and Band 30 | 262d? | 2014-12-15 A | 2015-12-15 A | 100% | finish no earlier than 2015-12-15 | R4 | 2096h | 2096h | LTE_CA_B2_B2_B29_B30-Perf | 34 | AT&T | AT&T | Rel-13 | 66 | RP-151131 |
| 1631 | 530.49 | **LTE Advanced 4 Band Carrier Aggregation (4DL/1UL) of Band 2, Band 4, Band 12 and Band 30** | 262d? | 2014-12-15 A | 2015-12-15 A | 100% |  | R4 | 6288h | 6288h | LTE_CA_B2_B4_B12_B30 | 34 | AT&T | AT&T | Rel-13 | 66 |  |
| 1632 | 530.49.1 | Core part:LTE Advanced 4 Band Carrier Aggregation (4DL/1UL) of Band 2, Band 4, Band 12 and Band 30 | 262d? | 2014-12-15 A | 2015-12-15 A | 100% | finish no earlier than 2015-12-15 | R4 | 2096h | 2096h | LTE_CA_B2_B4_B12_B30-Core | 34 | AT&T | AT&T | Rel-13 | 66 | RP-151131 |
| 1633 | 530.49.2 | Perf. part:LTE Advanced 4 Band Carrier Aggregation (4DL/1UL) of Band 2, Band 4, Band 12 and Band 30 | 262d? | 2014-12-15 A | 2015-12-15 A | 100% | finish no earlier than 2015-12-15 | R4 | 2096h | 2096h | LTE_CA_B2_B4_B12_B30-Perf | 34 | AT&T | AT&T | Rel-13 | 66 | RP-151131 |
| 1634 | 530.50 | **LTE Advanced 4 Band Carrier Aggregation (4DL/1UL) of Band 2, Band 4, Band 5 and Band 30** | 262d? | 2014-12-15 A | 2015-12-15 A | 100% |  | R4 | 6288h | 6288h | LTE_CA_B2_B4_B5_B30 | 34 | AT&T | AT&T | Rel-13 | 66 |  |
| 1635 | 530.50.1 | Core part:LTE Advanced 4 Band Carrier Aggregation (4DL/1UL) of Band 2, Band 4, Band 5 and Band 30 | 262d? | 2014-12-15 A | 2015-12-15 A | 100% | finish no earlier than 2015-12-15 | R4 | 2096h | 2096h | LTE_CA_B2_B4_B5_B30-Core | 34 | AT&T | AT&T | Rel-13 | 66 | RP-151131 |
| 1636 | 530.50.2 | Perf. part:LTE Advanced 4 Band Carrier Aggregation (4DL/1UL) of Band 2, Band 4, Band 5 and Band 30 | 262d? | 2014-12-15 A | 2015-12-15 A | 100% | finish no earlier than 2015-12-15 | R4 | 2096h | 2096h | LTE_CA_B2_B4_B5_B30-Perf | 34 | AT&T | AT&T | Rel-13 | 66 | RP-151131 |
| 1637 | 530.51 | **LTE Advanced 4 Band Carrier Aggregation (4DL/1UL) of Band 2, Band 4, Band 29 and Band 30** | 262d? | 2014-12-15 A | 2015-12-15 A | 100% |  | R4 | 6288h | 6288h | LTE_CA_B2_B4_B29_B30 | 34 | AT&T | AT&T | Rel-13 | 66 |  |
| 1638 | 530.51.1 | Core part:LTE Advanced 4 Band Carrier Aggregation (4DL/1UL) of Band 2, Band 4, Band 29 and Band 30 | 262d? | 2014-12-15 A | 2015-12-15 A | 100% | finish no earlier than 2015-12-15 | R4 | 2096h | 2096h | LTE_CA_B2_B4_B29_B30-Core | 34 | AT&T | AT&T | Rel-13 | 66 | RP-151131 |
| 1639 | 530.51.2 | Perf. part:LTE Advanced 4 Band Carrier Aggregation (4DL/1UL) of Band 2, Band 4, Band 29 and Band 30 | 262d? | 2014-12-15 A | 2015-12-15 A | 100% | finish no earlier than 2015-12-15 | R4 | 2096h | 2096h | LTE_CA_B2_B4_B29_B30-Perf | 34 | AT&T | AT&T | Rel-13 | 66 | RP-151131 |
| 1640 | 530.52 | **LTE Advanced 4 Band Carrier Aggregation (4DL/1UL) of Band 25, Band 41, Band 41 and Band 41** | 262d? | 2014-12-15 A | 2015-12-15 A | 100% |  | R4 | 6288h | 6288h | LTE_CA_B25_B41_B41_B41 | 34 | Alcatel-Lucent | Alcatel-Lucent | Rel-13 | 66 |  |
| 1641 | 530.52.1 | Core part:LTE Advanced 4 Band Carrier Aggregation (4DL/1UL) of Band 25, Band 41, Band 41 and Band 41 | 262d? | 2014-12-15 A | 2015-12-15 A | 100% | finish no earlier than 2015-12-15 | R4 | 2096h | 2096h | LTE_CA_B25_B41_B41_B41-Core | 34 | Alcatel-Lucent | Alcatel-Lucent | Rel-13 | 66 | RP-151131 |
| 1642 | 530.52.2 | Perf. part:LTE Advanced 4 Band Carrier Aggregation (4DL/1UL) of Band 25, Band 41, Band 41 and Band 41 | 262d? | 2014-12-15 A | 2015-12-15 A | 100% | finish no earlier than 2015-12-15 | R4 | 2096h | 2096h | LTE_CA_B25_B41_B41_B41-Perf | 34 | Alcatel-Lucent | Alcatel-Lucent | Rel-13 | 66 | RP-151131 |
| 1643 | 530.53 | **LTE Advanced dual uplink inter-band Carrier Aggregation Class A1 in REL-13** | 262d? | 2014-12-15 A | 2015-12-15 A | 100% |  | R4 | 6288h | 6288h | LTE_CA_2UL_R13-A1 | 34 | Huawei | Huawei | Rel-13 | 66 |  |
| 1644 | 530.53.1 | Core part:LTE Advanced dual uplink inter-band Carrier Aggregation Class A1 in REL-13 | 262d? | 2014-12-15 A | 2015-12-15 A | 100% | finish no earlier than 2015-12-15 | R4 | 2096h | 2096h | LTE_CA_2UL_R13-A1-Core | 34 | Huawei | Huawei | Rel-13 | 66 | RP-151131 |
| 1645 | 530.53.2 | Perf. part:LTE Advanced dual uplink inter-band Carrier Aggregation Class A1 in REL-13 | 262d? | 2014-12-15 A | 2015-12-15 A | 100% | finish no earlier than 2015-12-15 | R4 | 2096h | 2096h | LTE_CA_2UL_R13-A1-Perf | 34 | Huawei | Huawei | Rel-13 | 66 | RP-151131 |

Notes:
- 1623: 1st Apr 15: Compl:0%->50% 1st Apr 15: WID: RP-142198->RP-150449 1st Apr 15: Stat Rep: ->RP-150013 03/07/15: Compl:50%->95% 03/07/15: Stat Rep: RP-150013->RP-150536 29/09/15: Stat Rep: RP-150536->RP-151131
- 1624: 1st Apr 15: Compl:0%->50% 1st Apr 15: WID: RP-142198->RP-150449 1st Apr 15: Stat Rep: ->RP-150013 03/07/15: Compl:50%->95% 03/07/15: Stat Rep: RP-150013->RP-150536 29/09/15: Stat Rep: RP-150536->RP-151131
- 1626: 1st Apr 15: Compl:0%->50% 1st Apr 15: CD:Tue 15/12/15->Tue 15/09/15 1st Apr 15: WID: RP-142199->RP-150448 1st Apr 15: Stat Rep: ->RP-150013 03/07/15: Compl:50%->95% 03/07/15: CD:Tue 15/09/15->Tue 15/12/15 03/07/15: Stat Rep: RP-150013->RP-150536 29/09
- 1627: 1st Apr 15: Compl:0%->50% 1st Apr 15: WID: RP-142199->RP-150448 1st Apr 15: Stat Rep: ->RP-150013 03/07/15: Compl:50%->95% 03/07/15: Stat Rep: RP-150013->RP-150536 29/09/15: Stat Rep: RP-150536->RP-151131
- 1629: 1st Apr 15: Compl:0%->50% 1st Apr 15: WID: RP-142200->RP-150450 1st Apr 15: Stat Rep: ->RP-150013 03/07/15: Compl:50%->95% 03/07/15: Stat Rep: RP-150013->RP-150536 29/09/15: Stat Rep: RP-150536->RP-151131
- 1630: 1st Apr 15: Compl:0%->50% 1st Apr 15: WID: RP-142200->RP-150450 1st Apr 15: Stat Rep: ->RP-150013 03/07/15: Compl:50%->95% 03/07/15: Stat Rep: RP-150013->RP-150536 29/09/15: Stat Rep: RP-150536->RP-151131
- 1632: 1st Apr 15: Compl:0%->50% 1st Apr 15: WID: RP-142201->RP-150452 1st Apr 15: Stat Rep: ->RP-150013 03/07/15: Compl:50%->95% 03/07/15: Stat Rep: RP-150013->RP-150536 29/09/15: Stat Rep: RP-150536->RP-151131
- 1633: 1st Apr 15: Compl:0%->50% 1st Apr 15: WID: RP-142201->RP-150452 1st Apr 15: Stat Rep: ->RP-150013 03/07/15: Compl:50%->95% 03/07/15: Stat Rep: RP-150013->RP-150536 29/09/15: Stat Rep: RP-150536->RP-151131
- 1635: 1st Apr 15: Compl:0%->50% 1st Apr 15: WID: RP-142202->RP-150451 1st Apr 15: Stat Rep: ->RP-150013 03/07/15: Compl:50%->95% 03/07/15: Stat Rep: RP-150013->RP-150536 29/09/15: Stat Rep: RP-150536->RP-151131
- 1636: 1st Apr 15: Compl:0%->50% 1st Apr 15: WID: RP-142202->RP-150451 1st Apr 15: Stat Rep: ->RP-150013 03/07/15: Compl:50%->95% 03/07/15: Stat Rep: RP-150013->RP-150536 29/09/15: Stat Rep: RP-150536->RP-151131
- 1638: 1st Apr 15: Compl:0%->50% 1st Apr 15: WID: RP-142203->RP-150453 1st Apr 15: Stat Rep: ->RP-150013 03/07/15: Compl:50%->95% 03/07/15: Stat Rep: RP-150013->RP-150536 29/09/15: Stat Rep: RP-150536->RP-151131
- 1639: 1st Apr 15: Compl:0%->50% 1st Apr 15: WID: RP-142203->RP-150453 1st Apr 15: Stat Rep: ->RP-150013 03/07/15: Compl:50%->95% 03/07/15: Stat Rep: RP-150013->RP-150536 29/09/15: Stat Rep: RP-150536->RP-151131
- 1641: 1st Apr 15: Compl:0%->50% 1st Apr 15: Stat Rep: ->RP-150013 03/07/15: Compl:50%->90% 03/07/15: Stat Rep: RP-150013->RP-150536 29/09/15: Compl:90%->95% 29/09/15: CD:Tue 15/09/15->Tue 15/12/15 29/09/15: Stat Rep: RP-150536->RP-151131
- 1642: 1st Apr 15: Compl:0%->25% 1st Apr 15: Stat Rep: ->RP-150013 03/07/15: Compl:25%->75% 03/07/15: Stat Rep: RP-150013->RP-150536 29/09/15: Compl:75%->80% 29/09/15: Stat Rep: RP-150536->RP-151131
- 1644: 1st Apr 15: Compl:0%->40% 1st Apr 15: WID: RP-141935->RP-150411 1st Apr 15: Stat Rep: ->RP-150013 03/07/15: Compl:40%->60% 03/07/15: WID: RP-150411->RP-150678 03/07/15: Stat Rep: RP-150013->RP-150536 29/09/15: Compl:60%->80% 29/09/15: Stat Rep: RP-150
- 1645: 1st Apr 15: Compl:0%->40% 1st Apr 15: WID: RP-141935->RP-150411 1st Apr 15: Stat Rep: ->RP-150013 03/07/15: Compl:40%->60% 03/07/15: WID: RP-150411->RP-150678 03/07/15: Stat Rep: RP-150013->RP-150536 29/09/15: Compl:60%->80% 29/09/15: Stat Rep: RP-150

| ID | WBS | Task | Duration | Start | Finish | Complete | Baseline start | Baseline finish | Baseline duration | Constraint | Resources | Work | Actual work | Acronym | PCG approved | WI rapporteur name | WI rapporteur e-mail | Release | TSG approved | Status Report | Acronym_3GU_Export |
| --- | --- | --- | --- | --- | --- | --- | --- | --- | --- | --- | --- | --- | --- | --- | --- | --- | --- | --- | --- | --- | --- |
| 1646 | 530.54 | **LTE Advanced dual uplink inter-band Carrier Aggregation Class A2 in REL-13** | 262d? | 2014-12-15 A | 2015-12-15 A | 100% |  |  |  |  | R4 | 6288h | 6288h | LTE_CA_2UL_R13-A2 | 34 | Qualcomm | Qualcomm | Rel-13 | 66 |  |  |
| 1647 | 530.54.1 | Core part:LTE Advanced dual uplink inter-band Carrier Aggregation Class A2 in REL-13 | 262d? | 2014-12-15 A | 2015-12-15 A | 100% |  |  |  | finish no earlier than 2015-12-15 | R4 | 2096h | 2096h | LTE_CA_2UL_R13-A2-Core | 34 | Qualcomm | Qualcomm | Rel-13 | 66 | RP-151131 |  |
| 1648 | 530.54.2 | Perf. part:LTE Advanced dual uplink inter-band Carrier Aggregation Class A2 in REL-13 | 262d? | 2014-12-15 A | 2015-12-15 A | 100% |  |  |  | finish no earlier than 2015-12-15 | R4 | 2096h | 2096h | LTE_CA_2UL_R13-A2-Perf | 34 | Qualcomm | Qualcomm | Rel-13 | 66 | RP-151131 |  |
| 1649 | 530.55 | **LTE Advanced dual uplink inter-band Carrier Aggregation Class A3 in REL-13** | 262d? | 2014-12-15 A | 2015-12-15 A | 100% |  |  |  |  | R4 | 6288h | 6288h | LTE_CA_2UL_R13-A3 | 34 | Ericsson | Ericsson | Rel-13 | 66 |  |  |
| 1650 | 530.55.1 | Core part:LTE Advanced dual uplink inter-band Carrier Aggregation Class A3 in REL-13 | 262d? | 2014-12-15 A | 2015-12-15 A | 100% |  |  |  | finish no earlier than 2015-12-15 | R4 | 2096h | 2096h | LTE_CA_2UL_R13-A3-Core | 34 | Ericsson | Ericsson | Rel-13 | 66 | RP-151131 |  |
| 1651 | 530.55.2 | Perf. part:LTE Advanced dual uplink inter-band Carrier Aggregation Class A3 in REL-13 | 262d? | 2014-12-15 A | 2015-12-15 A | 100% |  |  |  | finish no earlier than 2015-12-15 | R4 | 2096h | 2096h | LTE_CA_2UL_R13-A3-Perf | 34 | Ericsson | Ericsson | Rel-13 | 66 | RP-151131 |  |
| 1652 | 530.56 | **LTE Advanced intra-band non-contiguous Carrier Aggregation in Band 41 for 4 DL** | 262d? | 2014-12-15 A | 2015-12-15 A | 100% |  |  |  |  | R4 | 6288h | 6288h | LTE_CA_NC_B41_4DL | 34 | Alcatel-Lucent | Alcatel-Lucent | Rel-13 | 66 |  |  |
| 1653 | 530.56.1 | Core part:LTE Advanced intra-band non-contiguous Carrier Aggregation in Band 41 for 4 DL | 262d? | 2014-12-15 A | 2015-12-15 A | 100% |  |  |  | finish no earlier than 2015-12-15 | R4 | 2096h | 2096h | LTE_CA_NC_B41_4DL-Core | 34 | Alcatel-Lucent | Alcatel-Lucent | Rel-13 | 66 | RP-151131 |  |
| 1654 | 530.56.2 | Perf. part:LTE Advanced intra-band non-contiguous Carrier Aggregation in Band 41 for 4 DL | 262d? | 2014-12-15 A | 2015-12-15 A | 100% | 2013-09-18 | 2015-12-24 | 593d? | finish no earlier than 2015-12-15 | R4 | 2096h | 2096h | LTE_CA_NC_B41_4DL-Perf | 31 | Alcatel-Lucent | Alcatel-Lucent | Rel-13 | 66 | RP-151131 | TEI13 |
| 1655 | 530.57 | **LTE Advanced 3 Band Carrier Aggregation (3DL/1UL) of Band 1, Band 3 and Band 42** | 66d? | 2015-03-16 A | 2015-06-15 A | 100% |  |  |  |  | R4 | 1584h | 1584h | LTE_CA_B1_B3_B42 | 34 | NTT DOCOMO, INC. |  | Rel-13 | 67 |  |  |
| 1656 | 530.57.1 | Core part:LTE Advanced 3 Band Carrier Aggregation (3DL/1UL) of Band 1, Band 3 and Band 42 | 66d? | 2015-03-16 A | 2015-06-15 A | 100% |  |  |  | finish no earlier than 2015-09-15 | R4 | 528h | 528h | LTE_CA_B1_B3_B42-Core | 34 | NTT DOCOMO, INC. |  | Rel-13 | 67 | RP-150536 |  |
| 1657 | 530.57.2 | Perf. part:LTE Advanced 3 Band Carrier Aggregation (3DL/1UL) of Band 1, Band 3 and Band 42 | 66d? | 2015-03-16 A | 2015-06-15 A | 100% |  |  |  | finish no earlier than 2015-09-15 | R4 | 528h | 528h | LTE_CA_B1_B3_B42-Perf | 34 | NTT DOCOMO, INC. |  | Rel-13 | 67 | RP-150536 |  |
| 1658 | 530.58 | **LTE Advanced 3 Band Carrier Aggregation (3DL/1UL) of Band 1, Band 19 and Band 42** | 66d? | 2015-03-16 A | 2015-06-15 A | 100% |  |  |  |  | R4 | 1584h | 1584h | LTE_CA_B1_B19_B42 | 34 | NTT DOCOMO, INC. |  | Rel-13 | 67 |  |  |
| 1659 | 530.58.1 | Core part:LTE Advanced 3 Band Carrier Aggregation (3DL/1UL) of Band 1, Band 19 and Band 42 | 66d? | 2015-03-16 A | 2015-06-15 A | 100% |  |  |  | finish no earlier than 2015-09-15 | R4 | 528h | 528h | LTE_CA_B1_B19_B42-Core | 34 | NTT DOCOMO, INC. |  | Rel-13 | 67 | RP-150536 |  |
| 1660 | 530.58.2 | Perf. part:LTE Advanced 3 Band Carrier Aggregation (3DL/1UL) of Band 1, Band 19 and Band 42 | 66d? | 2015-03-16 A | 2015-06-15 A | 100% |  |  |  | finish no earlier than 2015-09-15 | R4 | 528h | 528h | LTE_CA_B1_B19_B42-Perf | 34 | NTT DOCOMO, INC. |  | Rel-13 | 67 | RP-150536 |  |
| 1661 | 530.59 | **LTE Advanced 3 Band Carrier Aggregation (3DL/1UL) of Band 1, Band 21 and Band 42** | 66d? | 2015-03-16 A | 2015-06-15 A | 100% |  |  |  |  | R4 | 1584h | 1584h | LTE_CA_B1_B21_B42 | 34 | NTT DOCOMO, INC. |  | Rel-13 | 67 |  |  |
| 1662 | 530.59.1 | Core part:LTE Advanced 3 Band Carrier Aggregation (3DL/1UL) of Band 1, Band 21 and Band 42 | 66d? | 2015-03-16 A | 2015-06-15 A | 100% |  |  |  | finish no earlier than 2015-09-15 | R4 | 528h | 528h | LTE_CA_B1_B21_B42-Core | 34 | NTT DOCOMO, INC. |  | Rel-13 | 67 | RP-150536 |  |
| 1663 | 530.59.2 | Perf. part:LTE Advanced 3 Band Carrier Aggregation (3DL/1UL) of Band 1, Band 21 and Band 42 | 66d? | 2015-03-16 A | 2015-06-15 A | 100% |  |  |  | finish no earlier than 2015-09-15 | R4 | 528h | 528h | LTE_CA_B1_B21_B42-Perf | 34 | NTT DOCOMO, INC. |  | Rel-13 | 67 | RP-150536 |  |
| 1664 | 530.60 | **LTE Advanced 3 Band Carrier Aggregation (3DL/1UL) of Band 3, Band 19 and Band 42** | 66d? | 2015-03-16 A | 2015-06-15 A | 100% |  |  |  |  | R4 | 1584h | 1584h | LTE_CA_B3_B19_B42 | 34 | NTT DOCOMO, INC. |  | Rel-13 | 67 |  |  |
| 1665 | 530.60.1 | Core part:LTE Advanced 3 Band Carrier Aggregation (3DL/1UL) of Band 3, Band 19 and Band 42 | 66d? | 2015-03-16 A | 2015-06-15 A | 100% |  |  |  | finish no earlier than 2015-09-15 | R4 | 528h | 528h | LTE_CA_B3_B19_B42-Core | 34 | NTT DOCOMO, INC. |  | Rel-13 | 67 | RP-150536 |  |
| 1666 | 530.60.2 | Perf. part:LTE Advanced 3 Band Carrier Aggregation (3DL/1UL) of Band 3, Band 19 and Band 42 | 66d? | 2015-03-16 A | 2015-06-15 A | 100% |  |  |  | finish no earlier than 2015-09-15 | R4 | 528h | 528h | LTE_CA_B3_B19_B42-Perf | 34 | NTT DOCOMO, INC. |  | Rel-13 | 67 | RP-150536 |  |
| 1667 | 530.61 | **LTE Advanced 3 Band Carrier Aggregation (3DL/1UL) of Band 19, Band 21 and Band 42** | 66d? | 2015-03-16 A | 2015-06-15 A | 100% |  |  |  |  | R4 | 1584h | 1584h | LTE_CA_B19_B21_B42 | 34 | NTT DOCOMO, INC. |  | Rel-13 | 67 |  |  |
| 1668 | 530.61.1 | Core part:LTE Advanced 3 Band Carrier Aggregation (3DL/1UL) of Band 19, Band 21 and Band 42 | 66d? | 2015-03-16 A | 2015-06-15 A | 100% |  |  |  | finish no earlier than 2015-09-15 | R4 | 528h | 528h | LTE_CA_B19_B21_B42-Core | 34 | NTT DOCOMO, INC. |  | Rel-13 | 67 | RP-150536 |  |
| 1669 | 530.61.2 | Perf. part:LTE Advanced 3 Band Carrier Aggregation (3DL/1UL) of Band 19, Band 21 and Band 42 | 66d? | 2015-03-16 A | 2015-06-15 A | 100% |  |  |  | finish no earlier than 2015-09-15 | R4 | 528h | 528h | LTE_CA_B19_B21_B42-Perf | 34 | NTT DOCOMO, INC. |  | Rel-13 | 67 | RP-150536 |  |

Notes:
- 1647: 1st Apr 15: Compl:0%->50% 1st Apr 15: WID: RP-141975->RP-150408 1st Apr 15: Stat Rep: ->RP-150013 03/07/15: Stat Rep: RP-150013->RP-150536 29/09/15: Stat Rep: RP-150536->RP-151131
- 1648: 1st Apr 15: Compl:0%->50% 1st Apr 15: WID: RP-141975->RP-150408 1st Apr 15: Stat Rep: ->RP-150013 03/07/15: Stat Rep: RP-150013->RP-150536 29/09/15: Stat Rep: RP-150536->RP-151131
- 1650: 1st Apr 15: Compl:0%->25% 1st Apr 15: WID: RP-142010->RP-150409 1st Apr 15: Stat Rep: ->RP-150013 03/07/15: Compl:25%->50% 03/07/15: Stat Rep: RP-150013->RP-150536 29/09/15: Compl:50%->75% 29/09/15: Stat Rep: RP-150536->RP-151131;
- 1651: 1st Apr 15: Compl:0%->25% 1st Apr 15: WID: RP-142010->RP-150409 1st Apr 15: Stat Rep: ->RP-150013 03/07/15: Compl:25%->50% 03/07/15: Stat Rep: RP-150013->RP-150536 29/09/15: Compl:50%->75% 29/09/15: Stat Rep: RP-150536->RP-151131;
- 1653: 1st Apr 15: Compl:0%->10% 1st Apr 15: CD:Tue 15/03/16->Tue 15/12/15 1st Apr 15: Stat Rep: ->RP-150013 03/07/15: Compl:10%->50% 03/07/15: Stat Rep: RP-150013->RP-150536 29/09/15: Compl:50%->80% 29/09/15: Stat Rep: RP-150536->RP-151131
- 1654: 1st Apr 15: Compl:0%->10% 1st Apr 15: CD:Tue 18/12/18->Tue 15/12/15 1st Apr 15: Stat Rep: -->RP-150013 03/07/15: Compl:10%->25% 03/07/15: Stat Rep: RP-150013->RP-150536 29/09/15: Compl:25%->50% 29/09/15: Stat Rep: RP-150536->RP-151131 ;
- 1656: 03/07/15: Compl:0%->100% 03/07/15: CD:Tue 15/09/15->Mon 15/06/15 03/07/15: WID: RP-150121->RP-150641 03/07/15: Stat Rep: ->RP-150536
- 1657: 03/07/15: Compl:0%->100% 03/07/15: CD:Tue 15/09/15->Mon 15/06/15 03/07/15: WID: RP-150121->RP-150641 03/07/15: Stat Rep: ->RP-150536
- 1659: 03/07/15: Compl:0%->100% 03/07/15: CD:Tue 15/09/15->Mon 15/06/15 03/07/15: WID: RP-150122->RP-150642 03/07/15: Stat Rep: ->RP-150536
- 1660: 03/07/15: Compl:0%->100% 03/07/15: CD:Tue 15/09/15->Mon 15/06/15 03/07/15: WID: RP-150122->RP-150642 03/07/15: Stat Rep: ->RP-150536
- 1662: 03/07/15: Compl:0%->100% 03/07/15: CD:Tue 15/09/15->Mon 15/06/15 03/07/15: WID: RP-150123->RP-150643 03/07/15: Stat Rep: ->RP-150536
- 1663: 03/07/15: Compl:0%->100% 03/07/15: CD:Tue 15/09/15->Mon 15/06/15 03/07/15: WID: RP-150123->RP-150643 03/07/15: Stat Rep: ->RP-150536
- 1665: 03/07/15: Compl:0%->100% 03/07/15: CD:Tue 15/09/15->Mon 15/06/15 03/07/15: WID: RP-150124->RP-150644 03/07/15: Stat Rep: ->RP-150536
- 1666: 03/07/15: Compl:0%->100% 03/07/15: CD:Tue 15/09/15->Mon 15/06/15 03/07/15: WID: RP-150124->RP-150644 03/07/15: Stat Rep: ->RP-150536
- 1668: 03/07/15: Compl:0%->100% 03/07/15: CD:Tue 15/09/15->Mon 15/06/15 03/07/15: WID: RP-150125->RP-150645 03/07/15: Stat Rep: ->RP-150536
- 1669: 03/07/15: Compl:0%->100% 03/07/15: CD:Tue 15/09/15->Mon 15/06/15 03/07/15: WID: RP-150125->RP-150645 03/07/15: Stat Rep: ->RP-150536

| ID | WBS | Task | Duration | Start | Finish | Complete | Constraint | Resources | Work | Actual work | Acronym | PCG approved | WI rapporteur name | Release | TSG approved | Status Report |
| --- | --- | --- | --- | --- | --- | --- | --- | --- | --- | --- | --- | --- | --- | --- | --- | --- |
| 1670 | 530.62 | **Additional bandwidth combination set for LTE Advanced 3 Band Carrier Aggregation (3DL/1UL) of Band 4, Band 4 and Band 7** | 197d? | 2015-03-16 A | 2015-12-15 A | 100% |  | R4 | 4728h | 4728h | LTE_CA_B4_B4_B7_BWset | 34 | Rogers Communications | Rel-13 | 67 |  |
| 1671 | 530.62.1 | Core part: Additional bandwidth combination set for LTE Advanced 3 Band Carrier Aggregation (3DL/1UL) of Band 4, Band 4 and Band 7 | 197d? | 2015-03-16 A | 2015-12-15 A | 100% | finish no earlier than 2015-12-15 | R4 | 1576h | 1576h | LTE_CA_B4_B4_B7_BWset-Core | 34 | Rogers Communications | Rel-13 | 67 | RP-151131 |
| 1672 | 530.62.2 | Perf. part: Additional bandwidth combination set for LTE Advanced 3 Band Carrier Aggregation (3DL/1UL) of Band 4, Band 4 and Band 7 | 197d? | 2015-03-16 A | 2015-12-15 A | 100% | finish no earlier than 2015-12-15 | R4 | 1576h | 1576h | LTE_CA_B4_B4_B7_BWset-Perf | 34 | Rogers Communications | Rel-13 | 67 | RP-151131 |
| 1673 | 530.63 | **Additional bandwidth combination set for LTE Advanced 3 Band Carrier Aggregation (3DL/1UL) of Band 4, Band 7 and Band 12** | 197d? | 2015-03-16 A | 2015-12-15 A | 100% |  | R4 | 4728h | 4728h | LTE_CA_B4_B7_B12_BWset | 34 | Rogers Communications | Rel-13 | 67 |  |
| 1674 | 530.63.1 | Core part: Additional bandwidth combination set for LTE Advanced 3 Band Carrier Aggregation (3DL/1UL) of Band 4, Band 7 and Band 12 | 197d? | 2015-03-16 A | 2015-12-15 A | 100% | finish no earlier than 2015-12-15 | R4 | 1576h | 1576h | LTE_CA_B4_B7_B12_BWset-Core | 34 | Rogers Communications | Rel-13 | 67 | RP-151131 |
| 1675 | 530.63.2 | Perf. part: Additional bandwidth combination set for LTE Advanced 3 Band Carrier Aggregation (3DL/1UL) of Band 4, Band 7 and Band 12 | 197d? | 2015-03-16 A | 2015-12-15 A | 100% | finish no earlier than 2015-12-15 | R4 | 1576h | 1576h | LTE_CA_B4_B7_B12_BWset-Perf | 34 | Rogers Communications | Rel-13 | 67 | RP-151131 |
| 1676 | 530.64 | **LTE Advanced 3 Band Carrier Aggregation (3DL/1UL) of Band 2, Band 7 and Band 12** | 262d? | 2015-03-16 A | 2016-03-15 A | 100% |  | R4 | 6288h | 6288h | LTE_CA_B2_B7_B12 | 34 | Rogers Communications | Rel-13 | 67 |  |
| 1677 | 530.64.1 | Core part:LTE Advanced 3 Band Carrier Aggregation (3DL/1UL) of Band 2, Band 7 and Band 12 | 262d? | 2015-03-16 A | 2016-03-15 A | 100% | finish no earlier than 2016-03-15 | R4 | 2096h | 2096h | LTE_CA_B2_B7_B12-Core | 34 | Rogers Communications | Rel-13 | 67 | RP-151131 |
| 1678 | 530.64.2 | Perf. part:LTE Advanced 3 Band Carrier Aggregation (3DL/1UL) of Band 2, Band 7 and Band 12 | 262d? | 2015-03-16 A | 2016-03-15 A | 100% | finish no earlier than 2016-03-15 | R4 | 2096h | 2096h | LTE_CA_B2_B7_B12-Perf | 34 | Rogers Communications | Rel-13 | 67 | RP-151131 |
| 1679 | 530.65 | **LTE Advanced 3 Band Carrier Aggregation (3DL/1UL) of Band 2, Band 4 and Band 7** | 262d? | 2015-03-16 A | 2016-03-15 A | 100% |  | R4 | 6288h | 6288h | LTE_CA_B2_B4_B7 | 34 | Rogers Communications | Rel-13 | 67 |  |
| 1680 | 530.65.1 | Core part:LTE Advanced 3 Band Carrier Aggregation (3DL/1UL) of Band 2, Band 4 and Band 7 | 262d? | 2015-03-16 A | 2016-03-15 A | 100% | finish no earlier than 2016-03-15 | R4 | 2096h | 2096h | LTE_CA_B2_B4_B7-Core | 34 | Rogers Communications | Rel-13 | 67 | RP-151131 |
| 1681 | 530.65.2 | Perf. part:LTE Advanced 3 Band Carrier Aggregation (3DL/1UL) of Band 2, Band 4 and Band 7 | 262d? | 2015-03-16 A | 2016-03-15 A | 100% | finish no earlier than 2016-03-15 | R4 | 2096h | 2096h | LTE_CA_B2_B4_B7-Perf | 34 | Rogers Communications | Rel-13 | 67 | RP-151131 |
| 1682 | 530.66 | **LTE Advanced 3 Band Carrier Aggregation (3DL/1UL) of Band 7, Band 20 and Band 38** | 197d? | 2015-03-16 A | 2015-12-15 A | 100% |  | R4 | 4728h | 4728h | LTE_CA_B7_B20_B38 | 34 | Nokia Networks | Rel-13 | 67 |  |
| 1683 | 530.66.1 | Core part:LTE Advanced 3 Band Carrier Aggregation (3DL/1UL) of Band 7, Band 20 and Band 38 | 197d? | 2015-03-16 A | 2015-12-15 A | 100% | finish no earlier than 2015-12-15 | R4 | 1576h | 1576h | LTE_CA_B7_B20_B38-Core | 34 | Nokia Networks | Rel-13 | 67 | RP-151131 |
| 1684 | 530.66.2 | Perf. part:LTE Advanced 3 Band Carrier Aggregation (3DL/1UL) of Band 7, Band 20 and Band 38 | 197d? | 2015-03-16 A | 2015-12-15 A | 100% | finish no earlier than 2015-12-15 | R4 | 1576h | 1576h | LTE_CA_B7_B20_B38-Perf | 34 | Nokia Networks | Rel-13 | 67 | RP-151131 |
| 1685 | 530.67 | **LTE Advanced 4 Band Carrier Aggregation (4DL/1UL) of Band 2, Band 4, Band 4 and Band 12** | 197d? | 2015-03-16 A | 2015-12-15 A | 100% |  | R4 | 4728h | 4728h | LTE_CA_B2_B4_B4_B12 | 34 | Nokia Networks | Rel-13 | 67 |  |
| 1686 | 530.67.1 | Core part:LTE Advanced 4 Band Carrier Aggregation (4DL/1UL) of Band 2, Band 4, Band 4 and Band 12 | 197d? | 2015-03-16 A | 2015-12-15 A | 100% | finish no earlier than 2015-12-15 | R4 | 1576h | 1576h | LTE_CA_B2_B4_B4_B12-Core | 34 | Nokia Networks | Rel-13 | 67 | RP-151131 |
| 1687 | 530.67.2 | Perf. part:LTE Advanced 4 Band Carrier Aggregation (4DL/1UL) of Band 2, Band 4, Band 4 and Band 12 | 197d? | 2015-03-16 A | 2015-12-15 A | 100% | finish no earlier than 2015-12-15 | R4 | 1576h | 1576h | LTE_CA_B2_B4_B4_B12-Perf | 34 | Nokia Networks | Rel-13 | 67 | RP-151131 |
| 1688 | 530.68 | **LTE Advanced 4 Band Carrier Aggregation (4DL/1UL) of Band 2, Band 2, Band 4 and Band 12** | 197d? | 2015-03-16 A | 2015-12-15 A | 100% |  | R4 | 4728h | 4728h | LTE_CA_B2_B2_B4_B12 | 34 | Nokia Networks | Rel-13 | 67 |  |
| 1689 | 530.68.1 | Core part:LTE Advanced 4 Band Carrier Aggregation (4DL/1UL) of Band 2, Band 2, Band 4 and Band 12 | 197d? | 2015-03-16 A | 2015-12-15 A | 100% | finish no earlier than 2015-12-15 | R4 | 1576h | 1576h | LTE_CA_B2_B2_B4_B12-Core | 34 | Nokia Networks | Rel-13 | 67 | RP-151131 |
| 1690 | 530.68.2 | Perf. part:LTE Advanced 4 Band Carrier Aggregation (4DL/1UL) of Band 2, Band 2, Band 4 and Band 12 | 197d? | 2015-03-16 A | 2015-12-15 A | 100% | finish no earlier than 2015-12-15 | R4 | 1576h | 1576h | LTE_CA_B2_B2_B4_B12-Perf | 34 | Nokia Networks | Rel-13 | 67 | RP-151131 |
| 1691 | 530.69 | **LTE Advanced 4 Band Carrier Aggregation (4DL/1UL) of Band 2, Band 2, Band 4 and Band 4** | 197d? | 2015-03-16 A | 2015-12-15 A | 100% |  | R4 | 4728h | 4728h | LTE_CA_B2_B2_B4_B4 | 34 | Nokia Networks | Rel-13 | 67 |  |
| 1692 | 530.69.1 | Core part:LTE Advanced 4 Band Carrier Aggregation (4DL/1UL) of Band 2, Band 2, Band 4 and Band 4 | 197d? | 2015-03-16 A | 2015-12-15 A | 100% | finish no earlier than 2015-12-15 | R4 | 1576h | 1576h | LTE_CA_B2_B2_B4_B4-Core | 34 | Nokia Networks | Rel-13 | 67 | RP-151131 |
| 1693 | 530.69.2 | Perf. part:LTE Advanced 4 Band Carrier Aggregation (4DL/1UL) of Band 2, Band 2, Band 4 and Band 4 | 197d? | 2015-03-16 A | 2015-12-15 A | 100% | finish no earlier than 2015-12-15 | R4 | 1576h | 1576h | LTE_CA_B2_B2_B4_B4-Perf | 34 | Nokia Networks | Rel-13 | 67 | RP-151131 |

Notes:
- 1671: 03/07/15: CD:Tue 15/09/15->Tue 15/12/15 03/07/15: Stat Rep: ->RP-150536 29/09/15: Stat Rep: RP-150536->RP-151131
- 1672: 03/07/15: CD:Tue 15/09/15->Tue 15/12/15 03/07/15: Stat Rep: ->RP-150536 29/09/15: Stat Rep: RP-150536->RP-151131
- 1674: 03/07/15: CD:Tue 15/09/15->Tue 15/12/15 03/07/15: Stat Rep: ->RP-150536 29/09/15: Stat Rep: RP-150536->RP-151131
- 1675: 03/07/15: CD:Tue 15/09/15->Tue 15/12/15 03/07/15: Stat Rep: ->RP-150536 29/09/15: Stat Rep: RP-150536->RP-151131
- 1677: 03/07/15: Stat Rep: ->RP-150536 29/09/15: Stat Rep: RP-150536->RP-151131 ; 1/122/3/16: Compl:0%->100%
- 1678: 03/07/15: Stat Rep: ->RP-150536 29/09/15: Stat Rep: RP-150536->RP-151131 122/3/16: Compl:0%->100%
- 1680: 03/07/15: Stat Rep: ->RP-150536 29/09/15: Stat Rep: RP-150536->RP-1511311/1/16:22/3/16: Compl:0%->100%
- 1681: 03/07/15: Stat Rep: ->RP-150536 29/09/15: Stat Rep: RP-150536->RP-151131 1/1/1; 22/3/16: Compl:0%->100%
- 1683: 03/07/15: Compl:0%->30% 03/07/15: Stat Rep: ->RP-150536 29/09/15: Compl:30%->60% 29/09/15: Stat Rep: RP-150536->RP-151131
- 1684: 03/07/15: Compl:0%->30% 03/07/15: Stat Rep: ->RP-150536 29/09/15: Compl:30%->60% 29/09/15: Stat Rep: RP-150536->RP-151131
- 1686: 03/07/15: Compl:0%->95% 03/07/15: WID: RP-150073->RP-150660 03/07/15: Stat Rep: ->RP-150536 29/09/15: Stat Rep: RP-150536->RP-151131
- 1687: 03/07/15: Compl:0%->95% 03/07/15: WID: RP-150073->RP-150660 03/07/15: Stat Rep: ->RP-150536 29/09/15: Stat Rep: RP-150536->RP-151131
- 1689: 03/07/15: Compl:0%->95% 03/07/15: WID: RP-150074->RP-150659 03/07/15: Stat Rep: ->RP-150536 29/09/15: Stat Rep: RP-150536->RP-151131
- 1690: 03/07/15: Compl:0%->95% 03/07/15: WID: RP-150074->RP-150659 03/07/15: Stat Rep: ->RP-150536 29/09/15: Stat Rep: RP-150536->RP-151131
- 1692: 03/07/15: Compl:0%->95% 03/07/15: WID: RP-150075->RP-150658 03/07/15: Stat Rep: ->RP-150536 29/09/15: Stat Rep: RP-150536->RP-151131
- 1693: 03/07/15: Compl:0%->95% 03/07/15: WID: RP-150075->RP-150658 03/07/15: Stat Rep: ->RP-150536 29/09/15: Stat Rep: RP-150536->RP-151131

| ID | WBS | Task | Duration | Start | Finish | Complete | Constraint | Resources | Work | Actual work | Acronym | PCG approved | WI rapporteur name | Release | TSG approved | Status Report |
| --- | --- | --- | --- | --- | --- | --- | --- | --- | --- | --- | --- | --- | --- | --- | --- | --- |
| 1694 | 530.70 | **LTE Advanced 4 Band Carrier Aggregation (4DL/1UL) of Band 1, Band 3, Band 5 and Band 40** | 197d? | 2015-03-16 A | 2015-12-15 A | 100% |  | R4 | 4728h | 4728h | LTE_CA_B1_B3_B5_B40 | 34 | SK Telecom | Rel-13 | 67 |  |
| 1695 | 530.70.1 | Core part:LTE Advanced 4 Band Carrier Aggregation (4DL/1UL) of Band 1, Band 3, Band 5 and Band 40 | 197d? | 2015-03-16 A | 2015-12-15 A | 100% | finish no earlier than 2015-12-15 | R4 | 1576h | 1576h | LTE_CA_B1_B3_B5_B40-Core | 34 | SK Telecom | Rel-13 | 67 | RP-151131 |
| 1696 | 530.70.2 | Perf. part:LTE Advanced 4 Band Carrier Aggregation (4DL/1UL) of Band 1, Band 3, Band 5 and Band 40 | 197d? | 2015-03-16 A | 2015-12-15 A | 100% | finish no earlier than 2015-12-15 | R4 | 1576h | 1576h | LTE_CA_B1_B3_B5_B40-Perf | 34 | SK Telecom | Rel-13 | 67 | RP-151131 |
| 1697 | 530.71 | **LTE Advanced 4 Band Carrier Aggregation (4DL/1UL) of Band 1, Band 3, Band 7 and Band 8** | 197d? | 2015-03-16 A | 2015-12-15 A | 100% |  | R4 | 4728h | 4728h | LTE_CA_B1_B3_B7_B8 | 34 | Nokia Networks | Rel-13 | 67 |  |
| 1698 | 530.71.1 | Core part:LTE Advanced 4 Band Carrier Aggregation (4DL/1UL) of Band 1, Band 3, Band 7 and Band 8 | 197d? | 2015-03-16 A | 2015-12-15 A | 100% | finish no earlier than 2015-12-15 | R4 | 1576h | 1576h | LTE_CA_B1_B3_B7_B8-Core | 34 | Nokia Networks | Rel-13 | 67 | RP-151131 |
| 1699 | 530.71.2 | Perf. part:LTE Advanced 4 Band Carrier Aggregation (4DL/1UL) of Band 1, Band 3, Band 7 and Band 8 | 197d? | 2015-03-16 A | 2015-12-15 A | 100% | finish no earlier than 2015-12-15 | R4 | 1576h | 1576h | LTE_CA_B1_B3_B7_B8-Perf | 34 | Nokia Networks | Rel-13 | 67 | RP-151131 |
| 1700 | 530.72 | **LTE Advanced 4 Band Carrier Aggregation (4DL/1UL) of Band 2, Band 4, Band 5 and Band 29** | 197d? | 2015-03-16 A | 2015-12-15 A | 100% |  | R4 | 4728h | 4728h | LTE_CA_B2_B4_B5_B29 | 34 | Huawei | Rel-13 | 67 |  |
| 1701 | 530.72.1 | Core part:LTE Advanced 4 Band Carrier Aggregation (4DL/1UL) of Band 2, Band 4, Band 5 and Band 29 | 197d? | 2015-03-16 A | 2015-12-15 A | 100% | finish no earlier than 2015-12-15 | R4 | 1576h | 1576h | LTE_CA_B2_B4_B5_B29-Core | 34 | Huawei | Rel-13 | 67 | RP-151131 |
| 1702 | 530.72.2 | Perf. part:LTE Advanced 4 Band Carrier Aggregation (4DL/1UL) of Band 2, Band 4, Band 5 and Band 29 | 197d? | 2015-03-16 A | 2015-12-15 A | 100% | finish no earlier than 2015-12-15 | R4 | 1576h | 1576h | LTE_CA_B2_B4_B5_B29-Perf | 34 | Huawei | Rel-13 | 67 | RP-151131 |
| 1703 | 530.73 | **LTE Advanced dual uplink inter-band Carrier Aggregation FDD-TDD** | 197d? | 2015-03-16 A | 2015-12-15 A | 100% |  | R4 | 4728h | 4728h | LTE_CA_2UL_FDD_TDD | 34 | KDDI | Rel-13 | 67 |  |
| 1704 | 530.73.1 | Core part:LTE Advanced dual uplink inter-band Carrier Aggregation FDD-TDD | 197d? | 2015-03-16 A | 2015-12-15 A | 100% | finish no earlier than 2015-12-15 | R4 | 1576h | 1576h | LTE_CA_2UL_FDD_TDD-Core | 34 | KDDI | Rel-13 | 67 | RP-151131 |
| 1705 | 530.73.2 | Perf. part:LTE Advanced dual uplink inter-band Carrier Aggregation FDD-TDD | 197d? | 2015-03-16 A | 2015-12-15 A | 100% | finish no earlier than 2015-12-15 | R4 | 1576h | 1576h | LTE_CA_2UL_FDD_TDD-Perf | 34 | KDDI | Rel-13 | 67 | RP-151131 |
| 1706 | 530.74 | **LTE Advanced dual uplink inter-band Carrier Aggregation Class A4** | 197d? | 2015-03-16 A | 2015-12-15 A | 100% |  | R4 | 4728h | 4728h | LTE_CA_2UL_R13-A4 | 34 | Nokia Networks | Rel-13 | 67 |  |
| 1707 | 530.74.1 | Core part:LTE Advanced dual uplink inter-band Carrier Aggregation Class A4 in REL-13 | 197d? | 2015-03-16 A | 2015-12-15 A | 100% | finish no earlier than 2015-12-15 | R4 | 1576h | 1576h | LTE_CA_2UL_R13-A4-Core | 34 | Nokia Networks | Rel-13 | 67 | RP-151131 |
| 1708 | 530.74.2 | Perf. Part:LTE Advanced dual uplink inter-band Carrier Aggregation Class A4 in REL-13 | 197d? | 2015-03-16 A | 2015-12-15 A | 100% | finish no earlier than 2015-12-15 | R4 | 1576h | 1576h | LTE_CA_2UL_R13-A4-Perf | 34 | Nokia Networks | Rel-13 | 67 | RP-151131 |
| 1709 | 530.75 | **LTE Advanced 3DL/2UL inter-band Carrier Aggregation** | 197d? | 2015-03-16 A | 2015-12-15 A | 100% |  | R4 | 4728h | 4728h | LTE_CA_3DL_2UL | 34 | Nokia Corporation | Rel-13 | 67 |  |
| 1710 | 530.75.1 | Core part:LTE Advanced 3DL/2UL inter-band Carrier Aggregation | 197d? | 2015-03-16 A | 2015-12-15 A | 100% | finish no earlier than 2015-12-15 | R4 | 1576h | 1576h | LTE_CA_3DL_2UL-Core | 34 | Nokia Corporation | Rel-13 | 67 | RP-151131 |
| 1711 | 530.75.2 | Perf. part:LTE Advanced 3DL/2UL inter-band Carrier Aggregation | 197d? | 2015-03-16 A | 2015-12-15 A | 100% | finish no earlier than 2015-12-15 | R4 | 1576h | 1576h | LTE_CA_3DL_2UL-Perf | 34 | Nokia Corporation | Rel-13 | 67 | RP-151131 |
| 1712 | 530.76 | **LTE Advanced intra-band non-contiguous Carrier Aggregation in Band 42 for 3DL** | 66d? | 2015-03-16 A | 2015-06-15 A | 100% |  | R4 | 1584h | 1584h | LTE_CA_NC_B42_3DL | 34 | Huawei | Rel-13 | 67 |  |
| 1713 | 530.76.1 | Core part:LTE Advanced intra-band non-contiguous Carrier Aggregation in Band 42 for 3DL | 66d? | 2015-03-16 A | 2015-06-15 A | 100% | finish no earlier than 2015-09-15 | R4 | 528h | 528h | LTE_CA_NC_B42_3DL-Core | 34 | Huawei | Rel-13 | 67 | RP-150536 |
| 1714 | 530.76.2 | Perf. part:LTE Advanced intra-band non-contiguous Carrier Aggregation in Band 42 for 3DL | 66d? | 2015-03-16 A | 2015-06-15 A | 100% | finish no earlier than 2015-09-15 | R4 | 528h | 528h | LTE_CA_NC_B42_3DL-Perf | 34 | Huawei | Rel-13 | 67 | RP-150536 |
| 1715 | 530.77 | **LTE Advanced intra-band contiguous Carrier Aggregation in Band 8** | 197d? | 2015-03-16 A | 2015-12-15 A | 100% |  | R4 | 4728h | 4728h | LTE_CA_C_B8 | 34 | CMCC | Rel-13 | 67 |  |
| 1716 | 530.77.1 | Core part: LTE Advanced intra-band contiguous Carrier Aggregation in Band 8 | 197d? | 2015-03-16 A | 2015-12-15 A | 100% | finish no earlier than 2015-12-15 | R4 | 1576h | 1576h | LTE_CA_C_B8-Core | 34 | CMCC | Rel-13 | 67 | RP-151131 |
| 1717 | 530.77.2 | Perf. part: LTE Advanced intra-band contiguous Carrier Aggregation in Band 8 | 197d? | 2015-03-16 A | 2015-12-15 A | 100% | finish no earlier than 2015-12-15 | R4 | 1576h | 1576h | LTE_CA_C_B8-Perf | 34 | CMCC | Rel-13 | 67 | RP-151131 |

Notes:
- 1695: 03/07/15: Compl:0%->30% 03/07/15: WID: RP-150434->RP-150617 03/07/15: Stat Rep: ->RP-150536 29/09/15: Compl:30%->60% 29/09/15: CD:Tue 15/09/15->Tue 15/12/15 29/09/15: WID: RP-150617->RP-151216 29/09/15: Stat Rep: RP-150536->RP-151131
- 1696: 03/07/15: WID: RP-150434->RP-150617 03/07/15: Stat Rep: ->RP-150536 29/09/15: CD:Tue 15/09/15->Tue 15/12/15 29/09/15: WID: RP-150617->RP-151216 29/09/15: Stat Rep: RP-150536->RP-151131
- 1698: 03/07/15: Compl:0%->40% 03/07/15: Stat Rep: ->RP-150536 29/09/15: Compl:40%->45% 29/09/15: Stat Rep: RP-150536->RP-151131
- 1699: 03/07/15: Stat Rep: ->RP-150536 29/09/15: Stat Rep: RP-150536->RP-151131
- 1701: 03/07/15: Compl:0%->50% 03/07/15: Stat Rep: ->RP-150536 29/09/15: Compl:50%->95% 29/09/15: Stat Rep: RP-150536->RP-151131
- 1702: 03/07/15: Stat Rep: ->RP-150536 29/09/15: Compl:0%->95% 29/09/15: Stat Rep: RP-150536->RP-151131
- 1704: 03/07/15: Compl:0%->70% 03/07/15: Stat Rep: ->RP-150536 29/09/15: Compl:70%->90% 29/09/15: Stat Rep: RP-150536->RP-151131
- 1705: 03/07/15: CD:Tue 15/09/15->Tue 15/12/15 03/07/15: Stat Rep: ->RP-150536 29/09/15: Compl:0%->90% 29/09/15: Stat Rep: RP-150536->RP-151131
- 1707: 03/07/15: Compl:0%->25% 03/07/15: WID: RP-150410->RP-150616 03/07/15: Stat Rep: ->RP-150536 29/09/15: Compl:25%->75% 29/09/15: Stat Rep: RP-150536->RP-151131
- 1708: 03/07/15: Compl:0%->25% 03/07/15: WID: RP-150410->RP-150616 03/07/15: Stat Rep: ->RP-150536 29/09/15: Compl:25%->75% 29/09/15: Stat Rep: RP-150536->RP-151131
- 1710: 03/07/15: Compl:0%->25% 03/07/15: CD:Tue 15/03/16->Tue 15/12/15 03/07/15: Stat Rep: ->RP-150536 29/09/15: Compl:25%->75% 29/09/15: WID: RP-150479->RP-151230 29/09/15: Stat Rep: RP-150536->RP-151131
- 1711: 03/07/15: Compl:0%->25% 03/07/15: Stat Rep: ->RP-150536 29/09/15: Compl:25%->75% 29/09/15: CD:Tue 15/03/16->Tue 15/12/15 29/09/15: WID: RP-150479->RP-151230 29/09/15: Stat Rep: RP-150536->RP-151131
- 1713: 03/07/15: Compl:0%->100% 03/07/15: CD:Tue 15/09/15->Mon 15/06/15 03/07/15: Stat Rep: ->RP-150536
- 1714: 03/07/15: Compl:0%->100% 03/07/15: CD:Tue 15/09/15->Mon 15/06/15 03/07/15: Stat Rep: ->RP-150536
- 1716: 03/07/15: Compl:0%->60% 03/07/15: WID: RP-150437->RP-150809 03/07/15: Stat Rep: ->RP-150536 29/09/15: Compl:60%->90% 29/09/15: CD:Tue 15/09/15->Tue 15/12/15 29/09/15: WID: RP-150809->RP-151177 29/09/15: Stat Rep: RP-150536->RP-151131
- 1717: 03/07/15: WID: RP-150437->RP-150809 03/07/15: Stat Rep: ->RP-150536 29/09/15: Compl:0%->50% 29/09/15: CD:Tue 15/09/15->Tue 15/12/15 29/09/15: WID: RP-150809->RP-151177 29/09/15: Stat Rep: RP-150536->RP-151131;

| ID | WBS | Task | Duration | Start | Finish | Complete | Remaining | Total slack | Constraint | Resources | Work | Actual work | Acronym | PCG approved | WI rapporteur name | Release | TSG approved | Status Report |
| --- | --- | --- | --- | --- | --- | --- | --- | --- | --- | --- | --- | --- | --- | --- | --- | --- | --- | --- |
| 1718 | 530.78 | **LTE Advanced intra-band contiguous Carrier Aggregation in Band 42 for 4DL** | 197d? | 2015-03-16 A | 2015-12-15 A | 100% |  |  |  | R4 | 4728h | 4728h | LTE_CA_C_B42_4DL | 34 | CATT | Rel-13 | 67 |  |
| 1719 | 530.78.1 | Core part: LTE Advanced intra-band contiguous Carrier Aggregation in Band 42 for 4DL | 197d? | 2015-03-16 A | 2015-12-15 A | 100% |  |  | finish no earlier than 2015-12-15 | R4 | 1576h | 1576h | LTE_CA_C_B42_4DL-Core | 34 | CATT | Rel-13 | 67 | RP-151131 |
| 1720 | 530.78.2 | Perf. part: LTE Advanced intra-band contiguous Carrier Aggregation in Band 42 for 4DL | 197d? | 2015-03-16 A | 2015-12-15 A | 100% |  |  | finish no earlier than 2015-12-15 | R4 | 1576h | 1576h | LTE_CA_C_B42_4DL-Perf | 34 | CATT | Rel-13 | 67 | RP-151131 |
| 1721 | 530.79 | **LTE Advanced 3 Band Carrier Aggregation (3DL/1UL) of Band 1, Band 8 and Band 11** | 67d? | 2015-06-15 A | 2015-09-15 A | 100% |  |  |  | R4 | 1608h | 1608h | LTE_CA_B1_B8_B11 | 35 | Softbank Mobile | Rel-13 | 68 |  |
| 1722 | 530.79.1 | Core part:LTE Advanced 3 Band Carrier Aggregation (3DL/1UL) of Band 1, Band 8 and Band 11 | 67d? | 2015-06-15 A | 2015-09-15 A | 100% |  |  | finish no earlier than 2015-09-15 | R4 | 536h | 536h | LTE_CA_B1_B8_B11-Core | 35 | Softbank Mobile | Rel-13 | 68 | RP-151131 |
| 1723 | 530.79.2 | Perf. part:LTE Advanced 3 Band Carrier Aggregation (3DL/1UL) of Band 1, Band 8 and Band 11 | 67d? | 2015-06-15 A | 2015-09-15 A | 100% |  |  | finish no earlier than 2015-09-15 | R4 | 536h | 536h | LTE_CA_B1_B8_B11-Perf | 35 | Softbank Mobile | Rel-13 | 68 | RP-151131 |
| 1724 | 530.80 | **LTE Advanced 3 Band Carrier Aggregation (3DL/1UL) of Band 3, Band 20 and Band 32** | 197d? | 2015-06-15 A | 2016-03-15 | 90% | 19.69d? | 1110d |  | R4 | 4728h | 3364.8h | LTE_CA_B3_B20_B32 | 35 | Ericsson | Rel-13 | 68 |  |
| 1725 | 530.80.1 | Core part:LTE Advanced 3 Band Carrier Aggregation (3DL/1UL) of Band 3, Band 20 and Band 32 | 197d? | 2015-06-15 A | 2016-03-15 | 90% | 19.7d? | 1110d | finish no earlier than 2016-03-15 | R4 | 1576h | 1418.4h | LTE_CA_B3_B20_B32-Core | 35 | Ericsson | Rel-14 | 68 | RP-151131 |
| 1726 | 530.80.2 | Perf. part:LTE Advanced 3 Band Carrier Aggregation (3DL/1UL) of Band 3, Band 20 and Band 32 | 197d? | 2015-06-15 A | 2016-03-15 | 90% | 19.7d? | 1110d | finish no earlier than 2016-03-15 | R4 | 1576h | 1418.4h | LTE_CA_B3_B20_B32-Perf | 35 | Ericsson | Rel-14 | 68 | RP-151131 |
| 1727 | 530.81 | **LTE Advanced 3 Band Carrier Aggregation (3DL/1UL) for Band 7, Band 42 and Band 42** | 132d? | 2015-06-15 A | 2015-12-15 A | 100% |  |  |  | R4 | 3168h | 3168h | LTE_CA_B7_B42_B42 | 35 | Huawei | Rel-13 | 68 |  |
| 1728 | 530.81.1 | Core part:LTE Advanced 3 Band Carrier Aggregation (3DL/1UL) for Band 7, Band 42 and Band 42 | 132d? | 2015-06-15 A | 2015-12-15 A | 100% |  |  | finish no earlier than 2015-12-15 | R4 | 1056h | 1056h | LTE_CA_B7_B42_B42-Core | 35 | Huawei | Rel-13 | 68 | RP-151131 |
| 1729 | 530.81.2 | Perf. part:LTE Advanced 3 Band Carrier Aggregation (3DL/1UL) for Band 7, Band 42 and Band 42 | 132d? | 2015-06-15 A | 2015-12-15 A | 100% |  |  | finish no earlier than 2015-12-15 | R4 | 1056h | 1056h | LTE_CA_B7_B42_B42-Perf | 35 | Huawei | Rel-13 | 68 | RP-151131 |
| 1730 | 530.82 | **LTE Advanced 3 Band Carrier Aggregation (3DL/1UL) for Band 20, Band 42 and Band 42** | 67d? | 2015-06-15 A | 2015-09-15 A | 100% |  |  |  | R4 | 1608h | 1608h | LTE_CA_B20_B42_B42 | 35 | Huawei | Rel-13 | 68 |  |
| 1731 | 530.82.1 | Core part:LTE Advanced 3 Band Carrier Aggregation (3DL/1UL) for Band 20, Band 42 and Band 42 | 67d? | 2015-06-15 A | 2015-09-15 A | 100% |  |  | finish no earlier than 2015-12-15 | R4 | 536h | 536h | LTE_CA_B20_B42_B42-Core | 35 | Huawei | Rel-13 | 68 | RP-151131 |
| 1732 | 530.82.2 | Perf. part:LTE Advanced 3 Band Carrier Aggregation (3DL/1UL) for Band 20, Band 42 and Band 42 | 67d? | 2015-06-15 A | 2015-09-15 A | 100% |  |  | finish no earlier than 2015-12-15 | R4 | 536h | 536h | LTE_CA_B20_B42_B42-Perf | 35 | Huawei | Rel-13 | 68 | RP-151131 |
| 1733 | 530.83 | **LTE Advanced 3 Band Carrier Aggregation (3DL/1UL) for Band 3, Band 7 and Band 38** | 132d? | 2015-06-15 A | 2015-12-15 A | 100% |  |  |  | R4 | 3168h | 3168h | LTE_CA_B3_B7_B38 | 35 | Nokia Networks | Rel-13 | 68 |  |
| 1734 | 530.83.1 | Core part:LTE Advanced 3 Band Carrier Aggregation (3DL/1UL) for Band 3, Band 7 and Band 38 | 132d? | 2015-06-15 A | 2015-12-15 A | 100% |  |  | finish no earlier than 2015-12-15 | R4 | 1056h | 1056h | LTE_CA_B3_B7_B38-Core | 35 | Nokia Networks | Rel-13 | 68 | RP-151131 |
| 1735 | 530.83.2 | Perf. part:LTE Advanced 3 Band Carrier Aggregation (3DL/1UL) for Band 3, Band 7 and Band 38 | 132d? | 2015-06-15 A | 2015-12-15 A | 100% |  |  | finish no earlier than 2015-12-15 | R4 | 1056h | 1056h | LTE_CA_B3_B7_B38-Perf | 35 | Nokia Networks | Rel-13 | 68 | RP-151131 |
| 1736 | 530.84 | **LTE Advanced 3 Band Carrier Aggregation (3DL/1UL) of Band 28, Band 41 and Band 41** | 132d? | 2015-06-15 A | 2015-12-15 A | 100% |  |  |  | R4 | 3168h | 3168h | LTE_CA_B28_B41_B41 | 35 | KDDI | Rel-13 | 68 |  |
| 1737 | 530.84.1 | Core part:LTE Advanced 3 Band Carrier Aggregation (3DL/1UL) of Band 28, Band 41 and Band 41 | 132d? | 2015-06-15 A | 2015-12-15 A | 100% |  |  | finish no earlier than 2015-12-15 | R4 | 1056h | 1056h | LTE_CA_B28_B41_B41-Core | 35 | KDDI | Rel-13 | 68 | RP-151131 |
| 1738 | 530.84.2 | Perf. part:LTE Advanced 3 Band Carrier Aggregation (3DL/1UL) of Band 28, Band 41 and Band 41 | 132d? | 2015-06-15 A | 2015-12-15 A | 100% |  |  | finish no earlier than 2015-12-15 | R4 | 1056h | 1056h | LTE_CA_B28_B41_B41-Perf | 35 | KDDI | Rel-13 | 68 | RP-151131 |
| 1739 | 530.85 | **LTE Advanced 3 Band Carrier Aggregation (3DL/1UL) of Band 28, Band 42 and Band 42** | 132d? | 2015-06-15 A | 2015-12-15 A | 100% |  |  |  | R4 | 3168h | 3168h | LTE_CA_B28_B42_B42 | 35 | KDDI | Rel-13 | 68 |  |
| 1740 | 530.85.1 | Core part:LTE Advanced 3 Band Carrier Aggregation (3DL/1UL) of Band 28, Band 42 and Band 42 | 132d? | 2015-06-15 A | 2015-12-15 A | 100% |  |  | finish no earlier than 2015-12-15 | R4 | 1056h | 1056h | LTE_CA_B28_B42_B42-Core | 35 | KDDI | Rel-13 | 68 | RP-151131 |
| 1741 | 530.85.2 | Perf. part:LTE Advanced 3 Band Carrier Aggregation (3DL/1UL) of Band 28, Band 42 and Band 42 | 132d? | 2015-06-15 A | 2015-12-15 A | 100% |  |  | finish no earlier than 2015-12-15 | R4 | 1056h | 1056h | LTE_CA_B28_B42_B42-Perf | 35 | KDDI | Rel-13 | 68 | RP-151131 |

Notes:
- 1719: 03/07/15: Compl:0%->50% 03/07/15: Stat Rep: ->RP-150536 29/09/15: Compl:50%->80% 29/09/15: Stat Rep: RP-150536->RP-151131
- 1720: 03/07/15: Compl:0%->50% 03/07/15: Stat Rep: ->RP-150536 29/09/15: Compl:50%->80% 29/09/15: Stat Rep: RP-150536->RP-151131
- 1722: 29/09/15: Compl:0%->100% 29/09/15: Stat Rep: -->RP-151131
- 1723: 29/09/15: Compl:0%->100% 29/09/15: Stat Rep: -->RP-151131
- 1725: 29/09/15: Compl:0%->50% 29/09/15: Stat Rep: -->RP-1511311/22/3/16: Compl:50%->90%
- 1726: 29/09/15: Compl:0%->50% 29/09/15: Stat Rep: -->RP-151131 ; 22/3/16: Compl:50%->90%
- 1728: 29/09/15: Compl:0%->70% 29/09/15: Stat Rep: -->RP-151131
- 1729: 29/09/15: Compl:0%->70% 29/09/15: Stat Rep: -->RP-151131
- 1731: 29/09/15: Compl:0%->100% 29/09/15: CD:Tue 15/12/15->Tue 15/09/15 29/09/15: Stat Rep: -->RP-151131
- 1732: 29/09/15: Compl:0%->100% 29/09/15: CD:Tue 15/12/15->Tue 15/09/15 29/09/15: Stat Rep: -->RP-151131
- 1734: 29/09/15: Compl:0%->60% 29/09/15: Stat Rep: -->RP-1511311/1/16: Compl:
- 1735: 29/09/15: Compl:0%->60% 29/09/15: Stat Rep: -->RP-151131; 1/1/16: Comp
- 1737: 29/09/15: Compl:0%->50% 29/09/15: Stat Rep: -->RP-151131
- 1738: 29/09/15: Stat Rep: -->RP-151131
- 1740: 29/09/15: Compl:0%->40% 29/09/15: WID: RP-151112->RP-151158 29/09/15: Stat Rep: -->RP-151131
- 1741: 29/09/15: WID: RP-151112->RP-151158 29/09/15: Stat Rep: -->RP-151131;

| ID | WBS | Task | Duration | Start | Finish | Complete | Constraint | Resources | Work | Actual work | Acronym | PCG approved | WI rapporteur name | Release | TSG approved | Status Report |
| --- | --- | --- | --- | --- | --- | --- | --- | --- | --- | --- | --- | --- | --- | --- | --- | --- |
| 1742 | 530.86 | **LTE Advanced 4 Band Carrier Aggregation (4DL/1UL) of Band 2, Band 4, Band 7 and Band 12** | 197d? | 2015-06-15 A | 2016-03-15 A | 100% |  | R4 | 4728h | 4728h | LTE_CA_B2_B4_B7_B12 | 35 | Rogers Communications | Rel-13 | 68 |  |
| 1743 | 530.86.1 | Core part:LTE Advanced 4 Band Carrier Aggregation (4DL/1UL) of Band 2, Band 4, Band 7 and Band 12 | 197d? | 2015-06-15 A | 2016-03-15 A | 100% | finish no earlier than 2016-03-15 | R4 | 1576h | 1576h | LTE_CA_B2_B4_B7_B12-Core | 35 | Rogers Communications | Rel-13 | 68 | RP-151131 |
| 1744 | 530.86.2 | Perf. part:LTE Advanced 4 Band Carrier Aggregation (4DL/1UL) of Band 2, Band 4, Band 7 and Band 12 | 197d? | 2015-06-15 A | 2016-03-15 A | 100% | finish no earlier than 2016-03-15 | R4 | 1576h | 1576h | LTE_CA_B2_B4_B7_B12-Perf | 35 | Rogers Communications | Rel-13 | 68 | RP-151131 |
| 1745 | 530.87 | **LTE Advanced 4 Band Carrier Aggregation (4DL/1UL) of Band 1, Band 3, Band 19 and Band 42** | 132d? | 2015-06-15 A | 2015-12-15 A | 100% |  | R4 | 3168h | 3168h | LTE_CA_B1_B3_B19_B42 | 35 | NTT DOCOMO, INC. | Rel-13 | 68 |  |
| 1746 | 530.87.1 | Core part:LTE Advanced 4 Band Carrier Aggregation (4DL/1UL) of Band 1, Band 3, Band 19 and Band 42 | 132d? | 2015-06-15 A | 2015-12-15 A | 100% | finish no earlier than 2015-12-15 | R4 | 1056h | 1056h | LTE_CA_B1_B3_B19_B42-Core | 35 | NTT DOCOMO, INC. | Rel-13 | 68 | RP-151131 |
| 1747 | 530.87.2 | Perf. part:LTE Advanced 4 Band Carrier Aggregation (4DL/1UL) of Band 1, Band 3, Band 19 and Band 42 | 132d? | 2015-06-15 A | 2015-12-15 A | 100% | finish no earlier than 2015-12-15 | R4 | 1056h | 1056h | LTE_CA_B1_B3_B19_B42-Perf | 35 | NTT DOCOMO, INC. | Rel-13 | 68 | RP-151131 |
| 1748 | 530.88 | **LTE Advanced 4 Band Carrier Aggregation (4DL/1UL) of Band 1, Band 3, Band 42 and Band 42** | 132d? | 2015-06-15 A | 2015-12-15 A | 100% |  | R4 | 3168h | 3168h | LTE_CA_B1_B3_B42_B42 | 35 | NTT DOCOMO, INC. | Rel-13 | 68 |  |
| 1749 | 530.88.1 | Core part:LTE Advanced 4 Band Carrier Aggregation (4DL/1UL) of Band 1, Band 3, Band 42 and Band 42 | 132d? | 2015-06-15 A | 2015-12-15 A | 100% | finish no earlier than 2015-12-15 | R4 | 1056h | 1056h | LTE_CA_B1_B3_B42_B42-Core | 35 | NTT DOCOMO, INC. | Rel-13 | 68 | RP-151131 |
| 1750 | 530.88.2 | Perf. part:LTE Advanced 4 Band Carrier Aggregation (4DL/1UL) of Band 1, Band 3, Band 42 and Band 42 | 132d? | 2015-06-15 A | 2015-12-15 A | 100% | finish no earlier than 2015-12-15 | R4 | 1056h | 1056h | LTE_CA_B1_B3_B42_B42-Perf | 35 | NTT DOCOMO, INC. | Rel-13 | 68 | RP-151131 |
| 1751 | 530.89 | **LTE Advanced 4 Band Carrier Aggregation (4DL/1UL) of Band 1, Band 19, Band 42 and Band 42** | 132d? | 2015-06-15 A | 2015-12-15 A | 100% |  | R4 | 3168h | 3168h | LTE_CA_B1_B19_B42_B42 | 35 | NTT DOCOMO, INC. | Rel-13 | 68 |  |
| 1752 | 530.89.1 | Core part:LTE Advanced 4 Band Carrier Aggregation (4DL/1UL) of Band 1, Band 19, Band 42 and Band 42 | 132d? | 2015-06-15 A | 2015-12-15 A | 100% | finish no earlier than 2015-12-15 | R4 | 1056h | 1056h | LTE_CA_B1_B19_B42_B42-Core | 35 | NTT DOCOMO, INC. | Rel-13 | 68 | RP-151131 |
| 1753 | 530.89.2 | Perf. part:LTE Advanced 4 Band Carrier Aggregation (4DL/1UL) of Band 1, Band 19, Band 42 and Band 42 | 132d? | 2015-06-15 A | 2015-12-15 A | 100% | finish no earlier than 2015-12-15 | R4 | 1056h | 1056h | LTE_CA_B1_B19_B42_B42-Perf | 35 | NTT DOCOMO, INC. | Rel-13 | 68 | RP-151131 |
| 1754 | 530.90 | **LTE Advanced 4 Band Carrier Aggregation (4DL/1UL) of Band 3, Band 19, Band 42 and Band 42** | 132d? | 2015-06-15 A | 2015-12-15 A | 100% |  | R4 | 3168h | 3168h | LTE_CA_B3_B19_B42_B42 | 35 | NTT DOCOMO, INC. | Rel-13 | 68 |  |
| 1755 | 530.90.1 | Core part:LTE Advanced 4 Band Carrier Aggregation (4DL/1UL) of Band 3, Band 19, Band 42 and Band 42 | 132d? | 2015-06-15 A | 2015-12-15 A | 100% | finish no earlier than 2015-12-15 | R4 | 1056h | 1056h | LTE_CA_B3_B19_B42_B42-Core | 35 | NTT DOCOMO, INC. | Rel-13 | 68 | RP-151131 |
| 1756 | 530.90.2 | Perf. part:LTE Advanced 4 Band Carrier Aggregation (4DL/1UL) of Band 3, Band 19, Band 42 and Band 42 | 132d? | 2015-06-15 A | 2015-12-15 A | 100% | finish no earlier than 2015-12-15 | R4 | 1056h | 1056h | LTE_CA_B3_B19_B42_B42-Perf | 35 | NTT DOCOMO, INC. | Rel-13 | 68 | RP-151131 |
| 1757 | 530.91 | **LTE Advanced 4 Band Carrier Aggregation (4DL/1UL) of Band 1, Band 19, Band 21 and Band 42** | 132d? | 2015-06-15 A | 2015-12-15 A | 100% |  | R4 | 3168h | 3168h | LTE_CA_B1_B19_B21_B42 | 35 | NTT DOCOMO, INC. | Rel-13 | 68 |  |
| 1758 | 530.91.1 | Core part:LTE Advanced 4 Band Carrier Aggregation (4DL/1UL) of Band 1, Band 19, Band 21 and Band 42 | 132d? | 2015-06-15 A | 2015-12-15 A | 100% | finish no earlier than 2015-12-15 | R4 | 1056h | 1056h | LTE_CA_B1_B19_B21_B42-Core | 35 | NTT DOCOMO, INC. | Rel-13 | 68 | RP-151131 |
| 1759 | 530.91.2 | Perf. part:LTE Advanced 4 Band Carrier Aggregation (4DL/1UL) of Band 1, Band 19, Band 21 and Band 42 | 132d? | 2015-06-15 A | 2015-12-15 A | 100% | finish no earlier than 2015-12-15 | R4 | 1056h | 1056h | LTE_CA_B1_B19_B21_B42-Perf | 35 | NTT DOCOMO, INC. | Rel-13 | 68 | RP-151131 |
| 1760 | 530.92 | **LTE Advanced 4 Band Carrier Aggregation (4DL/1UL) of Band 1, Band 21, Band 42 and Band 42** | 132d? | 2015-06-15 A | 2015-12-15 A | 100% |  | R4 | 3168h | 3168h | LTE_CA_B1_B21_B42_B42 | 35 | NTT DOCOMO, INC. | Rel-13 | 68 |  |
| 1761 | 530.92.1 | Core part:LTE Advanced 4 Band Carrier Aggregation (4DL/1UL) of Band 1, Band 21, Band 42 and Band 42 | 132d? | 2015-06-15 A | 2015-12-15 A | 100% | finish no earlier than 2015-12-15 | R4 | 1056h | 1056h | LTE_CA_B1_B21_B42_B42-Core | 35 | NTT DOCOMO, INC. | Rel-13 | 68 | RP-151131 |
| 1762 | 530.92.2 | Perf. part:LTE Advanced 4 Band Carrier Aggregation (4DL/1UL) of Band 1, Band 21, Band 42 and Band 42 | 132d? | 2015-06-15 A | 2015-12-15 A | 100% | finish no earlier than 2015-12-15 | R4 | 1056h | 1056h | LTE_CA_B1_B21_B42_B42-Perf | 35 | NTT DOCOMO, INC. | Rel-13 | 68 | RP-151131 |
| 1763 | 530.93 | **LTE Advanced 4 Band Carrier Aggregation (4DL/1UL) of Band 19, Band 21, Band 42 and Band 42** | 132d? | 2015-06-15 A | 2015-12-15 A | 100% |  | R4 | 3168h | 3168h | LTE_CA_B19_B21_B42_B42 | 35 | NTT DOCOMO, INC. | Rel-13 | 68 |  |
| 1764 | 530.93.1 | Core part:LTE Advanced 4 Band Carrier Aggregation (4DL/1UL) of Band 19, Band 21, Band 42 and Band 42 | 132d? | 2015-06-15 A | 2015-12-15 A | 100% | finish no earlier than 2015-12-15 | R4 | 1056h | 1056h | LTE_CA_B19_B21_B42_B42-Core | 35 | NTT DOCOMO, INC. | Rel-13 | 68 | RP-151131 |
| 1765 | 530.93.2 | Perf. part:LTE Advanced 4 Band Carrier Aggregation (4DL/1UL) of Band 19, Band 21, Band 42 and Band 42 | 132d? | 2015-06-15 A | 2015-12-15 A | 100% | finish no earlier than 2015-12-15 | R4 | 1056h | 1056h | LTE_CA_B19_B21_B42_B42-Perf | 35 | NTT DOCOMO, INC. | Rel-13 | 68 | RP-151131 |

Notes:
- 1743: 29/09/15: Stat Rep: -->RP-151131 22/3/16: Compl:0%->100%
- 1744: 29/09/15: Stat Rep: -->RP-151131 ; 22/3/16: Compl:0%->100%
- 1746: 29/09/15: Compl:0%->95% 29/09/15: CD:Tue 15/09/15->Tue 15/12/15 29/09/15: Stat Rep: -->RP-151131
- 1747: 29/09/15: Compl:0%->95% 29/09/15: CD:Tue 15/09/15->Tue 15/12/15 29/09/15: Stat Rep: -->RP-151131
- 1749: 29/09/15: Compl:0%->95% 29/09/15: CD:Tue 15/09/15->Tue 15/12/15 29/09/15: Stat Rep: -->RP-151131
- 1750: 29/09/15: Compl:0%->95% 29/09/15: CD:Tue 15/09/15->Tue 15/12/15 29/09/15: Stat Rep: -->RP-151131
- 1752: 29/09/15: Compl:0%->95% 29/09/15: CD:Tue 15/09/15->Tue 15/12/15 29/09/15: Stat Rep: -->RP-151131
- 1753: 29/09/15: Compl:0%->95% 29/09/15: CD:Tue 15/09/15->Tue 15/12/15 29/09/15: Stat Rep: -->RP-151131
- 1755: 29/09/15: Compl:0%->95% 29/09/15: CD:Tue 15/09/15->Tue 15/12/15 29/09/15: Stat Rep: -->RP-151131
- 1756: 29/09/15: Compl:0%->95% 29/09/15: CD:Tue 15/09/15->Tue 15/12/15 29/09/15: Stat Rep: -->RP-151131
- 1758: 29/09/15: Compl:0%->95% 29/09/15: CD:Tue 15/09/15->Tue 15/12/15 29/09/15: Stat Rep: -->RP-151131
- 1759: 29/09/15: Compl:0%->95% 29/09/15: CD:Tue 15/09/15->Tue 15/12/15 29/09/15: Stat Rep: -->RP-151131
- 1761: 29/09/15: Compl:0%->95% 29/09/15: CD:Tue 15/09/15->Tue 15/12/15 29/09/15: Stat Rep: -->RP-151131
- 1762: 29/09/15: Compl:0%->95% 29/09/15: CD:Tue 15/09/15->Tue 15/12/15 29/09/15: Stat Rep: -->RP-151131
- 1764: 29/09/15: Compl:0%->95% 29/09/15: CD:Tue 15/09/15->Tue 15/12/15 29/09/15: Stat Rep: -->RP-151131
- 1765: 29/09/15: Compl:0%->95% 29/09/15: CD:Tue 15/09/15->Tue 15/12/15 29/09/15: Stat Rep: -->RP-151131

| ID | WBS | Task | Duration | Start | Finish | Complete | Constraint | Resources | Work | Actual work | Acronym | PCG approved | WI rapporteur name | Release | TSG approved | Status Report |
| --- | --- | --- | --- | --- | --- | --- | --- | --- | --- | --- | --- | --- | --- | --- | --- | --- |
| 1766 | 530.94 | **LTE Advanced 4 Band Carrier Aggregation (4DL/1UL) of Band 2, Band 4, Band 5 and Band 12** | 132d? | 2015-06-15 A | 2015-12-15 A | 100% |  | R4 | 3168h | 3168h | LTE_CA_B2_B4_B5_B12 | 35 | U.S. Cellular | Rel-13 | 68 |  |
| 1767 | 530.94.1 | Core part:LTE Advanced 4 Band Carrier Aggregation (4DL/1UL) of Band 2, Band 4, Band 5 and Band 12 | 132d? | 2015-06-15 A | 2015-12-15 A | 100% | finish no earlier than 2015-12-15 | R4 | 1056h | 1056h | LTE_CA_B2_B4_B5_B12-Core | 35 | U.S. Cellular | Rel-13 | 68 | RP-151131 |
| 1768 | 530.94.2 | Perf. part:LTE Advanced 4 Band Carrier Aggregation (4DL/1UL) of Band 2, Band 4, Band 5 and Band 12 | 132d? | 2015-06-15 A | 2015-12-15 A | 100% | finish no earlier than 2015-12-15 | R4 | 1056h | 1056h | LTE_CA_B2_B4_B5_B12-Perf | 35 | U.S. Cellular | Rel-13 | 68 | RP-151131 |
| 1769 | 530.95 | **LTE Advanced 4 Band Carrier Aggregation (4DL/1UL) of Band 2, Band 2, Band 4 and Band 5** | 132d? | 2015-06-15 A | 2015-12-15 A | 100% |  | R4 | 3168h | 3168h | LTE_CA_B2_B2_B4_B5 | 35 | U.S. Cellular | Rel-13 | 68 |  |
| 1770 | 530.95.1 | Core part:LTE Advanced 4 Band Carrier Aggregation (4DL/1UL) of Band 2, Band 2, Band 4 and Band 5 | 132d? | 2015-06-15 A | 2015-12-15 A | 100% | finish no earlier than 2015-12-15 | R4 | 1056h | 1056h | LTE_CA_B2_B2_B4_B5-Core | 35 | U.S. Cellular | Rel-13 | 68 | RP-151131 |
| 1771 | 530.95.2 | Perf. part:LTE Advanced 4 Band Carrier Aggregation (4DL/1UL) of Band 2, Band 2, Band 4 and Band 5 | 132d? | 2015-06-15 A | 2015-12-15 A | 100% | finish no earlier than 2015-12-15 | R4 | 1056h | 1056h | LTE_CA_B2_B2_B4_B5-Perf | 35 | U.S. Cellular | Rel-13 | 68 | RP-151131 |
| 1772 | 530.96 | **LTE Advanced 4-Band Carrier Aggregation (4DL/1UL) of Band 2, Band 2, Band 12 and Band 12** | 132d? | 2015-06-15 A | 2015-12-15 A | 100% |  | R4 | 3168h | 3168h | LTE_CA_B2_B2_B12_B12 | 35 | U.S. Cellular | Rel-13 | 68 |  |
| 1773 | 530.96.1 | Core part:LTE Advanced 4-Band Carrier Aggregation (4DL/1UL) of Band 2, Band 2, Band 12 and Band 12 | 132d? | 2015-06-15 A | 2015-12-15 A | 100% | finish no earlier than 2015-12-15 | R4 | 1056h | 1056h | LTE_CA_B2_B2_B12_B12-Core | 35 | U.S. Cellular | Rel-13 | 68 | RP-151131 |
| 1774 | 530.96.2 | Perf. part:LTE Advanced 4-Band Carrier Aggregation (4DL/1UL) of Band 2, Band 2, Band 12 and Band 12 | 132d? | 2015-06-15 A | 2015-12-15 A | 100% | finish no earlier than 2015-12-15 | R4 | 1056h | 1056h | LTE_CA_B2_B2_B12_B12-Perf | 35 | U.S. Cellular | Rel-13 | 68 | RP-151131 |
| 1775 | 530.97 | **LTE Advanced 4 Band Carrier Aggregation (4DL/1UL) of Band 4, Band 4, Band 5 and Band 30** | 197d? | 2015-06-15 A | 2016-03-15 A | 100% |  | R4 | 4728h | 4728h | LTE_CA_B4_B4_B5_B30 | 35 | AT&T | Rel-13 | 68 |  |
| 1776 | 530.97.1 | Core part:LTE Advanced 4 Band Carrier Aggregation (4DL/1UL) of Band 4, Band 4, Band 5 and Band 30 | 197d? | 2015-06-15 A | 2016-03-15 A | 100% | finish no earlier than 2016-03-15 | R4 | 1576h | 1576h | LTE_CA_B4_B4_B5_B30-Core | 35 | AT&T | Rel-13 | 68 | RP-151131 |
| 1777 | 530.97.2 | Perf. part:LTE Advanced 4 Band Carrier Aggregation (4DL/1UL) of Band 4, Band 4, Band 5 and Band 30 | 197d? | 2015-06-15 A | 2016-03-15 A | 100% | finish no earlier than 2016-03-15 | R4 | 1576h | 1576h | LTE_CA_B4_B4_B5_B30-Perf | 35 | AT&T | Rel-13 | 68 | RP-151131 |
| 1778 | 530.98 | **LTE Advanced 4 Band Carrier Aggregation (4DL/1UL) of Band 4, Band 4, Band 12 and Band 30** | 197d? | 2015-06-15 A | 2016-03-15 A | 100% |  | R4 | 4728h | 4728h | LTE_CA_B4_B4_B12_B30 | 35 | AT&T | Rel-13 | 68 |  |
| 1779 | 530.98.1 | Core part:LTE Advanced 4 Band Carrier Aggregation (4DL/1UL) of Band 4, Band 4, Band 12 and Band 30 | 197d? | 2015-06-15 A | 2016-03-15 A | 100% | finish no earlier than 2016-03-15 | R4 | 1576h | 1576h | LTE_CA_B4_B4_B12_B30-Core | 35 | AT&T | Rel-13 | 68 | RP-151131 |
| 1780 | 530.98.2 | Perf. part:LTE Advanced 4 Band Carrier Aggregation (4DL/1UL) of Band 4, Band 4, Band 12 and Band 30 | 197d? | 2015-06-15 A | 2016-03-15 A | 100% | finish no earlier than 2016-03-15 | R4 | 1576h | 1576h | LTE_CA_B4_B4_B12_B30-Perf | 35 | AT&T | Rel-13 | 68 | RP-151131 |
| 1781 | 530.99 | **LTE Advanced 4 Band Carrier Aggregation (4DL/1UL) of Band 4, Band 4, Band 29 and Band 30** | 197d? | 2015-06-15 A | 2016-03-15 A | 100% |  | R4 | 4728h | 4728h | LTE_CA_B4_B4_B29_B30 | 35 | AT&T | Rel-13 | 68 |  |
| 1782 | 530.99.1 | Core part:LTE Advanced 4 Band Carrier Aggregation (4DL/1UL) of Band 4, Band 4, Band 29 and Band 30 | 197d? | 2015-06-15 A | 2016-03-15 A | 100% | finish no earlier than 2016-03-15 | R4 | 1576h | 1576h | LTE_CA_B4_B4_B29_B30-Core | 35 | AT&T | Rel-13 | 68 | RP-151131 |
| 1783 | 530.99.2 | Perf. part:LTE Advanced 4 Band Carrier Aggregation (4DL/1UL) of Band 4, Band 4, Band 29 and Band 30 | 197d? | 2015-06-15 A | 2016-03-15 A | 100% | finish no earlier than 2016-03-15 | R4 | 1576h | 1576h | LTE_CA_B4_B4_B29_B30-Perf | 35 | AT&T | Rel-13 | 68 | RP-151131 |
| 1784 | 530.100 | **LTE Advanced 4 Band Carrier Aggregation (4DL/1UL) of Band 2, Band 2, Band 5 and Band 12** | 132d? | 2015-06-15 A | 2015-12-15 A | 100% |  | R4 | 3168h | 3168h | LTE_CA_B2_B2_B5_B12 | 35 | U.S. Cellular | Rel-13 | 68 |  |
| 1785 | 530.100.1 | Core part:LTE Advanced 4 Band Carrier Aggregation (4DL/1UL) of Band 2, Band 2, Band 5 and Band 12 | 132d? | 2015-06-15 A | 2015-12-15 A | 100% | finish no earlier than 2015-12-15 | R4 | 1056h | 1056h | LTE_CA_B2_B2_B5_B12-Core | 35 | U.S. Cellular | Rel-13 | 68 | RP-151131 |
| 1786 | 530.100.2 | Perf. part:LTE Advanced 4 Band Carrier Aggregation (4DL/1UL) of Band 2, Band 2, Band 5 and Band 12 | 132d? | 2015-06-15 A | 2015-12-15 A | 100% | finish no earlier than 2015-12-15 | R4 | 1056h | 1056h | LTE_CA_B2_B2_B5_B12-Perf | 35 | U.S. Cellular | Rel-13 | 68 | RP-151131 |
| 1787 | 530.101 | **LTE Advanced 4 Band Carrier Aggregation (4DL/1UL) of Band 2, Band 5, Band 12 and Band 12** | 132d? | 2015-06-15 A | 2015-12-15 A | 100% |  | R4 | 3168h | 3168h | LTE_CA_B2_B5_B12_B12 | 35 | U.S. Cellular | Rel-13 | 68 |  |
| 1788 | 530.101.1 | Core part:LTE Advanced 4 Band Carrier Aggregation (4DL/1UL) of Band 2, Band 5, Band 12 and Band 12 | 132d? | 2015-06-15 A | 2015-12-15 A | 100% | finish no earlier than 2015-12-15 | R4 | 1056h | 1056h | LTE_CA_B2_B5_B12_B12-Core | 35 | U.S. Cellular | Rel-13 | 68 | RP-151131 |
| 1789 | 530.101.2 | Perf. part:LTE Advanced 4 Band Carrier Aggregation (4DL/1UL) of Band 2, Band 5, Band 12 and Band 12 | 132d? | 2015-06-15 A | 2015-12-15 A | 100% | finish no earlier than 2015-12-15 | R4 | 1056h | 1056h | LTE_CA_B2_B5_B12_B12-Perf | 35 | U.S. Cellular | Rel-13 | 68 | RP-151131 |

Notes:
- 1767: 29/09/15: Compl:0%->40% 29/09/15: Stat Rep: -->RP-151131
- 1768: 29/09/15: Compl:0%->40% 29/09/15: Stat Rep: -->RP-151131
- 1770: 29/09/15: Compl:0%->40% 29/09/15: Stat Rep: -->RP-151131
- 1771: 29/09/15: Compl:0%->40% 29/09/15: Stat Rep: -->RP-151131
- 1773: 29/09/15: Compl:0%->40% 29/09/15: Stat Rep: -->RP-151131
- 1774: 29/09/15: Compl:0%->40% 29/09/15: Stat Rep: -->RP-151131
- 1776: 29/09/15: Stat Rep: -->RP-151131 22/3/16: Compl:50%->100%
- 1777: 29/09/15: Stat Rep: -->RP-151131 ; 22/3/16: Compl:50%->100%
- 1779: 29/09/15: Stat Rep: -->RP-151131 22/3/16: Compl:50%->100%
- 1780: 29/09/15: Stat Rep: -->RP-151131 22/3/16: Compl:50%->100%
- 1782: 29/09/15: Stat Rep: -->RP-151131 ; 22/3/16: Compl:50%->100%
- 1783: 29/09/15: Stat Rep: -->RP-151131 22/3/16: Compl:50%->100%
- 1785: 29/09/15: Compl:0%->40% 29/09/15: Stat Rep: -->RP-151131
- 1786: 29/09/15: Compl:0%->40% 29/09/15: Stat Rep: -->RP-151131
- 1788: 29/09/15: Compl:0%->40% 29/09/15: Stat Rep: -->RP-151131
- 1789: 29/09/15: Compl:0%->40% 29/09/15: Stat Rep: -->RP-151131

| ID | WBS | Task | Duration | Start | Finish | Complete | Constraint | Resources | Work | Actual work | Acronym | PCG approved | WI rapporteur name | Release | TSG approved | Status Report | Impacted TSs and TRs |
| --- | --- | --- | --- | --- | --- | --- | --- | --- | --- | --- | --- | --- | --- | --- | --- | --- | --- |
| 1790 | 530.102 | **LTE Advanced 3DL/2UL mixed intra- and inter-band Carrier Aggregation** | 132d? | 2015-06-15 A | 2015-12-15 A | 100% |  | R4 | 3168h | 3168h | LTE_CA_3DL_2UL_inter_intra | 35 | Nokia Networks | Rel-14 | 68 |  |  |
| 1791 | 530.102.1 | Core part:LTE Advanced 3DL/2UL mixed intra- and inter-band Carrier Aggregation | 132d? | 2015-06-15 A | 2015-12-15 A | 100% | finish no earlier than 2015-12-15 | R4 | 1056h | 1056h | LTE_CA_3DL_2UL_inter_intra-Core | 35 | Nokia Networks | Rel-13 | 68 | RP-151131 |  |
| 1792 | 530.102.2 | Perf. part:LTE Advanced 3DL/2UL mixed intra- and inter-band Carrier Aggregation | 132d? | 2015-06-15 A | 2015-12-15 A | 100% | finish no earlier than 2015-12-15 | R4 | 1056h | 1056h | LTE_CA_3DL_2UL_inter_intra-Perf | 35 | Nokia Networks | Rel-13 | 68 | RP-151131 |  |
| 1793 | 530.103 | **LTE Advanced intra-band contiguous Carrier Aggregation in Band 5** | 132d? | 2015-06-15 A | 2015-12-15 A | 100% |  | R4 | 3168h | 3168h | LTE_CA_C_B5 | 35 | Intel | Rel-13 | 68 |  |  |
| 1794 | 530.103.1 | Core part: LTE Advanced intra-band contiguous Carrier Aggregation in Band 5 | 132d? | 2015-06-15 A | 2015-12-15 A | 100% | finish no earlier than 2015-12-15 | R4 | 1056h | 1056h | LTE_CA_C_B5-Core | 35 | Intel | Rel-13 | 68 | RP-151131 |  |
| 1795 | 530.103.2 | Perf. part: LTE Advanced intra-band contiguous Carrier Aggregation in Band 5 | 132d? | 2015-06-15 A | 2015-12-15 A | 100% | finish no earlier than 2015-12-15 | R4 | 1056h | 1056h | LTE_CA_C_B5-Perf | 35 | Intel | Rel-13 | 68 | RP-151131 |  |
| 1796 | 530.104 | **Additional bandwidth combination set for LTE Advanced intra-band non-contiguous Carrier Aggregation in Band 4** | 67d? | 2015-06-15 A | 2015-09-15 A | 100% |  | R4 | 1608h | 1608h | LTE_CA_NC_B4_BWset | 35 | Nokia Networks | Rel-13 | 68 |  |  |
| 1797 | 530.104.1 | Core part: Additional bandwidth combination set for LTE Advanced intra-band non-contiguous Carrier Aggregation in Band 4 | 67d? | 2015-06-15 A | 2015-09-15 A | 100% | finish no earlier than 2015-09-15 | R4 | 536h | 536h | LTE_CA_NC_B4_BWset-Core | 35 | Nokia Networks | Rel-13 | 68 | RP-151131 |  |
| 1798 | 530.104.2 | Perf. part: Additional bandwidth combination set for LTE Advanced intra-band non-contiguous Carrier Aggregation in Band 4 | 67d? | 2015-06-15 A | 2015-09-15 A | 100% | finish no earlier than 2015-09-15 | R4 | 536h | 536h | LTE_CA_NC_B4_BWset-Perf | 35 | Nokia Networks | Rel-13 | 68 | RP-151131 |  |
| 1799 | 530.105 | **LTE Advanced intra-band non-contiguous Carrier Aggregation in Band 5** | 132d? | 2015-06-15 A | 2015-12-15 A | 100% |  | R4 | 3168h | 3168h | LTE_CA_NC_B5 | 35 | Intel | Rel-13 | 68 |  |  |
| 1800 | 530.105.1 | Core part:LTE Advanced intra-band non-contiguous Carrier Aggregation in Band 5 | 132d? | 2015-06-15 A | 2015-12-15 A | 100% | finish no earlier than 2015-12-15 | R4 | 1056h | 1056h | LTE_CA_NC_B5-Core | 35 | Intel | Rel-13 | 68 | RP-151131 |  |
| 1801 | 530.105.2 | Perf. part:LTE Advanced intra-band non-contiguous Carrier Aggregation in Band 5 | 132d? | 2015-06-15 A | 2015-12-15 A | 100% | finish no earlier than 2015-12-15 | R4 | 1056h | 1056h | LTE_CA_NC_B5-Perf | 35 | Intel | Rel-13 | 68 | RP-151131 |  |
| 1802 | 530.106 | **LTE Advanced intra-band non-contiguous Carrier Aggregation in Band 42 for 4DL** | 132d? | 2015-06-15 A | 2015-12-15 A | 100% |  | R4 | 3168h | 3168h | LTE_CA_NC_B42_4DL | 35 | Huawei | Rel-13 | 68 |  |  |
| 1803 | 530.106.1 | Core part:LTE Advanced intra-band non-contiguous Carrier Aggregation in Band 42 for 4DL | 132d? | 2015-06-15 A | 2015-12-15 A | 100% | finish no earlier than 2015-12-15 | R4 | 1056h | 1056h | LTE_CA_NC_B42_4DL-Core | 35 | Huawei | Rel-13 | 68 | RP-151131 |  |
| 1804 | 530.106.2 | Perf. part:LTE Advanced intra-band non-contiguous Carrier Aggregation in Band 42 for 4DL | 132d? | 2015-06-15 A | 2015-12-15 A | 100% | finish no earlier than 2015-12-15 | R4 | 1056h | 1056h | LTE_CA_NC_B42_4DL-Perf | 35 | Huawei | Rel-13 | 68 | RP-151131 |  |
| 1805 | 530.107 | **Additional bandwidth combination set for LTE Advanced inter-band Carrier Aggregation of Band 2 and Band 12** | 67d? | 2015-06-15 A | 2015-09-15 A | 100% |  | R4 | 1608h | 1608h | LTE_CA_B2_B12_BWset | 35 | Nokia Networks | Rel-13 | 68 |  |  |
| 1806 | 530.107.1 | Core part: Additional bandwidth combination set for LTE Advanced inter-band Carrier Aggregation of Band 2 and Band 12 | 67d? | 2015-06-15 A | 2015-09-15 A | 100% | finish no earlier than 2015-09-15 | R4 | 536h | 536h | LTE_CA_B2_B12_BWset-Core | 35 | Nokia Networks | Rel-13 | 68 | RP-151131 |  |
| 1807 | 530.107.2 | Perf. part: Additional bandwidth combination set for LTE Advanced inter-band Carrier Aggregation of Band 2 and Band 12 | 67d? | 2015-06-15 A | 2015-09-15 A | 100% | finish no earlier than 2015-09-15 | R4 | 536h | 536h | LTE_CA_B2_B12_BWset-Perf | 35 | Nokia Networks | Rel-13 | 68 | RP-151131 |  |
| 1808 | 530.108 | **Additional bandwidth combination set 2 for LTE Advanced inter-band Carrier Aggregation of Band 4 and Band 12** | 67d? | 2015-06-15 A | 2015-09-15 A | 100% |  | R4 | 1608h | 1608h | LTE_CA_B4_B12_BWset2 | 35 | Nokia Networks | Rel-13 | 68 |  |  |
| 1809 | 530.108.1 | Core part: Additional bandwidth combination set 2 for LTE Advanced inter-band Carrier Aggregation of Band 4 and Band 12 | 67d? | 2015-06-15 A | 2015-09-15 A | 100% | finish no earlier than 2015-09-15 | R4 | 536h | 536h | LTE_CA_B4_B12_BWset2-Core | 35 | Nokia Networks | Rel-13 | 68 | RP-151131 |  |
| 1810 | 530.108.2 | Perf. part: Additional bandwidth combination set 2 for LTE Advanced inter-band Carrier Aggregation of Band 4 and Band 12 | 67d? | 2015-06-15 A | 2015-09-15 A | 100% | finish no earlier than 2015-09-15 | R4 | 536h | 536h | LTE_CA_B4_B12_BWset2-Perf | 35 | Nokia Networks | Rel-13 | 68 | RP-151131 |  |
| 1811 | 530.109 | **Introduction of 1447-1467MHz Band for TD-LTE in China** | 330d? | 2015-06-15 A | 2016-09-15 A | 100% |  | R4 | 5824h | 5824h | LTE_TDD_1447MHz_China | 35 | Huawei | Rel-13 | 68 |  |  |
| 1812 | 530.109.1 | Core part: Introduction of 1447-1467MHz Band for TD-LTE in China | 132d? | 2015-06-15 A | 2015-12-15 A | 100% | finish no earlier than 2015-12-15 | R4 | 1056h | 1056h | LTE_TDD_1447MHz_China-Core | 35 | Huawei | Rel-13 | 68 | RP-151242 | 36.892 |
| 1813 | 530.109.2 | Perf. part: Introduction of 1447-1467MHz Band for TD-LTE in China | 132d? | 2015-06-15 A | 2015-12-15 A | 100% | finish no earlier than 2016-03-15 | R4 | 1056h | 1056h | LTE_TDD_1447MHz_China-Perf | 35 | Huawei | Rel-13 | 68 | RP-151242 |  |
| 1814 | 530.109.3 | UE Conformance Test Aspects - Introduction of 1447-1467MHz Band for TD-LTE in China | 134d? | 2016-03-15 A | 2016-09-15 A | 100% | finish no earlier than 2016-09-15 | R5 | 1072h | 1072h | LTE_TDD_1447MHz_China-UEConTest | 36 | Huawei | Rel-13 | 71 |  |  |

Notes:
- 1790: covers combinations of contiguous intra-band CA and inter-band CA or combinations of non-contiguous intra-band CA and inter-band CA for LTE; pure intra-band CA combinations are also covered by this WI; note: There is already a REL-13 WI LTE_CA_3DL_2UL whi
- 1791: covers combinations of contiguous intra-band CA and inter-band CA or combinations of non-contiguous intra-band CA and inter-band CA for LTE; pure intra-band CA combinations are also covered by this WI; note: There is already a REL-13 WI LTE_CA_3DL_2UL
- 1792: covers combinations of contiguous intra-band CA and inter-band CA or combinations of non-contiguous intra-band CA and inter-band CA for LTE; pure intra-band CA combinations are also covered by this WI; note: There is already a REL-13 WI LTE_CA_3DL_2UL
- 1794: 29/09/15: Compl:0%->20% 29/09/15: Stat Rep: -->RP-151131
- 1795: 29/09/15: Compl:0%->20% 29/09/15: Stat Rep: -->RP-151131
- 1796: LTE_CA_NC_B4 was completed in REL-12
- 1797: LTE_CA_NC_B4 was completed in REL-12 29/09/15: Compl:0%->100% 29/09/15: Stat Rep: -->RP-151131
- 1798: LTE_CA_NC_B4 was completed in REL-12 29/09/15: Compl:0%->100% 29/09/15: Stat Rep: -->RP-151131
- 1800: 29/09/15: Compl:0%->20% 29/09/15: Stat Rep: -->RP-151131
- 1801: 29/09/15: Compl:0%->20% 29/09/15: Stat Rep: -->RP-151131
- 1803: 29/09/15: Compl:0%->50% 29/09/15: Stat Rep: -->RP-151131
- 1804: 29/09/15: Stat Rep: -->RP-151131
- 1805: LTE_CA_B2_B12 was completed as REL-12 WI
- 1806: LTE_CA_B2_B12 was completed as REL-12 WI 29/09/15: Compl:0%->100% 29/09/15: Stat Rep: -->RP-151131
- 1807: LTE_CA_B2_B12 was completed as REL-12 WI 29/09/15: Compl:0%->100% 29/09/15: Stat Rep: -->RP-151131
- 1808: LTE_CA_B4_B12 was completed in REL-11 and LTE_CA_B4_B12_BWset was completed in REL-12
- 1809: LTE_CA_B4_B12 was completed in REL-11 and LTE_CA_B4_B12_BWset was completed in REL-12 29/09/15: Compl:0%->100% 29/09/15: Stat Rep: -->RP-151131
- 1810: LTE_CA_B4_B12 was completed in REL-11 and LTE_CA_B4_B12_BWset was completed in REL-12 29/09/15: Compl:0%->100% 29/09/15: Stat Rep: -->RP-151131
- 1811: Aug 15: TR numb added
- 1812: Aug 15: TR numb added 29/09/15: Compl:0%->20% 29/09/15: Stat Rep: -->RP-151242
- 1813: 29/09/15: Stat Rep: -->RP-151242
- 1814: testing REL-13 LTE_TDD_1447MHz_China-Core; 1/7/16: C;

| ID | WBS | Task | Duration | Start | Finish | Complete | Constraint | Resources | Work | Actual work | Acronym | PCG approved | WI rapporteur name | Release | TSG approved | Status Report |
| --- | --- | --- | --- | --- | --- | --- | --- | --- | --- | --- | --- | --- | --- | --- | --- | --- |
| 1815 | 530.110 | **LTE Advanced 4 Band Carrier Aggregation (4DL/1UL) of Band 41, Band 41, Band 42 and Band 42** | 132d? | 2015-06-15 A | 2015-12-15 A | 100% |  | R4 | 3168h | 3168h | LTE_CA_B41_B41_B42_B42 | 35 | ZTE | Rel-13 | 68 |  |
| 1816 | 530.110.1 | Core part:LTE Advanced 4 Band Carrier Aggregation (4DL/1UL) of Band 41, Band 41, Band 42 and Band 42 | 132d? | 2015-06-15 A | 2015-12-15 A | 100% | finish no earlier than 2015-12-15 | R4 | 1056h | 1056h | LTE_CA_B41_B41_B42_B42-Core | 35 | ZTE | Rel-13 | 68 | RP-151131 |
| 1817 | 530.110.2 | Perf. part:LTE Advanced 4 Band Carrier Aggregation (4DL/1UL) of Band 41, Band 41, Band 42 and Band 42 | 132d? | 2015-06-15 A | 2015-12-15 A | 100% | finish no earlier than 2015-12-15 | R4 | 1056h | 1056h | LTE_CA_B41_B41_B42_B42-Perf | 35 | ZTE | Rel-13 | 68 | RP-151131 |
| 1818 | 530.111 | **LTE Advanced inter-band Carrier Aggregation for Band 5 and Band 38** | 66d? | 2015-09-15 A | 2015-12-15 A | 100% |  | R4 | 1584h | 1584h | LTE_CA_B5_B38 | 35 | Huawei | Rel-13 | 69 |  |
| 1819 | 530.111.1 | Core part:LTE Advanced inter-band Carrier Aggregation for Band 5 and Band 38 | 66d? | 2015-09-15 A | 2015-12-15 A | 100% | finish no earlier than 2015-12-15 | R4 | 528h | 528h | LTE_CA_B5_B38-Core | 35 | Huawei | Rel-13 | 69 |  |
| 1820 | 530.111.2 | Perf. part:LTE Advanced inter-band Carrier Aggregation for Band 5 and Band 38 | 66d? | 2015-09-15 A | 2015-12-15 A | 100% | finish no earlier than 2015-12-15 | R4 | 528h | 528h | LTE_CA_B5_B38-Perf | 35 | Huawei | Rel-13 | 69 |  |
| 1821 | 530.112 | **LTE Advanced 3 Band Carrier Aggregation (3DL/1UL) of Band 1, Band 11 and Band 18** | 66d? | 2015-09-15 A | 2015-12-15 A | 100% |  | R4 | 1584h | 1584h | LTE_CA_B1_B11_B18 | 35 | KDDI | Rel-13 | 69 |  |
| 1822 | 530.112.1 | Core part:LTE Advanced 3 Band Carrier Aggregation (3DL/1UL) of Band 1, Band 11 and Band 18 | 66d? | 2015-09-15 A | 2015-12-15 A | 100% | finish no earlier than 2015-12-15 | R4 | 528h | 528h | LTE_CA_B1_B11_B18-Core | 35 | KDDI | Rel-13 | 69 |  |
| 1823 | 530.112.2 | Perf. part:LTE Advanced 3 Band Carrier Aggregation (3DL/1UL) of Band 1, Band 11 and Band 18 | 66d? | 2015-09-15 A | 2015-12-15 A | 100% | finish no earlier than 2015-12-15 | R4 | 528h | 528h | LTE_CA_B1_B11_B18-Perf | 35 | KDDI | Rel-13 | 69 |  |
| 1824 | 530.113 | **LTE Advanced 3 Band Carrier Aggregation (3DL/1UL) of Band 5, Band 40, and Band 40** | 66d? | 2015-09-15 A | 2015-12-15 A | 100% |  | R4 | 1584h | 1584h | LTE_CA_B5_B40_B40 | 35 | ZTE | Rel-13 | 69 |  |
| 1825 | 530.113.1 | Core part:LTE Advanced 3 Band Carrier Aggregation (3DL/1UL) of Band 5, Band 40, and Band 40 | 66d? | 2015-09-15 A | 2015-12-15 A | 100% | finish no earlier than 2015-12-15 | R4 | 528h | 528h | LTE_CA_B5_B40_B40-Core | 35 | ZTE | Rel-13 | 69 |  |
| 1826 | 530.113.2 | Perf. part:LTE Advanced 3 Band Carrier Aggregation (3DL/1UL) of Band 5, Band 40, and Band 40 | 66d? | 2015-09-15 A | 2015-12-15 A | 100% | finish no earlier than 2015-12-15 | R4 | 528h | 528h | LTE_CA_B5_B40_B40-Perf | 35 | ZTE | Rel-13 | 69 |  |
| 1827 | 530.114 | **LTE Advanced 3 Band Carrier Aggregation (3DL/1UL) for Band 3, Band 41 and Band 42** | 66d? | 2015-09-15 A | 2015-12-15 A | 100% |  | R4 | 1584h | 1584h | LTE_CA_B3_B41_B42 | 35 | Huawei | Rel-13 | 69 |  |
| 1828 | 530.114.1 | Core part:LTE Advanced 3 Band Carrier Aggregation (3DL/1UL) for Band 3, Band 41 and Band 42 | 66d? | 2015-09-15 A | 2015-12-15 A | 100% | finish no earlier than 2015-12-15 | R4 | 528h | 528h | LTE_CA_B3_B41_B42-Core | 35 | Huawei | Rel-13 | 69 |  |
| 1829 | 530.114.2 | Perf. part:LTE Advanced 3 Band Carrier Aggregation (3DL/1UL) for Band 3, Band 41 and Band 42 | 66d? | 2015-09-15 A | 2015-12-15 A | 100% | finish no earlier than 2015-12-15 | R4 | 528h | 528h | LTE_CA_B3_B41_B42-Perf | 35 | Huawei | Rel-13 | 69 |  |
| 1830 | 530.115 | **LTE Advanced 3 Band Carrier Aggregation (3DL/1UL) of Band 3, Band 41, and Band 41** | 66d? | 2015-09-15 A | 2015-12-15 A | 100% |  | R4 | 1584h | 1584h | LTE_CA_B3_B41_B41 | 35 | ZTE | Rel-13 | 69 |  |
| 1831 | 530.115.1 | Core part:LTE Advanced 3 Band Carrier Aggregation (3DL/1UL) of Band 3, Band 41, and Band 41 | 66d? | 2015-09-15 A | 2015-12-15 A | 100% | finish no earlier than 2015-12-15 | R4 | 528h | 528h | LTE_CA_B3_B41_B41-Core | 35 | ZTE | Rel-13 | 69 |  |
| 1832 | 530.115.2 | Perf. part:LTE Advanced 3 Band Carrier Aggregation (3DL/1UL) of Band 3, Band 41, and Band 41 | 66d? | 2015-09-15 A | 2015-12-15 A | 100% | finish no earlier than 2015-12-15 | R4 | 528h | 528h | LTE_CA_B3_B41_B41-Perf | 35 | ZTE | Rel-13 | 69 |  |
| 1833 | 530.116 | **LTE Advanced 4 Band Carrier Aggregation (4DL1UL) of Band 39, Band 41, Band 41 and Band 41** | 66d? | 2015-09-15 A | 2015-12-15 A | 100% |  | R4 | 1584h | 1584h | LTE_CA_B39_B41_B41_B41 | 35 | CMCC | Rel-13 | 69 |  |
| 1834 | 530.116.1 | Core part:LTE Advanced 4 Band Carrier Aggregation (4DL1UL) of Band 39, Band 41, Band 41 and Band 41 | 66d? | 2015-09-15 A | 2015-12-15 A | 100% | finish no earlier than 2015-12-15 | R4 | 528h | 528h | LTE_CA_B39_B41_B41_B41-Core | 35 | CMCC | Rel-13 | 69 |  |
| 1835 | 530.116.2 | Perf. part:LTE Advanced 4 Band Carrier Aggregation (4DL1UL) of Band 39, Band 41, Band 41 and Band 41 | 66d? | 2015-09-15 A | 2015-12-15 A | 100% | finish no earlier than 2015-12-15 | R4 | 528h | 528h | LTE_CA_B39_B41_B41_B41-Perf | 35 | CMCC | Rel-13 | 69 |  |
| 1836 | 530.117 | **LTE Advanced 4 Band Carrier Aggregation (4DL1UL) of Band 39, Band 39, Band 41 and Band 41** | 66d? | 2015-09-15 A | 2015-12-15 A | 100% |  | R4 | 1584h | 1584h | LTE_CA_B39_B39_B41_B41 | 35 | CMCC | Rel-13 | 69 |  |
| 1837 | 530.117.1 | Core part:LTE Advanced 4 Band Carrier Aggregation (4DL1UL) of Band 39, Band 39, Band 41 and Band 41 | 66d? | 2015-09-15 A | 2015-12-15 A | 100% | finish no earlier than 2015-12-15 | R4 | 528h | 528h | LTE_CA_B39_B39_B41_B41-Core | 35 | CMCC | Rel-13 | 69 |  |
| 1838 | 530.117.2 | Perf. part:LTE Advanced 4 Band Carrier Aggregation (4DL1UL) of Band 39, Band 39, Band 41 and Band 41 | 66d? | 2015-09-15 A | 2015-12-15 A | 100% | finish no earlier than 2015-12-15 | R4 | 528h | 528h | LTE_CA_B39_B39_B41_B41-Perf | 35 | CMCC | Rel-13 | 69 |  |

Notes:
- 1816: 29/09/15: Compl:0%->40% 29/09/15: WID: RP-150627->RP-151562 29/09/15: Stat Rep: ->RP-151131
- 1817: 29/09/15: Compl:0%->40% 29/09/15: WID: RP-150627->RP-151562 29/09/15: Stat Rep: ->RP-151131
- 1819: 1/1/16: Compl:0%->100%
- 1820: ; 1/1/16: Compl:0%->100%
- 1822: ; 1/1/16: Compl:0%->100%
- 1823: 1/1/16: Compl:0%->100%
- 1825: 1/1/16: Compl:0%->100%
- 1826: 1/1/16: Compl:0%->100%
- 1828: 1/1/16: Compl:0%->100%
- 1829: ; 1/1/16: Compl:0%->100%
- 1831: ; 1/1/16: Compl:0%->100%
- 1832: 1/1/16: Compl:0%->100%

| ID | WBS | Task | Duration | Start | Finish | Complete | Constraint | Resources | Work | Actual work | Acronym | PCG approved | WI rapporteur name | Release | TSG approved | Impacted TSs and TRs |
| --- | --- | --- | --- | --- | --- | --- | --- | --- | --- | --- | --- | --- | --- | --- | --- | --- |
| 1839 | 530.118 | **LTE Advanced 4 Band Carrier Aggregation (4DL/1UL) of Band 1, Band 3, Band 8 and Band 40** | 66d? | 2015-09-15 A | 2015-12-15 A | 100% |  | R4 | 1584h | 1584h | LTE_CA_B1_B3_B8_B40 | 35 | KT | Rel-13 | 69 |  |
| 1840 | 530.118.1 | Core part:LTE Advanced 4 Band Carrier Aggregation (4DL/1UL) of Band 1, Band 3, Band 8 and Band 40 | 66d? | 2015-09-15 A | 2015-12-15 A | 100% | finish no earlier than 2015-12-15 | R4 | 528h | 528h | LTE_CA_B1_B3_B8_B40-Core | 35 | KT | Rel-13 | 69 |  |
| 1841 | 530.118.2 | Perf. part:LTE Advanced 4 Band Carrier Aggregation (4DL/1UL) of Band 1, Band 3, Band 8 and Band 40 | 66d? | 2015-09-15 A | 2015-12-15 A | 100% | finish no earlier than 2015-12-15 | R4 | 528h | 528h | LTE_CA_B1_B3_B8_B40-Perf | 35 | KT | Rel-13 | 69 |  |
| 1842 | 530.119 | **LTE Advanced 4 Band Carrier Aggregation (4DL/1UL) for Band 3, Band 28, Band 40 and Band 40** | 66d? | 2015-09-15 A | 2015-12-15 A | 100% |  | R4 | 1584h | 1584h | LTE_CA_B3_B28_B40_B40 | 35 | Huawei | Rel-13 | 69 |  |
| 1843 | 530.119.1 | Core part:LTE Advanced 4 Band Carrier Aggregation (4DL/1UL) for Band 3, Band 28, Band 40 and Band 40 | 66d? | 2015-09-15 A | 2015-12-15 A | 100% | finish no earlier than 2015-12-15 | R4 | 528h | 528h | LTE_CA_B3_B28_B40_B40-Core | 35 | Huawei | Rel-13 | 69 |  |
| 1844 | 530.119.2 | Perf. part:LTE Advanced 4 Band Carrier Aggregation (4DL/1UL) for Band 3, Band 28, Band 40 and Band 40 | 66d? | 2015-09-15 A | 2015-12-15 A | 100% | finish no earlier than 2015-12-15 | R4 | 528h | 528h | LTE_CA_B3_B28_B40_B40-Perf | 35 | Huawei | Rel-13 | 69 |  |
| 1845 | 530.120 | **LTE Advanced 4 Band Carrier Aggregation (4DL/1UL) for Band 28, Band 40, Band 40 and Band 40** | 66d? | 2015-09-15 A | 2015-12-15 A | 100% |  | R4 | 1584h | 1584h | LTE_CA_B28_B40_B40_B40 | 35 | Huawei | Rel-13 | 69 |  |
| 1846 | 530.120.1 | Core part:LTE Advanced 4 Band Carrier Aggregation (4DL/1UL) for Band 28, Band 40, Band 40 and Band 40 | 66d? | 2015-09-15 A | 2015-12-15 A | 100% | finish no earlier than 2015-12-15 | R4 | 528h | 528h | LTE_CA_B28_B40_B40_B40-Core | 35 | Huawei | Rel-13 | 69 |  |
| 1847 | 530.120.2 | Perf. part:LTE Advanced 4 Band Carrier Aggregation (4DL/1UL) for Band 28, Band 40, Band 40 and Band 40 | 66d? | 2015-09-15 A | 2015-12-15 A | 100% | finish no earlier than 2015-12-15 | R4 | 528h | 528h | LTE_CA_B28_B40_B40_B40-Perf | 35 | Huawei | Rel-13 | 69 |  |
| 1848 | 530.121 | **LTE Advanced 4 Band Carrier Aggregation (4DL/1UL) of Band 3, Band 7, Band 7 and Band 28** | 66d? | 2015-09-15 A | 2015-12-15 A | 100% |  | R4 | 1584h | 1584h | LTE_CA_B3_B7_B7_B28 | 35 | Telstra | Rel-13 | 69 |  |
| 1849 | 530.121.1 | Core part:LTE Advanced 4 Band Carrier Aggregation (4DL/1UL) of Band 3, Band 7, Band 7 and Band 28 | 66d? | 2015-09-15 A | 2015-12-15 A | 100% | finish no earlier than 2015-12-15 | R4 | 528h | 528h | LTE_CA_B3_B7_B7_B28-Core | 35 | Telstra | Rel-13 | 69 |  |
| 1850 | 530.121.2 | Perf. part:LTE Advanced 4 Band Carrier Aggregation (4DL/1UL) of Band 3, Band 7, Band 7 and Band 28 | 66d? | 2015-09-15 A | 2015-12-15 A | 100% | finish no earlier than 2015-12-15 | R4 | 528h | 528h | LTE_CA_B3_B7_B7_B28-Perf | 35 | Telstra | Rel-13 | 69 |  |
| 1851 | 530.122 | **LTE Advanced 5 Band Carrier Aggregation (5DL/1UL) of Band 1, Band 3, Band 19, Band 42 and Band 42** | 66d? | 2015-09-15 A | 2015-12-15 A | 100% |  | R4 | 1584h | 1584h | LTE_CA_B1_B3_B19_B42_B42 | 35 | NTT DOCOMO | Rel-13 | 69 | 36.857-13 |
| 1852 | 530.122.1 | Core part:LTE Advanced 5 Band Carrier Aggregation (5DL/1UL) of Band 1, Band 3, Band 19, Band 42 and Band 42 | 66d? | 2015-09-15 A | 2015-12-15 A | 100% | finish no earlier than 2015-12-15 | R4 | 528h | 528h | LTE_CA_B1_B3_B19_B42_B42-Core | 35 | NTT DOCOMO | Rel-13 | 69 | 36.857-13 |
| 1853 | 530.122.2 | Perf. part:LTE Advanced 5 Band Carrier Aggregation (5DL/1UL) of Band 1, Band 3, Band 19, Band 42 and Band 42 | 66d? | 2015-09-15 A | 2015-12-15 A | 100% | finish no earlier than 2015-12-15 | R4 | 528h | 528h | LTE_CA_B1_B3_B19_B42_B42-Perf | 35 | NTT DOCOMO | Rel-13 | 69 | 36.857-13 |
| 1854 | 530.123 | **LTE Advanced 5 Band Carrier Aggregation (5DL/1UL) of Band 1, Band 19, Band 21, Band 42 and Band 42** | 66d? | 2015-09-15 A | 2015-12-15 A | 100% |  | R4 | 1584h | 1584h | LTE_CA_B1_B19_B21_B42_B42 | 35 | NTT DOCOMO | Rel-13 | 69 |  |
| 1855 | 530.123.1 | Core part:LTE Advanced 5 Band Carrier Aggregation (5DL/1UL) of Band 1, Band 19, Band 21, Band 42 and Band 42 | 66d? | 2015-09-15 A | 2015-12-15 A | 100% | finish no earlier than 2015-12-15 | R4 | 528h | 528h | LTE_CA_B1_B19_B21_B42_B42-Core | 35 | NTT DOCOMO | Rel-13 | 69 |  |
| 1856 | 530.123.2 | Perf. part:LTE Advanced 5 Band Carrier Aggregation (5DL/1UL) of Band 1, Band 19, Band 21, Band 42 and Band 42 | 66d? | 2015-09-15 A | 2015-12-15 A | 100% | finish no earlier than 2015-12-15 | R4 | 528h | 528h | LTE_CA_B1_B19_B21_B42_B42-Perf | 35 | NTT DOCOMO | Rel-13 | 69 |  |
| 1857 | 530.124 | **LTE Advanced 5 Band Carrier Aggregation (5DL/1UL) of Band 1, Band 3, Band 7, Band 7 and Band 28** | 131d? | 2015-09-15 A | 2016-03-15 A | 100% |  | R4 | 3144h | 3144h | LTE_CA_B1_B3_B7_B7_B28 | 35 | Telstra | Rel-13 | 69 |  |
| 1858 | 530.124.1 | Core part:LTE Advanced 5 Band Carrier Aggregation (5DL/1UL) of Band 1, Band 3, Band 7, Band 7 and Band 28 | 131d? | 2015-09-15 A | 2016-03-15 A | 100% | finish no earlier than 2016-03-15 | R4 | 1048h | 1048h | LTE_CA_B1_B3_B7_B7_B28-Core | 35 | Telstra | Rel-13 | 69 |  |
| 1859 | 530.124.2 | Perf. part:LTE Advanced 5 Band Carrier Aggregation (5DL/1UL) of Band 1, Band 3, Band 7, Band 7 and Band 28 | 131d? | 2015-09-15 A | 2016-03-15 A | 100% | finish no earlier than 2016-03-15 | R4 | 1048h | 1048h | LTE_CA_B1_B3_B7_B7_B28-Perf | 35 | Telstra | Rel-13 | 69 |  |
| 1860 | 530.125 | **LTE Advanced 5 Band Carrier Aggregation (5DL/1UL) of Band 3, Band 3, Band 7, Band 7 and Band 28** | 131d? | 2015-09-15 A | 2016-03-15 A | 100% |  | R4 | 3144h | 3144h | LTE_CA_B3_B3_B7_B7_B28 | 35 | Telstra | Rel-13 | 69 |  |
| 1861 | 530.125.1 | Core part:LTE Advanced 5 Band Carrier Aggregation (5DL/1UL) of Band 3, Band 3, Band 7, Band 7 and Band 28 | 131d? | 2015-09-15 A | 2016-03-15 A | 100% | finish no earlier than 2016-03-15 | R4 | 1048h | 1048h | LTE_CA_B3_B3_B7_B7_B28-Core | 35 | Telstra | Rel-13 | 69 |  |
| 1862 | 530.125.2 | Perf. part:LTE Advanced 5 Band Carrier Aggregation (5DL/1UL) of Band 3, Band 3, Band 7, Band 7 and Band 28 | 131d? | 2015-09-15 A | 2016-03-15 A | 100% | finish no earlier than 2016-03-15 | R4 | 1048h | 1048h | LTE_CA_B3_B3_B7_B7_B28-Perf | 35 | Telstra | Rel-13 | 69 |  |

Notes:
- 1840: ; 1/1
- 1841: 1
- 1858: ; 22/3/16: Compl:95%->100%;
- 1859: 22/3/16: Compl:95%->100%;
- 1861: 22/3/16: Compl:95%->100%
- 1862: ; 22/3/16: Compl:95%->100%

| ID | WBS | Task | Duration | Start | Finish | Complete | Remaining | Baseline start | Baseline finish | Baseline duration | Total slack | Constraint | Resources | Work | Actual work | Acronym | PCG approved | WI rapporteur name | Release | TSG approved | Impacted TSs and TRs | Status Report | WI rapporteur e-mail | Acronym_3GU_Export | Special Focus Doc | MCC resp |
| --- | --- | --- | --- | --- | --- | --- | --- | --- | --- | --- | --- | --- | --- | --- | --- | --- | --- | --- | --- | --- | --- | --- | --- | --- | --- | --- |
| 1863 | 530.126 | **LTE Advanced 3 Band Carrier Aggregation (3DL/3UL) of Band 39, Band 41 and Band 41** | 66d? | 2015-09-15 A | 2015-12-15 A | 100% |  |  |  |  |  |  | R4 | 1584h | 1584h | LTE_CA_3DL3UL_B39_B41_B41 | 35 | CATT | Rel-13 | 69 |  |  |  |  |  |  |
| 1864 | 530.126.1 | Core part:LTE Advanced 3 Band Carrier Aggregation (3DL/3UL) of Band 39, Band 41 and Band 41 | 66d? | 2015-09-15 A | 2015-12-15 A | 100% |  |  |  |  |  | finish no earlier than 2015-12-15 | R4 | 528h | 528h | LTE_CA_3DL3UL_B39_B41_B41-Core | 35 | CATT | Rel-13 | 69 |  |  |  |  |  |  |
| 1865 | 530.126.2 | Perf. part:LTE Advanced 3 Band Carrier Aggregation (3DL/3UL) of Band 39, Band 41 and Band 41 | 66d? | 2015-09-15 A | 2015-12-15 A | 100% |  |  |  |  |  | finish no earlier than 2015-12-15 | R4 | 528h | 528h | LTE_CA_3DL3UL_B39_B41_B41-Perf | 35 | CATT | Rel-13 | 69 |  |  |  |  |  |  |
| 1866 | 530.127 | **LTE Advanced 3 Band Carrier Aggregation (3DL/3UL) of Band 39, Band 39 and Band 41** | 66d? | 2015-09-15 A | 2015-12-15 A | 100% |  |  |  |  |  |  | R4 | 1584h | 1584h | LTE_CA_3DL3UL_B39_B39_B41 | 35 | CATT | Rel-13 | 69 | 36.899-13 |  |  |  |  |  |
| 1867 | 530.127.1 | Core part:LTE Advanced 3 Band Carrier Aggregation (3DL/3UL) of Band 39, Band 39 and Band 41 | 66d? | 2015-09-15 A | 2015-12-15 A | 100% |  |  |  |  |  | finish no earlier than 2015-12-15 | R4 | 528h | 528h | LTE_CA_3DL3UL_B39_B39_B41-Core | 35 | CATT | Rel-13 | 69 |  |  |  |  |  |  |
| 1868 | 530.127.2 | Perf. part:LTE Advanced 3 Band Carrier Aggregation (3DL/3UL) of Band 39, Band 39 and Band 41 | 66d? | 2015-09-15 A | 2015-12-15 A | 100% |  |  |  |  |  | finish no earlier than 2015-12-15 | R4 | 528h | 528h | LTE_CA_3DL3UL_B39_B39_B41-Perf | 35 | CATT | Rel-13 | 69 |  |  |  |  |  |  |
| 1869 | 530.128 | **Additional bandwidth combination set for LTE Advanced intra-band non-contiguous Carrier Aggregation in Band 7** | 66d? | 2015-09-15 A | 2015-12-15 A | 100% |  |  |  |  |  |  | R4 | 1584h | 1584h | LTE_CA_NC_B7_BWset | 35 | Huawei | Rel-13 | 69 |  |  |  |  |  |  |
| 1870 | 530.128.1 | Core part: Additional bandwidth combination set for LTE Advanced intra-band non-contiguous Carrier Aggregation in Band 7 | 66d? | 2015-09-15 A | 2015-12-15 A | 100% |  |  |  |  |  | finish no earlier than 2015-12-15 | R4 | 528h | 528h | LTE_CA_NC_B7_BWset-Core | 35 | Huawei | Rel-13 | 69 |  |  |  |  |  |  |
| 1871 | 530.128.2 | Perf. part: Additional bandwidth combination set for LTE Advanced intra-band non-contiguous Carrier Aggregation in Band 7 | 66d? | 2015-09-15 A | 2015-12-15 A | 100% |  |  |  |  |  | finish no earlier than 2015-12-15 | R4 | 528h | 528h | LTE_CA_NC_B7_BWset-Perf | 35 | Huawei | Rel-13 | 69 |  |  |  |  |  |  |
| 1872 | 530.129 | UE Conformance Test Aspects - Rel-13 LTE CA configurations | 655d? | 2015-12-15 A | 2018-06-15 | 67% | 216.15d? |  |  |  | 521d | finish no earlier than 2018-06-15 | R5 | 5240h | 3510.8h | LTE_CA_Rel13-UEConTest | 36 | Ericsson | Rel-13 | 70 |  |  |  |  |  |  |
| 1873 | 531 | (Small) Technical Enhancements and Improvements for Rel-13 | 593d? | 2013-09-18 A | 2015-12-21 A | 100% |  |  |  |  |  | finish no earlier than 2015-12-21 | SP; CP; RP; GP | 18976h | 18976h | TEI13 | 31 |  | Rel-13 | 61 |  | PCG-31 |  |  |  |  |
| 1874 | 532 | (Small) Test Technical Enhancements and Improvements for Rel-13 | 593d? | 2013-09-18 A | 2015-12-21 A | 100% |  |  |  |  |  | finish no earlier than 2015-12-21 | SP; CP; RP; GP | 18976h | 18976h | TEI13_Test | 31 |  | Rel-13 | 61 |  | PCG-31 |  |  |  |  |
| 1875 | 533 | Awaiting formal work item | 593d? | 2013-09-18 A | 2015-12-21 A | 100% |  |  |  |  |  | start no earlier than 2013-09-18 | SP; CP; RP; GP | 18976h | 18976h | DUMMY | 35 |  | Rel-13 | 69 |  |  |  |  |  |  |
| 1876 | 534 | (Small) Security Enhancements and Improvements for Rel-13 | 2372d? | 2006-12-12 A | 2015-12-21 A | 100% |  |  |  |  |  | finish no earlier than 2015-12-21 | S3 | 18976h | 18976h | SEC13 | 31 |  | Rel-13 | 61 |  | PCG-31 |  |  |  |  |
| 1877 | 535 | Release 13 IoT related Studies | 602d? | 2013-09-12 A | 2015-12-25 A | 100% |  | 2014-07-31 | 2015-12-25 | 366.5d? |  | start no earlier than 2013-09-12 | SP; R2 | 9632h | 9632h |  |  |  | Rel-13 |  |  |  |  |  |  |  |
| 1878 | 536 | Study on Power saving for Machine-Type Communications (MTC) devices | 266.6d? | 2014-08-12 A | 2015-08-14 A | 100% |  | 2014-06-18 | 2015-02-20 | 160.5d? |  | finish no earlier than 2015-08-14 | G2; G1 | 4000.8h | 4000.8h | FS_uPoD | 32 | China Mobile | Rel-13 | 60 | 43.869 |  | Jing Han (hanjing@chinamobile.com) | FS_uPoD |  |  |
| 1879 | 537 | Study on Cellular system support for ultra Low Complexity and low throughput Internet of Things | 329d? | 2014-05-30 A | 2015-08-28 A | 100% |  | 2015-01-14 | 2015-08-28 | 163d? |  | finish no earlier than 2015-08-28 | G1; G2 | 5264h | 5264h | FS_IoT_LC | 33 | Vodafone | Rel-13 | 66 | 45.8xy |  | chris.pudney@vodafone.com | FS_IoT_LC | MTC, M2M |  |
| 1880 | 538 | Study on architecture enhancements of cellular systems for ultra low complexity and low throughput Internet of Things | 196d? | 2015-03-13 A | 2015-12-11 A | 100% |  |  |  |  |  | finish no earlier than 2015-12-11 | S2 | 1568h | 1568h | FS_AE_CIoT | 34 | puneet.jain@intel.com | Rel-13 | 67 | New TR 23.8xx |  | puneet.jain@intel.com |  |  |  |
| 1881 | 539 | Study on Battery Efficient Security for very low Throughput Machine Type Communication Devices | 196d? | 2015-03-13 A | 2015-12-11 A | 100% |  |  |  |  |  | finish no earlier than 2015-12-11 | S3 | 1568h | 1568h | FS_BEST_MTC_Sec | 34 | Barry, Aguibou, VODAFONE Group Plc | Rel-13 | 67 | 32.863; 33.163 |  | Barry, Aguibou, VODAFONE Group Plc |  |  |  |
| 1882 | 540 | Study on Small data transmission enhancements for UMTS | 197d? | 2014-09-16 A | 2015-06-15 A | 100% |  |  |  |  |  | finish no earlier than 2015-06-15 | R1; R3 | 3152h | 3152h | FS_UTRA_SDATA | 33 | Ericsson | Rel-13 | 65 | 25.705 | RP-150843 | gerardo.agni.medina.acosta@ericsson.com | FS_UTRA_SDATA |  |  |
| 1883 | 541 | Study on Application specific Congestion control for Data Communication | 531.29d? | 2012-09-17 A | 2014-09-17 A | 100% |  | 2012-09-13 | 2014-09-17 | 532d? |  | finish no earlier than 2014-09-17 | S1 | 4250.28h | 4250.28h | FS_ACDC | 29 | NTT DOCOMO | Rel-13 | 57 | 22.806 | S1-143305 | Atsushi Minokuchi (minokuchi@nttdocomo.co.jp) | FS_ACDC |  | Alain |
| 1884 | 542 | Study on enhancements for Infrastructure based data Communication Between Devices | 266d? | 2013-09-14 A | 2014-09-17 A | 100% |  | 2013-09-12 | 2014-09-17 | 266d? |  | finish no earlier than 2014-09-17 | S1 | 2128h | 2128h | FS_eICBD | 31 | KPN | Rel-13 | 61 | 22.807 | S1-143309 | toon.norp@tno.nl | FS_eICBD | MTC, M2M | Alain |
| 1885 | 543 | Release 13 other Studies | 602d? | 2013-09-12 A | 2015-12-25 A | 100% |  | 2014-07-31 | 2015-12-25 | 366.5d? |  | start no earlier than 2013-09-12 | SP; R2 | 9632h | 9632h |  |  |  | Rel-13 |  |  |  |  |  |  |  |
| 1886 | 544 | Study on Isolated E-UTRAN Operation for Public Safety | 261d? | 2013-06-25 A | 2014-06-18 A | 100% |  | 2013-06-21 | 2014-06-18 | 262d? |  | finish no earlier than 2014-06-18 | S1 | 2088h | 2088h | FS_IOPS | 31 | General Dynamics | Rel-13 | 60 | 22.897 |  | paul.piggin@gd-broadband.com | FS_IOPS | Public Safety (A-A) | Alain |
| 1887 | 545 | Study on architecture enhancements for Public Safety | 131d? | 2014-12-12 A | 2015-06-12 A | 100% |  |  |  |  |  | finish no earlier than 2015-06-12 | S2 | 1048h | 1048h | FS_IOPS_St2 | 34 |  | Rel-13 | 66 |  |  | phil.young@gd-broadband.com |  |  |  |
| 1888 | 546 | Study on Security Aspects of Isolated E-UTRAN Operation for Public Safety | 137d? | 2015-03-12 A | 2015-09-18 A | 100% |  |  |  |  |  | finish no earlier than 2015-09-18 | S3 | 1096h | 1096h | FS_IOPS_Sec | 34 | Paul Piggin, General Dynamics UK | Rel-13 | 67 | New TR 33.897 |  | paul.piggin@gd-broadband.com |  |  |  |
| 1889 | 547 | (SA66: on hold) Study on Co-ordinated packet data network gateway (P-GW) change for SIPTO | 201d? | 2013-09-13 A | 2014-06-18 A | 100% |  | 2013-09-12 | 2014-06-18 | 202d? |  | finish no earlier than 2014-06-18 | S1 | 1608h | 1608h | FS_CSIPTO | 31 | Intel | Rel-13 | 61 | 22.828 |  | Eric.siow@intel.com | FS_CSIPTO |  | Alain |
| 1890 | 548 | Study on Flexible Mobile Service Steering | 201d? | 2013-12-13 A | 2014-09-17 A | 100% |  | 2013-12-11 | 2014-09-17 | 202d? |  | finish no earlier than 2014-09-17 | S1 | 1608h | 1608h | FS_FMSS | 32 | China Mobile | Rel-13 | 62 | 22.808 | S1-143310 | Lu Lu (lulu@chinamobile.com) | FS_FMSS |  | Alain |
| 1891 | 549 | Study on Enhanced Calling Information Presentation | 201d? | 2013-12-13 A | 2014-09-17 A | 100% |  | 2013-12-11 | 2014-09-17 | 201d? |  | finish no earlier than 2014-09-17 | S1 | 1608h | 1608h | FS_ECIP | 32 | China Mobile | Rel-13 | 62 | 22.810 | S1-143311 | LI Xiaofan (lixiaofan@chinamobile.com | FS_ECIP |  | Alain |
| 1892 | 550 | Study on RAN Sharing Enhancements on GERAN and UTRAN | 140d? | 2014-03-07 A | 2014-09-17 A | 100% |  | 2014-03-07 | 2014-09-17 | 139d? |  | finish no earlier than 2014-09-17 | S1 | 1120h | 1120h | FS_GUSH | 32 | Telefónica | Rel-13 | 63 | 22.852 updates |  | chris.friel@telefonica.com | FS_GUSH |  | Alain |

Notes:
- 1863: TDD case
- 1864: TDD case
- 1865: TDD case
- 1866: TDD case; 5/10/15: 36.899-13 added;
- 1867: TDD case
- 1868: TDD case
- 1869: LTE_CA_NC_B7 was completed in REL-12
- 1870: LTE_CA_NC_B7 was completed in REL-12 ;
- 1871: LTE_CA_NC_B7 was completed in REL-12 ;
- 1872: ; 22/3/16: Compl:0%->5%;1/7/16: Compl:5%->22%26/9/16: Compl:22%->; 2 21/3/17: Compl:39%...; ...;...; ;...; ;...
- 1873: -
- 1874: Created upon demand of RAN5
- 1876: -
- 1877: -
- 1878: GP#65 completion 02/15=>05/15. GP#60 approved WID. Linked to Rel-12 Feature MTCe, Stage 2 BB3: UE Power Consumptions Optimizations (UEPCOP). Dec.14: 30->40%; June2015: Compl:40%->75; 07/09/15: 75%->100
- 1879: GP#62 approved WID. Dec.14: 15->40%; June2015: Compl:40%->75; 07/09/15: 75%->100; 14/09/15: WID:GP-140421->GP-150354
- 1880: 07/09/15: 0%->20; 07/09/15: 20%->65; 7/12/15: 65%->95; 7/3/16: 95%->100
- 1881: TR number added; June2015: Compl:0%->10; 7/12/15: 10%->50; 11/12/15: 50%->75; 7/3/16: 75%->95; 19/9/16: 95%->100; 6/10/16: 33.163 added;
- 1882: 3/3/15: WID: RP-141861; Stat Rep: -->RP-141859. Impacted TR number added. 1st Apr 15: Compl:30%->55% 1st Apr 15: Stat Rep: RP-141859->RP-150196 03/07/15: Compl:55%->100% 03/07/15: Stat Rep: RP-150196->RP-150843
- 1883: SP#65 completed. SP#64 TR 22.806v200 for Approval. ACDC is applicable to UTRAN and E-UTRAN. Possible overlap with RAN2 TR 36.848 Study on smart congestion mitigation in E-UTRAN (prioritising MMTEL voice over other traffic during congestion)
- 1884: SP#65 completed. TR 22.807v200 for Approval
- 1885: -
- 1886: SP#64 completed. TR 22.897v200 for Approval. Linked to Rel-12 TR 22.803 (FS_ProSe) and FeaturES in CP-150ProSe, GCSE_LTE
- 1887: June2015: Compl:0%->100
- 1888: TR added; June2015: Compl:0%->30; 7/12/15: 30%->100
- 1889: SP#64 completed. TR 22.828v200 for Approval. Linked to FeaturES in CP-150Rel-10 LIPA_SIPTO & Rel-12 LIMONET
- 1890: SP#65 completed. TR 22.808v200 for Approval. Study supporting traffic classification and service chain selection capabilities per operators policy in order to realize efficient and flexible mobile service steering in the Gi-LAN network
- 1891: SP#65 completed. TR 22.810v200 for Approval. Linked to Multimedia Telephony Service for IMS (UID_7038), Customized Alerting Tone (CAT) UID_370028, Customized Ringing Signal (CRS) UID_380067
- 1892: SP#65 completed. Update on GERAN and UTRAN of Rel-12 TR 22.852 Study on RAN Sharing Enhancements (FS_RSE)

| ID | WBS | Task | Duration | Start | Finish | Complete | Baseline start | Baseline finish | Baseline duration | Total slack | Constraint | Resources | Work | Actual work | Acronym | PCG approved | WI rapporteur name | Release | TSG approved | MCC resp | Acronym_3GU_Export | PCG stopped | TSG stopped | Special Focus Doc | Status Report |
| --- | --- | --- | --- | --- | --- | --- | --- | --- | --- | --- | --- | --- | --- | --- | --- | --- | --- | --- | --- | --- | --- | --- | --- | --- | --- |
| 1893 | 551 | **Study on Usage Monitoring Enhancements for Service, Application and Subscriber Group** | 934d? | 2011-06-08 A | 2014-12-12 A | 100% | 2011-06-08 | 2014-12-10 | 929d? |  |  | S2 | 13978.1h | 13978.1h | FS_UMONC_sas | 27 | China Telecom | Rel-13 | 52 | Maurice | FS_UMONC_sas |  |  |  |  |
| 1894 | 551.1 | Deleted - SA1 part of Study on Usage Monitoring Control PCC Enhancement | 275d? | 2011-06-08 A | 2012-06-20 A | 100% | 2011-06-08 | 2012-06-20 | 275d? |  | finish no earlier than 2012-06-20 | S1 | 2200h | 2200h |  | 27 | ZTE |  | 52 | Maurice | FS_UMONC | PCG-31 | SP-58 |  |  |
| 1895 | 551.2 | SA2 part of Study on Usage Monitoring Control PCC Enhancement | 397.26d? | 2013-06-14 A | 2014-12-12 A | 100% | 2013-06-02 | 2014-12-10 | 403d? |  | finish no earlier than 2014-12-12 | S2 | 3178.08h | 3178.08h | FS_UMONC_sas | 27 | China Telecom | Rel-13 | 52 | Maurice |  |  |  |  |  |
| 1896 | 551.3 | Deleted - SA5 part of Study on Usage Monitoring Control enhancement | 141d? | 2012-03-02 A | 2012-09-12 A | 100% | 2012-03-02 | 2012-09-12 | 141d? |  | finish no earlier than 2012-09-12 | S5 | 1128h | 1128h |  | 27 | Huawei |  | 52 | Mirko |  | PCG-29 | SP-57 |  |  |
| 1897 | 552 | Study on Security aspects of Integration of Single Sign-On (SSO) frameworks with 3GPP networks | 1180d? | 2010-12-28 A | 2015-06-12 A | 100% | 2010-12-16 | 2014-09-17 | 988d? |  | finish no earlier than 2015-06-12 | S3 | 9440h | 9440h | FS_SSO_Int_Sec | 26 | Ericsson | Rel-13 | 50 | Mirko | FS_SSO_Int_Sec |  |  |  |  |
| 1898 | 553 | Study on Subscriber Privacy Impact in 3GPP | 591d? | 2013-09-17 A | 2015-12-16 A | 100% | 2013-09-12 | 2014-09-17 | 266d? |  | finish no earlier than 2015-12-16 | S3 | 4728h | 4728h | FS_SPI | 31 | China Unicom | Rel-13 | 61 | Mirko | FS_SPI |  |  |  |  |
| 1899 | 554 | Study on Enhancements of OAM aspects of Distributed Mobility Load Balancing (MLB) SON function | 458d? | 2014-09-15 A | 2016-06-13 A | 100% | 2013-09-12 | 2014-12-10 | 326d? |  | finish no earlier than 2016-06-13 | S5 | 3664h | 3664h | FS_D_MLB_SON_OAM | 31 | Cisco | Rel-13 | 61 | Mirko | FS_D_MLB_SON_OAM |  |  | SON |  |
| 1900 | 555 | Study on Application and Partitioning of Itf-N | 458d? | 2013-12-17 A | 2015-09-11 A | 100% | 2013-12-11 | 2014-12-10 | 261d? |  | finish no earlier than 2015-09-11 | S5 | 3664h | 3664h | FS_OAM_AP_Itf-N | 32 | China Mobile | Rel-13 | 62 | Mirko | FS_OAM_AP_Itf-N |  |  |  |  |
| 1901 | 556 | Study on Charging aspects on Roaming End-to-end scenarios with VoLTE IMS and interconnecting networks | 393d? | 2013-12-17 A | 2015-06-12 A | 100% | 2013-12-11 | 2014-12-10 | 261d? |  | finish no earlier than 2015-06-12 | S5 | 3144h | 3144h | FS_REVOLTE_IMS_CH | 32 | Deutsche Telekom | Rel-13 | 62 | Mirko | FS_REVOLTE_IMS_CH |  |  |  |  |
| 1902 | 557 | Study on Network Management of Virtualized Networks | 269d? | 2014-06-11 A | 2015-06-17 A | 100% | 2014-06-06 | 2015-06-17 | 269d? |  | finish no earlier than 2015-06-17 | S5 | 2152h | 2152h | FS_OAM_VIRNET | 33 | China Mobile, Huawei | Rel-13 | 64 |  | FS_OAM_VIRNET |  |  |  |  |
| 1903 | 558 | Study on Review of dedicated 3GPP UICC features | 729d? | 2013-03-13 A | 2015-12-16 A | 100% | 2013-03-04 | 2014-09-12 | 401d? |  | finish no earlier than 2015-12-16 | C6 | 5832h | 5832h | FS_Red_UCe | 30 | BlackBerry | Rel-13 | 59 | Xavier | FS_Red_UCe |  |  |  |  |
| 1904 | 559 | Study on Solutions for GSM/EDGE BTS Energy Saving | 458.8d? | 2011-08-30 A | 2015-11-20 A | 100% | 2009-03-10 | 2014-08-29 | 557d? |  | finish no earlier than 2015-11-20 | G1; G2 | 3670.4h | 3670.4h | FS_Energy_BTS | 25 | Nokia Networks | Rel-13 | 47 | Paolo | FS_Energy_BTS |  |  |  |  |
| 1905 | 560 | Study on Downlink MIMO | 459d? | 2014-08-14 A | 2016-05-12 A | 100% | 2013-08-20 | 2015-02-20 | 396d? |  | finish no earlier than 2016-05-12 | G1; G2 | 4004.8h | 4004.8h | FS_DOMIMO | 30 | Nokia Networks | Rel-13 | 57 | Paolo | FS_DOMIMO |  |  |  |  |
| 1906 | 561 | Study on MIMO OTA antenna test function for LTE | 462d? | 2013-03-18 A | 2014-12-15 A | 100% | 2013-03-15 | 2014-12-05 | 456d? |  | finish no earlier than 2014-12-15 | R4 | 3696h | 3696h | FS_LTE_MIMO_OTA_ATF | 33 | Keysight | Rel-13 | 64 |  | FS_LTE_MIMO_OTA_ATF |  |  |  | RP-142045 |
| 1907 | 562 | Stopped at 20% - Study on UpLink MultiUser Multiple-Input Multiple-Output (UL MU-MIMO) | 481.6d? | 2014-04-17 A | 2016-02-19 A | 100% | 2014-04-17 | 2015-02-20 | 195.5d? |  | finish no earlier than 2016-02-19 | G1; G2 | 5688h | 5688h | FS_UL_MU_MIMO | 32 | Huawei | Rel-13 | 60 |  | FS_UL_MU_MIMO |  | SP#71 |  |  |
| 1908 | 563 | Study on LTE FDD in the bands 1980-2010 MHz and 2170-2200 MHz | 854d? | 2012-09-11 A | 2015-12-15 A | 100% | 2012-09-11 | 2014-09-12 | 527d? |  | finish no earlier than 2015-12-15 | R4 | 6832h | 6832h | FS_LTE_1980_2170_Korea | 29 | KT | Rel-13 | 57 | Issam | FS_LTE_1980_2170_Korea |  |  |  | RP-151274 |
| 1909 | 564 | Study on Positioning enhancements for E-UTRA | 524d? | 2012-05-01 A | 2014-12-15 A | 100% | 2013-04-25 | 2014-12-05 | 256d? |  | finish no earlier than 2014-12-15 | R4 | 4192h | 4192h | FS_LCSenh_LTE | 31 | Huawei | Rel-13 | 60 | Issam | FS_LCSenh_LTE |  |  |  | RP-142224 |
| 1910 | 565 | Study on Multi-RAT joint coordination | 397d? | 2013-12-06 A | 2015-06-15 A | 100% | 2013-12-06 | 2014-12-05 | 261d? |  | finish no earlier than 2015-06-15 | R4 | 3176h | 3176h | FS_MultiRAT_JC | 32 | China Mobile | Rel-13 | 62 | Juha | FS_MultiRAT_JC |  |  | WLAN | RP-150807 |
| 1911 | 566 | Study on Advanced Wireless Services (AWS) - Extension band for LTE | 265d? | 2013-12-16 A | 2014-12-15 A | 100% | 2013-12-09 | 2014-12-05 | 261d? |  | finish no earlier than 2014-12-15 | R4 | 2120h | 2120h | FS_LTE_AWS_EXT | 33 | Qualcomm | Rel-13 | 64 |  | FS_LTE_AWS_EXT |  |  |  | RP-141968 |
| 1912 | 567 | Study on Indoor Positioning Enhancements for UTRA and LTE | 328d? | 2014-06-18 A | 2015-09-15 A | 100% | 2014-06-13 | 2015-09-17 | 330d? |  | finish no earlier than 2015-09-15 | R1; R4 | 5248h | 5248h | FS_UTRA_LTE_iPos_enh | 33 | NextNav | Rel-13 | 64 |  | FS_UTRA_LTE_iPos_enh |  |  |  | RP-151178 |
| 1913 | 568 | Study on Downlink enhancements for UMTS | 199d? | 2014-09-12 A | 2015-06-15 A | 100% |  |  |  |  | finish no earlier than 2015-06-15 | R2; R1 | 3184h | 3184h | FS_UTRA_EDL | 33 | Huawei | Rel-13 | 65 |  | FS_UTRA_EDL |  |  |  | RP-150681 |
| 1914 | 569 | Study on Elevation Beamforming/Full-Dimension (FD) MIMO for LTE | 199d? | 2014-09-12 A | 2015-06-15 A | 100% |  |  |  |  | finish no earlier than 2015-06-15 | R1 | 1592h | 1592h | FS_LTE_EBF_FDMIMO | 33 | Nokia Networks (DL), Samsung (UL) | Rel-13 | 65 |  | FS_LTE_EBF_FDMIMO |  |  |  | RP-150734 |
| 1915 | 570 | Study on Licensed-Assisted Access using LTE | 197d? | 2014-09-16 A | 2015-06-15 A | 100% |  |  |  |  | finish no earlier than 2015-06-15 | R1; R2; R4 | 4728h | 4728h | FS_LTE_LAA | 33 | Ericsson, Huawei | Rel-13 | 65 |  | FS_LTE_LAA |  |  |  | RP-150624 |
| 1916 | 571 | Study on EPC Signalling Improvement for Race Scenarios | 203d? | 2014-12-03 A | 2015-09-11 A | 100% |  |  |  |  | finish no earlier than 2015-09-11 | C4 | 1624h | 1624h | FS_EPC_SIG_RACE | 34 | Huawei | Rel-13 | 66 |  |  |  |  |  |  |
| 1917 | 572 | Study on Video Enhancements in 3GPP Multimedia Services | 261d? | 2014-12-12 A | 2015-12-11 A | 100% |  |  |  |  | finish no earlier than 2015-12-11 | S4 | 2088h | 2088h | FS_VE_3MS | 34 | Ye-Kui Wang, Qualcomm Incorporated | Rel-13 | 66 |  |  |  |  |  |  |
| 1918 | 573 | Study on possible additional configuration for LTE TDD | 197d? | 2014-12-15 A | 2015-09-15 A | 100% |  |  |  |  | finish no earlier than 2015-09-15 | R4 | 1576h | 1576h | FS_LTE_TDD_add_config | 34 | NTT DOCOMO, Hideaki Takahashi | Rel-13 | 66 |  |  |  |  |  | RP-151283 |
| 1919 | 574 | Study on Network-Assisted Interference Cancellation and Suppression for UMTS | 197d? | 2014-12-15 A | 2015-09-15 A | 100% |  |  |  |  | finish no earlier than 2015-09-15 | R1 | 1576h | 1576h | FS_UTRA_NAICS | 34 | Huawei | Rel-13 | 66 |  |  |  |  |  | RP-151235 |
| 1920 | 575 | Study on Enhanced Multiuser Transmissions and Network Assisted Interference Cancellation for LTE | 65d? | 2014-12-15 | 2015-03-15 |  |  |  |  | 1372d | finish no earlier than 2015-03-15 | R1 | 520h |  | FS_LTE_MUTX_NAIC | 34 | MediaTek | Rel-13 | 66 |  |  |  |  |  | RP-150213 |
| 1921 | 576 | Study on Support of single-cell point-to-multipoint transmission in LTE | 131d? | 2014-12-15 A | 2015-06-15 A | 100% |  |  |  |  | finish no earlier than 2015-06-15 | R4 | 1048h | 1048h | FS_LTE_SC_PTM | 34 | Jeff GAO | Rel-13 | 66 |  |  |  |  |  | RP-150695 |
| 1922 | 577 | Study on Extension of Dual Connectivity in E-UTRAN | 131d? | 2014-12-15 A | 2015-06-15 A | 100% |  |  |  |  | finish no earlier than 2015-06-15 | R3 | 1048h | 1048h | FS_LTE_dualC_ext | 34 | Samsung | Rel-13 | 66 |  |  |  |  |  | RP-150849 |
| 1923 | 578 | Study on further enhancements of small cell higher layer aspects for LTE | 197d? | 2014-12-15 A | 2015-09-15 A | 100% |  |  |  |  | finish no earlier than 2015-09-15 | R3 | 1576h | 1576h | FS_LTE_SC_enh2_hilayer | 34 | Huawei | Rel-13 | 66 |  |  |  |  |  | RP-151243 |
| 1924 | 579 | Study on RAN sharing enhancements for UMTS | 131d? | 2014-12-15 A | 2015-06-15 A | 100% |  |  |  |  | finish no earlier than 2015-06-15 | R3 | 1048h | 1048h | FS_RSE_UTRA_GUSH | 34 | Huawei | Rel-13 | 66 |  |  |  |  |  | RP-150684 |
| 1925 | 580 | Study on LTE DL 4 Rx antenna ports | 65d? | 2014-12-15 A | 2015-03-15 A | 100% |  |  |  |  | finish no earlier than 2015-03-15 | R4 | 520h | 520h | FS_LTE_4Rx_AP_DL | 34 | Ericsson | Rel-13 | 66 |  |  |  |  |  | RP-150138 |
| 1926 | 581 | Study on performance enhancements for high speed scenario in LTE | 262d? | 2014-12-15 A | 2015-12-15 A | 100% |  |  |  |  | finish no earlier than 2015-12-15 | R4 | 2096h | 2096h | FS_LTE_high_speed | 34 | NTTDoCoMo | Rel-13 | 66 |  |  |  |  |  | RP-151313 |
| 1927 | 582 | Study on Enhanced Multiuser Transmissions and Network | 261d? | 2014-12-12 | 2015-12-11 |  |  |  |  | 1177d | finish no earlier than 2015-12-11 | R1 | 2088h |  | FS_MUIC_LTE | 34 | Pei-Kai Liao | Rel-13 | 67 |  |  |  |  |  |  |
| 1928 | 583 | Study on regulatory aspects for flexible duplex for E-UTRAN | 133d? | 2016-06-15 A | 2016-12-15 A | 100% |  |  |  |  |  | RP | 1064h | 1064h | FS_LTE_flex_duplex_reg | 34 | LG Electronics Inc. | Rel-13 | 67 |  |  |  |  |  | RP-151307 |
| 1929 | 584 | Study on Downlink Multiuser Superposition Transmission for LTE | 197d? | 2015-03-16 A | 2015-12-15 A | 100% |  |  |  |  | finish no earlier than 2015-12-15 | R1 | 1576h | 1576h | FS_LTE_MUST | 34 | Mediatek | Rel-13 | 67 |  |  |  |  |  | RP-151345 |
| 1930 | 585 | Study on Measurement gap enhancement for LTE | 197d? | 2015-03-16 A | 2015-12-15 A | 100% |  |  |  |  | finish no earlier than 2015-12-15 | R4 | 1576h | 1576h | FS_LTE_meas_gap |  |  | Rel-13 | 67 |  |  |  |  |  | RP-151317 |
| 1931 | 586 | Study on Phase 1 of the Support of Emergency services over WLAN | 71d? | 2015-03-12 A | 2015-06-18 A | 100% |  |  |  |  | finish no earlier than 2015-06-18 | S2 | 568h | 568h | FS_SEW | 34 | Laurent Thiebaut, Alcatel Lucent | Rel-13 | 67 |  |  |  |  |  |  |
| 1932 | 587 | Study on EGPRS Access Security Enhancements with relation to cellular IoT | 197d? | 2015-03-12 A | 2015-12-11 A | 100% |  |  |  |  | finish no earlier than 2015-12-11 | S3 | 1576h | 1576h | FS_EASE_IoT | 34 | Vesa Torvinen, Ericsson | Rel-13 | 67 |  |  |  |  |  |  |
| 1933 | 588 | Study on SCC AS Restoration | 1d? | 2015-06-15 A | 2015-06-15 A | 100% |  |  |  |  | start no earlier than 2015-06-15 | C4 | 8h | 8h | FS_SCCAS_RES | 35 | Hao Zhang,, China Mobile | Rel-13 | 68 |  |  |  |  |  |  |
| 1934 | 589 | Study on S6a/S6d Shared Data Update | 130d? | 2015-06-15 A | 2015-12-11 A | 100% |  |  |  |  | finish no earlier than 2015-12-11 | C4 | 1040h | 1040h | FS_eSDU | 35 | Ulrich Wiehe, Nokia Networks | Rel-13 | 68 |  |  |  |  |  |  |
| 1935 | 590 | Study on Network Assistance for Network Synchronization in LTE | 395d? | 2015-06-15 A | 2016-12-15 A | 100% |  |  |  |  | finish no earlier than 2016-12-15 | R3 | 3160h | 3160h | FS_LTE_NW_SYNC | 35 | Huawei | Rel-14 | 68 |  |  |  |  |  |  |
| 1936 | 591 | Study onLTE Advanced inter-band Carrier Aggregation of Band 20 and Band 28 | 132d? | 2015-06-15 A | 2015-12-15 A | 100% |  |  |  |  | finish no earlier than 2015-12-15 | R4 | 1056h | 1056h | FS_LTE_CA_B20_B28 | 35 | TeliaSonera | Rel-13 | 68 |  |  |  |  |  | RP-151231 |
| 1937 | 592 | Study on Impacts of the Diameter Base Protocol Specification Update | 75d? | 2015-09-07 A | 2015-12-18 A | 100% |  |  |  |  | finish no earlier than 2015-12-18 | C4 | 600h | 600h | FS_DBPU | 35 | Huawei, Peter Schmitt | Rel-13 | 69 |  |  |  |  |  |  |
| 1938 | 593 | Study on new AWS-3/4 Band for LTE | 66d? | 2015-09-15 A | 2015-12-15 A | 100% |  |  |  |  | finish no earlier than 2015-12-15 | R4 | 528h | 528h | FS_LTE_AWS_3_4 | 35 | Dish Network | Rel-13 | 69 |  |  |  |  |  |  |
| 1939 | 594 | Study on multi-node testing for LAA | 263d? | 2016-06-15 A | 2017-06-15 A | 100% |  |  |  |  | finish no earlier than 2017-06-15 | R4 | 2104h | 2104h | FS_LTE_LAA_multinode_test | 37 | Huawei | Rel-13 | 72 |  |  |  |  |  |  |
| 1940 | 595 | Stopped - Study on Compliance of 3GPP SA5 specifications to the NGMN NGCOR | 1442d? | 2012-06-26 A | 2017-12-15 A | 100% | 2012-06-20 | 2015-09-16 | 854d? |  | finish no earlier than 2017-12-15 | S5 | 11536h | 11536h | FS_OAM_NGMN_NGCOR | 29 | Huawei | Rel-13 | 56 | Mirko | FS_OAM_NGMN_NGCOR |  |  |  |  |
| 1941 | 596 | Release 12 Features | 306d? | 2013-10-14 A | 2014-12-12 A | 100% | 2013-10-14 | 2014-12-10 | 304d? |  | finish no earlier than 2014-12-12 | SP; CP; RP; GP | 9792h | 9792h |  |  |  | Rel-12 |  |  |  |  |  |  |  |
| 1942 | 597 | Stage 1 - ONLY Features | 647d? | 2011-09-27 A | 2014-03-05 A | 100% | 2011-09-27 | 2014-03-05 | 647d? |  | start no earlier than 2011-09-27 | SP; CP | 10352h | 10352h |  | 30 |  | Rel-12 | 58 |  |  |  |  |  |  |

Notes:
- 1893: SP#64 revived. Added to the Title "for Service, Application and Subscriber Group", Changed Acronym: FS_UMONC=>FS_UMONC_sas / Impacted TSs and TRs: 23.858 / WI rapporteur e-mail: Jinyan Li (lijy@ctbri.com.cn)
- 1894: SP#56 completed / Impacted TSs and TRs: 23.858 / WI rapporteur e-mail: Li.Mian@zte.com.cn
- 1895: SP#64 revived. Updated WID SP-120554=>SP-140403. Changed Justification/objectives/Rapporteut ZTE=>China Unciom. SP#58 SA2 stopped (at 70% completion). Dec.14: 80->100%. Mar 15: WID SP-140403->SP-150029 / Impacted TSs and TRs: 23.858 / WI rapporteur e-mail: Jinyan Li (lijy@ctbri.com.cn)
- 1896: SP#57 stopped / Impacted TSs and TRs: 32.858 / WI rapporteur e-mail: Hui Cai (Sarah.Cai@huawei.com)
- 1897: SP#65 moved to Rel-13. Updated WID SP-100734=>SP-140576. Completion 09/14=>06/15. Dec.14: 60->65%; June2015: Compl:65%->100; June2015: WID:SP-140576->SP-150368 / Impacted TSs and TRs: 33.895 / WI rapporteur e-mail: vesa.lehtovirta@ericsson.com
- 1898: SP#65 moved to Rel-13. Completion 09/14=>12/15. Related to SA1 TR 22.949 Rel-6 Study on Privacy Capability (PrivCap) UID_31030 studied generalized privacy capability (protection of personal data and non-disclosure of identity). Dec.14: 80->85; June2015 / Impacted TSs and TRs: 33.849 / WI rapporteur e-mail: Feng Gao (gaofeng149@chinaunicom.cn)
- 1899: SP#64 completion 06/14=>12/14. Dec.14: 20->25%, CD: 12/14->06/15; June2015: Compl:25%->30; 7/12/15: 30%->45; 7/3/16: 45%->50; 13/6/16: 50%->100 / Impacted TSs and TRs: 32.860 / WI rapporteur e-mail: Vladimir Yanover (vyanover@cisco.com)
- 1900: -Dec.14: 15->30%, CD: 12/14->09/15; June2015: Compl:30%->60; 07/09/15: 60%->100 / Impacted TSs and TRs: 32.861 / WI rapporteur e-mail: Li Jian (lijian@chinamobile.com), Hu Yaxi (huyaxi@cmdi.chinamobile.com)
- 1901: SP#64 moved to Rel-13. Completion 06/14=>12/14. Dec.14: 35->55, CD: 12/14->06/15. Mar 15: 55->75%; June2015: Compl:75%->100 / Impacted TSs and TRs: 32.849 / WI rapporteur e-mail: Roland Jesske (r.jesske@telekom.de)
- 1902: Dec.14: 10->25%. Mar 15: 25->60%; June2015: Compl:60%->85; 07/09/15: 85%->100 / Impacted TSs and TRs: 32.842 / WI rapporteur e-mail: Liu Jinglei (liujinglei@chinamobile.com), zoulan@huawei.com
- 1903: CP#65 TR 31.901v100 for Information. Moved to Rel-13. Completion 09/14=>12/15. Waiting for feedback from external organizations (PTCRB/PVG). Dec.14: 65->100% / Impacted TSs and TRs: 31.901 / WI rapporteur e-mail: Adrian Buckley (abuckley@blackberry.com)
- 1904: GP#63 moved to Rel-13. Completion 08/14=>11/14. GP#55 TR 45.926v100 for Information. GP#47 approved WID. Dec.14: 90->95%. 3/3/15: start date corrected (was 03/09). 7/9/15: FCD: 8/15->11/15; 7/12/15: 95%->100 / Impacted TSs and TRs: 45.926 / WI rapporteur e-mail: juergen.hofmann@nokia.com
- 1905: GP#62 completion 08/14=>02/15. Moved to Rel-13. GP#57 approved WID. Dec.14: 50->65%, CD: 02/15->05/15. 7/9/15: FCD: 11/15->02/16; 2/3/16: 65%->75, FCD: 02/16->05/16; 11/9/17: 75%->100 / Impacted TSs and TRs: 45.8xy / WI rapporteur e-mail: juergen.hofmann@nokia.com
- 1906: CD:Thu 11/12/14->Mon 15/12/14; Compl:60%->100%; Stat Rep: RP-141124->RP-142045 / Impacted TSs and TRs: 36.509, new TR 37.978 / WI rapporteur e-mail: Moray_Rumney@keysight.com
- 1907: GP#62 completion 11/14=>02/15. GP#60 approved WID. Dec.14: 02/15->05/15. 02/03/16: stopped at 20% / Impacted TSs and TRs: 45.876 / WI rapporteur e-mail: Chao Luo (chluo@huawei.com)
- 1908: CD:Thu 11/12/14->Sun 15/03/15; Compl:85%->90%; Stat Rep: RP-141153->RP-141851 1st Apr 15: CD:Sun 15/03/15->Mon 15/06/15 1st Apr 15: WID: RP-141154->RP-150119 1st Apr 15: Stat Rep: RP-141851->RP-150120 03/07/15: CD:Mon 15/06/15->Tue 15/09/15 03/07/15: S / Impacted TSs and TRs: LTE 36.861 / WI rapporteur e-mail: Chungwoo HWANG (cwhwang@kt.com)
- 1909: WID: RP-140667->RP-130680; Stat Rep: RP-140639->RP-142224. 3/3/15: R1 removed as 2nd responsible WG / Impacted TSs and TRs: LTE 36.855 / WI rapporteur e-mail: Jie Cui (cuijie@huawei.com)
- 1910: ; WID: RP-142043->RP-132086; Stat Rep: RP-141301->RP-141838 1st Apr 15: Compl:55%->85% 1st Apr 15: WID: RP-132086->RP-150417 1st Apr 15: Stat Rep: RP-141838->RP-150187 03/07/15: Compl:85%->100% 03/07/15: Stat Rep: RP-150187->RP-150807 / Impacted TSs and TRs: UTRA, LTE 37.870 / WI rapporteur e-mail: Kimba Dit Adamou, Boubacar (jinba@chinamobile.com)
- 1911: CD:Thu 11/12/14->Mon 15/12/14; Compl:10%->100%; Stat Rep: RP-141429->RP-141968. 5/5/15: 2nd TR number added (to be clarified why two TR for a same topic) / Impacted TSs and TRs: 36.849, 36.869 / WI rapporteur e-mail: Gene Fong (gfong@qti.qualcomm.com)
- 1912: CD:Thu 17/09/15->Tue 15/09/15; Compl:0%->8%; Stat Rep: RP-141101->RP-141818 1st Apr 15: Compl:8%->30% 1st Apr 15: Stat Rep: RP-141818->RP-150080 03/07/15: Compl:30%->75% 03/07/15: Stat Rep: RP-150080->RP-150595 29/09/15: Compl:75%->100% 29/09/15: Stat / Impacted TSs and TRs: UTRA, LTE 37.857 / WI rapporteur e-mail: Vogedes Jerome (jvogedes@NextNav.com)
- 1913: WID: RP-141901; Stat Rep: -->RP-142233 1st Apr 15: Compl:40%->80% 1st Apr 15: WID: RP-141901->RP-150224 1st Apr 15: Stat Rep: RP-142233->RP-150223. 5/5/15: R4 replaced by R1 (correction mistake) 03/07/15: Compl:80%->100% 03/07/15: Stat Rep: RP-150223-> / Impacted TSs and TRs: UTRA TR 25.706 / WI rapporteur e-mail: jun.chen@huawei.com
- 1914: 3/3/15: WID: RP-141831; Stat Rep: -->RP-141822, impacted TR number added. 1st Apr 15: Compl:30%->45% 1st Apr 15: Stat Rep: RP-141822->RP-150346. 5/5/15: "R4" replaced by "R1" (correction mistake) 03/07/15: Compl:45%->100% 03/07/15: WID: RP-141831->RP-1 / Impacted TSs and TRs: 36.897 / WI rapporteur e-mail: bishwarup.mondal@nsn.com, hyoungju.ji@samsung.com
- 1915: 3/3/15: WID: RP-141817; Stat Rep: -->RP-141816. Impacted TR number added. 1st Apr 15: Compl:30%->40% 1st Apr 15: Stat Rep: RP-141816->RP-150414 03/07/15: Compl:40%->100% 03/07/15: Stat Rep: RP-150414->RP-150624 / Impacted TSs and TRs: 36.889 / WI rapporteur e-mail: havish.koorapaty@ericsson.com, david.mazzarese@huawei.com
- 1916: Mar15: 0->20%; June2015: Compl:20%->80; 07/09/15: 80%->95; 7/12/15: 95%->100 / Impacted TSs and TRs: New TR 29.811
- 1917: Mar. 15: 0->20%; June2015: Compl:20%->40; 07/09/15: 40%->80; 7/12/15: 80%->100 / WI rapporteur e-mail: yekuiw@qti.qualcomm.com
- 1918: TR 36.825 rapporteur: CATT. TR number added. 1st Apr 15: Compl:0%->5% 1st Apr 15: Stat Rep: ->RP-150151 03/07/15: Compl:5%->35% 03/07/15: WID: RP-142248->RP-150652 03/07/15: Stat Rep: RP-150151->RP-150805 29/09/15: Compl:35%->100% 29/09/15: Stat Rep: R / Impacted TSs and TRs: 36.825 / WI rapporteur e-mail: NTT DOCOMO
- 1919: TS number added 1st Apr 15: Compl:0%->20% 1st Apr 15: WID: RP-142250->RP-150174 1st Apr 15: Stat Rep: ->RP-150175. 5/5/15: "R4" replaced by "R1" (correction mistake) 03/07/15: Compl:20%->65% 03/07/15: Stat Rep: RP-150175->RP-150679 29/09/15: Compl:65%- / Impacted TSs and TRs: 25.766 / WI rapporteur e-mail: Huawei
- 1920: 1st Apr 15: CD:Tue 15/12/15->Sun 15/03/15 1st Apr 15: Stat Rep: ->RP-150213. 5/5/15: "R4" replaced by "R1" (correction mistake) / WI rapporteur e-mail: MediaTek
- 1921: deleted 660062 (duplicated). 29/1: TR number added 1st Apr 15: Compl:0%->25% 1st Apr 15: WID: RP-142205->RP-150177 1st Apr 15: Stat Rep: ->RP-150176 03/07/15: Compl:25%->100% 03/07/15: Stat Rep: RP-150176->RP-150695 / Impacted TSs and TRs: TR 36.890 / WI rapporteur e-mail: gaoyongqiang@huawei.com
- 1922: 1st Apr 15: WID: RP-142257->RP-150170 1st Apr 15: Stat Rep: ->RP-150163 03/07/15: Compl:85%->100% 03/07/15: Stat Rep: RP-150163->RP-150849. 7/10/15: responsible group corrected (R4->R3) / Impacted TSs and TRs: 36.875 / WI rapporteur e-mail: Samsung
- 1923: 03/07/15: Compl:10%->30% 03/07/15: Stat Rep: RP-150226->RP-150683 29/09/15: Compl:30%->100% 29/09/15: Stat Rep: RP-150683->RP-151243. 7/10/15: responsible group corrected (R4->R3) and TS (37.876->36.876) / Impacted TSs and TRs: 36.876 / WI rapporteur e-mail: Huawei
- 1924: 03/07/15: Compl:10%->100% 03/07/15: WID: RP-142284->RP-150686 03/07/15: Stat Rep: RP-150227->RP-150684. 7/10/15: responsible group corrected (R4->R3) / Impacted TSs and TRs: 25.756 / WI rapporteur e-mail: Huawei
- 1925: 1st Apr 15: Compl:0%->100% 1st Apr 15: WID: RP-142299->RP-150457 1st Apr 15: Stat Rep: ->RP-150138 / WI rapporteur e-mail: Ericsson
- 1926: TR Rapporteur is Huawei 1st Apr 15: Compl:0%->5% 1st Apr 15: WID: RP-142307->RP-150159 1st Apr 15: Stat Rep: ->RP-150517 03/07/15: Compl:5%->40% 03/07/15: Stat Rep: RP-150517->RP-150793 29/09/15: Compl:40%->80% 29/09/15: CD:Tue 15/09/15->Tue 15/12/15 2 / WI rapporteur e-mail: NTTDoCoMo
- 1927: TR added / Impacted TSs and TRs: 36.891 / WI rapporteur e-mail: pk.liao@mediatek.com
- 1928: TR added 03/07/15: Compl:0%->5% 03/07/15: Stat Rep: -->RP-150770 29/09/15: Compl:5%->100% 29/09/15: Stat Rep: RP-150770->RP-151307 / Impacted TSs and TRs: 36.882
- 1929: TR added 03/07/15: Compl:0%->30% 03/07/15: WID: RP-150496->RP-151100 03/07/15: Stat Rep: -->RP-150857 29/09/15: Compl:30%->50% 29/09/15: Stat Rep: RP-150857->RP-151345 / Impacted TSs and TRs: 36.859
- 1930: 03/07/15: Compl:0%->15% 03/07/15: CD:Thu 10/12/15->Tue 15/12/15 03/07/15: Stat Rep: ->RP-150754 03/07/15: Release: REL-13->Rel-13. Aug 15: TR numb added 29/09/15: Compl:15%->65% 29/09/15: Stat Rep: RP-150754->RP-151317 / Impacted TSs and TRs: 36.894
- 1931: June2015: Compl:0%->100, SP-150151->SP-150251 / Impacted TSs and TRs: new 23.771 / WI rapporteur e-mail: Laurent.thiebaut@alcatel-lucent.com
- 1932: TR added; June2015: Compl:0%->25; 7/12/15: 25%->70; 28/1/16: 33.420 added; 7/3/16: 70%->100 / Impacted TSs and TRs: New 33.860; 33.420
- 1933: 07/09/15: 5%->20; 7/12/15: 20%->100 / Impacted TSs and TRs: New 29.812 / WI rapporteur e-mail: zhanghao@chinamobile.com
- 1934: 07/09/15: 0%->20; 7/12/15: 20%->100 / Impacted TSs and TRs: New 29.813 / WI rapporteur e-mail: ulrich.wiehe@nokia.com
- 1935: Aug 15: TR numb added 29/09/15: Compl:0%->15% 29/09/15: WID: RP-151084->RP-151252 29/09/15: Stat Rep: -->RP-151240 22/3/16: Compl:60%->80%; 22/3/16: CD:Tue 15/03/16->Wed 15/06/16; ; / Impacted TSs and TRs: New 36.898
- 1936: 29/09/15: Compl:0%->20% 29/09/15: WID: RP-151101->RP-151515 29/09/15: Stat Rep: -->RP-151231
- 1937: 7/3/16: 0%->79; 13/6/16: 79%->99; 2/12/16: 99%->100 / Impacted TSs and TRs: 29.274, 29.060, 23.003, 29.272, 29.002, 29.305, 23.008, 29.230, 29.303, 23.007, 24.301, 24.008
- 1938: Impacted TSs and TRs: 36.870
- 1939: coexistence testing for REL-13 WI LTE_LAA26/9/16: Compl:0%->10%26/9/16: WID: RP-161197->RP-161672; 20/12/16: Compl:10%->30%; 20/12/16: CD:Thu 15/12/16->Wed 15/03/17; 20/12/16: WID: RP-161672->RP-162144; 21/3/17: CD:Wed 15/03/17->Thu 15/06/17; ;...
- 1940: SP#65 updated WID SP-140349=>SP-140539. Dec.14: 35->45, 12/14: 28.821 added. Mar 15: 45->50%; June2015: Compl:50%->60. 07/09/15: FCD: 09/15->12/15; 7/12/15: FCD:12/15->03/16; 21/3/17:marked as stopped, was 60% / Impacted TSs and TRs: TR 32.837, TR 28.821 / WI rapporteur e-mail: zoulan@huawei.com
- 1941: -
- 1942: -

| ID | WBS | Task | Duration | Start | Finish | Complete | Baseline start | Baseline finish | Baseline duration | Constraint | Resources | Work | Actual work | Acronym | PCG approved | Impacted TSs and TRs | WI rapporteur name | WI rapporteur e-mail | Release | TSG approved | MCC resp | Special Focus Doc | Acronym_3GU_Export | PCG stopped | TSG stopped |
| --- | --- | --- | --- | --- | --- | --- | --- | --- | --- | --- | --- | --- | --- | --- | --- | --- | --- | --- | --- | --- | --- | --- | --- | --- | --- |
| 1943 | 598 | **SIPTO Service Continuity of IP Data Session** | 262d? | 2010-09-23 A | 2011-09-21 A | 100% | 2010-09-23 | 2011-09-21 | 262d? |  | S1 | 4176h | 4176h | SIPTO_SC | 25 | Stage 1 | Vodafone | mona.mustapha@vodafone.com | Rel-12 | 49 | Alain | HNB | SIPTO_SC |  |  |
| 1944 | 598.1 | Stage 1 for SIPTO Service Continuity of IP Data Session | 262d? | 2010-09-23 A | 2011-09-21 A | 100% | 2010-09-23 | 2011-09-21 | 262d? | finish no earlier than 2011-09-21 | S1 | 2080h | 2080h | SIPTO_SC-SA1 | 25 | 22.101, 22.220 | Vodafone | mona.mustapha@vodafone.com | Rel-12 | 49 | Alain | HNB |  |  |  |
| 1945 | 599 | **Interworking between Mobile Operators using the Evolved Packet System and Data Application Providers** | 792d? | 2010-12-16 A | 2013-12-11 A | 100% | 2010-12-16 | 2013-12-11 | 792d? |  | S1; S2 | 22794.7h | 22794.7h | MOSAP | 26 | Stage 1 | Cisco | Vojislav Vucetic (vvucetic@cisco.com) | Rel-12 | 50 | Alain |  | MOSAP |  |  |
| 1946 | 599.1 | Stage 1 for MOSAP | 202d? | 2010-12-16 A | 2011-09-21 A | 100% | 2010-12-16 | 2011-09-21 | 202d? | finish no earlier than 2011-09-21 | S1 | 1600h | 1600h | MOSAP-SA1 | 26 | 22.278 | Cisco | Vojislav Vucetic (vvucetic@cisco.com) | Rel-12 | 50 | Alain |  |  |  |  |
| 1947 | 599.2 | TR on Stage 2 for MOSAP | 669d? | 2011-06-06 A | 2013-12-11 A | 100% | 2011-06-06 | 2013-12-11 | 669d? | finish no earlier than 2012-12-12 | S2 | 5338.74h | 5338.74h | MOSAP-SA2TR | 27 | new TR 23.862 | Intel | chang.hong.shan@intel.com | Rel-12 | 52 | Maurice |  |  |  |  |
| 1948 | 599.3 | Deleted - Stage 2 for MOSAP | 399d? | 2011-06-14 A | 2012-12-12 A | 100% | 2011-06-14 | 2012-12-12 | 399d? | finish no earlier than 2012-12-12 | S2 | 3184h | 3184h | MOSAP-SA2Del | 27 | TBD | Intel | chang.hong.shan@intel.com | Rel-12 | 52 | Maurice |  |  | PCG-30 | SP-58 |
| 1949 | 600 | **IMS Network-Independent Public User Identities** | 275d? | 2011-06-08 A | 2012-06-20 A | 100% | 2011-06-08 | 2012-06-20 | 275d? |  | S1 | 4390.4h | 4390.4h | INIPUI | 27 | Stage 1 | Vodafone | mona.mustapha@vodafone.com | Rel-12 | 52 | Alain |  | INIPUI |  |  |
| 1950 | 600.1 | Stage 1 for IMS Network-Independent Public User Identities | 275d? | 2011-06-08 A | 2012-06-20 A | 100% | 2011-06-08 | 2012-06-20 | 275d? | finish no earlier than 2012-06-20 | S1 | 2190.4h | 2190.4h | INIPUI-SA1 | 27 | 22.115, 22.228 | Vodafone | mona.mustapha@vodafone.com | Rel-12 | 52 | Alain |  |  |  |  |
| 1951 | 601 | **Service and Media Reachability for Users over Restrictive Firewalls** | 198d? | 2011-09-21 A | 2012-06-20 A | 100% | 2011-09-21 | 2012-06-20 | 198d? |  | S1 | 3161.67h | 3161.67h | SMURFs | 27 | Stage 1 | Vodafone | mona.mustapha@vodafone.com | Rel-12 | 53 | Alain |  | SMURFs |  |  |
| 1952 | 601.1 | Stage 1 for Service and Media Reachability for Users over Restrictive Firewalls | 198d? | 2011-09-21 A | 2012-06-20 A | 100% | 2011-09-21 | 2012-06-20 | 198d? | finish no earlier than 2012-06-08 | S1 | 1577.67h | 1577.67h | SMURFs-SA1 | 27 | 22.278 | Vodafone | mona.mustapha@vodafone.com | Rel-12 | 53 | Alain |  |  |  |  |
| 1953 | 602 | **Advanced IP Interconnection of Services (IPXS) for national interconnect** | 139d? | 2012-03-06 A | 2012-09-12 A | 100% | 2012-03-06 | 2012-09-12 | 139d? |  | S1 | 2208h | 2208h | IPXSNAT | 28 | Stage 1 | KPN | toon.norp@tno.nl | Rel-12 | 55 | Alain |  | IPXSNAT |  |  |
| 1954 | 602.1 | Stage 1 for Advanced IP Interconnection of Services (IPXS) for national interconnect | 139d? | 2012-03-06 A | 2012-09-12 A | 100% | 2012-03-06 | 2012-09-12 | 139d? | finish no earlier than 2012-09-12 | S1 | 1096h | 1096h | IPXSNAT-SA1 | 28 | 22.228 CR#0161 | KPN | toon.norp@tno.nl | Rel-12 | 55 | Alain |  |  |  |  |
| 1955 | 603 | **Integration of Single Sign-On (SSO) frameworks with 3GPP networks** | 137d? | 2012-03-08 A | 2012-09-12 A | 100% | 2012-03-08 | 2012-09-12 | 137d? |  | S1 | 2184h | 2184h | SSO_Int | 28 | Stage 1 | InterDigital | christopher.wallace@interdigital.com | Rel-12 | 55 | Alain |  | SSO_Int |  |  |
| 1956 | 603.1 | Stage 1 for Integration of Single Sign-On (SSO) frameworks with 3GPP networks | 137d? | 2012-03-08 A | 2012-09-12 A | 100% | 2012-03-08 | 2012-09-12 | 137d? | finish no earlier than 2012-09-12 | S1 | 1088h | 1088h | SSO_Int-SA1 | 28 | 22.101 | InterDigital | christopher.wallace@interdigital.com | Rel-12 | 55 | Alain |  |  |  |  |
| 1957 | 604 | **Explicit Communication Transfer Blind (ECT Blind) service interactions** | 3d? | 2012-06-18 A | 2012-06-20 A | 100% | 2012-06-18 | 2012-06-20 | 3d? |  | S1 | 48h | 48h | ECTB | 29 | Stage 1 | Orange | philippe.lottin@orange.com | Rel-12 | 56 | Alain |  | ECTB |  |  |
| 1958 | 604.1 | Stage 1 for Explicit Communication Transfer Blind (ECT Blind) service interactions | 3d? | 2012-06-18 A | 2012-06-20 A | 100% | 2012-06-18 | 2012-06-20 | 3d? | finish no earlier than 2012-06-20 | S1 | 24h | 24h | ECTB-SA1 | 29 | 22.173 | Orange | philippe.lottin@orange.com | Rel-12 | 56 | Alain |  |  |  |  |
| 1959 | 605 | **IMS access via Digital Video Broadcast - Return Channel via Satellite (DVB-RCS2)** | 162d? | 2012-02-02 A | 2012-09-12 A | 100% | 2012-02-02 | 2012-09-12 | 162d? |  | S1 | 2584h | 2584h | IMSSat | 29 | Stage 1 | KPN | toon.norp@tno.nl | Rel-12 | 57 | Alain |  | IMSSat |  |  |
| 1960 | 605.1 | Stage 1 for IMS access via DVB-RCS2 | 162d? | 2012-02-02 A | 2012-09-12 A | 100% | 2012-02-02 | 2012-09-12 | 162d? | finish no earlier than 2012-09-12 | S1 | 1288h | 1288h | IMSSat-SA1 | 29 | 22.228 | KPN | toon.norp@tno.nl | Rel-12 | 57 | Alain |  |  |  |  |
| 1961 | 606 | **Sequential Flexible Alerting** | 3d? | 2012-12-10 A | 2012-12-12 A | 100% | 2012-12-10 | 2012-12-12 | 3d? |  | S1 | 48h | 48h | SEQ_FA | 30 | Stage 1 | Orange | bruno.tossou@orange-ftgroup.com | Rel-12 | 58 | Alain |  | IMSSat |  |  |
| 1962 | 606.1 | Stage 1 for Sequential Flexible Alerting | 3d? | 2012-12-10 A | 2012-12-12 A | 100% | 2012-12-10 | 2012-12-12 | 3d? | finish no earlier than 2012-12-12 | S1 | 24h | 24h | SEQ_FA | 30 | 22.173 | Orange | bruno.tossou@orange-ftgroup.com | Rel-12 | 58 | Alain |  |  |  |  |
| 1963 | 607 | **Language and Modality Information for communications** | 63d? | 2012-12-11 A | 2013-03-06 A | 100% | 2012-12-11 | 2013-03-06 | 63d? |  | S1 | 1008h | 1008h | LangInfo | 30 | Stage 1 | Orange | philippe.lottin@orange.com | Rel-12 | 58 | Alain |  | LangInfo |  |  |
| 1964 | 607.1 | Stage 1 for Language and Modality Information for communications | 63d? | 2012-12-11 A | 2013-03-06 A | 100% | 2012-12-11 | 2013-03-06 | 63d? | finish no earlier than 2013-03-06 | S1 | 504h | 504h | LangInfo-SA1 | 30 | 22.228 | Orange | philippe.lottin@orange.com | Rel-12 | 58 | Alain |  |  |  |  |
| 1965 | 608 | **Emergency Session Identification** | 3d? | 2013-03-04 A | 2013-03-06 A | 100% | 2013-03-04 | 2013-03-06 | 3d? |  | S1 | 48h | 48h | ESID | 30 | Stage 1 | Telecom Italia | carmen.catalano@telecomitalia.it | Rel-12 | 59 | Alain |  | ESID |  |  |
| 1966 | 608.1 | Stage 1 for Emergency Session Identification | 3d? | 2013-03-04 A | 2013-03-06 A | 100% | 2013-03-04 | 2013-03-06 | 3d? | finish no earlier than 2013-03-06 | S1 | 24h | 24h | ESID-SA1 | 30 | 22.101 | Telecom Italia | carmen.catalano@telecomitalia.it | Rel-12 | 59 | Alain |  |  |  |  |

Notes:
- 1943: SP#57 moved to Rel-12 (Reason: Stage 2 for requirements in TS 22.101 clause 4.3.5 have not been implemented in Rel-11). Linked to Rel-10 Local IP Access and Selected Internet IP Traffic Offload (LIPA_SIPTO)
- 1944: SP#57 moved to Rel-12. SP#53 completed
- 1945: SP#58 Stage 2 stopped (TR only, no normative work done)
- 1946: SP#53 completed
- 1947: SP#62 completed. TR 23.862v200 for Approval. SP#58 frozen as v100.
- 1948: SP#58 stopped (no normative work done)
- 1949: Triggered by Rel-11 TR 22.894 (FS_INIPUI)
- 1950: SP#56 re-completed. Updated WID SP-110381=>SP-120425 (Re-opened & moved to Rel-12 by adding new reqs & removing reqs from Rel-11). SP#53 Rel-11 Stage 1 completed
- 1951: SP#56 Stage 1 completed
- 1952: SP#56 completed
- 1953: SP#57 Stage 1 completed. Linked to Rel-11 Feature Advanced IP Interconnection of Services (IPXS) UID_470051.
- 1954: SP#57 completed
- 1955: SP#57 Stage 1 completed. Triggered by Rel-12 TR 22.895. Linked to SA3 33.8xy (Study on Security aspects of SSO_Int), 33.914 (SSO application security for common IMS based on SIP Digest), 33.924 (i/w GBA and OpenID), 33.980 (i/w GBA and Liberty Alliance)
- 1956: SP#57 completed
- 1957: SP#56 WID approved & Stage 1 completed
- 1958: SP#56 new WID approved & work completed. Clarify the service interactions between ECT Blind and other MMTEL Supplementary Services
- 1959: SP#57 Stage 1 completed. Integrate Satcom access with IMS. Specify DVB-RCS2 as an IP Connectivity Access Network for IMS
- 1960: SP#57 completed. Definition of DVB-RCS2 as a non-3GPP IP Connectivity Access Network for IMS
- 1961: SP#58 approved WID & Stage 1 completed. Currently Flexible Alerting (FA) group members are simultaneously alerted by the incoming call. Add the possibility to alert FA group members sequentially. 22/01: acronym modified
- 1962: SP#58 approved WID & Stage 1 completed
- 1963: SP#59 Stage 1 completed. Triggered by Rel-11 Study on Non Voice Emergency Services (FS_NOVES) TR 22.871 use case 10
- 1964: SP#59 completed. Updated WID SP-120937=>SP-130108
- 1965: SP#59 Stage 1 completed.
- 1966: SP#59 completed (22.101 CR#0445)

| ID | WBS | Task | Duration | Start | Finish | Complete | Baseline start | Baseline finish | Baseline duration | Constraint | Resources | Work | Actual work | Acronym | PCG approved | WI rapporteur name | WI rapporteur e-mail | Release | TSG approved | MCC resp | PCG stopped | TSG stopped | Acronym_3GU_Export | Special Focus Doc | Status Report |
| --- | --- | --- | --- | --- | --- | --- | --- | --- | --- | --- | --- | --- | --- | --- | --- | --- | --- | --- | --- | --- | --- | --- | --- | --- | --- |
| 1967 | 609 | **Deleted - Application and Service Access Control** | 77d? | 2013-03-06 A | 2013-06-19 A | 100% | 2013-03-06 | 2013-06-19 | 77d? |  | S1 | 1224h | 1224h | ASAC | 30 | NTT DOCOMO | Atsushi Minokuchi (minokuchi@nttdocomo.co.jp) | Rel-12 | 59 | Alain | PCG-31 | SP-60 | ASAC |  |  |
| 1968 | 609.1 | Deleted - Stage 1 for Application and Service Access Control | 77d? | 2013-03-06 A | 2013-06-19 A | 100% | 2013-03-06 | 2013-06-19 | 77d? | finish no earlier than 2013-06-19 | S1 | 608h | 608h | ASAC-SA1del | 30 | NTT DOCOMO | Atsushi Minokuchi (minokuchi@nttdocomo.co.jp) | Rel-12 | 59 | Alain | PCG-31 | SP-60 |  |  |  |
| 1969 | 610 | **Prevention of Mobile-Originating signalling and/or data traffic of UE in Connected mode** | 3d? | 2013-03-04 A | 2013-03-06 A | 100% | 2013-03-04 | 2013-03-06 | 3d? |  | S1 | 48h | 48h | PMOC | 30 | NTT DOCOMO | Atsushi Minokuchi (minokuchi@nttdocomo.co.jp) | Rel-12 | 59 | Alain |  |  | PMOC |  |  |
| 1970 | 610.1 | Stage 1 for Prevention of Mobile-Originating signalling and/or data traffic of UE in Connected mode | 3d? | 2013-03-04 A | 2013-03-06 A | 100% | 2013-03-04 | 2013-03-06 | 3d? | finish no earlier than 2013-03-06 | S1 | 24h | 24h | PMOC-SA1 | 30 | NTT DOCOMO | Atsushi Minokuchi (minokuchi@nttdocomo.co.jp) | Rel-12 | 59 | Alain |  |  |  |  |  |
| 1971 | 611 | SA1/SA2 Features | 216d? | 2013-05-17 A | 2014-03-07 A | 100% | 2013-05-17 | 2014-03-07 | 216d? | finish no earlier than 2014-03-07 | SP; CP; RP | 5184h | 5184h |  | 30 |  |  | Rel-12 | 58 |  |  |  |  |  |  |
| 1972 | 612 | **LIPA Mobility and SIPTO at the Local Network** | 898d? | 2010-10-15 A | 2014-03-06 A | 100% | 2010-10-15 | 2014-03-06 | 898d? |  | S2; C4; C1; R3 | 87994h | 87994h | LIMONET | 26 | Huawei | zhufenqin@huawei.com | Rel-12 | 50 | Maurice |  |  | LIMONET | HNB |  |
| 1973 | 612.1 | TR on Stage 2 for LIPA Mobility and SIPTO at the Local Network | 580.85d? | 2010-10-15 A | 2013-03-06 A | 100% | 2010-10-15 | 2013-03-06 | 580.85d? | finish no earlier than 2013-03-06 | S2 | 4646.8h | 4646.8h | LIMONET-SA3 | 26 | Huawei | zhufenqin@huawei.com | Rel-12 | 50 | Maurice |  |  |  | HNB |  |
| 1974 | 612.2 | **BB1: SIPTO at the Local Network** | 892d? | 2010-10-22 A | 2014-03-05 A | 100% | 2010-10-22 | 2014-03-05 | 892d? |  | S2 | 31685.6h | 31685.6h | LIMONET-SIPTO | 26 | Huawei | zhufenqin@huawei.com | Rel-12 | 50 | Maurice |  |  | LIMONET-SIPTO | HNB |  |
| 1975 | 612.2.1 | Stage 2 for SIPTO at the Local Network | 655.85d? | 2010-10-22 A | 2013-06-19 A | 100% | 2010-10-22 | 2013-06-19 | 655.85d? | finish no earlier than 2013-06-19 | S2 | 5246.8h | 5246.8h | LIMONET-SIPTO-SA2 | 26 | Huawei | zhufenqin@huawei.com | Rel-12 | 50 | Maurice |  |  |  | HNB |  |
| 1976 | 612.2.2 | **Stage 3 CN aspects of SIPTO at the Local Network** | 649d? | 2011-09-24 A | 2014-03-05 A | 100% | 2011-09-24 | 2014-03-05 | 649d? |  | C4; C1 | 19680h | 19680h | LIMONET-SIPTO | 27 | Huawei | peter.schmitt@huawei.com | Rel-12 | 53 | Kimmo |  |  |  | HNB |  |
| 1977 | 612.2.2.1 | CT4 part of Stage 3 CN aspects of SIPTO at the Local Network | 518d? | 2011-09-24 A | 2013-09-06 A | 100% | 2011-09-24 | 2013-09-06 | 518d? | finish no earlier than 2013-09-06 | C4 | 4136h | 4136h | LIMONET-SIPTO-CT4 | 27 | Huawei | peter.schmitt@huawei.com | Rel-12 | 53 | Kimmo |  |  |  | HNB |  |
| 1978 | 612.2.2.2 | CT1 part of Stage 3 CN aspects of SIPTO at the Local Network | 646d? | 2011-09-24 A | 2014-03-05 A | 100% | 2011-09-24 | 2014-03-05 | 646d? | finish no earlier than 2014-01-29 | C1 | 5160h | 5160h | LIMONET-SIPTO-CT1 | 27 | Huawei | peter.schmitt@huawei.com | Rel-12 | 53 | Frederic |  |  |  | HNB |  |
| 1979 | 612.3 | **RAN aspects for SIPTO at the Local Network** | 269d? | 2013-03-04 A | 2014-03-06 A | 100% | 2013-03-04 | 2014-03-06 | 269d? |  | R3 | 4272h | 4272h | LIMONET-RAN | 30 | Huawei | zheng.zhou@huawei.com | Rel-12 | 59 | Juha |  |  | LIMONET-RAN | HNB |  |
| 1980 | 612.3.1 | Core part: RAN aspects for SIPTO at the Local Network | 266d? | 2013-03-04 A | 2014-03-06 A | 100% | 2013-03-04 | 2014-03-06 | 266d? | finish no earlier than 2014-03-06 | R3 | 2120h | 2120h | LIMONET-RAN-Core | 30 | Huawei | zheng.zhou@huawei.com | Rel-12 | 59 | Juha |  |  | LIMONET-RAN-Core | HNB | RP-131512 |
| 1981 | 612.4 | **Deleted - BB2: Stand-alone L-GW and associated Mobility for LIPA and SIPTO at the Local Network** | 566d? | 2010-10-22 A | 2012-12-12 A | 100% | 2010-10-22 | 2012-12-12 | 566d? |  | S2 | 18653.6h | 18653.6h | LIMONET-LIPA | 26 | Huawei | zhufenqin@huawei.com | Rel-12 | 50 | Maurice | PCG-30 | SP-58 | LIMONET-LIPA | HNB |  |
| 1982 | 612.4.1 | Deleted - Stage 2 for stand-alone L-GW and associated Mobility for LIPA and SIPTO at the Local Network | 519.85d? | 2010-10-22 A | 2012-12-12 A | 100% | 2010-10-22 | 2012-12-12 | 519.85d? | finish no earlier than 2012-12-12 | S2 | 4158.8h | 4158.8h | LIMONET-LIPA-del1 | 26 | Huawei | zhufenqin@huawei.com | Rel-12 | 50 | Maurice | PCG-30 | SP-58 |  | HNB |  |
| 1983 | 612.4.2 | **Deleted - Stage 3 CN aspects of LIPA Mobility** | 323d? | 2011-09-24 A | 2012-12-12 A | 100% | 2011-09-24 | 2012-12-12 | 323d? |  | C1; C4 | 10336h | 10336h | LIMONET-LIPA-del2 | 27 | Huawei | christian.herrero@huawei.com | Rel-12 | 53 | Frederic | PCG-30 | SP-58 |  | HNB |  |
| 1984 | 612.4.2.1 | Deleted - CT1 part of CN aspects of LIPA Mobility | 323d? | 2011-09-24 A | 2012-12-12 A | 100% | 2011-09-24 | 2012-12-12 | 323d? | finish no earlier than 2012-12-12 | C1 | 2584h | 2584h | LIMONET-LIPA-del3 | 27 | Huawei | christian.herrero@huawei.com | Rel-12 | 53 | Frederic | PCG-30 | SP-58 |  | HNB |  |
| 1985 | 612.4.2.2 | Deleted - CT4 part of CN aspects of LIPA Mobility | 323d? | 2011-09-24 A | 2012-12-12 A | 100% | 2011-09-24 | 2012-12-12 | 323d? | finish no earlier than 2012-12-12 | C4 | 2584h | 2584h | LIMONET-LIPA-del4 | 27 | Huawei | christian.herrero@huawei.com | Rel-12 | 53 | Kimmo | PCG-30 | SP-58 |  | HNB |  |
| 1986 | 613 | **Operator Policies for IP Interface Selection** | 720d? | 2011-03-23 A | 2013-12-06 A | 100% | 2011-03-23 | 2013-12-06 | 720d? |  | S2; C1 | 20256h | 20256h | OPIIS | 26 | LG Electronics | taehyeon.kim@lge.com | Rel-12 | 51 | Maurice |  |  | OPIIS |  |  |
| 1987 | 613.1 | TR on Stage 2 for Operator Policies for IP Interface Selection | 457d? | 2011-03-23 A | 2012-12-12 A | 100% | 2011-03-23 | 2012-12-12 | 457d? | finish no earlier than 2012-12-12 | S2 | 3640h | 3640h | OPIIS | 26 | LG Electronics | taehyeon.kim@lge.com | Rel-12 | 51 | Maurice |  |  |  |  |  |
| 1988 | 613.2 | Stage 2 for Operator Policies for IP Interface Selection | 511d? | 2011-04-04 A | 2013-03-06 A | 100% | 2011-04-04 | 2013-03-06 | 511d? | finish no earlier than 2013-03-06 | S2 | 4088h | 4088h | OPIIS | 26 | LG Electronics | taehyeon.kim@lge.com | Rel-12 | 51 | Maurice |  |  |  |  |  |
| 1989 | 613.3 | Stage 3 for Operator Policies for IP Interface Selection | 126d? | 2013-06-14 A | 2013-12-06 A | 100% | 2013-06-14 | 2013-12-06 | 126d? | finish no earlier than 2013-12-06 | C1 | 1008h | 1008h | OPIIS-CT | 31 | LG Electronics | Jaehyun Kim (jaehyun7.kim@lge.com) | Rel-12 | 60 | Frederic |  |  | OPIIS-CT |  |  |
| 1990 | 614 | **Short Message Service (SMS) submit and delivery without MSISDN in IMS** | 665d? | 2011-06-08 A | 2013-12-06 A | 100% | 2011-06-08 | 2013-12-06 | 665d? |  | S2; C1; C4 | 28336.3h | 28336.3h | SMSMI | 27 | Nokia Siemens Networks | curt.wong@nsn.com | Rel-12 | 52 | Maurice |  |  | SMSMI |  |  |
| 1991 | 614.1 | TR on Stage 2 for SMS submit and delivery without MSISDN in IMS | 402d? | 2011-06-08 A | 2012-12-12 A | 100% | 2011-06-08 | 2012-12-12 | 402d? | finish no earlier than 2012-12-12 | S2 | 3192.32h | 3192.32h | SMSMI-SA2TR | 27 | Nokia Siemens Networks | curt.wong@nsn.com | Rel-12 | 52 | Maurice |  |  |  |  |  |
| 1992 | 614.2 | Stage 2 for SMS submit and delivery without MSISDN in IMS | 400d? | 2011-06-13 A | 2012-12-12 A | 100% | 2011-06-13 | 2012-12-12 | 400d? | finish no earlier than 2012-12-12 | S2 | 3192h | 3192h | SMSMI-SA2 | 27 | Nokia Siemens Networks | curt.wong@nsn.com | Rel-12 | 52 | Maurice |  |  |  |  |  |

Notes:
- 1967: SP#60 stopped and Rel-13 FS_ACDC continues. Triggered by TR 22.806 Study on Application specific Congestion control for Data Communication (FS_ACDC) UID_570034 / Impacted TSs and TRs: Stage 1
- 1968: SP#60 stopped and Rel-13 FS_ACDC contd. Allow/prohibit for E-UTRAN idle mode UE initiation of particular applications defined by operator and subject to regional regulations. Prevent/mitigate overload of AN/CN defined by operator (congestion or disaster) / Impacted TSs and TRs: 22.011
- 1969: SP#59 Stage 1 completed / Impacted TSs and TRs: Stage 1
- 1970: SP#59 completed / Impacted TSs and TRs: 22.011
- 1971: -
- 1972: CP#63 completed. SP#58 updated WID SP-120256=>SP-120926 (stopped BB2 LIMONET-LIPA on Mobility). Linked to UID_450035 Local IP Access and Selected IP Traffic Offload (LIPA_SIPTO) / Impacted TSs and TRs: Stage 2/3
- 1973: SP#59 completed. TR 23.859 v100 for Information and Approval / Impacted TSs and TRs: new TR 23.859
- 1974: SP#60 completed / Impacted TSs and TRs: 23.060, 23.401
- 1975: SP#60 completed / Impacted TSs and TRs: 23.060, 23.401
- 1976: CP#63 completed / Impacted TSs and TRs: Stage 3
- 1977: CP#61 completed / Impacted TSs and TRs: 23.003, 23.008, 29.002, 29.060, 29.230, 29.272, 29.274, 29.303
- 1978: CP#63 completed / Impacted TSs and TRs: 24.008, 24.301
- 1979: - / Impacted TSs and TRs: UTRA, LTE
- 1980: RP#62 completed / Impacted TSs and TRs: 25.401, 25.413, 25.423, 25.467, 25.469, 36.300, 36.413, 36.423
- 1981: SP#58 updated WID SP-120256=>SP-120926 (stopped BB2 LIMONET-LIPA on Mobility) / Impacted TSs and TRs: 23.060, 23.401
- 1982: SP#58 updated WID SP-120256=>SP-120926 (stopped BB2 LIMONET-LIPA on Mobility) / Impacted TSs and TRs: 23.060, 23.401
- 1983: SP#58 CT Stage 3 part stopped because of SA stopping Stage 2 for BB2 LIMONET-LIPA on Mobility) / Impacted TSs and TRs: Stage 3
- 1984: SP#58 CT Stage 3 part stopped because of SA stopping Stage 2 for BB2 LIMONET-LIPA on Mobility) / Impacted TSs and TRs: 24.008, 24.301
- 1985: SP#58 CT Stage 3 part stopped because of SA stopping Stage 2 for BB2 LIMONET-LIPA on Mobility) / Impacted TSs and TRs: 29.060, 29.274, 29.281, 29.303, 29.002, 29.272, 29.275, 29.282, 29.305
- 1986: Linked to Rel-10 IFOM IP Flow Mobility and seamless WLAN offload (non-seamless WLAN offload aspects) & Rel-11 LIMONET (support traffic offload at local network) / Impacted TSs and TRs: Stage 2/3
- 1987: SP#58 completed / Impacted TSs and TRs: new TR 23.853
- 1988: SP#59 completed (23.402 CR#152: Introduction of Inter-APN Routing Policies) / Impacted TSs and TRs: 23.402
- 1989: CP#62 completed. Specify Inter-APN Routing Policies for selecting an IP interface to route IP flows among a choice of available interfacES in CP-150both 3GPP and non-3GPP accesses / Impacted TSs and TRs: 24.302, 24.312
- 1990: Linked to Rel-7 SMSIP (Support of SMS over generic 3GPP IP access), Rel-11 SIMTC, Rel-12 TR 22.988 SA1 Study on alternatives to E.164 for MTC / Impacted TSs and TRs: Stage 2/3
- 1991: SP#58 completed / Impacted TSs and TRs: new TR 23.863
- 1992: SP#58 completed / Impacted TSs and TRs: 23.204, 23.682

| ID | WBS | Task | Duration | Start | Finish | Complete | Remaining | Baseline start | Baseline finish | Baseline duration | Total slack | Constraint | Resources | Work | Actual work | Acronym | PCG approved | Impacted TSs and TRs | WI rapporteur name | WI rapporteur e-mail | Release | TSG approved | MCC resp | Acronym_3GU_Export | Status Report | Special Focus Doc |
| --- | --- | --- | --- | --- | --- | --- | --- | --- | --- | --- | --- | --- | --- | --- | --- | --- | --- | --- | --- | --- | --- | --- | --- | --- | --- | --- |
| 1993 | 614.3 | **Stage 3 for SMS submit and delivery without MSISDN in IMS** | 205d? | 2013-03-01 A | 2013-12-06 A | 100% |  | 2013-03-01 | 2013-12-06 | 205d? |  |  | C1; C4 | 5992h | 5992h | SMSMI-CT | 30 | Stage 3 | NSN | peter.leis@nsn.com | Rel-12 | 59 | Frederic | SMSMI-CT |  |  |
| 1994 | 614.3.1 | CT1 part of Stage 3 for SMS submit and delivery without MSISDN in IMS | 205d? | 2013-03-01 A | 2013-12-06 A | 100% |  | 2013-03-01 | 2013-12-06 | 205d? |  | finish no earlier than 2013-12-06 | C1 | 1608h | 1608h | SMSMI-CT | 30 | 23.040, 24.341 | NSN | peter.leis@nsn.com | Rel-12 | 59 | Frederic |  |  |  |
| 1995 | 614.3.2 | CT4 part of Stage 3 for SMS submit and delivery without MSISDN in IMS | 139d? | 2013-03-01 A | 2013-09-06 A | 100% |  | 2013-03-01 | 2013-09-06 | 139d? |  | finish no earlier than 2013-09-06 | C4 | 1104h | 1104h | SMSMI-CT | 30 | 23.008, 29.002, 29.305, 29.328, 29.338 | NSN | peter.leis@nsn.com | Rel-12 | 59 | Kimmo |  |  |  |
| 1996 | 615 | **IMS-based Telepresence** | 1247.5d? | 2010-03-22 A | 2014-12-09 | 66% | 430.02d? | 2010-03-19 | 2014-12-05 | 1243.5d? | 1440d |  | S1; C1; C3; C4; IETF | 122882h | 38645.9h | IMS_TELEP | 27 | Stage 1/2/3 | Orange | bruno.tossou@orange-ftgroup.com | Rel-12 | 53 | Alain | IMS_TELEP |  |  |
| 1997 | 615.1 | Stage 1 for IMS-based Telepresence | 197d? | 2011-09-22 A | 2012-06-20 A | 100% |  | 2011-09-22 | 2012-06-20 | 197d? |  | finish no earlier than 2012-06-08 | S1 | 1569.86h | 1569.86h | IMS_TELEP | 27 | 22.228 | Orange | bruno.tossou@orange-ftgroup.com | Rel-12 | 53 | Alain |  |  |  |
| 1998 | 615.2 | **CT part for IMS Telepresence (Stage 2/3)** | 1247.5d? | 2010-03-22 A | 2014-12-09 | 64% | 444.19d? | 2010-03-19 | 2014-12-05 | 1243.5d? | 1440d |  | C1; C3; C4; IETF | 87712h | 30772h | IMS_TELEP | 30 | Stage 2/3 | Huawei | Weiwei(Tommy) Yang (tommy@huawei.com) | Rel-12 | 58 | Frederic |  |  |  |
| 1999 | 615.2.1 | TR on CT part of IMS Telepresence (Stage 2/3) | 399d? | 2012-12-07 A | 2014-06-13 A | 100% |  | 2012-12-07 | 2014-06-13 | 399d? |  | finish no earlier than 2014-06-13 | C1 | 3184h | 3184h | IMS_TELEP | 30 | New TR 24.803 | Huawei | Weiwei(Tommy) Yang (tommy@huawei.com) | Rel-12 | 58 | Frederic |  |  |  |
| 2000 | 615.2.2 | CT1 part of IMS Telepresence (Stage 3) | 526d? | 2012-12-07 A | 2014-12-09 A | 100% |  | 2012-12-07 | 2014-09-12 | 464d? |  | finish no earlier than 2014-12-09 | C1 | 4208h | 4208h | IMS_TELEP | 30 | 24.147, 24.166, 24.229, New TS 24.103 | Huawei | Weiwei(Tommy) Yang (tommy@huawei.com) | Rel-12 | 58 | Frederic |  | CP-140616 |  |
| 2001 | 615.2.3 | (IETF) CT1 part of IMS Telepresence (mmusic-sctp-sdp) | 851d? | 2010-03-22 A | 2014-12-09 | 50% | 425.5d? | 2010-03-19 | 2014-12-05 | 849d? | 1440d | finish no earlier than 2014-12-09 | C1-IETF | 6808h | 3404h | IMS_TELEP | 33 | draft-ietf-mmusic-sctp-sdp | christer.holmberg@ericsson.com | christer.holmberg@ericsson.com | Rel-12 | 64 |  |  |  |  |
| 2002 | 615.2.4 | (IETF) CT1 part of IMS Telepresence (clue-framework ) | 851d? | 2010-03-22 A | 2014-12-09 | 50% | 425.5d? | 2010-03-19 | 2014-12-05 | 849d? | 1440d | finish no earlier than 2014-12-09 | C1-IETF | 6808h | 3404h | IMS_TELEP | 33 | draft-ietf-clue-framework | christer.holmberg@ericsson.com | christer.holmberg@ericsson.com | Rel-12 | 64 |  |  |  |  |
| 2003 | 615.2.5 | (IETF) CT1 part of IMS Telepresence (clue-datachannel) | 851d? | 2010-03-22 A | 2014-12-09 | 50% | 425.5d? | 2010-03-19 | 2014-12-05 | 849d? | 1440d | finish no earlier than 2014-12-09 | C1-IETF | 6808h | 3404h | IMS_TELEP | 33 | draft-ietf-clue-datachannel | christer.holmberg@ericsson.com | christer.holmberg@ericsson.com | Rel-12 | 64 |  |  |  |  |
| 2004 | 615.2.6 | (IETF) CT1 part of IMS Telepresence (clue-signaling) | 851d? | 2010-03-22 A | 2014-12-09 | 50% | 425.5d? | 2010-03-19 | 2014-12-05 | 849d? | 1440d | finish no earlier than 2014-12-09 | C1-IETF | 6808h | 3404h | IMS_TELEP | 33 | draft-ietf-clue-signaling | christer.holmberg@ericsson.com | christer.holmberg@ericsson.com | Rel-12 | 64 |  |  |  |  |
| 2005 | 615.2.7 | (IETF) CT1 part of IMS Telepresence (clue-data-model-schema) | 851d? | 2010-03-22 A | 2014-12-09 | 50% | 425.5d? | 2010-03-19 | 2014-12-05 | 849d? | 1440d | finish no earlier than 2014-12-09 | C1-IETF | 6808h | 3404h | IMS_TELEP | 33 | draft-ietf-clue-data-model-schema | christer.holmberg@ericsson.com | christer.holmberg@ericsson.com | Rel-12 | 64 |  |  |  |  |
| 2006 | 615.2.8 | CT3 part of IMS Telepresence (Stage 3) | 467d? | 2012-12-07 A | 2014-09-11 A | 100% |  | 2012-12-07 | 2014-09-12 | 467d? |  | finish no earlier than 2014-09-12 | C3 | 3736h | 3736h | IMS_TELEP | 30 | 29.165 | Huawei | Weiwei(Tommy) Yang (tommy@huawei.com) | Rel-12 | 58 | Adrian |  |  |  |
| 2007 | 615.2.9 | CT4 part of IMS Telepresence (Stage 2/3) | 328d? | 2013-09-13 A | 2014-12-09 A | 100% |  | 2013-09-10 | 2014-09-12 | 266d? |  | finish no earlier than 2014-12-09 | C4 | 2624h | 2624h | IMS_TELEP | 31 | 23.333, 29.333 | Huawei | Weiwei(Tommy) Yang (tommy@huawei.com) | Rel-12 | 61 | Kimmo |  | CP-140477 |  |
| 2008 | 616 | **Group Communication System Enablers for LTE** | 727d? | 2012-06-18 A | 2015-03-15 A | 100% |  | 2012-06-18 | 2014-09-17 | 597d? |  |  | S1; S2; S3; C3; C4; R3; C1 | 59744h | 58696h | GCSE_LTE | 29 | Stage 1/2/3 | Nokia Networks | Juergen.Merkel@nsn.com | Rel-12 | 56 | Alain | GCSE_LTE |  | Public Safety (A-A) |
| 2009 | 616.1 | Stage 1 for Group Communication System Enablers for LTE | 267d? | 2012-06-18 A | 2013-06-19 A | 100% |  | 2012-06-18 | 2013-06-19 | 267d? |  | finish no earlier than 2013-06-19 | S1 | 2128h | 2128h | GCSE_LTE | 29 | New TS 22.468 | Nokia Networks | Juergen.Merkel@nsn.com | Rel-12 | 56 | Alain |  |  | Public Safety (A-A) |
| 2010 | 616.2 | TR on Architecture enhancements to support Group Communication System Enablers for LTE | 267d? | 2013-03-07 A | 2014-03-07 A | 100% |  | 2013-03-07 | 2014-03-07 | 267d? |  | finish no earlier than 2014-03-07 | S2 | 2128h | 2128h | GCSE_LTE | 30 | New TR 23.768 | Nokia Networks | rainer.liebhart@nsn.com | Rel-12 | 59 | Maurice |  |  | Public Safety (A-A) |
| 2011 | 616.3 | Stage 2 for Group Communication System Enablers for LTE | 402d? | 2013-03-12 A | 2014-09-16 A | 100% |  | 2013-03-12 | 2014-09-17 | 402d? |  | finish no earlier than 2014-09-17 | S2 | 3208h | 3208h | GCSE_LTE | 30 | New TS 23.468 | Nokia Networks | rainer.liebhart@nsn.com | Rel-12 | 59 | Maurice |  |  | Public Safety (A-A) |
| 2012 | 616.4 | TR on Security for Group Communication System Enablers for LTE (Stage 2) | 201d? | 2013-09-12 A | 2014-06-18 A | 100% |  | 2013-09-12 | 2014-06-18 | 201d? |  | finish no earlier than 2014-06-18 | S3 | 1608h | 1608h | GCSE_LTE | 31 | New TR 33.888 | Nokia Networks | anja.jerichow@nsn.com | Rel-12 | 61 | Mirko |  |  | Public Safety (A-A) |
| 2013 | 616.5 | Security for Group Communication System Enablers for LTE (Stage 2) | 201d? | 2013-09-13 A | 2014-06-18 A | 100% |  | 2013-09-13 | 2014-06-18 | 201d? |  | finish no earlier than 2014-06-18 | S3 | 1608h | 1608h | GCSE_LTE | 31 | 33.246 | Nokia Networks | anja.jerichow@nsn.com | Rel-12 | 61 | Mirko |  |  | Public Safety (A-A) |
| 2014 | 616.6 | **CT aspects of Group Communication System Enablers for LTE** | 131d? | 2014-06-13 A | 2014-12-09 A | 100% |  | 2014-06-13 | 2014-09-12 | 66d? |  |  | C3; C4; C1 | 5200h | 4152h | GCSE_LTE-CT | 33 | Stage 3 | Nokia Networks | thomas.belling@nsn.com | Rel-12 | 64 |  | GCSE_LTE-CT |  | Public Safety (A-A) |
| 2015 | 616.6.1 | CT3 part of Group Communication System Enablers for LTE | 66d? | 2014-06-13 A | 2014-09-11 A | 100% |  | 2014-06-13 | 2014-09-12 | 66d? |  | finish no earlier than 2014-09-12 | C3 | 528h | 528h | GCSE_LTE-CT | 33 | 29.212, 29.213, 29.214, 29.274, New TS 29.468 | Nokia Networks | thomas.belling@nsn.com | Rel-12 | 64 |  |  |  | Public Safety (A-A) |
| 2016 | 616.6.2 | CT4 part of Group Communication System Enablers for LTE | 128d? | 2014-06-13 A | 2014-12-09 A | 100% |  | 2014-06-13 | 2014-09-12 | 66d? |  | finish no earlier than 2014-12-09 | C4 | 1024h | 1024h | GCSE_LTE-CT | 33 | 23.007, 23.008 | Nokia Networks | thomas.belling@nsn.com | Rel-12 | 64 |  |  | CP-140725 | Public Safety (A-A) |
| 2017 | 616.6.3 | CT1 part of Group Communication System Enablers for LTE | 63d? | 2014-09-12 A | 2014-12-09 A | 100% |  |  |  |  |  | finish no earlier than 2014-12-09 | C1 | 504h | 504h | GCSE_LTE-CT | 33 | 24.301 | Nokia Networks | thomas.belling@nsn.com | Rel-12 | 65 |  |  | CP-140614 | Public Safety (A-A) |

Notes:
- 1993: CP#62 completed. Address scenario IMS client to IMS client SMS (comprises SMS receive and send SMS without requiring an MSISDN associated as part of their subscription record in HSS
- 1994: CP#62 completed
- 1995: CP#61 completed
- 1996: This feature does not introduce any changes to the IMS architecture, and no stage 2 impacts are identified
- 1997: SP#56 completed. 2/4/15: acronym changed to IMS_TELEP
- 1998: CP#65 updated WID CP-140196=>CP-140624. 2/4/15: acronym changed to IMS_TELEP
- 1999: CP#64 completed. 2/4/15: acronym changed to IMS_TELEP
- 2000: CP#65 TS 24.103v100 for Information. Updated WID CP-140196=>CP-140624. Completion 09/14=>12/14. Exception in CP-140616. Dec.14: 90->100%. 2/4/15: acronym changed to IMS_TELEP
- 2001: work in progress. 2/4/15: acronym changed to IMS_TELEP
- 2002: work in progress. 2/4/15: acronym changed to IMS_TELEP
- 2003: work in progress. 2/4/15: acronym changed to IMS_TELEP
- 2004: work in progress. 2/4/15: acronym changed to IMS_TELEP
- 2005: work in progress. 2/4/15: acronym changed to IMS_TELEP
- 2006: CP#65 completed. 2/4/15: acronym changed to IMS_TELEP
- 2007: CP#65 updated WID CP-140196=>CP-140624. Completion 09/14=>12/14. Exception in CP-140477. Mar.15: 0->100%. 2/4/15: acronym changed to IMS_TELEP
- 2008: Linked to Rel-12 FS_ProSe TR 22.803 Study on Proximity-based Services. External requirements: NIST, MESA, APCO Global Alliance, TCCA. Specify 3GPP system enablers to support group communication over LTE for Public Safety
- 2009: SP#60 completed. TS 22.468 v100 for 1-step Approval
- 2010: SP#63 completed. TR 23.768v200 for Approval
- 2011: SP#65 completed. Updated WID SP-140113=>SP-140433. SP#63 TS 23.468v100 for 1-step Approval
- 2012: SP#64 completed. TR 33.888v100 for 1-step Approval
- 2013: SP#64 completed
- 2014: CP#65 updated WID CP-140452=>C3-143199 (added CT1 part)
- 2015: CP#65 completed. TS 29.468v200 for Approval
- 2016: CP#65 completion 09/14=>12/14. Exception in CP-140725. Dec.14: 35->100
- 2017: CP#65 updated WID CP-140452=>CP-140559 (added CT1 part). Exception in CP-140614. Dec.14: 90->100%

| ID | WBS | Task | Duration | Start | Finish | Complete | Remaining | Baseline start | Baseline finish | Baseline duration | Total slack | Constraint | Resources | Work | Actual work | Acronym | PCG approved | Impacted TSs and TRs | WI rapporteur name | WI rapporteur e-mail | Release | TSG approved | Special Focus Doc | Acronym_3GU_Export | Status Report | MCC resp | PCG stopped | TSG stopped |
| --- | --- | --- | --- | --- | --- | --- | --- | --- | --- | --- | --- | --- | --- | --- | --- | --- | --- | --- | --- | --- | --- | --- | --- | --- | --- | --- | --- | --- |
| 2018 | 616.7 | **Group Call eMBMS congestion management for LTE** | 198d? | 2014-06-16 A | 2015-03-15 A | 100% |  | 2014-06-13 | 2014-09-12 | 66d? |  |  | R3 | 3152h | 3152h | GCSE_LTE-MBMS_CM | 33 | LTE | Alcatel-Lucent | hakon.helmers@alcatel-lucent.com | Rel-12 | 64 | Public Safety (A-A) | GCSE_LTE-MBMS_CM |  |  |  |  |
| 2019 | 616.7.1 | Core part: Group Call eMBMS congestion management for LTE | 196d? | 2014-06-16 A | 2015-03-15 A | 100% |  | 2014-06-13 | 2014-09-12 | 66d? |  | finish no earlier than 2015-03-15 | R3 | 1568h | 1568h | GCSE_LTE-MBMS_CM-Core | 33 | 36.413 | Alcatel-Lucent | hakon.helmers@alcatel-lucent.com | Rel-12 | 64 | Public Safety (A-A) | GCSE_LTE-MBMS_CM-Core | RP-150081 |  |  |  |
| 2020 | 617 | **Machine-Type and other mobile data applications Communications enhancements** | 1692d? | 2009-12-10 A | 2016-05-12 | 98% | 40.3d? | 2009-12-10 | 2014-09-12 | 1255d? | 1068d |  |  | 58859h | 57908.6h | MTCe | 29 | Stage 1/2/3 | Intel | puneet.jain@intel.com | Rel-12 | 56 | MTC, M2M | MTCe |  | Maurice |  |  |
| 2021 | 617.1 | Stage 1 for Support for Interworking with M2M Service Enablement | 189d? | 2012-06-18 A | 2013-03-06 A | 100% |  | 2012-06-18 | 2013-03-06 | 189d? |  | finish no earlier than 2013-03-06 | S1 | 1504h | 1504h | MTCe-SIMSE | 29 | 22.368 | KPN | toon.norp@tno.nl | Rel-12 | 56 | MTC, M2M | MTCe-SIMSE |  | Alain |  |  |
| 2022 | 617.2 | Stage 1 for Machine-Type and other mobile data applications Communications – Service Requirement Maintenance | 127d? | 2012-09-13 A | 2013-03-06 A | 100% |  | 2012-09-13 | 2013-03-06 | 127d? |  | finish no earlier than 2013-03-06 | S1 | 1008h | 1008h | MTCe-SRM | 29 | 22.101, 22.368 | KPN | toon.norp@tno.nl | Rel-12 | 57 | MTC, M2M | MTCe-SRM |  | Alain |  |  |
| 2023 | 617.3 | TR on Security aspects of Machine-Type Communications | 1113d? | 2009-12-10 A | 2014-03-07 A | 100% |  | 2009-12-10 | 2014-03-07 | 1113d? |  | finish no earlier than 2014-03-07 | S3 | 8896h | 8896h | MTCe-SA3TR | 29 | New TR 33.868 | Samsung | Rajavelsamy R (rajvel@samsung.com) | Rel-12 | 56 | MTC, M2M |  |  | Mirko |  |  |
| 2024 | 617.4 | Security and Privacy aspects for Machine-Type and other mobile data applications Communications enhancements (Stage 2) | 452d? | 2012-06-22 A | 2014-03-07 A | 100% |  | 2012-06-22 | 2014-03-07 | 452d? |  | finish no earlier than 2014-03-07 | S3 | 3608h | 3608h | MTCe-SA3 | 29 | New TS 33.187 | Samsung | Rajavelsamy R (rajvel@samsung.com) | Rel-12 | 56 | MTC, M2M |  |  | Mirko |  |  |
| 2025 | 617.5 | **BB1: Small Data and Device Triggering Enhancements (SDDTE)** | 594d? | 2012-06-18 A | 2014-09-11 A | 100% |  | 2012-06-18 | 2014-09-12 | 594d? |  |  | S2; C4; C3 | 24400h | 24400h | MTCe-SDDTE | 29 |  | Intel | puneet.jain@intel.com | Rel-12 | 56 | MTC, M2M | MTCe-SDDTE |  | Maurice |  |  |
| 2026 | 617.5.1 | TR on Stage 2 BB1: Small Data and Device Triggering Enhancements | 394d? | 2012-06-18 A | 2013-12-11 A | 100% |  | 2012-06-18 | 2013-12-11 | 394d? |  | finish no earlier than 2013-12-11 | S2 | 3128h | 3128h | MTCe-SDDTE | 29 | New TR 23.887 | Intel | puneet.jain@intel.com | Rel-12 | 56 | MTC, M2M |  |  | Maurice |  |  |
| 2027 | 617.5.2 | Stage 2 for BB1: Small Data and Device Triggering Enhancements | 390d? | 2012-06-26 A | 2013-12-11 A | 100% |  | 2012-06-26 | 2013-12-11 | 390d? |  | finish no earlier than 2013-12-11 | S2 | 3120h | 3120h | MTCe-SDDTE | 29 | 23.682 | Intel | puneet.jain@intel.com | Rel-12 | 56 | MTC, M2M |  |  | Maurice |  |  |
| 2028 | 617.5.3 | **Stage 3 for BB1: Small Data and Device Triggering Enhancements** | 138d? | 2014-03-05 A | 2014-09-11 A | 100% |  | 2014-03-05 | 2014-09-12 | 138d? |  |  | C4; C3 | 3896h | 3896h | MTCe-SDDTE-CT | 32 | Stage 3 | Huawei | peter.schmitt@huawei.com | Rel-12 | 63 | MTC, M2M | MTCe-SDDTE-CT |  | Kimmo |  |  |
| 2029 | 617.5.3.1 | CT4 part of Stage 3 for BB1: Small Data and Device Triggering Enhancement | 138d? | 2014-03-05 A | 2014-09-11 A | 100% |  | 2014-03-05 | 2014-09-12 | 138d? |  | finish no earlier than 2014-09-12 | C4 | 1104h | 1104h | MTCe-SDDTE-CT | 32 | 29.002, 29.336, 23.008, 29.337, 29.338, 29.230 | Huawei | peter.schmitt@huawei.com | Rel-12 | 63 | MTC, M2M |  |  | Kimmo |  |  |
| 2030 | 617.5.3.2 | CT3 part of Stage 3 for BB1: Small Data and Device Triggering Enhancement | 73d? | 2014-03-05 A | 2014-06-13 A | 100% |  | 2014-03-05 | 2014-06-13 | 73d? |  | finish no earlier than 2014-06-13 | C3 | 584h | 584h | MTCe-SDDTE-CT | 32 | 29.368 | Huawei | peter.schmitt@huawei.com | Rel-12 | 63 | MTC, M2M |  |  | Adrian |  |  |
| 2031 | 617.6 | Deleted - BB2: Monitoring Enhancements (MONTE) | 131d? | 2012-06-18 A | 2012-12-12 A | 100% |  | 2012-06-18 | 2012-12-12 | 131d? |  | finish no earlier than 2012-12-12 | S2 | 1048h | 1048h | MTCe-MONTE | 29 | 23.682 | Intel | puneet.jain@intel.com | Rel-12 | 56 | MTC, M2M | MTCe-MONTE |  | Maurice | PCG-30 | SP-58 |
| 2032 | 617.7 | **BB3: UE Power Consumptions Optimizations (UEPCOP)** | 1031d? | 2012-06-18 A | 2016-05-12 | 93% | 71.29d? | 2012-06-18 | 2014-09-12 | 594d? | 1068d |  |  | 13712h | 12761.6h | MTCe-UEPCOP | 29 |  | Ericsson | peter.hedman@ericsson.com | Rel-12 | 56 | MTC, M2M | MTCe-UEPCOP |  | Maurice |  |  |
| 2033 | 617.7.1 | TR on Stage 2 BB3: UE Power Consumptions Optimizations (UEPCOP) | 394d? | 2012-06-18 A | 2013-12-11 A | 100% |  | 2012-06-18 | 2013-12-11 | 394d? |  | finish no earlier than 2013-12-11 | S2 | 3128h | 3128h | MTCe-UEPCOP | 29 | New TR 23.887 | Ericsson | peter.hedman@ericsson.com | Rel-12 | 56 | MTC, M2M |  |  | Maurice |  |  |
| 2034 | 617.7.2 | Stage 2 for BB3: UE Power Consumptions Optimizations (UEPCOP) | 390d? | 2012-06-26 A | 2013-12-11 A | 100% |  | 2012-06-26 | 2013-12-11 | 390d? |  | finish no earlier than 2013-12-11 | S2 | 3120h | 3120h | MTCe-UEPCOP | 29 | 23.060, 23.401, 23.682 | Ericsson | peter.hedman@ericsson.com | Rel-12 | 56 | MTC, M2M |  |  | Maurice |  |  |
| 2035 | 617.7.3 | **Stage 3 for BB3: UE Power Consumptions Optimizations (UEPCOP)** | 597d? | 2013-12-06 A | 2016-03-15 A | 100% |  | 2013-12-06 | 2014-09-12 | 202d? |  |  |  | 6368h | 6368h | MTCe-UEPCOP-CT | 32 | Stage 3 | Ericsson | mikael.wass@ericsson.com | Rel-12 | 62 | MTC, M2M | MTCe-UEPCOP-CT |  | Frederic |  |  |
| 2036 | 617.7.3.1 | CT1 part of Stage 3 for BB3: UE Power Consumptions Optimizations (UEPCOP) | 202d? | 2013-12-06 A | 2014-09-11 A | 100% |  | 2013-12-06 | 2014-09-12 | 202d? |  | finish no earlier than 2014-09-12 | C1 | 1608h | 1608h | MTCe-UEPCOP-CT1 | 32 | 24.008, 24.301 | Ericsson | mikael.wass@ericsson.com | Rel-12 | 62 | MTC, M2M |  |  | Frederic |  |  |
| 2037 | 617.7.3.2 | Deleted - CT4 part of Stage 3 for BB3: UE Power Consumptions Optimizations (UEPCOP) | 201d? | 2013-12-09 A | 2014-09-11 A | 100% |  | 2013-12-09 | 2014-09-12 | 201d? |  | finish no earlier than 2014-09-12 | C4 | 1608h | 1608h | MTCe-UEPCOP-CT4 | 32 | 29.274, 29.060, 23.008 | Ericsson | mikael.wass@ericsson.com | Rel-12 | 62 | MTC, M2M |  |  | Kimmo | PCG-33 | CP-65 |
| 2038 | 617.7.3.3 | CT6 part of Stage 3 for BB3: UE Power Consumptions Optimizations (UEPCOP) | 263d? | 2013-12-09 A | 2014-12-09 A | 100% |  | 2013-12-09 | 2014-09-12 | 201d? |  | finish no earlier than 2014-12-09 | C6 | 2104h | 2104h | MTCe-UEPCOP-CT6 | 32 | 31.101, 31.102, 31.111 | Ericsson | mikael.wass@ericsson.com | Rel-12 | 62 | MTC, M2M |  | CP-140697 | Xavier |  |  |
| 2039 | 617.7.3.4 | UE Conformance Test Aspects - UE Power Consumptions Optimizations (UEPCOP) | 131d? | 2015-09-15 A | 2016-03-15 A | 100% |  |  |  |  |  | finish no earlier than 2016-03-15 | R5 | 1048h | 1048h | MTCe-UEPCOP-UEConTest | 35 |  | Ericsson |  | Rel-12 | 69 |  |  |  |  |  |  |
| 2040 | 617.7.4 | Support of Power Saving Mode in GERAN | 5d? | 2014-08-25 A | 2014-08-29 A | 100% |  |  |  |  |  | finish no earlier than 2014-08-29 | G1 | 40h | 40h | MTCe-UEPCOP-GERAN | 33 | 43.022 | Ericsson | sajal.kumar.das@ericsson.com | Rel-12 | 63 |  | MTCe-UEPCOP-GERAN |  |  |  |  |
| 2041 | 617.7.5 | Testing of Support of Power Saving Mode in GERAN | 132d? | 2015-11-11 A | 2016-05-12 | 10% | 118.8d? |  |  |  | 1068d | finish no earlier than 2016-05-12 | G3 | 1056h | 105.6h | MTCe-UEPCOP_GERAN3new | 36 |  | Ericsson | sajal.kumar.das@ericsson.com | Rel-12 | 70 |  | MTCe-UEPCOP-GERAN |  |  |  |  |
| 2042 | 617.8 | Deleted - BB4: Group based MTC feature (GROUP) | 129d? | 2012-06-20 A | 2012-12-12 A | 100% |  | 2012-06-20 | 2012-12-12 | 129d? |  | finish no earlier than 2012-12-12 | S2 | 1032h | 1032h | MTCe-GROUP | 29 | 23.682 | KPN | Annemieke Kips | Rel-12 | 56 | MTC, M2M | MTCe-GROUP |  | Maurice | PCG-30 | SP-58 |

Notes:
- 2018: -
- 2019: CD:Thu 11/12/14->Sun 15/03/15; Compl:25%->80%; Stat Rep: RP-141327->RP-141863 1st Apr 15: Compl:80%->100% 1st Apr 15: Stat Rep: RP-141863->RP-150081
- 2020: -
- 2021: SP#59 completed. Define requirements for interworking with M2M service enablement layer specified by ETSI TC M2M in TS 102 689 ( specification for Service Enablement layer)
- 2022: SP#59 completed. Updated WID SP-120541=>SP-130105
- 2023: SP#63 completed. TR 33.868v100 for 1-step Approval. Was Rel-10 UID_460023 (Security for NIMTC). Was Rel-11 UID_490028 (TR on Security aspects of MTC). SP#56 activity transferred to Rel-12 Feature MTCe
- 2024: SP#63 completed. TS 33.187v100 for 1-step Approval
- 2025: -
- 2026: SP#62 completed. TR 23.887v200 for Approval
- 2027: SP#62 completed
- 2028: CP#65 updated WID CP-140272=>CP-140489
- 2029: CP#65 completed. Updated WID CP-140272=>CP-140489
- 2030: CP#64 completed
- 2031: SP#58 stopped (at 20% completion)
- 2032: -
- 2033: SP#62 completed. TR 23.887v200 for Approval
- 2034: SP#62 completed
- 2035: -
- 2036: CP#65 completed
- 2037: CP#65 stopped (no inpact on CT4)
- 2038: CP#65 completion 09/14=>12/14. Exception in CP-140697; June2015: Compl:90%->100
- 2039: tested: MTCe-UEPCOP was a REL-12 SA2 WI; NAS over LTE and UTRA;1/1/16: Compl:0%->25%22/3/16: C
- 2040: GP#63 approved WID and completed
- 2041: 7/12/15: created.02/3/16: acronym: MTCe-UEPCOP-GERAN_test->MTCe-UEPCOP_GERAN3new; 2/3/16: 0%->10
- 2042: SP#58 stopped (at 25% completion)

| ID | WBS | Task | Duration | Start | Finish | Complete | Baseline start | Baseline finish | Baseline duration | Constraint | Resources | Work | Actual work | Acronym | PCG approved | WI rapporteur name | WI rapporteur e-mail | Release | TSG approved | MCC resp | Special Focus Doc | Acronym_3GU_Export | Status Report | PCG stopped | TSG stopped |
| --- | --- | --- | --- | --- | --- | --- | --- | --- | --- | --- | --- | --- | --- | --- | --- | --- | --- | --- | --- | --- | --- | --- | --- | --- | --- |
| 2043 | 617.9 | **RAN enhancements for Machine-Type and other mobile data applications Communications** | 161.2d? | 2014-02-03 A | 2014-09-12 A | 100% | 2014-02-03 | 2014-09-12 | 160.2d? |  | R2; R3 | 3651h | 3651h | MTCe-RAN | 32 | ZTE | sergio.parolari@zte.com.cn | Rel-12 | 62 | Yong-Jun | MTC, M2M | MTCe-RAN |  |  |  |
| 2044 | 617.9.1 | Core part: RAN enhancements for Machine-Type and other mobile data applications Communications | 133d? | 2014-02-03 A | 2014-09-12 A | 100% | 2014-02-03 | 2014-09-12 | 133d? | finish no earlier than 2014-09-12 | R2; R3 | 2128h | 2128h | MTCe-RAN-Core | 32 | ZTE | sergio.parolari@zte.com.cn | Rel-12 | 62 | Yong-Jun | MTC, M2M | MTCe-RAN-Core | RP-141096 |  |  |
| 2045 | 618 | **Low cost & enhanced coverage MTC UE for LTE** | 922d? | 2013-06-15 A | 2016-12-15 A | 100% | 2013-06-20 | 2015-03-13 | 456d? |  | R1; R2; R4 | 34104h | 34104h | LC_MTC_LTE | 31 | Vodafone | eric.bouton@vodafone.com | Rel-12 | 60 | Patrick | MTC, M2M | LC_MTC_LTE |  |  |  |
| 2046 | 618.1 | Core part: Low cost & enhanced coverage MTC UE for LTE | 174.67d? | 2013-06-15 A | 2014-12-15 A | 100% | 2013-10-15 | 2014-09-12 | 108.67d? | finish no earlier than 2014-12-15 | R1; R2; R4 | 4192h | 4192h | LC_MTC_LTE-Core | 31 | Vodafone | eric.bouton@vodafone.com | Rel-12 | 60 | Patrick | MTC, M2M | LC_MTC_LTE-Core | RP-142024 |  |  |
| 2047 | 618.2 | Perf. part: Low cost & enhanced coverage MTC UE for LTE | 522d? | 2013-06-15 A | 2015-06-15 A | 100% | 2013-06-20 | 2015-03-13 | 456d? | finish no earlier than 2015-06-15 | R4 | 4176h | 4176h | LC_MTC_LTE-Perf | 31 | Vodafone | eric.bouton@vodafone.com | Rel-12 | 60 | Issam | MTC, M2M | LC_MTC_LTE-Perf | RP-150915 |  |  |
| 2048 | 618.3 | UE Conformance Test Aspects - Low cost & enhanced coverage MTC UE for LTE | 460d? | 2015-03-16 A | 2016-12-15 A | 100% |  |  |  | finish no earlier than 2016-12-15 | R5 | 3680h | 3680h | LC_MTC_LTE-UEConTest | 34 | Ericsson |  | Rel-12 | 67 |  |  |  |  |  |  |
| 2049 | 619 | **Policy and Charging Control for supporting fixed broadband access networks** | 660d? | 2012-06-20 A | 2014-12-12 A | 100% | 2012-06-20 | 2014-09-17 | 595d? |  | S2; S1; S5; C3; C1; C4 | 84075.4h | 84075.4h | P4C | 29 | Huawei | marco.spini@huawei.com | Rel-12 | 56 | Maurice |  | P4C |  |  |  |
| 2050 | 619.1 | Stage 1 for Policy and Charging Support for Fixed Mobile Convergence | 3d? | 2012-09-10 A | 2012-09-12 A | 100% | 2012-09-10 | 2012-09-12 | 3d? | finish no earlier than 2012-09-12 | S1 | 24h | 24h | P4C-FMC | 29 | Huawei | amar.deol@huawei.com | Rel-12 | 57 | Alain |  | P4C-FMC |  |  |  |
| 2051 | 619.2 | **BB1: Policy and Charging Control for supporting traffic from fixed terminals and NSWO (Non Seamless WLAN Offload) traffic from 3GPP UEs in fixed broadband access networks (P4C-F)** | 660d? | 2012-06-20 A | 2014-12-12 A | 100% | 2012-06-20 | 2014-09-17 | 595d? |  | S2; S5; C3; C1; C4 | 45657.3h | 45657.3h | P4C-F | 29 | Huawei | marco.spini@huawei.com | Rel-12 | 56 | Maurice | WLAN | P4C-F |  |  |  |
| 2052 | 619.2.1 | TR on Stage 2 for BB1: Policy and Charging Control for supporting traffic from fixed terminals and NSWO traffic from 3GPP UEs in fixed broadband access networks (P4C-F) | 539.9d? | 2012-06-20 A | 2014-12-12 A | 100% | 2012-06-20 | 2014-09-17 | 476.9d? | finish no earlier than 2014-12-12 | S2 | 4290.1h | 4290.1h | P4C-F-SA2TR | 29 | Huawei | marco.spini@huawei.com | Rel-12 | 56 | Maurice | WLAN |  |  |  |  |
| 2053 | 619.2.2 | Stage 2 for BB1: Policy and Charging Control for supporting traffic from fixed terminals and NSWO traffic from 3GPP UEs in fixed broadband access networks (P4C-F) | 272.9d? | 2012-06-20 A | 2013-12-11 A | 100% | 2012-06-20 | 2013-12-11 | 272.9d? | finish no earlier than 2013-12-11 | S2 | 2183.2h | 2183.2h | P4C-F-SA2 | 29 | Huawei | marco.spini@huawei.com | Rel-12 | 56 | Maurice | WLAN |  |  |  |  |
| 2054 | 619.2.3 | **Stage 3 for BB1: Policy and Charging Control for supporting traffic from fixed terminals and NSWO traffic from 3GPP UEs in fixed broadband access networks** | 203d? | 2013-09-06 A | 2014-06-13 A | 100% | 2013-09-06 | 2014-06-13 | 203d? |  | C3; C1; C4 | 8088h | 8088h | P4C-F-CT3 | 31 | Huawei | Xia Haitao (xiahaitao@huawei.com) | Rel-12 | 61 | Adrian | WLAN | P4C-F-CT3 |  |  |  |
| 2055 | 619.2.3.1 | CT3 part of Stage 3 for BB1: Policy and Charging Control for supporting traffic from fixed terminals and NSWO traffic from 3GPP UEs in fixed broadband access networks | 203d? | 2013-09-06 A | 2014-06-13 A | 100% | 2013-09-06 | 2014-06-13 | 203d? | finish no earlier than 2014-06-13 | C3 | 1608h | 1608h | P4C-F-CT3 | 31 | Huawei | Xia Haitao (xiahaitao@huawei.com) | Rel-12 | 61 | Adrian | WLAN |  |  |  |  |
| 2056 | 619.2.3.2 | CT1 part of Stage 3 for BB1: Policy and Charging Control for supporting traffic from fixed terminals and NSWO traffic from 3GPP UEs in fixed broadband access networks | 65d? | 2013-12-06 A | 2014-03-05 A | 100% | 2013-12-06 | 2014-03-05 | 65d? | finish no earlier than 2014-03-05 | C1 | 512h | 512h | P4C-F-CT3 | 32 | Huawei | Xia Haitao (xiahaitao@huawei.com) | Rel-12 | 62 | Frederic | WLAN |  |  |  |  |
| 2057 | 619.2.3.3 | CT4 part of Stage 3 for BB1: Policy and Charging Control for supporting traffic from fixed terminals and NSWO traffic from 3GPP UEs in fixed broadband access networks | 137d? | 2013-12-06 A | 2014-06-13 A | 100% | 2013-12-06 | 2014-06-13 | 137d? | finish no earlier than 2014-06-13 | C4 | 1096h | 1096h | P4C-F-CT3 | 32 | Huawei | Xia Haitao (xiahaitao@huawei.com) | Rel-12 | 62 | Kimmo | WLAN |  |  |  |  |
| 2058 | 619.2.4 | Policy and Charging Enforcement Function (PCEF) based Charging for traffic from fixed terminals and NSWO traffic from 3GPP UEs in fixed broadband access networks (Stage 2/3) | 326d? | 2013-06-21 A | 2014-09-17 A | 100% | 2013-06-21 | 2014-09-17 | 326d? | finish no earlier than 2014-09-17 | S5 | 2608h | 2608h | P4C-F-CH_P | 31 | Alcatel-Lucent | maryse.gardella@alcatel-lucent.com | Rel-12 | 60 | Mirko | WLAN | P4C-F-CH_P |  |  |  |
| 2059 | 619.2.5 | Traffic Detection Function (TDF) based Charging for traffic from fixed terminals and NSWO traffic from 3GPP UEs in fixed broadband access networks (Stage 2/3) | 261d? | 2013-06-24 A | 2014-06-18 A | 100% | 2013-06-24 | 2014-06-18 | 261d? | finish no earlier than 2014-06-18 | S5 | 2088h | 2088h | P4C-F-CH_T | 31 | Openet Telecom | alan.mcnamee@openet.com | Rel-12 | 60 | Mirko | WLAN | P4C-F-CH_T |  |  |  |
| 2060 | 619.3 | **BB2: Policy and Charging Control for 3GPP UEs connected to BroadBand Forum access network as Trusted network in Interworking scenario (P4C-TI)** | 266d? | 2012-06-20 A | 2013-06-19 A | 100% | 2012-06-20 | 2013-06-19 | 266d? |  | S2 | 2610.07h | 2610.07h | P4C-TI | 29 | Alcatel-Lucent | konstantin.livanos@alcatel-lucent.com | Rel-12 | 56 | Maurice |  | P4C-TI |  |  |  |
| 2061 | 619.3.1 | TR on Stage 2 for BB2: Policy and Charging Control for 3GPP UEs connected to BroadBand Forum access network as Trusted network in Interworking scenario (P4C-TI) | 109.2d? | 2012-06-20 A | 2013-06-19 A | 100% | 2012-06-20 | 2013-06-19 | 109.2d? | finish no earlier than 2013-06-06 | S2 | 862.87h | 862.87h | P4C-TI-SA2TR | 29 | Alcatel-Lucent | konstantin.livanos@alcatel-lucent.com | Rel-12 | 56 | Maurice |  |  |  |  |  |
| 2062 | 619.3.2 | Stage 2 for BB2: Policy and Charging Control for 3GPP UEs connected to BroadBand Forum access network as Trusted network in Interworking scenario (P4C-TI) | 109.2d? | 2012-06-20 A | 2013-06-19 A | 100% | 2012-06-20 | 2013-06-19 | 109.2d? | finish no earlier than 2013-06-19 | S2 | 873.6h | 873.6h | P4C-TI-SA2 | 29 | Alcatel-Lucent | konstantin.livanos@alcatel-lucent.com | Rel-12 | 56 | Maurice |  |  |  |  |  |
| 2063 | 619.4 | Deleted - BB3: Policy and Charging Control for 3GPP UEs connected to fixed broadband access network via S2b and S2c reference points for EPC routed traffic (P4C-S2bc) | 128d? | 2012-06-21 A | 2012-12-12 A | 100% | 2012-06-21 | 2012-12-12 | 128d? | finish no earlier than 2012-12-12 | S2 | 1024h | 1024h | P4C-S2bc | 29 | ZTE | Tricci So (tso@zteusa.com) | Rel-12 | 56 | Maurice |  | P4C-S2bc |  | PCG-30 | SP-58 |
| 2064 | 619.5 | Deleted - BB4: Policy and Charging Control for EPC routed traffic over fixed broadband access networks of 3GPP UEs connected via H(e)NB in convergent scenarios (P4C-HeNB) | 128d? | 2012-06-21 A | 2012-12-12 A | 100% | 2012-06-21 | 2012-12-12 | 128d? | finish no earlier than 2012-12-12 | S2 | 1024h | 1024h | P4C-HeNB | 29 | NEC | Stefan.Schmid@neclab.eu | Rel-12 | 56 | Maurice |  | P4C-HeNB |  | PCG-30 | SP-58 |
| 2065 | 619.6 | Deleted - BB5: Policy and Charging Control for supporting Layer 2 traffic in fixed broadband access network (P4C-FL2) | 128d? | 2012-06-21 A | 2012-12-12 A | 100% | 2012-06-21 | 2012-12-12 | 128d? | finish no earlier than 2012-12-12 | S2 | 1024h | 1024h | P4C-FL2 | 29 | Huawei | marco.spini@huawei.com | Rel-12 | 56 | Maurice |  | P4C-FL2 |  | PCG-30 | SP-58 |
| 2066 | 619.7 | Deleted - BB6: Policy and Charging Control for 3GPP UEs connected to fixed broadband access networks via S2a reference point for EPC routed traffic in convergence (P4C-TC) | 129d? | 2012-06-20 A | 2012-12-12 A | 100% | 2012-06-20 | 2012-12-12 | 129d? | finish no earlier than 2012-12-12 | S2 | 1032h | 1032h | P4C-TC | 29 | ZTE | Tricci So (tso@zteusa.com) | Rel-12 | 56 | Maurice |  | P4C-TC |  | PCG-30 | SP-58 |

Notes:
- 2043: Triggered by TR 23.887 Machine Type and other mobile data applications Communications Enhancements (MTCe), TR 37.869 Study on Enhancements MTC and other Mobile Data Applications; RAN aspects (FS_MTCe_RAN), Rel-11 TR 23.888 SIMTC / Impacted TSs and TRs: UTRA, LTE
- 2044: RP#65 completed / Impacted TSs and TRs: 25.300, 25.304, 25.413, 36.300, 36.304, 36.413, 36.423
- 2045: Triggered by Rel-11 TR 36.888 (FS_LC_MTC_UE) / Impacted TSs and TRs: LTE
- 2046: ; CD:Thu 18/06/15->Mon 15/06/15; WID: RP-130848->RP-140522; Stat Rep: RP-141221->RP-142024 / Impacted TSs and TRs: 36.101, 36.104, 36.133, 36.201, 36.211, 36.212, 36.213, 36.300, 36.302, 36.306, 36.321, 36.331
- 2047: ; CD:Thu 18/06/15->Mon 15/06/15; WID: RP-130848->RP-140522; Stat Rep: RP-141221->RP-142024 1st Apr 15: Compl:65%->90% 1st Apr 15: CD:Sun 15/03/15->Mon 15/06/15 1st Apr 15: Stat Rep: RP-142024->RP-150149 03/07/15: Compl:90%->100% 03/07/15: WID: RP-14052 / Impacted TSs and TRs: 36.101, 36.104, 36.133
- 2048: 03/07/15: Compl:0%->13% 03/07/15: WID: RP-150135->RP-150838 03/07/15: Stat Rep: ->RP-150833 29/09/15: Compl:13%->25% 29/09/15: Stat Rep: RP-150833->RP-151165 ; 1/1/16: Compl:25%->70% ; 1/1/16: CD:Tue 15/12/15->Tue 15/03/16
- 2049: Linked to BBF, IETF work. SP#58 stopped BB3 to BB6. Split BB1 and BB2 into TR and Stage 2 work / Impacted TSs and TRs: Stage 1/2/3
- 2050: SP#57 completed / Impacted TSs and TRs: 22.278
- 2051: -
- 2052: SP#64 TR 23.896 was never sent for approval due to incomplete P4C BBs. SP#61 TR 23.896v100 for Information. Dec.14: 90->100%. Mar15: 23.896 for approval. / Impacted TSs and TRs: new TR 23.896
- 2053: SP#62 completed / Impacted TSs and TRs: 23.139, 23.203
- 2054: - / Impacted TSs and TRs: Stage 3
- 2055: CP#64 completed / Impacted TSs and TRs: 29.212, 29.213, 29.215, 29.219
- 2056: CP#63 completed / Impacted TSs and TRs: 24.302
- 2057: CP#64 completed / Impacted TSs and TRs: 29.273
- 2058: SP#65 completed. Introduce Charging Characteristics in Convergent scenario, Include missing fixed user location information for NSWO / Impacted TSs and TRs: Stage 2 (32.240, 32.251), Stage 3 (32.298, 32.299)
- 2059: SP#64 completed / Impacted TSs and TRs: Stage 2 (32.240, 32.251), Stage 3 (32.298, 32.299)
- 2060: -
- 2061: SP#60 completed / Impacted TSs and TRs: new TR 23.839
- 2062: SP#60 completed / Impacted TSs and TRs: 23.139, 23.203
- 2063: SP#58 stopped (at 0% completion) / Impacted TSs and TRs: 23.139, 23.203, new TR 23.896
- 2064: SP#58 stopped (at 0% completion) / Impacted TSs and TRs: 23.139, 23.203, new TR 23.896
- 2065: SP#58 stopped (at 0% completion) / Impacted TSs and TRs: 23.139, 23.203, new TR 23.896
- 2066: SP#58 stopped (at 30% completion) / Impacted TSs and TRs: 23.139, 23.203, new TR 23.896

| ID | WBS | Task | Duration | Start | Finish | Complete | Baseline start | Baseline finish | Baseline duration | Constraint | Resources | Work | Actual work | Acronym | PCG approved | Impacted TSs and TRs | WI rapporteur name | WI rapporteur e-mail | Release | TSG approved | MCC resp | Acronym_3GU_Export | Status Report | Special Focus Doc | PCG stopped | TSG stopped |
| --- | --- | --- | --- | --- | --- | --- | --- | --- | --- | --- | --- | --- | --- | --- | --- | --- | --- | --- | --- | --- | --- | --- | --- | --- | --- | --- |
| 2067 | 620 | **IMS Business Trunking for IP-PBX in Static Mode of Operation** | 847.1d? | 2011-09-28 A | 2014-12-09 A | 100% | 2011-09-28 | 2014-09-12 | 782.1d? |  | S2; S1; C1; C3 | 43555.2h | 43555.2h | BusTI | 29 | Stage 1/2/3 | Deutsche Telekom | michele.zarri@telekom.com | Rel-12 | 56 | Maurice | BusTI |  |  |  |  |
| 2068 | 620.1 | Stage 1 for IMS Business Trunking for IP-PBX in Static Mode of Operation | 64d? | 2011-09-28 A | 2012-09-12 A | 100% | 2011-09-28 | 2012-09-12 | 64d? | finish no earlier than 2012-08-30 | S1 | 504h | 504h | BusTI-SA1 | 29 | 22.228 | Deutsche Telekom | kurt.bischinger@t-mobile.at | Rel-12 | 56 | Alain |  |  |  |  |  |
| 2069 | 620.2 | TR on IMS Business Trunking for IP-PBX in Static Mode of Operation | 268d? | 2012-06-18 A | 2013-06-19 A | 100% | 2012-06-18 | 2013-06-19 | 268d? | finish no earlier than 2013-06-19 | S2; S1 | 4288h | 4288h | BusTI-SATR | 29 | new TR 23.897 | Deutsche Telekom | michele.zarri@telekom.com | Rel-12 | 56 | Maurice |  |  |  |  |  |
| 2070 | 620.3 | Stage 2 for IMS Business Trunking for IP-PBX in Static Mode of Operation | 263d? | 2012-06-25 A | 2013-06-19 A | 100% | 2012-06-25 | 2013-06-19 | 263d? | finish no earlier than 2013-06-19 | S2 | 2104h | 2104h | BusTI-SA2 | 29 | 23.228 | Deutsche Telekom | michele.zarri@telekom.com | Rel-12 | 56 | Maurice |  |  |  |  |  |
| 2071 | 620.4 | **CT aspects of IMS Business Trunking for IP-PBX in Static Mode of Operation (Stage 3)** | 333d? | 2013-09-06 A | 2014-12-09 A | 100% | 2013-09-06 | 2014-09-12 | 268d? |  | C1; C3 | 9552h | 9552h | BusTI-CT | 31 | Stage 3 | Deutsche Telekom | michael.kreipl@telekom.de | Rel-12 | 61 | Frederic | BusTI-CT |  |  |  |  |
| 2072 | 620.4.1 | CT1 part of CT aspects of IMS Business Trunking for IP-PBX in Static Mode of Operation (Stage 3) | 329d? | 2013-09-06 A | 2014-12-09 A | 100% | 2013-09-06 | 2014-09-12 | 267d? | finish no earlier than 2014-12-09 | C1 | 2632h | 2632h | BusTI-CT | 31 | 23.218, 24.229, 24.525 (transfer of ETSI TS 182 025) | Deutsche Telekom | michael.kreipl@telekom.de | Rel-12 | 61 | Frederic |  | CP-140607 |  |  |  |
| 2073 | 620.4.2 | CT3 part of CT aspects of IMS Business Trunking for IP-PBX in Static Mode of Operation (Stage 3) | 201d? | 2013-09-06 A | 2014-06-11 A | 100% | 2013-09-06 | 2014-06-13 | 201d? | finish no earlier than 2014-06-13 | C3 | 1608h | 1608h | BusTI-CT | 31 | 29.165 | Deutsche Telekom | michael.kreipl@telekom.de | Rel-12 | 61 | Adrian |  |  |  |  |  |
| 2074 | 621 | **WLAN Network Selection for 3GPP Terminals** | 659d? | 2012-06-18 A | 2014-12-09 A | 100% | 2012-06-18 | 2014-09-12 | 594d? |  | S2; S1; S3; C1 | 35272h | 35272h | WLAN_NS | 29 | Stage 1/2/3 | Intel | vivek.g.gupta@intel.com | Rel-12 | 56 | Maurice | WLAN_NS |  | WLAN |  |  |
| 2075 | 621.1 | TR on Stage 2 for WLAN Network Selection for 3GPP Terminals | 396d? | 2012-06-18 A | 2013-12-11 A | 100% | 2012-06-18 | 2013-12-11 | 396d? | finish no earlier than 2013-12-11 | S2; S1 | 6336h | 6336h | WLAN_NS-SATR | 29 | New TR 23.865 | Intel | vivek.g.gupta@intel.com | Rel-12 | 56 | Maurice |  |  | WLAN |  |  |
| 2076 | 621.2 | Stage 2 for WLAN Network Selection for 3GPP Terminals | 392d? | 2012-06-22 A | 2013-12-11 A | 100% | 2012-06-22 | 2013-12-11 | 392d? | finish no earlier than 2013-12-11 | S2 | 3136h | 3136h | WLAN_NS-SA2 | 29 | 23.402, 23.865 | Intel | vivek.g.gupta@intel.com | Rel-12 | 56 | Maurice |  |  | WLAN |  |  |
| 2077 | 621.3 | Deleted - TR on Security Aspects of WLAN Network Selection for 3GPP Terminals | 326d? | 2012-12-13 A | 2014-03-07 A | 100% | 2012-12-13 | 2014-03-07 | 326d? | finish no earlier than 2014-03-07 | S3 | 2608h | 2608h | WLAN_Nsdel | 30 | New TR 33.865 | Huawei | Lydia Xu (xuyixian@huawei.com) | Rel-12 | 58 | Mirko |  |  | WLAN | PCG-32 | CP-63 |
| 2078 | 621.4 | CT aspects of WLAN Network Selection for 3GPP Terminals (Stage 3) | 263d? | 2013-12-06 A | 2014-12-09 A | 100% | 2013-12-06 | 2014-09-12 | 201d? | finish no earlier than 2014-12-09 | C1 | 2104h | 2104h | WLAN_NS-CT | 32 | 24.302, 24.312 | Qualcomm | Amer Catovic, amerc@qualcomm.com | Rel-12 | 62 | Frederic | WLAN_NS-CT | CP-140622 | WLAN |  |  |
| 2079 | 622 | **Deleted - IMS Registration Control** | 496d? | 2012-01-31 A | 2013-12-11 A | 100% | 2012-01-31 | 2013-12-11 | 496d? |  | S1; S2; C1; C4 | 23400h | 23400h | IMS_RegCon | 29 | Stage 1/2/3 | China Mobile | lulu@chinamobile.com | Rel-12 | 57 | Alain | IMS_RegCon |  |  | PCG-32 | SP-62 |
| 2080 | 622.1 | Deleted - Stage 1 for IMS Registration Control | 164d? | 2012-01-31 A | 2012-09-12 A | 100% | 2012-01-31 | 2012-09-12 | 164d? | finish no earlier than 2012-09-12 | S1 | 1304h | 1304h | IMS_RegCon-del1 | 29 | 22.228 | China Mobile | lulu@chinamobile.com | Rel-12 | 57 | Alain |  |  |  | PCG-32 | SP-62 |
| 2081 | 622.2 | Deleted - Stage 2 for IMS Registration Control | 262d? | 2012-12-13 A | 2013-12-11 A | 100% | 2012-12-13 | 2013-12-11 | 262d? | finish no earlier than 2013-12-11 | S2 | 2096h | 2096h | IMS_RegCon-del2 | 30 | 23.228 | China Mobile | Jiang Yi (jiangyi@chinamobile.com) | Rel-12 | 58 | Maurice |  |  |  | PCG-32 | SP-62 |
| 2082 | 622.3 | **Deleted - CT aspects of IMS registration control** | 129d? | 2013-06-19 A | 2013-12-11 A | 100% | 2013-06-19 | 2013-12-11 | 129d? |  | C1; C4 | 4128h | 4128h | IMS_RegCon-CT | 31 | Stage 2/3 | China Mobile | Jiang Yi (jiangyi@chinamobile.com) | Rel-12 | 60 | Frederic | IMS_RegCon-CT |  |  | PCG-32 | SP-62 |
| 2083 | 622.3.1 | Deleted - CT1 aspects of CT aspects of IMS registration control (Stage 2/3) | 129d? | 2013-06-19 A | 2013-12-11 A | 100% | 2013-06-19 | 2013-12-11 | 129d? | finish no earlier than 2013-12-11 | C1 | 1032h | 1032h | IMS_RegCon-CT1 | 31 | 23.218, 24.229 | China Mobile | Jiang Yi (jiangyi@chinamobile.com) | Rel-12 | 60 | Frederic |  |  |  | PCG-32 | SP-62 |
| 2084 | 622.3.2 | Deleted - CT4 aspects of CT aspects of IMS registration control (Stage 3) | 129d? | 2013-06-19 A | 2013-12-11 A | 100% | 2013-06-19 | 2013-12-11 | 129d? | finish no earlier than 2013-12-11 | C4 | 1032h | 1032h | IMS_RegCon-CT4 | 31 | 29.228, 29.229, 23.008 | China Mobile | Jiang Yi (jiangyi@chinamobile.com) | Rel-12 | 60 | Kimmo |  |  |  | PCG-32 | SP-62 |
| 2085 | 623 | **Proximity-based Services** | 1186d? | 2012-12-13 A | 2017-06-15 A | 100% | 2012-12-13 | 2015-03-13 | 593d? |  |  | 36376.8h | 36376.8h | ProSe | 30 | Stage 1/2 | Qualcomm | Rich Hovey (rhovey@qualcomm.com) | Rel-12 | 58 | Alain | ProSe |  | Public Safety (A-A) |  |  |
| 2086 | 623.1 | Stage 1 for Proximity-based Services | 137d? | 2012-12-13 A | 2013-06-19 A | 100% | 2012-12-13 | 2013-06-19 | 137d? | finish no earlier than 2013-06-19 | S1 | 1088h | 1088h | ProSe-SA1 | 30 | 22.115, 22.278 | Qualcomm | Rich Hovey (rhovey@qualcomm.com) | Rel-12 | 58 | Alain |  |  | Public Safety (A-A) |  |  |
| 2087 | 623.2 | TR on Stage 2 for Proximity-based Services | 327d? | 2012-12-13 A | 2014-03-07 A | 100% | 2012-12-13 | 2014-03-07 | 327d? | finish no earlier than 2014-03-07 | S2 | 2608h | 2608h | ProSe-SA2TR | 30 | New TR 23.703 | Qualcomm | Haris Zisimopoulos (harisz@qti.qualcomm.com) | Rel-12 | 58 | Maurice |  |  | Public Safety (A-A) |  |  |
| 2088 | 623.3 | Stage 2 for Proximity-based Services | 397d? | 2012-12-19 A | 2014-06-18 A | 100% | 2012-12-19 | 2014-06-18 | 397d? | finish no earlier than 2014-06-18 | S2 | 3168.8h | 3168.8h | ProSe-SA2 | 30 | New TS 23.303 | Qualcomm | Haris Zisimopoulos (harisz@qti.qualcomm.com) | Rel-12 | 58 | Maurice |  |  | Public Safety (A-A) |  |  |
| 2089 | 623.4 | Security for Proximity-based Services | 464d? | 2013-03-13 A | 2014-12-12 A | 100% | 2013-03-13 | 2014-06-18 | 336d? | finish no earlier than 2014-12-12 | S3 | 3712h | 3712h | ProSe-SA3 | 30 | 33.220, New TS 33.303 | Qualcomm | Adrian Escott (aescott@qti.qualcomm.com) | Rel-12 | 59 | Mirko |  | SP-140584 | Public Safety (A-A) |  |  |
| 2090 | 623.5 | (IETF) Security for Proximity-based Services (ietf-avtcore-srtp-aes-gcm) | 63d? | 2014-09-12 A | 2014-12-09 A | 100% |  |  |  | finish no earlier than 2014-12-09 | S3-IETF | 504h | 504h | ProSe | 33 | RFC 7714 (was ietf-avtcore-srtp-aes-gcm) | Atle Monrad | atle.monrad@ericsson.com | Rel-12 | 65 |  |  |  | Public Safety (A-A) |  |  |

Notes:
- 2067: Linked to Rel-11 IPXS Feature UID_470051 Advanced IP Interconnection of Services. This WI defines a generic framework for interconnecting with any type of IMS based network including IP-PBXs.
- 2068: SP#57 completed. 22.228CR#0171
- 2069: SP#60 completed
- 2070: SP#60 completed
- 2071: -
- 2072: CP#65 completion 09/14=>12/14. Exception in CP-140607. Dec.14: 85->100%
- 2073: CP#64 completed
- 2074: Evaluate and if needed enhance existing 3GPP solutions for WLAN network selection taking into account WFA Hotspot 2.0 solutions
- 2075: SP#62 completed
- 2076: SP#62 completed
- 2077: SP#63 stopped (84% complete)
- 2078: CP#65 completion 09/14=>12/14. CP#65 exception CP-140622. Dec.14: 95->100%
- 2079: SP#62 stopped. Specify for fixed line the requirement of controlling user registration to IMS based on network information related to user location (e.g. IP address, DSLAM information)
- 2080: SP#57 completed
- 2081: SP#62 stopped at 50% completion
- 2082: SP#62 no CT/Stage 3 work is needed (stopped at 0% completion)
- 2083: SP#62 no CT/Stage 3 work is needed (stopped at 0% completion)
- 2084: SP#62 no CT/Stage 3 work is needed (stopped at 0% completion)
- 2085: SP#65 SA3 updated the SA-wide WID SP-140300=>SP-140574 (Moved the TR phase to Rel-13 as a stand-alone Study). Triggered by Rel-12 TR 22.803 Study on Proximity-based Services (FS_ProSe) UID_530044
- 2086: SP#60 completed
- 2087: SP#63 completed. TR 23.703v200 for Approval
- 2088: SP#64 completed open issue/alignment to RAN/SA3 decisions. SP#63 TS 23.303v100 for 1-step Approval
- 2089: SP#65 re-opened. Completion 06/14=>12/14. Exception in SP-140584. Updated WID SP-140300=>SP-140574 (Moved the TR phase to Rel-13 as a stand-alone Study). SP#64 completed. TS 33.303 v100 for 1-step Approval; Aug2015: 90%->100
- 2090: Submitted to IESG for publication; 7/3/16: 75%->100

| ID | WBS | Task | Duration | Start | Finish | Complete | Remaining | Baseline start | Baseline finish | Baseline duration | Total slack | Constraint | Resources | Work | Actual work | Acronym | PCG approved | WI rapporteur name | WI rapporteur e-mail | Release | TSG approved | Status Report | Special Focus Doc | Acronym_3GU_Export | MCC resp |
| --- | --- | --- | --- | --- | --- | --- | --- | --- | --- | --- | --- | --- | --- | --- | --- | --- | --- | --- | --- | --- | --- | --- | --- | --- | --- |
| 2091 | 623.6 | **Charging Aspects of Proximity-based Services** | 195d? | 2014-06-19 A | 2015-03-13 A | 100% |  | 2014-06-18 | 2014-09-17 | 66d? |  |  | S5 | 4160h | 4160h | ProSe-CH | 33 | Qualcomm | Cheng Hong (hongc@qti.qualcomm.com) | Rel-12 | 64 | SP-140543 | Public Safety (A-A) | ProSe-CH |  |
| 2092 | 623.6.1 | Study on Charging support for ProSe one-to-many Direct Communication for Public Safety use | 130d? | 2014-06-19 A | 2014-12-12 A | 100% |  | 2014-06-18 | 2014-09-17 | 66d? |  | finish no earlier than 2014-12-12 | S5 | 1040h | 1040h | ProSe-CH-SA5TR | 33 | Qualcomm | Cheng Hong (hongc@qti.qualcomm.com) | Rel-12 | 64 | SP-140543 | Public Safety (A-A) |  |  |
| 2093 | 623.6.2 | Specification of Charging Aspects of Proximity-based Services | 195d? | 2014-06-19 A | 2015-03-13 A | 100% |  | 2014-06-18 | 2014-09-17 | 66d? |  | finish no earlier than 2015-03-13 | S5 | 1560h | 1560h | ProSe-CH-SA5 | 33 | Qualcomm | Cheng Hong (hongc@qti.qualcomm.com) | Rel-12 | 64 | SP-140543 | Public Safety (A-A) |  |  |
| 2094 | 623.7 | **CT aspects of Proximity-based Services (Stage 3)** | 203d? | 2014-03-05 A | 2014-12-09 A | 100% |  | 2014-03-05 | 2014-09-12 | 138d? |  |  |  | 6392h | 6392h | ProSe-CT | 32 | Qualcomm | Lena Chaponniere (lguellec@qti.qualcomm.com) | Rel-12 | 63 |  | Public Safety (A-A) | ProSe-CT | Frederic |
| 2095 | 623.7.1 | CT1 part of CT aspects of Proximity-based Services | 200d? | 2014-03-05 A | 2014-12-09 A | 100% |  | 2014-03-05 | 2014-09-12 | 138d? |  | finish no earlier than 2014-12-09 | C1 | 1600h | 1600h | ProSe-CT | 32 | Qualcomm | Lena Chaponniere (lguellec@qti.qualcomm.com) | Rel-12 | 63 | CP-140615 | Public Safety (A-A) |  | Frederic |
| 2096 | 623.7.2 | CT3 part of CT aspects of Proximity-based Services | 200d? | 2014-03-05 A | 2014-12-09 A | 100% |  | 2014-03-05 | 2014-09-12 | 138d? |  | finish no earlier than 2014-12-09 | C3 | 1600h | 1600h | ProSe-CT | 32 | Qualcomm | Lena Chaponniere (lguellec@qti.qualcomm.com) | Rel-12 | 63 | CP-140568 | Public Safety (A-A) |  | Adrian |
| 2097 | 623.7.3 | CT4 part of CT aspects of Proximity-based Services | 200d? | 2014-03-05 A | 2014-12-09 A | 100% |  | 2014-03-05 | 2014-09-12 | 138d? |  | finish no earlier than 2014-12-09 | C4 | 1600h | 1600h | ProSe-CT | 32 | Qualcomm | Lena Chaponniere (lguellec@qti.qualcomm.com) | Rel-12 | 63 | CP-140484 | Public Safety (A-A) |  | Kimmo |
| 2098 | 623.7.4 | CT6 part of CT aspects of Proximity-based Services | 199d? | 2014-03-06 A | 2014-12-09 A | 100% |  | 2014-03-06 | 2014-09-12 | 137d? |  | finish no earlier than 2014-12-09 | C6 | 1592h | 1592h | ProSe-CT | 32 | Qualcomm | Lena Chaponniere (lguellec@qti.qualcomm.com) | Rel-12 | 63 | CP-140695 | Public Safety (A-A) |  | Xavier |
| 2099 | 623.8 | **LTE Device to Device Proximity Services** | 857d? | 2014-03-11 A | 2017-06-15 A | 100% |  | 2014-03-06 | 2015-03-13 | 267d? |  |  |  | 14744h | 14744h | LTE_D2D_Prox | 32 | Qualcomm | Shailesh Patil (patil@qti.qualcomm.com) | Rel-12 | 63 |  | Public Safety (A-A) | LTE_D2D_Prox | Patrick |
| 2100 | 623.8.1 | Core part: LTE Device to Device Proximity Services | 263d? | 2014-03-15 A | 2015-03-15 A | 100% |  | 2014-07-11 | 2014-09-12 | 45.67d? |  | finish no earlier than 2015-03-15 | R1; R2; R4 | 6312h | 6312h | LTE_D2D_Prox-Core | 32 | Qualcomm | Shailesh Patil (patil@qti.qualcomm.com) | Rel-12 | 63 | RP-150094 | Public Safety (A-A) | LTE_D2D_Prox-Core | Patrick |
| 2101 | 623.8.2 | Perf. part: LTE Device to Device Proximity Services | 464d? | 2014-03-11 A | 2015-12-15 A | 100% |  | 2014-03-06 | 2015-03-13 | 267d? |  | finish no earlier than 2015-12-15 | R4 | 3712h | 3712h | LTE_D2D_Prox-Perf | 32 | Qualcomm | Shailesh Patil (patil@qti.qualcomm.com) | Rel-12 | 63 | RP-151276 | Public Safety (A-A) | LTE_D2D_Prox-Perf | Issam |
| 2102 | 623.8.3 | UE Conformance Test Aspects – LTE Device-to-Device Proximity Services | 590d? | 2015-03-16 A | 2017-06-15 A | 100% |  |  |  |  |  | finish no earlier than 2017-06-15 | R5 | 4720h | 4720h | LTE_D2D_Prox-UEConTest | 34 | Qualcomm | svora@qti.qualcomm.com | Rel-12 | 67 |  |  |  |  |
| 2103 | 624 | **Web Real Time Communication access to IMS** | 530d? | 2012-12-14 A | 2014-12-12 | 88% | 63.97d? | 2012-12-14 | 2014-12-10 | 525d? | 1437d |  | S1; S2; S3 | 34985.8h | 22067h | IMS_WebRTC | 30 | China Mobile | lulu@chinamobile.com | Rel-12 | 58 |  |  | IMS_WebRTC | Alain |
| 2104 | 624.1 | Stage 1 for Web Real Time Communication access to IMS | 136d? | 2012-12-14 A | 2013-06-19 A | 100% |  | 2012-12-14 | 2013-06-19 | 136d? |  | finish no earlier than 2013-06-19 | S1 | 1088h | 1088h | IMS_WebRTC | 30 | China Mobile | lulu@chinamobile.com | Rel-12 | 58 |  |  |  | Alain |
| 2105 | 624.2 | TR on Stage 2 for Web Real Time Communication access to IMS | 126d? | 2013-06-19 A | 2013-12-11 A | 100% |  | 2013-06-19 | 2013-12-11 | 126d? |  | finish no earlier than 2013-12-11 | S2 | 1008h | 1008h | IMS_WebRTC | 31 | China Mobile | Yu Qing (yuqing@chinamobile.com) | Rel-12 | 60 |  |  |  | Maurice |
| 2106 | 624.3 | Stage 2 for Web Real Time Communication access to IMS | 192d? | 2013-06-19 A | 2014-03-07 A | 100% |  | 2013-06-19 | 2014-03-07 | 192d? |  | finish no earlier than 2014-03-07 | S2 | 1528h | 1528h | IMS_WebRTC | 31 | China Mobile | Yu Qing (yuqing@chinamobile.com) | Rel-12 | 60 |  |  |  | Maurice |
| 2107 | 624.4 | (IETF) Web Real Time Communication access to IMS (rtcweb-overview) | 391d? | 2013-06-25 A | 2014-12-12 | 50% | 195.5d? | 2013-06-19 | 2014-12-10 | 389d? | 1437d | finish no earlier than 2014-12-12 | C1-IETF | 3128h | 1564h | IMS_WebRTC | 32 | Uwe Rauschenbach | Uwe Rauschenbach | Rel-12 | 63 |  |  |  |  |
| 2108 | 624.5 | TR on Security for Web Real Time Communication access to IMS | 202d? | 2013-12-11 A | 2014-09-17 A | 100% |  | 2013-12-11 | 2014-09-17 | 202d? |  | finish no earlier than 2014-09-17 | S3 | 1608h | 1608h | IMS_WebRTC | 32 | Ericsson | oscar.ohlsson@ericsson.com | Rel-12 | 62 |  |  |  | Mirko |
| 2109 | 624.6 | Security for Web Real Time Communication access to IMS | 202d? | 2013-09-12 A | 2014-06-18 A | 100% |  | 2013-09-12 | 2014-06-18 | 202d? |  | finish no earlier than 2014-06-18 | S3 | 1609.85h | 1609.85h | IMS_WebRTC | 31 | Ericsson | oscar.ohlsson@ericsson.com | Rel-12 | 61 |  |  |  | Mirko |
| 2110 | 624.7 | **CT aspects of Web Real Time Communication (WebRTC) Access to IMS** | 203d? | 2014-03-05 A | 2014-12-09 | 93% | 14.71d? | 2014-03-05 | 2014-12-05 | 198d? | 1440d |  | C1; C4; IETF | 12296h | 10397.2h | IMS_WebRTC-CT | 32 | China Mobile | Jiang Yi (jiangyi@chinamobile.com) | Rel-12 | 63 |  |  | IMS_WebRTC-CT | Frederic |
| 2111 | 624.7.1 | CT1 part of CT aspects of Web Real Time Communication (WebRTC) Access to IMS | 200d? | 2014-03-05 A | 2014-12-09 A | 100% |  | 2014-03-05 | 2014-09-12 | 138d? |  | finish no earlier than 2014-12-09 | C1 | 1600h | 1600h | IMS_WebRTC-CT1 | 32 | China Mobile | Jiang Yi (jiangyi@chinamobile.com) | Rel-12 | 63 | CP-140621 |  |  | Frederic |
| 2112 | 624.7.2 | (IETF) Web Real Time Communication access to IMS (rtcweb-data-channel) | 200d? | 2014-03-06 A | 2014-12-09 | 90% | 20d? | 2014-03-05 | 2014-12-05 | 198d? | 1440d | finish no earlier than 2014-12-09 | C1-IETF | 1600h | 1440h | IMS_WebRTC-data | 33 | christer.holmberg@ericsson.com | christer.holmberg@ericsson.com | Rel-12 | 64 |  |  |  |  |
| 2113 | 624.7.3 | (IETF) Web Real Time Communication access to IMS (rtcweb-stun-consent-freshness) | 200d? | 2014-03-06 A | 2014-12-09 A | 100% |  | 2014-03-05 | 2014-12-05 | 198d? |  | finish no earlier than 2014-12-09 | C1-IETF | 1600h | 1600h | IMS_WebRTC-stun | 33 | christer.holmberg@ericsson.com | christer.holmberg@ericsson.com | Rel-12 | 64 |  |  |  |  |
| 2114 | 624.7.4 | (IETF) Web Real Time Communication access to IMS (draft-yusef-sipcore-sip-oauth) | 63d? | 2014-09-12 A | 2014-12-09 | 25% | 47.25d? |  |  |  | 1440d | finish no earlier than 2014-12-09 | C1-IETF | 504h | 126h | IMS_WebRTC-yusef | 33 | christer.holmberg@ericsson.com | christer.holmberg@ericsson.com | Rel-12 | 65 |  |  |  |  |
| 2115 | 624.7.5 | Deleted - (IETF) Web Real Time Communication access to IMS (draft-holmberg-sipcore-auth-id) | 65d? | 2014-09-12 A | 2014-12-09 A | 100% |  |  |  |  |  | start no earlier than 2014-09-12 | C1-IETF | 520h | 520h | IMS_WebRTC-holmb | 34 | christer.holmberg@ericsson.com |  | Rel-12 | 66 |  |  |  |  |
| 2116 | 624.7.6 | CT4 part of CT aspects of Web Real Time Communication (WebRTC) Access to IMS | 200d? | 2014-03-05 A | 2014-12-09 A | 100% |  | 2014-03-05 | 2014-09-19 | 143d? |  | finish no earlier than 2014-12-09 | C4 | 1600h | 1600h | IMS_WebRTC-CT4 | 32 | China Mobile | Jiang Yi (jiangyi@chinamobile.com) | Rel-12 | 63 | CP-140732 |  |  | Kimmo |

Notes:
- 2091: SP#65 exception in SP-140543. Mar15: 85->100% / Impacted TSs and TRs: Stage 2/3
- 2092: SP#65 completion 09/14=>12/14. Exception in SP-140543. TR 32.844v100 for Information. Dec.14: CD: 09/14->12/14, 60->100% / Impacted TSs and TRs: New TR 32.844
- 2093: SP#65 completion 09/14=>12/14. Exception in SP-140543. SP#65 TR 32.277v100 for Information. Dec.14: CD: 09/14->03/15, 40->75%. Mar15: 75->100% / Impacted TSs and TRs: 32.240, 32.297, 32.298, 32.299, New TS 32.277
- 2094: CP#64 updated WID CP-140194=>CP-140290 / Impacted TSs and TRs: Stage 3
- 2095: CP#65 completion 09/14=>12/14. Exception in CP-140615. TS 24.333/4v200 for Approval. Dec.14: 90->100% / Impacted TSs and TRs: 24.301, 23.122, New TSs (24.333, 24.334)
- 2096: CP#65 completion 09/14=>12/14. TS 29.343v100 for 1-step Approval. Exception in CP-140568. Dec.14: 90->100 / Impacted TSs and TRs: New TS 29.343
- 2097: CP#65 completion 09/14=>12/14. TS 29.344/5v100 for 1-step Approval. Exception in CP-140484. Dec.14: 90->100 / Impacted TSs and TRs: 29.272, 23.008, 23.003, New TSs (29.344, 29.345)
- 2098: CP#65 completion 09/14=>12/14. Exception in CP-140695. Dec.14: 60->100% / Impacted TSs and TRs: 31.102
- 2099: follow-up of TR 36.843 FS_LTE_D2D_Prox / Impacted TSs and TRs: LTE
- 2100: ; CD:Sat 15/03/14->Sun 15/03/15Compl:0%->95%; CD:Fri 13/03/15->Sun 15/03/15; Stat Rep: RP-141244->RP-141894 1st Apr 15: Compl:95%->100% 1st Apr 15: Stat Rep: RP-141894->RP-150094 / Impacted TSs and TRs: 36.101, 36.133, 36.211, 36.212, 36.213, 36.214, 36.300, 36.304, 36.306, 36.321, 36.322, 36.323, 36.331, 36.413, 36.423, New TR 36.877
- 2101: ; CD:Sat 15/03/14->Sun 15/03/15; Stat Rep: RP-141244->RP-141894 1st Apr 15: Compl:10%->25% 1st Apr 15: Stat Rep: RP-141894->RP-150094 03/07/15: Compl:25%->70% 03/07/15: Stat Rep: RP-150094->RP-150760 29/09/15: Compl:70%->95% 29/09/15: CD:Tue 15/09/15-> / Impacted TSs and TRs: 36.101, 36.133
- 2102: rapporteur e-mail added 03/07/15: Compl:0%->10% 03/07/15: Stat Rep: ->RP-150765 29/09/15: Compl:10%->30% 29/09/15: CD:Tue 15/12/15->Wed 15/06/16 29/09/15: Stat Rep: RP-150765->RP-151280 1/1/16: Compl:30%->45% 1/1/16: WID: RP-1; ...; ;...
- 2103: IETF RTCWEB and W3C WEBRTC groups are specifying a browser-based client to support communication services. Interoperability for WebRTC clients to access 3GPP IMS is needed. / Impacted TSs and TRs: Stage 1/2
- 2104: SP#60 completed / Impacted TSs and TRs: 22.101, 22.228
- 2105: SP#62 completed. TR 23.701v100 for Information & Approval / Impacted TSs and TRs: New TR 23.701
- 2106: SP#63 completed / Impacted TSs and TRs: 23.228
- 2107: In WGLC. Mar15: responsible WG changed from S2-IETF / Impacted TSs and TRs: draft-ietf-rtcweb-overview
- 2108: SP#65 completed. TR 33.871v200 for Approval / Impacted TSs and TRs: New TR 33.871
- 2109: SP#64 completed / Impacted TSs and TRs: 33.203, 33.328
- 2110: - / Impacted TSs and TRs: Stage 3
- 2111: CP#65 TS 24.371v100 for Information. Completion 09/14=>12/14. Exception in CP-140621. Dec.14: 70->90%. 3/3/15: 100% cpltd. / Impacted TSs and TRs: 24.229, New TS 24.371
- 2112: Submitted to IESG for publication. Mar15: In RFC-Editors queue / Impacted TSs and TRs: draft-ietf-rtcweb-data-channel
- 2113: Mar15: Publication requested; 7/3/16: 50%->100 / Impacted TSs and TRs: draft-ietf-rtcweb-stun-consent-freshness
- 2114: work in progress / Impacted TSs and TRs: draft-yusef-sipcore-sip-oaut
- 2115: 7/3/16: 25%->100 since deleted (draft no longer needed). / Impacted TSs and TRs: draft-holmberg-sipcore-auth-id
- 2116: CP#65 completion 09/14=>12/14. Exception in CP-140732. Dec.14: 30->80%. Mar. 15: 100% / Impacted TSs and TRs: 23.334, 29.334

| ID | WBS | Task | Duration | Start | Finish | Complete | Baseline start | Baseline finish | Baseline duration | Constraint | Resources | Work | Actual work | Acronym | PCG approved | WI rapporteur name | WI rapporteur e-mail | Release | TSG approved | MCC resp | Acronym_3GU_Export | Special Focus Doc | Status Report |
| --- | --- | --- | --- | --- | --- | --- | --- | --- | --- | --- | --- | --- | --- | --- | --- | --- | --- | --- | --- | --- | --- | --- | --- |
| 2117 | 625 | **Usage Monitoring Control PCC enhancement** | 196d? | 2012-12-13 A | 2013-09-06 A | 100% | 2012-12-13 | 2013-09-06 | 196d? |  | S2; C3 | 4112h | 4112h | UMONC | 30 | ZTE | bi.yifeng@zte.com.cn | Rel-12 | 58 | Maurice | UMONC |  |  |
| 2118 | 625.1 | Stage 2 for Usage Monitoring Control PCC enhancement | 61d? | 2012-12-13 A | 2013-03-06 A | 100% | 2012-12-13 | 2013-03-06 | 61d? | finish no earlier than 2013-03-06 | S2 | 488h | 488h | UMONC | 30 | ZTE | bi.yifeng@zte.com.cn | Rel-12 | 58 | Maurice |  |  |  |
| 2119 | 625.2 | CT3 aspects of Usage Monitoring Control PCC enhancement (Stage 3) | 63d? | 2013-06-14 A | 2013-09-06 A | 100% | 2013-06-14 | 2013-09-06 | 63d? | finish no earlier than 2013-09-06 | C3 | 488h | 488h | UMONC-CT3 | 31 | ZTE | zhou.xiaoyun@zte.com.cn | Rel-12 | 60 | Adrian | UMONC-CT3 |  |  |
| 2120 | 626 | **Application Based Charging** | 340d? | 2013-03-07 A | 2014-06-18 A | 100% | 2013-03-07 | 2014-06-18 | 340d? |  | S2; S5; C3 | 11612h | 11612h | ABC | 30 | Allot | Alla Goldner (agoldner@allot.com) | Rel-12 | 59 | Maurice | ABC |  |  |
| 2121 | 626.1 | Stage 2 for Application Based Charging | 76d? | 2013-03-07 A | 2013-06-19 A | 100% | 2013-03-07 | 2013-06-19 | 76d? | finish no earlier than 2013-12-11 | S2 | 608h | 608h | ABC-SA2 | 30 | Allot | Alla Goldner (agoldner@allot.com) | Rel-12 | 59 | Maurice |  |  |  |
| 2122 | 626.2 | Charging for Application Based Charging | 232.5d? | 2013-06-19 A | 2014-06-18 A | 100% | 2013-06-19 | 2014-06-18 | 232.5d? | finish no earlier than 2014-06-18 | S5 | 1836h | 1836h | ABC-CT5 | 31 | Openet Telecom | alan.mcnamee@openet.com | Rel-12 | 60 | Mirko |  |  |  |
| 2123 | 626.3 | CT3 aspects of Application Based Charging (Stage 3) | 127d? | 2013-06-14 A | 2013-12-06 A | 100% | 2013-06-14 | 2013-12-06 | 127d? | finish no earlier than 2013-12-06 | C3 | 1008h | 1008h | ABC-CT3 | 31 | Allot | Alla Goldner (agoldner@allot.com) | Rel-12 | 60 | Adrian | ABC-CT3 |  |  |
| 2124 | 627 | **Enhanced S2a Mobility Over trusted WLAN access to EPC** | 332d? | 2013-09-09 A | 2014-12-09 A | 100% | 2013-09-09 | 2014-09-12 | 267d? |  | S2; C1; C4 | 19024h | 19024h | eSaMOG | 31 | ZTE | Tricci So (tso@zteusa.com) | Rel-12 | 61 | Maurice | eSaMOG | WLAN |  |
| 2125 | 627.1 | Stage 2 for Enhanced S2a Mobility Over trusted WLAN access to EPC | 130d? | 2013-09-11 A | 2014-03-07 A | 100% | 2013-09-11 | 2014-03-07 | 130d? | finish no earlier than 2014-03-07 | S2 | 1032h | 1032h | eSaMOG-SA2 | 31 | ZTE | Tricci So (tso@zteusa.com) | Rel-12 | 61 | Maurice |  | WLAN |  |
| 2126 | 627.2 | **Stage 3 for Enhanced S2a Mobility Over trusted WLAN access to EPC** | 332d? | 2013-09-09 A | 2014-12-09 A | 100% | 2013-09-09 | 2014-09-12 | 267d? |  | C1; C4 | 10048h | 10048h | eSaMOG-St3 | 31 | ZTE | Joy Zhou (zhou.xingyue@zte.com.cn) | Rel-12 | 61 | Frederic | eSaMOG-St3 | WLAN |  |
| 2127 | 627.2.1 | CT1 part of Stage 3 for Enhanced S2a Mobility Over trusted WLAN access to EPC | 329d? | 2013-09-09 A | 2014-12-09 A | 100% | 2013-09-09 | 2014-09-12 | 267d? | finish no earlier than 2014-12-09 | C1 | 2624h | 2624h | eSaMOG-St3 | 31 | ZTE | Joy Zhou (zhou.xingyue@zte.com.cn) | Rel-12 | 61 | Frederic |  | WLAN | CP-140608 |
| 2128 | 627.2.2 | CT4 part of Stage 3 for Enhanced S2a Mobility Over trusted WLAN access to EPC | 266d? | 2013-09-09 A | 2014-09-11 A | 100% | 2013-09-09 | 2014-09-12 | 266d? | finish no earlier than 2014-09-12 | C4 | 2128h | 2128h | eSaMOG-St3 | 31 | ZTE | Joy Zhou (zhou.xingyue@zte.com.cn) | Rel-12 | 61 | Kimmo |  | WLAN |  |
| 2129 | 628 | **Optimized Offloading to WLAN in 3GPP-RAT Mobility** | 199d? | 2013-09-12 A | 2014-06-13 A | 100% | 2013-09-12 | 2014-06-13 | 199d? |  | S2; C1 | 4800h | 4800h | WORM | 31 | BlackBerry | Steve Barrett (sbarrett@blackberry.com) | Rel-12 | 61 | Maurice | WORM | WLAN |  |
| 2130 | 628.1 | Stage 2 for Optimized Offloading to WLAN in 3GPP-RAT Mobility | 66d? | 2013-09-12 A | 2013-12-11 A | 100% | 2013-09-12 | 2013-12-11 | 66d? | finish no earlier than 2013-12-11 | S2 | 528h | 528h | WORM-SA2 | 31 | BlackBerry | Steve Barrett (sbarrett@blackberry.com) | Rel-12 | 61 | Maurice |  | WLAN |  |
| 2131 | 628.2 | CT aspects of Optimized Offloading to WLAN in 3GPP-RAT Mobility (Stage 3) | 136d? | 2013-12-06 A | 2014-06-13 A | 100% | 2013-12-06 | 2014-06-13 | 136d? | finish no earlier than 2014-06-13 | C1 | 1088h | 1088h | WORM-CT | 32 | Intel | Chen-ho Chin (chen-hox.chin@intel.com) | Rel-12 | 62 | Frederic | WORM-CT | WLAN |  |
| 2132 | 629 | **Network-provided Location information for IMS Trusted WLAN Access Network (TWAN) case** | 264d? | 2013-09-12 A | 2014-09-11 A | 100% | 2013-09-12 | 2014-09-12 | 264d? |  | S2; C3; C1; C4 | 18624h | 18624h | NETLOC_TWAN | 31 | Alcatel-Lucent | Laurent.thiebaut@alcatel-lucent.com | Rel-12 | 61 | Maurice | NETLOC_TWAN | WLAN |  |
| 2133 | 629.1 | Stage 2 for Network-provided Location information for IMS Trusted WLAN Access Network (TWAN) case | 129d? | 2013-09-12 A | 2014-03-07 A | 100% | 2013-09-12 | 2014-03-07 | 129d? | finish no earlier than 2014-03-07 | S2 | 1024h | 1024h | NETLOC_TWAN-SA2 | 31 | Alcatel-Lucent | Laurent.thiebaut@alcatel-lucent.com | Rel-12 | 61 | Maurice |  |  |  |
| 2134 | 629.2 | **CT aspects of Network-provided Location information for IMS Trusted WLAN Access Network (TWAN) case (Stage 3)** | 202d? | 2013-12-06 A | 2014-09-11 A | 100% | 2013-12-06 | 2014-09-12 | 202d? |  | C3; C1; C4 | 9152h | 9152h | NETLOC_TWAN-CT | 32 | China Telecom | Xia Xu (xiaxu@ctbri.com.cn) | Rel-12 | 62 | Adrian | NETLOC_TWAN-CT |  |  |
| 2135 | 629.2.1 | CT3 part of Network-provided Location information for IMS Trusted WLAN Access Network (TWAN) case | 137d? | 2013-12-06 A | 2014-06-13 A | 100% | 2013-12-06 | 2014-06-13 | 137d? | finish no earlier than 2014-06-13 | C3 | 1088h | 1088h | NETLOC_TWAN-CT | 32 | China Telecom | Xia Xu (xiaxu@ctbri.com.cn) | Rel-12 | 62 | Adrian |  |  |  |
| 2136 | 629.2.2 | CT1 part of Network-provided Location information for IMS Trusted WLAN Access Network (TWAN) case | 201d? | 2013-12-09 A | 2014-09-11 A | 100% | 2013-12-09 | 2014-09-12 | 201d? | finish no earlier than 2014-09-12 | C1 | 1608h | 1608h | NETLOC_TWAN-CT | 32 | China Telecom | Xia Xu (xiaxu@ctbri.com.cn) | Rel-12 | 62 | Frederic |  |  |  |
| 2137 | 629.2.3 | CT4 part of Network-provided Location information for IMS Trusted WLAN Access Network (TWAN) case | 201d? | 2013-12-06 A | 2014-09-11 A | 100% | 2013-12-06 | 2014-09-12 | 201d? | finish no earlier than 2014-09-12 | C4 | 1608h | 1608h | NETLOC_TWAN-CT | 32 | China Telecom | Xia Xu (xiaxu@ctbri.com.cn) | Rel-12 | 62 | Kimmo |  |  |  |
| 2138 | 630 | **Core Network Overload - User Location Information reporting improvement** | 203d? | 2013-12-11 A | 2014-09-17 A | 100% | 2013-12-11 | 2014-09-12 | 199d? |  | S2; C3; C4; S5 | 10920h | 10920h | CNO_ULI | 32 | Alcatel-Lucent | nicolas.drevon@alcatel-lucent.com | Rel-12 | 62 | Maurice | CNO_ULI |  |  |
| 2139 | 630.1 | Stage 2 for Core Network Overload - User Location Information reporting improvement | 64d? | 2013-12-11 A | 2014-03-07 A | 100% | 2013-12-11 | 2014-03-07 | 64d? | finish no earlier than 2014-03-07 | S2 | 504h | 504h | CNO_ULI-SA2 | 32 | Alcatel-Lucent | nicolas.drevon@alcatel-lucent.com | Rel-12 | 62 | Maurice |  |  |  |
| 2140 | 630.2 | Charging aspects of Core Network Overload – User Location Information reporting improvements | 3d? | 2014-09-15 A | 2014-09-17 A | 100% |  |  |  | finish no earlier than 2014-09-17 | S5 | 24h | 24h | CNO_ULI-CH | 33 | Alcatel-Lucent | maryse.gardella@alcatel-lucent.com | Rel-12 | 65 |  | CNO_ULI-CH |  |  |

Notes:
- 2117: SP#59 Stage 2 completed. Triggered by Rel-12 TR 23.858 Study on Usage Monitoring Control enhancement (UID_520035) / Impacted TSs and TRs: Stage 2/3
- 2118: SP#59 completed. 23.203 CR#0782 (Time Based Usage Monitoring), CR#0784 (Usage Monitoring via Online Charging System) / Impacted TSs and TRs: 23.203
- 2119: CP#61 completed. 2/4/15: acronym changed to "UMONC-CT3" / Impacted TSs and TRs: 29.212, 29.214, 29.215
- 2120: Triggered by TR 23.800 Study on Application Based Charging (FS_ABC) UID_560038 / Impacted TSs and TRs: Stage 2/3
- 2121: SP#60 completed / Impacted TSs and TRs: 23.203
- 2122: SP#64 completed / Impacted TSs and TRs: 32.240, 32.251, 32.296, 32.298, 32.299
- 2123: CP#62 completed / Impacted TSs and TRs: 29.212, 29.213, 29.214, 29.215, 29.219
- 2124: - / Impacted TSs and TRs: Stage 2/3
- 2125: SP#63 completed / Impacted TSs and TRs: 23.402
- 2126: CP#62 updated WID CP-130580=>CP-130715 / Impacted TSs and TRs: Stage 3
- 2127: CP#65 completion 09/14=>12/14. Exception in CP-140608. TS 24.244 v200 for Approval. Dec.14: 95->100% / Impacted TSs and TRs: 24.302, New TS 24.244 (WLAN control plane protocol for trusted WLAN access to EPC)
- 2128: CP#65 completed / Impacted TSs and TRs: 29.273, 29.274, 29.275
- 2129: Linked to TR 23.890 Study on Optimized Offloading to WLAN in 3GPP-RAT mobility (FS_WORM), SAE for support for non-3GPP accesses, Multi-Access PDN Connectivity (MAPCON), IP Flow Mobility and Seamless WLAN Offload (IFOM), CS Fallback in EPS (SAES-CSFB) / Impacted TSs and TRs: Stage 2/3
- 2130: SP#62 completed / Impacted TSs and TRs: 23.272, 23.401, 23.402
- 2131: CP#64 completed. Stage 3 enabling differentiation/prioritization of 3GPP RATs relative to WLAN for traffic flow routing based on Inter-System Routing Policies / Impacted TSs and TRs: 24.302, 24.312
- 2132: Rel-11 Network Provided Location Information for IMS (NWK-PL2IMS) covers the case where UE is served by a 3GPP RAN. This WI covers the case where the UE is served by a TWAN / Impacted TSs and TRs: Stage 2/3
- 2133: SP#63 completed / Impacted TSs and TRs: 23.203, 23.228, 23.402
- 2134: - / Impacted TSs and TRs: Stage 3
- 2135: CP#64 completed / Impacted TSs and TRs: 29.212, 29.214
- 2136: CP#65 completed / Impacted TSs and TRs: 24.229
- 2137: CP#65 completed / Impacted TSs and TRs: 29.273, 29.274, 29.275, 29.328, 29.329
- 2138: - / Impacted TSs and TRs: Stage 2/3
- 2139: SP#63 completed / Impacted TSs and TRs: 23.060, 23.203, 23.401
- 2140: SP#65 New WID approved & completed. Introduction of Presence Reporting Areas for Charging / Impacted TSs and TRs: 32.251, 32.298, 32.299

| ID | WBS | Task | Duration | Start | Finish | Complete | Remaining | Baseline start | Baseline finish | Baseline duration | Total slack | Constraint | Resources | Work | Actual work | Acronym | PCG approved | Impacted TSs and TRs | WI rapporteur name | Release | TSG approved | MCC resp | Acronym_3GU_Export | Special Focus Doc | PCG stopped | TSG stopped | Status Report |
| --- | --- | --- | --- | --- | --- | --- | --- | --- | --- | --- | --- | --- | --- | --- | --- | --- | --- | --- | --- | --- | --- | --- | --- | --- | --- | --- | --- |
| 2141 | 630.3 | **CT aspects of Core Network Overload – User Location Information reporting improvements** | 138d? | 2014-03-05 A | 2014-09-11 A | 100% |  | 2014-03-05 | 2014-09-12 | 138d? |  |  | C3; C4 | 3896h | 3896h | CNO_ULI-CT | 32 | Stage 3 | Alcatel-Lucent | Rel-12 | 63 | Adrian | CNO_ULI-CT |  |  |  |  |
| 2142 | 630.3.1 | CT3 part of CT aspects of Core Network Overload – User Location Information reporting improvements | 73d? | 2014-03-05 A | 2014-06-13 A | 100% |  | 2014-03-05 | 2014-06-13 | 73d? |  | finish no earlier than 2014-06-13 | C3 | 584h | 584h | CNO_ULI-CT | 32 | 29.212, 29.213 | Alcatel-Lucent | Rel-12 | 63 | Adrian |  |  |  |  |  |
| 2143 | 630.3.2 | CT4 part of CT aspects of Core Network Overload – User Location Information reporting improvements | 138d? | 2014-03-05 A | 2014-09-11 A | 100% |  | 2014-03-05 | 2014-09-12 | 138d? |  | finish no earlier than 2014-09-12 | C4 | 1104h | 1104h | CNO_ULI-CT | 32 | 23.008, 29.060, 29.274 | Alcatel-Lucent | Rel-12 | 63 | Kimmo |  |  |  |  |  |
| 2144 | 631 | Rel-12 Security small Enhancements | 923d? | 2011-03-23 A | 2014-09-17 A | 100% |  | 2011-03-23 | 2014-06-18 | 859d? |  | finish no earlier than 2014-09-17 | S3 | 7384h | 7384h | SEC12 | 29 | Stage 2/3 |  | Rel-12 | 56 | Mirko | SEC12 |  |  |  |  |
| 2145 | 632 | **Security aspects of Public Warning System** | 925d? | 2011-03-23 A | 2014-09-17 A | 100% |  | 2011-03-23 | 2014-09-17 | 924d? |  |  | S3; S1 | 36832h | 36832h | PWS_Sec | 26 |  | ST-Ericsson | Rel-12 | 51 | Mirko | PWS_Sec | Public Safety (I-A) |  |  |  |
| 2146 | 632.1 | Stage 1 for Protection against false PWS Warning Notifications | 65d? | 2012-06-15 A | 2012-09-12 A | 100% |  | 2012-06-15 | 2012-09-12 | 65d? |  | finish no earlier than 2012-09-12 | S1 | 512h | 512h | PWS_Sec-SA1 | 29 | 22.268 | Vodafone | Rel-12 | 56 | Alain |  | Public Safety (I-A) |  |  |  |
| 2147 | 632.2 | TR on SA3 part for Security aspects of Public Warning System | 921d? | 2011-03-23 A | 2014-09-17 A | 100% |  | 2011-03-23 | 2014-09-17 | 921d? |  | finish no earlier than 2014-09-17 | S3 | 7360h | 7360h | PWS_Sec-SA3TR | 26 | New TR 33.869 changed to 33.969 | ST-Ericsson | Rel-12 | 51 | Mirko |  | Public Safety (I-A) |  |  |  |
| 2148 | 632.3 | Deleted - SA3 part for Security aspects of Public Warning System | 852d? | 2011-03-30 A | 2014-06-18 A | 100% |  | 2011-03-30 | 2014-06-18 | 852d? |  | finish no earlier than 2014-06-18 | S3 | 6808h | 6808h | PWS_Sec-del1 | 26 | New TS 33.269 | ST-Ericsson | Rel-12 | 51 | Mirko |  | Public Safety (I-A) | PCG-33 | SP-64 |  |
| 2149 | 632.4 | Deleted - Stage 1 for Security aspects of Public Warning System | 330d? | 2011-03-23 A | 2012-06-20 A | 100% |  | 2011-03-23 | 2012-06-20 | 330d? |  | start no earlier than 2011-03-23 | S1 | 2640h | 2640h | PWS_Sec-del2 | 26 | 22.268 | ST-Ericsson | Rel-12 | 51 | Alain |  | Public Safety (I-A) | PCG-29 | SP-56 |  |
| 2150 | 632.5 | Deleted - Stage 2 for Security aspects of Public Warning System | 133d? | 2011-03-23 A | 2011-09-21 A | 100% |  | 2011-03-23 | 2011-09-21 | 133d? |  | start no earlier than 2011-03-23 | S2 | 1064h | 1064h | PWS_Sec-del3 | 26 | 23.401 | ST-Ericsson | Rel-12 | 51 | Maurice |  | Public Safety (I-A) | PCG-27 | SP-53 |  |
| 2151 | 632.6 | Deleted - CT1 part for Security aspects of Public Warning System | 328d? | 2011-03-25 A | 2012-06-20 A | 100% |  | 2011-03-25 | 2012-06-20 | 328d? |  | finish no earlier than 2012-06-20 | C1 | 2624h | 2624h | PWS_Sec-del4 | 26 | 23.041 | ST-Ericsson | Rel-12 | 51 | Frederic |  | Public Safety (I-A) | PCG-29 | SP-56 |  |
| 2152 | 632.7 | Deleted - RAN2 part for Security aspects of Public Warning System | 128d? | 2011-03-25 A | 2011-09-16 A | 100% |  | 2011-03-25 | 2011-09-16 | 128d? |  | start no earlier than 2011-03-25 | R2 | 1024h | 1024h | PWS_Sec-del5 | 26 | 36.331 | ST-Ericsson | Rel-12 | 51 | Yong-Jun |  | Public Safety (I-A) | PCG-27 | RP-53 |  |
| 2153 | 633 | Security enhancements for usage of Generic Bootstrapping Architecture (GBA) from the browser (Stage 2) | 536d? | 2011-06-08 A | 2013-06-20 A | 100% |  | 2011-06-08 | 2013-06-19 | 536d? |  | finish no earlier than 2013-06-19 | S3 | 4256h | 4256h | Web_GBA | 27 | 33.220, 33.222, New TR 33.823 | Nokia | Rel-12 | 52 | Mirko | Web_GBA |  |  |  |  |
| 2154 | 634 | **Extended IMS media plane security features** | 657d? | 2012-06-20 A | 2014-12-09 | 97% | 22.25d? | 2012-06-20 | 2014-12-10 | 655d? | 1440d |  | S3; C4; C1; C3; IETF | 73585.2h | 70852.3h | eMEDIASEC | 29 | Stage 2/3 | Vodafone | Rel-12 | 56 | Mirko | eMEDIASEC |  |  |  |  |
| 2155 | 634.1 | SA3 part of Extended IMS media plane security features (Stage 2) | 530d? | 2012-06-20 A | 2014-06-18 A | 100% |  | 2012-06-20 | 2014-06-18 | 530d? |  | finish no earlier than 2014-06-18 | S3 | 4185.2h | 4185.2h | eMEDIASEC-SA3 | 29 | 33.328 | Vodafone | Rel-12 | 56 | Mirko |  |  |  |  |  |
| 2156 | 634.2 | (IETF) SA3 part of Extended IMS media plane security features (RFC 7345) | 591d? | 2012-06-20 A | 2014-09-12 A | 100% |  | 2012-06-20 | 2014-12-10 | 654d? |  | finish no earlier than 2014-09-12 | S3-IETF | 4728h | 4728h | eMEDIASECSA3IETF | 31 | RFC 7345 (was draft-ietf-mmusic-udptl-dtls) | christer.holmberg@ericsson.com | Rel-12 | 61 |  |  |  |  |  |  |
| 2157 | 634.3 | **CT aspects of Extended IMS media plane security features (Stage 2/3)** | 528d? | 2012-12-13 A | 2014-12-09 | 95% | 25.34d? | 2012-12-13 | 2014-12-05 | 523d? | 1440d |  | C4; C1; C3; IETF | 38392h | 36549.1h | eMEDIASEC-CT | 30 | Stage 2/3 | Alcatel-Lucent | Rel-12 | 58 | Kimmo | eMEDIASEC-CT |  |  |  |  |
| 2158 | 634.3.1 | TR on Extended IMS media plane security features and TCP related NAT traversal support; IMS H.248 profiles aspects | 461d? | 2012-12-13 A | 2014-09-11 A | 100% |  | 2012-12-13 | 2014-09-12 | 461d? |  | finish no earlier than 2014-09-12 | C4 | 3688h | 3688h | eMEDIASEC-CT | 30 | New TR 29.828 | Alcatel-Lucent | Rel-12 | 58 | Kimmo |  |  |  |  |  |
| 2159 | 634.3.2 | CT4 part of CT aspects of Extended IMS media plane security features | 520d? | 2012-12-19 A | 2014-12-09 A | 100% |  | 2012-12-19 | 2014-09-12 | 458d? |  | finish no earlier than 2014-12-09 | C4 | 4160h | 4160h | eMEDIASEC-CT | 30 | 23.334, 29.334, 29.238, 23.333, 29.333 | Alcatel-Lucent | Rel-12 | 58 | Kimmo |  |  |  |  | CP-140479 |
| 2160 | 634.3.3 | (IETF) CT4 part of Extended IMS media plane security features (RFC 7345) | 457d? | 2012-12-18 A | 2014-09-11 A | 100% |  | 2012-12-18 | 2014-12-05 | 519d? |  | finish no earlier than 2014-09-11 | C4-IETF | 3656h | 3656h | eMEDIASEC-CT | 32 | RFC 7345 (was draft-ietf-mmusic-udptl-dtls) | christer.holmberg@ericsson.com | Rel-12 | 62 |  |  |  |  |  |  |
| 2161 | 634.3.4 | (IETF) CT4 part of Extended IMS media plane security features (draft-schwarz-mmusic-sdp-for-gw) | 129d? | 2014-06-12 | 2014-12-09 |  |  | 2014-06-12 | 2014-12-05 | 127d? | 1440d | finish no earlier than 2014-12-09 | C4-IETF | 1032h |  | eMEDIASEC-CT | 33 | draft-schwarz-mmusic-sdp-for-gw | christer.holmberg@ericsson.com | Rel-12 | 64 |  |  |  |  |  |  |
| 2162 | 634.3.5 | CT1 part of CT aspects of Extended IMS media plane security features | 463d? | 2012-12-13 A | 2014-09-11 A | 100% |  | 2012-12-13 | 2014-09-12 | 463d? |  | finish no earlier than 2014-09-12 | C1 | 3696h | 3696h | eMEDIASEC-CT | 30 | 23.218, 24.147, 24.229, 24.247 | Alcatel-Lucent | Rel-12 | 58 | Frederic |  |  |  |  |  |
| 2163 | 634.3.6 | (IETF) CT1 part of Extended IMS media plane security features (RFC 7345) | 137d? | 2014-03-06 A | 2014-09-11 A | 100% |  | 2014-03-06 | 2014-12-05 | 197d? |  | finish no earlier than 2014-09-11 | C1-IETF | 1096h | 1096h | eMEDIASEC-CT | 32 | RFC 7345 (was draft-ietf-mmusic-udptl-dtls) | christer.holmberg@ericsson.com | Rel-12 | 62 |  |  |  |  |  |  |
| 2164 | 634.3.7 | CT3 part of CT aspects of Extended IMS media plane security features | 521d? | 2012-12-19 A | 2014-12-09 A | 100% |  | 2012-12-19 | 2014-06-13 | 394d? |  | finish no earlier than 2014-12-09 | C3 | 4168h | 4168h | eMEDIASEC-CT | 30 | 29.162 | Alcatel-Lucent | Rel-12 | 58 | Adrian |  |  |  |  | CP-140569 |
| 2165 | 635 | Lawful Interception in the 3GPP Rel-12 | 592d? | 2012-09-17 A | 2014-12-12 A | 100% |  | 2012-09-17 | 2014-09-12 | 526d? |  | finish no earlier than 2014-12-12 | S3 | 4736h | 4736h | LI12 | 29 | 33.106, 33.107, 33.108 | PIDS, Alcatel-Lucent | Rel-12 | 57 | Mirko | LI12 |  |  |  |  |

Notes:
- 2141: Specify Stage 3 procedures to support the ULI signalling optimizations / WI rapporteur e-mail: horst.brinkmann@alcatel-lucent.com
- 2142: CP#64 completed / WI rapporteur e-mail: horst.brinkmann@alcatel-lucent.com
- 2143: CP#65 completed / WI rapporteur e-mail: horst.brinkmann@alcatel-lucent.com
- 2144: SEC12 is an umbrella Feature for Security related TEI12 type of changes that are not part of any other dedicated feature
- 2145: - / WI rapporteur e-mail: john.mattsson@ericsson.com
- 2146: SP#57 completed. Specify reqs to protect against false PWS Warning Notifications (Optional as not all regions/countries require this functionality). WID covers all objectivES in CP-150SA3 PWS_Sec Feature-level WID replacing the original Stage 1 UID_510154 / WI rapporteur e-mail: adrian.neal@vodafone.com
- 2147: SP#65 completed. TR 33.969v100 for 1-step Approval. Former TR 33.869 changed to 33.969. / WI rapporteur e-mail: john.mattsson@ericsson.com
- 2148: SP#64 stopped / WI rapporteur e-mail: john.mattsson@ericsson.com
- 2149: Completed in Rel-9 under PWS. SP#55 stopped, Stage 1 requirements removed from Rel-9 onwards (SP-120172). AP 55/1: SA1 to align Stage 1 PWS security for Rel-12. SA1 new WID PWS Security UID_560029. / WI rapporteur e-mail: john.mattsson@ericsson.com
- 2150: SP#53 work stopped as already done in previous releases / WI rapporteur e-mail: john.mattsson@ericsson.com
- 2151: TSG#56 work stopped. SP#56 updated WID SP-110223=>SP-120334 (removed all but SA3 impacted specs) / WI rapporteur e-mail: mikael.wass@ericsson.com
- 2152: RP#53 work stopped as no WI in RAN / WI rapporteur e-mail: john.mattsson@ericsson.com
- 2153: SP#60 completed / WI rapporteur e-mail: Silke.Holtmanns@nokia.com
- 2154: Triggered by Rel-11 TR 33.829 Study on Extended IMS media plane security features (FS_eMEDIASEC) / WI rapporteur e-mail: Aguibou.Barry@vodafone.com
- 2155: SP#64 completed / WI rapporteur e-mail: Aguibou.Barry@vodafone.com
- 2156: SP#65 completed / WI rapporteur e-mail: christer.holmberg@ericsson.com
- 2157: - / WI rapporteur e-mail: bruno.landais@alcatel-lucent.com
- 2158: CP#65 completed. TR 29.828v200 for Approval. 2/4/15: acronym changed to eMEDIASEC-CT / WI rapporteur e-mail: bruno.landais@alcatel-lucent.com
- 2159: CP#65 completion 09/14=>12/14. Exception in CP-140479. Dec.14: 90->100. 2/4/15: acronym changed to eMEDIASEC-CT / WI rapporteur e-mail: bruno.landais@alcatel-lucent.com
- 2160: CP#65 completed. 2/4/15: acronym changed to eMEDIASEC-CT / WI rapporteur e-mail: christer.holmberg@ericsson.com
- 2161: Work in progress. 2/4/15: acronym changed to eMEDIASEC-CT; 22/3/18: 100%->0 / WI rapporteur e-mail: christer.holmberg@ericsson.com
- 2162: CP#65 completed. 2/4/15: acronym changed to eMEDIASEC-CT / WI rapporteur e-mail: bruno.landais@alcatel-lucent.com
- 2163: CP#65 completed. 2/4/15: acronym changed to eMEDIASEC-CT / WI rapporteur e-mail: christer.holmberg@ericsson.com
- 2164: CP#65 completion 06/14=>12/14. Level 100%=>80%. Exception in CP-140569. CP#64 completed. Dec.14: 80->100. 2/4/15: acronym changed to eMEDIASEC-CT / WI rapporteur e-mail: bruno.landais@alcatel-lucent.com
- 2165: 3/3/15: 75->100% / WI rapporteur e-mail: Koen Jaspers (k.b.jaspers@minjus.nl), terry.jacobson@alcatel-lucent.com

| ID | WBS | Task | Duration | Start | Finish | Complete | Baseline start | Baseline finish | Baseline duration | Constraint | Resources | Work | Actual work | Acronym | PCG approved | WI rapporteur name | WI rapporteur e-mail | Release | TSG approved | MCC resp | Acronym_3GU_Export | Status Report |
| --- | --- | --- | --- | --- | --- | --- | --- | --- | --- | --- | --- | --- | --- | --- | --- | --- | --- | --- | --- | --- | --- | --- |
| 2166 | 636 | **Tunneling of UE Services over Restrictive Access Networks (Stage 2/3)** | 401d? | 2012-12-13 A | 2014-06-18 A | 100% | 2012-12-13 | 2014-06-18 | 401d? |  | S3; C1 | 11662.5h | 11662.5h | TURAN | 30 | Acme Packet | Prashant Kumar (PKumar@acmepacket.com) | Rel-12 | 58 | Mirko | TURAN |  |
| 2167 | 636.1 | SA3 part of Tunneling of UE Services over Restrictive Access Networks (Stage 2/3) | 400d? | 2012-12-13 A | 2014-06-18 A | 100% | 2012-12-13 | 2014-06-18 | 400d? | finish no earlier than 2014-06-18 | S3 | 3168h | 3168h | TURAN-SA3 | 30 | Acme Packet | Prashant Kumar (PKumar@acmepacket.com) | Rel-12 | 58 | Mirko |  |  |
| 2168 | 636.2 | CT aspects of Tunneling of UE Services over Restrictive Access Networks (Stage 3) | 264d? | 2013-06-14 A | 2014-06-13 A | 100% | 2013-06-14 | 2014-06-13 | 264d? | finish no earlier than 2014-06-13 | C1 | 2094.45h | 2094.45h | TURAN-CT | 31 | Huawei | Haitao Wei (weihaitao@huawei.com) | Rel-12 | 60 | Frederic | TURAN-CT |  |
| 2169 | 637 | Specification of the TUAK Algorithm Set | 139d? | 2013-12-09 A | 2014-06-18 A | 100% | 2013-12-09 | 2014-06-18 | 139d? | finish no earlier than 2014-06-18 | S3 | 1112h | 1112h | STAS | 32 | Vodafone | aguibou.barry@vodafone.com | Rel-12 | 62 | Mirko | STAS |  |
| 2170 | 638 | **Codec for Enhanced Voice Services** | 1575d? | 2010-03-25 A | 2016-03-15 A | 100% | 2010-03-25 | 2014-12-12 | 1245d? |  | S4; S1; C4; C1; C3 | 87912h | 87912h | EVS_codec | 24 | Huawei | lei.miao@huawei.com | Rel-12 | 47 | Paolo | EVS_codec |  |
| 2171 | 638.1 | Stage 1 for Codec for Enhanced Voice Services | 1d? | 2010-03-25 A | 2010-03-25 A | 100% | 2010-03-25 | 2010-03-25 | 1d? | start no earlier than 2010-03-25 | S1 | 8h | 8h | EVS_codec-SA1 | 24 | Huawei | lei.miao@huawei.com | Rel-12 | 47 | Paolo |  |  |
| 2172 | 638.2 | Stage 2/3 for Codec for Enhanced Voice Services | 1240d? | 2010-03-25 A | 2014-12-12 A | 100% | 2010-03-25 | 2014-09-17 | 1178d? | finish no earlier than 2014-12-12 | S4 | 9896h | 9896h | EVS_codec-SA4 | 24 | Huawei | lei.miao@huawei.com | Rel-12 | 47 | Paolo |  | SP-140467 |
| 2173 | 638.3 | TR on Performance characterization of Codec for Enhanced Voice Services | 1239d? | 2010-03-25 A | 2014-12-12 A | 100% | 2010-03-25 | 2014-12-12 | 1239d? | finish no earlier than 2014-12-12 | S4 | 9888h | 9888h | EVS_codec-SA4TR | 24 | Huawei | lei.miao@huawei.com | Rel-12 | 47 | Paolo |  | SP-140467 |
| 2174 | 638.4 | **CT impacts of codec for Enhanced Voice Services** | 63d? | 2014-09-16 A | 2014-12-09 A | 100% |  |  |  |  | C4; C1; C3 | 3024h | 3024h | EVS_codec-CT | 33 | Nokia Networks | Jan.Kall@nsn.com | Rel-12 | 65 |  | EVS_codec-CT |  |
| 2175 | 638.4.1 | CT4 part of CT impacts of codec for Enhanced Voice Services | 63d? | 2014-09-16 A | 2014-12-09 A | 100% |  |  |  | finish no earlier than 2014-12-09 | C4 | 504h | 504h | EVS_codec-CT | 33 | Nokia Networks | Jan.Kall@nsn.com | Rel-12 | 65 |  |  | CP-140478 |
| 2176 | 638.4.2 | CT1 part of CT impacts of codec for Enhanced Voice Services | 63d? | 2014-09-16 A | 2014-12-09 A | 100% |  |  |  | finish no earlier than 2014-12-09 | C1 | 504h | 504h | EVS_codec-CT | 33 | Nokia Networks | Jan.Kall@nsn.com | Rel-12 | 65 |  |  | CP-140618 |
| 2177 | 638.4.3 | CT3 part of CT impacts of codec for Enhanced Voice Services | 63d? | 2014-09-16 A | 2014-12-09 A | 100% |  |  |  | finish no earlier than 2014-12-09 | C3 | 504h | 504h | EVS_codec-CT | 33 | Nokia Networks | Jan.Kall@nsn.com | Rel-12 | 65 |  |  | CP-140560 |
| 2178 | 638.5 | UE Conformance Test Aspects - Codec for Enhanced Voice Services (EVS) | 262d? | 2015-03-16 A | 2016-03-15 A | 100% |  |  |  | finish no earlier than 2016-03-15 | R5 | 2096h | 2096h | EVS_codec-UEConTest | 34 | Ericsson |  | Rel-12 | 67 |  |  | RP-151164 |
| 2179 | 639 | **Coordination of Video Orientation** | 400d? | 2012-06-07 A | 2013-12-06 A | 100% | 2012-06-07 | 2013-12-06 | 400d? |  | S4; C4; C1; C3 | 20496.8h | 20496.8h | CVO | 29 | Ericsson | frederic.gabin@ericsson.com | Rel-12 | 56 | Paolo | CVO |  |
| 2180 | 639.1 | SA4 part of Coordination of Video Orientation | 196d? | 2012-06-07 A | 2013-03-06 A | 100% | 2012-06-07 | 2013-03-06 | 196d? | finish no earlier than 2013-03-06 | S4 | 1560h | 1560h | CVO-SA4 | 29 | Ericsson | frederic.gabin@ericsson.com | Rel-12 | 56 | Paolo |  |  |
| 2181 | 639.2 | **CT aspects of Coordination of Video Orientation** | 129d? | 2013-06-14 A | 2013-12-06 A | 100% | 2013-06-14 | 2013-12-06 | 129d? |  | C4; C1; C3 | 6136.8h | 6136.8h | CVO-CT | 31 | Ericsson | nevenka.biondic@ericsson.com | Rel-12 | 60 | Kimmo | CVO-CT |  |
| 2182 | 639.2.1 | CT4 part of CT aspects of Coordination of Video Orientation | 128.05d? | 2013-06-14 A | 2013-12-06 A | 100% | 2013-06-14 | 2013-12-06 | 128.05d? | finish no earlier than 2013-12-06 | C4 | 1008.4h | 1008.4h | CVO-CT | 31 | Ericsson | nevenka.biondic@ericsson.com | Rel-12 | 60 | Kimmo |  |  |
| 2183 | 639.2.2 | CT1 part of CT aspects of Coordination of Video Orientation | 129d? | 2013-06-14 A | 2013-12-06 A | 100% | 2013-06-14 | 2013-12-06 | 129d? | finish no earlier than 2013-12-06 | C1 | 1016h | 1016h | CVO-CT | 31 | Ericsson | nevenka.biondic@ericsson.com | Rel-12 | 60 | Frederic |  |  |
| 2184 | 639.2.3 | CT3 part of CT aspects of Coordination of Video Orientation | 127.05d? | 2013-06-14 A | 2013-12-06 A | 100% | 2013-06-14 | 2013-12-06 | 127.05d? | finish no earlier than 2013-12-06 | C3 | 1016.4h | 1016.4h | CVO-CT | 31 | Ericsson | nevenka.biondic@ericsson.com | Rel-12 | 60 | Adrian |  |  |
| 2185 | 640 | **High Efficiency Video Coding** | 594d? | 2012-09-12 A | 2014-12-05 A | 100% | 2012-09-12 | 2014-12-05 | 591d? |  | S4; IETF | 21576h | 21576h | HEVC | 29 | Qualcomm | Ye-Kui Wang (yekuiw@qti.qualcomm.com) | Rel-12 | 57 | Paolo | HEVC |  |
| 2186 | 640.1 | TR on Evaluation of High Efficiency Video Coding for 3GPP Services | 464d? | 2012-09-12 A | 2014-06-19 A | 100% | 2012-09-12 | 2014-06-19 | 464d? | finish no earlier than 2014-06-18 | S4 | 3704h | 3704h | HEVC-SA4TR | 29 | Qualcomm | Ye-Kui Wang (yekuiw@qti.qualcomm.com) | Rel-12 | 57 | Paolo |  |  |
| 2187 | 640.2 | High Efficiency Video Coding in 3GPP services PSS, MBMS, DASH, MMS, MTSI, IMS Messaging and Presence | 462d? | 2012-09-17 A | 2014-06-18 A | 100% | 2012-09-17 | 2014-06-18 | 462d? | finish no earlier than 2014-06-18 | S4 | 3688h | 3688h | HEVC-SA4 | 29 | Qualcomm | Ye-Kui Wang (yekuiw@qti.qualcomm.com) | Rel-12 | 57 | Paolo |  |  |
| 2188 | 640.3 | (IETF) High Efficiency Video Coding | 587d? | 2012-09-17 A | 2014-12-05 A | 100% | 2012-09-17 | 2014-12-05 | 587d? | finish no earlier than 2014-12-05 | S4-IETF | 4696h | 4696h | HEVC-SA4IETF | 32 | Thomas Stockhammer, Qualcomm Incorporated | tsto@qti.qualcomm.com | Rel-12 | 63 |  |  |  |
| 2189 | 641 | Mobile stereoscopic 3D services extensions | 200d? | 2012-12-12 A | 2013-09-11 A | 100% | 2012-12-12 | 2013-09-11 | 200d? | finish no earlier than 2013-09-11 | S4 | 1568h | 1568h | M3DV_Ext | 30 | Huawei | lukasz.kondrad@huawei.com | Rel-12 | 58 | Paolo | M3DV_Ext |  |

Notes:
- 2166: Linked to Rel-12 SMURFs. Related to TS 22.278 (EPS) cl.7.1.8 Service Reachability (Firewall traversal for IP based services for non-3GPP access), TS 22.228 (IMS) cl.5 (support Firewall traversal), TR 33.830 (Study on Firewall traversal) / Impacted TSs and TRs: Stage 2/3
- 2167: SP#64 completed / Impacted TSs and TRs: 33.203, 33.402
- 2168: CP#64 completed. Stage 3 for 2 new SA3 solutions for firewall traversal: 1) UE access to PLMN IP-based services via restrictive non-3GPP Ans, 2) UE access to IMS services via restrictive ANs / Impacted TSs and TRs: 24.229, 24.302, New TS 24.322
- 2169: SP#64 completed. Triggered by SP-130602 LS from ETSI SAGE (TUAK as alternative to Milenage). 12/14: new TS added / Impacted TSs and TRs: New TSs: 35.231, 35.232, 35.233, TR 35.9nn, TR 35.9nn, TR 35.9nn
- 2170: Triggered by UID_370045 Study on enhanced voice service requirements for EPS (TR 22.813)
- 2171: SP#47 completed / Impacted TSs and TRs: 22.173
- 2172: SP#65 completion 09/14=>12/14. Exception in SP-140467. TS 26.441v200 for Approval. TSs 26.442/44/45/46/47/48/49/50/51v100 for 1-step Approval. Ongoing TS 26.443 EVS Codec ANSI C code (floating point). Dec.14: 90->95 / Impacted TSs and TRs: 26.114, New TS (26.441, 26.442, 26.443, 26.444, 26.445, 26.446, 26.447, 26.448, 26.449, 26.450, 26.451)
- 2173: SP#65 completion 09/14=>12/14. Ongoing TR 26.952 EVS Codec Performance Characterization. Exception in SP-140467 / Impacted TSs and TRs: New TR 26.952
- 2174: Stage 3; WID: CP-140492-> CP-140800
- 2175: CP#65 exception in CP-140478. Dec.14: 0->100; WID: CP-140492-> CP-140800 / Impacted TSs and TRs: 23.334, 29.232, 29.238, 29.332, 29.333, 29.334
- 2176: CP#65 exception in CP-140618. Dec.14: 0->100%; WID: CP-140492-> CP-140800 / Impacted TSs and TRs: 24.229
- 2177: CP#65 exception in CP-140560. Dec.14: 20->100; WID: CP-140492-> CP-140800 / Impacted TSs and TRs: 29.163, 29.292
- 2178: 03/07/15: Compl:0%->25% 03/07/15: WID: RP-150137->RP-150836 03/07/15: Stat Rep: ->RP-150831 29/09/15: Compl:25%->75% 29/09/15: Stat Rep: RP-150831->RP-1511641/1/16: Compl:75%->95%1/1/16: CD:Tue 15/12/15->Tue 15/03/16;
- 2179: CP#62 completed. Resolve backward compatible video orientation mis-alignment in MTSI real-time video communication via interaction between MTSI video clients at call setup & during mid-call of the video orientation for correct local rendering
- 2180: SP#59 completed. Resolve backward compatible video orientation mis-alignment in MTSI real-time video communication via interaction between MTSI video clients at call setup & during mid-call of the video orientation for correct local rendering / Impacted TSs and TRs: 26.114, 26.141, 26.234, 26.346
- 2181: Complete CVO support (both, basic 2 bit orientation and additional option for extra 6 bit granularity) within CN protocols/procedures for IMS nodes, e.g. IMS ALG/AGW,IBCF/TrGW,MRFC/MRFP & add support of CVO-related SDP attributes to be negotiated by UE / Impacted TSs and TRs: Stage 2/3
- 2182: CP#62 completed / Impacted TSs and TRs: 23.333, 23.334, 29.238, 29.332, 29.333, 29.334
- 2183: CP#62 completed / Impacted TSs and TRs: 24.229
- 2184: CP#62 completed / Impacted TSs and TRs: 29.162, 29.163
- 2185: Specify the support of HEVC in 3GPP services (PSS, DASH, MTSI, MMS, MBMS, IMS Messaging and Presence)
- 2186: SP#64 completed. TR 26.906v200 for Approval / Impacted TSs and TRs: New TR 26.906
- 2187: SP#64 completed / Impacted TSs and TRs: 26.114, 26.140, 26.141, 26.234, 26.244, 26.247, 26.346
- 2188: Submitted to IESG for publication. 7/10/15: Rapporteur added; 7/3/16: 50%->95; 13/6/16: 95%->100 / Impacted TSs and TRs: draft-ietf-payload-rtp-h265=>RFC7798
- 2189: SP#61 completed. Related to Rel-11 Study On Mobile 3D Video Coding (FS_M3DVC) TR 26.905 and Rel-11 Mobile 3D Video Coding (M3DVC) / Impacted TSs and TRs: 26.114, 26.245, 26.247, 26.430

| ID | WBS | Task | Duration | Start | Finish | Complete | Baseline start | Baseline finish | Baseline duration | Constraint | Resources | Work | Actual work | Acronym | PCG approved | WI rapporteur name | WI rapporteur e-mail | Release | TSG approved | MCC resp | Acronym_3GU_Export | Impacted TSs and TRs | Status Report | Special Focus Doc |
| --- | --- | --- | --- | --- | --- | --- | --- | --- | --- | --- | --- | --- | --- | --- | --- | --- | --- | --- | --- | --- | --- | --- | --- | --- |
| 2190 | 642 | **IMS-based Streaming and Download Delivery Enhancements** | 329d? | 2012-12-12 A | 2014-03-07 A | 100% | 2012-12-12 | 2014-03-07 | 329d? |  | S4 | 7800h | 7800h | IMS_SDE | 30 | Intel | ozgur.oyman@intel.com | Rel-12 | 58 | Paolo | IMS_SDE |  |  |  |
| 2191 | 642.1 | TR on IMS-based Streaming and Download Delivery Enhancements | 326d? | 2012-12-12 A | 2014-03-07 A | 100% | 2012-12-12 | 2014-03-07 | 326d? | finish no earlier than 2014-03-07 | S4 | 2584h | 2584h | IMS_SDE-SA4TR | 30 | Intel | ozgur.oyman@intel.com | Rel-12 | 58 | Paolo |  | new TR 26.827 |  |  |
| 2192 | 642.2 | Specification on IMS-based Streaming and Download Delivery Enhancements | 327d? | 2012-12-13 A | 2014-03-07 A | 100% | 2012-12-13 | 2014-03-07 | 327d? | finish no earlier than 2014-03-07 | S4 | 2584h | 2584h | IMS_SDE-SA4 | 30 | Intel | ozgur.oyman@intel.com | Rel-12 | 58 | Paolo |  | 26.237 |  |  |
| 2193 | 643 | **Acoustic Requirements and Test methods for IMS-based conversational speech services over LTE** | 532d? | 2012-12-12 A | 2014-12-12 A | 100% | 2012-12-12 | 2014-09-17 | 467d? |  | S4 | 14224h | 14224h | ART_LTE | 30 | Qualcomm | Andre Schevciw (aschevci@qualcomm.com) | Rel-12 | 58 | Paolo | ART_LTE | Stage 3 |  |  |
| 2194 | 643.1 | Acoustic Requirements and Test methods for IMS-based conversational speech services over LTE - NarrowBand and WideBand aspects | 265d? | 2012-12-12 A | 2013-12-11 A | 100% | 2012-12-12 | 2013-12-11 | 265d? | finish no earlier than 2013-12-11 | S4 | 2088h | 2088h | ART_LTE-NBWB | 30 | Sony Mobile Communications | Peter.Isberg@sony.com | Rel-12 | 58 | Paolo | ART_LTE-NBWB | 26.131, 26.132 |  |  |
| 2195 | 643.2 | Acoustic Requirements and Test methods for IMS-based conversational speech services over LTE - UE Delay aspects | 462d? | 2012-12-12 A | 2014-09-17 A | 100% | 2012-12-12 | 2014-09-17 | 461d? | finish no earlier than 2014-09-17 | S4 | 3696h | 3696h | ART_LTE-UED | 30 | AT&T, Orange | luisa.marchetto@att.com, stephane.ragot@orange.com | Rel-12 | 58 | Paolo | ART_LTE-UED | 26.131, 26.132 |  |  |
| 2196 | 643.3 | Acoustic Requirements and Test methods for IMS-based conversational speech services over LTE - Super wideband and fullband aspects | 523d? | 2012-12-12 A | 2014-12-12 A | 100% | 2012-12-12 | 2014-09-17 | 461d? | finish no earlier than 2014-12-12 | S4 | 4184h | 4184h | ART_LTE-SUPER | 30 | Sony Mobile Communications | peter.isberg@sonymobile.com | Rel-12 | 58 | Paolo | ART_LTE-SUPER | 26.131, 26.132 | SP-140470 |  |
| 2197 | 644 | **MBMS Improvements** | 471d? | 2013-03-06 A | 2014-12-12 A | 100% | 2013-03-06 | 2014-09-17 | 406d? |  | S4 | 18584h | 18584h | MI | 30 | Ericsson | eric.turcotte@ericsson.com | Rel-12 | 59 | Paolo | MI |  | SP-140471 |  |
| 2198 | 644.1 | TR on Enhanced MBMS Operation | 463d? | 2013-03-06 A | 2014-12-12 A | 100% | 2013-03-06 | 2014-09-17 | 401d? | finish no earlier than 2014-12-12 | S4 | 3704h | 3704h | MI-EMOTR | 30 | Huawei | Zhiming Li (lizhiming@huawei.com) | Rel-12 | 59 | Paolo |  | New TR 26.848 | SP-140471 |  |
| 2199 | 644.2 | Enhanced MBMS Operation | 463d? | 2013-03-06 A | 2014-12-12 A | 100% | 2013-03-06 | 2014-09-17 | 401d? | finish no earlier than 2014-12-12 | S4 | 3704h | 3704h | MI-EMO | 30 | Huawei | Zhiming Li (lizhiming@huawei.com) | Rel-12 | 59 | Paolo | MI-EMO | 26.247, 26.346 | SP-140471 |  |
| 2200 | 644.3 | TR on MBMS operation on Demand | 463d? | 2013-03-06 A | 2014-12-12 A | 100% | 2013-03-06 | 2014-09-17 | 401d? | finish no earlier than 2014-12-12 | S4 | 3704h | 3704h | MI-MooDTR | 30 | Qualcomm | Charles Lo (clo@qti.qualcomm.com) | Rel-12 | 59 | Paolo |  | New TR 26.849 | SP-140471 |  |
| 2201 | 644.4 | MBMS operation on Demand | 463d? | 2013-03-06 A | 2014-12-12 A | 100% | 2013-03-06 | 2014-09-17 | 401d? | finish no earlier than 2014-12-12 | S4 | 3704h | 3704h | MI-MooD | 30 | Qualcomm | Charles Lo (clo@qti.qualcomm.com) | Rel-12 | 59 | Paolo | MI-MooD | 26.346 | SP-140471 |  |
| 2202 | 645 | **End-to-End Multimedia Telephony Service for IMS (MTSI) extensions** | 667d? | 2013-03-06 A | 2015-09-14 A | 100% | 2013-03-06 | 2015-03-13 | 533d? |  | S4 | 32648h | 32648h | E2EMTSI | 30 | Ericsson | tomas.frankkila@ericsson.com | Rel-12 | 59 | Paolo | E2EMTSI | 26.114 |  |  |
| 2203 | 645.1 | S4 aspects of End-to-End Multimedia Telephony Service for IMS (MTSI) extensions | 406d? | 2013-03-06 A | 2014-09-16 A | 100% | 2013-03-06 | 2015-03-13 | 533d? | finish no earlier than 2014-09-17 | S4 | 3248h | 3248h | E2EMTSI | 30 | Ericsson | tomas.frankkila@ericsson.com | Rel-12 | 59 | Paolo | E2EMTSI | 26.114 |  |  |
| 2204 | 645.2 | **CT aspects of End-to-End Multimedia Telephony Service for IMS (MTSI) extensions** | 589d? | 2013-06-21 A | 2015-09-14 A | 100% | 2013-06-20 | 2014-09-12 | 326d? |  | C3; C1; C4 | 24064h | 24064h | E2EMTSI-CT | 31 | Ericsson | susana.fernandez@ericsson.com | Rel-12 | 60 | Adrian |  | Stage 2/3 |  |  |
| 2205 | 645.2.1 | CT3 part of CT aspects of End-to-End Multimedia Telephony Service for IMS (MTSI) extensions | 589d? | 2013-06-21 A | 2015-09-14 A | 100% | 2013-06-20 | 2014-09-12 | 326d? | finish no earlier than 2015-09-14 | C3 | 4712h | 4712h | E2EMTSI-CT | 31 | Ericsson | susana.fernandez@ericsson.com | Rel-12 | 60 | Adrian |  | 29.162, 29.163, 29.213, 29.214 |  |  |
| 2206 | 645.2.2 | CT1 part of CT aspects of End-to-End Multimedia Telephony Service for IMS (MTSI) extensions | 326d? | 2013-06-21 A | 2014-09-12 A | 100% | 2013-06-20 | 2014-09-12 | 326d? | finish no earlier than 2014-09-12 | C1 | 2608h | 2608h | E2EMTSI-CT | 31 | Ericsson | susana.fernandez@ericsson.com | Rel-12 | 60 | Frederic |  | 24.229 |  |  |
| 2207 | 645.2.3 | CT4 part of CT aspects of End-to-End Multimedia Telephony Service for IMS (MTSI) extensions | 326d? | 2013-06-21 A | 2014-09-12 A | 100% | 2013-06-20 | 2014-09-12 | 326d? | finish no earlier than 2014-09-12 | C4 | 2608h | 2608h | E2EMTSI-CT | 31 | Ericsson | susana.fernandez@ericsson.com | Rel-12 | 60 | Kimmo |  | 23.333, 23.334, 29.238, 29.332, 29.333, 29.334 |  |  |
| 2208 | 646 | Video Coding Enhancements in IMS Messaging and Presence | 64d? | 2013-12-11 A | 2014-03-07 A | 100% | 2013-12-11 | 2014-03-07 | 64d? | finish no earlier than 2014-03-07 | S4 | 504h | 504h | VCEIMP | 32 | Ericsson | frederic.gabin@ericsson.com | Rel-12 | 62 | Paolo | VCEIMP | 26.141 |  |  |
| 2209 | 647 | Video Telephony Robustness Improvements | 66d? | 2014-06-18 A | 2014-09-16 A | 100% | 2014-06-18 | 2014-09-17 | 66d? | finish no earlier than 2014-09-17 | S4 | 528h | 528h | VTRI | 33 | Qualcomm | Muhammed Coban (mcoban@qti.qualcomm.com) | Rel-12 | 64 |  | VTRI | 26.114 |  |  |
| 2210 | 648 | **Rel-12 Operations, Administration, Maintenance and Provisioning (OAM&P)** | 857d? | 2011-09-21 A | 2014-12-12 A | 100% | 2011-09-21 | 2014-09-17 | 792d? |  | S5 | 58352.5h | 58352.5h | OAM12 | 29 |  |  | Rel-12 | 56 | Mirko | OAM12 |  |  |  |
| 2211 | 648.1 | **Rel-12 Self-Organizing Networks (SON) - OAM aspects** | 591d? | 2011-09-21 A | 2013-12-11 A | 100% | 2011-09-21 | 2013-12-11 | 591d? |  | S5 | 9408h | 9408h | OAM12-SON | 29 |  |  | Rel-12 | 56 | Mirko | OAM12-SON |  |  | HNB, SON |
| 2212 | 648.1.1 | Multi-vendor Plug and Play eNB connection to the network | 586d? | 2011-09-21 A | 2013-12-11 A | 100% | 2011-09-21 | 2013-12-11 | 586d? | finish no earlier than 2013-12-11 | S5 | 4680h | 4680h | SON-NM-MUPPET | 29 | NSN | anatoly.andrianov@nsn.com | Rel-12 | 56 | Mirko | SON-NM-MUPPET | 32.501, New TSs (32.508, 32.509) |  | HNB, SON |
| 2213 | 648.2 | **Compliance of 3GPP SA5 specifications to the NGMN Next Generation Converged Operations Requirements (NGCOR)** | 596d? | 2012-06-20 A | 2014-09-17 A | 100% | 2012-06-20 | 2014-09-17 | 595d? |  | S5 | 11616.5h | 11616.5h | OAM-NGMN_NGCOR | 29 | Huawei | christian.toche@huawei.com | Rel-12 | 56 | Mirko | OAM-NGMN_NGCOR |  |  |  |
| 2214 | 648.2.1 | Converged Management Model Alignment (Phase 2) | 593d? | 2012-06-20 A | 2014-09-17 A | 100% | 2012-06-20 | 2014-09-17 | 593d? | finish no earlier than 2014-09-17 | S5 | 4744h | 4744h | OAM-MODAL | 29 | NSN | olaf.pollakowski@nsn.com | Rel-12 | 56 | Mirko | OAM-MODAL | 32.156, new TR 28.820 |  |  |
| 2215 | 648.2.2 | 3GPP Fault Management Solution Profile for NGMN NGCOR | 266d? | 2012-06-20 A | 2013-06-19 A | 100% | 2012-06-20 | 2013-06-19 | 266d? | finish no earlier than 2013-06-19 | S5 | 2104.53h | 2104.53h | OAM-FMSP | 29 | Ericsson | thomas.tovinger@ericsson.com | Rel-12 | 56 | Mirko | OAM-FMSP | new TS 28.390 |  |  |

Notes:
- 2190: Provide an extension of IMS based PSS and MBMS user services
- 2191: SP#63 completed. Identify use cases and requirements based on Rel-10/11 PSS and MBMS functionality to be addressed for IMS-based streaming and download enhancements
- 2192: SP#63 completed. Develop procedures towards enabling the IMS-based extensions of the identified use casES in CP-150TS 26.237. Refine existing MBMS download procedures to enable IMS-based MBMS file repair with the use of conventional HTTP web servers.
- 2193: Triggered by Rel-12 Feature Codec for Enhanced Voice Services (EVS_codec) UID_470030. Need for super wideband acoustic requirements and test methods
- 2194: SP#62 completed
- 2195: SP#65 completed
- 2196: SP#65 completion 09/14=>12/14. Exception in SP-140470. Dec.14: 65->100
- 2197: Stage 3 based on existing Stage 2 in TS 23.246 MBMS Architecture and functional description
- 2198: SP#65 completion 09/14=>12/14. Exception in SP-140471. SP#63 TR 26.848v100 for Information. Dec.14: 85->100.
- 2199: SP#65 completion 09/14=>12/14. Exception in SP-140471. Dec.14: 85->100
- 2200: SP#65 completion 09/14=>12/14. Exception in SP-140471. SP#63 TR 26.849v100 for Information. Dec.14: 75->100
- 2201: SP#65 completion 09/14=>12/14. Exception in SP-140471. Dec.14: 75->100
- 2202: SP#65 completed. Updated WID SP-130670=>SP-140594. Reduced Scope & Objectives. Moved work on new TR 26.924, etc. to Rel-13. Co-ordinate with CT1/3/4. Linked to SA4 Rel-7 Media handling and interaction in MTSI (MTSI-MHI) UID_7040
- 2203: SP#65 completed. Updated WID SP-130670=>SP-140594. Reduced Scope & Objectives. Moved work on new TR 26.924, etc. to Rel-13. Co-ordinate with CT1/3/4. Linked to SA4 Rel-7 Media handling and interaction in MTSI (MTSI-MHI) UID_7040
- 2204: Stage 2/3. 5/5/15: corrected to be Rel-12. Nothing to be done in the end (covered by Rel-13 QOSE2EMTSI-CT), so 100%
- 2205: Dec.14: CD: 09/14->09/15. 5/5/15: corrected to be Rel-12. Nothing to be done in the end (covered by Rel-13 QOSE2EMTSI-CT), so 100%
- 2206: CP#64 completion 06/14=>09/14. 5/5/15: corrected to be Rel-12. Nothing to be done in the end (covered by Rel-13 QOSE2EMTSI-CT), so 100%
- 2207: CP#64 completion 06/14=>09/14. 5/5/15: corrected to be Rel-12. Nothing to be done in the end (covered by Rel-13 QOSE2EMTSI-CT), so 100%
- 2208: SP#63 completed. Linked to Rel-6 Media Codecs and Formats for IMS Messaging and Presence (PRESNC-COFIMP) UID_34025. Work item which gave rise to TS 26.141
- 2209: SP#65 completed. Linked to E2EMTSI (End-to-End Multimedia Telephony Service for IMS extensions). Add Reqs&guidelines for video telephony robustness to improve service perf. for PLI, Generic NACK, and FIR messages within overall bitrate limit
- 2210: OAM12 is an umbrella Feature for changes that are not part of any other dedicated feature/WI
- 2211: OAM12-SON is an umbrella BB also for SON related TEI12 type of changes that are not part of any other dedicated feature/WI
- 2212: SP#62 completed. TS 32.508v200 for Approval, TS 32.509v100 for 1-step Approval
- 2213: SP#65 moved to Rel-13 OAM-PMID (Converged management Performance Management Interface Definition) UID_560235
- 2214: SP#65 completed. TR 28.280v100 for 1-step Approval
- 2215: SP#60 completed. TS 28.390v200 for Approval

| ID | WBS | Task | Duration | Start | Finish | Complete | Baseline start | Baseline finish | Baseline duration | Constraint | Resources | Work | Actual work | Acronym | PCG approved | WI rapporteur name | WI rapporteur e-mail | Release | TSG approved | MCC resp | Special Focus Doc | Acronym_3GU_Export | Status Report | TSG stopped |
| --- | --- | --- | --- | --- | --- | --- | --- | --- | --- | --- | --- | --- | --- | --- | --- | --- | --- | --- | --- | --- | --- | --- | --- | --- |
| 2216 | 648.3 | **Network Management for 3GPP Interworking WLAN** | 793d? | 2011-09-21 A | 2014-09-17 A | 100% | 2011-09-21 | 2014-06-18 | 727d? |  | S5 | 17232h | 17232h | OAM-IWLAN | 27 | China Mobile | Chengang@chinamobile.com, lijian@chinamobile.com | Rel-12 | 53 | Mirko | WLAN | OAM-IWLAN |  |  |
| 2217 | 648.3.1 | Performance measurements part Network Management for 3GPP Interworking WLAN | 785d? | 2011-09-22 A | 2014-09-17 A | 100% | 2011-09-22 | 2014-06-18 | 720d? | finish no earlier than 2014-09-17 | S5 | 6272h | 6272h | OAM-IWLAN-SA5P | 27 | China Mobile | Chengang@chinamobile.com, lijian@chinamobile.com | Rel-12 | 53 | Mirko | WLAN |  |  |  |
| 2218 | 648.3.2 | NIM part Network Management for 3GPP Interworking WLAN | 585d? | 2011-09-21 A | 2013-12-11 A | 100% | 2011-09-21 | 2013-12-11 | 585d? | finish no earlier than 2013-12-11 | S5 | 4672h | 4672h | OAM-IWLAN-SA5NM | 27 | China Mobile | Chengang@chinamobile.com, lijian@chinamobile.com | Rel-12 | 53 | Mirko | WLAN |  |  |  |
| 2219 | 648.4 | **Rel-12 Network Infrastructure Management** | 267d? | 2013-12-11 A | 2014-12-12 A | 100% | 2013-12-11 | 2014-09-17 | 202d? |  | S5 | 5848h | 5848h | OAM12-NIM | 30 |  |  | Rel-12 | 58 | Mirko |  | OAM12-NIM |  |  |
| 2220 | 648.4.1 | Alarm quality improvements | 263d? | 2013-12-11 A | 2014-12-12 A | 100% | 2013-12-11 | 2014-09-17 | 201d? | finish no earlier than 2014-12-12 | S5 | 2104h | 2104h | OAM-AMI-SA5 | 32 | TeliaSonera | tommy.berggren@teliasonera.com | Rel-12 | 62 | Mirko |  | OAM-AMI | SP-140544 |  |
| 2221 | 648.4.2 | Radio Planning Tool (RPT) interface | 201d? | 2014-03-07 A | 2014-12-12 A | 100% | 2014-03-07 | 2014-09-17 | 139d? | finish no earlier than 2014-12-12 | S5 | 1608h | 1608h | OAM-RPTi-SA5 | 32 | Nokia Networks | olaf.pollakowski@nsn.com | Rel-12 | 63 | Mirko |  | OAM-RPTi | SP-140546 |  |
| 2222 | 648.5 | Deleted - Rel-12 Performance Management | 328d? | 2013-06-21 A | 2014-09-16 A | 100% | 2013-06-21 | 2014-09-17 | 328d? |  | S5 | 2624h | 2624h | OAM12-PM | 30 |  |  | Rel-12 | 58 | Mirko |  | OAM12-PM |  | SP-69 |
| 2223 | 648.6 | **OAM aspects of Network Sharing** | 267d? | 2013-12-11 A | 2014-12-12 A | 100% | 2013-12-11 | 2014-09-17 | 202d? |  | S5 | 6344h | 6344h | OAM-SHARE | 32 | Orange | jeanmichel.cornily@orange.com | Rel-12 | 62 | Mirko |  | OAM-SHARE | SP-140545 |  |
| 2224 | 648.6.1 | OAM aspects of Network Sharing - Concepts and high-level requirements | 263d? | 2013-12-11 A | 2014-12-12 A | 100% | 2013-12-11 | 2014-09-17 | 201d? | finish no earlier than 2014-12-12 | S5 | 2104h | 2104h | OAM-SHARE-SA5c | 32 | Orange | jeanmichel.cornily@orange.com | Rel-12 | 62 | Mirko |  |  | SP-140545 |  |
| 2225 | 648.6.2 | OAM aspects of Network Sharing - Impacts on existing specifications | 263d? | 2013-12-12 A | 2014-12-12 A | 100% | 2013-12-12 | 2014-09-17 | 201d? | finish no earlier than 2014-12-12 | S5 | 2104h | 2104h | OAM-SHARE-SA5imp | 32 | Orange | jeanmichel.cornily@orange.com | Rel-12 | 62 | Mirko |  |  | SP-140545 |  |
| 2226 | 649 | **Rel-12 Charging** | 402d? | 2012-12-12 A | 2014-06-18 A | 100% | 2012-12-12 | 2014-06-18 | 402d? |  | S5 | 10112h | 10112h | CH12 | 29 |  |  | Rel-12 | 57 | Mirko |  | CH12 |  |  |
| 2227 | 649.1 | Short Message Service - Service Center (SMS-SC) Offline Charging | 325d? | 2012-12-12 A | 2014-03-10 A | 100% | 2012-12-12 | 2014-03-07 | 325d? | finish no earlier than 2014-03-07 | S5 | 2592h | 2592h | SMS-SC-CH | 30 | Alcatel-Lucent | maryse.gardella@alcatel-lucent.com | Rel-12 | 58 | Mirko |  | SMS-SC-CH |  |  |
| 2228 | 649.2 | Charging per IP - Connectivity Access Network (IP-CAN) Session (Stage 2/3) | 201d? | 2013-09-12 A | 2014-06-18 A | 100% | 2013-09-12 | 2014-06-18 | 201d? | finish no earlier than 2014-06-18 | S5 | 1608h | 1608h | CHIPS | 31 | Ericsson | david.shrader@ericsson.com | Rel-12 | 61 | Mirko |  | CHIPS |  |  |
| 2229 | 649.3 | Charging using an Alternative Roaming Provider (Stage 2/3) | 202d? | 2013-09-12 A | 2014-06-18 A | 100% | 2013-09-12 | 2014-06-18 | 202d? | finish no earlier than 2014-06-18 | S5 | 1608h | 1608h | CHARP | 31 | Ericsson | david.shrader@ericsson.com | Rel-12 | 61 | Mirko |  | CHARP |  |  |
| 2230 | 649.4 | Charging for IMS centralized service (ICS) control (Stage 2/3) | 137d? | 2013-12-11 A | 2014-06-18 A | 100% | 2013-12-11 | 2014-06-18 | 137d? | finish no earlier than 2014-06-18 | S5 | 1088h | 1088h | CHICS | 32 | NSN | Gerald.Goermer@nsn.com | Rel-12 | 62 | Mirko |  | CHICS |  |  |
| 2231 | 650 | **IMS Emergency PSAP Callback (Stage 3)** | 724d? | 2011-09-21 A | 2014-06-13 A | 100% | 2011-09-21 | 2014-06-13 | 724d? |  | C1; C3; IETF | 38848h | 38848h | EMC_PC | 27 | Ericsson | christer.holmberg@ericsson.com | Rel-12 | 53 | Frederic | Public Safety (I-A) | EMC_PC |  |  |
| 2232 | 650.1 | CT1 part of IMS Emergency PSAP Callback | 721d? | 2011-09-22 A | 2014-06-13 A | 100% | 2011-09-22 | 2014-06-13 | 721d? | finish no earlier than 2014-06-13 | C1 | 5760h | 5760h | EMC_PC | 27 | Ericsson | christer.holmberg@ericsson.com | Rel-12 | 53 | Frederic | Public Safety (I-A) |  |  |  |
| 2233 | 650.2 | (IETF) CT1 part of IMS Emergency PSAP Callback (RFC 7090) | 723d? | 2011-09-21 A | 2014-06-13 A | 100% | 2011-09-21 | 2014-06-13 | 723d? | finish no earlier than 2014-06-13 | C1-IETF | 5776h | 5776h | EMC_PC | 27 | christer.holmberg@ericsson.com | christer.holmberg@ericsson.com | Rel-12 | 53 | Frederic | Public Safety (I-A) |  |  |  |
| 2234 | 650.3 | CT3 part of IMS Emergency PSAP Callback | 519d? | 2011-09-24 A | 2013-09-06 A | 100% | 2011-09-24 | 2013-09-06 | 519d? | finish no earlier than 2013-09-06 | C3 | 4152h | 4152h | EMC_PC | 27 | Ericsson | christer.holmberg@ericsson.com | Rel-12 | 53 | Adrian | Public Safety (I-A) |  |  |  |
| 2235 | 650.4 | (IETF) CT3 part of IMS Emergency PSAP Callback (RFC 7090) | 724d? | 2011-09-21 A | 2014-06-13 A | 100% | 2011-09-21 | 2014-06-13 | 724d? | finish no earlier than 2014-06-13 | C3-IETF | 5784h | 5784h | EMC_PC | 31 | christer.holmberg@ericsson.com | christer.holmberg@ericsson.com | Rel-12 | 60 | Adrian | Public Safety (I-A) |  |  |  |
| 2236 | 651 | Interworking between a PLMN with WLAN to access the EPC and a PDN (Stage 3) | 265d? | 2012-09-10 A | 2013-09-06 A | 100% | 2012-09-10 | 2013-09-06 | 265d? | finish no earlier than 2013-08-12 | C3 | 2091.72h | 2091.72h | SAES_WLAN_EPC_intwk | 29 | Huawei | Christian.Herrero@huawei.com | Rel-12 | 57 | Adrian | WLAN | SAES_WLAN_EPC_intwk |  |  |
| 2237 | 652 | **Reporting Enhancements in Warning Message Delivery (Stage 2/3)** | 402d? | 2012-12-07 A | 2014-06-13 A | 100% | 2012-12-07 | 2014-06-13 | 402d? |  | C1; C4; R3 | 20832.2h | 20832.2h | REP_WMD | 30 | one2many | peter.sanders@one2many.eu | Rel-12 | 58 | Frederic | Public Safety (I-A) | REP_WMD |  |  |
| 2238 | 652.1 | CT1 part of Reporting Enhancements in Warning Message Delivery (Stage 2) | 329d? | 2012-12-07 A | 2014-03-04 A | 100% | 2012-12-07 | 2014-03-04 | 329d? | finish no earlier than 2014-03-06 | C1 | 2592.18h | 2592.18h | REP_WMD-CT1 | 30 | one2many | peter.sanders@one2many.eu | Rel-12 | 58 | Frederic | Public Safety (I-A) |  |  |  |
| 2239 | 652.2 | CT4 part of Reporting Enhancements in Warning Message Delivery (Stage 2/3) | 400d? | 2012-12-10 A | 2014-06-13 A | 100% | 2012-12-10 | 2014-06-13 | 400d? | finish no earlier than 2014-06-13 | C4 | 3168h | 3168h | REP_WMD-CT4 | 30 | one2many | peter.sanders@one2many.eu | Rel-12 | 58 | Kimmo | Public Safety (I-A) |  |  |  |

Notes:
- 2216: SP#65 updated WID SP-120779=>SP-140542 (removed parts on CN and non-3GPP access). Discontinue I-WLAN spec.
- 2217: SP#65 completed. TS 28.402v100 for 1-step Approval, withdraw New TS 28.401 (CN and non-3GPP access i/w PMs). Moved PMs for EPC and non-3GPP access i/w from 28.401=>28.402 / Impacted TSs and TRs: new TS 28.401, withdrawn new TS 28.402
- 2218: SP#65 discontinue I-WLAN specs: Move parts (e.g. IOCs) applicable for EPC and non-3GPP access interworking NRMs from 28.601/2/6 to 28.611/2/6. Withdraw 28.601/2/6 (CN and non-3GPP access i/w NRMs). SP#62 completed. TSs 28.601/2/6/11/12/16 for Approval / Impacted TSs and TRs: 32.632, 32.636, 32.752, 32.756, new TS (28.611, 28.612, 28.616, withdrawn 28.601, 28.602, 28.606)
- 2219: -
- 2220: SP#65 completion 09/14=>12/14. Exception in SP-140544. Triggered by Rel-12 TR 32.859 Study on Alarm Management (FS_OAM_AM) . Dec.14: 50->100 / Impacted TSs and TRs: 32.111-1, 32.111-2, 32.111-6
- 2221: SP#65 completion 09/14=>12/14. Exception in SP-140546. SP#65 v100 TS 28.667/8 for Information. Dec.14: 60->100 / Impacted TSs and TRs: 32.101, New TSs (28.667, 28.668, 28.669)
- 2222: OAM12-PM is an umbrella BB also for PM related TEI12 type of changes that are not part of any other dedicated feature/WI
- 2223: SP#65 completion 09/14=>12/14. Exception in SP-140545. Triggered by Rel-12 TR 32.851 Study on OAM aspects of Network Sharing (FS_OAM_SHARE), Rel-6 Network Sharing (NTShar) UID_31018 / Impacted TSs and TRs: Stage 1/2/3
- 2224: SP#65 completion 09/14=>12/14. Exception in SP-140545. LM 80->100 / Impacted TSs and TRs: new TS 32.130
- 2225: SP#65 completion 09/14=>12/14. Exception in SP-140545. Dec.14: 60->100 / Impacted TSs and TRs: 28.401,28.621/2/3,28.651/2/3,28.654/5/6,28.657/8/9,28.701/2/3,28.731/2/3,28.734/5/6,32.101/2,32.111-1/2/3/6,32.121/2/6,32.155,32.171/2/6,32.300/1/2/6,32.311/2/6,32.321/2/6,32.331/2/6,32.341/2/6,32.351/352/6,32.361/2/6,32.381/2/6,32.405/6/7/8/9/10/11/12/41
- 2226: CH12 is an umbrella Feature for changes that are not part of any other dedicated feature/WI
- 2227: Stage 2/3. SP#63 completed. Updated WID SP-120775=>SP-140027 / Impacted TSs and TRs: 32.240, 32.274, 32.297, 32.298, 32.299
- 2228: SP#64 completed. 12/15: Acronym reverted back from CHIPCAN to CHIPS / Impacted TSs and TRs: 32.251, 32.298, 32.299
- 2229: SP#64 completed. TS 32.276v200 for Approval, 32.293v100 for 1-step Approval / Impacted TSs and TRs: 32.240, 32.299, New TSs [32.276 (Voice Call Service Charging), 32.293 (Proxy Function)]
- 2230: SP#64 completed. Align SA5 Charging specifications with Rel-8 Feature IMS Centralized Service control (ICSRA) and subsequent enhancements under TEIx (SA2 23.292 ICSRA Stage 2, CT3 29.292, CT1 24.607, 24.611) / Impacted TSs and TRs: 32.250, 32.298
- 2231: Dep. IETF ECRIT on PSAP call back. Fulfill SA1/2 Rel-7 EMC1 reqs UID_32045 PS domain and IMS impacts for supporting IMS Emergency calls (related to BB UID_1653 Emergency Call Enhancements for IP& PS Based Calls / Impacted TSs and TRs: Stage 3
- 2232: CP#64 completed. 2/4/15: acronym changed to EMC_PC / Impacted TSs and TRs: 24.229, tied to completion of IETF dependencies: 24.604, 24.605, 24.610, 24.611, 24.629
- 2233: CP#64 completed. 2/4/15: acronym changed to EMC_PC / Impacted TSs and TRs: RFC 7090 (was draft-ietf-ecrit-psap-callback
- 2234: CP#61 completed. 2/4/15: acronym changed to EMC_PC / Impacted TSs and TRs: 29.163, 29.165
- 2235: CP#64 completed. 2/4/15: acronym changed to EMC_PC / Impacted TSs and TRs: RFC 7090 (was draft-ietf-ecrit-psap-callback)
- 2236: CP#61 completed. Linked to Rel-8 Feature SAES in CP-150System Architecture Evolution specification - Evolved Packet System (non RAN aspects) UID_320005 / Impacted TSs and TRs: 29.061
- 2237: Stage 1 for Cell Broadcast does not exist. This WID enhances the reporting capabilities of Warning Message Delivery. Introduce LTE functionality requested by regulators, equivalent to existing 2G/3G functionality. / Impacted TSs and TRs: Stage 2/3
- 2238: CP#63 completed / Impacted TSs and TRs: 23.041
- 2239: CP#64 completed / Impacted TSs and TRs: 23.007, 29.168

| ID | WBS | Task | Duration | Start | Finish | Complete | Remaining | Baseline start | Baseline finish | Baseline duration | Total slack | Constraint | Resources | Work | Actual work | Acronym | PCG approved | WI rapporteur name | Release | TSG approved | MCC resp | Special Focus Doc | Acronym_3GU_Export | Status Report |
| --- | --- | --- | --- | --- | --- | --- | --- | --- | --- | --- | --- | --- | --- | --- | --- | --- | --- | --- | --- | --- | --- | --- | --- | --- |
| 2240 | 652.3 | **Public Warning System - Reset/Failure/Restart in Warning Message Delivery in LTE** | 340d? | 2013-03-04 A | 2014-06-13 A | 100% |  | 2013-03-04 | 2014-06-13 | 340d? |  |  | R3 | 5424h | 5424h | REP_WMD-RFR_PWS | 30 | one2many, Huawei | Rel-12 | 59 | Juha | Public Safety (I-A) | REP_WMD-RFR_PWS |  |
| 2241 | 652.3.1 | Core part: PWS - Reset/Failure/Restart in Warning Message Delivery in LTE | 338d? | 2013-03-04 A | 2014-06-13 A | 100% |  | 2013-03-04 | 2014-06-13 | 338d? |  | finish no earlier than 2014-06-13 | R3 | 2704h | 2704h | REP_WMD-RFR_PWS-Core | 30 | one2many, Huawei | Rel-12 | 59 | Juha | Public Safety (I-A) | REP_WMD-RFR_PWS-Core | RP-140637 |
| 2242 | 653 | **Single Radio Voice Call Continuity (SRVCC) before ringing (Stage 3)** | 331d? | 2012-12-07 A | 2014-03-06 A | 100% |  | 2012-12-07 | 2014-03-06 | 331d? |  |  | C1; C3; R5 | 9584h | 9584h | bSRVCC | 30 | NTT DOCOMO | Rel-12 | 58 | Frederic |  | bSRVCC |  |
| 2243 | 653.1 | CT1 part of Single Radio Voice Call Continuity (SRVCC) before ringing | 138d? | 2012-12-07 A | 2013-06-14 A | 100% |  | 2012-12-07 | 2013-06-14 | 138d? |  | finish no earlier than 2013-06-14 | C1 | 1096h | 1096h | bSRVCC | 30 | NTT DOCOMO | Rel-12 | 58 | Frederic |  |  |  |
| 2244 | 653.2 | CT3 part of Single Radio Voice Call Continuity (SRVCC) before ringing | 3d? | 2013-06-12 A | 2013-06-14 A | 100% |  | 2013-06-12 | 2013-06-14 | 3d? |  | finish no earlier than 2013-06-14 | C3 | 24h | 24h | bSRVCC | 31 | NTT DOCOMO | Rel-12 | 60 | Adrian |  |  |  |
| 2245 | 653.3 | Test part: Single Radio Voice Call Continuity (SRVCC) before ringing | 65d? | 2013-12-06 A | 2014-03-06 A | 100% |  | 2013-12-06 | 2014-03-06 | 65d? |  | finish no earlier than 2014-03-06 | R5 | 520h | 520h | bSRVCC-UEConTest | 32 | NTT DOCOMO | Rel-12 | 62 | Ingbert |  | bSRVCC-UEConTest | RP-140422 |
| 2246 | 654 | **IMS Stage 3 IETF Protocol Alignment - phase 6** | 532d? | 2012-12-07 A | 2014-12-09 | 97% | 17.95d? | 2012-12-07 | 2014-12-05 | 527d? | 1440d |  | C1; C3; IETF | 20640.6h | 17961.5h | IMSProtoc6 | 30 | Alcatel-Lucent | Rel-12 | 58 | Frederic |  | IMSProtoc6 |  |
| 2247 | 654.1 | CT1 part of IMS Stage 3 IETF Protocol Alignment - phase 6 | 464d? | 2012-12-07 A | 2014-09-11 A | 100% |  | 2012-12-07 | 2014-09-12 | 464d? |  | finish no earlier than 2014-09-12 | C1 | 3712h | 3712h | IMSProtoc6 | 30 | Alcatel-Lucent | Rel-12 | 58 | Frederic |  |  |  |
| 2248 | 654.2 | (IETF) CT1 part of IMS Stage 3 IETF Protocol Alignment - phase 6 (holmberg-sipcore-received-realm) | 410d? | 2013-05-21 A | 2014-12-09 A | 100% |  | 2013-05-21 | 2014-12-05 | 408d? |  | finish no earlier than 2014-12-09 | C1-IETF | 3256.25h | 3256.25h | IMSProtoc6 | 31 | christer.holmberg@ericsson.com | Rel-12 | 60 | Frederic |  |  |  |
| 2249 | 654.3 | (IETF) CT1 part of IMS Stage 3 IETF Protocol Alignment - phase 6 (allen-sipcore-sip-tree-cap-indicators) | 63d? | 2014-09-12 A | 2014-12-09 | 25% | 47.25d? |  |  |  | 1440d | finish no earlier than 2014-12-09 | C1-IETF | 504h | 126h | IMSProtoc6 | 33 | christer.holmberg@ericsson.com | Rel-12 | 65 |  |  |  |  |
| 2250 | 654.4 | (IETF) CT1 part of IMS Stage 3 IETF Protocol Alignment - phase 6 (draft-ietf-insipid-session-id) | 65d? | 2014-09-12 A | 2014-12-09 A | 100% |  |  |  |  |  | start no earlier than 2014-09-12 | C1-IETF | 520h | 520h | IMSProtoc6 | 34 | christer.holmberg@ericsson.com | Rel-12 | 65 |  |  |  |  |
| 2251 | 654.5 | CT3 part of IMS Stage 3 IETF Protocol Alignment - phase 6 | 71d? | 2014-06-06 A | 2014-09-11 A | 100% |  | 2014-06-06 | 2014-09-12 | 71d? |  | finish no earlier than 2014-09-12 | C3 | 568h | 568h | IMSProtoc6 | 30 | Alcatel-Lucent | Rel-12 | 58 | Adrian |  |  |  |
| 2252 | 654.6 | (IETF) CT3 part of IMS Stage 3 IETF Protocol Alignment - phase 6 (holmberg-sipcore-received-realm) | 327d? | 2013-09-06 A | 2014-12-05 A | 100% |  | 2013-09-06 | 2014-12-05 | 327d? |  | finish no earlier than 2014-12-05 | C3-IETF | 2608h | 2608h | IMSProtoc6 | 31 | christer.holmberg@ericsson.com | Rel-12 | 61 |  |  |  |  |
| 2253 | 655 | **SAE Protocol Development - Phase 3** | 467d? | 2012-12-07 A | 2014-09-11 A | 100% |  | 2012-12-07 | 2014-09-12 | 467d? |  |  | C1 | 14920h | 14920h | SAES3 | 30 | InterDigital | Rel-12 | 58 | Frederic |  | SAES3 |  |
| 2254 | 655.1 | SAE Protocol Development (Stage 3) - Phase 3 | 466d? | 2012-12-07 A | 2014-09-11 A | 100% |  | 2012-12-07 | 2014-09-12 | 466d? |  | finish no earlier than 2014-09-12 | C1 | 3728h | 3728h | SAES3-CT1 | 30 | InterDigital | Rel-12 | 58 | Frederic |  |  |  |
| 2255 | 655.2 | CS Fallback in EPS - Phase 3 | 466d? | 2012-12-07 A | 2014-09-11 A | 100% |  | 2012-12-07 | 2014-09-12 | 466d? |  | finish no earlier than 2014-09-12 | C1 | 3728h | 3728h | SAES3-CSFB | 30 | InterDigital | Rel-12 | 58 | Frederic |  | SAES3-CSFB |  |
| 2256 | 655.3 | SAE for support for non-3GPP accesses - Phase 3 | 466d? | 2012-12-07 A | 2014-09-11 A | 100% |  | 2012-12-07 | 2014-09-12 | 466d? |  | finish no earlier than 2014-09-12 | C1 | 3728h | 3728h | SAES3-non3GPP | 30 | InterDigital | Rel-12 | 58 | Frederic |  | SAES3-non3GPP |  |
| 2257 | 656 | **IM-SSF Application Server Service Data Descriptions (Stage 2/3)** | 138d? | 2012-12-07 A | 2013-06-14 A | 100% |  | 2012-12-07 | 2013-06-14 | 138d? |  |  | C4; C1 | 3780h | 3780h | IMS_SSFDD | 30 | Huawei | Rel-12 | 58 | Kimmo |  | IMS_SSFDD |  |
| 2258 | 656.1 | Stage 2 for IM-SSF Application Server Service Data Descriptions | 62d? | 2012-12-07 A | 2013-03-01 A | 100% |  | 2012-12-07 | 2013-03-01 | 62d? |  | finish no earlier than 2013-06-14 | C1 | 488h | 488h | IMS_SSFDD | 30 | Huawei | Rel-12 | 58 | Frederic |  |  |  |
| 2259 | 656.2 | Stage 3 for IM-SSF Application Server Service Data Descriptions | 136.5d? | 2012-12-10 A | 2013-06-14 A | 100% |  | 2012-12-10 | 2013-06-14 | 136.5d? |  | finish no earlier than 2013-06-14 | C4 | 1084h | 1084h | IMS_SSFDD | 30 | Huawei | Rel-12 | 58 | Kimmo |  |  |  |
| 2260 | 657 | **Diameter based interface between SGSN and SMS central functions (Stage 2/3)** | 265d? | 2012-12-10 A | 2013-12-06 A | 100% |  | 2012-12-10 | 2013-12-06 | 265d? |  |  | C4; C1 | 7952h | 7952h | Dia_SGSN_SMS | 30 | Alcatel-Lucent | Rel-12 | 58 | Kimmo |  | Dia_SGSN_SMS |  |
| 2261 | 657.1 | Stage 2 for Diameter based interface between SGSN and SMS central functions | 201d? | 2013-03-07 A | 2013-12-06 A | 100% |  | 2013-03-07 | 2013-12-06 | 201d? |  | finish no earlier than 2013-12-06 | C1 | 1608h | 1608h | Dia_SGSN_SMS | 30 | Alcatel-Lucent | Rel-12 | 59 | Frederic |  |  |  |
| 2262 | 657.2 | Stage 3 for Diameter based interface between SGSN and SMS central functions | 265d? | 2012-12-10 A | 2013-12-06 A | 100% |  | 2012-12-10 | 2013-12-06 | 265d? |  | finish no earlier than 2013-12-06 | C4 | 2104h | 2104h | Dia_SGSN_SMS | 30 | Alcatel-Lucent | Rel-12 | 58 | Kimmo |  |  |  |
| 2263 | 658 | Diameter based interface between SGSN-GMLC (Stage 3) | 265d? | 2012-12-10 A | 2013-12-06 A | 100% |  | 2012-12-10 | 2013-12-06 | 265d? |  | finish no earlier than 2013-12-06 | C4 | 2096h | 2096h | Dia_SGSN_GMLC | 30 | Cisco | Rel-12 | 58 | Kimmo |  | Dia_SGSN_GMLC |  |
| 2264 | 659 | IMS impacts on UICC Application Aspects (Stage 3) | 465d? | 2013-03-04 A | 2014-12-09 A | 100% |  | 2013-03-04 | 2014-09-12 | 403d? |  | finish no earlier than 2014-12-09 | C6 | 3720h | 3720h | IMS_UApAs | 30 | Giesecke & Devrient | Rel-12 | 59 | Xavier |  | IMS_UApAs | CP-140696 |

Notes:
- 2240: - / Impacted TSs and TRs: LTE / WI rapporteur e-mail: peter.sanders@one2many.eu, Dai Mingzeng (daimingzeng@huawei.com)
- 2241: RP#64 completed / Impacted TSs and TRs: 36.413 / WI rapporteur e-mail: peter.sanders@one2many.eu, Dai Mingzeng (daimingzeng@huawei.com)
- 2242: Linked to Rel-8 Feature IMS Service Continuity (IMS-Cont) UID_390056. TS 23.237 Rel-12 CR#0444 under TEI12 / Impacted TSs and TRs: GERAN, UTRA, LTE / WI rapporteur e-mail: keisuke.sasada.kx@nttdocomo.com
- 2243: CP#60 completed. 2/4/15: acronym changed to bSRVCC / Impacted TSs and TRs: 24.008, 24.237 / WI rapporteur e-mail: keisuke.sasada.kx@nttdocomo.com
- 2244: CP#60 completedbSRVCC / Impacted TSs and TRs: 29.165 / WI rapporteur e-mail: keisuke.sasada.kx@nttdocomo.com
- 2245: RP#63 completed. Testing for CT1 TS 24.237 (IMS service continuity Stage 3) / Impacted TSs and TRs: 34.229-1, 34.229-2, 36.523-1, 36.523-2 / WI rapporteur e-mail: Masahiro.Tamaoki.eu@nttdocomo.com
- 2246: - / Impacted TSs and TRs: Stage 3 / WI rapporteur e-mail: keith.drage@alcatel-lucent.com
- 2247: CP#65 completed. 4/2/15: acronym changed to IMSProtoc6 / Impacted TSs and TRs: 23.218, 24.229, 24.930 / WI rapporteur e-mail: keith.drage@alcatel-lucent.com
- 2248: Not completed internet-draft. 4/2/15: acronym changed to IMSProtoc6; 21/3/17: 50%->100 / Impacted TSs and TRs: draft-holmberg-sipcore-received-realm / WI rapporteur e-mail: christer.holmberg@ericsson.com
- 2249: Not completed internet-draft. 4/2/15: acronym changed to IMSProtoc6 / Impacted TSs and TRs: draft-allen-sipcore-sip-tree-cap-indicators / WI rapporteur e-mail: christer.holmberg@ericsson.com
- 2250: work in progress. 4/2/15: acronym changed to IMSProtoc6; 21/3/17: 25%->100 / Impacted TSs and TRs: draft-ietf-insipid-session-id
- 2251: CP#65 completed. 4/2/15: acronym changed to IMSProtoc6 / Impacted TSs and TRs: 29.163, 29.165 / WI rapporteur e-mail: keith.drage@alcatel-lucent.com
- 2252: Not completed internet-draft. 4/2/15: acronym changed to IMSProtoc6; 21/3/17: 50%->100 / Impacted TSs and TRs: draft-holmberg-sipcore-received-realm / WI rapporteur e-mail: christer.holmberg@ericsson.com
- 2253: Stage 3 continuation of Rel-8 Feature SAES (3GPP System Architecture Evolution Specification - Evolved Packet System) UID_320005 / Impacted TSs and TRs: Stage 2/3 / WI rapporteur e-mail: behrouz.aghili@interdigital.com
- 2254: CP#65 completed / Impacted TSs and TRs: 23.122, 24.008, 24.167, 24.229, 24.301, 24.302, 24.303, 24.304, 24.305, 24.312, 29.018, 29.118 / WI rapporteur e-mail: behrouz.aghili@interdigital.com
- 2255: CP#65 completed / Impacted TSs and TRs: 23.122, 24.008, 24.167, 24.229, 24.301, 24.302, 24.303, 24.304, 24.305, 24.312, 29.018, 29.118 / WI rapporteur e-mail: behrouz.aghili@interdigital.com
- 2256: CP#65 completed / Impacted TSs and TRs: 23.122, 24.008, 24.167, 24.229, 24.301, 24.302, 24.303, 24.304, 24.305, 24.312, 29.018, 29.118 / WI rapporteur e-mail: behrouz.aghili@interdigital.com
- 2257: CP#60 completed / Impacted TSs and TRs: Stage 2/3 / WI rapporteur e-mail: susan.shishufeng@huawei.com
- 2258: CP#59 completed / Impacted TSs and TRs: 23.218 / WI rapporteur e-mail: susan.shishufeng@huawei.com
- 2259: CP#60 completed / Impacted TSs and TRs: 29.328, 29.329, 29.364 / WI rapporteur e-mail: susan.shishufeng@huawei.com
- 2260: CP#62 completed / Impacted TSs and TRs: Stage 2/3 / WI rapporteur e-mail: jean-jacques.trottin@alcatel-lucent.com
- 2261: CP#62 completed / Impacted TSs and TRs: 23.040 / WI rapporteur e-mail: jean-jacques.trottin@alcatel-lucent.com
- 2262: CP#62 completed / Impacted TSs and TRs: 29.002, 29.230, 29.272, 29.305, 29.336, 29.337, 29.338 / WI rapporteur e-mail: jean-jacques.trottin@alcatel-lucent.com
- 2263: CP#62 completed. Updated WID CP-130273=>CP-130598. No Stage 2 impact. Define a Diameter variant for the protocol used over existing reference points between SGSN and GMLC for LCS (replace the use of MAP by Diameter protocol) / Impacted TSs and TRs: 29.002, 29.172, 29.173, 29.230, 29.272 / WI rapporteur e-mail: Nirav Salot (nsalot@cisco.com)
- 2264: CP#65 completion 09/14=>12/14. Exception in CP-140696. Dec.14: 85->100% / Impacted TSs and TRs: 31.102, 31.103, 31.111, 31.130 / WI rapporteur e-mail: sergi.espi@gi-de.com

| ID | WBS | Task | Duration | Start | Finish | Complete | Baseline start | Baseline finish | Baseline duration | Constraint | Resources | Work | Actual work | Acronym | PCG approved | Impacted TSs and TRs | WI rapporteur name | WI rapporteur e-mail | Release | TSG approved | MCC resp | Acronym_3GU_Export | Status Report |
| --- | --- | --- | --- | --- | --- | --- | --- | --- | --- | --- | --- | --- | --- | --- | --- | --- | --- | --- | --- | --- | --- | --- | --- |
| 2265 | 660 | **eMBMS restoration procedures** | 406d? | 2013-03-01 A | 2014-09-11 A | 100% | 2013-03-01 | 2014-06-13 | 341d? |  | C4; C3 | 10272h | 10272h | eMBMS_Rest | 30 | Stage 3 | Alcatel-Lucent | bruno.landais@alcatel-lucent.com | Rel-12 | 59 | Kimmo | eMBMS_Rest |  |
| 2266 | 660.1 | CT4 part of eMBMS restoration procedures | 205d? | 2013-03-01 A | 2013-12-06 A | 100% | 2013-03-01 | 2013-12-06 | 205d? | finish no earlier than 2013-12-06 | C4 | 1616h | 1616h | eMBMS_Rest | 30 | 23.007, 23.008, 29.274 | Alcatel-Lucent | bruno.landais@alcatel-lucent.com | Rel-12 | 59 | Kimmo |  |  |
| 2267 | 660.2 | CT3 part of eMBMS restoration procedures | 270d? | 2013-09-04 A | 2014-09-11 A | 100% | 2013-09-04 | 2014-06-13 | 205d? | finish no earlier than 2014-09-12 | C3 | 2160h | 2160h | eMBMS_Rest | 31 | 29.061 | Alcatel-Lucent | bruno.landais@alcatel-lucent.com | Rel-12 | 61 | Kimmo |  |  |
| 2268 | 661 | **Dual Radio VCC enhancements (Stage 2/3)** | 325d? | 2012-09-19 A | 2013-12-06 A | 100% | 2012-09-19 | 2013-12-06 | 325d? |  | C1; C3.S2 | 10866.2h | 10866.2h | eDRVCC | 30 | Stage 2/3 | Ericsson | Jan.Holm@ericsson.com | Rel-12 | 59 | Maurice | eDRVCC |  |
| 2269 | 661.1 | Stage 2 for Dual Radio VCC enhancements | 57.55d? | 2012-09-19 A | 2013-03-01 A | 100% | 2012-09-19 | 2013-03-01 | 57.55d? | finish no earlier than 2013-03-01 | S2 | 460.4h | 460.4h | eDRVCC | 30 | 23.237 | Ericsson | Jan.Holm@ericsson.com | Rel-12 | 59 | Maurice |  |  |
| 2270 | 661.2 | **Stage 3 for Dual Radio VCC enhancements** | 205d? | 2013-03-01 A | 2013-12-06 A | 100% | 2013-03-01 | 2013-12-06 | 205d? |  | C1; C3 | 5205.8h | 5205.8h | eDRVCC | 30 | Stage 3 | Ericsson | Jan.Holm@ericsson.com | Rel-12 | 59 | Frederic |  |  |
| 2271 | 661.2.1 | CT1 part of Stage 3 for Dual Radio VCC enhancements | 205d? | 2013-03-01 A | 2013-12-06 A | 100% | 2013-03-01 | 2013-12-06 | 205d? | finish no earlier than 2013-12-06 | C1 | 1608h | 1608h | eDRVCC | 30 | 24.237, 24.292 | Ericsson | Jan.Holm@ericsson.com | Rel-12 | 59 | Frederic |  |  |
| 2272 | 661.2.2 | CT3 part of Stage 3 for Dual Radio VCC enhancements | 41.7d? | 2013-03-01 A | 2013-09-06 A | 100% | 2013-03-01 | 2013-09-06 | 41.7d? | finish no earlier than 2013-09-06 | C3 | 317.8h | 317.8h | eDRVCC | 30 | 29.165 | Ericsson | Jan.Holm@ericsson.com | Rel-12 | 59 | Adrian |  |  |
| 2273 | 662 | **CT aspects of Signalling of Image Size (Stage 2/3)** | 129d? | 2013-06-14 A | 2013-12-06 A | 100% | 2013-06-14 | 2013-12-06 | 129d? |  | C4; C1; C3 | 6136.8h | 6136.8h | SIS_CT | 31 | Stage 2/3 | Ericsson | nevenka.biondic@ericsson.com | Rel-12 | 60 | Kimmo | SIS_CT |  |
| 2274 | 662.1 | CT4 part of Signalling of Image Size | 128.05d? | 2013-06-14 A | 2013-12-06 A | 100% | 2013-06-14 | 2013-12-06 | 128.05d? | finish no earlier than 2013-12-06 | C4 | 1008.4h | 1008.4h | SIS_CT | 31 | 23.333, 23.334, 29.238, 29.332, 29.333, 29.334 | Ericsson | nevenka.biondic@ericsson.com | Rel-12 | 60 | Kimmo |  |  |
| 2275 | 662.2 | CT1 part of CT Aspects of Signalling of Image Size | 129d? | 2013-06-14 A | 2013-12-06 A | 100% | 2013-06-14 | 2013-12-06 | 129d? | finish no earlier than 2013-12-06 | C1 | 1016h | 1016h | SIS_CT | 31 | 24.229 | Ericsson | nevenka.biondic@ericsson.com | Rel-12 | 60 | Frederic |  |  |
| 2276 | 662.3 | CT3 part of CT Aspects of Signalling of Image Size | 128.05d? | 2013-06-14 A | 2013-12-06 A | 100% | 2013-06-14 | 2013-12-06 | 128.05d? | finish no earlier than 2013-12-06 | C3 | 1016.4h | 1016.4h | SIS_CT | 31 | 29.162, 29.163 | Ericsson | nevenka.biondic@ericsson.com | Rel-12 | 60 | Adrian |  |  |
| 2277 | 663 | IMS Centralized Services (ICS) InterWorking Enhancement in Mobile Switching Center Server (MSC-S) | 129d? | 2013-06-14 A | 2013-12-06 A | 100% | 2013-06-14 | 2013-12-06 | 129d? | finish no earlier than 2013-12-06 | C3 | 1008h | 1008h | ICS_IWE | 31 | 29.292 | Orange | marianne.mohali@orange.com | Rel-12 | 60 | Adrian | ICS_IWE |  |
| 2278 | 664 | GPRS Tunnelling Protocol for the Control plane (GTP-C) Overload Control Mechanisms | 267d? | 2013-09-06 A | 2014-09-11 A | 100% | 2013-09-06 | 2014-09-12 | 267d? | finish no earlier than 2014-09-12 | C4 | 2136h | 2136h | GOCMe | 31 | 23.008, 29.230, 29.273, 29.274, 29.303, New TR 29.807 | Cisco | Nirav Salot (nsalot@cisco.com) | Rel-12 | 61 | Kimmo | GOCMe |  |
| 2279 | 665 | **Proxy Call Session Control Function (P-CSCF) restoration enhancements (Stage 2/3)** | 447.1d? | 2013-04-03 A | 2014-12-09 A | 100% | 2013-04-03 | 2014-12-05 | 442.1d? |  | C4; C3; C1 | 54903.2h | 54903.2h | PCSCF_RES | 31 | Stage 2/3 | Ericsson | maria.cruz.bartolome@ericsson.com | Rel-12 | 61 | Kimmo | PCSCF_RES |  |
| 2280 | 665.1 | TR on Proxy Call Session Control Function (P-CSCF) restoration enhancements | 266d? | 2013-09-06 A | 2014-09-11 A | 100% | 2013-09-06 | 2014-09-12 | 266d? | finish no earlier than 2014-09-12 | C4 | 2128h | 2128h | PCSCF_RES | 31 | New TR 29.806 | Ericsson | maria.cruz.bartolome@ericsson.com | Rel-12 | 61 | Kimmo |  |  |
| 2281 | 665.2 | **Common for HSS & PCRF solutions** | 447.1d? | 2013-04-03 A | 2014-12-09 A | 100% |  |  |  |  | C4; C3; C1 | 18602.4h | 18602.4h | PCSCF_RES | 33 |  | Ericsson | maria.cruz.bartolome@ericsson.com | Rel-12 | 64 |  |  |  |
| 2282 | 665.2.1 | CT4 part of Common for HSS & PCRF solutions | 328d? | 2013-09-06 A | 2014-12-09 A | 100% | 2013-09-06 | 2014-12-05 | 326d? | finish no earlier than 2014-12-09 | C4 | 2624h | 2624h | PCSCF_RES | 31 | 23.380, 29.060, 29.274 | Ericsson | maria.cruz.bartolome@ericsson.com | Rel-12 | 61 | Kimmo |  | CP-140481 |
| 2283 | 665.2.2 | CT1 part of Common for HSS & PCRF solutions | 328d? | 2013-04-03 A | 2014-12-05 A | 100% | 2013-04-03 | 2014-12-05 | 326d? | finish no earlier than 2014-12-09 | C1 | 2624h | 2624h | PCSCF_RES | 33 | 24.008 | Ericsson | maria.cruz.bartolome@ericsson.com | Rel-12 | 64 | Kimmo |  |  |
| 2284 | 665.2.3 | CT3 part of Common for HSS & PCRF solutions | 328d? | 2013-05-03 A | 2014-12-09 A | 100% | 2013-05-03 | 2014-12-05 | 326d? | finish no earlier than 2014-12-09 | C3 | 2624h | 2624h | PCSCF_RES | 33 | 29.061, 29.165 | Huawei | susan.shishufeng@huawei.com | Rel-12 | 65 | Kimmo |  | CP-140687 |
| 2285 | 665.3 | **HSS based solution** | 447.1d? | 2013-04-03 A | 2014-12-09 A | 100% |  |  |  |  | C4; C1 | 12401.6h | 12401.6h | PCSCF_RES | 33 |  | Ericsson | maria.cruz.bartolome@ericsson.com | Rel-12 | 64 |  |  |  |
| 2286 | 665.3.1 | CT4 part of HSS based solution | 328d? | 2013-09-06 A | 2014-12-09 A | 100% | 2013-09-06 | 2014-12-05 | 326d? | finish no earlier than 2014-12-09 | C4 | 2624h | 2624h | PCSCF_RES | 31 | 29.002, 29.228, 29.229, 29.272, 29.305 | Ericsson | maria.cruz.bartolome@ericsson.com | Rel-12 | 61 | Kimmo |  | CP-140481 |
| 2287 | 665.3.2 | CT1 part of HSS based solution | 328d? | 2013-04-03 A | 2014-12-09 A | 100% | 2013-04-03 | 2014-12-05 | 326d? | finish no earlier than 2014-12-09 | C1 | 2624h | 2624h | PCSCF_RES | 33 | 24.229 | Ericsson | maria.cruz.bartolome@ericsson.com | Rel-12 | 64 | Kimmo |  | CP-140605 |
| 2288 | 665.4 | **PCRF based solution** | 447.1d? | 2013-04-03 A | 2014-12-09 A | 100% |  |  |  |  | C3; C1 | 12401.6h | 12401.6h | PCSCF_RES | 33 |  | Huawei | susan.shishufeng@huawei.com | Rel-12 | 64 |  |  |  |
| 2289 | 665.4.1 | CT3 part of PCRF based solution | 328d? | 2013-05-03 A | 2014-12-09 A | 100% | 2013-05-03 | 2014-12-05 | 326d? | finish no earlier than 2014-12-09 | C3 | 2624h | 2624h | PCSCF_RES | 33 | 29.212, 29.213, 29.214, 29.215 | Huawei | susan.shishufeng@huawei.com | Rel-12 | 64 | Kimmo |  | CP-140687 |
| 2290 | 665.4.2 | CT1 part of PCRF based solution | 328d? | 2013-04-03 A | 2014-12-09 A | 100% | 2013-04-03 | 2014-12-05 | 326d? | finish no earlier than 2014-12-09 | C1 | 2624h | 2624h | PCSCF_RES | 33 | 24.229 | Huawei | susan.shishufeng@huawei.com | Rel-12 | 64 | Kimmo |  | CP-140605 |

Notes:
- 2265: CP#62 completed. Linked to Rel-9 MBMS support in EPS (MBMS_EPS). Rel-10 CT Features EPC Node Restoration with/out Idle mode Signalling Reduction (ISR) activated (EPC_NR/EPC_NR_ISR)
- 2266: CP#62 completed
- 2267: CP#65 completed
- 2268: CP#62 completed. Stage 2 in Rel-12 TEI12 TS 23.237 CR#0431, CR#0440, CR#0441, CR#0453 (pre-alerting). Stage 3 linked to Rel-8 Feature IMS Service Continuity (IMS-Cont) UID_390056 (Stage 2 in TS 23.237). 2/4/15: acronym changed to eDRVCC
- 2269: Stage 2 in Rel-12 TEI12 TS 23.237 CR#0431, CR#0440, CR#0441, CR#0453 (pre-alerting). 2/4/15: acronym changed to eDRVCC
- 2270: CP#62 completed
- 2271: CP#62 completed. 2/4/15: acronym changed to eDRVCC
- 2272: CP#61 completed. 2/4/15: acronym changed to eDRVCC
- 2273: CP#62 completed. SA4 Rel-8 MTSI Video: Dynamic Rate Adaptation/Signalling of Image Size UID_34041 has included service aspects to support image attribute (a=imageattr) in TS 26.114 as in RFC 6236. But associated CN aspects were not included
- 2274: CP#62 completed
- 2275: CP#62 completed
- 2276: CP#62 completed
- 2277: CP#62 completed. Stage 3 enhancement interworking between IMS and MSC-S for IMS Centralized Services (ICS)
- 2278: CP#65 completed. Updated WID CP-130433=>CP-140488
- 2279: CP#65 updated WID CP-140443=>CP-140490. Based TR 29.806, solutions B and D are selected for standardization. Dec.14: 95->100
- 2280: CP#65 completed. TR 29.806v200 for Approval
- 2281: -
- 2282: CP#65 completion 09/14=>12/14. Exception in CP-140481. Dec.14: 90->100
- 2283: CP#65 completed
- 2284: CP#65 updated WID CP-140443=>CP-140490 (added CT3 part). Exception in CP-140687
- 2285: -
- 2286: CP#65 completion 09/14=>12/14. Exception in CP-140481. Dec.14: 90->100
- 2287: CP#65 completion 09/14=>12/14. Exception in CP-140605. Dec.14: 65->100%
- 2288: -
- 2289: CP#65 updated WID CP-140443=>CP-140490 (added CT3 part). Exception in CP-140687
- 2290: CP#65 completion 09/14=>12/14. Exception in CP-140605. Dec.14: 65->100

| ID | WBS | Task | Duration | Start | Finish | Complete | Baseline start | Baseline finish | Baseline duration | Constraint | Resources | Work | Actual work | Acronym | PCG approved | WI rapporteur name | WI rapporteur e-mail | Release | TSG approved | MCC resp | Acronym_3GU_Export | Status Report |
| --- | --- | --- | --- | --- | --- | --- | --- | --- | --- | --- | --- | --- | --- | --- | --- | --- | --- | --- | --- | --- | --- | --- |
| 2291 | 666 | **Updating IMS to conform to RFC 6665 (Stage 3)** | 400d? | 2013-09-09 A | 2015-03-13 A | 100% | 2013-09-09 | 2014-09-12 | 267d? |  | C1; C3 | 9576h | 9576h | UP6665 | 31 | BlackBerry | Andrew Allen (aallen@blackberry.com) | Rel-12 | 61 | Frederic | UP6665 |  |
| 2292 | 666.1 | CT1 part of Updating IMS to conform to RFC 6665 | 329d? | 2013-09-09 A | 2014-12-09 A | 100% | 2013-09-09 | 2014-09-12 | 267d? | finish no earlier than 2014-12-09 | C1 | 2624h | 2624h | UP6665 | 31 | BlackBerry | Andrew Allen (aallen@blackberry.com) | Rel-12 | 61 | Frederic |  | CP-140620 |
| 2293 | 666.2 | CT3 part of Updating IMS to conform to RFC 6665 | 66d? | 2013-09-09 A | 2013-12-06 A | 100% | 2013-09-09 | 2013-12-06 | 66d? | finish no earlier than 2013-12-06 | C3 | 528h | 528h | UP6665 | 31 | BlackBerry | Andrew Allen (aallen@blackberry.com) | Rel-12 | 61 | Maurice |  |  |
| 2294 | 666.3 | (IETF) CT1 part of Updating IMS to conform to RFC 6665 (draft-ietf-sipcore-refer-clarifications) | 1d? | 2015-03-13 A | 2015-03-13 A | 100% |  |  |  |  | C1-IETF | 8h | 8h | UP6665 | 34 | BlackBerry | Andrew Allen (aallen@blackberry.com) | Rel-12 | 67 |  |  |  |
| 2295 | 666.4 | (IETF) CT1 part of Updating IMS to conform to RFC 6665 (draft-ietf-sipcore-refer-explicit-subscription) | 1d? | 2015-03-13 A | 2015-03-13 A | 100% |  |  |  |  | C1-IETF | 8h | 8h | UP6665 | 34 | BlackBerry | Andrew Allen (aallen@blackberry.com) | Rel-12 | 67 |  |  |  |
| 2296 | 666.5 | (IETF) CT1 part of Updating IMS to conform to RFC 6665 (draft-roach-sipcore-6665-clarifications) | 1d? | 2015-03-13 A | 2015-03-13 A | 100% |  |  |  |  | C1-IETF | 8h | 8h | UP6665 | 34 | BlackBerry | Andrew Allen (aallen@blackberry.com) | Rel-12 | 67 |  |  |  |
| 2297 | 667 | **IMS Operator Determined Call Barring enhancements (Stage 3)** | 202d? | 2013-12-06 A | 2014-09-11 A | 100% | 2013-12-06 | 2014-06-13 | 137d? |  | C1; C3 | 5928h | 5928h | eIODB | 32 | Ericsson | Jorgen.Axell@ericsson.com | Rel-12 | 62 | Frederic | eIODB |  |
| 2298 | 667.1 | CT1 part of IMS Operator Determined Call Barring enhancements | 136d? | 2013-12-06 A | 2014-06-13 A | 100% | 2013-12-06 | 2014-06-13 | 136d? | finish no earlier than 2014-06-13 | C1 | 1088h | 1088h | eIODB | 32 | Ericsson | Jorgen.Axell@ericsson.com | Rel-12 | 62 | Frederic |  |  |
| 2299 | 667.2 | CT3 part of IMS Operator Determined Call Barring enhancements | 201d? | 2013-12-09 A | 2014-09-11 A | 100% | 2013-12-09 | 2014-06-13 | 136d? | finish no earlier than 2014-09-12 | C3 | 1608h | 1608h | eIODB | 32 | Ericsson | Jorgen.Axell@ericsson.com | Rel-12 | 62 | Adrian |  |  |
| 2300 | 668 | Signalling Improvements for Network Efficiency (Stage 3) | 264d? | 2013-12-06 A | 2014-12-09 A | 100% | 2013-12-06 | 2014-09-12 | 202d? | finish no earlier than 2014-12-09 | C1 | 2112h | 2112h | SINE | 32 | Huawei | Lin Shu (shulin@huawei.com) | Rel-12 | 62 | Frederic | SINE | CP-140617 |
| 2301 | 669 | **Interactive Connectivity Establishment (ICE, IETF RFC 5245) impacts on IMS H.248 profiles** | 138d? | 2014-03-05 A | 2014-09-11 A | 100% | 2014-03-05 | 2014-09-12 | 138d? |  | C4; C3 | 3896h | 3896h | ICEH248 | 32 | NSN | Jan.Kall@nsn.com | Rel-12 | 63 | Kimmo | ICEH248 |  |
| 2302 | 669.1 | CT4 part of ICE impacts on IMS H.248 profiles (Stage 2/3) | 138d? | 2014-03-05 A | 2014-09-11 A | 100% | 2014-03-05 | 2014-09-12 | 138d? | finish no earlier than 2014-09-12 | C4 | 1104h | 1104h | ICEH248 | 32 | NSN | Jan.Kall@nsn.com | Rel-12 | 63 | Kimmo |  |  |
| 2303 | 669.2 | CT3 part of ICE impacts on IMS H.248 profiles (Stage 2) | 73d? | 2014-03-05 A | 2014-06-13 A | 100% | 2014-03-05 | 2014-06-13 | 73d? | finish no earlier than 2014-06-13 | C3 | 584h | 584h | ICEH248 | 32 | NSN | Jan.Kall@nsn.com | Rel-12 | 63 | Adrian |  |  |
| 2304 | 670 | **Transfer of ETSI business trunking specifications** | 203d? | 2014-03-05 A | 2014-12-09 A | 100% | 2014-03-05 | 2014-09-17 | 141d? |  | C1; S1 | 5976h | 5976h | IMS_Corp2 | 32 | Alcatel-Lucent | keith.drage@alcatel-lucent.com, Youssef Chadli | Rel-12 | 63 | Frederic | IMS_Corp2 |  |
| 2305 | 670.1 | SA1 part of Transfer of ETSI business trunking specifications | 141d? | 2014-03-05 A | 2014-09-17 A | 100% | 2014-03-05 | 2014-09-17 | 141d? | finish no earlier than 2014-09-17 | S1 | 1128h | 1128h | IMS_Corp2 | 32 | Alcatel-Lucent | betsy.covell@alcatel-lucent.com | Rel-12 | 63 | Alain |  | S1-143300 |
| 2306 | 670.2 | CT1 part of Transfer of ETSI business trunking specifications | 200d? | 2014-03-05 A | 2014-12-09 A | 100% | 2014-03-05 | 2014-09-12 | 138d? | finish no earlier than 2014-12-09 | C1 | 1600h | 1600h | IMS_Corp2 | 32 | Alcatel-Lucent | keith.drage@alcatel-lucent.com, Youssef Chadli | Rel-12 | 63 | Frederic |  | CP-140619 |
| 2307 | 671 | **Support of ALT-C attribute** | 200d? | 2014-03-10 A | 2014-12-09 A | 100% | 2014-03-05 | 2014-09-12 | 138d? |  | C4; C1; C3 | 9600h | 9600h | ALTC | 32 | Orange | lionel.morand@orange.com | Rel-12 | 63 | Kimmo | ALTC |  |
| 2308 | 671.1 | CT4 part of Support of ALT-C attribute | 200d? | 2014-03-10 A | 2014-12-09 A | 100% | 2014-03-05 | 2014-09-12 | 138d? | finish no earlier than 2014-12-09 | C4 | 1600h | 1600h | ALTC | 32 | Orange | lionel.morand@orange.com | Rel-12 | 63 | Kimmo |  | CP-140485 |
| 2309 | 671.2 | CT1 part of Support of ALT-C attribute | 200d? | 2014-03-10 A | 2014-12-09 A | 100% | 2014-03-05 | 2014-09-12 | 138d? | finish no earlier than 2014-12-09 | C1 | 1600h | 1600h | ALTC | 32 | Orange | lionel.morand@orange.com | Rel-12 | 63 | Frederic |  | CP-140611 |
| 2310 | 671.3 | CT3 part of Support of ALT-C attribute | 200d? | 2014-03-10 A | 2014-12-09 A | 100% | 2014-03-05 | 2014-06-13 | 73d? | finish no earlier than 2014-12-09 | C3 | 1600h | 1600h | ALTC | 32 | Orange | lionel.morand@orange.com | Rel-12 | 63 | Adrian |  | CP-140563 |
| 2311 | 672 | **Diameter Overload Control Mechanisms** | 131d? | 2014-06-13 A | 2014-12-09 A | 100% | 2014-06-13 | 2014-12-05 | 126d? |  | C4; IETF | 4144h | 4144h | DOCME | 33 | Orange | lionel.morand@orange.com | Rel-12 | 64 |  | DOCME |  |
| 2312 | 672.1 | CT4 part of Diameter Overload Control Mechanisms | 128d? | 2014-06-13 A | 2014-12-09 A | 100% | 2014-06-13 | 2014-09-12 | 66d? | finish no earlier than 2014-12-09 | C4 | 1024h | 1024h | DOCME | 33 | Orange | lionel.morand@orange.com | Rel-12 | 64 |  |  | CP-140486 |
| 2313 | 672.2 | (IETF) Diameter Overload Control Mechanisms | 128d? | 2014-06-13 A | 2014-12-09 A | 100% | 2014-06-13 | 2014-12-05 | 126d? | finish no earlier than 2014-12-09 | C4-IETF | 1024h | 1024h | DOCME | 33 | christer.holmberg@ericsson.com | christer.holmberg@ericsson.com | Rel-12 | 64 |  |  |  |
| 2314 | 673 | **Impacts of RFC7044 for introduction of the new History-Info header field** | 131d? | 2014-06-13 A | 2014-12-09 A | 100% | 2014-06-13 | 2014-09-12 | 66d? |  | C1; C3 | 3648h | 3648h | HISTORY_CT | 33 | Deutsche Telekom | Roland Jesske (r.jesske@telekom.de) | Rel-12 | 64 |  | HISTORY_CT |  |
| 2315 | 673.1 | CT1 part of Impacts of RFC7044 for introduction of the new History-Info header field | 128d? | 2014-06-13 A | 2014-12-09 A | 100% | 2014-06-13 | 2014-09-12 | 66d? | finish no earlier than 2014-12-09 | C1 | 1024h | 1024h | HISTORY_CT | 33 | Deutsche Telekom | Roland Jesske (r.jesske@telekom.de) | Rel-12 | 64 |  |  | CP-140609 |
| 2316 | 673.2 | CT3 part of Impacts of RFC7044 for introduction of the new History-Info header field | 66d? | 2014-06-13 A | 2014-09-11 A | 100% | 2014-06-13 | 2014-09-12 | 66d? | finish no earlier than 2014-09-12 | C3 | 528h | 528h | HISTORY_CT | 33 | Deutsche Telekom | Roland Jesske (r.jesske@telekom.de) | Rel-12 | 64 |  |  |  |

Notes:
- 2291: Stage 3. Review the references related to RFC 3265 in the 3GPP IMS specifications and determine the impact of the RFC 6665 changes / Impacted TSs and TRs: Stage 3
- 2292: CP#65 completion 09/14=>12/14. Exception in CP-140620. 3/3/15: 100% cpltd. / Impacted TSs and TRs: 23.218, 24.141, 24.147, 24.229, 24.237, 24.292, 24.337, 24.341, 24.604, 24.606, 24.623, 24.628, 24.629, 24.642
- 2293: CP#62 completed / Impacted TSs and TRs: 29.163, 29.165
- 2294: Added as per CT chair indications on 12th March 2015, no WID, no end date / Impacted TSs and TRs: draft-ietf-sipcore-refer-clarification
- 2295: Added as per CT chair indications on 12th March 2015, no WID, no end date; 14/09/15: 50%->100 / Impacted TSs and TRs: draft-ietf-sipcore-refer-explicit-subscription
- 2296: Added as per CT chair indications on 12th March 2015, no WID, no end date; 14/09/15: 50%->100 / Impacted TSs and TRs: draft-roach-sipcore-6665-clarification
- 2297: Handling of premium rate numbers remained OPEN in Rel-11 (shifted to Rel-12). CP-130384 LS_out sent to SA1 / GSMA informing this TSG CP#60 decision / Impacted TSs and TRs: Stage 3
- 2298: CP#64 completed / Impacted TSs and TRs: 24.229, 24.315
- 2299: CP#65 completed / Impacted TSs and TRs: 29.165
- 2300: CP#65 completion 09/14=>12/14. Exception in CP-140617.Dec.14: 80->85%. 3/3/15: 100% cpltd. / Impacted TSs and TRs: 24.008, 24.301
- 2301: Add optional ICE support as defined in Rel-8 TS (23.228, 24.229) to Iq, Ix, Mn, Mp, Mc interfaces. SA2 Rel-12 TS 23.228 requires support for ICE in eP-CSCF, eIMS-AGW for WebRTC / Impacted TSs and TRs: Stage 2/3
- 2302: CP#65 completed / Impacted TSs and TRs: 23.333, 23.334, 29.232, 29.238, 29.332, 29.333, 29.334
- 2303: CP#64 completed / Impacted TSs and TRs: 29.162, 29.163, 29.292
- 2304: Rel-12 enhancements to business trunking (BusTI). ETSI E2NA(14)000019 asked 3GPP to take responsibility of business communications over IMS: TS 181 019, TS 182 023, TS 182 024, TS 182 025, TR 183 060
- 2305: SP#65 completed. TS 22.519v200 for Approval / Impacted TSs and TRs: New TS 22.519 (ETSI TS 181 019)
- 2306: CP#65 TS 24.525v200 for Approval. TR 24.969v100 for Information. Completion 09/14=>12/14. Exception in CP-140619. Dec.14: 90->100 / Impacted TSs and TRs: New TSs [24.523 (TS 182 023), 24.524 (TS 182 024), 24.525 (TS 182 025)], New TR 24.969 (TR 183 069)
- 2307: SA2 TS 23.228 requires UEs supporting IPv4, IPv6 or both IPv4 and IPv6 IP address formats shall be supported by IMS. Specify procedures to support altc SDP attribute within IMS for terminating communications destined to an enterprise network.
- 2308: CP#65 completion 09/14=>12/14. Exception in CP-140485. Dec.14: 0->100 / Impacted TSs and TRs: 23.334, 29.238, 29.334
- 2309: CP#65 completion 09/14=>12/14. Exception in CP-140611. Dec.14: 0->100 / Impacted TSs and TRs: 24.229
- 2310: CP#65 completion 09/14=>12/14. Exception in CP-140563. Dec.14: 0->100 / Impacted TSs and TRs: 29.162
- 2311: Triggered by TR 29.809 Study on Diameter overload control mechanism (FS_DOCME)
- 2312: CP#65 completion 09/14=>12/14. Exception in CP-140486. Dec.14: 70->100 / Impacted TSs and TRs: 29.228, 29.229, 29.272, 29.273, 29.328, 29.329, 29.336, 29.337, 29.344, 29.345
- 2313: Mar15: In WGLC; 7/3/16: 50%->100 / Impacted TSs and TRs: draft-ietf-dime-ovli
- 2314: IETF updated RFC4244 for History-Info header field to RFC7044. IETF introduced new features which could be useful for 3GPP use cases.
- 2315: CP#65 completion 09/14=>12/14. Exception in CP-140609. Dec.14: 85->100 / Impacted TSs and TRs: 24.229, 24.259, 24.604
- 2316: CP#65 completed / Impacted TSs and TRs: 29.163, 29.165, 29.292

| ID | WBS | Task | Duration | Start | Finish | Complete | Remaining | Baseline start | Baseline finish | Baseline duration | Total slack | Constraint | Resources | Work | Actual work | Acronym | PCG approved | WI rapporteur name | Release | TSG approved | Acronym_3GU_Export | Status Report | MCC resp |
| --- | --- | --- | --- | --- | --- | --- | --- | --- | --- | --- | --- | --- | --- | --- | --- | --- | --- | --- | --- | --- | --- | --- | --- |
| 2317 | 674 | **Indication of NNI Routeing scenarios in SIP requests** | 131d? | 2014-06-13 A | 2014-12-09 A | 100% |  | 2014-06-13 | 2014-12-05 | 126d? |  |  | C1; C3; IETF | 5456h | 4408h | NNI_RS | 33 | Ericsson | Rel-12 | 64 | NNI_RS |  |  |
| 2318 | 674.1 | CT1 part of Indication of NNI Routeing scenarios in SIP requests | 128d? | 2014-06-13 A | 2014-12-09 A | 100% |  | 2014-06-13 | 2014-09-12 | 66d? |  | finish no earlier than 2014-12-09 | C1 | 1024h | 1024h | NNI_RS | 33 | Ericsson | Rel-12 | 64 |  | CP-140613 |  |
| 2319 | 674.2 | (IETF) CT1 part of Indication of NNI Routeing scenarios in SIP requests (holmberg-dispatch-iotl) | 95d? | 2014-06-13 A | 2014-12-09 A | 100% |  | 2014-06-13 | 2014-12-05 | 93d? |  | finish no earlier than 2014-12-09 | C1-IETF | 760h | 760h | NNI_RS | 33 | christer.holmberg@ericsson.com | Rel-12 | 64 |  |  |  |
| 2320 | 674.3 | CT3 part of Indication of NNI Routeing scenarios in SIP requests | 66d? | 2014-06-13 A | 2014-09-11 A | 100% |  | 2014-06-13 | 2014-09-12 | 66d? |  | finish no earlier than 2014-09-12 | C3 | 528h | 528h | NNI_RS | 33 | Ericsson | Rel-12 | 64 |  |  |  |
| 2321 | 675 | Unstructured Supplementary Service Data (USSD) method selection (Stage 3) | 3d? | 2014-06-11 A | 2014-06-13 A | 100% |  | 2014-06-11 | 2014-06-13 | 3d? |  | finish no earlier than 2014-06-13 | C1 | 24h | 24h | USSD_MS | 33 | Ericsson | Rel-12 | 64 | USSD_MS |  |  |
| 2322 | 676 | Representational State Transfer (REST) reference point between Application Function (AF) and Protocol Converter (PC) | 128d? | 2014-06-13 A | 2014-12-09 A | 100% |  | 2014-06-13 | 2014-09-12 | 66d? |  | finish no earlier than 2014-12-09 | C3 | 1024h | 1024h | REST_AF_PC | 33 | Alcatel-Lucent | Rel-12 | 64 | REST_AF_PC | CP-140561 |  |
| 2323 | 677 | **Overload Control for PCC based Diameter applications** | 131d? | 2014-06-13 A | 2014-12-09 A | 100% |  | 2014-06-13 | 2014-12-05 | 126d? |  |  | C3; IETF | 3648h | 3648h | DOCME-PCC | 33 | Huawei | Rel-12 | 64 | DOCME-PCC |  |  |
| 2324 | 677.1 | CT3 part of Overload Control for PCC based Diameter applications | 66d? | 2014-06-13 A | 2014-09-11 A | 100% |  | 2014-06-13 | 2014-09-12 | 66d? |  | finish no earlier than 2014-09-12 | C3 | 528h | 528h | DOCME-PCC | 33 | Huawei | Rel-12 | 64 |  |  |  |
| 2325 | 677.2 | (IETF) Overload Control for PCC based Diameter applications | 128d? | 2014-06-13 A | 2014-12-09 A | 100% |  | 2014-06-13 | 2014-12-05 | 126d? |  | finish no earlier than 2014-12-09 | C3-IETF | 1024h | 1024h | DOCME-PCC | 33 | christer.holmberg@ericsson.com | Rel-12 | 64 |  |  |  |
| 2326 | 678 | Network Initiated USSD Simulation Services in IMS | 63d? | 2014-09-12 A | 2014-12-09 A | 100% |  |  |  |  |  | finish no earlier than 2014-12-09 | C1 | 504h | 504h | USSI-NET | 33 | AT&T | Rel-12 | 65 | USSI-NET | CP-140610 |  |
| 2327 | 679 | **Introduction of ER-GSM band for GSM-R** | 651d? | 2011-09-16 A | 2014-02-28 A | 100% |  | 2011-09-16 | 2014-02-28 | 651d? |  |  | G1; C1; G3new | 26496h | 26496h | RT_ERGSM | 27 | Kapsch Carriercom, Sierra Wireless | Rel-12 | 51 | RT_ERGSM |  | Paolo |
| 2328 | 679.1 | GERAN1 part of Introduction of ER-GSM band for GSM-R | 647d? | 2011-09-16 A | 2014-02-28 A | 100% |  | 2011-09-16 | 2014-02-28 | 647d? |  | finish no earlier than 2014-02-28 | G1 | 5168h | 5168h | RT_ERGSM | 27 | Kapsch Carriercom, Sierra Wireless | Rel-12 | 51 |  |  | Paolo |
| 2329 | 679.2 | Test part: Introduction of ER-GSM band for GSM-R | 131d? | 2013-09-02 A | 2014-02-28 A | 100% |  | 2013-09-02 | 2014-02-28 | 131d? |  | finish no earlier than 2014-02-28 | G3new | 1048h | 1048h | RT_ERGSM | 31 | Kapsch Carriercom, Sierra Wireless | Rel-12 | 59 |  |  | Ingbert |
| 2330 | 679.3 | CT1 part of Introduction of ER-GSM band for GSM-R | 582d? | 2011-09-28 A | 2013-12-06 A | 100% |  | 2011-09-28 | 2013-12-06 | 582d? |  | finish no earlier than 2013-12-06 | C1 | 4656h | 4656h | RT_ERGSM | 27 | Kapsch Carriercom, Sierra Wireless | Rel-12 | 53 |  |  | Frederic |
| 2331 | 680 | **Downlink Multi Carrier GERAN** | 666d? | 2012-09-10 A | 2015-03-13 | 91% | 61.92d? | 2012-09-10 | 2014-09-12 | 533d? | 1372d |  | G2; G1; C1; G3new | 34536h | 12164.8h | DMCG | 29 | Ericsson | Rel-12 | 55 | DMCG |  | Gert |
| 2332 | 680.1 | Core part: Downlink Multi Carrier GERAN | 229d? | 2013-07-22 A | 2014-05-30 A | 100% |  | 2013-07-22 | 2014-05-30 | 229d? |  | finish no earlier than 2014-05-30 | G2; G1 | 3664h | 3664h | DMCG | 29 | Ericsson | Rel-12 | 55 |  |  | Gert |
| 2333 | 680.2 | CT part: Downlink Multi Carrier GERAN | 533d? | 2012-09-10 A | 2014-09-11 A | 100% |  | 2012-09-10 | 2014-09-12 | 533d? |  | finish no earlier than 2014-09-12 | C1 | 4264h | 4264h | DMCG | 29 | Ericsson | Rel-12 | 55 |  |  | Frederic |
| 2334 | 680.3 | Test part: Downlink Multi Carrier GERAN | 662d? | 2012-09-10 A | 2015-03-13 | 80% | 132.4d? | 2012-09-10 | 2014-08-29 | 522d? | 1372d | finish no earlier than 2015-03-13 | G3new | 5296h | 4236.8h | DMCG-MStest | 29 | ST-Ericsson | Rel-12 | 55 | DMCG-MStest |  | Ingbert |
| 2335 | 681 | **Mobile Station Receive Diversity (MSRD) for Voice Services over Adaptive Multi-user channels on One Slot (VAMOS)** | 459d? | 2013-03-01 A | 2014-11-21 A | 100% |  | 2013-03-01 | 2014-08-29 | 396d? |  |  | G1; G2; C1; G3new | 24064h | 24064h | MSRD_VAMOS | 30 | Nokia Networks, Microsoft | Rel-12 | 57 | MSRD_VAMOS | GP-140579 | Paolo |
| 2336 | 681.1 | CT1 introduction of MS capability support for MS supporting MSRD for VAMOS | 205d? | 2013-03-01 A | 2013-12-06 A | 100% |  | 2013-03-01 | 2013-12-06 | 205d? |  | finish no earlier than 2013-12-06 | C1 | 1640h | 1640h | MSRD_VAMOS | 30 | Nokia Networks, Microsoft | Rel-12 | 57 |  |  | Frederic |
| 2337 | 681.2 | MSRD for VAMOS - Performance Requirements | 257.5d? | 2013-11-28 A | 2014-11-21 A | 100% |  | 2013-11-28 | 2014-08-29 | 197.5d? |  | finish no earlier than 2014-11-21 | G1; G2 | 4120h | 4120h | MSRD_VAMOS-PerfReq | 30 | Nokia Networks, Microsoft | Rel-12 | 57 | MSRD_VAMOS-PerfReq | GP-140579 | Paolo |
| 2338 | 681.3 | MSRD for VAMOS - MS Conformance Test | 453d? | 2013-03-06 A | 2014-11-21 A | 100% |  | 2013-03-06 | 2014-08-29 | 393d? |  | finish no earlier than 2014-11-21 | G3new | 3616h | 3616h | MSRD_VAMOS-Test | 30 | Nokia Networks, Microsoft | Rel-12 | 57 | MSRD_VAMOS-Test | GP-140579 | Ingbert |
| 2339 | 682 | **New Training Sequence Codes (TSC) for GERAN** | 277d? | 2013-11-22 A | 2014-12-09 | 93% | 18.18d? | 2013-11-22 | 2014-08-29 | 202d? | 1440d |  | G1; G2; C1 | 11184h | 10449.7h | NewToN | 32 | Ericsson | Rel-12 | 60 | NewToN | GP-140542 | Paolo |
| 2340 | 682.1 | GERAN1 part of New Training Sequence Codes (TSC) for GERAN | 261d? | 2013-11-22 A | 2014-11-21 A | 100% |  | 2013-11-22 | 2014-08-29 | 201d? |  | finish no earlier than 2014-11-21 | G1 | 2088h | 2088h | NewToN | 32 | Ericsson | Rel-12 | 60 |  | GP-140542 | Paolo |
| 2341 | 682.2 | GERAN2 part of New Training Sequence Codes (TSC) for GERAN | 261d? | 2013-11-22 A | 2014-11-21 | 80% | 52.2d? | 2013-11-22 | 2014-08-29 | 201d? | 1452d | finish no earlier than 2014-11-21 | G2 | 2088h | 1670.4h | NewToN | 32 | Ericsson | Rel-12 | 60 |  | GP-140542 | Gert |
| 2342 | 682.3 | CT1 part of New Training Sequence Codes (TSC) for GERAN (Stage 3) | 273d? | 2013-11-22 A | 2014-12-09 A | 100% |  | 2013-11-22 | 2014-08-29 | 201d? |  | finish no earlier than 2014-12-09 | C1 | 2184h | 2184h | NewToN | 32 | Ericsson | Rel-12 | 60 |  | CP-140604 | Frederic |

Notes:
- 2317: Triggered by TR 24.802 Study on Indication of Network to Network Interface (NNI) Routeing scenarios in SIP requests UID_580025 / WI rapporteur e-mail: Jan.Holm@ericsson.com
- 2318: CP#65 completion 09/14=>12/14. Exception in CP-140613. Dec.14: 95->100 / Impacted TSs and TRs: 24.229 / WI rapporteur e-mail: Jan.Holm@ericsson.com
- 2319: Publication requested; 7/3/16: 50%->100 / Impacted TSs and TRs: draft-holmberg-dispatch-iotl / WI rapporteur e-mail: christer.holmberg@ericsson.com
- 2320: CP#65 completed / Impacted TSs and TRs: 29.079, 29.165 / WI rapporteur e-mail: Jan.Holm@ericsson.com
- 2321: CP#64 approved WID & completed. Related to R11 USSD simulation service in IMS (delivery of UE originating USSD request using IMS, I.e. introduce 2nd method for delivery of UE originating USSD request to network (additional to USSD using CS domain) / Impacted TSs and TRs: 24.173, 24.390, New TS 24.391 / WI rapporteur e-mail: ivo.sedlacek@ericsson.com
- 2322: CP#65 completion 09/14=>12/14. TS 29.201v200 for Approval. Exception in CP-140561. Dec.14: 80->100 / Impacted TSs and TRs: 29.213, 29.214, new TS 29.201 / WI rapporteur e-mail: horst.brinkmann@alcatel-lucent.com
- 2323: Triggered by TR 29.809 Study on Diameter overload control mechanism (FS_DOCME) / WI rapporteur e-mail: Xia Haitao (xiahaitao@huawei.com)
- 2324: CP#65 completed / Impacted TSs and TRs: 29.212, 29.213, 29.214 / WI rapporteur e-mail: Xia Haitao (xiahaitao@huawei.com)
- 2325: work in progress; 7/3/16: 50%->100 / Impacted TSs and TRs: draft-ietf-dime-ovli / WI rapporteur e-mail: christer.holmberg@ericsson.com
- 2326: CP#65 exception in CP-140610. Dec.14: 75->100 / Impacted TSs and TRs: 24.390 / WI rapporteur e-mail: Martin Dolly (md3135@att.com)
- 2327: Use of band 870-876/915-921 MHz for land mobile service on national possibilities/market demand - as per ECC/DEC/(04)06. Introduction of ERGSM band, Performance requirements and Deployment scenarios. / Impacted TSs and TRs: GERAN / WI rapporteur e-mail: thomas.chatelet@kapsch.net, Rémi Lascoux (rlascoux@sierrawireless.com)
- 2328: GP#61 completed. GP#51 approved WID / Impacted TSs and TRs: 45.001, 45.005, 45.008, 45.050 / WI rapporteur e-mail: thomas.chatelet@kapsch.net, Rémi Lascoux (rlascoux@sierrawireless.com)
- 2329: GP#61 completed / Impacted TSs and TRs: 51.010, 51.021 / WI rapporteur e-mail: thomas.chatelet@kapsch.net, Rémi Lascoux (rlascoux@sierrawireless.com)
- 2330: CP#62 completed. Added ERGSM capability indication (24.008 CR#2469R1) / Impacted TSs and TRs: 24.008 / WI rapporteur e-mail: thomas.chatelet@kapsch.net, Rémi Lascoux (rlascoux@sierrawireless.com)
- 2331: Linked to Rel-7 Downlink Dual Carrier UID_50579 (Previous work on multiple carriers on the downlink was limited to two). Ref: TR 45.912 Feasibility study for evolved GERAN, TS 43.064 GPRS Stage 2 / Impacted TSs and TRs: GERAN / WI rapporteur e-mail: paul.schliwa-bertling@ericsson.com
- 2332: GP#62 completed. GP#55 approved WID / Impacted TSs and TRs: 43.064, 44.004, 44.018, 44.060, 45.002, 45.003, 45.005, 45.008, 48.018 / WI rapporteur e-mail: paul.schliwa-bertling@ericsson.com
- 2333: CP#65 completed / Impacted TSs and TRs: 24.008 / WI rapporteur e-mail: paul.schliwa-bertling@ericsson.com
- 2334: GP#63 completion 08/14=>11/14. Dec.14: 35->80%, CD:11/14->03/15 / Impacted TSs and TRs: 51.010-1, 51.010-2 / WI rapporteur e-mail: hakan.e.grunditz@stericsson.com
- 2335: GP#63 completion 08/14=>11/14. Exception in GP-140579. Linked to Rel-7 Mobile Station Receive Diversity (DARP Phase II) UID_50569, Rel-9 Voice Services over Adaptive Multiuser channels on One Slot (VAMOS) UID_420002 / Impacted TSs and TRs: GERAN / WI rapporteur e-mail: Khairul Hasan (Nokia Networks), Markku Tarkiainen (Nokia=>Microsoft)
- 2336: CP#62 completed / Impacted TSs and TRs: 24.008 / WI rapporteur e-mail: Khairul Hasan (Nokia Networks), Markku Tarkiainen (Nokia=>Microsoft)
- 2337: GP#63 completion 08/14=>11/14. Exception in GP-140579. Dec.14: 95->100 / Impacted TSs and TRs: 44.018, 45.001, 45.002, 45.005, 45.008, 45.009 / WI rapporteur e-mail: Khairul Hasan (Nokia Networks), Markku Tarkiainen (Nokia=>Microsoft)
- 2338: GP#63 completion 08/14=>11/14. Exception in GP-140579. Dec.14: 85->100 / Impacted TSs and TRs: 51.010-1, 51.010-2 / WI rapporteur e-mail: Khairul Hasan (Nokia Networks), Markku Tarkiainen (Nokia=>Microsoft)
- 2339: GP#63 completion 08/14=>11/14. Exception in GP-140542. GP#60 approved WID. Triggered by GP-131041, GP#40 GP-081949 (WID VAMOS). Linked to Rel-9 VAMOS (Previous work where new TSCs were defined for GMSK modulation) UID_420002 / Impacted TSs and TRs: GERAN / WI rapporteur e-mail: Mårten Sundberg
- 2340: GP#63 completion 08/14=>11/14. Exception in GP-140542. Dec.14: 80->100% / Impacted TSs and TRs: 45.001, 45.002, 45.008, 45.009, 45.050 / WI rapporteur e-mail: Mårten Sundberg
- 2341: GP#63 completion 08/14=>11/14. Exception in GP-140542. / Impacted TSs and TRs: 44.018, 44.060 / WI rapporteur e-mail: Mårten Sundberg
- 2342: CP#65 completion 09/14=>12/14. CP#65 exception in CP-140604. 3/3/15: 100% cpltd. / Impacted TSs and TRs: 24.008 / WI rapporteur e-mail: Mårten Sundberg

| ID | WBS | Task | Duration | Start | Finish | Complete | Remaining | Baseline start | Baseline finish | Baseline duration | Total slack | Constraint | Resources | Work | Actual work | Acronym | PCG approved | WI rapporteur name | Release | TSG approved | MCC resp | Acronym_3GU_Export | Status Report | Special Focus Doc | PCG stopped | TSG stopped |
| --- | --- | --- | --- | --- | --- | --- | --- | --- | --- | --- | --- | --- | --- | --- | --- | --- | --- | --- | --- | --- | --- | --- | --- | --- | --- | --- |
| 2343 | 683 | **Verification of radiated multi-antenna reception performance of UEs in LTE/UMTS** | 469d? | 2012-03-05 A | 2013-12-06 A | 100% |  | 2012-03-05 | 2013-12-06 | 469d? |  |  | R4 | 7464h | 7464h | HSPA_LTE_measRP_MIMO | 28 | Vodafone | Rel-12 | 55 | Issam | HSPA_LTE_measRP_MIMO |  |  |  |  |
| 2344 | 683.1 | Perf. Part: Verification of radiated multi-antenna reception performance of UEs in LTE/UMTS | 464d? | 2012-03-05 A | 2013-12-06 A | 100% |  | 2012-03-05 | 2013-12-06 | 464d? |  | finish no earlier than 2013-12-06 | R4 | 3712h | 3712h | HSPA_LTE_measRP_MIMO-Perf | 28 | Vodafone | Rel-12 | 55 | Issam | HSPA_LTE_measRP_MIMO-Perf | RP-131507 |  |  |  |
| 2345 | 684 | **Further enhancements to H(e)NB mobility - Part 3 (Stage 2/3)** | 330d? | 2012-09-12 A | 2013-12-06 A | 100% |  | 2012-09-12 | 2013-12-06 | 330d? |  |  | R3; R2 | 10560h | 10560h | EHNB_enh3 | 29 | Alcatel-Lucent | Rel-12 | 57 | Juha | EHNB_enh3 |  | HNB |  |  |
| 2346 | 684.1 | Core part: Further enhancements to H(e)NB mobility - Part 3 | 330d? | 2012-09-12 A | 2013-12-06 A | 100% |  | 2012-09-12 | 2013-12-06 | 330d? |  | finish no earlier than 2013-12-06 | R3; R2 | 5280h | 5280h | EHNB_enh3-Core | 29 | Alcatel-Lucent | Rel-12 | 57 | Juha | EHNB_enh3-Core | RP-131508 | HNB |  |  |
| 2347 | 685 | **Support for BeiDou Navigation Satellite System (BDS) for UTRA and LTE** | 604d? | 2013-03-04 A | 2015-06-15 A | 100% |  | 2013-03-04 | 2015-06-12 | 600d? |  |  | R2; R3; R4; R5 | 31680h | 31680h | LCS_BDS | 30 | CATR | Rel-12 | 59 | Yong-Jun | LCS_BDS |  |  |  |  |
| 2348 | 685.1 | Core part: Support for BeiDou Navigation Satellite System (BDS) for UTRA | 204d? | 2013-06-02 A | 2014-03-06 A | 100% |  | 2013-06-02 | 2014-03-06 | 204d? |  | finish no earlier than 2014-03-06 | R2; R3 | 3264h | 3264h | LCS_BDS-UTRA-Core | 30 | ZTE | Rel-12 | 59 | Yong-Jun | LCS_BDS-UTRA-Core | RP-131500 |  |  |  |
| 2349 | 685.2 | Perf. part: Support for BeiDou Navigation Satellite System (BDS) for UTRA | 336d? | 2013-03-07 A | 2014-06-13 A | 100% |  | 2013-03-07 | 2014-06-13 | 336d? |  | finish no earlier than 2014-06-13 | R4 | 2688h | 2688h | LCS_BDS-UTRA-Perf | 30 | ZTE | Rel-12 | 59 | Issam | LCS_BDS-UTRA-Perf | RP-140714 |  |  |  |
| 2350 | 685.3 | Core part: Support for BeiDou Navigation Satellite System (BDS) for LTE | 202d? | 2013-03-04 A | 2013-12-06 A | 100% |  | 2013-03-04 | 2013-12-06 | 202d? |  | finish no earlier than 2013-12-06 | R2 | 1616h | 1616h | LCS_BDS-LTE-Core | 30 | CATR | Rel-12 | 59 | Yong-Jun | LCS_BDS-LTE-Core | RP-131525 |  |  |  |
| 2351 | 685.4 | Perf. part: Support for BeiDou Navigation Satellite System (BDS) for LTE | 336d? | 2013-03-07 A | 2014-06-13 A | 100% |  | 2013-03-07 | 2014-06-13 | 336d? |  | finish no earlier than 2014-06-13 | R4 | 2688h | 2688h | LCS_BDS-LTE-Perf | 30 | ZTE | Rel-12 | 59 | Issam | LCS_BDS-LTE-Perf | RP-140713 |  |  |  |
| 2352 | 685.5 | Test part: BeiDou Navigation Satellite System (BDS) Positioning Support for LTE and UMTS | 262d? | 2014-06-15 A | 2015-06-15 A | 100% |  | 2014-06-13 | 2015-06-12 | 261d? |  | finish no earlier than 2015-06-15 | R5 | 2096h | 2096h | LCS_BDS-UEConTest | 33 | CATT | Rel-12 | 64 |  | LCS_BDS-UEConTest | RP-150656 |  |  |  |
| 2353 | 686 | **Support for BeiDou Navigation Satellite System (BDS) for LCS in GERAN** | 345d? | 2013-11-22 A | 2015-03-13 | 93% | 25.19d? | 2013-11-22 | 2014-11-21 | 262d? | 1372d |  | G2; G1; G3new | 14213.2h | 5848.39h | LCS_BDS_GERAN | 32 | ZTE | Rel-12 | 60 | Gert | LCS_BDS_GERAN |  |  |  |  |
| 2354 | 686.1 | GERAN2 part of Support for BeiDou Navigation Satellite System (BDS) for LCS in GERAN | 201d? | 2013-11-22 A | 2014-08-29 A | 100% |  | 2013-11-22 | 2014-08-29 | 201d? |  | finish no earlier than 2014-08-29 | G2 | 1608h | 1608h | LCS_BDS_GERAN | 32 | ZTE | Rel-12 | 60 | Gert |  |  |  |  |  |
| 2355 | 686.2 | GERAN1 part of Support for BeiDou Navigation Satellite System (BDS) for LCS in GERAN | 201d? | 2013-11-22 A | 2014-08-29 A | 100% |  | 2013-11-22 | 2014-08-29 | 201d? |  | finish no earlier than 2014-08-29 | G1 | 1608h | 1608h | LCS_BDS_GERAN | 32 | ZTE | Rel-12 | 60 | Paolo |  |  |  |  |  |
| 2356 | 686.3 | Support for BeiDou Navigation Satellite System (BDS) for LCS in GERAN3new | 272d? | 2014-03-01 A | 2015-03-13 | 80% | 54.4d? | 2014-02-28 | 2014-11-21 | 192d? | 1372d | finish no earlier than 2015-03-13 | G3new | 2176h | 1740.8h | LCS_BDS_GERAN-GERAN3new | 32 | CATR | Rel-12 | 61 | Ingbert | LCS_BDS_GERAN-GERAN3new |  |  |  |  |
| 2357 | 686.4 | Deleted - Test part: Support for BeiDou Navigation Satellite System (BDS) for LCS in GERAN | 71d? | 2013-11-22 A | 2014-02-28 A | 100% |  | 2013-11-22 | 2014-02-28 | 71d? |  | finish no earlier than 2014-08-29 | G3new | 565.19h | 565.19h | LCS_BDS_GERAN-MStest | 32 | ZTE | Rel-12 | 60 | Ingbert | LCS_BDS_GERAN-MStest |  |  | PCG-32 | GP-61 |
| 2358 | 687 | **Deleted - New Base Station specification structure** | 127d? | 2013-06-18 A | 2013-12-06 A | 100% |  | 2013-06-18 | 2013-12-06 | 127d? |  |  | R4 | 3024h | 3024h | BSspec_struc | 31 | Ericsson | Rel-12 | 60 | Issam | BSspec_struc |  |  | PCG-32 | RP-62 |
| 2359 | 687.1 | Deleted - Core part: New Base Station specification structure | 126d? | 2013-06-18 A | 2013-12-06 A | 100% |  | 2013-06-18 | 2013-12-06 | 126d? |  | finish no earlier than 2013-12-06 | R4 | 1008h | 1008h | BSspec_struc-Core | 31 | Ericsson | Rel-12 | 60 | Issam | BSspec_struc-Core | RP-131513 |  | PCG-32 | RP-62 |
| 2360 | 687.2 | Deleted - Perf. part: New Base Station specification structure | 125d? | 2013-06-20 A | 2013-12-06 A | 100% |  | 2013-06-20 | 2013-12-06 | 125d? |  | finish no earlier than 2013-12-06 | R4 | 1000h | 1000h | BSspec_struc-Perf | 31 | Ericsson | Rel-12 | 60 | Issam | BSspec_struc-Perf | RP-131514 |  | PCG-32 | RP-62 |
| 2361 | 688 | **L-band for Supplemental Downlink in E-UTRA and UTRA** | 659d? | 2013-06-17 A | 2015-12-15 A | 100% |  | 2013-06-17 | 2014-06-13 | 264d? |  |  | R4; R2; R3 | 21600h | 21600h | LTE_UTRA_SDL_BandL | 31 | Orange | Rel-12 | 60 | Issam | LTE_UTRA_SDL_BandL |  |  |  |  |
| 2362 | 688.1 | Core part: L-band for Supplemental Downlink in E-UTRA and UTRA | 87.33d? | 2014-02-13 A | 2014-06-13 A | 100% |  | 2014-02-13 | 2014-06-13 | 87.33d? |  | finish no earlier than 2014-06-13 | R4; R2; R3 | 2096h | 2096h | LTE_UTRA_SDL_BandL-Core | 31 | Orange | Rel-12 | 60 | Issam | LTE_UTRA_SDL_BandL-Core | RP-140633 |  |  |  |
| 2363 | 688.2 | Perf. part: L-band for Supplemental Downlink in E-UTRA and UTRA | 264d? | 2013-06-17 A | 2014-06-13 A | 100% |  | 2013-06-17 | 2014-06-13 | 264d? |  | finish no earlier than 2014-06-13 | R4 | 2112h | 2112h | LTE_UTRA_SDL_BandL-Perf | 31 | Orange | Rel-12 | 60 | Issam | LTE_UTRA_SDL_BandL-Perf | RP-140633 |  |  |  |
| 2364 | 688.3 | UE Conformance Test Aspects - L-band for Supplemental Downlink in E-UTRA and UTRA | 197d? | 2015-03-16 A | 2015-12-15 A | 100% |  |  |  |  |  | finish no earlier than 2015-12-15 | R5 | 1576h | 1576h | LTE_UTRA_SDL_BandL-UEConTest | 34 | Ericsson | Rel-12 | 67 |  |  | RP-151163 |  |  |  |
| 2365 | 689 | **LTE-HRPD (High Rate Packet Data in 3GPP2) inter-RAT SON** | 263d? | 2013-06-18 A | 2014-06-13 A | 100% |  | 2013-06-18 | 2014-06-13 | 263d? |  |  | R3; S2; C4; G2 | 11096h | 11096h | LTE_HRPD_SON | 31 | China Telecom | Rel-12 | 60 | Juha | LTE_HRPD_SON |  | SON |  |  |
| 2366 | 689.1 | Stage 2 for LTE-HRPD (High Rate Packet Data in 3GPP2) inter-RAT SON | 67d? | 2013-09-11 A | 2013-12-11 A | 100% |  | 2013-09-11 | 2013-12-11 | 67d? |  | finish no earlier than 2013-09-11 | S2 | 528h | 528h | LTE_HRPD_SON | 31 | Huawei | Rel-12 | 61 | Maurice |  |  |  |  |  |
| 2367 | 689.2 | Core part: LTE-HRPD (High Rate Packet Data in 3GPP2) inter-RAT SON | 263d? | 2013-06-18 A | 2014-06-13 A | 100% |  | 2013-06-18 | 2014-06-13 | 263d? |  | finish no earlier than 2014-06-13 | R3 | 2088h | 2088h | LTE_HRPD_SON-Core | 31 | China Telecom | Rel-12 | 60 | Juha | LTE_HRPD_SON-Core | RP-140745 |  |  |  |
| 2368 | 689.3 | CT aspects for LTE-HRPD (High Rate Packet Data in 3GPP2) inter-RAT SON (Stage 3) | 3d? | 2013-09-04 A | 2013-09-06 A | 100% |  | 2013-09-04 | 2013-09-06 | 3d? |  | finish no earlier than 2013-09-06 | C4 | 24h | 24h | LTE_HRPD_SON-CT | 31 | Huawei | Rel-12 | 61 | Kimmo | LTE_HRPD_SON-CT |  |  |  |  |
| 2369 | 689.4 | GERAN aspects for LTE-HRPD inter-RAT SON, RAN Information Management (RIM) - Stage 3 | 5d? | 2013-08-26 A | 2013-08-30 A | 100% |  | 2013-08-26 | 2013-08-30 | 5d? |  | finish no earlier than 2013-09-06 | G2 | 40h | 40h | LTE_HRPD_SON-RIM | 31 | Alcatel-Lucent | Rel-12 | 59 | Gert | LTE_HRPD_SON-RIM |  |  |  |  |

Notes:
- 2343: RP#59 moved to Rel-12. Triggered by FS_HSPA_LTE_measRP_MIMO_multi-antenna. Core functionality exists since Rel-6 & Rel-7 (MIMO). Adds a very generic test method to test UEs with 2 or more Rx antennas / Impacted TSs and TRs: UTRA, LTE / WI rapporteur e-mail: Luis Anaya
- 2344: RP#62 completed. Rx diversity (defined as Rel-6 HSDPA RAN4 enhanced type 1 req.) & MIMO (defined as Rel-7 HSDPA MIMO for HSPA). Rx diversity & MIMO (defined as part of Rel-8 basic LTE WI) / Impacted TSs and TRs: new TR 37.977 / WI rapporteur e-mail: luis.anaya@vodafone.com
- 2345: Triggered by FS_EHNB_enh (TR 37.803) / Impacted TSs and TRs: UTRA, LTE / WI rapporteur e-mail: Martin.Warner@alcatel-lucent.com
- 2346: RP#62 completed / Impacted TSs and TRs: 25.304, 25.331, 25.367, 25.467, 25.469, 36.300, 36.331 / WI rapporteur e-mail: Martin.Warner@alcatel-lucent.com
- 2347: BeiDou = Chinese Navigation Satellite System. Location Services (LCS) TS 22.071 Stage 1, TS 23.271 Stage 2 / Impacted TSs and TRs: UTRA, LTE / WI rapporteur e-mail: Ying Du (duying1@catr.cn)
- 2348: RP#62 completed / Impacted TSs and TRs: 25.305, 25.306, 25.331, 25.453, 25.413, 25.423, 25.433 / WI rapporteur e-mail: Huang He (huang.he4@zte.com.cn)
- 2349: RP#64 completed. TS 25.173v100 for 1-step Approval / Impacted TSs and TRs: 25.172 (FDD), new TS 25.173 (TDD) / WI rapporteur e-mail: Ling Soonleh (soonleh.ling@zte.com.cn)
- 2350: RP#62 completed / Impacted TSs and TRs: 36.305, 36.355 / WI rapporteur e-mail: Ying Du (duying1@catr.cn)
- 2351: RP#64 completed / Impacted TSs and TRs: 36.171 / WI rapporteur e-mail: Ling Soonleh (soonleh.ling@zte.com.cn)
- 2352: ; Stat Rep: RP-141350->RP-141950 1st Apr 15: Compl:80%->90% 1st Apr 15: Stat Rep: RP-141950->RP-150357 03/07/15: Compl:90%->100% 03/07/15: Stat Rep: RP-150357->RP-150656 / Impacted TSs and TRs: 34.108, 36.508, 37.571-1, 37.571-2, 37.571-3, 37.571-4, 37.571-5 / WI rapporteur e-mail: Chen Xiaiozhong (chenxiaozhong@catt.cn)
- 2353: GP#60 approved WID. Based on the same framework used in Rel-8 Support for Additional Navigation Satellite Systems (ANSS) for LCS UID_38001 / Impacted TSs and TRs: GERAN / WI rapporteur e-mail: Wang Xinhui (wangxinhui@zte.com.cn)
- 2354: GP#63 completed / Impacted TSs and TRs: 44.031, 49.031, 44.071, 48.031 / WI rapporteur e-mail: Wang Xinhui (wangxinhui@zte.com.cn)
- 2355: GP#63 completed / Impacted TSs and TRs: 43.059, 45.005 / WI rapporteur e-mail: Wang Xinhui (wangxinhui@zte.com.cn)
- 2356: Dec.14: 25->80%, CD: 11/14->03/15 / Impacted TSs and TRs: 51010-1, 51.010-2, 51.010-7 / WI rapporteur e-mail: Zhou DaiWei, China Academy of Telecommunication Research, zhoudaiwei@catr.cn
- 2357: GP#61 stopped / Impacted TSs and TRs: 51.010-1 / WI rapporteur e-mail: Wang Xinhui (wangxinhui@zte.com.cn)
- 2358: Triggered by Rel-12 TR 37.810 Study on Base Station specification structure (FS_BSspec_struc) / Impacted TSs and TRs: UTRA, LTE, MSR / WI rapporteur e-mail: johan.skold@ericsson.com
- 2359: RP#62 stopped (at 20% completion) / Impacted TSs and TRs: 25.104, 25.105, 36.104, 37.104, 37.810, New TR 37.811 (New BS specification structure), New TS 37.xya (New RF core specification) / WI rapporteur e-mail: johan.skold@ericsson.com
- 2360: RP#62 stopped (at 0% completion) / Impacted TSs and TRs: 25.113, 25.141, 25.142, 36.113, 36.141, 37.113, 37.141, 37.810, New TS 37.xyz (New RF test specification, New TS 37.xyw (ew EMC specification) / WI rapporteur e-mail: johan.skold@ericsson.com
- 2361: ECC(12)052 CEPT decision to harmonize 1452-1492 MHz (L-band) for mobile communications Supplemental Downlink (SDL) => standardize L-band and corresponding E-UTRA and UTRA requirements for SDL operation in Region 1 / Impacted TSs and TRs: UTRA, LTE / WI rapporteur e-mail: olfa.benhaddada@orange.com
- 2362: RP#64 completed. RP#65 forgotten TR 37.814 v100 for 1-step Approval / Impacted TSs and TRs: 25.101, 25.104, 25.113, 25.133, 25.307, 25.327, 25.461, 25.466, 34.124, 36.101, 36.104, 36.113, 36.124, 36.133, 36.307, 36.331, 37.104, 37.113, new TR 37.814 / WI rapporteur e-mail: olfa.benhaddada@orange.com
- 2363: RP#64 completed / Impacted TSs and TRs: 25.133, 25.141, 25.307, 25.327, 36.133, 36.141, 36.307, 37.141 / WI rapporteur e-mail: olfa.benhaddada@orange.com
- 2364: 03/07/15: Compl:0%->85% 03/07/15: CD:Mon 15/06/15->Tue 15/09/15 03/07/15: WID: RP-150134->RP-150835 03/07/15: Stat Rep: ->RP-150830 29/09/15: Compl:85%->90% 29/09/15: CD:Tue 15/09/15->Tue 15/12/15 29/09/15: Stat Rep: RP-150830->RP-151163; 1/1/16
- 2365: Triggered by Rel-12 TR 37.813 (FS_LTE_HRPD_SON). SA2 should verify the architecture solution in TR 37.813 for inter-RAT load balancing between LTE-HRPD. CT4 should specify the RIM extension to support the feature. / Impacted TSs and TRs: UTRA, LTE / WI rapporteur e-mail: Jinlian_wu@189.cn
- 2366: SP#62 completed / Impacted TSs and TRs: 23.402 / WI rapporteur e-mail: Huan Li (ivy.lihuan@huawei.com)
- 2367: RP#64 completed / Impacted TSs and TRs: 36.300, 36.413 / WI rapporteur e-mail: Jinlian_wu@189.cn
- 2368: CP#61 WID approved & Completed / Impacted TSs and TRs: 29.274, 29.276, 29.280 / WI rapporteur e-mail: Xiaoyan SHI (sean.shixiaoyan@huawei.com
- 2369: GP#59 WID approved & Completed / Impacted TSs and TRs: 48.018 / WI rapporteur e-mail: marguerite.woch@alcatel-lucent.com

| ID | WBS | Task | Duration | Start | Finish | Complete | Remaining | Baseline start | Baseline finish | Baseline duration | Total slack | Constraint | Resources | Work | Actual work | Acronym | PCG approved | Impacted TSs and TRs | WI rapporteur name | WI rapporteur e-mail | Release | TSG approved | MCC resp | Acronym_3GU_Export | Status Report | Special Focus Doc | PCG stopped | TSG stopped |
| --- | --- | --- | --- | --- | --- | --- | --- | --- | --- | --- | --- | --- | --- | --- | --- | --- | --- | --- | --- | --- | --- | --- | --- | --- | --- | --- | --- | --- |
| 2370 | 690 | **Increasing the minimum number of carriers for UE monitoring in UTRA and E-UTRA** | 1180d? | 2013-12-15 A | 2018-06-15 | 63% | 432.48d? | 2013-12-09 | 2015-03-13 | 331d? | 521d |  | R4; R2 | 22844.4h | 9736.4h | LTE_UTRA_IncMon | 32 | UTRA, LTE | Ericsson | christopher.callender@ericsson.com | Rel-12 | 62 | Issam | LTE_UTRA_IncMon |  |  |  |  |
| 2371 | 690.1 | Core part: Increasing the minimum number of carriers for UE monitoring in UTRA and E-UTRA | 201d? | 2013-12-15 A | 2014-12-15 A | 100% |  | 2014-01-06 | 2014-09-12 | 133d? |  | finish no earlier than 2014-12-15 | R4; R2 | 1844.4h | 1844.4h | LTE_UTRA_IncMon-Core | 32 | 25.133, 25.331, 36.133 | Ericsson | christopher.callender@ericsson.com | Rel-12 | 62 | Issam | LTE_UTRA_IncMon-Core | RP-141787 |  |  |  |
| 2372 | 690.2 | Perf. part: Increasing the minimum number of carriers for UE monitoring in UTRA and E-UTRA | 395d? | 2013-12-15 A | 2015-06-15 A | 100% |  | 2013-12-09 | 2015-03-13 | 331d? |  | finish no earlier than 2015-06-15 | R4 | 3160h | 3160h | LTE_UTRA_IncMon-Perf | 32 | 25.133, 36.133 | Ericsson | christopher.callender@ericsson.com | Rel-12 | 62 | Issam | LTE_UTRA_IncMon-Perf | RP-150596 |  |  |  |
| 2373 | 690.3 | UE Conformance Test Aspects - Increasing the minimum number of carriers for UE monitoring in UTRA and E-UTRA | 655d? | 2015-12-15 A | 2018-06-15 | 30% | 458.5d? |  |  |  | 521d | finish no earlier than 2018-06-15 | R5 | 5240h | 1572h | LTE_UTRA_IncMon-UEConTest | 36 |  | Ericsson |  | Rel-12 | 70 |  |  |  |  |  |  |
| 2374 | 691 | **WLAN/3GPP Radio Interworking** | 267d? | 2013-12-06 A | 2014-12-09 A | 100% |  | 2013-12-06 | 2014-09-17 | 205d? |  |  | R2; S2; C1; C4 | 11021h | 11021h | UTRA_LTE_WLAN_interw | 32 | UTRA, LTE | Intel | sasha.sirotkin@intel.com | Rel-12 | 62 | Yong-Jun | UTRA_LTE_WLAN_interw |  | WLAN |  |  |
| 2375 | 691.1 | Core part: WLAN/3GPP Radio Interworking | 202d? | 2013-12-06 A | 2014-09-12 A | 100% |  | 2013-12-06 | 2014-09-12 | 202d? |  | finish no earlier than 2014-09-12 | R2 | 1616h | 1616h | UTRA_LTE_WLAN_interw-Core | 32 | 25.304, 25.306, 25.331, 36.304, 36.306, 36.331 | Intel | sasha.sirotkin@intel.com | Rel-12 | 62 | Yong-Jun | UTRA_LTE_WLAN_interw-Core | RP-141310 | WLAN |  |  |
| 2376 | 691.2 | SA2 aspects of WLAN/3GPP Radio Interworking | 140d? | 2014-03-07 A | 2014-09-17 A | 100% |  | 2014-03-07 | 2014-09-17 | 139d? |  | finish no earlier than 2014-09-17 | S2 | 1120h | 1120h | UTRA_LTE_WLAN_interw-SA2 | 32 | 23.402, 23.401, 23.060, 23.251 | Alcatel-Lucent | nicolas.drevon@alcatel-lucent.com | Rel-12 | 63 | Maurice | UTRA_LTE_WLAN_interw-SA2 |  | WLAN |  |  |
| 2377 | 691.3 | **CT aspects of WLAN/3GPP Radio Interworking (Stage 2/3)** | 68d? | 2014-09-09 A | 2014-12-09 A | 100% |  | 2014-06-13 | 2014-09-12 | 66d? |  |  | C1; C4 | 1665.6h | 1665.6h | UTRA_LTE_WLAN_interw-CT | 33 | Stage 2/3 | Alcatel-Lucent | jennifer.liu@alcatel-lucent.com | Rel-12 | 64 |  | UTRA_LTE_WLAN_interw-CT |  | WLAN |  |  |
| 2378 | 691.3.1 | CT1 part of CT aspects of WLAN/3GPP Radio Interworking (Stage 3) | 68d? | 2014-09-09 A | 2014-12-09 A | 100% |  | 2014-06-13 | 2014-09-12 | 66d? |  | finish no earlier than 2014-12-09 | C1 | 528h | 528h | UTRA_LTE_WLAN_interw-CT | 33 | 24.008, 24.301, 24.302, 24.312 | Alcatel-Lucent | jennifer.liu@alcatel-lucent.com | Rel-12 | 64 |  |  | CP-140720 | WLAN |  |  |
| 2379 | 691.3.2 | CT4 part of CT aspects of WLAN/3GPP Radio Interworking (Stage 2/3) | 63d? | 2014-09-12 A | 2014-12-09 A | 100% |  |  |  |  |  | finish no earlier than 2014-12-09 | C4 | 504h | 504h | UTRA_LTE_WLAN_interw-CT | 33 | 23.008, 29.002, 29.272, 29.274, 29.305 | Alcatel-Lucent | jennifer.liu@alcatel-lucent.com | Rel-12 | 65 |  |  | CP-140482 | WLAN |  |  |
| 2380 | 692 | UE Conformance Test Aspects – WLAN/3GPP Radio Interworking | 327d? | 2014-12-15 A | 2016-03-15 A | 100% |  |  |  |  |  | finish no earlier than 2016-03-15 | R5 | 2616h | 2616h | UTRA_LTE_WLAN_interw-UEConTest | 34 |  | Intel | Intel | Rel-12 | 66 |  |  | RP-151264 |  |  |  |
| 2381 | 693 | **Rel-12 LTE Carrier Aggregation** | 1384d? | 2011-09-19 A | 2016-12-15 A | 100% |  | 2011-09-19 | 2014-12-11 | 855d? |  |  | R4 | 567982h | 567982h | LTE_CA_Rel-12 | 30 | LTE |  |  | Rel-12 | 58 | Issam | LTE_CA_Rel-12 |  | CA |  |  |
| 2382 | 693.1 | **LTE Advanced inter-band Carrier Aggregation of Band 1 and Band 7** | 792d? | 2011-09-19 A | 2014-09-12 A | 100% |  | 2011-09-19 | 2014-09-12 | 791d? |  |  | R4 | 18896h | 18896h | LTE_CA_B1_B7 | 27 | LTE | Ericsson | christian.bergljung@ericsson.com | Rel-12 | 53 | Issam | LTE_CA_B1_B7 |  | CA |  |  |
| 2383 | 693.1.1 | Core part:LTE Advanced inter-band Carrier Aggregation of Band 1 and Band 7 | 790d? | 2011-09-19 A | 2014-09-12 A | 100% |  | 2011-09-19 | 2014-09-12 | 790d? |  | finish no earlier than 2014-09-12 | R4 | 6312h | 6312h | LTE_CA_B1_B7-Core | 27 | 36.101, 36.104, new generic TR 36.851 | Ericsson | christian.bergljung@ericsson.com | Rel-12 | 53 | Issam | LTE_CA_B1_B7-Core | RP-141084 | CA |  |  |
| 2384 | 693.1.2 | Perf. part:LTE Advanced inter-band Carrier Aggregation of Band 1 and Band 7 | 781d? | 2011-10-03 A | 2014-09-12 A | 100% |  | 2011-09-30 | 2014-09-12 | 781d? |  | finish no earlier than 2014-09-12 | R4 | 6248h | 6248h | LTE_CA_B1_B7-Perf | 27 | 36.141, 36.307 | Ericsson | christian.bergljung@ericsson.com | Rel-12 | 53 | Issam | LTE_CA_B1_B7-Perf | RP-141084 | CA |  |  |
| 2385 | 693.2 | **LTE Advanced intra-band non-contiguous Carrier Aggregation in Band 25** | 462d? | 2011-09-19 A | 2013-06-14 A | 100% |  | 2011-09-19 | 2013-06-14 | 462d? |  |  | R4 | 11056h | 11056h | LTE_CA_NC_B25 | 27 | LTE | Sprint | George.Cummings@sprint.com | Rel-12 | 53 | Issam | LTE_CA_NC_B25 |  | CA |  |  |
| 2386 | 693.2.1 | Core part:LTE Advanced intra-band non-contiguous Carrier Aggregation in Band 25 | 459d? | 2011-09-19 A | 2013-06-14 A | 100% |  | 2011-09-19 | 2013-06-14 | 459d? |  | finish no earlier than 2013-06-14 | R4 | 3672h | 3672h | LTE_CA_NC_B25-Core | 27 | 36.101, 36.104, 36.133, new TR 36.833-2-25 | Sprint | George.Cummings@sprint.com | Rel-12 | 53 | Issam | LTE_CA_NC_B25-Core | RP-130563 | CA |  |  |
| 2387 | 693.2.2 | Perf. part:LTE Advanced intra-band non-contiguous Carrier Aggregation in Band 25 | 461d? | 2011-09-19 A | 2013-06-14 A | 100% |  | 2011-09-19 | 2013-06-14 | 461d? |  | finish no earlier than 2013-06-14 | R4 | 3688h | 3688h | LTE_CA_NC_B25-Perf | 27 | 36.141, 36.307 | Sprint | George.Cummings@sprint.com | Rel-12 | 53 | Issam | LTE_CA_NC_B25-Perf | RP-130759 | CA |  |  |
| 2388 | 693.3 | **Deleted -LTE Advanced inter-band Carrier Aggregation of Band 3 and Band 5 with 2UL** | 265d? | 2012-03-05 A | 2013-03-01 A | 100% |  | 2012-03-05 | 2013-03-01 | 265d? |  |  | R4 | 6296h | 6296h | LTE_CA_B3_B5_2UL | 28 | LTE | SK Telecom | Seungpyo Hong | Rel-12 | 55 | Issam | LTE_CA_B3_B5_2UL |  | CA | PCG-30 | RP-59 |
| 2389 | 693.3.1 | Deleted - Core part:LTE Advanced inter-band Carrier Aggregation of Band 3 and Band 5 with 2UL | 262d? | 2012-03-05 A | 2013-03-01 A | 100% |  | 2012-03-05 | 2013-03-01 | 262d? |  | finish no earlier than 2013-03-01 | R4 | 2096h | 2096h | LTE_CA_B3_B5_2UL-Core | 28 | 36.101, 36.104, 36.133, 36.307, new generic TR 36.851 | SK Telecom | Seungpyo Hong | Rel-12 | 55 | Issam | LTE_CA_B3_B5_2UL-Core | RP-130098 | CA | PCG-30 | RP-59 |
| 2390 | 693.3.2 | Deleted - Perf. part:LTE Advanced inter-band Carrier Aggregation of Band 3 and Band 5 with 2UL | 260d? | 2012-03-12 A | 2013-03-01 A | 100% |  | 2012-03-12 | 2013-03-01 | 260d? |  | finish no earlier than 2013-03-01 | R4 | 2080h | 2080h | LTE_CA_B3_B5_2UL-Perf | 28 | 36.133, 36.141 | SK Telecom | Seungpyo Hong | Rel-12 | 55 | Issam | LTE_CA_B3_B5_2UL-Perf | RP-130099 | CA | PCG-30 | RP-59 |
| 2391 | 693.4 | UE Conformance Test Aspects - Further Rel-12 configurations for LTE Advanced Carrier Aggregation with 2UL | 460d? | 2015-03-16 A | 2016-12-15 A | 100% |  |  |  |  |  | finish no earlier than 2016-12-15 | R5 | 3680h | 3680h | LTE_CA_Rel12_2UL-UEConTest | 34 |  | Ericsson | NA | Rel-12 | 67 |  |  |  |  |  |  |
| 2392 | 693.5 | **LTE Advanced intra-band non-contiguous Carrier Aggregation in Band 3** | 469d? | 2012-03-05 A | 2013-12-06 A | 100% |  | 2012-03-05 | 2013-12-06 | 469d? |  |  | R4 | 11136h | 11136h | LTE_CA_NC_B3 | 28 | LTE | SK Telecom | haesung.park@sk.com | Rel-12 | 55 | Issam | LTE_CA_NC_B3 |  | CA |  |  |
| 2393 | 693.5.1 | Core part:LTE Advanced intra-band non-contiguous Carrier Aggregation in Band 3 | 462d? | 2012-03-05 A | 2013-12-06 A | 100% |  | 2012-03-05 | 2013-12-06 | 462d? |  | finish no earlier than 2013-12-06 | R4 | 3696h | 3696h | LTE_CA_NC_B3-Core | 28 | 36.101, 36.104, 36.133, new TR 36.833-2-03 | SK Telecom | haesung.park@sk.com | Rel-12 | 55 | Issam | LTE_CA_NC_B3-Core | RP-131573 | CA |  |  |
| 2394 | 693.5.2 | Perf. part:LTE Advanced intra-band non-contiguous Carrier Aggregation in Band 3 | 461d? | 2012-03-15 A | 2013-12-06 A | 100% |  | 2012-03-15 | 2013-12-06 | 461d? |  | finish no earlier than 2013-12-06 | R4 | 3688h | 3688h | LTE_CA_NC_B3-Perf | 28 | 36.101, 36.104, 36.133, 36.141, 36.307 | SK Telecom | haesung.park@sk.com | Rel-12 | 55 | Issam | LTE_CA_NC_B3-Perf | RP-131574 | CA |  |  |

Notes:
- 2370: -
- 2371: ; CD:Thu 18/12/14->Mon 15/12/14; WID: RP-141966->RP-142235; Stat Rep: RP-141600->RP-141787
- 2372: ; CD:Fri 12/06/15->Mon 15/06/15; WID: RP-141966->RP-142235; Stat Rep: RP-141600->RP-141787 1st Apr 15: Compl:5%->40% 1st Apr 15: Stat Rep: RP-141787->RP-150063 03/07/15: Compl:40%->100% 03/07/15: Stat Rep: RP-150063->RP-150596
- 2373: 22/3/16: Compl:0%->4%1/7/16: CD:Thu 15/09/16->Thu 15/12/16; 26/9/16: Com 21/3/17: Compl...; ...;...; ;...; 2...
- 2374: Triggered by Rel-12 TR 37.834 Study on WLAN/3GPP Radio Interworking (FS_UTRA_LTE_WLAN_interw)
- 2375: SP#65 completed
- 2376: SP#65 completed
- 2377: CP#65 revised WID CP-140287=>CP-140623 (added CT4 part)
- 2378: CP#65 completion 09/14=>12/14. Exception in CP-140720. 78%->95%. 12/12: 95->78%. 3/3/15: 100% cpltd.
- 2379: CP#65 revised WID CP-140287=>CP-140623 (added CT4 part). Exception in CP-140482. Dec.14: 50->100
- 2380: Rel13->Rel-12; Moved at appropriate place 1st Apr 15: Compl:0%->5% 1st Apr 15: Stat Rep: ->RP-150098 03/07/15: Compl:5%->20% 03/07/15: Stat Rep: RP-150098->RP-150929 29/09/15: Compl:20%->60% 29/09/15: WID: RP-141879->RP-151270 29/09/15: Stat Rep: RP-15
- 2381: LTE_CA_Rel-12
- 2382: Inter-band CA 2DL
- 2383: RP#65 completed. Updated WID RP-132042=>RP-141487
- 2384: RP#65 completed
- 2385: Intra-band NC
- 2386: RP#60 completed. TR 36.841 for 1-step Approval
- 2387: RP#60 completed
- 2388: Inter-band 2UL
- 2389: RP#59 stopped (covered by new WI LTE_CA_2UL-A4)
- 2390: RP#59 stopped (covered by new WI LTE_CA_2UL-A4)
- 2391: 03/07/15: Compl:0%->29% 03/07/15: Stat Rep: ->RP-150834 29/09/15: Compl:29%->55% 29/09/15: Stat Rep: RP-150834->RP-151166 1/1/16: Compl:55%->70% 1/1/16: CD:Tue 15/12/15->Tue 15/03/16 1/1/16: WID: RP-1;
- 2392: Intra-band NC
- 2393: RP#62 completed
- 2394: RP#62 completed

| ID | WBS | Task | Duration | Start | Finish | Complete | Baseline start | Baseline finish | Baseline duration | Constraint | Resources | Work | Actual work | Acronym | PCG approved | Impacted TSs and TRs | WI rapporteur name | WI rapporteur e-mail | Release | TSG approved | MCC resp | PCG stopped | TSG stopped | Special Focus Doc | Acronym_3GU_Export | Status Report |
| --- | --- | --- | --- | --- | --- | --- | --- | --- | --- | --- | --- | --- | --- | --- | --- | --- | --- | --- | --- | --- | --- | --- | --- | --- | --- | --- |
| 2395 | 693.6 | **Deleted - LTE Advanced intra-band contiguous Carrier Aggregation in Band 1** | 265d? | 2012-06-18 A | 2013-06-14 A | 100% | 2012-06-18 | 2013-06-14 | 265d? |  | R4 | 6328h | 6328h | LTE_CA_C_B1 | 29 | LTE | KDDI | Masaaki Obara (ms-obara@kddi.com) | Rel-12 | 56 | Issam | PCG-31 | RP-60 | CA | LTE_CA_C_B1 |  |
| 2396 | 693.6.1 | Deleted - Core part: LTE Advanced intra-band contiguous Carrier Aggregation in Band 1 | 265d? | 2012-06-18 A | 2013-06-14 A | 100% | 2012-06-18 | 2013-06-14 | 265d? | finish no earlier than 2013-06-14 | R4 | 2120h | 2120h | LTE_CA_C_B1-Core | 29 | 36.101, 36.104, 36.133, 36.141, 36.307, new TR 36.835 | KDDI | Masaaki Obara (ms-obara@kddi.com) | Rel-12 | 56 | Issam | PCG-31 | RP-60 | CA | LTE_CA_C_B1-Core | RP-130549 |
| 2397 | 693.6.2 | Deleted - Perf. part: LTE Advanced intra-band contiguous Carrier Aggregation in Band 1 | 261d? | 2012-06-22 A | 2013-06-14 A | 100% | 2012-06-22 | 2013-06-14 | 261d? | finish no earlier than 2013-06-14 | R4 | 2088h | 2088h | LTE_CA_C_B1-Perf | 29 | 36.101, 36.104, 36.133, 36.141, 36.307 | KDDI | Masaaki Obara (ms-obara@kddi.com) | Rel-12 | 56 | Issam | PCG-31 | RP-60 | CA | LTE_CA_C_B1-Perf | RP-130550 |
| 2398 | 693.7 | **LTE Advanced intra-band non-contiguous Carrier Aggregation in Band 4** | 327d? | 2012-06-18 A | 2013-09-06 A | 100% | 2012-06-18 | 2013-09-06 | 327d? |  | R4 | 7752h | 7752h | LTE_CA_NC_B4 | 29 | LTE | T-Mobile USA | nelson.ueng@t-mobile.com | Rel-12 | 56 | Issam |  |  | CA | LTE_CA_NC_B4 |  |
| 2399 | 693.7.1 | Core part:LTE Advanced intra-band non-contiguous Carrier Aggregation in Band 4 | 323d? | 2012-06-18 A | 2013-09-06 A | 100% | 2012-06-18 | 2013-09-06 | 323d? | finish no earlier than 2013-09-06 | R4 | 2568h | 2568h | LTE_CA_NC_B4-Core | 29 | 36.101, 36.104, 36.133, new TR 36.833-2-04 | T-Mobile USA | nelson.ueng@t-mobile.com | Rel-12 | 56 | Issam |  |  | CA | LTE_CA_NC_B4-Core | RP-131039 |
| 2400 | 693.7.2 | Perf. part:LTE Advanced intra-band non-contiguous Carrier Aggregation in Band 4 | 323d? | 2012-06-22 A | 2013-09-06 A | 100% | 2012-06-22 | 2013-09-06 | 323d? | finish no earlier than 2013-09-06 | R4 | 2568h | 2568h | LTE_CA_NC_B4-Perf | 29 | 36.101, 36.104, 36.133, 36.141, 36.307 | T-Mobile USA | nelson.ueng@t-mobile.com | Rel-12 | 56 | Issam |  |  | CA | LTE_CA_NC_B4-Perf | RP-131040 |
| 2401 | 693.8 | **LTE Advanced inter-band Carrier Aggregation of Band 2 and Band 4** | 327d? | 2012-06-18 A | 2013-09-06 A | 100% | 2012-06-18 | 2013-09-06 | 327d? |  | R4 | 7752h | 7752h | LTE_CA_B2_B4 | 29 | LTE | T-Mobile USA | nelson.ueng@t-mobile.com | Rel-12 | 56 | Issam |  |  | CA | LTE_CA_B2_B4 |  |
| 2402 | 693.8.1 | Core part:LTE Advanced inter-band Carrier Aggregation of Band 2 and Band 4 | 321d? | 2012-06-18 A | 2013-09-06 A | 100% | 2012-06-18 | 2013-09-06 | 321d? | finish no earlier than 2013-09-06 | R4 | 2568h | 2568h | LTE_CA_B2_B4-Core | 29 | 36.101, 36.104, 36.133, new generic TR 36.851 | T-Mobile USA | nelson.ueng@t-mobile.com | Rel-12 | 56 | Issam |  |  | CA | LTE_CA_B2_B4-Core | RP-131007 |
| 2403 | 693.8.2 | Perf. part:LTE Advanced inter-band Carrier Aggregation of Band 2 and Band 4 | 321d? | 2012-06-22 A | 2013-09-06 A | 100% | 2012-06-22 | 2013-09-06 | 321d? | finish no earlier than 2013-09-06 | R4 | 2568h | 2568h | LTE_CA_B2_B4-Perf | 29 | 36.101, 36.104, 36.133, 36.141, 36.307 | T-Mobile USA | nelson.ueng@t-mobile.com | Rel-12 | 56 | Issam |  |  | CA | LTE_CA_B2_B4-Perf | RP-131376 |
| 2404 | 693.9 | **LTE Advanced inter-band Carrier Aggregation of Band 23 and Band 29** | 202d? | 2012-09-12 A | 2013-06-14 A | 100% | 2012-09-12 | 2013-06-14 | 202d? |  | R4 | 4832h | 4832h | LTE_CA_B23_B29 | 29 | LTE | DISH Network | mariam.sorond@dish.com, johny.kim@dish.com | Rel-12 | 57 | Issam |  |  | CA | LTE_CA_B23_B29 |  |
| 2405 | 693.9.1 | Core part:LTE Advanced inter-band Carrier Aggregation of Band 23 and Band 29 | 201d? | 2012-09-12 A | 2013-06-14 A | 100% | 2012-09-12 | 2013-06-14 | 201d? | finish no earlier than 2013-06-14 | R4 | 1608h | 1608h | LTE_CA_B23_B29-Core | 29 | 36.101, 36.104, 36.133, new generic TR 36.851 | DISH Network | mariam.sorond@dish.com, johny.kim@dish.com | Rel-12 | 57 | Issam |  |  | CA | LTE_CA_B23_B29-Core | RP-130535 |
| 2406 | 693.9.2 | Perf. part:LTE Advanced inter-band Carrier Aggregation of Band 23 and Band 29 | 201d? | 2012-09-12 A | 2013-06-14 A | 100% | 2012-09-12 | 2013-06-14 | 201d? | finish no earlier than 2013-06-14 | R4 | 1608h | 1608h | LTE_CA_B23_B29-Perf | 29 | 36.141, 36.307 | DISH Network | mariam.sorond@dish.com, johny.kim@dish.com | Rel-12 | 57 | Issam |  |  | CA | LTE_CA_B23_B29-Perf | RP-130536 |
| 2407 | 693.10 | **LTE Advanced inter-band Carrier Aggregation of Band 3 and Band 26** | 203d? | 2012-09-11 A | 2013-06-14 A | 100% | 2012-09-11 | 2013-06-14 | 203d? |  | R4 | 4840h | 4840h | LTE_CA_B3_B26 | 29 | LTE | KT | Chungwoo HWANG (cwhwang@kt.com) | Rel-12 | 57 | Issam |  |  | CA | LTE_CA_B3_B26 |  |
| 2408 | 693.10.1 | Core part:LTE Advanced inter-band Carrier Aggregation of Band 3 and Band 26 | 202d? | 2012-09-11 A | 2013-06-14 A | 100% | 2012-09-11 | 2013-06-14 | 202d? | finish no earlier than 2013-06-14 | R4 | 1608h | 1608h | LTE_CA_B3_B26-Core | 29 | 36.101, 36.104, 36.133, 36.307, new generic TR 36.851 | KT | Chungwoo HWANG (cwhwang@kt.com) | Rel-12 | 57 | Issam |  |  | CA | LTE_CA_B3_B26-Core | RP-130527 |
| 2409 | 693.10.2 | Perf. part:LTE Advanced inter-band Carrier Aggregation of Band 3 and Band 26 | 202d? | 2012-09-11 A | 2013-06-14 A | 100% | 2012-09-11 | 2013-06-14 | 202d? | finish no earlier than 2013-06-14 | R4 | 1608h | 1608h | LTE_CA_B3_B26-Perf | 29 | 36.101, 36.104, 36.133, 36.141, 36.307 | KT | Chungwoo HWANG (cwhwang@kt.com) | Rel-12 | 57 | Issam |  |  | CA | LTE_CA_B3_B26-Perf | RP-130528 |
| 2410 | 693.11 | **LTE Advanced inter-band Carrier Aggregation of Band 3 and Band 19** | 203d? | 2012-09-11 A | 2013-06-14 A | 100% | 2012-09-11 | 2013-06-14 | 203d? |  | R4 | 4840h | 4840h | LTE_CA_B3_B19 | 29 | LTE | NTT DOCOMO | Kei ANDO | Rel-12 | 57 | Issam |  |  | CA | LTE_CA_B3_B19 |  |
| 2411 | 693.11.1 | Core part:LTE Advanced inter-band Carrier Aggregation of Band 3 and Band 19 | 201d? | 2012-09-11 A | 2013-06-14 A | 100% | 2012-09-11 | 2013-06-14 | 201d? | finish no earlier than 2013-06-14 | R4 | 1608h | 1608h | LTE_CA_B3_B19-Core | 29 | 36.101, 36.104, 36.133, new generic TR 36.851 | NTT DOCOMO | Kei ANDO | Rel-12 | 57 | Issam |  |  | CA | LTE_CA_B3_B19-Core | RP-130525 |
| 2412 | 693.11.2 | Perf. part:LTE Advanced inter-band Carrier Aggregation of Band 3 and Band 19 | 201d? | 2012-09-13 A | 2013-06-14 A | 100% | 2012-09-13 | 2013-06-14 | 201d? | finish no earlier than 2013-06-14 | R4 | 1608h | 1608h | LTE_CA_B3_B19-Perf | 29 | 36.141, 36.307 | NTT DOCOMO | Kei ANDO | Rel-12 | 57 | Issam |  |  | CA | LTE_CA_B3_B19-Perf | RP-130526 |
| 2413 | 693.12 | **Deleted -LTE Advanced inter-band Carrier Aggregation of Band 38 and Band 39** | 66d? | 2012-09-11 A | 2012-12-07 A | 100% | 2012-09-11 | 2012-12-07 | 66d? |  | R4 | 1584h | 1584h | LTE_CA_B38_B39 | 29 | LTE | China Mobile | Pan Qun (panqun@chinamobile.com) | Rel-12 | 57 | Issam | PCG-30 | RP-58 | CA | LTE_CA_B38_B39 |  |
| 2414 | 693.12.1 | Deleted - Core part:LTE Advanced inter-band Carrier Aggregation of Band 38 and Band 39 | 66d? | 2012-09-11 A | 2012-12-07 A | 100% | 2012-09-11 | 2012-12-07 | 66d? | finish no earlier than 2012-12-07 | R4 | 528h | 528h | LTE_CA_B38_B39-Core | 29 | 36.101, 36.104, 36.307, new generic TR 36.851 | China Mobile | Pan Qun (panqun@chinamobile.com) | Rel-12 | 57 | Issam | PCG-30 | RP-58 | CA | LTE_CA_B38_B39-Core | RP-121624 |
| 2415 | 693.12.2 | Deleted - Perf. part:LTE Advanced inter-band Carrier Aggregation of Band 38 and Band 39 | 66d? | 2012-09-11 A | 2012-12-07 A | 100% | 2012-09-11 | 2012-12-07 | 66d? | finish no earlier than 2012-12-07 | R4 | 528h | 528h | LTE_CA_B38_B39-Perf | 29 | 36.133, 36.141 | China Mobile | Pan Qun (panqun@chinamobile.com) | Rel-12 | 57 | Issam | PCG-30 | RP-58 | CA | LTE_CA_B38_B39-Perf | RP-121625 |
| 2416 | 693.13 | **LTE Advanced intra-band contiguous Carrier Aggregation in Band 3** | 265d? | 2012-09-11 A | 2013-09-06 A | 100% | 2012-09-11 | 2013-09-06 | 265d? |  | R4 | 6312h | 6312h | LTE_CA_C_B3 | 29 | LTE | China Unicom | Fei CUI (cuifei1@chinaunicom.cn) | Rel-12 | 57 | Issam |  |  | CA | LTE_CA_C_B3 |  |
| 2417 | 693.13.1 | Core part: LTE Advanced intra-band contiguous Carrier Aggregation in Band 3 | 263d? | 2012-09-11 A | 2013-09-06 A | 100% | 2012-09-11 | 2013-09-06 | 263d? | finish no earlier than 2013-09-06 | R4 | 2096h | 2096h | LTE_CA_C_B3-Core | 29 | 36.101, 36.104, 36.133, new TR 36.833-1-03 | China Unicom | Fei CUI (cuifei1@chinaunicom.cn) | Rel-12 | 57 | Issam |  |  | CA | LTE_CA_C_B3-Core | RP-131029 |
| 2418 | 693.13.2 | Perf. part: LTE Advanced intra-band contiguous Carrier Aggregation in Band 3 | 263d? | 2012-09-11 A | 2013-09-06 A | 100% | 2012-09-11 | 2013-09-06 | 263d? | finish no earlier than 2013-09-06 | R4 | 2096h | 2096h | LTE_CA_C_B3-Perf | 29 | 36.141, 36.307 | China Unicom | Fei CUI (cuifei1@chinaunicom.cn) | Rel-12 | 57 | Issam |  |  | CA | LTE_CA_C_B3-Perf | RP-131030 |

Notes:
- 2395: Intra-band C
- 2396: RP#60 stopped at 10% completion (rationale in RP-130670)
- 2397: RP#60 stopped at 0% completion
- 2398: Intra-band NC
- 2399: RP#61 completed. Updated WID RP-130842=>RP-131135
- 2400: RP#61 completed. Updated WID RP-130842=>RP-131135
- 2401: Inter-band 1 UL
- 2402: RP#61 completed
- 2403: RP#61 completed
- 2404: Inter-band 1 UL
- 2405: RP#60 completed
- 2406: RP#60 completed
- 2407: Inter-band 1 UL
- 2408: RP#60 completed. Updated WID RP-130199=>RP-130658
- 2409: RP#60 completed. Updated WID RP-130199=>RP-130658
- 2410: Inter-band 1 UL
- 2411: RP#60 completed
- 2412: RP#60 completed
- 2413: Inter-band 1 UL
- 2414: RP#58 stopped at 10% completion following regulatory decisions (see instead new WI LTE_CA_B39_B41)
- 2415: RP#58 stopped at 0% completion following regulatory decisions (see instead new WI LTE_CA_B39_B41)
- 2416: Intra-band NC
- 2417: RP#61 completed. Updated WID RP-130294=>RP-131184 (impacted specs)
- 2418: RP#61 completed

| ID | WBS | Task | Duration | Start | Finish | Complete | Baseline start | Baseline finish | Baseline duration | Constraint | Resources | Work | Actual work | Acronym | PCG approved | WI rapporteur name | WI rapporteur e-mail | Release | TSG approved | MCC resp | Special Focus Doc | Acronym_3GU_Export | Status Report |
| --- | --- | --- | --- | --- | --- | --- | --- | --- | --- | --- | --- | --- | --- | --- | --- | --- | --- | --- | --- | --- | --- | --- | --- |
| 2419 | 693.14 | **LTE Advanced inter-band Carrier Aggregation of Band 1 and Band 8** | 362.8d? | 2012-02-02 A | 2013-06-14 A | 100% | 2012-02-02 | 2013-06-14 | 362.8d? |  | R4 | 6118.4h | 6118.4h | LTE_CA_B1_B8 | 29 | Softbank Mobile | Kenichi Kihara | Rel-12 | 57 | Issam | CA | LTE_CA_B1_B8 |  |
| 2420 | 693.14.1 | Core part:LTE Advanced inter-band Carrier Aggregation of Band 1 and Band 8 | 201d? | 2012-02-02 A | 2013-06-14 A | 100% | 2012-02-02 | 2013-06-14 | 201d? | finish no earlier than 2013-06-14 | R4 | 1608h | 1608h | LTE_CA_B1_B8-Core | 29 | Softbank Mobile | Kenichi Kihara | Rel-12 | 57 | Issam | CA | LTE_CA_B1_B8-Core | RP-130515 |
| 2421 | 693.14.2 | Perf. part:LTE Advanced inter-band Carrier Aggregation of Band 1 and Band 8 | 202d? | 2012-09-11 A | 2013-06-14 A | 100% | 2012-09-11 | 2013-06-14 | 202d? | finish no earlier than 2013-06-14 | R4 | 1608h | 1608h | LTE_CA_B1_B8-Perf | 29 | Softbank Mobile | Kenichi Kihara | Rel-12 | 57 | Issam | CA | LTE_CA_B1_B8-Perf | RP-130516 |
| 2422 | 693.15 | **LTE Advanced inter-band Carrier Aggregation of Band 3 and Band 28** | 203d? | 2012-09-11 A | 2013-06-14 A | 100% | 2012-09-11 | 2013-06-14 | 203d? |  | R4 | 4840h | 4840h | LTE_CA_B3_B28 | 29 | eAccess | FukumotoShiro@eaccess.net | Rel-12 | 57 | Issam | CA | LTE_CA_B3_B28 |  |
| 2423 | 693.15.1 | Core part:LTE Advanced inter-band Carrier Aggregation of Band 3 and Band 28 | 202d? | 2012-09-11 A | 2013-06-14 A | 100% | 2012-09-11 | 2013-06-14 | 202d? | finish no earlier than 2013-06-14 | R4 | 1608h | 1608h | LTE_CA_B3_B28-Core | 29 | eAccess | FukumotoShiro@eaccess.net | Rel-12 | 57 | Issam | CA | LTE_CA_B3_B28-Core | RP-130529 |
| 2424 | 693.15.2 | Perf. part:LTE Advanced inter-band Carrier Aggregation of Band 3 and Band 28 | 201d? | 2012-09-12 A | 2013-06-14 A | 100% | 2012-09-12 | 2013-06-14 | 201d? | finish no earlier than 2013-06-14 | R4 | 1608h | 1608h | LTE_CA_B3_B28-Perf | 29 | eAccess | FukumotoShiro@eaccess.net | Rel-12 | 57 | Issam | CA | LTE_CA_B3_B28-Perf | RP-130530 |
| 2425 | 693.16 | **LTE Advanced inter-band Carrier Aggregation of Band 1 and Band 26** | 200d? | 2012-12-07 A | 2013-09-06 A | 100% | 2012-12-07 | 2013-09-06 | 200d? |  | R4 | 4768h | 4768h | LTE_CA_B1_B26 | 30 | KDDI | Masaaki Obara (ms-obara@kddi.com) | Rel-12 | 58 | Issam | CA | LTE_CA_B1_B26 |  |
| 2426 | 693.16.1 | Core part:LTE Advanced inter-band Carrier Aggregation of Band 1 and Band 26 | 200d? | 2012-12-07 A | 2013-09-06 A | 100% | 2012-12-07 | 2013-09-06 | 200d? | finish no earlier than 2013-09-06 | R4 | 1576h | 1576h | LTE_CA_B1_B26-Core | 30 | KDDI | Masaaki Obara (ms-obara@kddi.com) | Rel-12 | 58 | Issam | CA | LTE_CA_B1_B26-Core | RP-131005 |
| 2427 | 693.16.2 | Perf. part:LTE Advanced inter-band Carrier Aggregation of Band 1 and Band 26 | 200d? | 2012-12-07 A | 2013-09-06 A | 100% | 2012-12-07 | 2013-09-06 | 200d? | finish no earlier than 2013-09-06 | R4 | 1600h | 1600h | LTE_CA_B1_B26-Perf | 30 | KDDI | Masaaki Obara (ms-obara@kddi.com) | Rel-12 | 58 | Issam | CA | LTE_CA_B1_B26-Perf | RP-131006 |
| 2428 | 693.17 | **LTE Advanced inter-band Carrier Aggregation of Band 39 and Band 41** | 330d? | 2012-12-10 A | 2014-03-06 A | 100% | 2012-12-10 | 2014-03-06 | 330d? |  | R4 | 7848h | 7848h | LTE_CA_B39_B41 | 30 | China Mobile | Pan Qun (panqun@chinamobile.com) | Rel-12 | 58 | Issam | CA | LTE_CA_B39_B41 | RP-140428 |
| 2429 | 693.17.1 | Core part:LTE Advanced inter-band Carrier Aggregation of Band 39 and Band 41 | 326d? | 2012-12-10 A | 2014-03-06 A | 100% | 2012-12-10 | 2014-03-06 | 326d? | finish no earlier than 2014-03-06 | R4 | 2608h | 2608h | LTE_CA_B39_B41-Core | 30 | China Mobile | Pan Qun (panqun@chinamobile.com) | Rel-12 | 58 | Issam | CA | LTE_CA_B39_B41-Core | RP-140428 |
| 2430 | 693.17.2 | Perf. part:LTE Advanced inter-band Carrier Aggregation of Band 39 and Band 41 | 325d? | 2012-12-14 A | 2014-03-06 A | 100% | 2012-12-14 | 2014-03-06 | 325d? | finish no earlier than 2014-03-06 | R4 | 2600h | 2600h | LTE_CA_B39_B41-Perf | 30 | China Mobile | Pan Qun (panqun@chinamobile.com) | Rel-12 | 58 | Issam | CA | LTE_CA_B39_B41-Perf | RP-140428 |
| 2431 | 693.18 | **LTE Advanced inter-band Carrier Aggregation of Band 2 and Band 12** | 467d? | 2012-12-10 A | 2014-09-12 A | 100% | 2012-12-10 | 2014-09-12 | 466d? |  | R4 | 10040h | 10040h | LTE_CA_B2_B12 | 30 | US Cellular | sebastian.thalanany@uscellular.com | Rel-12 | 58 | Issam | CA | LTE_CA_B2_B12 |  |
| 2432 | 693.18.1 | Core part:LTE Advanced inter-band Carrier Aggregation of Band 2 and Band 12 | 464d? | 2012-12-10 A | 2014-09-12 A | 100% | 2012-12-10 | 2014-09-12 | 464d? | finish no earlier than 2014-09-12 | R4 | 3704h | 3704h | LTE_CA_B2_B12-Core | 30 | US Cellular | sebastian.thalanany@uscellular.com | Rel-12 | 58 | Issam | CA | LTE_CA_B2_B12-Core | RP-141084 |
| 2433 | 693.18.2 | Perf. part:LTE Advanced inter-band Carrier Aggregation of Band 2 and Band 12 | 325d? | 2012-12-14 A | 2014-03-06 A | 100% | 2012-12-14 | 2014-03-06 | 325d? | finish no earlier than 2014-06-13 | R4 | 2600h | 2600h | LTE_CA_B2_B12-Perf | 30 | US Cellular | sebastian.thalanany@uscellular.com | Rel-12 | 58 | Issam | CA | LTE_CA_B2_B12-Perf | RP-140428 |
| 2434 | 693.19 | **LTE Advanced intra-band non-contiguous Carrier Aggregation in Band 7** | 265d? | 2012-12-10 A | 2013-12-06 A | 100% | 2012-12-10 | 2013-12-06 | 265d? |  | R4 | 6296h | 6296h | LTE_CA_NC_B7 | 30 | Ericsson | christian.bergljung@ericsson.com | Rel-12 | 58 | Issam | CA | LTE_CA_NC_B7 |  |
| 2435 | 693.19.1 | Core part:LTE Advanced intra-band non-contiguous Carrier Aggregation in Band 7 | 261d? | 2012-12-10 A | 2013-12-06 A | 100% | 2012-12-10 | 2013-12-06 | 261d? | finish no earlier than 2013-12-06 | R4 | 2088h | 2088h | LTE_CA_NC_B7-Core | 30 | Ericsson | christian.bergljung@ericsson.com | Rel-12 | 58 | Issam | CA | LTE_CA_NC_B7-Core | RP-131575 |
| 2436 | 693.19.2 | Perf. part:LTE Advanced intra-band non-contiguous Carrier Aggregation in Band 7 | 261d? | 2012-12-14 A | 2013-12-06 A | 100% | 2012-12-14 | 2013-12-06 | 261d? | finish no earlier than 2013-12-06 | R4 | 2088h | 2088h | LTE_CA_NC_B7-Perf | 30 | Ericsson | christian.bergljung@ericsson.com | Rel-12 | 58 | Issam | CA | LTE_CA_NC_B7-Perf | RP-131576 |
| 2437 | 693.20 | **LTE Advanced intra-band contiguous Carrier Aggregation in Band 27** | 401d? | 2012-12-10 A | 2014-06-13 A | 100% | 2012-12-10 | 2014-06-13 | 401d? |  | R4 | 8472h | 8472h | LTE_CA_C_B27 | 30 | NII Holdings | bill.shvodian@nii.com | Rel-12 | 58 | Issam | CA | LTE_CA_C_B27 |  |
| 2438 | 693.20.1 | Core part: LTE Advanced intra-band contiguous Carrier Aggregation in Band 27 | 261d? | 2012-12-10 A | 2013-12-06 A | 100% | 2012-12-10 | 2013-12-06 | 261d? | finish no earlier than 2013-12-06 | R4 | 2088h | 2088h | LTE_CA_C_B27-Core | 30 | NII Holdings | bill.shvodian@nii.com | Rel-12 | 58 | Issam | CA | LTE_CA_C_B27-Core | RP-131567 |
| 2439 | 693.20.2 | Perf part: LTE Advanced intra-band contiguous Carrier Aggregation in Band 27 | 397d? | 2012-12-14 A | 2014-06-13 A | 100% | 2012-12-14 | 2014-06-13 | 397d? | finish no earlier than 2014-06-13 | R4 | 3176h | 3176h | LTE_CA_C_B27-Perf | 30 | NII Holdings | bill.shvodian@nii.com | Rel-12 | 58 | Issam | CA | LTE_CA_C_B27-Perf | RP-140569 |
| 2440 | 693.21 | **LTE Advanced inter-band Carrier Aggregation of Band 2 and Band 13** | 76d? | 2013-03-04 A | 2013-06-14 A | 100% | 2013-03-04 | 2013-06-14 | 76d? |  | R4 | 1824h | 1824h | LTE_CA_B2_B13 | 30 | Ericsson | christian.bergljung@ericsson.com | Rel-12 | 59 | Issam | CA | LTE_CA_B2_B13 |  |
| 2441 | 693.21.1 | Core part:LTE Advanced inter-band Carrier Aggregation of Band 2 and Band 13 | 76d? | 2013-03-04 A | 2013-06-14 A | 100% | 2013-03-04 | 2013-06-14 | 76d? | finish no earlier than 2013-06-14 | R4 | 608h | 608h | LTE_CA_B2_B13-Core | 30 | Ericsson | christian.bergljung@ericsson.com | Rel-12 | 59 | Issam | CA | LTE_CA_B2_B13-Core | RP-130523 |
| 2442 | 693.21.2 | Perf. part:LTE Advanced inter-band Carrier Aggregation of Band 2 and Band 13 | 76d? | 2013-03-04 A | 2013-06-14 A | 100% | 2013-03-04 | 2013-06-14 | 76d? | finish no earlier than 2013-06-14 | R4 | 608h | 608h | LTE_CA_B2_B13-Perf | 30 | Ericsson | christian.bergljung@ericsson.com | Rel-12 | 59 | Issam | CA | LTE_CA_B2_B13-Perf | RP-130524 |

Notes:
- 2419: Inter-band 1 UL / Impacted TSs and TRs: LTE
- 2420: RP#60 completed / Impacted TSs and TRs: 36.101, 36.104, new generic TR 36.851
- 2421: RP#60 completed / Impacted TSs and TRs: 36.141, 36.307
- 2422: Inter-band 1 UL / Impacted TSs and TRs: LTE
- 2423: RP#60 completed / Impacted TSs and TRs: 36.101, 36.104, new generic TR 36.851
- 2424: RP#60 completed / Impacted TSs and TRs: 36.141, 36.307
- 2425: Inter-band 1UL/2DL / Impacted TSs and TRs: LTE
- 2426: RP#61 completed / Impacted TSs and TRs: 36.101, 36.104, 36.133, new generic TR 36.851
- 2427: RP#61 completed / Impacted TSs and TRs: 36.141, 36.307
- 2428: Inter-band 2DL / Impacted TSs and TRs: LTE
- 2429: RP#63 completed. Replaces the Stopped WI - LTE Advanced inter-band Carrier Aggregation of Band 38 and Band 39 (LTE_CA_B38_B39) UID_570015 / Impacted TSs and TRs: 36.101, 36.104, 36.307, new generic TR 36.851
- 2430: RP#63 completed / Impacted TSs and TRs: 36.133, 36.141
- 2431: Inter-band CA 2DL / Impacted TSs and TRs: LTE
- 2432: RP#65 completed / Impacted TSs and TRs: 36.101, 36.104, 36.133, 36.141, 36.307, new generic TR 36.851
- 2433: RP#63 completed / Impacted TSs and TRs: 36.101, 36.104, 36.133, 36.141, 36.307
- 2434: Intra-band NC / Impacted TSs and TRs: LTE
- 2435: RP#62 completed / Impacted TSs and TRs: 36.101, 36.104, 36.133, new TR 36.833-2-07
- 2436: RP#62 completed / Impacted TSs and TRs: 36.141, 36.307
- 2437: Intra-band contig. CA 2DL/1UL / Impacted TSs and TRs: LTE
- 2438: RP#62 completed / Impacted TSs and TRs: 36.101, 36.104, new TR 36.833-1-27
- 2439: RP#64 completed. TR 36.833-1-27v200 for Approval / Impacted TSs and TRs: 36.101, 36.133, 36.141, 36.307, new TR 36.833-1-27
- 2440: Inter-band 1 UL / Impacted TSs and TRs: LTE
- 2441: RP#60 completed / Impacted TSs and TRs: 36.101, 36.104, 36.133, new generic TR 36.851
- 2442: RP#60 completed / Impacted TSs and TRs: 36.101, 36.104, 36.133, 36.141, 36.307

| ID | WBS | Task | Duration | Start | Finish | Complete | Baseline start | Baseline finish | Baseline duration | Constraint | Resources | Work | Actual work | Acronym | PCG approved | WI rapporteur name | WI rapporteur e-mail | Release | TSG approved | MCC resp | Special Focus Doc | Acronym_3GU_Export | Status Report | PCG stopped | TSG stopped |
| --- | --- | --- | --- | --- | --- | --- | --- | --- | --- | --- | --- | --- | --- | --- | --- | --- | --- | --- | --- | --- | --- | --- | --- | --- | --- |
| 2443 | 693.22 | **LTE Advanced inter-band Carrier Aggregation of Band 19 and Band 21** | 76d? | 2013-03-04 A | 2013-06-14 A | 100% | 2013-03-04 | 2013-06-14 | 76d? |  | R4 | 1824h | 1824h | LTE_CA_B19_B21 | 30 | NTT DOCOMO | Kei ANDO | Rel-12 | 59 | Issam | CA | LTE_CA_B19_B21 |  |  |  |
| 2444 | 693.22.1 | Core part:LTE Advanced inter-band Carrier Aggregation of Band 19 and Band 21 | 76d? | 2013-03-04 A | 2013-06-14 A | 100% | 2013-03-04 | 2013-06-14 | 76d? | finish no earlier than 2013-06-14 | R4 | 608h | 608h | LTE_CA_B19_B21-Core | 30 | NTT DOCOMO | Kei ANDO | Rel-12 | 59 | Issam | CA | LTE_CA_B19_B21-Core | RP-130533 |  |  |
| 2445 | 693.22.2 | Perf. part:LTE Advanced inter-band Carrier Aggregation of Band 19 and Band 21 | 76d? | 2013-03-04 A | 2013-06-14 A | 100% | 2013-03-04 | 2013-06-14 | 76d? | finish no earlier than 2013-06-14 | R4 | 608h | 608h | LTE_CA_B19_B21-Perf | 30 | NTT DOCOMO | Kei ANDO | Rel-12 | 59 | Issam | CA | LTE_CA_B19_B21-Perf | RP-130534 |  |  |
| 2446 | 693.23 | **Deleted -LTE Advanced inter-band Carrier Aggregation of Band 8 and Band 26** | 204d? | 2013-03-04 A | 2013-12-06 A | 100% | 2013-03-04 | 2013-12-06 | 204d? |  | R4 | 4848h | 4848h | LTE_CA_B8_B26 | 30 | KT | Chungwoo HWANG (cwhwang@kt.com) | Rel-12 | 59 | Issam | CA | LTE_CA_B8_B26 |  | PCG-32 | RP-62 |
| 2447 | 693.23.1 | Deleted - Core part:LTE Advanced inter-band Carrier Aggregation of Band 8 and Band 26 | 201d? | 2013-03-04 A | 2013-12-06 A | 100% | 2013-03-04 | 2013-12-06 | 201d? | finish no earlier than 2013-12-06 | R4 | 1608h | 1608h | LTE_CA_B8_B26-Core | 30 | KT | Chungwoo HWANG (cwhwang@kt.com) | Rel-12 | 59 | Issam | CA | LTE_CA_B8_B26-Core | RP-131549 | PCG-32 | RP-62 |
| 2448 | 693.23.2 | Deleted - Perf. part:LTE Advanced inter-band Carrier Aggregation of Band 8 and Band 26 | 201d? | 2013-03-04 A | 2013-12-06 A | 100% | 2013-03-04 | 2013-12-06 | 201d? | finish no earlier than 2013-12-06 | R4 | 1608h | 1608h | LTE_CA_B8_B26-Perf | 30 | KT | Chungwoo HWANG (cwhwang@kt.com) | Rel-12 | 59 | Issam | CA | LTE_CA_B8_B26-Perf | RP-131550 | PCG-32 | RP-62 |
| 2449 | 693.24 | **LTE Advanced dual uplink inter-band Carrier Aggregation Class A1** | 474d? | 2013-03-04 A | 2014-12-15 A | 100% | 2013-03-04 | 2014-09-12 | 405d? |  | R4 | 11272h | 11272h | LTE_CA_2UL-A1 | 30 | Huawei | Liu Ye (leo.liuye@huawei.com) | Rel-12 | 59 | Issam | CA | LTE_CA_2UL-A1 |  |  |  |
| 2450 | 693.24.1 | Core part:LTE Advanced dual uplink inter-band Carrier Aggregation Class A1 | 468d? | 2013-03-04 A | 2014-12-15 A | 100% | 2013-03-04 | 2014-09-12 | 402d? | finish no earlier than 2014-12-15 | R4 | 3744h | 3744h | LTE_CA_2UL-A1-Core | 30 | Huawei | Liu Ye (leo.liuye@huawei.com) | Rel-12 | 59 | Issam | CA | LTE_CA_2UL-A1-Core | RP-141732 |  |  |
| 2451 | 693.24.2 | Perf. part:LTE Advanced dual uplink inter-band Carrier Aggregation Class A1 | 467d? | 2013-03-13 A | 2014-12-15 A | 100% | 2013-03-08 | 2014-09-12 | 401d? | finish no earlier than 2014-12-15 | R4 | 3736h | 3736h | LTE_CA_2UL-A1-Perf | 30 | Huawei | Liu Ye (leo.liuye@huawei.com) | Rel-12 | 59 | Issam | CA | LTE_CA_2UL-A1-Perf | RP-141732 |  |  |
| 2452 | 693.25 | **LTE Advanced dual uplink inter-band Carrier Aggregation Class A2** | 474d? | 2013-03-04 A | 2014-12-15 A | 100% | 2013-03-04 | 2014-09-12 | 405d? |  | R4 | 11272h | 11272h | LTE_CA_2UL-A2 | 30 | Qualcomm | Gene Fong (gfong@qti.qualcomm.com) | Rel-12 | 59 | Issam | CA | LTE_CA_2UL-A2 |  |  |  |
| 2453 | 693.25.1 | Core part:LTE Advanced dual uplink inter-band Carrier Aggregation Class A2 | 468d? | 2013-03-04 A | 2014-12-15 A | 100% | 2013-03-04 | 2014-09-12 | 402d? | finish no earlier than 2014-12-15 | R4 | 3744h | 3744h | LTE_CA_2UL-A2-Core | 30 | Qualcomm | Gene Fong (gfong@qti.qualcomm.com) | Rel-12 | 59 | Issam | CA | LTE_CA_2UL-A2-Core | RP-141732 |  |  |
| 2454 | 693.25.2 | Perf. part:LTE Advanced dual uplink inter-band Carrier Aggregation Class A2 | 467d? | 2013-03-13 A | 2014-12-15 A | 100% | 2013-03-08 | 2014-09-12 | 401d? | finish no earlier than 2014-12-15 | R4 | 3736h | 3736h | LTE_CA_2UL-A2-Perf | 30 | Qualcomm | Gene Fong (gfong@qti.qualcomm.com) | Rel-12 | 59 | Issam | CA | LTE_CA_2UL-A2-Perf | RP-141732 |  |  |
| 2455 | 693.26 | **LTE Advanced dual uplink inter-band Carrier Aggregation Class A3** | 474d? | 2013-03-04 A | 2014-12-15 A | 100% | 2013-03-04 | 2014-09-12 | 405d? |  | R4 | 11264h | 11264h | LTE_CA_2UL-A3 | 30 | Ericsson | christian.bergljung@ericsson.com | Rel-12 | 59 | Issam | CA | LTE_CA_2UL-A3 |  |  |  |
| 2456 | 693.26.1 | Core part:LTE Advanced dual uplink inter-band Carrier Aggregation Class A3 | 467d? | 2013-03-04 A | 2014-12-15 A | 100% | 2013-03-04 | 2014-09-12 | 401d? | finish no earlier than 2014-12-15 | R4 | 3736h | 3736h | LTE_CA_2UL-A3-Core | 30 | Ericsson | christian.bergljung@ericsson.com | Rel-12 | 59 | Issam | CA | LTE_CA_2UL-A3-Core | RP-141732 |  |  |
| 2457 | 693.26.2 | Perf. part:LTE Advanced dual uplink inter-band Carrier Aggregation Class A3 | 467d? | 2013-03-13 A | 2014-12-15 A | 100% | 2013-03-08 | 2014-09-12 | 401d? | finish no earlier than 2014-12-15 | R4 | 3736h | 3736h | LTE_CA_2UL-A3-Perf | 30 | Ericsson | christian.bergljung@ericsson.com | Rel-12 | 59 | Issam | CA | LTE_CA_2UL-A3-Perf | RP-141732 |  |  |
| 2458 | 693.27 | **LTE Advanced dual uplink inter-band Carrier Aggregation Class A4** | 474d? | 2013-03-04 A | 2014-12-15 A | 100% | 2013-03-04 | 2014-09-12 | 405d? |  | R4 | 11272h | 11272h | LTE_CA_2UL-A4 | 30 | Nokia | petri.j.vasenkari@nokia.com | Rel-12 | 59 | Issam | CA | LTE_CA_2UL-A4 |  |  |  |
| 2459 | 693.27.1 | Core part:LTE Advanced dual uplink inter-band Carrier Aggregation Class A4 | 468d? | 2013-03-04 A | 2014-12-15 A | 100% | 2013-03-04 | 2014-09-12 | 402d? | finish no earlier than 2014-12-15 | R4 | 3744h | 3744h | LTE_CA_2UL-A4-Core | 30 | Nokia | petri.j.vasenkari@nokia.com | Rel-12 | 59 | Issam | CA | LTE_CA_2UL-A4-Core | RP-141732 |  |  |
| 2460 | 693.27.2 | Perf. part:LTE Advanced dual uplink inter-band Carrier Aggregation Class A4 | 467d? | 2013-03-13 A | 2014-12-15 A | 100% | 2013-03-08 | 2014-09-12 | 401d? | finish no earlier than 2014-12-15 | R4 | 3736h | 3736h | LTE_CA_2UL-A4-Perf | 30 | Nokia | petri.j.vasenkari@nokia.com | Rel-12 | 59 | Issam | CA | LTE_CA_2UL-A4-Perf | RP-141732 |  |  |
| 2461 | 693.28 | **LTE Advanced dual uplink inter-band Carrier Aggregation Class A5** | 474d? | 2013-03-04 A | 2014-12-15 A | 100% | 2013-03-04 | 2014-09-12 | 405d? |  | R4 | 11264h | 11264h | LTE_CA_2UL-A5 | 30 | NTT DOCOMO | kei.andou.ye@nttdocomo.com | Rel-12 | 59 | Issam | CA | LTE_CA_2UL-A5 |  |  |  |
| 2462 | 693.28.1 | Core part:LTE Advanced dual uplink inter-band Carrier Aggregation Class A5 | 467d? | 2013-03-04 A | 2014-12-15 A | 100% | 2013-03-04 | 2014-09-12 | 401d? | finish no earlier than 2014-12-15 | R4 | 3736h | 3736h | LTE_CA_2UL-A5-Core | 30 | NTT DOCOMO | kei.andou.ye@nttdocomo.com | Rel-12 | 59 | Issam | CA | LTE_CA_2UL-A5-Core | RP-141732 |  |  |
| 2463 | 693.28.2 | Perf. part:LTE Advanced dual uplink inter-band Carrier Aggregation Class A5 | 467d? | 2013-03-13 A | 2014-12-15 A | 100% | 2013-03-08 | 2014-09-12 | 401d? | finish no earlier than 2014-12-15 | R4 | 3736h | 3736h | LTE_CA_2UL-A5-Perf | 30 | NTT DOCOMO | kei.andou.ye@nttdocomo.com | Rel-12 | 59 | Issam | CA | LTE_CA_2UL-A5-Perf | RP-141732 |  |  |
| 2464 | 693.29 | **LTE Advanced intra-band contiguous Carrier Aggregation in Band 39** | 269d? | 2013-03-04 A | 2014-03-06 A | 100% | 2013-03-04 | 2014-03-06 | 269d? |  | R4 | 6400h | 6400h | LTE_CA_C_B39 | 30 | China Mobile | Li Nan (linan@chinamobile.com) | Rel-12 | 59 | Issam | CA | LTE_CA_C_B39 |  |  |  |
| 2465 | 693.29.1 | Core part: LTE Advanced intra-band contiguous Carrier Aggregation in Band 39 | 266d? | 2013-03-04 A | 2014-03-06 A | 100% | 2013-03-04 | 2014-03-06 | 266d? | finish no earlier than 2014-03-06 | R4 | 2128h | 2128h | LTE_CA_C_B39-Core | 30 | China Mobile | Li Nan (linan@chinamobile.com) | Rel-12 | 59 | Issam | CA | LTE_CA_C_B39-Core | RP-140428 |  |  |
| 2466 | 693.29.2 | Perf. part: LTE Advanced intra-band contiguous Carrier Aggregation in Band 39 | 265d? | 2013-03-07 A | 2014-03-06 A | 100% | 2013-03-07 | 2014-03-06 | 265d? | finish no earlier than 2014-03-06 | R4 | 2120h | 2120h | LTE_CA_C_B39-Perf | 30 | China Mobile | Li Nan (linan@chinamobile.com) | Rel-12 | 59 | Issam | CA | LTE_CA_C_B39-Perf | RP-140428 |  |  |

Notes:
- 2443: Inter-band 1 UL / Impacted TSs and TRs: LTE
- 2444: RP#60 completed / Impacted TSs and TRs: 36.101, 36.104, 36.133, new generic TR 36.851
- 2445: RP#60 completed / Impacted TSs and TRs: 36.141, 36.307
- 2446: Inter-band 1 UL / Impacted TSs and TRs: LTE
- 2447: RP#62 stopped (at 20%) / Impacted TSs and TRs: 36.101, 36.104, 36.133, new generic TR 36.851
- 2448: RP#62 stopped (at 20%) / Impacted TSs and TRs: 36.141, 36.307
- 2449: Inter-band CA 2UL / Impacted TSs and TRs: LTE
- 2450: ; WID: RP-142043->RP-141941; Stat Rep: RP-141084->RP-141732 / Impacted TSs and TRs: 36.101, 36.104, New generic TR 36.860
- 2451: ; WID: RP-142043->RP-141941; Stat Rep: RP-141084->RP-141732 / Impacted TSs and TRs: 36.133
- 2452: Inter-band CA 2UL / Impacted TSs and TRs: LTE
- 2453: ; Stat Rep: RP-141084->RP-141732 / Impacted TSs and TRs: 36.101, 36.104, 36.133, New generic TR 36.860
- 2454: ; Stat Rep: RP-141084->RP-141732 / Impacted TSs and TRs: 36.141, 36.307
- 2455: Inter-band CA 2UL / Impacted TSs and TRs: LTE
- 2456: ; Stat Rep: RP-141084->RP-141732 / Impacted TSs and TRs: 36.101, 36.104, 36.133, New generic TR 36.860
- 2457: ; Stat Rep: RP-141084->RP-141732 / Impacted TSs and TRs: 36.141, 36.307
- 2458: Inter-band CA 2UL. RP#65 updated WID RP-140476=>RP-141160. / Impacted TSs and TRs: LTE
- 2459: ; WID: RP-142043->RP-141967; Stat Rep: RP-141084->RP-141732 / Impacted TSs and TRs: 36.101, 36.104, 36.133, New generic TR 36.860
- 2460: ; WID: RP-142043->RP-141967; Stat Rep: RP-141084->RP-141732 / Impacted TSs and TRs: 36.141, 36.307
- 2461: Inter-band CA 2UL. RP#65 updated WID RP-131146=>RP-141195. Changed Rapp Renesas=>Broadcom=>NTT DOCOMO / Impacted TSs and TRs: LTE
- 2462: ; Stat Rep: RP-141084->RP-141732 / Impacted TSs and TRs: 36.101, 36.104, 36.133, New generic TR 36.860
- 2463: ; Stat Rep: RP-141084->RP-141732 / Impacted TSs and TRs: 36.141, 36.307
- 2464: Intra-band C 2DL/2UL / Impacted TSs and TRs: LTE
- 2465: RP#63 completed / Impacted TSs and TRs: 36.101, 36.104, 36.133, New TR 36.833-1-39 [instead of 36.845]
- 2466: RP#63 completed / Impacted TSs and TRs: 36.141, 36.307

| ID | WBS | Task | Duration | Start | Finish | Complete | Baseline start | Baseline finish | Baseline duration | Constraint | Resources | Work | Actual work | Acronym | PCG approved | WI rapporteur name | WI rapporteur e-mail | Release | TSG approved | MCC resp | Special Focus Doc | Acronym_3GU_Export | Status Report | PCG stopped | TSG stopped |
| --- | --- | --- | --- | --- | --- | --- | --- | --- | --- | --- | --- | --- | --- | --- | --- | --- | --- | --- | --- | --- | --- | --- | --- | --- | --- |
| 2467 | 693.30 | **LTE Advanced intra-band non-contiguous Carrier Aggregation: framework requirements for 2UL** | 397d? | 2013-06-18 A | 2014-12-15 A | 100% | 2013-06-18 | 2014-09-12 | 328d? |  | R4 | 6328h | 6328h | LTE_CA_NC_2UL | 31 | Nokia | petri.j.vasenkari@nokia.com | Rel-12 | 60 | Issam | CA | LTE_CA_NC_2UL |  |  |  |
| 2468 | 693.30.1 | Core part:LTE Advanced intra-band non-contiguous Carrier Aggregation: framework requirements for 2UL | 394d? | 2013-06-18 A | 2014-12-15 A | 100% | 2013-06-18 | 2014-09-12 | 328d? | finish no earlier than 2014-12-15 | R4 | 3152h | 3152h | LTE_CA_NC_2UL-Core | 31 | Nokia | petri.j.vasenkari@nokia.com | Rel-12 | 60 | Issam | CA | LTE_CA_NC_2UL-Core | RP-141732 |  |  |
| 2469 | 693.31 | **Deleted -LTE Advanced intra-band non-contiguous Carrier Aggregation in Band 41 for 2UL** | 191d? | 2013-06-19 A | 2014-03-06 A | 100% | 2013-06-19 | 2014-03-06 | 191d? |  | R4 | 4576h | 4576h | LTE_CA_NC_B41_2UL | 31 | Sprint | yang.xu@clearwire.com | Rel-12 | 60 | Issam | CA | LTE_CA_NC_B41_2UL | RP-140428 | PCG-32 | RP-63 |
| 2470 | 693.31.1 | Deleted - Core part:LTE Advanced intra-band non-contiguous Carrier Aggregation in Band 41 for 2UL | 191d? | 2013-06-19 A | 2014-03-06 A | 100% | 2013-06-19 | 2014-03-06 | 191d? | finish no earlier than 2014-03-06 | R4 | 1528h | 1528h | LTE_CA_NC_B41_2UL-Core | 31 | Sprint | yang.xu@clearwire.com | Rel-12 | 60 | Issam | CA | LTE_CA_NC_B41_2UL-Core | RP-140428 | PCG-32 | RP-63 |
| 2471 | 693.31.2 | Deleted - Perf. part:LTE Advanced intra-band non-contiguous Carrier Aggregation in Band 41 for 2UL | 190d? | 2013-06-20 A | 2014-03-06 A | 100% | 2013-06-20 | 2014-03-06 | 190d? | finish no earlier than 2014-03-06 | R4 | 1520h | 1520h | LTE_CA_NC_B41_2UL-Perf | 31 | Sprint | yang.xu@clearwire.com | Rel-12 | 60 | Issam | CA | LTE_CA_NC_B41_2UL-Perf | RP-140428 | PCG-32 | RP-63 |
| 2472 | 693.32 | **LTE Advanced intra-band non-contiguous Carrier Aggregation in Band 4 for 2UL** | 396d? | 2013-06-19 A | 2014-12-15 A | 100% | 2013-06-19 | 2014-09-12 | 327d? |  | R4 | 9448h | 9448h | LTE_CA_NC_B4_2UL | 31 | T-Mobile USA | nelson.ueng@t-mobile.com | Rel-12 | 60 | Issam | CA | LTE_CA_NC_B4_2UL |  |  |  |
| 2473 | 693.32.1 | Core part:LTE Advanced intra-band non-contiguous Carrier Aggregation in Band 4 for 2UL | 393d? | 2013-06-19 A | 2014-12-15 A | 100% | 2013-06-19 | 2014-09-12 | 327d? | finish no earlier than 2014-12-15 | R4 | 3144h | 3144h | LTE_CA_NC_B4_2UL-Core | 31 | T-Mobile USA | nelson.ueng@t-mobile.com | Rel-12 | 60 | Issam | CA | LTE_CA_NC_B4_2UL-Core | RP-141732 |  |  |
| 2474 | 693.32.2 | Perf. part:LTE Advanced intra-band non-contiguous Carrier Aggregation in Band 4 for 2UL | 392d? | 2013-06-25 A | 2014-12-15 A | 100% | 2013-06-20 | 2014-09-12 | 326d? | finish no earlier than 2014-12-15 | R4 | 3136h | 3136h | LTE_CA_NC_B4_2UL-Perf | 31 | T-Mobile USA | nelson.ueng@t-mobile.com | Rel-12 | 60 | Issam | CA | LTE_CA_NC_B4_2UL-Perf | RP-141732 |  |  |
| 2475 | 693.33 | **LTE Advanced intra-band contiguous Carrier Aggregation in Band 23** | 127d? | 2013-06-18 A | 2013-12-06 A | 100% | 2013-06-18 | 2013-12-06 | 127d? |  | R4 | 3032h | 3032h | LTE_CA_C_B23 | 31 | Dish Network | mariam.sorond@dish.com, johny.kim@dish.com | Rel-12 | 60 | Issam | CA | LTE_CA_C_B23 |  |  |  |
| 2476 | 693.33.1 | Core part: LTE Advanced intra-band contiguous Carrier Aggregation in Band 23 | 126d? | 2013-06-18 A | 2013-12-06 A | 100% | 2013-06-18 | 2013-12-06 | 126d? | finish no earlier than 2013-12-06 | R4 | 1008h | 1008h | LTE_CA_C_B23-Core | 31 | Dish Network | mariam.sorond@dish.com, johny.kim@dish.com | Rel-12 | 60 | Issam | CA | LTE_CA_C_B23-Core | RP-131565 |  |  |
| 2477 | 693.33.2 | Perf. part: LTE Advanced intra-band contiguous Carrier Aggregation in Band 23 | 126d? | 2013-06-18 A | 2013-12-06 A | 100% | 2013-06-18 | 2013-12-06 | 126d? | finish no earlier than 2013-12-06 | R4 | 1008h | 1008h | LTE_CA_C_B23-Perf | 31 | Dish Network | mariam.sorond@dish.com, johny.kim@dish.com | Rel-12 | 60 | Issam | CA | LTE_CA_C_B23-Perf | RP-131566 |  |  |
| 2478 | 693.34 | **LTE Advanced intra-band non-contiguous Carrier Aggregation in Band 23** | 263d? | 2013-06-18 A | 2014-06-13 A | 100% | 2013-06-18 | 2014-06-13 | 263d? |  | R4 | 5216h | 5216h | LTE_CA_NC_B23 | 31 | Dish Network | mariam.sorond@dish.com, johny.kim@dish.com | Rel-12 | 60 | Issam | CA | LTE_CA_NC_B23 |  |  |  |
| 2479 | 693.34.1 | Core part:LTE Advanced intra-band non-contiguous Carrier Aggregation in Band 23 | 126d? | 2013-06-18 A | 2013-12-06 A | 100% | 2013-06-18 | 2013-12-06 | 126d? | finish no earlier than 2013-12-06 | R4 | 1008h | 1008h | LTE_CA_NC_B23-Core | 31 | Dish Network | mariam.sorond@dish.com, johny.kim@dish.com | Rel-12 | 60 | Issam | CA | LTE_CA_NC_B23-Core | RP-131577 |  |  |
| 2480 | 693.34.2 | Perf. part:LTE Advanced intra-band non-contiguous Carrier Aggregation in Band 23 | 263d? | 2013-06-18 A | 2014-06-13 A | 100% | 2013-06-18 | 2014-06-13 | 263d? | finish no earlier than 2014-06-13 | R4 | 2104h | 2104h | LTE_CA_NC_B23-Perf | 31 | Dish Network | mariam.sorond@dish.com, johny.kim@dish.com | Rel-12 | 60 | Issam | CA | LTE_CA_NC_B23-Perf | RP-140569 |  |  |
| 2481 | 693.35 | **LTE Advanced inter-band Carrier Aggregation of Band 12 and Band 25** | 127d? | 2013-06-18 A | 2013-12-06 A | 100% | 2013-06-18 | 2013-12-06 | 127d? |  | R4 | 3032h | 3032h | LTE_CA_B12_B25 | 31 | US Cellular | sebastian.thalanany@uscellular.com | Rel-12 | 60 | Issam | CA | LTE_CA_B12_B25 |  |  |  |
| 2482 | 693.35.1 | Core part:LTE Advanced inter-band Carrier Aggregation of Band 12 and Band 25 | 126d? | 2013-06-18 A | 2013-12-06 A | 100% | 2013-06-18 | 2013-12-06 | 126d? | finish no earlier than 2013-12-06 | R4 | 1008h | 1008h | LTE_CA_B12_B25-Core | 31 | US Cellular | sebastian.thalanany@uscellular.com | Rel-12 | 60 | Issam | CA | LTE_CA_B12_B25-Core | RP-131705 |  |  |
| 2483 | 693.35.2 | Perf. part:LTE Advanced inter-band Carrier Aggregation of Band 12 and Band 25 | 126d? | 2013-06-19 A | 2013-12-06 A | 100% | 2013-06-19 | 2013-12-06 | 126d? | finish no earlier than 2013-12-06 | R4 | 1008h | 1008h | LTE_CA_B12_B25-Perf | 31 | US Cellular | sebastian.thalanany@uscellular.com | Rel-12 | 60 | Issam | CA | LTE_CA_B12_B25-Perf | RP-131706 |  |  |
| 2484 | 693.36 | **LTE Advanced inter-band Carrier Aggregation of Band 1 and Band 18 - Additional bandwidth combination set** | 61d? | 2013-06-18 A | 2013-09-06 A | 100% | 2013-06-18 | 2013-09-06 | 61d? |  | R4 | 1464h | 1464h | LTE_CA_B1_B18_BWset | 31 | KDDI | Masaaki Obara (ms-obara@kddi.com) | Rel-12 | 60 | Issam | CA | LTE_CA_B1_B18_BWset |  |  |  |
| 2485 | 693.36.1 | Core part:LTE Advanced inter-band Carrier Aggregation of Band 1 and Band 18 - Additional bandwidth combination set | 61d? | 2013-06-18 A | 2013-09-06 A | 100% | 2013-06-18 | 2013-09-06 | 61d? | finish no earlier than 2013-09-06 | R4 | 488h | 488h | LTE_CA_B1_B18_BWset-Core | 31 | KDDI | Masaaki Obara (ms-obara@kddi.com) | Rel-12 | 60 | Issam | CA | LTE_CA_B1_B18_BWset-Core | RP-131003 |  |  |
| 2486 | 693.36.2 | Perf. part:LTE Advanced inter-band Carrier Aggregation of Band 1 and Band 18 - Additional bandwidth combination set | 61d? | 2013-06-18 A | 2013-09-06 A | 100% | 2013-06-18 | 2013-09-06 | 61d? | finish no earlier than 2013-09-06 | R4 | 488h | 488h | LTE_CA_B1_B18_BWset-Perf | 31 | KDDI | Masaaki Obara (ms-obara@kddi.com) | Rel-12 | 60 | Issam | CA | LTE_CA_B1_B18_BWset-Perf | RP-131004 |  |  |
| 2487 | 693.37 | **LTE Advanced inter-band Carrier Aggregation of Band 2 and Band 5** | 61d? | 2013-06-18 A | 2013-09-06 A | 100% | 2013-06-18 | 2013-09-06 | 61d? |  | R4 | 1464h | 1464h | LTE_CA_B2_B5 | 31 | AT&T | marc.grant@att.com | Rel-12 | 60 | Issam | CA | LTE_CA_B2_B5 |  |  |  |
| 2488 | 693.37.1 | Core part:LTE Advanced inter-band Carrier Aggregation of Band 2 and Band 5 | 61d? | 2013-06-18 A | 2013-09-06 A | 100% | 2013-06-18 | 2013-09-06 | 61d? | finish no earlier than 2013-09-06 | R4 | 488h | 488h | LTE_CA_B2_B5-Core | 31 | AT&T | marc.grant@att.com | Rel-12 | 60 | Issam | CA | LTE_CA_B2_B5-Core | RP-131009 |  |  |
| 2489 | 693.37.2 | Perf. part:LTE Advanced inter-band Carrier Aggregation of Band 2 and Band 5 | 61d? | 2013-06-18 A | 2013-09-06 A | 100% | 2013-06-18 | 2013-09-06 | 61d? | finish no earlier than 2013-12-06 | R4 | 488h | 488h | LTE_CA_B2_B5-Perf | 31 | AT&T | marc.grant@att.com | Rel-12 | 60 | Issam | CA | LTE_CA_B2_B5-Perf | RP-131010 |  |  |
| 2490 | 693.38 | **LTE Advanced 3 Band Carrier Aggregation (3DL/1UL) of Band 2, Band 5 and Band 30** | 329d? | 2013-06-18 A | 2014-09-12 A | 100% | 2013-06-18 | 2014-09-12 | 328d? |  | R4 | 7872h | 7872h | LTE_CA_B2_B5_B30 | 31 | AT&T | marc.grant@att.com | Rel-12 | 60 | Issam | CA | LTE_CA_B2_B5_B30 |  |  |  |
| 2491 | 693.38.1 | Core part:LTE Advanced 3 Band Carrier Aggregation (3DL/1UL) of Band 2, Band 5 and Band 30 | 328d? | 2013-06-18 A | 2014-09-12 A | 100% | 2013-06-18 | 2014-09-12 | 328d? | finish no earlier than 2014-09-12 | R4 | 2624h | 2624h | LTE_CA_B2_B5_B30-Core | 31 | AT&T | marc.grant@att.com | Rel-12 | 60 | Issam | CA | LTE_CA_B2_B5_B30-Core | RP-141084 |  |  |
| 2492 | 693.38.2 | Perf. part:LTE Advanced 3 Band Carrier Aggregation (3DL/1UL) of Band 2, Band 5 and Band 30 | 327d? | 2013-06-18 A | 2014-09-12 A | 100% | 2013-06-18 | 2014-09-12 | 327d? | finish no earlier than 2014-09-12 | R4 | 2616h | 2616h | LTE_CA_B2_B5_B30-Perf | 31 | AT&T | marc.grant@att.com | Rel-12 | 60 | Issam | CA | LTE_CA_B2_B5_B30-Perf | RP-141084 |  |  |

Notes:
- 2467: Intra-band non-contig. CA 2DL / Impacted TSs and TRs: LTE
- 2468: ; WID: RP-142043->RP-141962; Stat Rep: RP-141084->RP-141732 / Impacted TSs and TRs: 36.101, 36.104, 36.133, 36.306, 36.331, New TR 36.833-4
- 2469: Intra-band NC 2UL / Impacted TSs and TRs: LTE
- 2470: RP#63 stopped (5% complete). Reason: Market conditions have eliminated the need for this feature, at least for the foreseeable future / Impacted TSs and TRs: 36.101, 36.104, 36.133, new TR 36.833-3-41
- 2471: RP#63 stopped (0% complete). / Impacted TSs and TRs: 36.101, 36.104, 36.133, 36.141, 36.307
- 2472: Intra-band non-contig. CA 2DL / Impacted TSs and TRs: LTE
- 2473: ; WID: RP-142043->RP-141784; Stat Rep: RP-141084->RP-141732 / Impacted TSs and TRs: 36.101, 36.104, 36.133, new TR 36.833-4-04
- 2474: ; WID: RP-142043->RP-141784; Stat Rep: RP-141084->RP-141732 / Impacted TSs and TRs: 36.101, 36.104, 36.133, 36.141, 36.307
- 2475: Intra-band C CA / Impacted TSs and TRs: LTE
- 2476: RP#62 completed / Impacted TSs and TRs: 36.101, 36.104, 36.133, new TR 36.833-1-23 [instead of 36.864]
- 2477: RP#62 completed / Impacted TSs and TRs: 36.141, 36.307
- 2478: Intra-band non-contig. CA 2DL / Impacted TSs and TRs: LTE
- 2479: RP#62 completed / Impacted TSs and TRs: 36.101, 36.104, 36.133, new TR 36.833-2-23
- 2480: RP#64 completed. TR 36.833-2-23v200 for Approval / Impacted TSs and TRs: 36.101, 36.133, 36.141, 36.307, new TR 36.833-2-23
- 2481: Inter-band 1UL/2DL / Impacted TSs and TRs: LTE
- 2482: RP#62 completed / Impacted TSs and TRs: 36.101, 36.104, 36.133, new generic TR 36.851
- 2483: RP#62 completed / Impacted TSs and TRs: 36.141, 36.307
- 2484: Inter-band 1UL/2DL / Impacted TSs and TRs: LTE
- 2485: RP#61 completed / Impacted TSs and TRs: 36.101, new generic TR 36.851
- 2486: RP#61 completed / Impacted TSs and TRs: 36.307
- 2487: Inter-band 2DL / Impacted TSs and TRs: LTE
- 2488: RP#61 completed / Impacted TSs and TRs: 36.101, 36.104, 36.307
- 2489: RP#61 completed / Impacted TSs and TRs: 36.101, 36.104, 36.133, 36.141, 36.307
- 2490: Inter-band 3DL / Impacted TSs and TRs: LTE
- 2491: RP#65 completed. TR 36.853v200 for Approval / Impacted TSs and TRs: 36.101, 36.104, 36.133, 36.141, 36.307, new generic TR 36.853 (3 Band CA with 1UL)
- 2492: RP#65 completed / Impacted TSs and TRs: 36.101, 36.104, 36.133, 36.141, 36.307

| ID | WBS | Task | Duration | Start | Finish | Complete | Baseline start | Baseline finish | Baseline duration | Constraint | Resources | Work | Actual work | Acronym | PCG approved | WI rapporteur name | WI rapporteur e-mail | Release | TSG approved | MCC resp | PCG stopped | TSG stopped | Special Focus Doc | Acronym_3GU_Export | Status Report |
| --- | --- | --- | --- | --- | --- | --- | --- | --- | --- | --- | --- | --- | --- | --- | --- | --- | --- | --- | --- | --- | --- | --- | --- | --- | --- |
| 2493 | 693.39 | **Deleted -LTE Advanced 3 Band Carrier Aggregation (3DL/1UL) of Band 2, Band 17 and Band 30** | 127d? | 2013-06-18 A | 2013-12-06 A | 100% | 2013-06-18 | 2013-12-06 | 127d? |  | R4 | 3024h | 3024h | LTE_CA_B2_B17_B30 | 31 | AT&T | marc.grant@att.com | Rel-12 | 60 | Issam | PCG-32 | RP-62 | CA | LTE_CA_B2_B17_B30 |  |
| 2494 | 693.39.1 | Deleted - Core part:LTE Advanced 3 Band Carrier Aggregation (3DL/1UL) of Band 2, Band 17 and Band 30 | 126d? | 2013-06-18 A | 2013-12-06 A | 100% | 2013-06-18 | 2013-12-06 | 126d? | finish no earlier than 2014-06-13 | R4 | 1008h | 1008h | LTE_CA_B2_B17_B30-Core | 31 | AT&T | marc.grant@att.com | Rel-12 | 60 | Issam | PCG-32 | RP-62 | CA | LTE_CA_B2_B17_B30-Core | RP-131590 |
| 2495 | 693.39.2 | Deleted - Perf. part:LTE Advanced 3 Band Carrier Aggregation (3DL/1UL) of Band 2, Band 17 and Band 30 | 125d? | 2013-06-19 A | 2013-12-06 A | 100% | 2013-06-19 | 2013-12-06 | 125d? | finish no earlier than 2014-09-12 | R4 | 1000h | 1000h | LTE_CA_B2_B17_B30-Perf | 31 | AT&T | marc.grant@att.com | Rel-12 | 60 | Issam | PCG-32 | RP-62 | CA | LTE_CA_B2_B17_B30-Perf | RP-131591 |
| 2496 | 693.40 | **LTE Advanced 3 Band Carrier Aggregation (3DL/1UL) of Band 2, Band 29 and Band 30** | 328d? | 2013-06-19 A | 2014-09-12 A | 100% | 2013-06-19 | 2014-09-12 | 327d? |  | R4 | 7856h | 7856h | LTE_CA_B2_B29_B30 | 31 | AT&T | marc.grant@att.com | Rel-12 | 60 | Issam |  |  | CA | LTE_CA_B2_B29_B30 |  |
| 2497 | 693.40.1 | Core part:LTE Advanced 3 Band Carrier Aggregation (3DL/1UL) of Band 2, Band 29 and Band 30 | 327d? | 2013-06-19 A | 2014-09-12 A | 100% | 2013-06-19 | 2014-06-13 | 262d? | finish no earlier than 2014-09-12 | R4 | 2616h | 2616h | LTE_CA_B2_B29_B30-Core | 31 | AT&T | marc.grant@att.com | Rel-12 | 60 | Issam |  |  | CA | LTE_CA_B2_B29_B30-Core | RP-141084 |
| 2498 | 693.40.2 | Perf. part:LTE Advanced 3 Band Carrier Aggregation (3DL/1UL) of Band 2, Band 29 and Band 30 | 327d? | 2013-06-19 A | 2014-09-12 A | 100% | 2013-06-19 | 2014-09-12 | 327d? | finish no earlier than 2014-09-12 | R4 | 2616h | 2616h | LTE_CA_B2_B29_B30-Perf | 31 | AT&T | marc.grant@att.com | Rel-12 | 60 | Issam |  |  | CA | LTE_CA_B2_B29_B30-Perf | RP-141084 |
| 2499 | 693.41 | **LTE Advanced 3 Band Carrier Aggregation (3DL/1UL) of Band 4, Band 5 and Band 30** | 331d? | 2013-06-14 A | 2014-09-12 A | 100% | 2013-06-14 | 2014-09-12 | 330d? |  | R4 | 7904h | 7904h | LTE_CA_B4_B5_B30 | 31 | AT&T | marc.grant@att.com | Rel-12 | 60 | Issam |  |  | CA | LTE_CA_B4_B5_B30 |  |
| 2500 | 693.41.1 | Core part:LTE Advanced 3 Band Carrier Aggregation (3DL/1UL) of Band 4, Band 5 and Band 30 | 330d? | 2013-06-14 A | 2014-09-12 A | 100% | 2013-06-14 | 2014-09-12 | 330d? | finish no earlier than 2014-09-12 | R4 | 2640h | 2640h | LTE_CA_B4_B5_B30-Core | 31 | AT&T | marc.grant@att.com | Rel-12 | 60 | Issam |  |  | CA | LTE_CA_B4_B5_B30-Core | RP-141084 |
| 2501 | 693.41.2 | Perf. part:LTE Advanced 3 Band Carrier Aggregation (3DL/1UL) of Band 4, Band 5 and Band 30 | 327d? | 2013-06-19 A | 2014-09-12 A | 100% | 2013-06-19 | 2014-09-12 | 327d? | finish no earlier than 2014-09-12 | R4 | 2616h | 2616h | LTE_CA_B4_B5_B30-Perf | 31 | AT&T | marc.grant@att.com | Rel-12 | 60 | Issam |  |  | CA | LTE_CA_B4_B5_B30-Perf | RP-141084 |
| 2502 | 693.42 | **Deleted -LTE Advanced 3 Band Carrier Aggregation (3DL/1UL) of Band 4, Band 17 and Band 30** | 127d? | 2013-06-18 A | 2013-12-06 A | 100% | 2013-06-18 | 2013-12-06 | 127d? |  | R4 | 3040h | 3040h | LTE_CA_B4_B17_B30 | 31 | AT&T | marc.grant@att.com | Rel-12 | 60 | Issam | PCG-32 | RP-62 | CA | LTE_CA_B4_B17_B30 |  |
| 2503 | 693.42.1 | Deleted - Core part:LTE Advanced 3 Band Carrier Aggregation (3DL/1UL) of Band 4, Band 17 and Band 30 | 127d? | 2013-06-18 A | 2013-12-06 A | 100% | 2013-06-18 | 2013-12-06 | 127d? | finish no earlier than 2013-12-06 | R4 | 1016h | 1016h | LTE_CA_B4_B17_B30-Core | 31 | AT&T | marc.grant@att.com | Rel-12 | 60 | Issam | PCG-32 | RP-62 | CA | LTE_CA_B4_B17_B30-Core | RP-131598 |
| 2504 | 693.42.2 | Deleted - Perf. part:LTE Advanced 3 Band Carrier Aggregation (3DL/1UL) of Band 4, Band 17 and Band 30 | 126d? | 2013-06-19 A | 2013-12-06 A | 100% | 2013-06-19 | 2013-12-06 | 126d? | finish no earlier than 2013-12-06 | R4 | 1008h | 1008h | LTE_CA_B4_B17_B30-Perf | 31 | AT&T | marc.grant@att.com | Rel-12 | 60 | Issam | PCG-32 | RP-62 | CA | LTE_CA_B4_B17_B30-Perf | RP-131599 |
| 2505 | 693.43 | **LTE Advanced 3 Band Carrier Aggregation (3DL/1UL) of Band 4, Band 29 and Band 30** | 331d? | 2013-06-14 A | 2014-09-12 A | 100% | 2013-06-14 | 2014-09-12 | 330d? |  | R4 | 7904h | 7904h | LTE_CA_B4_B29_B30 | 31 | AT&T | marc.grant@att.com | Rel-12 | 60 | Issam |  |  | CA | LTE_CA_B4_B29_B30 |  |
| 2506 | 693.43.1 | Core part:LTE Advanced 3 Band Carrier Aggregation (3DL/1UL) of Band 4, Band 29 and Band 30 | 330d? | 2013-06-14 A | 2014-09-12 A | 100% | 2013-06-14 | 2014-09-12 | 330d? | finish no earlier than 2014-09-12 | R4 | 2640h | 2640h | LTE_CA_B4_B29_B30-Core | 31 | AT&T | marc.grant@att.com | Rel-12 | 60 | Issam |  |  | CA | LTE_CA_B4_B29_B30-Core | RP-141084 |
| 2507 | 693.43.2 | Perf. part:LTE Advanced 3 Band Carrier Aggregation (3DL/1UL) of Band 4, Band 29 and Band 30 | 327d? | 2013-06-19 A | 2014-09-12 A | 100% | 2013-06-19 | 2014-09-12 | 327d? | finish no earlier than 2014-09-12 | R4 | 2616h | 2616h | LTE_CA_B4_B29_B30-Perf | 31 | AT&T | marc.grant@att.com | Rel-12 | 60 | Issam |  |  | CA | LTE_CA_B4_B29_B30-Perf | RP-141084 |
| 2508 | 693.44 | **LTE Advanced 3 Band Carrier Aggregation (3DL/1UL) of Band 2, Band 4 and Band 13** | 331d? | 2013-06-14 A | 2014-09-12 A | 100% | 2013-06-14 | 2014-09-12 | 330d? |  | R4 | 7904h | 7904h | LTE_CA_B2_B4_B13 | 31 | Verizon | zheng.zhao@verizonwireless.com | Rel-12 | 60 | Issam |  |  | CA | LTE_CA_B2_B4_B13 |  |
| 2509 | 693.44.1 | Core part:LTE Advanced 3 Band Carrier Aggregation (3DL/1UL) of Band 2, Band 4 and Band 13 | 330d? | 2013-06-14 A | 2014-09-12 A | 100% | 2013-06-14 | 2014-09-12 | 330d? | finish no earlier than 2014-09-12 | R4 | 2640h | 2640h | LTE_CA_B2_B4_B13-Core | 31 | Verizon | zheng.zhao@verizonwireless.com | Rel-12 | 60 | Issam |  |  | CA | LTE_CA_B2_B4_B13-Core | RP-141084 |
| 2510 | 693.44.2 | Perf. part:LTE Advanced 3 Band Carrier Aggregation (3DL/1UL) of Band 2, Band 4 and Band 13 | 327d? | 2013-06-19 A | 2014-09-12 A | 100% | 2013-06-19 | 2014-09-12 | 327d? | finish no earlier than 2014-09-12 | R4 | 2616h | 2616h | LTE_CA_B2_B4_B13-Perf | 31 | Verizon | zheng.zhao@verizonwireless.com | Rel-12 | 60 | Issam |  |  | CA | LTE_CA_B2_B4_B13-Perf | RP-141084 |
| 2511 | 693.45 | **LTE Advanced 3 Band Carrier Aggregation (3DL/1UL) of Band 2, Band 2 and Band 13** | 329d? | 2013-06-18 A | 2014-09-12 A | 100% | 2013-06-18 | 2014-09-12 | 328d? |  | R4 | 7864h | 7864h | LTE_CA_B2_B2_B13 | 31 | Verizon | zheng.zhao@verizonwireless.com | Rel-12 | 60 | Issam |  |  | CA | LTE_CA_B2_B2_B13 |  |
| 2512 | 693.45.1 | Core part:LTE Advanced 3 Band Carrier Aggregation (3DL/1UL) of Band 2, Band 2 and Band 13 | 327d? | 2013-06-18 A | 2014-09-12 A | 100% | 2013-06-18 | 2014-09-12 | 327d? | finish no earlier than 2014-09-12 | R4 | 2616h | 2616h | LTE_CA_B2_B2_B13-Core | 31 | Verizon | zheng.zhao@verizonwireless.com | Rel-12 | 60 | Issam |  |  | CA | LTE_CA_B2_B2_B13-Core | RP-141084 |
| 2513 | 693.45.2 | Perf. part:LTE Advanced 3 Band Carrier Aggregation (3DL/1UL) of Band 2, Band 2 and Band 13 | 327d? | 2013-06-19 A | 2014-09-12 A | 100% | 2013-06-19 | 2014-09-12 | 327d? | finish no earlier than 2014-09-12 | R4 | 2616h | 2616h | LTE_CA_B2_B2_B13-Perf | 31 | Verizon | zheng.zhao@verizonwireless.com | Rel-12 | 60 | Issam |  |  | CA | LTE_CA_B2_B2_B13-Perf | RP-141084 |
| 2514 | 693.46 | **LTE Advanced 3 Band Carrier Aggregation (3DL/1UL) of Band 4, Band 4 and Band 13** | 331d? | 2013-06-14 A | 2014-09-12 A | 100% | 2013-06-14 | 2014-09-12 | 330d? |  | R4 | 7928h | 7928h | LTE_CA_B4_B4_B13 | 31 | Verizon | zheng.zhao@verizonwireless.com | Rel-12 | 60 | Issam |  |  | CA | LTE_CA_B4_B4_B13 |  |
| 2515 | 693.46.1 | Core part:LTE Advanced 3 Band Carrier Aggregation (3DL/1UL) of Band 4, Band 4 and Band 13 | 330d? | 2013-06-14 A | 2014-09-12 A | 100% | 2013-06-14 | 2014-09-12 | 330d? | finish no earlier than 2014-09-12 | R4 | 2640h | 2640h | LTE_CA_B4_B4_B13-Core | 31 | Verizon | zheng.zhao@verizonwireless.com | Rel-12 | 60 | Issam |  |  | CA | LTE_CA_B4_B4_B13-Core | RP-141084 |
| 2516 | 693.46.2 | Perf. part:LTE Advanced 3 Band Carrier Aggregation (3DL/1UL) of Band 4, Band 4 and Band 13 | 330d? | 2013-06-14 A | 2014-09-12 A | 100% | 2013-06-14 | 2014-09-12 | 330d? | finish no earlier than 2014-09-12 | R4 | 2640h | 2640h | LTE_CA_B4_B4_B13-Perf | 31 | Verizon | zheng.zhao@verizonwireless.com | Rel-12 | 60 | Issam |  |  | CA | LTE_CA_B4_B4_B13-Perf | RP-141084 |

Notes:
- 2493: Inter-band 3DL / Impacted TSs and TRs: LTE
- 2494: RP#62 stopped (25% complete) following RP-131652 discussion / Impacted TSs and TRs: 36.101, 36.104, 36.133, 36.141, 36.307, new generic TR 36.853 (3 Band CA with 1UL)
- 2495: RP#62 stopped (25% complete) following RP-131652 discussion / Impacted TSs and TRs: 36.101, 36.104, 36.133, 36.141, 36.307
- 2496: Inter-band 3DL / Impacted TSs and TRs: LTE
- 2497: RP#65 completed. Updated WID RP-131697=>RP-141212 / Impacted TSs and TRs: 36.101, 36.104, 36.133, 36.141, 36.307, new generic TR 36.853 (3 Band CA with 1UL)
- 2498: RP#65 completed / Impacted TSs and TRs: 36.101, 36.104, 36.133, 36.141, 36.307
- 2499: Inter-band CA 3DL / Impacted TSs and TRs: LTE
- 2500: RP#65 completed. Updated WID RP-131698=>RP-141213 / Impacted TSs and TRs: 36.101, 36.104, 36.133, 36.141, 36.307, new generic TR 36.853 (3 Band CA with 1UL)
- 2501: RP#65 completed / Impacted TSs and TRs: 36.101, 36.104, 36.133, 36.141, 36.307
- 2502: Inter-band 3DL / Impacted TSs and TRs: LTE
- 2503: RP#62 stopped (25% complete) following RP-131653 discussion / Impacted TSs and TRs: 36.101, 36.104, 36.133, 36.141, 36.307, new generic TR 36.853 (3 Band CA with 1UL)
- 2504: RP#62 stopped (25% complete) following RP-131653 discussion / Impacted TSs and TRs: 36.101, 36.104, 36.133, 36.141, 36.307
- 2505: Inter-band CA 3DL / Impacted TSs and TRs: LTE
- 2506: RP#65 completed. Updated WID RP-131699=>RP- 141215 / Impacted TSs and TRs: 36.101, 36.104, 36.133, 36.141, 36.307, new generic TR 36.853 (3 Band CA with 1UL)
- 2507: RP#65 completed / Impacted TSs and TRs: 36.101, 36.104, 36.133, 36.141, 36.307
- 2508: Inter-band CA 3DL / Impacted TSs and TRs: LTE
- 2509: RP#65 completed. Updated RP-131684=>RP-141434 / Impacted TSs and TRs: 36.101, 36.104, 36.133, new generic TR 36.853 (3 Band CA with 1UL)
- 2510: RP#65 completed / Impacted TSs and TRs: 36.101, 36.133, 36.141, 36.307
- 2511: Inter-band CA 3DL / Impacted TSs and TRs: LTE
- 2512: RP#65 completed. Updated WID RP-131682=>RP-141435 / Impacted TSs and TRs: 36.101, 36.104, 36.133, new generic TR 36.853 (3 Band CA with 1UL)
- 2513: RP#65 completed / Impacted TSs and TRs: 36.101, 36.133, 36.141, 36.307
- 2514: Inter-band CA 3DL / Impacted TSs and TRs: LTE
- 2515: RP#65 completed. Updated WID RP-131683=>RP-141433 / Impacted TSs and TRs: 36.101, 36.104, 36.133, new generic TR 36.853 (3 Band CA with 1UL)
- 2516: RP#65 completed / Impacted TSs and TRs: 36.101, 36.133, 36.141, 36.307

| ID | WBS | Task | Duration | Start | Finish | Complete | Baseline start | Baseline finish | Baseline duration | Constraint | Resources | Work | Actual work | Acronym | PCG approved | Impacted TSs and TRs | WI rapporteur name | WI rapporteur e-mail | Release | TSG approved | MCC resp | Special Focus Doc | Acronym_3GU_Export | Status Report |
| --- | --- | --- | --- | --- | --- | --- | --- | --- | --- | --- | --- | --- | --- | --- | --- | --- | --- | --- | --- | --- | --- | --- | --- | --- |
| 2517 | 693.47 | **LTE Advanced inter-band Carrier Aggregation of Band 7 and Band 28** | 66d? | 2013-09-09 A | 2013-12-06 A | 100% | 2013-09-09 | 2013-12-06 | 66d? |  | R4 | 1584h | 1584h | LTE_CA_B7_B28 | 31 | LTE | Huawei | Liehai Liu (liuliehai@huawei.com) | Rel-12 | 61 | Issam | CA | LTE_CA_B7_B28 |  |
| 2518 | 693.47.1 | Core part:LTE Advanced inter-band Carrier Aggregation of Band 7 and Band 28 | 66d? | 2013-09-09 A | 2013-12-06 A | 100% | 2013-09-09 | 2013-12-06 | 66d? | finish no earlier than 2013-12-06 | R4 | 528h | 528h | LTE_CA_B7_B28-Core | 31 | 36.101, 36.104, 36.307 | Huawei | Liehai Liu (liuliehai@huawei.com) | Rel-12 | 61 | Issam | CA | LTE_CA_B7_B28-Core | RP-131545 |
| 2519 | 693.47.2 | Perf. part:LTE Advanced inter-band Carrier Aggregation of Band 7 and Band 28 | 66d? | 2013-09-09 A | 2013-12-06 A | 100% | 2013-09-09 | 2013-12-06 | 66d? | finish no earlier than 2013-12-06 | R4 | 528h | 528h | LTE_CA_B7_B28-Perf | 31 | 36.141 | Huawei | Liehai Liu (liuliehai@huawei.com) | Rel-12 | 61 | Issam | CA | LTE_CA_B7_B28-Perf | RP-131546 |
| 2520 | 693.48 | **LTE Advanced inter-band Carrier Aggregation of Band 5 and Band 25** | 66d? | 2013-09-09 A | 2013-12-06 A | 100% | 2013-09-09 | 2013-12-06 | 66d? |  | R4 | 1584h | 1584h | LTE_CA_B5_B25 | 31 | LTE | U.S. Cellular | sebastian.thalanany@uscellular.com | Rel-12 | 61 | Issam | CA | LTE_CA_B5_B25 |  |
| 2521 | 693.48.1 | Core part:LTE Advanced inter-band Carrier Aggregation of Band 5 and Band 25 | 66d? | 2013-09-09 A | 2013-12-06 A | 100% | 2013-09-09 | 2013-12-06 | 66d? | finish no earlier than 2013-12-06 | R4 | 528h | 528h | LTE_CA_B5_B25-Core | 31 | 36.101, 36.104, 36.133, new generic TR 36.851 | U.S. Cellular | sebastian.thalanany@uscellular.com | Rel-12 | 61 | Issam | CA | LTE_CA_B5_B25-Core | RP-131543 |
| 2522 | 693.48.2 | Perf. part:LTE Advanced inter-band Carrier Aggregation of Band 5 and Band 25 | 66d? | 2013-09-09 A | 2013-12-06 A | 100% | 2013-09-09 | 2013-12-06 | 66d? | finish no earlier than 2013-12-06 | R4 | 528h | 528h | LTE_CA_B5_B25-Perf | 31 | 36.141, 36.307 | U.S. Cellular | sebastian.thalanany@uscellular.com | Rel-12 | 61 | Issam | CA | LTE_CA_B5_B25-Perf | RP-131705 |
| 2523 | 693.49 | **LTE Advanced inter-band Carrier Aggregation of Band 1 and Band 11** | 202d? | 2013-09-09 A | 2014-06-13 A | 100% | 2013-09-09 | 2014-06-13 | 202d? |  | R4 | 4848h | 4848h | LTE_CA_B1_B11 | 31 | LTE | SoftBank Mobile | kenichi.kihara@g.softbank.co.jp | Rel-12 | 61 | Issam | CA | LTE_CA_B1_B11 |  |
| 2524 | 693.49.1 | Core part:LTE Advanced inter-band Carrier Aggregation of Band 1 and Band 11 | 202d? | 2013-09-09 A | 2014-06-13 A | 100% | 2013-09-09 | 2014-06-13 | 202d? | finish no earlier than 2014-06-13 | R4 | 1616h | 1616h | LTE_CA_B1_B11-Core | 31 | 36.101, 36.104, new generic TR 36.851 | SoftBank Mobile | kenichi.kihara@g.softbank.co.jp | Rel-12 | 61 | Issam | CA | LTE_CA_B1_B11-Core | RP-140569 |
| 2525 | 693.49.2 | Perf. part:LTE Advanced inter-band Carrier Aggregation of Band 1 and Band 11 | 202d? | 2013-09-09 A | 2014-06-13 A | 100% | 2013-09-09 | 2014-06-13 | 202d? | finish no earlier than 2014-06-13 | R4 | 1616h | 1616h | LTE_CA_B1_B11-Perf | 31 | 36.141, 36.307 | SoftBank Mobile | kenichi.kihara@g.softbank.co.jp | Rel-12 | 61 | Issam | CA | LTE_CA_B1_B11-Perf | RP-140569 |
| 2526 | 693.50 | **LTE Advanced inter-band Carrier Aggregation of Band 8 and Band 11** | 268d? | 2013-09-09 A | 2014-09-12 A | 100% | 2013-09-09 | 2014-09-12 | 267d? |  | R4 | 6416h | 6416h | LTE_CA_B8_B11 | 31 | LTE | SoftBank Mobile | kenichi.kihara@g.softbank.co.jp | Rel-12 | 61 | Issam | CA | LTE_CA_B8_B11 |  |
| 2527 | 693.50.1 | Core part:LTE Advanced inter-band Carrier Aggregation of Band 8 and Band 11 | 267d? | 2013-09-09 A | 2014-09-12 A | 100% | 2013-09-09 | 2014-09-12 | 267d? | finish no earlier than 2014-09-12 | R4 | 2136h | 2136h | LTE_CA_B8_B11-Core | 31 | 36.101, 36.104, new generic TR 36.851 | SoftBank Mobile | kenichi.kihara@g.softbank.co.jp | Rel-12 | 61 | Issam | CA | LTE_CA_B8_B11-Core | RP-141084 |
| 2528 | 693.50.2 | Perf. part:LTE Advanced inter-band Carrier Aggregation of Band 8 and Band 11 | 267d? | 2013-09-09 A | 2014-09-12 A | 100% | 2013-09-09 | 2014-09-12 | 267d? | finish no earlier than 2014-09-12 | R4 | 2136h | 2136h | LTE_CA_B8_B11-Perf | 31 | 36.141, 36.307 | SoftBank Mobile | kenichi.kihara@g.softbank.co.jp | Rel-12 | 61 | Issam | CA | LTE_CA_B8_B11-Perf | RP-141084 |
| 2529 | 693.51 | **LTE Advanced inter-band Carrier Aggregation of Band 5 and Band 7** | 62d? | 2013-09-09 A | 2013-12-02 A | 100% | 2013-09-09 | 2013-12-02 | 62d? |  | R4 | 1488h | 1488h | LTE_CA_B5_B7 | 31 | LTE | LG Uplus | Yeonsang KOO (yskoo@lguplus.co.kr) | Rel-12 | 61 | Issam | CA | LTE_CA_B5_B7 |  |
| 2530 | 693.51.1 | Core part:LTE Advanced inter-band Carrier Aggregation of Band 5 and Band 7 | 62d? | 2013-09-09 A | 2013-12-02 A | 100% | 2013-09-09 | 2013-12-02 | 62d? | finish no earlier than 2013-12-02 | R4 | 496h | 496h | LTE_CA_B5_B7-Core | 31 | 36.101, 36.104, 36.133, new generic TR 36.851 | LG Uplus | Yeonsang KOO (yskoo@lguplus.co.kr) | Rel-12 | 61 | Issam | CA | LTE_CA_B5_B7-Core | RP-131541 |
| 2531 | 693.51.2 | Perf. part:LTE Advanced inter-band Carrier Aggregation of Band 5 and Band 7 | 62d? | 2013-09-09 A | 2013-12-02 A | 100% | 2013-09-09 | 2013-12-02 | 62d? | finish no earlier than 2013-12-02 | R4 | 496h | 496h | LTE_CA_B5_B7-Perf | 31 | 36.141, 36.307 | LG Uplus | Yeonsang KOO (yskoo@lguplus.co.kr) | Rel-12 | 61 | Issam | CA | LTE_CA_B5_B7-Perf | RP-131542 |
| 2532 | 693.52 | **LTE Advanced intra-band contiguous Carrier Aggregation in Band 41 for 3DL** | 400d? | 2013-09-09 A | 2015-03-15 A | 100% | 2013-09-09 | 2014-09-12 | 267d? |  | R4 | 8512h | 8512h | LTE_CA_C_B41_3DL | 31 | LTE | Alcatel-Lucent | man-hung.ng@alcatel-lucent.com | Rel-12 | 61 | Issam | CA | LTE_CA_C_B41_3DL |  |
| 2533 | 693.52.1 | Core part: LTE Advanced intra-band contiguous Carrier Aggregation in Band 41 for 3DL | 267d? | 2013-09-09 A | 2014-09-12 A | 100% | 2013-09-09 | 2014-09-12 | 267d? | finish no earlier than 2014-09-12 | R4 | 2136h | 2136h | LTE_CA_C_B41_3DL-Core | 31 | 36.101, 36.104, 36.133, 36.307, New TR 36.833-5-41 | Alcatel-Lucent | man-hung.ng@alcatel-lucent.com | Rel-12 | 61 | Issam | CA | LTE_CA_C_B41_3DL-Core | RP-141084 |
| 2534 | 693.52.2 | Perf. part: LTE Advanced intra-band contiguous Carrier Aggregation in Band 41 for 3DL | 397d? | 2013-09-09 A | 2015-03-15 A | 100% | 2013-09-09 | 2014-09-12 | 267d? | finish no earlier than 2015-03-15 | R4 | 3176h | 3176h | LTE_CA_C_B41_3DL-Perf | 31 | 36.141 | Alcatel-Lucent | man-hung.ng@alcatel-lucent.com | Rel-12 | 61 | Issam | CA | LTE_CA_C_B41_3DL-Perf | RP-150013 |
| 2535 | 693.53 | **LTE Advanced intra-band non-contiguous Carrier Aggregation in Band 2** | 202d? | 2013-09-09 A | 2014-06-13 A | 100% | 2013-09-09 | 2014-06-13 | 202d? |  | R4 | 4840h | 4840h | LTE_CA_NC_B2 | 31 | LTE | Ericsson | imadur.rahman@ericsson.com | Rel-12 | 61 | Issam | CA | LTE_CA_NC_B2 |  |
| 2536 | 693.53.1 | Core part:LTE Advanced intra-band non-contiguous Carrier Aggregation in Band 2 | 202d? | 2013-09-09 A | 2014-06-13 A | 100% | 2013-09-09 | 2014-06-13 | 202d? | finish no earlier than 2014-06-13 | R4 | 1616h | 1616h | LTE_CA_NC_B2-Core | 31 | 36.101, 36.104, 36.133, New TR 36.833-2-02 | Ericsson | imadur.rahman@ericsson.com | Rel-12 | 61 | Issam | CA | LTE_CA_NC_B2-Core | RP-140569 |
| 2537 | 693.53.2 | Perf. part:LTE Advanced intra-band non-contiguous Carrier Aggregation in Band 2 | 201d? | 2013-09-10 A | 2014-06-13 A | 100% | 2013-09-10 | 2014-06-13 | 201d? | finish no earlier than 2014-06-13 | R4 | 1608h | 1608h | LTE_CA_NC_B2-Perf | 31 | 36.141, 36.307 | Ericsson | imadur.rahman@ericsson.com | Rel-12 | 61 | Issam | CA | LTE_CA_NC_B2-Perf | RP-140569 |
| 2538 | 693.54 | **LTE Advanced inter-band Carrier Aggregation of Band 1 and Band 3** | 202d? | 2013-12-09 A | 2014-09-12 A | 100% | 2013-12-09 | 2014-09-12 | 201d? |  | R4 | 4832h | 4832h | LTE_CA_B1_B3 | 32 | LTE | China Unicom | Hao Chen (chenhao49@chinaunicom.cn) | Rel-12 | 62 | Issam | CA | LTE_CA_B1_B3 |  |
| 2539 | 693.54.1 | Core part:LTE Advanced inter-band Carrier Aggregation of Band 1 and Band 3 | 201d? | 2013-12-09 A | 2014-09-12 A | 100% | 2013-12-09 | 2014-09-12 | 201d? | finish no earlier than 2014-09-12 | R4 | 1608h | 1608h | LTE_CA_B1_B3-Core | 32 | 36.101, 36.104, 36.133, new generic TR 36.851 | China Unicom | Hao Chen (chenhao49@chinaunicom.cn) | Rel-12 | 62 | Issam | CA | LTE_CA_B1_B3-Core | RP-141084 |
| 2540 | 693.54.2 | Perf. part:LTE Advanced inter-band Carrier Aggregation of Band 1 and Band 3 | 201d? | 2013-12-09 A | 2014-09-12 A | 100% | 2013-12-09 | 2014-09-12 | 201d? | finish no earlier than 2014-09-12 | R4 | 1608h | 1608h | LTE_CA_B1_B3-Perf | 32 | 36.141, 36.307 | China Unicom | Hao Chen (chenhao49@chinaunicom.cn) | Rel-12 | 62 | Issam | CA | LTE_CA_B1_B3-Perf | RP-141084 |

Notes:
- 2517: Inter-band 1UL/2DL
- 2518: RP#62 completed
- 2519: RP#62 completed
- 2520: Inter-band 1UL/2DL
- 2521: RP#62 completed
- 2522: RP#62 completed
- 2523: Inter-band CA 2DL
- 2524: RP#64 completed
- 2525: RP#64 completed
- 2526: Inter-band CA 2DL
- 2527: RP#65 completed
- 2528: RP#65 completed
- 2529: Inter-band 1UL/2DL
- 2530: RP#62 completed
- 2531: RP#62 completed
- 2532: Intra-band contig. CA 3DL
- 2533: RP#65 completed
- 2534: ; WID: RP-142043->RP-142017; Stat Rep: RP-141084->RP-141732 1st Apr 15: Compl:70%->100% 1st Apr 15: Stat Rep: RP-141732->RP-150013
- 2535: Intra-band non-contig. CA 2DL
- 2536: RP#64 completed. TR 36.833-2-02v100 for 1-step Approval
- 2537: RP#64 completed
- 2538: Inter-band CA 2DL
- 2539: RP#65 completed
- 2540: RP#65 completed

| ID | WBS | Task | Duration | Start | Finish | Complete | Baseline start | Baseline finish | Baseline duration | Constraint | Resources | Work | Actual work | Acronym | PCG approved | WI rapporteur name | WI rapporteur e-mail | Release | TSG approved | MCC resp | Special Focus Doc | Acronym_3GU_Export | Status Report |
| --- | --- | --- | --- | --- | --- | --- | --- | --- | --- | --- | --- | --- | --- | --- | --- | --- | --- | --- | --- | --- | --- | --- | --- |
| 2541 | 693.55 | **LTE Advanced inter-band Carrier Aggregation of Band 1 and Band 28** | 270d? | 2013-12-09 A | 2014-12-15 A | 100% | 2013-12-09 | 2014-09-12 | 201d? |  | R4 | 6432h | 6432h | LTE_CA_B1_B28 | 32 | KDDI | Masaaki Obara (ms-obara@kddi.com) | Rel-12 | 62 | Issam | CA | LTE_CA_B1_B28 |  |
| 2542 | 693.55.1 | Core part:LTE Advanced inter-band Carrier Aggregation of Band 1 and Band 28 | 267d? | 2013-12-09 A | 2014-12-15 A | 100% | 2013-12-09 | 2014-09-12 | 201d? | finish no earlier than 2014-12-15 | R4 | 2136h | 2136h | LTE_CA_B1_B28-Core | 32 | KDDI | Masaaki Obara (ms-obara@kddi.com) | Rel-12 | 62 | Issam | CA | LTE_CA_B1_B28-Core | RP-141732 |
| 2543 | 693.55.2 | Perf. part:LTE Advanced inter-band Carrier Aggregation of Band 1 and Band 28 | 267d? | 2013-12-12 A | 2014-12-15 A | 100% | 2013-12-09 | 2014-09-12 | 201d? | finish no earlier than 2014-12-15 | R4 | 2136h | 2136h | LTE_CA_B1_B28-Perf | 32 | KDDI | Masaaki Obara (ms-obara@kddi.com) | Rel-12 | 62 | Issam | CA | LTE_CA_B1_B28-Perf | RP-141732 |
| 2544 | 693.56 | **LTE Advanced inter-band Carrier Aggregation of Band 2 and Band 4 - Additional bandwidth combination set** | 65d? | 2013-12-09 A | 2014-03-06 A | 100% | 2013-12-09 | 2014-03-06 | 65d? |  | R4 | 1560h | 1560h | LTE_CA_B2_B4_BWset | 32 | T-Mobile USA | nelson.ueng@t-mobile.com | Rel-12 | 62 | Issam | CA | LTE_CA_B2_B4_BWset |  |
| 2545 | 693.56.1 | Core part:LTE Advanced inter-band Carrier Aggregation of Band 2 and Band 4 - Additional bandwidth combination set | 65d? | 2013-12-09 A | 2014-03-06 A | 100% | 2013-12-09 | 2014-03-06 | 65d? | finish no earlier than 2014-03-06 | R4 | 520h | 520h | LTE_CA_B2_B4_BWset-Core | 32 | T-Mobile USA | nelson.ueng@t-mobile.com | Rel-12 | 62 | Issam | CA | LTE_CA_B2_B4_BWset-Core | RP-140428 |
| 2546 | 693.56.2 | Perf. part:LTE Advanced inter-band Carrier Aggregation of Band 2 and Band 4 - Additional bandwidth combination set | 65d? | 2013-12-09 A | 2014-03-06 A | 100% | 2013-12-09 | 2014-03-06 | 65d? | finish no earlier than 2014-03-06 | R4 | 520h | 520h | LTE_CA_B2_B4_BWset-Perf | 32 | T-Mobile USA | nelson.ueng@t-mobile.com | Rel-12 | 62 | Issam | CA | LTE_CA_B2_B4_BWset-Perf | RP-140428 |
| 2547 | 693.57 | **LTE Advanced inter-band Carrier Aggregation of Band 4 and Band 27** | 136d? | 2013-12-09 A | 2014-06-13 A | 100% | 2013-12-09 | 2014-06-13 | 136d? |  | R4 | 3264h | 3264h | LTE_CA_B4_B27 | 32 | NII Holdings | bill.shvodian@nii.com | Rel-12 | 62 | Issam | CA | LTE_CA_B4_B27 |  |
| 2548 | 693.57.1 | Core part:LTE Advanced inter-band Carrier Aggregation of Band 4 and Band 27 | 136d? | 2013-12-09 A | 2014-06-13 A | 100% | 2013-12-09 | 2014-06-13 | 136d? | finish no earlier than 2014-06-13 | R4 | 1088h | 1088h | LTE_CA_B4_B27-Core | 32 | NII Holdings | bill.shvodian@nii.com | Rel-12 | 62 | Issam | CA | LTE_CA_B4_B27-Core | RP-140569 |
| 2549 | 693.57.2 | Perf. part:LTE Advanced inter-band Carrier Aggregation of Band 4 and Band 27 | 136d? | 2013-12-09 A | 2014-06-13 A | 100% | 2013-12-09 | 2014-06-13 | 136d? | finish no earlier than 2014-06-13 | R4 | 1088h | 1088h | LTE_CA_B4_B27-Perf | 32 | NII Holdings | bill.shvodian@nii.com | Rel-12 | 62 | Issam | CA | LTE_CA_B4_B27-Perf | RP-140569 |
| 2550 | 693.58 | **LTE Advanced inter-band Carrier Aggregation of Band 3 and Band 27** | 65d? | 2013-12-09 A | 2014-03-06 A | 100% | 2013-12-09 | 2014-03-06 | 65d? |  | R4 | 1560h | 1560h | LTE_CA_B3_B27 | 32 | KT | Chungwoo HWANG (cwhwang@kt.com) | Rel-12 | 62 | Issam | CA | LTE_CA_B3_B27 | RP-140428 |
| 2551 | 693.58.1 | Core part:LTE Advanced inter-band Carrier Aggregation of Band 3 and Band 27 | 65d? | 2013-12-09 A | 2014-03-06 A | 100% | 2013-12-09 | 2014-03-06 | 65d? | finish no earlier than 2014-03-06 | R4 | 520h | 520h | LTE_CA_B3_B27-Core | 32 | KT | Chungwoo HWANG (cwhwang@kt.com) | Rel-12 | 62 | Issam | CA | LTE_CA_B3_B27-Core | RP-140428 |
| 2552 | 693.58.2 | Perf. part:LTE Advanced inter-band Carrier Aggregation of Band 3 and Band 27 | 65d? | 2013-12-09 A | 2014-03-06 A | 100% | 2013-12-09 | 2014-03-06 | 65d? | finish no earlier than 2014-03-06 | R4 | 520h | 520h | LTE_CA_B3_B27-Perf | 32 | KT | Chungwoo HWANG (cwhwang@kt.com) | Rel-12 | 62 | Issam | CA | LTE_CA_B3_B27-Perf | RP-140428 |
| 2553 | 693.59 | **LTE Advanced inter-band Carrier Aggregation in Band 8 and Band 20 - Additional channel bandwidth** | 65d? | 2013-12-09 A | 2014-03-06 A | 100% | 2013-12-09 | 2014-03-06 | 65d? |  | R4 | 1560h | 1560h | LTE_CA_B8_B20_BW | 32 | Vodafone | luis.anaya@vodafone.com | Rel-12 | 62 | Issam | CA | LTE_CA_B8_B20_BW | RP-140428 |
| 2554 | 693.59.1 | Core part:LTE Advanced inter-band Carrier Aggregation in Band 8 and Band 20 - Additional channel bandwidth | 65d? | 2013-12-09 A | 2014-03-06 A | 100% | 2013-12-09 | 2014-03-06 | 65d? | finish no earlier than 2014-03-06 | R4 | 520h | 520h | LTE_CA_B8_B20_BW-Core | 32 | Vodafone | luis.anaya@vodafone.com | Rel-12 | 62 | Issam | CA | LTE_CA_B8_B20_BW-Core | RP-140428 |
| 2555 | 693.59.2 | Perf. part:LTE Advanced inter-band Carrier Aggregation in Band 8 and Band 20 - Additional channel bandwidth | 65d? | 2013-12-09 A | 2014-03-06 A | 100% | 2013-12-09 | 2014-03-06 | 65d? | finish no earlier than 2014-03-06 | R4 | 520h | 520h | LTE_CA_B8_B20_BW-Perf | 32 | Vodafone | luis.anaya@vodafone.com | Rel-12 | 62 | Issam | CA | LTE_CA_B8_B20_BW-Perf | RP-140428 |
| 2556 | 693.60 | **LTE Advanced 3 Band Carrier Aggregation (3DL/1UL) for Band 1, Band 3 and Band 8** | 202d? | 2013-12-09 A | 2014-09-12 A | 100% | 2013-12-09 | 2014-09-12 | 201d? |  | R4 | 4832h | 4832h | LTE_CA_B1_B3_B8 | 32 | KT | Ilwhan Kim (ilwhan.kim@kt.com) | Rel-12 | 62 | Issam | CA | LTE_CA_B1_B3_B8 |  |
| 2557 | 693.60.1 | Core part:LTE Advanced 3 Band Carrier Aggregation (3DL/1UL) for Band 1, Band 3 and Band 8 | 201d? | 2013-12-09 A | 2014-09-12 A | 100% | 2013-12-09 | 2014-09-12 | 201d? | finish no earlier than 2014-09-12 | R4 | 1608h | 1608h | LTE_CA_B1_B3_B8-Core | 32 | KT | Ilwhan Kim (ilwhan.kim@kt.com) | Rel-12 | 62 | Issam | CA | LTE_CA_B1_B3_B8-Core | RP-141084 |
| 2558 | 693.60.2 | Perf. part:LTE Advanced 3 Band Carrier Aggregation (3DL/1UL) for Band 1, Band 3 and Band 8 | 201d? | 2013-12-09 A | 2014-09-12 A | 100% | 2013-12-09 | 2014-09-12 | 201d? | finish no earlier than 2014-09-12 | R4 | 1608h | 1608h | LTE_CA_B1_B3_B8-Perf | 32 | KT | Ilwhan Kim (ilwhan.kim@kt.com) | Rel-12 | 62 | Issam | CA | LTE_CA_B1_B3_B8-Perf | RP-141084 |
| 2559 | 693.61 | **LTE Advanced 3 Band Carrier Aggregation (3DL/1UL) for Band 1, Band 5 and Band 7** | 202d? | 2013-12-09 A | 2014-09-12 A | 100% | 2013-12-09 | 2014-09-12 | 201d? |  | R4 | 4832h | 4832h | LTE_CA_B1_B5_B7 | 32 | LG Uplus | Yeonsang KOO (yskoo@lguplus.co.kr) | Rel-12 | 62 | Issam | CA | LTE_CA_B1_B5_B7 |  |
| 2560 | 693.61.1 | Core part:LTE Advanced 3 Band Carrier Aggregation (3DL/1UL) for Band 1, Band 5 and Band 7 | 201d? | 2013-12-09 A | 2014-09-12 A | 100% | 2013-12-09 | 2014-09-12 | 201d? | finish no earlier than 2014-09-12 | R4 | 1608h | 1608h | LTE_CA_B1_B5_B7-Core | 32 | LG Uplus | Yeonsang KOO (yskoo@lguplus.co.kr) | Rel-12 | 62 | Issam | CA | LTE_CA_B1_B5_B7-Core | RP-141084 |
| 2561 | 693.61.2 | Perf. part:LTE Advanced 3 Band Carrier Aggregation (3DL/1UL) for Band 1, Band 5 and Band 7 | 201d? | 2013-12-09 A | 2014-09-12 A | 100% | 2013-12-09 | 2014-09-12 | 201d? | finish no earlier than 2014-09-12 | R4 | 1608h | 1608h | LTE_CA_B1_B5_B7-Perf | 32 | LG Uplus | Yeonsang KOO (yskoo@lguplus.co.kr) | Rel-12 | 62 | Issam | CA | LTE_CA_B1_B5_B7-Perf | RP-141084 |
| 2562 | 693.62 | **LTE Advanced 3 Band Carrier Aggregation (3DL/1UL) for Band 2, Band 4 and Band 5** | 202d? | 2013-12-09 A | 2014-09-12 A | 100% | 2013-12-09 | 2014-09-12 | 201d? |  | R4 | 4832h | 4832h | LTE_CA_B2_B4_B5 | 32 | U.S. Cellular | sebastian.thalanany@uscellular.com | Rel-12 | 62 | Issam | CA | LTE_CA_B2_B4_B5 |  |
| 2563 | 693.62.1 | Core part:LTE Advanced 3 Band Carrier Aggregation (3DL/1UL) for Band 2, Band 4 and Band 5 | 201d? | 2013-12-09 A | 2014-09-12 A | 100% | 2013-12-09 | 2014-09-12 | 201d? | finish no earlier than 2014-09-12 | R4 | 1608h | 1608h | LTE_CA_B2_B4_B5-Core | 32 | U.S. Cellular | sebastian.thalanany@uscellular.com | Rel-12 | 62 | Issam | CA | LTE_CA_B2_B4_B5-Core | RP-141084 |
| 2564 | 693.62.2 | Perf. part:LTE Advanced 3 Band Carrier Aggregation (3DL/1UL) for Band 2, Band 4 and Band 5 | 201d? | 2013-12-09 A | 2014-09-12 A | 100% | 2013-12-09 | 2014-09-12 | 201d? | finish no earlier than 2014-09-12 | R4 | 1608h | 1608h | LTE_CA_B2_B4_B5-Perf | 32 | U.S. Cellular | sebastian.thalanany@uscellular.com | Rel-12 | 62 | Issam | CA | LTE_CA_B2_B4_B5-Perf | RP-141084 |

Notes:
- 2541: Inter-band CA 2DL / Impacted TSs and TRs: LTE
- 2542: ; WID: RP-142043->RP-141803; Stat Rep: RP-141084->RP-141732 / Impacted TSs and TRs: 36.101, 36.104, 36.133, 36.307, new generic TR 36.851
- 2543: ; WID: RP-142043->RP-141803; Stat Rep: RP-141084->RP-141732 / Impacted TSs and TRs: 36.133, 36.141
- 2544: Inter-band 2DL / Impacted TSs and TRs: LTE
- 2545: RP#63 completed / Impacted TSs and TRs: 36.101, new generic TR 36.851
- 2546: RP#63 completed / Impacted TSs and TRs: 36.307
- 2547: Inter-band CA 2DL / Impacted TSs and TRs: LTE
- 2548: RP#64 completed / Impacted TSs and TRs: 36.101, 36.104, 36.133, new generic TR 36.851
- 2549: RP#64 completed / Impacted TSs and TRs: 36.141, 36.307
- 2550: Inter-band CA 2DL/1UL / Impacted TSs and TRs: LTE
- 2551: RP#63 completed. Updated WID RP-131752=>RP-140119 / Impacted TSs and TRs: 36.101, 36.104, 36.133, 36.307, New generic TR 36.851
- 2552: RP#63 completed. Updated WID RP-131752=>RP-140119 / Impacted TSs and TRs: 36.101, 36.104, 36.133, 36.141
- 2553: Inter-band 2DL / Impacted TSs and TRs: LTE
- 2554: RP#63 completed / Impacted TSs and TRs: 36.101, 36.104, 36.307
- 2555: RP#63 completed / Impacted TSs and TRs: 36.141
- 2556: Inter-band CA 3DL / Impacted TSs and TRs: LTE
- 2557: RP#65 completed. Updated WID RP-131753=>RP-141654 / Impacted TSs and TRs: 36.101, 36.104, 36.133, 36.141, 36.307, new generic TR 36.853 (3 Band CA with 1UL)
- 2558: RP#65 completed / Impacted TSs and TRs: 36.101, 36.104, 36.133, 36.141, 36.307
- 2559: Inter-band CA 3DL / Impacted TSs and TRs: LTE
- 2560: RP#65 completed. Updated WID RP-140209=>RP-141462 / Impacted TSs and TRs: 36.101, 36.104, 36.133, new generic TR 36.853 (3 Band CA with 1UL)
- 2561: RP#65 completed / Impacted TSs and TRs: 36.141, 36.307
- 2562: Inter-band CA 3DL / Impacted TSs and TRs: LTE
- 2563: RP#65 completed / Impacted TSs and TRs: 36.101, 36.104, 36.133, new generic TR 36.853 (3 Band CA with 1UL)
- 2564: RP#65 completed / Impacted TSs and TRs: 36.141, 36.307

| ID | WBS | Task | Duration | Start | Finish | Complete | Baseline start | Baseline finish | Baseline duration | Constraint | Resources | Work | Actual work | Acronym | PCG approved | WI rapporteur name | WI rapporteur e-mail | Release | TSG approved | MCC resp | Special Focus Doc | Acronym_3GU_Export | Status Report |
| --- | --- | --- | --- | --- | --- | --- | --- | --- | --- | --- | --- | --- | --- | --- | --- | --- | --- | --- | --- | --- | --- | --- | --- |
| 2565 | 693.63 | **LTE Advanced 3 Band Carrier Aggregation (3DL/1UL) for Band 2, Band 4 and Band 12** | 268d? | 2013-12-09 A | 2014-12-11 A | 100% | 2013-12-09 | 2014-09-12 | 201d? |  | R4 | 5872h | 5872h | LTE_CA_B2_B4_B12 | 32 | U.S. Cellular | sebastian.thalanany@uscellular.com | Rel-12 | 62 | Issam | CA | LTE_CA_B2_B4_B12 |  |
| 2566 | 693.63.1 | Core part:LTE Advanced 3 Band Carrier Aggregation (3DL/1UL) for Band 2, Band 4 and Band 12 | 201d? | 2013-12-09 A | 2014-09-12 A | 100% | 2013-12-09 | 2014-09-12 | 201d? | finish no earlier than 2014-09-12 | R4 | 1608h | 1608h | LTE_CA_B2_B4_B12-Core | 32 | U.S. Cellular | sebastian.thalanany@uscellular.com | Rel-12 | 62 | Issam | CA | LTE_CA_B2_B4_B12-Core | RP-141084 |
| 2567 | 693.63.2 | Perf. part:LTE Advanced 3 Band Carrier Aggregation (3DL/1UL) for Band 2, Band 4 and Band 12 | 265d? | 2013-12-09 A | 2014-12-11 A | 100% | 2013-12-09 | 2014-09-12 | 201d? | finish no earlier than 2014-12-11 | R4 | 2120h | 2120h | LTE_CA_B2_B4_B12-Perf | 32 | U.S. Cellular | sebastian.thalanany@uscellular.com | Rel-12 | 62 | Issam | CA | LTE_CA_B2_B4_B12-Perf | RP-141084 |
| 2568 | 693.64 | **LTE Advanced 3 Band Carrier Aggregation (3DL/1UL) for Band 2, Band 5 and Band 12** | 202d? | 2013-12-09 A | 2014-09-12 A | 100% | 2013-12-09 | 2014-09-12 | 201d? |  | R4 | 4832h | 4832h | LTE_CA_B2_B5_B12 | 32 | U.S. Cellular | sebastian.thalanany@uscellular.com | Rel-12 | 62 | Issam | CA | LTE_CA_B2_B5_B12 |  |
| 2569 | 693.64.1 | Core part:LTE Advanced 3 Band Carrier Aggregation (3DL/1UL) for Band 2, Band 5 and Band 12 | 201d? | 2013-12-09 A | 2014-09-12 A | 100% | 2013-12-09 | 2014-09-12 | 201d? | finish no earlier than 2014-09-12 | R4 | 1608h | 1608h | LTE_CA_B2_B5_B12-Core | 32 | U.S. Cellular | sebastian.thalanany@uscellular.com | Rel-12 | 62 | Issam | CA | LTE_CA_B2_B5_B12-Core | RP-141084 |
| 2570 | 693.64.2 | Perf. part:LTE Advanced 3 Band Carrier Aggregation (3DL/1UL) for Band 2, Band 5 and Band 12 | 201d? | 2013-12-10 A | 2014-09-12 A | 100% | 2013-12-09 | 2014-09-12 | 201d? | finish no earlier than 2014-09-12 | R4 | 1608h | 1608h | LTE_CA_B2_B5_B12-Perf | 32 | U.S. Cellular | sebastian.thalanany@uscellular.com | Rel-12 | 62 | Issam | CA | LTE_CA_B2_B5_B12-Perf | RP-141084 |
| 2571 | 693.65 | **LTE Advanced 3 Band Carrier Aggregation (3DL/1UL) for Band 2, Band 12 and Band 12** | 202d? | 2013-12-09 A | 2014-09-12 A | 100% | 2013-12-09 | 2014-09-12 | 201d? |  | R4 | 4832h | 4832h | LTE_CA_B2_B12_B12 | 32 | AT&T | marc.grant@att.com | Rel-12 | 62 | Issam | CA | LTE_CA_B2_B12_B12 |  |
| 2572 | 693.65.1 | Core part:LTE Advanced 3 Band Carrier Aggregation (3DL/1UL) for Band 2, Band 12 and Band 12 | 201d? | 2013-12-09 A | 2014-09-12 A | 100% | 2013-12-09 | 2014-09-12 | 201d? | finish no earlier than 2014-09-12 | R4 | 1608h | 1608h | LTE_CA_B2_B12_B12-Core | 32 | AT&T | marc.grant@att.com | Rel-12 | 62 | Issam | CA | LTE_CA_B2_B12_B12-Core | RP-141084 |
| 2573 | 693.65.2 | Perf. part:LTE Advanced 3 Band Carrier Aggregation (3DL/1UL) for Band 2, Band 12 and Band 12 | 201d? | 2013-12-09 A | 2014-09-12 A | 100% | 2013-12-09 | 2014-09-12 | 201d? | finish no earlier than 2014-09-12 | R4 | 1608h | 1608h | LTE_CA_B2_B12_B12-Perf | 32 | AT&T | marc.grant@att.com | Rel-12 | 62 | Issam | CA | LTE_CA_B2_B12_B12-Perf | RP-141084 |
| 2574 | 693.66 | **LTE Advanced 3 Band Carrier Aggregation (3DL/1UL) for Band 2, Band 12 and Band 30** | 202d? | 2013-12-09 A | 2014-09-12 A | 100% | 2013-12-09 | 2014-09-12 | 201d? |  | R4 | 4832h | 4832h | LTE_CA_B2_B12_B30 | 32 | AT&T | marc.grant@att.com | Rel-12 | 62 | Issam | CA | LTE_CA_B2_B12_B30 |  |
| 2575 | 693.66.1 | Core part:LTE Advanced 3 Band Carrier Aggregation (3DL/1UL) for Band 2, Band 12 and Band 30 | 201d? | 2013-12-09 A | 2014-09-12 A | 100% | 2013-12-09 | 2014-09-12 | 201d? | finish no earlier than 2014-09-12 | R4 | 1608h | 1608h | LTE_CA_B2_B12_B30-Core | 32 | AT&T | marc.grant@att.com | Rel-12 | 62 | Issam | CA | LTE_CA_B2_B12_B30-Core | RP-141084 |
| 2576 | 693.66.2 | Perf. part:LTE Advanced 3 Band Carrier Aggregation (3DL/1UL) for Band 2, Band 12 and Band 30 | 201d? | 2013-12-09 A | 2014-09-12 A | 100% | 2013-12-09 | 2014-09-12 | 201d? | finish no earlier than 2014-09-12 | R4 | 1608h | 1608h | LTE_CA_B2_B12_B30-Perf | 32 | AT&T | marc.grant@att.com | Rel-12 | 62 | Issam | CA | LTE_CA_B2_B12_B30-Perf | RP-141084 |
| 2577 | 693.67 | **LTE Advanced 3 Band Carrier Aggregation (3DL/1UL) for Band 3, Band 7 and Band 20** | 202d? | 2013-12-09 A | 2014-09-12 A | 100% | 2013-12-09 | 2014-09-12 | 201d? |  | R4 | 4832h | 4832h | LTE_CA_B3_B7_B20 | 32 | Vodafone | luis.anaya@vodafone.com | Rel-12 | 62 | Issam | CA | LTE_CA_B3_B7_B20 |  |
| 2578 | 693.67.1 | Core part:LTE Advanced 3 Band Carrier Aggregation (3DL/1UL) for Band 3, Band 7 and Band 20 | 201d? | 2013-12-09 A | 2014-09-12 A | 100% | 2013-12-09 | 2014-09-12 | 201d? | finish no earlier than 2014-09-12 | R4 | 1608h | 1608h | LTE_CA_B3_B7_B20-Core | 32 | Vodafone | luis.anaya@vodafone.com | Rel-12 | 62 | Issam | CA | LTE_CA_B3_B7_B20-Core | RP-141084 |
| 2579 | 693.67.2 | Perf. part:LTE Advanced 3 Band Carrier Aggregation (3DL/1UL) for Band 3, Band 7 and Band 20 | 201d? | 2013-12-10 A | 2014-09-12 A | 100% | 2013-12-09 | 2014-09-12 | 201d? | finish no earlier than 2014-09-12 | R4 | 1608h | 1608h | LTE_CA_B3_B7_B20-Perf | 32 | Vodafone | luis.anaya@vodafone.com | Rel-12 | 62 | Issam | CA | LTE_CA_B3_B7_B20-Perf | RP-141084 |
| 2580 | 693.68 | **LTE Advanced 3 Band Carrier Aggregation (3DL/1UL) for Band 4, Band 5 and Band 12** | 202d? | 2013-12-09 A | 2014-09-12 A | 100% | 2013-12-09 | 2014-09-12 | 201d? |  | R4 | 4832h | 4832h | LTE_CA_B4_B5_B12 | 32 | U.S. Cellular | sebastian.thalanany@uscellular.com | Rel-12 | 62 | Issam | CA | LTE_CA_B4_B5_B12 |  |
| 2581 | 693.68.1 | Core part:LTE Advanced 3 Band Carrier Aggregation (3DL/1UL) for Band 4, Band 5 and Band 12 | 201d? | 2013-12-09 A | 2014-09-12 A | 100% | 2013-12-09 | 2014-09-12 | 201d? | finish no earlier than 2014-09-12 | R4 | 1608h | 1608h | LTE_CA_B4_B5_B12-Core | 32 | U.S. Cellular | sebastian.thalanany@uscellular.com | Rel-12 | 62 | Issam | CA | LTE_CA_B4_B5_B12-Core | RP-141084 |
| 2582 | 693.68.2 | Perf. part:LTE Advanced 3 Band Carrier Aggregation (3DL/1UL) for Band 4, Band 5 and Band 12 | 201d? | 2013-12-09 A | 2014-09-12 A | 100% | 2013-12-09 | 2014-09-12 | 201d? | finish no earlier than 2014-09-12 | R4 | 1608h | 1608h | LTE_CA_B4_B5_B12-Perf | 32 | U.S. Cellular | sebastian.thalanany@uscellular.com | Rel-12 | 62 | Issam | CA | LTE_CA_B4_B5_B12-Perf | RP-141084 |
| 2583 | 693.69 | **LTE Advanced 3 Band Carrier Aggregation (3DL/1UL) for Band 4, Band 12 and Band 12** | 202d? | 2013-12-09 A | 2014-09-12 A | 100% | 2013-12-09 | 2014-09-12 | 201d? |  | R4 | 4832h | 4832h | LTE_CA_B4_B12_B12 | 32 | AT&T | marc.grant@att.com | Rel-12 | 62 | Issam | CA | LTE_CA_B4_B12_B12 |  |
| 2584 | 693.69.1 | Core part:LTE Advanced 3 Band Carrier Aggregation (3DL/1UL) for Band 4, Band 12 and Band 12 | 201d? | 2013-12-09 A | 2014-09-12 A | 100% | 2013-12-09 | 2014-09-12 | 201d? | finish no earlier than 2014-09-12 | R4 | 1608h | 1608h | LTE_CA_B4_B12_B12-Core | 32 | AT&T | marc.grant@att.com | Rel-12 | 62 | Issam | CA | LTE_CA_B4_B12_B12-Core | RP-141084 |
| 2585 | 693.69.2 | Perf. part:LTE Advanced 3 Band Carrier Aggregation (3DL/1UL) for Band 4, Band 12 and Band 12 | 201d? | 2013-12-09 A | 2014-09-12 A | 100% | 2013-12-09 | 2014-09-12 | 201d? | finish no earlier than 2014-09-12 | R4 | 1608h | 1608h | LTE_CA_B4_B12_B12-Perf | 32 | AT&T | marc.grant@att.com | Rel-12 | 62 | Issam | CA | LTE_CA_B4_B12_B12-Perf | RP-141084 |
| 2586 | 693.70 | **LTE Advanced 3 Band Carrier Aggregation (3DL/1UL) for Band 4, Band 12 and Band 30** | 202d? | 2013-12-09 A | 2014-09-12 A | 100% | 2013-12-09 | 2014-09-12 | 201d? |  | R4 | 4832h | 4832h | LTE_CA_B4_B12_B30 | 32 | AT&T | marc.grant@att.com | Rel-12 | 62 | Issam | CA | LTE_CA_B4_B12_B30 |  |
| 2587 | 693.70.1 | Core part:LTE Advanced 3 Band Carrier Aggregation (3DL/1UL) for Band 4, Band 12 and Band 30 | 201d? | 2013-12-09 A | 2014-09-12 A | 100% | 2013-12-09 | 2014-09-12 | 201d? | finish no earlier than 2014-09-12 | R4 | 1608h | 1608h | LTE_CA_B4_B12_B30-Core | 32 | AT&T | marc.grant@att.com | Rel-12 | 62 | Issam | CA | LTE_CA_B4_B12_B30-Core | RP-141084 |
| 2588 | 693.70.2 | Perf. part:LTE Advanced 3 Band Carrier Aggregation (3DL/1UL) for Band 4, Band 12 and Band 30 | 201d? | 2013-12-09 A | 2014-09-12 A | 100% | 2013-12-09 | 2014-09-12 | 201d? | finish no earlier than 2014-09-12 | R4 | 1608h | 1608h | LTE_CA_B4_B12_B30-Perf | 32 | AT&T | marc.grant@att.com | Rel-12 | 62 | Issam | CA | LTE_CA_B4_B12_B30-Perf | RP-141084 |

Notes:
- 2565: Inter-band CA 3DL / Impacted TSs and TRs: LTE
- 2566: RP#65 completed / Impacted TSs and TRs: 36.101, 36.104, 36.133, new generic TR 36.853 (3 Band CA with 1UL)
- 2567: RP#65 completion 09/14=>12/14 / Impacted TSs and TRs: 36.141, 36.307
- 2568: Inter-band CA 3DL / Impacted TSs and TRs: LTE
- 2569: RP#65 completed / Impacted TSs and TRs: 36.101, 36.104, 36.133, new generic TR 36.853 (3 Band CA with 1UL)
- 2570: RP#65 completed / Impacted TSs and TRs: 36.141, 36.307
- 2571: Inter-band CA 3DL / Impacted TSs and TRs: LTE
- 2572: RP#65 completed / Impacted TSs and TRs: 36.101, 36.104, 36.133, 36.141, 36.307, new generic TR 36.853
- 2573: RP#65 completed / Impacted TSs and TRs: 36.101, 36.104, 36.133, 36.141, 36.307
- 2574: Inter-band CA 3DL / Impacted TSs and TRs: LTE
- 2575: RP#65 completed. Updated WID RP-131652=>RP-141211. / Impacted TSs and TRs: 36.101, 36.104, 36.133, 36.141, 36.307, new generic TR 36.853 (3 Band CA with 1UL)
- 2576: RP#65 completed / Impacted TSs and TRs: 36.101, 36.104, 36.133, 36.141, 36.307
- 2577: Inter-band CA 3DL / Impacted TSs and TRs: LTE
- 2578: RP#65 completed. Updated WID RP-140244=>RP-141224 / Impacted TSs and TRs: 36.101, 36.104, 36.133, new generic TR 36.853 (3 Band CA with 1UL)
- 2579: RP#65 completed / Impacted TSs and TRs: 36.101, 36.133, 36.141, 36.307
- 2580: Inter-band CA 3DL / Impacted TSs and TRs: LTE
- 2581: RP#65 completed / Impacted TSs and TRs: 36.101, 36.104, 36.133, new generic TR 36.853 (3 Band CA with 1UL)
- 2582: RP#65 completed / Impacted TSs and TRs: 36.141, 36.307
- 2583: Inter-band CA 3DL / Impacted TSs and TRs: LTE
- 2584: RP#65 completed / Impacted TSs and TRs: 36.101, 36.104, 36.133, 36.141, 36.307, new generic TR 36.853 (3 Band CA with 1UL)
- 2585: RP#65 completed / Impacted TSs and TRs: 36.101, 36.104, 36.133, 36.141, 36.307
- 2586: Inter-band CA 3DL / Impacted TSs and TRs: LTE
- 2587: RP#65 completed. Updated WID RP-131653=>RP-141214 / Impacted TSs and TRs: 36.101, 36.104, 36.133, 36.141, 36.307, new generic TR 36.853 (3 Band CA with 1UL)
- 2588: RP#65 completed / Impacted TSs and TRs: 36.101, 36.104, 36.133, 36.141, 36.307

| ID | WBS | Task | Duration | Start | Finish | Complete | Baseline start | Baseline finish | Baseline duration | Constraint | Resources | Work | Actual work | Acronym | PCG approved | WI rapporteur name | WI rapporteur e-mail | Release | TSG approved | MCC resp | Special Focus Doc | Acronym_3GU_Export | Status Report |
| --- | --- | --- | --- | --- | --- | --- | --- | --- | --- | --- | --- | --- | --- | --- | --- | --- | --- | --- | --- | --- | --- | --- | --- |
| 2589 | 693.71 | **LTE Advanced intra-band contiguous Carrier Aggregation in Band 42** | 136d? | 2013-12-09 A | 2014-06-13 A | 100% | 2013-12-09 | 2014-06-13 | 136d? |  | R4 | 3264h | 3264h | LTE_CA_C_B42 | 32 | CATT | Yuexia Song (songyuexia@catt.cn) | Rel-12 | 62 | Issam | CA | LTE_CA_C_B42 |  |
| 2590 | 693.71.1 | Core part: LTE Advanced intra-band contiguous Carrier Aggregation in Band 42 | 136d? | 2013-12-09 A | 2014-06-13 A | 100% | 2013-12-09 | 2014-06-13 | 136d? | finish no earlier than 2014-06-13 | R4 | 1088h | 1088h | LTE_CA_C_B42-Core | 32 | CATT | Yuexia Song (songyuexia@catt.cn) | Rel-12 | 62 | Issam | CA | LTE_CA_C_B42-Core | RP-140569 |
| 2591 | 693.71.2 | Perf. part: LTE Advanced intra-band contiguous Carrier Aggregation in Band 42 | 136d? | 2013-12-09 A | 2014-06-13 A | 100% | 2013-12-09 | 2014-06-13 | 136d? | finish no earlier than 2014-06-13 | R4 | 1088h | 1088h | LTE_CA_C_B42-Perf | 32 | CATT | Yuexia Song (songyuexia@catt.cn) | Rel-12 | 62 | Issam | CA | LTE_CA_C_B42-Perf | RP-140569 |
| 2592 | 693.72 | **LTE Advanced intra-band contiguous Carrier Aggregation in Band 7 - Additional bandwidth combinations** | 136d? | 2013-12-09 A | 2014-06-13 A | 100% | 2013-12-09 | 2014-06-13 | 136d? |  | R4 | 3264h | 3264h | LTE_CA_C_B7_BW | 32 | Orange | Olfa BEN HADDADA | Rel-12 | 62 | Issam | CA | LTE_CA_C_B7_BW |  |
| 2593 | 693.72.1 | Core part: LTE Advanced intra-band contiguous Carrier Aggregation in Band 7 - Additional bandwidth combinations | 136d? | 2013-12-09 A | 2014-06-13 A | 100% | 2013-12-09 | 2014-06-13 | 136d? | finish no earlier than 2014-06-13 | R4 | 1088h | 1088h | LTE_CA_C_B7_BW-Core | 32 | Orange | Olfa BEN HADDADA | Rel-12 | 62 | Issam | CA | LTE_CA_C_B7_BW-Core | RP-140569 |
| 2594 | 693.72.2 | Perf. part: LTE Advanced intra-band contiguous Carrier Aggregation in Band 7 - Additional bandwidth combinations | 136d? | 2013-12-09 A | 2014-06-13 A | 100% | 2013-12-09 | 2014-06-13 | 136d? | finish no earlier than 2014-06-13 | R4 | 1088h | 1088h | LTE_CA_C_B7_BW-Perf | 32 | Orange | Olfa BEN HADDADA | Rel-12 | 62 | Issam | CA | LTE_CA_C_B7_BW-Perf | RP-140569 |
| 2595 | 693.73 | **LTE Advanced intra-band non-contiguous Carrier Aggregation in Band 41 for 3 DL** | 334d? | 2013-12-09 A | 2015-03-15 A | 100% | 2013-12-09 | 2014-09-12 | 200d? |  | R4 | 6920h | 6920h | LTE_CA_NC_B41_3DL | 32 | Sprint, Alcatel-Lucent | man-hung.ng@alcatel-lucent.com | Rel-12 | 62 | Issam | CA | LTE_CA_NC_B41_3DL |  |
| 2596 | 693.73.1 | Core part:LTE Advanced intra-band non-contiguous Carrier Aggregation in Band 41 for 3 DL | 200d? | 2013-12-09 A | 2014-09-11 A | 100% | 2013-12-09 | 2014-09-12 | 200d? | finish no earlier than 2014-09-12 | R4 | 1600h | 1600h | LTE_CA_NC_B41_3DL-Core | 32 | Sprint, Alcatel-Lucent | man-hung.ng@alcatel-lucent.com | Rel-12 | 62 | Issam | CA | LTE_CA_NC_B41_3DL-Core | RP-141084 |
| 2597 | 693.73.2 | Perf. part:LTE Advanced intra-band non-contiguous Carrier Aggregation in Band 41 for 3 DL | 331d? | 2013-12-09 A | 2015-03-15 A | 100% | 2013-12-09 | 2014-09-12 | 200d? | finish no earlier than 2015-03-15 | R4 | 2648h | 2648h | LTE_CA_NC_B41_3DL-Perf | 32 | Sprint, Alcatel-Lucent | man-hung.ng@alcatel-lucent.com | Rel-12 | 62 | Issam | CA | LTE_CA_NC_B41_3DL-Perf | RP-150013 |
| 2598 | 693.74 | **LTE Advanced intra-band non-contiguous Carrier Aggregation in Band 42** | 136d? | 2013-12-09 A | 2014-06-13 A | 100% | 2013-12-09 | 2014-06-13 | 136d? |  | R4 | 3264h | 3264h | LTE_CA_NC_B42 | 32 | Huawei | Liu Liehai (liuliehai@huawei.com) | Rel-12 | 62 | Issam | CA | LTE_CA_NC_B42 |  |
| 2599 | 693.74.1 | Core part:LTE Advanced intra-band non-contiguous Carrier Aggregation in Band 42 | 136d? | 2013-12-09 A | 2014-06-13 A | 100% | 2013-12-09 | 2014-06-13 | 136d? | finish no earlier than 2014-06-13 | R4 | 1088h | 1088h | LTE_CA_NC_B42-Core | 32 | Huawei | Liu Liehai (liuliehai@huawei.com) | Rel-12 | 62 | Issam | CA | LTE_CA_NC_B42-Core | RP-140569 |
| 2600 | 693.74.2 | Perf. part:LTE Advanced intra-band non-contiguous Carrier Aggregation in Band 42 | 136d? | 2013-12-09 A | 2014-06-13 A | 100% | 2013-12-09 | 2014-06-13 | 136d? | finish no earlier than 2014-06-13 | R4 | 1088h | 1088h | LTE_CA_NC_B42-Perf | 32 | Huawei | Liu Liehai (liuliehai@huawei.com) | Rel-12 | 62 | Issam | CA | LTE_CA_NC_B42-Perf | RP-140569 |
| 2601 | 693.75 | **LTE Advanced 3 Band Carrier Aggregation (3DL/1UL) for Band 1, Band 3 and Band 5** | 203d? | 2013-12-06 A | 2014-09-12 A | 100% | 2013-12-06 | 2014-09-12 | 202d? |  | R4 | 4856h | 4856h | LTE_CA_B1_B3_B5 | 32 | SK Telecom | haesung.park@sk.com | Rel-12 | 62 | Issam | CA | LTE_CA_B1_B3_B5 |  |
| 2602 | 693.75.1 | Core part:LTE Advanced 3 Band Carrier Aggregation(3DL/1UL) for Band 1, Band 3 and Band 5 | 202d? | 2013-12-06 A | 2014-09-12 A | 100% | 2013-12-06 | 2014-09-12 | 202d? | finish no earlier than 2014-09-12 | R4 | 1616h | 1616h | LTE_CA_B1_B3_B5-Core | 32 | SK Telecom | haesung.park@sk.com | Rel-12 | 62 | Issam | CA | LTE_CA_B1_B3_B5-Core | RP-141084 |
| 2603 | 693.75.2 | Perf. part:LTE Advanced 3 Band Carrier Aggregation(3DL/1UL) for Band 1, Band 3 and Band 5 | 202d? | 2013-12-06 A | 2014-09-12 A | 100% | 2013-12-06 | 2014-09-12 | 202d? | finish no earlier than 2014-09-12 | R4 | 1616h | 1616h | LTE_CA_B1_B3_B5-Perf | 32 | SK Telecom | haesung.park@sk.com | Rel-12 | 62 | Issam | CA | LTE_CA_B1_B3_B5-Perf | RP-141084 |
| 2604 | 693.76 | **LTE Advanced 3 Band Carrier Aggregation (3DL/1UL) for Band 1, Band 3 and Band 20** | 202d? | 2013-12-09 A | 2014-09-12 A | 100% | 2013-12-09 | 2014-09-12 | 201d? |  | R4 | 4832h | 4832h | LTE_CA_B1_B3_B20 | 32 | Vodafone | luis.anaya@vodafone.com | Rel-12 | 62 | Issam | CA | LTE_CA_B1_B3_B20 |  |
| 2605 | 693.76.1 | Core part:LTE Advanced 3 Band Carrier Aggregation (3DL/1UL) for Band 1, Band 3 and Band 20 | 201d? | 2013-12-09 A | 2014-09-12 A | 100% | 2013-12-09 | 2014-09-12 | 201d? | finish no earlier than 2014-09-12 | R4 | 1608h | 1608h | LTE_CA_B1_B3_B20-Core | 32 | Vodafone | luis.anaya@vodafone.com | Rel-12 | 62 | Issam | CA | LTE_CA_B1_B3_B20-Core | RP-141084 |
| 2606 | 693.76.2 | Perf. part:LTE Advanced 3 Band Carrier Aggregation (3DL/1UL) for Band 1, Band 3 and Band 20 | 201d? | 2013-12-10 A | 2014-09-12 A | 100% | 2013-12-09 | 2014-09-12 | 201d? | finish no earlier than 2014-09-12 | R4 | 1608h | 1608h | LTE_CA_B1_B3_B20-Perf | 32 | Vodafone | luis.anaya@vodafone.com | Rel-12 | 62 | Issam | CA | LTE_CA_B1_B3_B20-Perf | RP-141084 |
| 2607 | 693.77 | **LTE Advanced 3 Band Carrier Aggregation (3DL/1UL) for Band 1, Band 7 and Band 20** | 202d? | 2013-12-09 A | 2014-09-12 A | 100% | 2013-12-09 | 2014-09-12 | 201d? |  | R4 | 4832h | 4832h | LTE_CA_B1_B7_B20 | 32 | Vodafone | luis.anaya@vodafone.com | Rel-12 | 62 | Issam | CA | LTE_CA_B1_B7_B20 |  |
| 2608 | 693.77.1 | Core part:LTE Advanced 3 Band Carrier Aggregation (3DL/1UL) for Band 1, Band 7 and Band 20 | 201d? | 2013-12-09 A | 2014-09-12 A | 100% | 2013-12-09 | 2014-09-12 | 201d? | finish no earlier than 2014-09-12 | R4 | 1608h | 1608h | LTE_CA_B1_B7_B20-Core | 32 | Vodafone | luis.anaya@vodafone.com | Rel-12 | 62 | Issam | CA | LTE_CA_B1_B7_B20-Core | RP-141084 |
| 2609 | 693.77.2 | Perf. part:LTE Advanced 3 Band Carrier Aggregation (3DL/1UL) for Band 1, Band 7 and Band 20 | 201d? | 2013-12-10 A | 2014-09-12 A | 100% | 2013-12-09 | 2014-09-12 | 201d? | finish no earlier than 2014-09-12 | R4 | 1608h | 1608h | LTE_CA_B1_B7_B20-Perf | 32 | Vodafone | luis.anaya@vodafone.com | Rel-12 | 62 | Issam | CA | LTE_CA_B1_B7_B20-Perf | RP-141084 |
| 2610 | 693.78 | **LTE Advanced 3 Band Carrier Aggregation (3DL/1UL) for Band 7, Band 8 and Band 20** | 270d? | 2013-12-09 A | 2014-12-15 A | 100% | 2013-12-09 | 2014-09-12 | 201d? |  | R4 | 6432h | 6432h | LTE_CA_B7_B8_B20 | 32 | Vodafone | luis.anaya@vodafone.com | Rel-12 | 62 | Issam | CA | LTE_CA_B7_B8_B20 |  |
| 2611 | 693.78.1 | Core part:LTE Advanced 3 Band Carrier Aggregation (3DL/1UL) for Band 7, Band 8 and Band 20 | 267d? | 2013-12-09 A | 2014-12-15 A | 100% | 2013-12-09 | 2014-09-12 | 201d? | finish no earlier than 2014-12-15 | R4 | 2136h | 2136h | LTE_CA_B7_B8_B20-Core | 32 | Vodafone | luis.anaya@vodafone.com | Rel-12 | 62 | Issam | CA | LTE_CA_B7_B8_B20-Core | RP-141732 |
| 2612 | 693.78.2 | Perf. part:LTE Advanced 3 Band Carrier Aggregation (3DL/1UL) for Band 7, Band 8 and Band 20 | 267d? | 2013-12-12 A | 2014-12-15 A | 100% | 2013-12-09 | 2014-09-12 | 201d? | finish no earlier than 2014-12-15 | R4 | 2136h | 2136h | LTE_CA_B7_B8_B20-Perf | 32 | Vodafone | luis.anaya@vodafone.com | Rel-12 | 62 | Issam | CA | LTE_CA_B7_B8_B20-Perf | RP-141732 |

Notes:
- 2589: Intra-band contig. CA 2DL/2UL / Impacted TSs and TRs: LTE
- 2590: RP#64 completed. TR 36.833-1-42v100 for 1-step Approval. Updated WID RP-132029=>RP-140728 / Impacted TSs and TRs: 36.101, 36.104, 36.133, new TR 36.833-1-42
- 2591: RP#64 completed. TR 36.833-1-42v100 for 1-step Approval. Updated WID RP-132029=>RP-140728 / Impacted TSs and TRs: 36.141, 36.307
- 2592: Intra-band contig. CA 2DL/2UL / Impacted TSs and TRs: LTE
- 2593: RP#64 completed / Impacted TSs and TRs: 36.101, 36.307
- 2594: RP#64 completed / Impacted TSs and TRs: 36.307
- 2595: Intra-band non-contig. CA 3DL / Impacted TSs and TRs: LTE
- 2596: RP#65 completed / Impacted TSs and TRs: 36.101, 36.104, 36.133, 36.307, new TR 36.833-6-xy
- 2597: CD:Thu 12/03/15->Sun 15/03/15; Compl:60%->70%; Stat Rep: RP-141084->RP-141732 1st Apr 15: Compl:70%->100% 1st Apr 15: Stat Rep: RP-141732->RP-150013 / Impacted TSs and TRs: 36.141
- 2598: Intra-band non-contig. CA 2DL / Impacted TSs and TRs: LTE
- 2599: RP#64 completed. Updated WID RP-140404=>RP-140671. TR 36.833-2-42v100 for 1-step Approval / Impacted TSs and TRs: 36.101, 36.104, 36.133, new TR 36.833-2-42
- 2600: RP#64 completed / Impacted TSs and TRs: 36.141, 36.307
- 2601: Inter-band CA 3DL / Impacted TSs and TRs: LTE
- 2602: RP#65 completed. Updated WID RP-132121=>RP-141454 / Impacted TSs and TRs: 36.101, 36.104, 36.133, new generic TR 36.853 (3 Band CA with 1UL)
- 2603: RP#65 completed. Updated WID RP-132121=>RP-141454 / Impacted TSs and TRs: 36.141, 36.307
- 2604: Inter-band CA 3DL / Impacted TSs and TRs: LTE
- 2605: RP#65 completed. Updated WID RP-141017=>RP-141222 / Impacted TSs and TRs: 36.101, 36.104, 36.133, new generic TR 36.851 (2 Band CA with 1UL), TR 36.853 (3 Band CA with 1UL)
- 2606: RP#65 completed / Impacted TSs and TRs: 36.101, 36.133, 36.141, 36.307
- 2607: Inter-band CA 3DL / Impacted TSs and TRs: LTE
- 2608: RP#65 completed. Updated WID RP-140243=>RP-141223 / Impacted TSs and TRs: 36.101, 36.104, 36.133, new generic TR 36.853 (3 Band CA with 1UL), TR 36.851 (2 Band CA with 1UL)
- 2609: RP#65 completed / Impacted TSs and TRs: 36.101, 36.133, 36.141, 36.307
- 2610: Inter-band CA 3DL / Impacted TSs and TRs: LTE
- 2611: CD:Thu 11/12/14->Mon 15/12/14; Compl:85%->100%; Stat Rep: RP-141084->RP-141732 / Impacted TSs and TRs: 36.101, 36.104, 36.133, new generic TR 36.853 (3 Band CA with 1UL), TR 36.851 (2 Band CA with 1UL)
- 2612: CD:Thu 11/12/14->Mon 15/12/14; Compl:0%->100%; Stat Rep: RP-141084->RP-141732 / Impacted TSs and TRs: 36.101, 36.133, 36.141, 36.307

| ID | WBS | Task | Duration | Start | Finish | Complete | Baseline start | Baseline finish | Baseline duration | Constraint | Resources | Work | Actual work | Acronym | PCG approved | WI rapporteur name | WI rapporteur e-mail | Release | TSG approved | MCC resp | Special Focus Doc | Acronym_3GU_Export | Status Report | PCG stopped | TSG stopped |
| --- | --- | --- | --- | --- | --- | --- | --- | --- | --- | --- | --- | --- | --- | --- | --- | --- | --- | --- | --- | --- | --- | --- | --- | --- | --- |
| 2613 | 693.79 | **Additional bandwidth combinations for LTE Advanced inter-band Carrier Aggregation of Band 2 and Band 29 and of Band 4 and Band 29** | 4d? | 2014-03-03 A | 2014-03-06 A | 100% | 2014-03-03 | 2014-03-06 | 4d? |  | R4 | 64h | 64h | LTE_DL_FDD700_B29_Bwset | 32 | AT&T | marc.grant@att.com | Rel-12 | 63 | Issam | CA | LTE_DL_FDD700_B29_Bwset |  |  |  |
| 2614 | 693.79.1 | Core part: Additional bandwidth combinations for LTE Advanced inter-band Carrier Aggregation of Band 2 and Band 29 and of Band 4 and Band 29 | 4d? | 2014-03-03 A | 2014-03-06 A | 100% | 2014-03-03 | 2014-03-06 | 4d? | finish no earlier than 2014-03-06 | R4 | 32h | 32h | LTE_DL_FDD700_B29_BWset-Core | 32 | AT&T | marc.grant@att.com | Rel-12 | 63 | Issam | CA | LTE_DL_FDD700_B29_BWset-Core | RP-140428 |  |  |
| 2615 | 693.80 | **Additional bandwidth combination set for LTE Advanced inter-band Carrier Aggregation of Band 3 and Band 20** | 72d? | 2014-03-06 A | 2014-06-13 A | 100% | 2014-03-06 | 2014-06-13 | 72d? |  | R4 | 1152h | 1152h | LTE_CA_B3_B20_BWset | 32 | NSN | iwajlo.angelow@nsn.com | Rel-12 | 63 | Issam | CA | LTE_CA_B3_B20_BWset |  |  |  |
| 2616 | 693.80.1 | Core part: Additional bandwidth combination set for LTE Advanced inter-band Carrier Aggregation of Band 3 and Band 20 | 72d? | 2014-03-06 A | 2014-06-13 A | 100% | 2014-03-06 | 2014-06-13 | 72d? | finish no earlier than 2014-06-13 | R4 | 576h | 576h | LTE_CA_B3_B20_BWset-Core | 32 | NSN | iwajlo.angelow@nsn.com | Rel-12 | 63 | Issam | CA | LTE_CA_B3_B20_BWset-Core | RP-140569 |  |  |
| 2617 | 693.81 | **Additional bandwidth combination set for LTE Advanced inter-band Carrier Aggregation of Band 7 and Band 20** | 72d? | 2014-03-06 A | 2014-06-13 A | 100% | 2014-03-06 | 2014-06-13 | 72d? |  | R4 | 1152h | 1152h | LTE_CA_B7_B20_BWset | 32 | NSN | iwajlo.angelow@nsn.com | Rel-12 | 63 | Issam | CA | LTE_CA_B7_B20_BWset |  |  |  |
| 2618 | 693.81.1 | Core part: Additional bandwidth combination set for LTE Advanced inter-band Carrier Aggregation of Band 7 and Band 20 | 72d? | 2014-03-06 A | 2014-06-13 A | 100% | 2014-03-06 | 2014-06-13 | 72d? | finish no earlier than 2014-06-13 | R4 | 576h | 576h | LTE_CA_B7_B20_BWset-Core | 32 | NSN | iwajlo.angelow@nsn.com | Rel-12 | 63 | Issam | CA | LTE_CA_B7_B20_BWset-Core | RP-140569 |  |  |
| 2619 | 693.82 | **Additional bandwidth combinations for LTE Advanced inter-band Carrier Aggregation to support 3DL fallback** | 72d? | 2014-03-06 A | 2014-06-13 A | 100% | 2014-03-06 | 2014-06-13 | 72d? |  | R4 | 1152h | 1152h | LTE_CA_3DL_FB_BW | 32 | Qualcomm | Fong Gene (gfong@qti.qualcomm.com) | Rel-12 | 63 | Issam | CA | LTE_CA_3DL_FB_BW |  |  |  |
| 2620 | 693.82.1 | Core part: Additional bandwidth combinations for LTE Advanced inter-band Carrier Aggregation to support 3DL fallback | 72d? | 2014-03-06 A | 2014-06-13 A | 100% | 2014-03-06 | 2014-06-13 | 72d? | finish no earlier than 2014-06-13 | R4 | 576h | 576h | LTE_CA_3DL_FB_BW-Core | 32 | Qualcomm | Fong Gene (gfong@qti.qualcomm.com) | Rel-12 | 63 | Issam | CA | LTE_CA_3DL_FB_BW-Core | RP-140569 |  |  |
| 2621 | 693.83 | **LTE Advanced 3 Band Carrier Aggregation (3DL/1UL) of Band 3, Band 7 and Band 7** | 138d? | 2014-03-06 A | 2014-09-12 A | 100% | 2014-03-06 | 2014-09-12 | 137d? |  | R4 | 3296h | 3296h | LTE_CA_B3_B7_B7 | 32 | Nokia Networks | iwajlo.angelow@nsn.com | Rel-12 | 63 | Issam | CA | LTE_CA_B3_B7_B7 |  |  |  |
| 2622 | 693.83.1 | Core part:LTE Advanced 3 Band Carrier Aggregation (3DL/1UL) of Band 3, Band 7 and Band 7 | 137d? | 2014-03-06 A | 2014-09-12 A | 100% | 2014-03-06 | 2014-09-12 | 137d? | finish no earlier than 2014-09-12 | R4 | 1096h | 1096h | LTE_CA_B3_B7_B7-Core | 32 | Nokia Networks | iwajlo.angelow@nsn.com | Rel-12 | 63 | Issam | CA | LTE_CA_B3_B7_B7-Core | RP-141084 |  |  |
| 2623 | 693.83.2 | Perf. part:LTE Advanced 3 Band Carrier Aggregation (3DL/1UL) of Band 3, Band 7 and Band 7 | 137d? | 2014-03-06 A | 2014-09-12 A | 100% | 2014-03-06 | 2014-09-12 | 137d? | finish no earlier than 2014-09-12 | R4 | 1096h | 1096h | LTE_CA_B3_B7_B7-Perf | 32 | Nokia Networks | iwajlo.angelow@nsn.com | Rel-12 | 63 | Issam | CA | LTE_CA_B3_B7_B7-Perf | RP-141084 |  |  |
| 2624 | 693.84 | **LTE Advanced 3 Band Carrier Aggregation (3DL/1UL) of Band 1, Band 19 and Band 21** | 138d? | 2014-03-06 A | 2014-09-12 A | 100% | 2014-03-06 | 2014-09-12 | 137d? |  | R4 | 3296h | 3296h | LTE_CA_B1_B19_B21 | 32 | NTT DOCOMO | teruaki.toeda.zf@nttdocomo.com | Rel-12 | 63 | Issam | CA | LTE_CA_B1_B19_B21 |  |  |  |
| 2625 | 693.84.1 | Core part:LTE Advanced 3 Band Carrier Aggregation (3DL/1UL) of Band 1, Band 19 and Band 21 | 137d? | 2014-03-06 A | 2014-09-12 A | 100% | 2014-03-06 | 2014-09-12 | 137d? | finish no earlier than 2014-09-12 | R4 | 1096h | 1096h | LTE_CA_B1_B19_B21-Core | 32 | NTT DOCOMO | teruaki.toeda.zf@nttdocomo.com | Rel-12 | 63 | Issam | CA | LTE_CA_B1_B19_B21-Core | RP-141084 |  |  |
| 2626 | 693.84.2 | Perf. part:LTE Advanced 3 Band Carrier Aggregation (3DL/1UL) of Band 1, Band 19 and Band 21 | 137d? | 2014-03-06 A | 2014-09-12 A | 100% | 2014-03-06 | 2014-09-12 | 137d? | finish no earlier than 2014-09-12 | R4 | 1096h | 1096h | LTE_CA_B1_B19_B21-Perf | 32 | NTT DOCOMO | teruaki.toeda.zf@nttdocomo.com | Rel-12 | 63 | Issam | CA | LTE_CA_B1_B19_B21-Perf | RP-141084 |  |  |
| 2627 | 693.85 | **LTE Advanced 3 Band Carrier Aggregation (3DL/1UL) of Band 3, Band 3 and Band 7** | 138d? | 2014-03-06 A | 2014-09-12 A | 100% | 2014-03-06 | 2014-09-12 | 137d? |  | R4 | 3296h | 3296h | LTE_CA_B3_B3_B7 | 32 | TeliaSonera | Ralf.Schuh@TeliaSonera.com | Rel-12 | 63 | Issam | CA | LTE_CA_B3_B3_B7 |  |  |  |
| 2628 | 693.85.1 | Core part: LTE-Advanced 3 Band Carrier Aggregation (3DL/1UL) of Band 3, Band 3 and Band 7 | 137d? | 2014-03-06 A | 2014-09-12 A | 100% | 2014-03-06 | 2014-09-12 | 137d? | finish no earlier than 2014-09-12 | R4 | 1096h | 1096h | LTE_CA_B3_B3_B7-Core | 32 | TeliaSonera | Ralf.Schuh@TeliaSonera.com | Rel-12 | 63 | Issam | CA | LTE_CA_B3_B3_B7-Core | RP-141084 |  |  |
| 2629 | 693.85.2 | Perf. part: LTE-Advanced 3 Band Carrier Aggregation (3DL/1UL) of Band 3, Band 3 and Band 7 | 137d? | 2014-03-06 A | 2014-09-12 A | 100% | 2014-03-06 | 2014-09-12 | 137d? | finish no earlier than 2014-09-12 | R4 | 1096h | 1096h | LTE_CA_B3_B3_B7-Perf | 32 | TeliaSonera | Ralf.Schuh@TeliaSonera.com | Rel-12 | 63 | Issam | CA | LTE_CA_B3_B3_B7-Perf | RP-141084 |  |  |
| 2630 | 693.86 | **LTE Advanced intra-band contiguous Carrier Aggregation in Band 40 for 3DL** | 72d? | 2014-03-06 A | 2014-06-13 A | 100% | 2014-03-06 | 2014-06-13 | 72d? |  | R4 | 1728h | 1728h | LTE_CA_C_B40_3DL | 32 | China Mobile | Pan Qun (panqun@chinamobile.com) | Rel-12 | 63 | Issam | CA | LTE_CA_C_B40_3DL |  |  |  |
| 2631 | 693.86.1 | Core part: LTE Advanced intra-band contiguous Carrier Aggregation in Band 40 for 3DL | 72d? | 2014-03-06 A | 2014-06-13 A | 100% | 2014-03-06 | 2014-06-13 | 72d? | finish no earlier than 2014-06-13 | R4 | 576h | 576h | LTE_CA_C_B40_3DL-Core | 32 | China Mobile | Pan Qun (panqun@chinamobile.com) | Rel-12 | 63 | Issam | CA | LTE_CA_C_B40_3DL-Core | RP-140569 |  |  |
| 2632 | 693.86.2 | Perf. part: LTE Advanced intra-band contiguous Carrier Aggregation in Band 40 for 3DL | 72d? | 2014-03-06 A | 2014-06-13 A | 100% | 2014-03-06 | 2014-06-13 | 72d? | finish no earlier than 2014-06-13 | R4 | 576h | 576h | LTE_CA_C_B40_3DL-Perf | 32 | China Mobile | Pan Qun (panqun@chinamobile.com) | Rel-12 | 63 | Issam | CA | LTE_CA_C_B40_3DL-Perf | RP-140569 |  |  |
| 2633 | 693.87 | **Additional bandwidth combination set for LTE Advanced inter-band Carrier Aggregation of Band 4 and Band 12** | 137d? | 2014-03-07 A | 2014-09-12 A | 100% | 2014-03-06 | 2014-12-05 | 197d? |  | R4 | 3288h | 3288h | LTE_CA_B4_B12_BWset | 32 | T-Mobile USA | nelson.ueng@t-mobile.com | Rel-12 | 63 | Issam | CA | LTE_CA_B4_B12_BWset |  |  |  |
| 2634 | 693.87.1 | Core part: Additional bandwidth combination set for LTE Advanced inter-band Carrier Aggregation of Band 4 and Band 12 | 137d? | 2014-03-07 A | 2014-09-12 A | 100% | 2014-03-06 | 2014-12-05 | 197d? | finish no earlier than 2014-09-12 | R4 | 1096h | 1096h | LTE_CA_B4_B12_BWset-Core | 32 | T-Mobile USA | nelson.ueng@t-mobile.com | Rel-12 | 63 | Issam | CA | LTE_CA_B4_B12_BWset-Core | RP-141084 |  |  |
| 2635 | 693.87.2 | Deleted - Perf. part: Additional bandwidth combination set for LTE Advanced inter-band Carrier Aggregation of Band 4 and Band 12 | 137d? | 2014-03-07 A | 2014-09-12 A | 100% | 2014-03-06 | 2014-12-05 | 197d? | finish no earlier than 2014-09-12 | R4 | 1096h | 1096h | LTE_CA_B4_B12_BWset-Perf | 32 | T-Mobile USA | nelson.ueng@t-mobile.com | Rel-12 | 63 | Issam | CA | LTE_CA_B4_B12_BWset-Perf | RP-141084 | PCG-33 | RP-65 |
| 2636 | 693.88 | **LTE Advanced inter-band Carrier Aggregation of Band 41 and Band 42** | 138d? | 2014-03-06 A | 2014-09-12 A | 100% | 2014-03-06 | 2014-09-12 | 137d? |  | R4 | 2776h | 2776h | LTE_CA_B41_B42 | 32 | Huawei | leo.liuye@huawei.com | Rel-12 | 63 | Issam | CA | LTE_CA_B41_B42 |  |  |  |
| 2637 | 693.88.1 | Core part:LTE Advanced inter-band Carrier Aggregation of Band 41 and Band 42 | 72d? | 2014-03-06 A | 2014-09-12 A | 100% | 2014-03-06 | 2014-09-12 | 72d? | finish no earlier than 2014-09-12 | R4 | 576h | 576h | LTE_CA_B41_B42-Core | 32 | Huawei | leo.liuye@huawei.com | Rel-12 | 63 | Issam | CA | LTE_CA_B41_B42-Core | RP-141084 |  |  |
| 2638 | 693.88.2 | Perf. Part:LTE Advanced inter-band Carrier Aggregation of Band 41 and Band 42 | 137d? | 2014-03-07 A | 2014-09-12 A | 100% | 2014-03-06 | 2014-09-12 | 137d? | finish no earlier than 2014-09-12 | R4 | 1096h | 1096h | LTE_CA_B41_B42-Perf | 32 | Huawei | leo.liuye@huawei.com | Rel-12 | 63 | Issam | CA | LTE_CA_B41_B42-Perf | RP-141084 |  |  |

Notes:
- 2613: Inter-band 2DL/1UL / Impacted TSs and TRs: LTE
- 2614: RP#63 approved WI (no Perf. Part) & completed. Rel-10 and Rel-11 versions of 36.307 affected / Impacted TSs and TRs: 36.101, 36.307
- 2615: Inter-band CA 2DL / Impacted TSs and TRs: LTE
- 2616: RP#64 completed / Impacted TSs and TRs: 36.101, TR 36.851
- 2617: Inter-band CA 2DL / Impacted TSs and TRs: LTE
- 2618: RP#64 completed / Impacted TSs and TRs: 36.101, TR 36.851
- 2619: Inter-band CA 2DL / Impacted TSs and TRs: LTE
- 2620: RP#64 completed, Additional BW combinations added for 6 Wis: 3 open Rel-12 Wis (B1_B5_B7, B2_B29_B30, B4_B29_B30) and 3 completed Rel-11 Wis (B3_B5, B4_B5, B4_B12) / Impacted TSs and TRs: 36.101, 36.307
- 2621: Inter-band CA 3DL. Mar15: acronym reverted to LTE_CA_B3_B7_B7_ / Impacted TSs and TRs: LTE
- 2622: RP#65 completed. Updated WID RP-140095=>RP-141196. Mar15: acronym reverted to LTE_CA_B3_B7_B7-Core_ / Impacted TSs and TRs: 36.101, 36.104, 36.133, new generic TR 36.853 (3 Band CA with 1UL)
- 2623: RP#65 completed. Updated WID RP-140095=>RP-141196. Mar15: acronym reverted from LTE_CA_B3_B7_B7-Perf_ / Impacted TSs and TRs: 36.141, 36.307
- 2624: Inter-band CA 3DL / Impacted TSs and TRs: LTE
- 2625: RP#65 completed. Updated WID RP-140106=>RP-141193 / Impacted TSs and TRs: 36.101, 36.104, 36.133, new generic TR 36.853 (3 Band CA with 1UL)
- 2626: RP#65 completed. Updated WID RP-140106=>RP-141193 / Impacted TSs and TRs: 36.141, 36.307
- 2627: Inter-band CA 3DL / Impacted TSs and TRs: LTE
- 2628: RP#65 completed. Updated RP-140390=>RP-141126 / Impacted TSs and TRs: 36.101, 36.104, 36.133, new generic TR 36.853 (3 Band CA with 1UL)
- 2629: RP#65 completed. Updated RP-140390=>RP-141126 / Impacted TSs and TRs: 36.141, 36.307
- 2630: Intra-band contig. CA 3DL / Impacted TSs and TRs: LTE
- 2631: RP#64 completed. Updated WID RP-140453=>RP-140948 / Impacted TSs and TRs: 36.101, 36.104, 36.133, New TR 36.833-5-40
- 2632: RP#64 completed. Updated WID RP-140453=>RP-140948 / Impacted TSs and TRs: 36.141, 36.307
- 2633: Inter-band CA 2DL / Impacted TSs and TRs: LTE
- 2634: RP#65 completed. Updated WID RP-140987=>RP-141235 (removed Perf. Part) / Impacted TSs and TRs: 36.101, generic TR 36.850
- 2635: RP#65 stopped. Updated WID RP-140987=>RP-141235 (removed Perf. Part) / Impacted TSs and TRs: 36.307
- 2636: Inter-band CA 2DL / Impacted TSs and TRs: LTE
- 2637: RP#65 completed / Impacted TSs and TRs: 36.101, 36.104, TR 36.851
- 2638: RP#65 completed / Impacted TSs and TRs: 36.141

| ID | WBS | Task | Duration | Start | Finish | Complete | Baseline start | Baseline finish | Baseline duration | Constraint | Resources | Work | Actual work | Acronym | PCG approved | WI rapporteur name | WI rapporteur e-mail | Release | TSG approved | MCC resp | Special Focus Doc | Acronym_3GU_Export | Status Report |
| --- | --- | --- | --- | --- | --- | --- | --- | --- | --- | --- | --- | --- | --- | --- | --- | --- | --- | --- | --- | --- | --- | --- | --- |
| 2639 | 693.89 | **LTE Advanced 3 Band Carrier Aggregation (3DL/1UL) of Band 4, Band 4, and Band 12** | 138d? | 2014-03-06 A | 2014-09-12 A | 100% | 2014-03-06 | 2014-12-05 | 197d? |  | R4 | 3296h | 3296h | LTE_CA_B4_B4_B12 | 32 | T-Mobile USA | nelson.ueng@t-mobile.com | Rel-12 | 63 | Issam | CA | LTE_CA_B4_B4_B12 |  |
| 2640 | 693.89.1 | Core part:LTE Advanced 3 Band Carrier Aggregation (3DL/1UL) of Band 4, Band 4, and Band 12 | 137d? | 2014-03-06 A | 2014-09-12 A | 100% | 2014-03-06 | 2014-12-05 | 197d? | finish no earlier than 2014-09-12 | R4 | 1096h | 1096h | LTE_CA_B4_B4_B12-Core | 32 | T-Mobile USA | nelson.ueng@t-mobile.com | Rel-12 | 63 | Issam | CA | LTE_CA_B4_B4_B12-Core | RP-141084 |
| 2641 | 693.89.2 | Perf. part:LTE Advanced 3 Band Carrier Aggregation (3DL/1UL) of Band 4, Band 4, and Band 12 | 137d? | 2014-03-07 A | 2014-09-12 A | 100% | 2014-03-06 | 2014-12-05 | 197d? | finish no earlier than 2014-09-12 | R4 | 1096h | 1096h | LTE_CA_B4_B4_B12-Perf | 32 | T-Mobile USA | nelson.ueng@t-mobile.com | Rel-12 | 63 | Issam | CA | LTE_CA_B4_B4_B12-Perf | RP-141084 |
| 2642 | 693.90 | **LTE Advanced 3 Band Carrier Aggregation (3DL/1UL) of Band 2, Band 4, and Band 4** | 138d? | 2014-03-06 A | 2014-09-12 A | 100% | 2014-03-06 | 2014-12-05 | 197d? |  | R4 | 3296h | 3296h | LTE_CA_B2_B4_B4 | 32 | T-Mobile USA | nelson.ueng@T-Mobile.com | Rel-12 | 63 | Issam | CA | LTE_CA_B2_B4_B4 |  |
| 2643 | 693.90.1 | Core part:LTE Advanced 3 Band Carrier Aggregation (3DL/1UL) of Band 2, Band 4, and Band 4 | 137d? | 2014-03-06 A | 2014-09-12 A | 100% | 2014-03-06 | 2014-12-05 | 197d? | finish no earlier than 2014-09-12 | R4 | 1096h | 1096h | LTE_CA_B2_B4_B4-Core | 32 | T-Mobile USA | nelson.ueng@T-Mobile.com | Rel-12 | 63 | Issam | CA | LTE_CA_B2_B4_B4-Core | RP-141084 |
| 2644 | 693.90.2 | Perf. part:LTE Advanced 3 Band Carrier Aggregation (3DL/1UL) of Band 2, Band 4, and Band 4 | 137d? | 2014-03-07 A | 2014-09-12 A | 100% | 2014-03-06 | 2014-12-05 | 197d? | finish no earlier than 2014-09-12 | R4 | 1096h | 1096h | LTE_CA_B2_B4_B4-Perf | 32 | T-Mobile USA | nelson.ueng@T-Mobile.com | Rel-12 | 63 | Issam | CA | LTE_CA_B2_B4_B4-Perf | RP-141084 |
| 2645 | 693.91 | **Additional bandwidth combinations for LTE Advanced intra-band non-contiguous Carrier Aggregation in Band 25** | 138d? | 2014-03-06 A | 2014-09-12 A | 100% | 2014-03-06 | 2014-09-12 | 137d? |  | R4 | 3296h | 3296h | LTE_CA_NC_B25_BWset | 32 | Huawei | Liu Liehai (liuliehai@huawei.com) | Rel-12 | 63 | Issam | CA | LTE_CA_NC_B25_BWset |  |
| 2646 | 693.91.1 | Core part: Additional bandwidth combinations for LTE Advanced intra-band non-contiguous Carrier Aggregation in Band 25 | 137d? | 2014-03-06 A | 2014-09-12 A | 100% | 2014-03-06 | 2014-09-12 | 137d? | finish no earlier than 2014-09-12 | R4 | 1096h | 1096h | LTE_CA_NC_B25_BWset-Core | 32 | Huawei | Liu Liehai (liuliehai@huawei.com) | Rel-12 | 63 | Issam | CA | LTE_CA_NC_B25_BWset-Core | RP-141084 |
| 2647 | 693.91.2 | Perf. part: Additional bandwidth combinations for LTE Advanced intra-band non-contiguous Carrier Aggregation in Band 25 | 137d? | 2014-03-07 A | 2014-09-12 A | 100% | 2014-03-06 | 2014-09-12 | 137d? | finish no earlier than 2014-09-12 | R4 | 1096h | 1096h | LTE_CA_NC_B25_BWset-Perf | 32 | Huawei | Liu Liehai (liuliehai@huawei.com) | Rel-12 | 63 | Issam | CA | LTE_CA_NC_B25_BWset-Perf | RP-141084 |
| 2648 | 693.92 | **Additional bandwidth combination set for LTE Advanced inter-band Carrier Aggregation of Band 2 and Band 4** | 66d? | 2014-06-15 A | 2014-09-15 A | 100% | 2014-06-13 | 2014-09-12 | 66d? |  | R4 | 1056h | 1056h | LTE_CA_B2_B4_Bwset2 | 33 | T-Mobile USA | nelson.ueng@T-Mobile.com | Rel-12 | 64 |  | CA | LTE_CA_B2_B4_BWset |  |
| 2649 | 693.92.1 | Core part: Additional bandwidth combination set 2 for LTE Advanced inter-band Carrier Aggregation of Band 2 and Band 4 | 66d? | 2014-06-15 A | 2014-09-15 A | 100% | 2014-06-13 | 2014-09-12 | 66d? | finish no earlier than 2014-09-15 | R4 | 528h | 528h | LTE_CA_B2_B4_BWset2-Core | 33 | T-Mobile USA | nelson.ueng@T-Mobile.com | Rel-12 | 64 |  | CA | LTE_CA_B2_B4_BWset-Core | RP-141084 |
| 2650 | 693.93 | **Additional bandwidth combination set for LTE Advanced inter-band Carrier Aggregation of Band 2 and Band 5** | 132d? | 2014-06-18 A | 2014-12-15 A | 100% | 2014-06-13 | 2014-09-12 | 66d? |  | R4 | 3168h | 3168h | LTE_CA_B2_B5_BWset | 33 | AT&T | marc.grant@att.com | Rel-12 | 64 |  | CA | LTE_CA_B2_B5_BWset |  |
| 2651 | 693.93.1 | Core part: Additional bandwidth combination set for LTE Advanced inter-band Carrier Aggregation of Band 2 and Band 5 | 132d? | 2014-06-18 A | 2014-12-15 A | 100% | 2014-06-13 | 2014-09-12 | 66d? | finish no earlier than 2014-12-15 | R4 | 1056h | 1056h | LTE_CA_B2_B5_Bwset-Core | 33 | AT&T | marc.grant@att.com | Rel-12 | 64 |  | CA | LTE_CA_B2_B5_Bwset-Core | RP-141732 |
| 2652 | 693.93.2 | Perf. Part: Additional bandwidth combination set for LTE Advanced inter-band Carrier Aggregation of Band 2 and Band 5 | 132d? | 2014-06-18 A | 2014-12-15 A | 100% | 2014-06-13 | 2014-09-12 | 66d? | finish no earlier than 2014-12-15 | R4 | 1056h | 1056h | LTE_CA_B2_B5_BWset-Perf | 33 | AT&T | marc.grant@att.com | Rel-12 | 64 |  | CA | LTE_CA_B2_B5_BWset-Perf | RP-141732 |
| 2653 | 693.94 | **E-UTRA UE demodulation/Channel State Information (CSI) performance requirements for multiple Carrier Aggregation configurations** | 198d? | 2014-06-16 A | 2015-03-15 A | 100% | 2014-06-13 | 2015-03-13 | 196d? |  | R4 | 3152h | 3152h | LTE_CA_Mult | 33 | China Mobile | Zhang Xiaoran (zhangxiaoran@chinamobile.com) | Rel-12 | 64 |  | CA | LTE_CA_Mult |  |
| 2654 | 693.94.1 | Perf. Part: E-UTRA UE demodulation/Channel State Information (CSI) performance requirements for multiple Carrier Aggregation configurations | 196d? | 2014-06-16 A | 2015-03-15 A | 100% | 2014-06-13 | 2015-03-13 | 196d? | finish no earlier than 2015-03-15 | R4 | 1568h | 1568h | LTE_CA_Mult-Perf | 33 | China Mobile | Zhang Xiaoran (zhangxiaoran@chinamobile.com) | Rel-12 | 64 |  | CA | LTE_CA_Mult-Perf | RP-150188 |
| 2655 | 693.95 | **LTE Advanced 3 Band Carrier Aggregation (3DL/1UL) of Band 1, Band 3 and Band 19** | 66d? | 2014-06-16 A | 2014-09-12 A | 100% | 2014-06-13 | 2014-09-12 | 66d? |  | R4 | 1584h | 1584h | LTE_CA_B1_B3_B19 | 33 | NTT DOCOMO | teruaki.toeda.zf@nttdocomo.com | Rel-12 | 64 |  | CA | LTE_CA_B1_B3_B19 |  |
| 2656 | 693.95.1 | Core part:LTE Advanced 3 Band Carrier Aggregation (3DL/1UL) of Band 1, Band 3 and Band 19 | 66d? | 2014-06-16 A | 2014-09-12 A | 100% | 2014-06-13 | 2014-09-12 | 66d? | finish no earlier than 2014-09-12 | R4 | 528h | 528h | LTE_CA_B1_B3_B19-Core | 33 | NTT DOCOMO | teruaki.toeda.zf@nttdocomo.com | Rel-12 | 64 |  | CA | LTE_CA_B1_B3_B19-Core | RP-141084 |
| 2657 | 693.95.2 | Perf. Part:LTE Advanced 3 Band Carrier Aggregation (3DL/1UL) of Band 1, Band 3 and Band 19 | 66d? | 2014-06-16 A | 2014-09-12 A | 100% | 2014-06-13 | 2014-09-12 | 66d? | finish no earlier than 2014-09-12 | R4 | 528h | 528h | LTE_CA_B1_B3_B19-Perf | 33 | NTT DOCOMO | teruaki.toeda.zf@nttdocomo.com | Rel-12 | 64 |  | CA | LTE_CA_B1_B3_B19-Perf | RP-141084 |
| 2658 | 693.96 | **LTE Advanced 3 Band Carrier Aggregation (3DL/1UL) of Band 19, Band 42 and Band 42** | 66d? | 2014-06-16 A | 2014-09-12 A | 100% | 2014-06-13 | 2014-09-12 | 66d? |  | R4 | 1584h | 1584h | LTE_CA_B19_B42_B42 | 33 | NTT DOCOMO | teruaki.toeda.zf@nttdocomo.com | Rel-12 | 64 |  | CA | LTE_CA_B19_B42_B42 |  |
| 2659 | 693.96.1 | Core part:LTE Advanced 3 Band Carrier Aggregation (3DL/1UL) of Band 19, Band 42 and Band 42 | 66d? | 2014-06-16 A | 2014-09-12 A | 100% | 2014-06-13 | 2014-09-12 | 66d? | finish no earlier than 2014-09-12 | R4 | 528h | 528h | LTE_CA_B19_B42_B42-Core | 33 | NTT DOCOMO | teruaki.toeda.zf@nttdocomo.com | Rel-12 | 64 |  | CA | LTE_CA_B19_B42_B42-Core | RP-141084 |
| 2660 | 693.96.2 | Perf. Part:LTE Advanced 3 Band Carrier Aggregation (3DL/1UL) of Band 19, Band 42 and Band 42 | 66d? | 2014-06-16 A | 2014-09-12 A | 100% | 2014-06-13 | 2014-09-12 | 66d? | finish no earlier than 2014-09-12 | R4 | 528h | 528h | LTE_CA_B19_B42_B42-Perf | 33 | NTT DOCOMO | teruaki.toeda.zf@nttdocomo.com | Rel-12 | 64 |  | CA | LTE_CA_B19_B42_B42-Perf | RP-141084 |
| 2661 | 693.97 | **LTE Advanced 3 Band Carrier Aggregation (3DL/1UL) of Band 3, Band 42 and Band 42** | 198d? | 2014-06-16 A | 2015-03-15 A | 100% | 2014-06-13 | 2014-09-12 | 66d? |  | R4 | 4720h | 4720h | LTE_CA_B3_B42_B42 | 33 | NTT DOCOMO | ANDO Kei (kei.andou.ye@nttdocomo.com) | Rel-12 | 64 |  | CA | LTE_CA_B3_B42_B42 |  |
| 2662 | 693.97.1 | Core part:LTE Advanced 3 Band Carrier Aggregation (3DL/1UL) of Band 3, Band 42 and Band 42 | 196d? | 2014-06-16 A | 2015-03-15 A | 100% | 2014-06-13 | 2014-09-12 | 66d? | finish no earlier than 2015-03-15 | R4 | 1568h | 1568h | LTE_CA_B3_B42_B42-Core | 33 | NTT DOCOMO | ANDO Kei (kei.andou.ye@nttdocomo.com) | Rel-12 | 64 |  | CA | LTE_CA_B3_B42_B42-Core | RP-150013 |
| 2663 | 693.97.2 | Perf. Part:LTE Advanced 3 Band Carrier Aggregation (3DL/1UL) of Band 3, Band 42 and Band 42 | 196d? | 2014-06-16 A | 2015-03-15 A | 100% | 2014-06-13 | 2014-09-12 | 66d? | finish no earlier than 2016-03-15 | R4 | 1568h | 1568h | LTE_CA_B3_B42_B42-Perf | 33 | NTT DOCOMO | ANDO Kei (kei.andou.ye@nttdocomo.com) | Rel-12 | 64 |  | CA | LTE_CA_B3_B42_B42-Perf | RP-150013 |

Notes:
- 2639: Inter-band CA 3DL / Impacted TSs and TRs: LTE
- 2640: RP#65 completed. Updated WID RP-140116=>RP-141709 / Impacted TSs and TRs: 36.101, 36.104, 36.133, 36.141, 36.307, generic TR 36.853 (3 Band CA with 1UL)
- 2641: RP#65 completed / Impacted TSs and TRs: 36.101, 36.104, 36.133, 36.141, 36.307
- 2642: Inter-band CA 3DL / Impacted TSs and TRs: LTE
- 2643: RP#65 completed. Updated WID RP-140117=>RP-141236 / Impacted TSs and TRs: 36.101, 36.104, 36.133, 36.141, 36.307, generic TR 36.853 (3 Band CA with 1UL)
- 2644: RP#65 completed / Impacted TSs and TRs: 36.101, 36.104, 36.133, 36.141, 36.307
- 2645: Intra-band non-contig. CA 2DL / Impacted TSs and TRs: LTE
- 2646: RP#65 completed / Impacted TSs and TRs: 36.101, 36.307, TR 36.833-2-25
- 2647: RP#65 completed / Impacted TSs and TRs: 36.307
- 2648: Inter-band CA 2DL. Mar 15: acronym changed from LTE_CA_B2_B4_Bwset_ / Impacted TSs and TRs: LTE
- 2649: Dec 14: Prev CD:Fri 12/09/14; Prev %:100%, title changed. Mar 15: Acronym changed to LTE_CA_B2_B4_BWset2-Core_ / Impacted TSs and TRs: 36.101, 36.851
- 2650: 2DL/1UL / Impacted TSs and TRs: LTE
- 2651: ; WID: RP-142043->RP-141803; Stat Rep: RP-141084->RP-141732 / Impacted TSs and TRs: 36.101, 36.851
- 2652: CD:Thu 11/12/14->Mon 15/12/14; Compl:0%->0%; Stat Rep: RP-141084->RP-141732 / Impacted TSs and TRs: 36.307
- 2653: LTE / Impacted TSs and TRs: LTE
- 2654: CD:Thu 12/03/15->Sun 15/03/15; Compl:10%->90%; Stat Rep: RP-141303->RP-141839 1st Apr 15: Compl:90%->100% 1st Apr 15: Stat Rep: RP-141839->RP-150188 / Impacted TSs and TRs: 36.101
- 2655: Inter-band CA 3DL / Impacted TSs and TRs: LTE
- 2656: RP#65 completed / Impacted TSs and TRs: 36.101, 36.104, 36.133, generic TR 36.853 (3 Band CA with 1UL)
- 2657: RP#65 completed / Impacted TSs and TRs: 36.141, 36.307
- 2658: Inter-band CA 3DL / Impacted TSs and TRs: LTE
- 2659: RP#65 completed / Impacted TSs and TRs: 36.101, 36.104, 36.133, generic TR 36.853 (3 Band CA with 1UL)
- 2660: RP#65 completed / Impacted TSs and TRs: 36.141, 36.307
- 2661: 3DL/1UL / Impacted TSs and TRs: LTE
- 2662: CD:Thu 11/12/14->Sun 15/03/15; Compl:50%->70%; Stat Rep: RP-141084->RP-141732 1st Apr 15: Compl:70%->100% 1st Apr 15: Stat Rep: RP-141732->RP-150013 / Impacted TSs and TRs: 36.101, 36.104, 36.133, generic TR 36.853 (3 Band CA with 1UL)
- 2663: CD:Thu 11/12/14->Tue 15/03/16; Compl:50%->70%; Stat Rep: RP-141084->RP-141732 1st Apr 15: Compl:70%->100% 1st Apr 15: CD:Tue 15/03/16->Sun 15/03/15 1st Apr 15: Stat Rep: RP-141732->RP-150013 / Impacted TSs and TRs: 36.141, 36.307

| ID | WBS | Task | Duration | Start | Finish | Complete | Baseline start | Baseline finish | Baseline duration | Constraint | Resources | Work | Actual work | Acronym | PCG approved | WI rapporteur name | WI rapporteur e-mail | Release | TSG approved | Special Focus Doc | Acronym_3GU_Export | Status Report | MCC resp |
| --- | --- | --- | --- | --- | --- | --- | --- | --- | --- | --- | --- | --- | --- | --- | --- | --- | --- | --- | --- | --- | --- | --- | --- |
| 2664 | 693.98 | **LTE Advanced 3 Band Carrier Aggregation (3DL/1UL) of Band 1, Band 42 and Band 42** | 66d? | 2014-06-16 A | 2014-09-12 A | 100% | 2014-06-13 | 2014-09-12 | 66d? |  | R4 | 1584h | 1584h | LTE_CA_B1_B42_B42 | 33 | NTT DOCOMO | ANDO Kei (kei.andou.ye@nttdocomo.com) | Rel-12 | 64 | CA | LTE_CA_B1_B42_B42 |  |  |
| 2665 | 693.98.1 | Core part:LTE Advanced 3 Band Carrier Aggregation (3DL/1UL) of Band 1, Band 42 and Band 42 | 66d? | 2014-06-16 A | 2014-09-12 A | 100% | 2014-06-13 | 2014-09-12 | 66d? | finish no earlier than 2014-09-12 | R4 | 528h | 528h | LTE_CA_B1_B42_B42-Core | 33 | NTT DOCOMO | ANDO Kei (kei.andou.ye@nttdocomo.com) | Rel-12 | 64 | CA | LTE_CA_B1_B42_B42-Core | RP-141084 |  |
| 2666 | 693.98.2 | Perf. Part:LTE Advanced 3 Band Carrier Aggregation (3DL/1UL) of Band 1, Band 42 and Band 42 | 66d? | 2014-06-16 A | 2014-09-12 A | 100% | 2014-06-13 | 2014-09-12 | 66d? | finish no earlier than 2014-09-12 | R4 | 528h | 528h | LTE_CA_B1_B42_B42-Perf | 33 | NTT DOCOMO | ANDO Kei (kei.andou.ye@nttdocomo.com) | Rel-12 | 64 | CA | LTE_CA_B1_B42_B42-Perf | RP-141084 |  |
| 2667 | 693.99 | **Additional bandwidth combination set for LTE Advanced intra-band contiguous Carrier Aggregation in Band 40 for 3DL** | 66d? | 2014-06-16 A | 2014-09-12 A | 100% | 2014-06-13 | 2014-09-12 | 66d? |  | R4 | 1096h | 1096h | LTE_CA_C_B40_3DL_BW | 33 | TeliaSonera | Ralf.Schuh@TeliaSonera.com | Rel-12 | 64 | CA | LTE_CA_C_B40_3DL_BW |  |  |
| 2668 | 693.99.1 | Core part: Additional bandwidth combination set for LTE Advanced intra-band contiguous Carrier Aggregation in Band 40 for 3DL | 66d? | 2014-06-16 A | 2014-09-12 A | 100% | 2014-06-13 | 2014-09-12 | 66d? | finish no earlier than 2014-09-12 | R4 | 528h | 528h | LTE_CA_C_B40_3DL_BW-Core | 33 | TeliaSonera | Ralf.Schuh@TeliaSonera.com | Rel-12 | 64 | CA | LTE_CA_C_B40_3DL_BW-Core | RP-141084 |  |
| 2669 | 693.99.2 | Perf. part: Additional bandwidth combination set for LTE Advanced intra-band contiguous Carrier Aggregation in Band 40 for 3DL | 5d? | 2014-09-08 A | 2014-09-12 A | 100% |  |  |  | finish no earlier than 2014-09-12 | R4 | 40h | 40h | LTE_CA_C_B40_3DL_BW-Perf | 33 | TeliaSonera | Ralf.Schuh@TeliaSonera.com | Rel-12 | 65 |  | LTE_CA_C_B40_3DL_BW-Perf | RP-141084 |  |
| 2670 | 693.100 | **LTE Advanced inter-band Carrier Aggregation of Band 18 and Band 28** | 3d? | 2014-09-10 A | 2014-09-12 A | 100% | 2014-03-06 | 2015-03-13 | 267d? |  | R4 | 72h | 72h | LTE_CA_B18_B28 | 33 | KDDI | Masaaki Obara (ms-obara@kddi.com) | Rel-12 | 65 | CA | LTE_CA_B18_B28 |  | Issam |
| 2671 | 693.100.1 | Core part:LTE Advanced inter-band Carrier Aggregation of Band 18 and Band 28 | 3d? | 2014-09-10 A | 2014-09-12 A | 100% | 2014-03-06 | 2015-03-13 | 267d? | finish no earlier than 2014-09-12 | R4 | 24h | 24h | LTE_CA_B18_B28-Core | 33 | KDDI | Masaaki Obara (ms-obara@kddi.com) | Rel-12 | 65 | CA | LTE_CA_B18_B28-Core |  | Issam |
| 2672 | 693.100.2 | Perf. Part:LTE Advanced inter-band Carrier Aggregation of Band 18 and Band 28 | 3d? | 2014-09-10 A | 2014-09-12 A | 100% | 2014-03-06 | 2015-03-13 | 267d? | finish no earlier than 2014-09-12 | R4 | 24h | 24h | LTE_CA_B18_B28-Perf | 33 | KDDI | Masaaki Obara (ms-obara@kddi.com) | Rel-12 | 65 | CA | LTE_CA_B18_B28-Perf |  | Issam |
| 2673 | 693.101 | **LTE Advanced inter-band Carrier Aggregation of Band 5 and Band 13** | 206d? | 2014-03-06 A | 2014-12-15 A | 100% | 2014-03-06 | 2014-12-05 | 197d? |  | R4 | 4896h | 4896h | LTE_CA_B5_B13 | 32 | Intel | xinrong.wang@intel.com | Rel-12 | 63 | CA | LTE_CA_B5_B13 |  | Issam |
| 2674 | 693.101.1 | Core part:LTE Advanced inter-band Carrier Aggregation of Band 5 and Band 13 | 203d? | 2014-03-06 A | 2014-12-15 A | 100% | 2014-03-06 | 2014-12-05 | 197d? | finish no earlier than 2014-12-15 | R4 | 1624h | 1624h | LTE_CA_B5_B13-Core | 32 | Intel | xinrong.wang@intel.com | Rel-12 | 63 | CA | LTE_CA_B5_B13-Core | RP-141732 | Issam |
| 2675 | 693.101.2 | Perf. part:LTE Advanced inter-band Carrier Aggregation of Band 5 and Band 13 | 203d? | 2014-03-06 A | 2014-12-15 A | 100% | 2014-03-06 | 2014-12-05 | 197d? | finish no earlier than 2014-12-15 | R4 | 1624h | 1624h | LTE_CA_B5_B13-Perf | 32 | Intel | xinrong.wang@intel.com | Rel-12 | 63 | CA | LTE_CA_B5_B13-Perf | RP-141732 | Issam |
| 2676 | 693.102 | **LTE Advanced 3 Band Carrier Aggregation (3DL/1UL) of Band 2, Band 2 and Band 5** | 206d? | 2014-03-06 A | 2014-12-15 A | 100% | 2014-03-06 | 2014-12-05 | 197d? |  | R4 | 4912h | 4912h | LTE_CA_B2_B2_B5 | 32 | Intel | peiling.zhang@intel.com | Rel-12 | 63 | CA | LTE_CA_B2_B2_B5 |  | Issam |
| 2677 | 693.102.1 | Core part:LTE Advanced 3 Band Carrier Aggregation (3DL/1UL) of Band 2, Band 2 and Band 5 | 205d? | 2014-03-06 A | 2014-12-15 A | 100% | 2014-03-06 | 2014-12-05 | 197d? | finish no earlier than 2014-12-15 | R4 | 1640h | 1640h | LTE_CA_B2_B2_B5-Core | 32 | Intel | peiling.zhang@intel.com | Rel-12 | 63 | CA | LTE_CA_B2_B2_B5-Core | RP-141732 | Issam |
| 2678 | 693.102.2 | Perf. part:LTE Advanced 3 Band Carrier Aggregation (3DL/1UL) of Band 2, Band 2 and Band 5 | 203d? | 2014-03-06 A | 2014-12-15 A | 100% | 2014-03-06 | 2014-12-05 | 197d? | finish no earlier than 2014-12-15 | R4 | 1624h | 1624h | LTE_CA_B2_B2_B5-Perf | 32 | Intel | peiling.zhang@intel.com | Rel-12 | 63 | CA | LTE_CA_B2_B2_B5-Perf | RP-141732 | Issam |
| 2679 | 693.103 | **LTE Advanced 3 Band Carrier Aggregation (3DL/1UL) of Band 4, Band 4 and Band 5** | 206d? | 2014-03-06 A | 2014-12-15 A | 100% | 2014-03-06 | 2014-12-05 | 197d? |  | R4 | 4912h | 4912h | LTE_CA_B4_B4_B5 | 32 | Intel | peiling.zhang@intel.com | Rel-12 | 63 | CA | LTE_CA_B4_B4_B5 |  | Issam |
| 2680 | 693.103.1 | Core part:LTE Advanced 3 Band Carrier Aggregation (3DL/1UL) of Band 4, Band 4 and Band 5 | 205d? | 2014-03-06 A | 2014-12-15 A | 100% | 2014-03-06 | 2014-12-05 | 197d? | finish no earlier than 2014-12-15 | R4 | 1640h | 1640h | LTE_CA_B4_B4_B5-Core | 32 | Intel | peiling.zhang@intel.com | Rel-12 | 63 | CA | LTE_CA_B4_B4_B5-Core | RP-141732 | Issam |
| 2681 | 693.103.2 | Perf. part:LTE Advanced 3 Band Carrier Aggregation (3DL/1UL) of Band 4, Band 4 and Band 5 | 203d? | 2014-03-06 A | 2014-12-15 A | 100% | 2014-03-06 | 2014-12-05 | 197d? | finish no earlier than 2014-12-15 | R4 | 1624h | 1624h | LTE_CA_B4_B4_B5-Perf | 32 | Intel | peiling.zhang@intel.com | Rel-12 | 63 | CA | LTE_CA_B4_B4_B5-Perf | RP-141732 | Issam |
| 2682 | 693.104 | **LTE Advanced 3 Band Carrier Aggregation (3DL/1UL) of Band 2, Band 5 and Band 13** | 206d? | 2014-03-06 A | 2014-12-15 A | 100% | 2014-03-06 | 2014-12-05 | 197d? |  | R4 | 4896h | 4896h | LTE_CA_B2_B5_B13 | 32 | Intel | xinrong.wang@intel.com | Rel-12 | 63 | CA | LTE_CA_B2_B5_B13 |  | Issam |
| 2683 | 693.104.1 | Core part:LTE Advanced 3 Band Carrier Aggregation (3DL/1UL) of Band 2, Band 5 and Band 13 | 203d? | 2014-03-06 A | 2014-12-15 A | 100% | 2014-03-06 | 2014-12-05 | 197d? | finish no earlier than 2014-12-15 | R4 | 1624h | 1624h | LTE_CA_B2_B5_B13-Core | 32 | Intel | xinrong.wang@intel.com | Rel-12 | 63 | CA | LTE_CA_B2_B5_B13-Core | RP-141732 | Issam |
| 2684 | 693.104.2 | Perf. part:LTE Advanced 3 Band Carrier Aggregation (3DL/1UL) of Band 2, Band 5 and Band 13 | 203d? | 2014-03-06 A | 2014-12-15 A | 100% | 2014-03-06 | 2014-12-05 | 197d? | finish no earlier than 2014-12-15 | R4 | 1624h | 1624h | LTE_CA_B2_B5_B13-Perf | 32 | Intel | xinrong.wang@intel.com | Rel-12 | 63 | CA | LTE_CA_B2_B5_B13-Perf | RP-141732 | Issam |
| 2685 | 693.105 | **LTE Advanced 3 Band Carrier Aggregation (3DL/1UL) of Band 4, Band 5 and Band 13** | 206d? | 2014-03-06 A | 2014-12-15 A | 100% | 2014-03-06 | 2014-12-05 | 197d? |  | R4 | 4896h | 4896h | LTE_CA_B4_B5_B13 | 32 | Intel | xinrong.wang@intel.com | Rel-12 | 63 | CA | LTE_CA_B4_B5_B13 |  | Issam |
| 2686 | 693.105.1 | Core part:LTE Advanced 3 Band Carrier Aggregation (3DL/1UL) of Band 4, Band 5 and Band 13 | 203d? | 2014-03-06 A | 2014-12-15 A | 100% | 2014-03-06 | 2014-12-05 | 197d? | finish no earlier than 2014-12-15 | R4 | 1624h | 1624h | LTE_CA_B4_B5_B13-Core | 32 | Intel | xinrong.wang@intel.com | Rel-12 | 63 | CA | LTE_CA_B4_B5_B13-Core | RP-141732 | Issam |
| 2687 | 693.105.2 | Perf. part:LTE Advanced 3 Band Carrier Aggregation (3DL/1UL) of Band 4, Band 5 and Band 13 | 203d? | 2014-03-06 A | 2014-12-15 A | 100% | 2014-03-06 | 2014-12-05 | 197d? | finish no earlier than 2014-12-15 | R4 | 1624h | 1624h | LTE_CA_B4_B5_B13-Perf | 32 | Intel | xinrong.wang@intel.com | Rel-12 | 63 | CA | LTE_CA_B4_B5_B13-Perf | RP-141732 | Issam |

Notes:
- 2664: Inter-band CA 3DL / Impacted TSs and TRs: LTE
- 2665: RP#65 completed / Impacted TSs and TRs: 36.101, 36.104, 36.133, generic TR 36.853 (3 Band CA with 1UL)
- 2666: RP#65 completed / Impacted TSs and TRs: 36.141, 36.307
- 2667: Inter-band CA 3DL / Impacted TSs and TRs: LTE
- 2668: RP#65 completed. Updated WID RP-140950=>RP-141127 / Impacted TSs and TRs: 36.101
- 2669: RP#65 updated WID RP-140950=>RP-141127 (added Perf. Part). Completed. / Impacted TSs and TRs: 36.307
- 2670: Inter-band CA 2DL / Impacted TSs and TRs: LTE
- 2671: RP#65 WID approved & completed. Triggered by revised Rel-13 WID RP-140451=>RP-141610 (take out B18_B28 for Rel-12 from the Rel-13 B1_B18_B28) / Impacted TSs and TRs: 36.101, 36.104, 36.133
- 2672: - / Impacted TSs and TRs: 36.141, 36.307
- 2673: Inter-band CA 2DL / Impacted TSs and TRs: LTE
- 2674: CD:Thu 12/03/15->Mon 15/12/14; Compl:50%->100%; Stat Rep: RP-141084->RP-141732; Release: Rel-13->Rel-12 / Impacted TSs and TRs: 36.101, 36.104, 36.133, generic TR 36.851 (2 Band CA with 1UL)
- 2675: CD:Thu 12/03/15->Mon 15/12/14; Compl:10%->100%; Stat Rep: RP-141084->RP-141732; Release: Rel-13->Rel-12 / Impacted TSs and TRs: 36.101, 36.133, 36.141, 36.307
- 2676: Inter-band CA 3DL / Impacted TSs and TRs: LTE
- 2677: CD:Thu 12/03/15->Mon 15/12/14; Compl:90%->100%; Stat Rep: RP-141084->RP-141732; Release: Rel-13->Rel-12 / Impacted TSs and TRs: 36.101, 36.104, 36.133, generic TR 36.853 (3 Band CA with 1UL)
- 2678: CD:Thu 12/03/15->Mon 15/12/14; Compl:10%->100%; Stat Rep: RP-141084->RP-141732; Release: Rel-13->Rel-12 / Impacted TSs and TRs: 36.101, 36.133, 36.141, 36.307
- 2679: Inter-band CA 3DL / Impacted TSs and TRs: LTE
- 2680: CD:Thu 12/03/15->Mon 15/12/14; Compl:90%->100%; Stat Rep: RP-141084->RP-141732; Release: Rel-13->Rel-12 / Impacted TSs and TRs: 36.101, 36.104, 36.133, generic TR 36.853 (3 Band CA with 1UL)
- 2681: CD:Thu 12/03/15->Mon 15/12/14; Compl:10%->100%; Stat Rep: RP-141084->RP-141732; Release: Rel-13->Rel-12 / Impacted TSs and TRs: 36.101, 36.133, 36.141, 36.307
- 2682: Inter-band CA 3DL / Impacted TSs and TRs: LTE
- 2683: CD:Thu 12/03/15->Mon 15/12/14; Compl:50%->100%; Stat Rep: RP-141084->RP-141732; Release: Rel-13->Rel-12 / Impacted TSs and TRs: 36.101, 36.104, 36.133, generic TR 36.853 (3 Band CA with 1UL)
- 2684: CD:Thu 12/03/15->Mon 15/12/14; Compl:10%->100%; Stat Rep: RP-141084->RP-141732; Release: Rel-13->Rel-12 / Impacted TSs and TRs: 36.101, 36.133, 36.141, 36.307
- 2685: Inter-band CA 3DL / Impacted TSs and TRs: LTE
- 2686: CD:Thu 12/03/15->Mon 15/12/14; Compl:50%->100%; Stat Rep: RP-141084->RP-141732; Release: Rel-13->Rel-12 / Impacted TSs and TRs: 36.101, 36.104, 36.133, generic TR 36.853 (3 Band CA with 1UL)
- 2687: CD:Thu 12/03/15->Mon 15/12/14; Compl:10%->100%; Stat Rep: RP-141084->RP-141732; Release: Rel-13->Rel-12 / Impacted TSs and TRs: 36.101, 36.133, 36.141, 36.307

| ID | WBS | Task | Duration | Start | Finish | Complete | Baseline start | Baseline finish | Baseline duration | Constraint | Resources | Work | Actual work | Acronym | PCG approved | WI rapporteur name | WI rapporteur e-mail | Release | TSG approved | MCC resp | Special Focus Doc | Acronym_3GU_Export | Status Report |
| --- | --- | --- | --- | --- | --- | --- | --- | --- | --- | --- | --- | --- | --- | --- | --- | --- | --- | --- | --- | --- | --- | --- | --- |
| 2688 | 693.106 | **LTE Advanced 3 Band Carrier Aggregation (3DL/1UL) of Band 1, Band 3 and Band 26** | 206d? | 2014-03-06 A | 2014-12-15 A | 100% | 2014-03-06 | 2014-12-05 | 197d? |  | R4 | 4896h | 4896h | LTE_CA_B1_B3_B26 | 32 | China Telecom | Zhao Dong (zhaodong@ctbri.com.cn) | Rel-12 | 63 | Issam | CA | LTE_CA_B1_B3_B26 |  |
| 2689 | 693.106.1 | Core part:LTE Advanced 3 Band Carrier Aggregation (3DL/1UL) of Band 1, Band 3 and Band 26 | 203d? | 2014-03-06 A | 2014-12-15 A | 100% | 2014-03-06 | 2014-12-05 | 197d? | finish no earlier than 2014-12-15 | R4 | 1624h | 1624h | LTE_CA_B1_B3_B26-Core | 32 | China Telecom | Zhao Dong (zhaodong@ctbri.com.cn) | Rel-12 | 63 | Issam | CA | LTE_CA_B1_B3_B26-Core | RP-141732 |
| 2690 | 693.106.2 | Perf. part:LTE Advanced 3 Band Carrier Aggregation (3DL/1UL) of Band 1, Band 3 and Band 26 | 203d? | 2014-03-06 A | 2014-12-15 A | 100% | 2014-03-06 | 2014-12-05 | 197d? | finish no earlier than 2014-12-15 | R4 | 1624h | 1624h | LTE_CA_B1_B3_B26-Perf | 32 | China Telecom | Zhao Dong (zhaodong@ctbri.com.cn) | Rel-12 | 63 | Issam | CA | LTE_CA_B1_B3_B26-Perf | RP-141732 |
| 2691 | 693.107 | **LTE Advanced 3 Band Carrier Aggregation (3DL/1UL) of Band 1, Band 18 and Band 28** | 206d? | 2014-03-06 A | 2014-12-15 A | 100% | 2014-03-06 | 2015-03-13 | 267d? |  | R4 | 4896h | 4896h | LTE_CA_B1_B18_B28 | 32 | KDDI | Masaaki Obara (ms-obara@kddi.com) | Rel-12 | 63 | Issam | CA | LTE_CA_B1_B18_B28 |  |
| 2692 | 693.107.1 | Core part:LTE Advanced 3 Band Carrier Aggregation (3DL/1UL) of Band 1, Band 18 and Band 28 | 203d? | 2014-03-06 A | 2014-12-15 A | 100% | 2014-03-06 | 2015-03-13 | 267d? | finish no earlier than 2014-12-15 | R4 | 1624h | 1624h | LTE_CA_B1_B18_B28-Core | 32 | KDDI | Masaaki Obara (ms-obara@kddi.com) | Rel-12 | 63 | Issam | CA | LTE_CA_B1_B18_B28-Core | RP-141732 |
| 2693 | 693.107.2 | Perf. part:LTE Advanced 3 Band Carrier Aggregation (3DL/1UL) of Band 1, Band 18 and Band 28 | 203d? | 2014-03-11 A | 2014-12-15 A | 100% | 2014-03-06 | 2015-03-13 | 267d? | finish no earlier than 2014-12-15 | R4 | 1624h | 1624h | LTE_CA_B1_B18_B28-Perf | 32 | KDDI | Masaaki Obara (ms-obara@kddi.com) | Rel-12 | 63 | Issam | CA | LTE_CA_B1_B18_B28-Perf | RP-141732 |
| 2694 | 693.108 | **LTE Advanced 3 Band Carrier Aggregation (3DL/1UL) of Band 4, Band 7 and Band 12** | 132d? | 2014-06-18 A | 2014-12-15 A | 100% | 2014-06-13 | 2015-03-13 | 196d? |  | R4 | 3168h | 3168h | LTE_CA_B4_B7_B12 | 33 | Rogers Wireless | pavlo.nebesny@rci.rogers.com | Rel-12 | 64 |  | CA | LTE_CA_B4_B7_B12 |  |
| 2695 | 693.108.1 | Core part:LTE Advanced 3 Band Carrier Aggregation (3DL/1UL) of Band 4, Band 7 and Band 12 | 132d? | 2014-06-18 A | 2014-12-15 A | 100% | 2014-06-13 | 2015-03-13 | 196d? | finish no earlier than 2014-12-15 | R4 | 1056h | 1056h | LTE_CA_B4_B7_B12-Core | 33 | Rogers Wireless | pavlo.nebesny@rci.rogers.com | Rel-12 | 64 |  | CA | LTE_CA_B4_B7_B12-Core | RP-141732 |
| 2696 | 693.108.2 | Perf. Part:LTE Advanced 3 Band Carrier Aggregation (3DL/1UL) of Band 4, Band 7 and Band 12 | 132d? | 2014-06-18 A | 2014-12-15 A | 100% | 2014-06-13 | 2015-03-13 | 196d? | finish no earlier than 2014-12-15 | R4 | 1056h | 1056h | LTE_CA_B4_B7_B12-Perf | 33 | Rogers Wireless | pavlo.nebesny@rci.rogers.com | Rel-12 | 64 |  | CA | LTE_CA_B4_B7_B12-Perf | RP-141732 |
| 2697 | 693.109 | **LTE Advanced 3 Band Carrier Aggregation (3DL/1UL) of Band 4, Band 4 and Band 7** | 132d? | 2014-06-18 A | 2014-12-15 A | 100% | 2014-06-13 | 2015-03-13 | 196d? |  | R4 | 3168h | 3168h | LTE_CA_B4_B4_B7 | 33 | Rogers Wireless | pavlo.nebesny@rci.rogers.com | Rel-12 | 64 |  | CA | LTE_CA_B4_B4_B7 |  |
| 2698 | 693.109.1 | Core part:LTE Advanced 3 Band Carrier Aggregation (3DL/1UL) of Band 4, Band 4 and Band 7 | 132d? | 2014-06-18 A | 2014-12-15 A | 100% | 2014-06-13 | 2015-03-13 | 196d? | finish no earlier than 2014-12-15 | R4 | 1056h | 1056h | LTE_CA_B4_B4_B7-Core | 33 | Rogers Wireless | pavlo.nebesny@rci.rogers.com | Rel-12 | 64 |  | CA | LTE_CA_B4_B4_B7-Core | RP-141732 |
| 2699 | 693.109.2 | Perf. Part:LTE Advanced 3 Band Carrier Aggregation (3DL/1UL) of Band 4, Band 4 and Band 7 | 132d? | 2014-06-18 A | 2014-12-15 A | 100% | 2014-06-13 | 2015-03-13 | 196d? | finish no earlier than 2014-12-15 | R4 | 1056h | 1056h | LTE_CA_B4_B4_B7-Perf | 33 | Rogers Wireless | pavlo.nebesny@rci.rogers.com | Rel-12 | 64 |  | CA | LTE_CA_B4_B4_B7-Perf | RP-141732 |
| 2700 | 693.110 | **LTE Advanced 3 Band Carrier Aggregation (3DL/1UL) of Band 39, Band 41 and Band 41** | 134d? | 2014-06-16 A | 2014-12-15 A | 100% | 2014-06-13 | 2014-12-05 | 126d? |  | R4 | 3184h | 3184h | LTE_CA_B39_B41_B41 | 33 | China Mobile | PAN Qun (panqun@chinamobile.com) | Rel-12 | 64 |  | CA | LTE_CA_B39_B41_B41 |  |
| 2701 | 693.110.1 | Core part:LTE Advanced 3 Band Carrier Aggregation (3DL/1UL) of Band 39, Band 41 and Band 41 | 132d? | 2014-06-16 A | 2014-12-15 A | 100% | 2014-06-13 | 2014-12-05 | 126d? | finish no earlier than 2014-12-15 | R4 | 1056h | 1056h | LTE_CA_B39_B41_B41-Core | 33 | China Mobile | PAN Qun (panqun@chinamobile.com) | Rel-12 | 64 |  | CA | LTE_CA_B39_B41_B41-Core | RP-141732 |
| 2702 | 693.110.2 | Perf. Part:LTE Advanced 3 Band Carrier Aggregation (3DL/1UL) of Band 39, Band 41 and Band 41 | 132d? | 2014-06-18 A | 2014-12-15 A | 100% | 2014-06-13 | 2014-12-05 | 126d? | finish no earlier than 2014-12-15 | R4 | 1056h | 1056h | LTE_CA_B39_B41_B41-Perf | 33 | China Mobile | PAN Qun (panqun@chinamobile.com) | Rel-12 | 64 |  | CA | LTE_CA_B39_B41_B41-Perf | RP-141732 |
| 2703 | 693.111 | **LTE Advanced 3 Band Carrier Aggregation (3DL/1UL) of Band 1, Band 41 and Band 41** | 132d? | 2014-06-18 A | 2014-12-15 A | 100% | 2014-06-13 | 2015-03-13 | 196d? |  | R4 | 3168h | 3168h | LTE_CA_B1_B41_B41 | 33 | KDDI | Masaaki Obara (ms-obara@kddi.com) | Rel-12 | 64 |  | CA | LTE_CA_B1_B41_B41 |  |
| 2704 | 693.111.1 | Core part:LTE Advanced 3 Band Carrier Aggregation (3DL/1UL) of Band 1, Band 41 and Band 41 | 132d? | 2014-06-18 A | 2014-12-15 A | 100% | 2014-06-13 | 2015-03-13 | 196d? | finish no earlier than 2014-12-15 | R4 | 1056h | 1056h | LTE_CA_B1_B41_B41-Core | 33 | KDDI | Masaaki Obara (ms-obara@kddi.com) | Rel-12 | 64 |  | CA | LTE_CA_B1_B41_B41-Core | RP-141732 |
| 2705 | 693.111.2 | Perf. Part:LTE Advanced 3 Band Carrier Aggregation (3DL/1UL) of Band 1, Band 41 and Band 41 | 132d? | 2014-06-18 A | 2014-12-15 A | 100% | 2014-06-13 | 2015-03-13 | 196d? | finish no earlier than 2014-12-15 | R4 | 1056h | 1056h | LTE_CA_B1_B41_B41-Perf | 33 | KDDI | Masaaki Obara (ms-obara@kddi.com) | Rel-12 | 64 |  | CA | LTE_CA_B1_B41_B41-Perf | RP-141732 |
| 2706 | 693.112 | **LTE Advanced 3 Band Carrier Aggregation (3DL/1UL) of Band 26, Band 41 and Band 41** | 132d? | 2014-06-18 A | 2014-12-15 A | 100% | 2014-06-13 | 2015-03-13 | 196d? |  | R4 | 3168h | 3168h | LTE_CA_B26_B41_B41 | 33 | KDDI | Masaaki Obara (ms-obara@kddi.com) | Rel-12 | 64 |  | CA | LTE_CA_B26_B41_B41 |  |
| 2707 | 693.112.1 | Core part:LTE Advanced 3 Band Carrier Aggregation (3DL/1UL) of Band 26, Band 41 and Band 41 | 132d? | 2014-06-18 A | 2014-12-15 A | 100% | 2014-06-13 | 2015-03-13 | 196d? | finish no earlier than 2014-12-15 | R4 | 1056h | 1056h | LTE_CA_B26_B41_B41-Core | 33 | KDDI | Masaaki Obara (ms-obara@kddi.com) | Rel-12 | 64 |  | CA | LTE_CA_B26_B41_B41-Core | RP-141732 |
| 2708 | 693.112.2 | Perf. Part:LTE Advanced 3 Band Carrier Aggregation (3DL/1UL) of Band 26, Band 41 and Band 41 | 132d? | 2014-06-18 A | 2014-12-15 A | 100% | 2014-06-13 | 2015-03-13 | 196d? | finish no earlier than 2014-12-15 | R4 | 1056h | 1056h | LTE_CA_B26_B41_B41-Perf | 33 | KDDI | Masaaki Obara (ms-obara@kddi.com) | Rel-12 | 64 |  | CA | LTE_CA_B26_B41_B41-Perf | RP-141732 |
| 2709 | 693.113 | **LTE Advanced 3 Band Carrier Aggregation (3DL/1UL) of Band 25, Band 41 and Band 41** | 68d? | 2014-09-15 A | 2014-12-15 A | 100% | 2014-06-13 | 2015-03-13 | 196d? |  | R4 | 1632h | 1632h | LTE_CA_B25_B41_B41 | 33 | Alcatel-Lucent | Ng, Man Hung (man-hung.ng@alcatel-lucent.com) | Rel-12 | 65 |  | CA | LTE_CA_B25_B41_B41 |  |
| 2710 | 693.113.1 | Core part:LTE Advanced 3 Band Carrier Aggregation (3DL/1UL) of Band 25, Band 41 and Band 41 | 68d? | 2014-09-15 A | 2014-12-15 A | 100% | 2014-06-13 | 2015-03-13 | 196d? | finish no earlier than 2014-12-15 | R4 | 544h | 544h | LTE_CA_B25_B41_B41-Core | 33 | Alcatel-Lucent | Ng, Man Hung (man-hung.ng@alcatel-lucent.com) | Rel-12 | 65 |  | CA | LTE_CA_B25_B41_B41-Core | RP-141732 |
| 2711 | 693.113.2 | Perf. Part:LTE Advanced 3 Band Carrier Aggregation (3DL/1UL) of Band 25, Band 41 and Band 41 | 68d? | 2014-09-15 A | 2014-12-15 A | 100% | 2014-06-13 | 2015-03-13 | 196d? | finish no earlier than 2014-12-15 | R4 | 544h | 544h | LTE_CA_B25_B41_B41-Perf | 33 | Alcatel-Lucent | Ng, Man Hung (man-hung.ng@alcatel-lucent.com) | Rel-12 | 65 |  | CA | LTE_CA_B25_B41_B41-Perf | RP-141732 |

Notes:
- 2688: Inter-band CA 3DL / Impacted TSs and TRs: LTE
- 2689: CD:Thu 11/12/14->Mon 15/12/14; Compl:90%->100%; Stat Rep: RP-141084->RP-141732; Release: Rel-13->Rel-12 / Impacted TSs and TRs: 36.101, 36.104, 36.133, generic TR 36.853 (3 Band CA with 1UL)
- 2690: CD:Thu 11/12/14->Mon 15/12/14; Compl:90%->100%; Stat Rep: RP-141084->RP-141732; Release: Rel-13->Rel-12 / Impacted TSs and TRs: 36.141, 36.307
- 2691: Inter-band CA 3DL / Impacted TSs and TRs: LTE
- 2692: ; WID: RP-142043->RP-141788; Stat Rep: RP-141084->RP-141732; Release: Rel-13->Rel-12 / Impacted TSs and TRs: 36.101, 36.104, 36.133, generic TR 36.853 (3 Band CA with 1UL)
- 2693: ; WID: RP-142043->RP-141788; Stat Rep: RP-141084->RP-141732; Release: Rel-13->Rel-12 / Impacted TSs and TRs: 36.141, 36.307
- 2694: Inter-band CA 3DL/1UL / Impacted TSs and TRs: LTE
- 2695: CD:Thu 12/03/15->Mon 15/12/14; Compl:0%->100%; Stat Rep: RP-141084->RP-141732; Release: Rel-13->Rel-12 / Impacted TSs and TRs: 36.101, 36.104, 36.133, 36.307, generic TR 36.851 (2 Band CA with 1UL), generic TR 36.853 (3 Band CA with 1UL)
- 2696: CD:Thu 12/03/15->Mon 15/12/14; Compl:0%->100%; Stat Rep: RP-141084->RP-141732; Release: Rel-13->Rel-12 / Impacted TSs and TRs: 36.133, 36.141
- 2697: Inter-band CA 3DL/1UL / Impacted TSs and TRs: LTE
- 2698: CD:Thu 12/03/15->Mon 15/12/14; Compl:0%->100%; Stat Rep: RP-141084->RP-141732; Release: Rel-13->Rel-12 / Impacted TSs and TRs: 36.101, 36.104, 36.133, 36.307, generic TR 36.853 (3 Band CA with 1UL)
- 2699: CD:Thu 12/03/15->Mon 15/12/14; Compl:0%->100%; Stat Rep: RP-141084->RP-141732; Release: Rel-13->Rel-12 / Impacted TSs and TRs: 36.133, 36.141
- 2700: Inter-band CA 3DL/1UL / Impacted TSs and TRs: LTE
- 2701: ; WID: RP-140708->RP-142301; Stat Rep: RP-141084->RP-141732; Release: Rel-13->Rel-12 / Impacted TSs and TRs: 36.101, 36.104, 36.133, generic TR 36.853 (3 Band CA with 1UL)
- 2702: ; WID: RP-140708->RP-142301; Stat Rep: RP-141084->RP-141732; Release: Rel-13->Rel-12 / Impacted TSs and TRs: 36.141, 36.307
- 2703: Inter-band CA 3DL/1UL / Impacted TSs and TRs: LTE
- 2704: ; WID: RP-142043->RP-142297; Stat Rep: RP-141084->RP-141732; Release: Rel-13->Rel-12 / Impacted TSs and TRs: 36.101, 36.104, 36.133, generic TR 36.853 (3 Band CA with 1UL)
- 2705: Compl:100%->0%; WID: RP-142043->RP-142297; Stat Rep: RP-141084->RP-141732; Release: Rel-13->Rel-12 / Impacted TSs and TRs: 36.141, 36.307
- 2706: Inter-band CA 3DL/1UL / Impacted TSs and TRs: LTE
- 2707: ; WID: RP-142043->RP-142298; Stat Rep: RP-141084->RP-141732; Release: Rel-13->Rel-12 / Impacted TSs and TRs: 36.101, 36.104, 36.133, generic TR 36.853 (3 Band CA with 1UL)
- 2708: Compl:100%->0%; WID: RP-142043->RP-142298; Stat Rep: RP-141084->RP-141732; Release: Rel-13->Rel-12 / Impacted TSs and TRs: 36.141, 36.307
- 2709: Inter-band CA 3DL/1UL / Impacted TSs and TRs: LTE
- 2710: ; WID: RP-142043->RP-142018; Stat Rep: -->RP-141732; Release: Rel-13->Rel-12 / Impacted TSs and TRs: 36.101, 36.104, 36.307, New TR 36.833-x-yz
- 2711: ; WID: RP-142043->RP-142018; Stat Rep: -->RP-141732; Release: Rel-13->Rel-12 / Impacted TSs and TRs: 36.141

| ID | WBS | Task | Duration | Start | Finish | Complete | Baseline start | Baseline finish | Baseline duration | Constraint | Resources | Work | Actual work | Acronym | PCG approved | WI rapporteur name | WI rapporteur e-mail | Release | TSG approved | Special Focus Doc | Acronym_3GU_Export | Status Report | MCC resp | PCG stopped | TSG stopped |
| --- | --- | --- | --- | --- | --- | --- | --- | --- | --- | --- | --- | --- | --- | --- | --- | --- | --- | --- | --- | --- | --- | --- | --- | --- | --- |
| 2712 | 693.114 | **LTE Advanced 3 Band Carrier Aggregation (3DL/1UL) of Band 39, Band 39 and Band 41** | 68d? | 2014-09-15 A | 2014-12-15 A | 100% | 2014-06-13 | 2015-03-13 | 196d? |  | R4 | 1632h | 1632h | LTE_CA_B39_B39_B41 | 33 | China Mobile | PAN, Qun (panqun@chinamobile.com) | Rel-12 | 65 | CA | LTE_CA_B39_B39_B41 |  |  |  |  |
| 2713 | 693.114.1 | Core part:LTE Advanced 3 Band Carrier Aggregation (3DL/1UL) of Band 39, Band 39 and Band 41 | 68d? | 2014-09-15 A | 2014-12-15 A | 100% | 2014-06-13 | 2015-03-13 | 196d? | finish no earlier than 2014-12-15 | R4 | 544h | 544h | LTE_CA_B39_B39_B41-Core | 33 | China Mobile | PAN, Qun (panqun@chinamobile.com) | Rel-12 | 65 | CA | LTE_CA_B39_B39_B41-Core | RP-141732 |  |  |  |
| 2714 | 693.114.2 | Perf. Part:LTE Advanced 3 Band Carrier Aggregation (3DL/1UL) of Band 39, Band 39 and Band 41 | 68d? | 2014-09-15 A | 2014-12-15 A | 100% | 2014-06-13 | 2015-03-13 | 196d? | finish no earlier than 2014-12-15 | R4 | 544h | 544h | LTE_CA_B39_B39_B41-Perf | 33 | China Mobile | PAN, Qun (panqun@chinamobile.com) | Rel-12 | 65 | CA | LTE_CA_B39_B39_B41-Perf | RP-141732 |  |  |  |
| 2715 | 693.115 | **LTE Advanced 3 Band Carrier Aggregation (3DL/1UL) of Band 2, Band 2 and Band 29** | 68d? | 2014-09-15 A | 2014-12-15 A | 100% | 2014-06-13 | 2015-03-13 | 196d? |  | R4 | 1632h | 1632h | LTE_CA_B2_B2_B29 | 33 | AT&T | marc.grant@att.com | Rel-12 | 65 | CA | LTE_CA_B2_B2_B29 |  |  |  |  |
| 2716 | 693.115.1 | Core part:LTE Advanced 3 Band Carrier Aggregation (3DL/1UL) of Band 2, Band 2 and Band 29 | 68d? | 2014-09-15 A | 2014-12-15 A | 100% | 2014-06-13 | 2015-03-13 | 196d? | finish no earlier than 2014-12-15 | R4 | 544h | 544h | LTE_CA_B2_B2_B29-Core | 33 | AT&T | marc.grant@att.com | Rel-12 | 65 | CA | LTE_CA_B2_B2_B29-Core | RP-141732 |  |  |  |
| 2717 | 693.115.2 | Perf. Part:LTE Advanced 3 Band Carrier Aggregation (3DL/1UL) of Band 2, Band 2 and Band 29 | 68d? | 2014-09-15 A | 2014-12-15 A | 100% | 2014-06-13 | 2015-03-13 | 196d? | finish no earlier than 2014-12-15 | R4 | 544h | 544h | LTE_CA_B2_B2_B29-Perf | 33 | AT&T | marc.grant@att.com | Rel-12 | 65 | CA | LTE_CA_B2_B2_B29-Perf | RP-141732 |  |  |  |
| 2718 | 693.116 | **LTE Advanced 3 Band Carrier Aggregation (3DL/1UL) of Band 2, Band 4 and Band 29** | 68d? | 2014-09-15 A | 2014-12-15 A | 100% | 2014-06-13 | 2015-03-13 | 196d? |  | R4 | 1632h | 1632h | LTE_CA_B2_B4_B29 | 33 | Huawei | SHAN Huiping (shanhuiping@huawei.com) | Rel-12 | 65 | CA | LTE_CA_B2_B4_B29 |  |  |  |  |
| 2719 | 693.116.1 | Core part:LTE Advanced 3 Band Carrier Aggregation (3DL/1UL) of Band 2, Band 4 and Band 29 | 68d? | 2014-09-15 A | 2014-12-15 A | 100% | 2014-06-13 | 2015-03-13 | 196d? | finish no earlier than 2014-12-15 | R4 | 544h | 544h | LTE_CA_B2_B4_B29-Core | 33 | Huawei | SHAN Huiping (shanhuiping@huawei.com) | Rel-12 | 65 | CA | LTE_CA_B2_B4_B29-Core | RP-141732 |  |  |  |
| 2720 | 693.116.2 | Perf. Part:LTE Advanced 3 Band Carrier Aggregation (3DL/1UL) of Band 2, Band 4 and Band 29 | 68d? | 2014-09-15 A | 2014-12-15 A | 100% | 2014-06-13 | 2015-03-13 | 196d? | finish no earlier than 2014-12-15 | R4 | 544h | 544h | LTE_CA_B2_B4_B29-Perf | 33 | Huawei | SHAN Huiping (shanhuiping@huawei.com) | Rel-12 | 65 | CA | LTE_CA_B2_B4_B29-Perf | RP-141732 |  |  |  |
| 2721 | 694 | UE Conformance Test Aspects – Further Rel-12 configurations for LTE Advanced Carrier Aggregation | 393d? | 2013-09-15 A | 2015-03-15 A | 100% | 2013-09-09 | 2014-12-05 | 327d? | finish no earlier than 2015-03-15 | R5 | 3144h | 3144h | LTE_CA_Rel12-UEConTest | 31 | Microsoft | jussi.kuusisto@microsoft.com | Rel-12 | 61 | CA | LTE_CA_Rel12-UEConTest | RP-150076 | Ingbert |  |  |
| 2722 | 695 | UE Conformance Test Aspects – Further Rel-12 configurations for LTE Advanced Carrier Aggregation with 3DL | 394d? | 2014-09-15 A | 2016-03-15 A | 100% |  |  |  | finish no earlier than 2016-03-15 | R5 | 3152h | 3152h | LTE_CA_Rel12_3DL-UEConTest | 33 | Microsoft | jussi.kuusisto@microsoft.com | Rel-12 | 65 | CA | LTE_CA_Rel12_3DL-UEConTest | RP-151464 |  |  |  |
| 2723 | 696 | **Deleted - Carrier based HetNet ICIC for LTE** | 595d? | 2011-03-18 A | 2013-06-14 A | 100% | 2011-03-18 | 2013-06-14 | 595d? |  | R3; R1; R2 | 28560h | 28560h | LTE_CA_HetNet_ICIC | 26 | Nokia Siemens Networks | krzysztof.kordybach@nsn.com | Rel-12 | 51 |  | LTE_CA_HetNet_ICIC |  | Juha | PCG-31 | RP-60 |
| 2724 | 696.1 | Deleted - Core part: Carrier based HetNet ICIC for LTE | 595d? | 2011-03-18 A | 2013-06-14 A | 100% | 2011-03-18 | 2013-06-14 | 595d? | finish no earlier than 2013-06-14 | R3; R1; R2 | 14280h | 14280h | LTE_CA_HetNet_ICIC-Core | 26 | Nokia Siemens Networks | krzysztof.kordybach@nsn.com | Rel-12 | 51 |  | LTE_CA_HetNet_ICIC-Core | RP-130500 | Juha | PCG-31 | RP-60 |
| 2725 | 697 | **LTE in the US Wireless Communications Service (WCS) Band 30** | 600d? | 2012-09-12 A | 2014-12-15 A | 100% | 2012-09-12 | 2014-12-05 | 591d? |  | R4; R2; R5 | 20312h | 20312h | LTE_WCS_band | 29 | AT&T | marc.grant@att.com | Rel-12 | 57 |  | LTE_WCS_band |  | Issam |  |  |
| 2726 | 697.1 | Core part: LTE in the US Wireless Communications Service (WCS) Band 30 | 202d? | 2012-09-12 A | 2013-06-14 A | 100% | 2012-09-12 | 2013-06-14 | 202d? | finish no earlier than 2013-06-14 | R4; R2 | 3232h | 3232h | LTE_WCS_band-Core | 29 | AT&T | marc.grant@att.com | Rel-12 | 57 |  | LTE_WCS_band-Core | RP-130569 | Issam |  |  |
| 2727 | 697.2 | Perf. Part: LTE in the US Wireless Communications Service (WCS) Band 30 | 201d? | 2012-09-13 A | 2013-06-14 A | 100% | 2012-09-13 | 2013-06-14 | 201d? | finish no earlier than 2013-06-14 | R4 | 1608h | 1608h | LTE_WCS_band-Perf | 29 | AT&T | marc.grant@att.com | Rel-12 | 57 |  | LTE_WCS_band-Perf | RP-130570 | Issam |  |  |
| 2728 | 697.3 | Test Part: LTE in the US Wireless Communications Service (WCS) Band 30 | 134d? | 2014-06-15 A | 2014-12-15 A | 100% | 2014-06-13 | 2014-12-05 | 126d? | finish no earlier than 2014-12-15 | R5 | 1072h | 1072h | LTE_WCS_band-UEConTest | 33 | Ericsson | fredrik.sundstrom@ericsson.com | Rel-12 | 64 |  | LTE_WCS_band-UEConTest | RP-141773 |  |  |  |
| 2729 | 698 | **Introduction of LTE 450 MHz band in Brazil** | 331d? | 2012-09-11 A | 2013-12-06 A | 100% | 2012-09-11 | 2013-12-06 | 331d? |  | R4; R5 | 10000h | 10000h | LTE450_Brazil | 29 | Huawei | Liehai Liu (liuliehai@huawei.com) | Rel-12 | 57 |  | LTE450_Brazil |  | Issam |  |  |
| 2730 | 698.1 | Core part: Introduction of LTE 450 MHz band in Brazil | 201d? | 2012-09-11 A | 2013-06-14 A | 100% | 2012-09-11 | 2013-06-14 | 201d? | finish no earlier than 2013-06-14 | R4 | 1608h | 1608h | LTE450_Brazil-Core | 29 | Huawei | Liehai Liu (liuliehai@huawei.com) | Rel-12 | 57 |  | LTE450_Brazil-Core | RP-130567 | Issam |  |  |
| 2731 | 698.2 | Perf. part: Introduction of LTE 450 MHz band in Brazil | 261d? | 2012-09-13 A | 2013-09-06 A | 100% | 2012-09-13 | 2013-09-06 | 261d? | finish no earlier than 2013-09-06 | R4 | 2088h | 2088h | LTE450_Brazil-Perf | 29 | Huawei | Liehai Liu (liuliehai@huawei.com) | Rel-12 | 57 |  | LTE450_Brazil-Perf | RP-131070 | Issam |  |  |
| 2732 | 698.3 | Test part: Introduction of LTE 450 MHz band in Brazil | 126d? | 2013-06-18 A | 2013-12-06 A | 100% | 2013-06-18 | 2013-12-06 | 126d? | finish no earlier than 2013-12-06 | R5 | 1008h | 1008h | LTE450_Brazil-UEConTest | 31 | Huawei | Xiang Li (tricia.li@huawei.com) | Rel-12 | 60 |  | LTE450_Brazil-UEConTest | RP-131457 | Ingbert |  |  |
| 2733 | 699 | **Further Downlink MIMO Enhancement for LTE Advanced** | 927d? | 2012-09-11 A | 2016-03-15 A | 100% | 2012-09-11 | 2014-09-12 | 532d? |  | R1; R4 | 25384.8h | 25384.8h | LTE_eDL_MIMO_enh | 29 | Alcatel-Lucent | Min Zhang (min.hs.zhang@alcatel-lucent.com) | Rel-12 | 57 |  | LTE_eDL_MIMO_enh |  | Patrick |  |  |
| 2734 | 699.1 | Core part: Further Downlink MIMO Enhancement for LTE Advanced | 464d? | 2012-09-11 A | 2014-06-13 A | 100% | 2012-09-11 | 2014-06-13 | 464d? | finish no earlier than 2014-06-13 | R1 | 3696.76h | 3696.76h | LTE_eDL_MIMO_enh-Core | 29 | Alcatel-Lucent | Min Zhang (min.hs.zhang@alcatel-lucent.com) | Rel-12 | 57 |  | LTE_eDL_MIMO_enh-Core | RP-140652 | Patrick |  |  |
| 2735 | 699.2 | Perf. part: Further Downlink MIMO Enhancement for LTE Advanced | 595d? | 2012-09-15 A | 2014-12-15 A | 100% | 2012-09-18 | 2014-09-12 | 526d? | finish no earlier than 2014-12-15 | R4 | 4760h | 4760h | LTE_eDL_MIMO_enh-Perf | 29 | Alcatel-Lucent | ren.da@alcatel-lucent.com | Rel-12 | 57 |  | LTE_eDL_MIMO_enh-Perf | RP-142042 | Issam |  |  |
| 2736 | 699.3 | UE Conformance Test Aspects - Further DL MIMO Enhancement for LTE-Advanced | 262d? | 2015-03-16 A | 2016-03-15 A | 100% |  |  |  | finish no earlier than 2016-03-15 | R5 | 2096h | 2096h | LTE_eDL_MIMO_enh-UEConTest | 34 | ZTE |  | Rel-12 | 67 |  |  | RP-151189 |  |  |  |

Notes:
- 2712: Inter-band CA 3DL/1UL / Impacted TSs and TRs: LTE
- 2713: ; WID: RP-141288->RP-142302; Stat Rep: -->RP-141732; Release: Rel-13->Rel-12 / Impacted TSs and TRs: 36.101, 36.104, 36.133, New TR 36.8xx
- 2714: ; WID: RP-141288->RP-142302; Stat Rep: -->RP-141732; Release: Rel-13->Rel-12 / Impacted TSs and TRs: 36.141, 36.307
- 2715: Inter-band CA 3DL/1UL / Impacted TSs and TRs: LTE
- 2716: CD:Thu 11/12/14->Mon 15/12/14; Compl:0%->100%; Stat Rep: -->RP-141732; Release: Rel-13->Rel-12 / Impacted TSs and TRs: 36.101, 36.104, 36.133, New TR 36.8xx
- 2717: CD:Thu 11/12/14->Mon 15/12/14; Compl:0%->100%; Stat Rep: -->RP-141732; Release: Rel-13->Rel-12 / Impacted TSs and TRs: 36.141, 36.307
- 2718: Inter-band CA 3DL/1UL / Impacted TSs and TRs: LTE
- 2719: CD:Fri 11/12/15->Mon 15/12/14; Compl:0%->100%; Stat Rep: -->RP-141732; Release: Rel-13->Rel-12 / Impacted TSs and TRs: 36.101, 36.104, 36.133, New TR 36.8xx
- 2720: CD:Thu 11/12/14->Mon 15/12/14; Compl:0%->100%; Stat Rep: -->RP-141732; Release: Rel-13->Rel-12 / Impacted TSs and TRs: 36.141, 36.307
- 2721: ; Stat Rep: RP-141444->RP-141774 1st Apr 15: Compl:75%->100% 1st Apr 15: WID: RP-140621->RP-150077 1st Apr 15: Stat Rep: RP-141774->RP-150076 / Impacted TSs and TRs: 36.508, 36.521-1, 36.521-2, 36.521-3, 36.523-1, 36.523-2, 36.523-3, 37.571-1, 37.571-3, 37.571-5
- 2722: ; Stat Rep: -->RP-141775 1st Apr 15: Compl:6%->12% 1st Apr 15: CD:Tue 15/09/15->Tue 15/12/15 1st Apr 15: WID: RP-142231->RP-150079 1st Apr 15: Stat Rep: RP-141775->RP-150078 03/07/15: Compl:12%->35% 03/07/15: WID: RP-150079->RP-150594 03/07/15: Stat Re / Impacted TSs and TRs: 36.508, 36.521-1, 36.521-2, 36.521-3, 36.523-1, 36.523-2, 36.523-3, 37.571-1, 37.571-3, 37.571-5
- 2723: RP#60 stopped. RP#58 on hold til June 2013 / Impacted TSs and TRs: LTE
- 2724: RP#60 stopped at 40% completion. RP#58 on hold til June 2013 / Impacted TSs and TRs: 36.300, 36.413, 36.420, 36.423
- 2725: RP#58 RP-121701 work can start based on FCC Order (FCC-12-130) http://hraunfoss.fcc.gov/edocs_public/attachmatch/FCC-12-130A1.pdf / Impacted TSs and TRs: LTE
- 2726: RP#60 completed. Updated WID RP-121419=>RP-130843 / Impacted TSs and TRs: 36.101, 36.104, 36.113, 36.124, 36.133, 36.307, 36.331, new TR 36.846
- 2727: RP#60 completed. Updated WID RP-121419=>RP-130843 / Impacted TSs and TRs: 36.101, 36.133, 36.141
- 2728: ; Stat Rep: RP-141166->RP-141773 / Impacted TSs and TRs: 36.508, 36.521-1, 36.521-2, 36.521-3, 36.523-2, 36.523-3, 37.571-1
- 2729: - / Impacted TSs and TRs: LTE
- 2730: RP#60 completed. TR 36.840 v100 for 1-step Approval / Impacted TSs and TRs: 36.101, 36.104, 36.113, 36.124, 36.133, 37.104, 37.113, 36.307, new TR 36.840
- 2731: RP#61 completed / Impacted TSs and TRs: 36.133, 36.141, 37.141
- 2732: RP#62 completed / Impacted TSs and TRs: 36.508, 36.521-1, 36.521-2, 36.521-3
- 2733: Stage 3 / Impacted TSs and TRs: LTE
- 2734: RP#64 completed / Impacted TSs and TRs: 36.211, 36.212, 36.213, 36.331
- 2735: ; CD:Fri 12/06/15->Mon 15/06/15; WID: RP-141966->RP-142235; Stat Rep: RP-141378->RP-142042 / Impacted TSs and TRs: 36.101
- 2736: 03/07/15: Compl:0%->10% 03/07/15: Stat Rep: ->RP-150606 29/09/15: Compl:10%->70% 29/09/15: Stat Rep: RP-150606->RP-1511891/1/16: Compl:70%->75%

| ID | WBS | Task | Duration | Start | Finish | Complete | Remaining | Baseline start | Baseline finish | Baseline duration | Total slack | Constraint | Resources | Work | Actual work | Acronym | PCG approved | WI rapporteur name | Release | TSG approved | MCC resp | PCG stopped | TSG stopped | Acronym_3GU_Export | Status Report | Special Focus Doc |
| --- | --- | --- | --- | --- | --- | --- | --- | --- | --- | --- | --- | --- | --- | --- | --- | --- | --- | --- | --- | --- | --- | --- | --- | --- | --- | --- |
| 2737 | 700 | **Deleted - New Carrier Type for LTE** | 265d? | 2012-09-11 A | 2013-09-06 A | 100% |  | 2012-09-11 | 2013-09-06 | 265d? |  |  | R1; R2; R4 | 14808h | 14808h | LTE_NCT | 29 | Ericsson | Rel-12 | 57 | Patrick | PCG-31 | RP-61 | LTE_NCT |  |  |
| 2738 | 700.1 | Deleted - Core part: New Carrier Type for LTE | 265d? | 2012-09-11 A | 2013-09-06 A | 100% |  | 2012-09-11 | 2013-09-06 | 265d? |  | finish no earlier than 2013-09-06 | R1; R2; R4 | 6360h | 6360h | LTE_NCT-Core | 29 | Ericsson | Rel-12 | 57 | Patrick | PCG-31 | RP-61 | LTE_NCT-Core | RP-130984 |  |
| 2739 | 700.2 | Deleted - Perf. part: New Carrier Type for LTE | 261d? | 2012-09-17 A | 2013-09-06 A | 100% |  | 2012-09-17 | 2013-09-06 | 261d? |  | finish no earlier than 2013-09-06 | R4 | 2088h | 2088h | LTE_NCT-Perf | 29 | Ericsson | Rel-12 | 57 | Issam | PCG-31 | RP-61 | LTE_NCT-Perf | RP-130985 |  |
| 2740 | 701 | **Further Enhancements to LTE TDD for DL-UL Interference Management and Traffic Adaptation** | 1385d? | 2012-12-07 A | 2018-03-15 | 99% | 0d? | 2012-12-07 | 2014-12-05 | 527d? | 0d |  | R1; R2; R3; R4 | 56138.6h | 15825.3h | LTE_TDD_eIMTA | 30 | CATT | Rel-12 | 58 | Patrick |  |  | LTE_TDD_eIMTA |  | Small cell |
| 2741 | 701.1 | Core part: Further Enhancements to LTE TDD for DL-UL Interference Management and Traffic Adaptation | 24.58d? | 2012-12-07 A | 2014-06-13 A | 100% |  | 2012-12-07 | 2014-06-13 | 24.58d? |  | finish no earlier than 2014-06-13 | R1; R2; R3; R4 | 786.56h | 786.56h | LTE_TDD_eIMTA-Core | 30 | CATT | Rel-12 | 58 | Patrick |  |  | LTE_TDD_eIMTA-Core | RP-140724 | Small cell |
| 2742 | 701.2 | Perf. part: Further Enhancements to LTE TDD for DL-UL Interference Management and Traffic Adaptation | 725d? | 2012-12-15 A | 2015-09-15 A | 100% |  | 2012-12-07 | 2014-12-05 | 527d? |  | finish no earlier than 2015-09-15 | R4 | 5800h | 5800h | LTE_TDD_eIMTA-Perf | 30 | CATT | Rel-12 | 58 | Patrick |  |  | LTE_TDD_eIMTA-Perf | RP-151447 | Small cell |
| 2743 | 701.3 | UE Conformance Test Aspects - Further Enhancements to LTE TDD for DL-UL Interference Management and Traffic Adaptation | 654d? | 2015-09-15 A | 2018-03-15 A | 100% |  |  |  |  |  | finish no earlier than 2018-03-15 | R5 | 5232h | 5232h | LTE_TDD_eIMTA-UEConTest | 35 | CATT | Rel-12 | 69 |  |  |  |  |  |  |
| 2744 | 702 | **HetNet Mobility enhancements for LTE** | 641.65d? | 2012-04-13 A | 2014-09-12 A | 100% |  | 2012-04-13 | 2014-09-12 | 640.65d? |  |  | R2; R4 | 11624h | 11624h | HetNet_eMOB_LTE | 30 | Alcatel-Lucent | Rel-12 | 58 | Yong-Jun |  |  | HetNet_eMOB_LTE |  |  |
| 2745 | 702.1 | Core part: HetNet Mobility enhancements for LTE | 263.5d? | 2012-04-13 A | 2014-09-12 A | 100% |  | 2012-04-13 | 2014-09-12 | 263.5d? |  | finish no earlier than 2014-09-12 | R2; R4 | 4216h | 4216h | HetNet_eMOB_LTE-Core | 30 | Alcatel-Lucent | Rel-12 | 58 | Yong-Jun |  |  | HetNet_eMOB_LTE-Core | RP-141413 |  |
| 2746 | 703 | **Further enhancements for HeNB mobility-X2-GW** | 401d? | 2012-12-10 A | 2014-06-13 A | 100% |  | 2012-12-10 | 2014-06-13 | 401d? |  |  | R3 | 6408h | 6408h | EHNB_enh2_X2GW | 30 | Alcatel-Lucent | Rel-12 | 58 | Juha |  |  | EHNB_enh2_X2GW |  | HNB |
| 2747 | 703.1 | Core part: Further enhancements for HeNB mobility-X2-GW | 400d? | 2012-12-10 A | 2014-06-13 A | 100% |  | 2012-12-10 | 2014-06-13 | 400d? |  | finish no earlier than 2014-06-13 | R3 | 3200h | 3200h | EHNB_enh2_X2GW-Core | 30 | Alcatel-Lucent | Rel-12 | 58 | Juha |  |  | EHNB_enh2_X2GW-Core | RP-140592 | HNB |
| 2748 | 704 | **8 Rx Antennas for LTE UL** | 265d? | 2012-12-10 A | 2013-12-06 A | 100% |  | 2012-12-10 | 2013-12-06 | 265d? |  |  | R4 | 4208h | 4208h | LTE_UL_8Rx | 30 | China Telecom | Rel-12 | 58 | Issam |  |  | LTE_UL_8Rx |  |  |
| 2749 | 704.1 | Perf. part: 8 Rx Antennas for LTE UL | 261d? | 2012-12-10 A | 2013-12-06 A | 100% |  | 2012-12-10 | 2013-12-06 | 261d? |  | finish no earlier than 2013-12-06 | R4 | 2088h | 2088h | LTE_UL_8Rx-Perf | 30 | China Telecom | Rel-12 | 58 | Issam |  |  | LTE_UL_8Rx-Perf | RP-131523 |  |
| 2750 | 705 | **LTE TDD-FDD joint operation including Carrier Aggregation** | 444.03d? | 2013-04-12 A | 2014-12-15 A | 100% |  | 2013-04-12 | 2014-12-05 | 435.03d? |  |  | R1; R2; R4 | 14776h | 14776h | LTE_CA_TDD_FDD | 31 | Nokia | Rel-12 | 60 | Patrick |  |  | LTE_CA_TDD_FDD |  |  |
| 2751 | 705.1 | Core part: LTE TDD-FDD joint operation including Carrier Aggregation | 87.33d? | 2013-04-12 A | 2014-06-13 A | 100% |  | 2013-04-12 | 2014-06-13 | 87.33d? |  | finish no earlier than 2014-06-13 | R1; R2; R4 | 2096h | 2096h | LTE_CA_TDD_FDD-Core | 31 | Nokia, China Mobile (for TR) | Rel-12 | 60 | Patrick |  |  | LTE_CA_TDD_FDD-Core | RP-140982 |  |
| 2752 | 705.2 | Perf. part: LTE TDD-FDD joint operation including Carrier Aggregation | 397d? | 2013-06-15 A | 2014-12-15 A | 100% |  | 2013-06-20 | 2014-12-05 | 386d? |  | finish no earlier than 2014-12-15 | R4 | 3176h | 3176h | LTE_CA_TDD_FDD-Perf | 31 | Nokia | Rel-12 | 60 | Issam |  |  | LTE_CA_TDD_FDD-Perf | RP-141972 |  |
| 2753 | 706 | **LTE Coverage Enhancements** | 604.17d? | 2013-03-01 A | 2015-06-15 A | 100% |  | 2013-03-01 | 2014-12-05 | 465.17d? |  |  | R1; R2; R4; R5 | 26709.4h | 21348.1h | Cov_Enh_LTE | 31 | China Telecom | Rel-12 | 60 | Patrick |  |  | Cov_Enh_LTE |  |  |
| 2754 | 706.1 | Core part: LTE Coverage Enhancements | 87d? | 2013-03-01 A | 2014-06-13 A | 100% |  | 2013-03-01 | 2014-06-13 | 87d? |  | finish no earlier than 2014-06-13 | R1; R2; R4 | 2088h | 2088h | Cov_Enh_LTE-Core | 31 | China Telecom | Rel-12 | 60 | Patrick |  |  | Cov_Enh_LTE-Core | RP-140683 |  |
| 2755 | 706.2 | Perf. part: LTE Coverage Enhancements | 397d? | 2013-06-15 A | 2014-12-15 A | 100% |  | 2013-06-20 | 2014-12-05 | 386d? |  | finish no earlier than 2014-12-15 | R4 | 3176h | 3176h | Cov_Enh_LTE-Perf | 31 | China Telecom | Rel-12 | 60 | Issam |  |  | Cov_Enh_LTE-Perf | RP-141833 |  |
| 2756 | 706.3 | Test part: LTE Coverage Enhancements | 198d? | 2014-09-15 A | 2015-06-15 A | 100% |  |  |  |  |  | finish no earlier than 2015-09-15 | R5 | 1584h | 1584h | Cov_Enh_LTE-UEConTest | 33 | China Telecom | Rel-12 | 65 |  |  |  | Cov_Enh_LTE-UEConTest | RP-150631 |  |
| 2757 | 707 | **Further MBMS operations support for E-UTRAN** | 330d? | 2013-09-15 A | 2014-12-15 A | 100% |  | 2013-12-09 | 2014-09-12 | 201d? |  |  | R2; R1; R3; R4 | 21280h | 21280h | MBMS_LTE_OS | 31 | Verizon | Rel-12 | 61 | Yong-Jun |  |  | MBMS_LTE_OS |  |  |
| 2758 | 707.1 | Core part: Further MBMS operations support for E-UTRAN | 329d? | 2013-09-15 A | 2014-12-15 A | 100% |  | 2014-04-04 | 2014-09-12 | 115.25d? |  | finish no earlier than 2014-12-15 | R2; R1; R3; R4 | 10528h | 10528h | MBMS_LTE_OS-Core | 31 | Verizon | Rel-12 | 61 | Yong-Jun |  |  | MBMS_LTE_OS-Core | RP-141821 |  |
| 2759 | 707.2 | Perf. part: Further MBMS operations support for E-UTRAN | 264d? | 2013-12-15 A | 2014-12-15 A | 100% |  | 2013-12-09 | 2014-09-12 | 201d? |  | finish no earlier than 2014-12-15 | R4 | 2112h | 2112h | MBMS_LTE_OS-Perf | 32 | Verizon | Rel-12 | 62 | Issam |  |  | MBMS_LTE_OS-Perf | RP-141821 |  |
| 2760 | 708 | **Dual connectivity for LTE** | 985d? | 2013-12-15 A | 2017-09-15 | 99% | 0d? | 2013-12-09 | 2014-12-05 | 261d? | 0d |  | R2; R1; R3; R4; S2; C4 | 55728h | 30528h | LTE_SC_enh_dualC | 32 | NTT DOCOMO | Rel-12 | 62 | Yong-Jun |  |  | LTE_SC_enh_dualC |  | Small cell |
| 2761 | 708.1 | Core part: Dual connectivity for LTE | 264d? | 2013-12-15 A | 2014-12-15 A | 100% |  | 2014-04-29 | 2014-09-12 | 99d? |  | finish no earlier than 2014-12-15 | R2; R1; R3; R4 | 8448h | 8448h | LTE_SC_enh_dualC-Core | 32 | NTT DOCOMO, NEC | Rel-12 | 62 | Yong-Jun |  |  | LTE_SC_enh_dualC-Core | RP-141796 | Small cell |
| 2762 | 708.2 | Perf. part: Dual Connectivity for LTE | 395d? | 2013-12-15 A | 2015-06-15 A | 100% |  | 2013-12-09 | 2014-12-05 | 261d? |  | finish no earlier than 2015-06-15 | R4 | 3160h | 3160h | LTE_SC_enh_dualC-Perf | 32 | NTT DOCOMO | Rel-12 | 62 | Issam |  |  | LTE_SC_enh_dualC-Perf | RP-150791 | Small cell |
| 2763 | 708.3 | SA2 part of Dual connectivity for LTE | 131d? | 2014-03-19 A | 2014-09-17 A | 100% |  | 2014-03-19 | 2014-09-17 | 131d? |  | finish no earlier than 2014-09-17 | S2 | 1048h | 1048h | LTE_SC_enh_dualC-S2 | 32 |  | Rel-12 | 63 |  |  |  |  |  | Small cell |
| 2764 | 708.4 | CT aspects of Dual connectivity for LTE | 63d? | 2014-09-12 A | 2014-12-09 A | 100% |  |  |  |  |  | finish no earlier than 2014-12-09 | C4 | 504h | 504h | LTE_SC_enh_dualC-CT | 33 | Huawei | Rel-12 | 65 |  |  |  | LTE_SC_enh_dualC-CT | CP-140487 | Small cell |
| 2765 | 708.5 | UE Conformance Test Aspects - Dual connectivity for LTE | 591d? | 2015-06-15 A | 2017-09-15 A | 100% |  |  |  |  |  | finish no earlier than 2017-09-15 | R5 | 4728h | 4728h | LTE_SC_enh_dualC-UEConTest | 35 | Ericsson | Rel-12 | 68 |  |  |  |  |  |  |

Notes:
- 2737: RP#61 stopped. Continue discussion on use cases and requirements for a NCT in LTE beyond Rel-12. Action: Ericsson to provide at RP#62 a summary of work done so far / Impacted TSs and TRs: LTE / WI rapporteur e-mail: daniel.n.larsson@ericsson.com
- 2738: RP#61 stopped at 20% completion / Impacted TSs and TRs: 36.101, 36.104, 36.133, 36.211, 36.212, 36.213, 36.321, 36.331 / WI rapporteur e-mail: daniel.n.larsson@ericsson.com
- 2739: RP#61 stopped at 0% completion / Impacted TSs and TRs: 36.101, 36.104, 36.133, 36.141 / WI rapporteur e-mail: daniel.n.larsson@ericsson.com
- 2740: Stage 3. Triggered by Rel-11 TR 36.828 Study on Further Enhancements to LTE TDD for DL-UL Interference Management and Traffic Adaptation (FS_LTE_TDD_eIMTA) UID_510039 / Impacted TSs and TRs: LTE / WI rapporteur e-mail: Zukang Shen (shenzukang@catt.cn)
- 2741: RP#64 completed / Impacted TSs and TRs: 36.101, 36.104, 36.133, 36.211, 36.212, 36.213, 36.214, 36.300, 36.321, 36.331, 36.413, 36.423 / WI rapporteur e-mail: Zukang Shen (shenzukang@catt.cn)
- 2742: ; CD:Thu 18/06/15->Mon 15/06/15; WID: RP-141966->RP-142235; Stat Rep: RP-141342->RP-141948 1st Apr 15: Compl:30%->55% 1st Apr 15: Stat Rep: RP-141948->RP-150154 03/07/15: Compl:55%->95% 03/07/15: CD:Mon 15/06/15->Tue 15/09/15 03/07/15: Stat Rep: RP-150 / Impacted TSs and TRs: 36.101, 36.104, 36.133, 36.141 / WI rapporteur e-mail: Zukang Shen (shenzukang@catt.cn)
- 2743: tested: REL-12 WI LTE_TDD_eIMTA-Core;1/1/16: Compl:0%->5%; 22/3/16: Compl:5%->15% 21/3/...; 19...; 8...27/3/...
- 2744: Stage 3. Triggered by Rel-11 TR 36.839 Study on HetNet mobility enhancements for LTE (FS_HetNet_eMOB_LTE) / Impacted TSs and TRs: LTE / WI rapporteur e-mail: sudeep.palat@alcatel-lucent.com
- 2745: SP#65 completed / Impacted TSs and TRs: 36.133, 36.304, 36.331 / WI rapporteur e-mail: sudeep.palat@alcatel-lucent.com
- 2746: Rel-10 H(e)NB Mobility Enhancements adds signalling via horizontal RAN interfaces (Iurh, X2) to support H(e)NB to H(e)NB mobility. Rel-11 TR37.803 triggered WI UID_560014 partly completed in Rel-11; remaining work including solution definition is Rel-12 / Impacted TSs and TRs: LTE / WI rapporteur e-mail: Philippe.Godin@alcatel-lucent.com
- 2747: RP#64 completed / Impacted TSs and TRs: 36.300, 36.413, 36.423 / WI rapporteur e-mail: Philippe.Godin@alcatel-lucent.com
- 2748: WI has perf. part only (as change from 4Rx to 8Rx has no Core spec impact) / Impacted TSs and TRs: LTE / WI rapporteur e-mail: Shan Yang (yangshan@ctbri.com.cn)
- 2749: RP#62 completed / Impacted TSs and TRs: 36.104, 36.141 / WI rapporteur e-mail: Shan Yang (yangshan@ctbri.com.cn)
- 2750: - / Impacted TSs and TRs: LTE / WI rapporteur e-mail: lars.e.lindh@nokia.com
- 2751: RP#64 completed / Impacted TSs and TRs: 36.101, 36.104, 36.133, 36.201, 36.211, 36.212, 36.213, 36.300, 36.302, 36.306, 36.331, new TR 36.847 / WI rapporteur e-mail: lars.e.lindh@nokia.com, Xiaodong Shen (shenxiaodong@chinamobile.com)
- 2752: ; CD:Thu 18/06/15->Mon 15/06/15; WID: RP-130848->RP-140522; Stat Rep: RP-141374->RP-141972 / Impacted TSs and TRs: 36.101, 36.104, 36.133 / WI rapporteur e-mail: lars.e.lindh@nokia.com
- 2753: Triggered by Rel-11 TR 36.824 (FS_Cov_Enh_LTE) / Impacted TSs and TRs: LTE / WI rapporteur e-mail: Xiaoming She (shexm@ctbri.com.cn)
- 2754: RP#64 completed / Impacted TSs and TRs: 36.101, 36.104, 36.133, 36.211, 36.212, 36.213, 36.300, 36.321, 36.331 / WI rapporteur e-mail: Xiaoming She (shexm@ctbri.com.cn)
- 2755: ; CD:Thu 18/06/15->Mon 15/06/15; WID: RP-141966->RP-142235; Stat Rep: RP-141149->RP-141833 / Impacted TSs and TRs: 36.101, 36.104, 36.133, 36.141 / WI rapporteur e-mail: Xiaoming She (shexm@ctbri.com.cn)
- 2756: ; Stat Rep: -->RP-141834 03/07/15: Compl:5%->100% 03/07/15: CD:Tue 15/09/15->Mon 15/06/15 03/07/15: Stat Rep: RP-141834->RP-150631 / Impacted TSs and TRs: 36.508, 36.523-1, 36.523-2, 36.523-3 / WI rapporteur e-mail: YANG Shan (yangshan@ctbri.com.cn)
- 2757: Solutions for Minimization of Drive Tests (MDT), in order to reduce the need for manual drive testing for MBMS. / Impacted TSs and TRs: LTE / WI rapporteur e-mail: yeesin.chan@verizonwireless.com
- 2758: ; CD:Thu 18/06/15->Mon 15/06/15; WID: RP-130848->RP-140522; Stat Rep: RP-141431->RP-141821 / Impacted TSs and TRs: 36.133, 36.214, 36.300, 36.304, 36.306, 36.331, 36.413, 36.423, 37.320 / WI rapporteur e-mail: yeesin.chan@verizonwireless.com
- 2759: ; CD:Wed 17/12/14->Mon 15/12/14; WID: RP-130848->RP-140522; Stat Rep: RP-141431->RP-141821 / Impacted TSs and TRs: 36.133 / WI rapporteur e-mail: yeesin.chan@verizonwireless.com
- 2760: Triggered by TR 36.842 Study on Small Cell Enhancements for E-UTRA and E-UTRAN Higher-layer aspects (UID_580044) / Impacted TSs and TRs: LTE / WI rapporteur e-mail: tooru.uchino.fv@nttdocomo.com
- 2761: ; CD:Wed 18/03/15->Sun 15/03/15; WID: RP-130848->RP-140522; Stat Rep: RP-141264->RP-141796 / Impacted TSs and TRs: 36.101, 36.104, 36.133, 36.211, 36.212, 36.213, 36.300, 36.302, 36.306, 36.321, 36.322, 36.323, 36.331, 36.410, 36.413, 36.420, 36.423, new RAN3 TS 36.425 / WI rapporteur e-mail: RAN1/2/4 tooru.uchino.fv@nttdocomo.com, RAN3 Chenghock Ng (ngcheng@da.jp.nec.com)
- 2762: ; Stat Rep: RP-141264->RP-141796 1st Apr 15: Compl:15%->45% 1st Apr 15: Stat Rep: RP-141796->RP-150160 03/07/15: Compl:45%->100% 03/07/15: Stat Rep: RP-150160->RP-150791 / Impacted TSs and TRs: 36.101, 36.104, 36.133 / WI rapporteur e-mail: kunihiko.teshima.hg@nttdocomo.com
- 2763: SP#64 Three CRs agreed in SP-140262 (23.251CR0099, 23.401CR2658&CR2707). Dec.14:99->100% / Impacted TSs and TRs: 23.251, 23.401
- 2764: Stage 2/3. CP#65 exception in CP-140487. LM70->100 / Impacted TSs and TRs: 23.007, 23.008, 29.274, 29.281 / WI rapporteur e-mail: Xiaoyan SHI (sean.shixiaoyan@huawei.com)
- 2765: tested Core part: LTE_SC_enh_dualC-Core 29/09/15: Compl:0%->3% 29/09/15: Stat Rep: -->RP-1511671/1/16: Compl:3%->15%1/1/16: CD:Tue 15/03/16->Wed 15/06/16; ...; ...; ;...

| ID | WBS | Task | Duration | Start | Finish | Complete | Baseline start | Baseline finish | Baseline duration | Constraint | Resources | Work | Actual work | Acronym | PCG approved | WI rapporteur name | WI rapporteur e-mail | Release | TSG approved | MCC resp | Special Focus Doc | Acronym_3GU_Export | Status Report |
| --- | --- | --- | --- | --- | --- | --- | --- | --- | --- | --- | --- | --- | --- | --- | --- | --- | --- | --- | --- | --- | --- | --- | --- |
| 2766 | 709 | **E-UTRA Small cell enhancements - Physical layer aspects** | 919d? | 2013-12-15 A | 2017-06-15 A | 100% | 2013-07-19 | 2014-12-05 | 364.75d? |  | R1; R2; R4 | 32364.7h | 32364.7h | LTE_SC_enh_L1 | 32 | Huawei | Elean FAN (fanxiaoan@huawei.com) | Rel-12 | 62 | Patrick | Small cell | LTE_SC_enh_L1 |  |
| 2767 | 709.1 | Core part: E-UTRA Small cell enhancements - Physical layer aspects | 161.25d? | 2013-12-15 A | 2014-12-15 A | 100% | 2013-07-19 | 2014-09-12 | 202d? | finish no earlier than 2014-12-15 | R1; R2; R4 | 3870h | 3870h | LTE_SC_enh_L1-Core | 32 | Huawei | Elean FAN (fanxiaoan@huawei.com) | Rel-12 | 62 | Patrick | Small cell | LTE_SC_enh_L1-Core | RP-141899 |
| 2768 | 709.2 | Perf. part: E-UTRA Small cell enhancements - Physical layer aspects | 394d? | 2013-12-15 A | 2015-06-15 A | 100% | 2013-12-09 | 2014-12-05 | 261d? | finish no earlier than 2015-06-15 | R4 | 3152h | 3152h | LTE_SC_enh_L1-Perf | 32 | Huawei | Elean FAN (fanxiaoan@huawei.com) | Rel-12 | 62 | Issam | Small cell | LTE_SC_enh_L1-Perf | RP-150690 |
| 2769 | 709.3 | UE Conformance Test Aspects - E-UTRA Small cell enhancements - Physical layer aspects | 525d? | 2015-06-15 A | 2017-06-15 A | 100% |  |  |  | finish no earlier than 2017-06-15 | R5 | 4200h | 4200h | LTE_SC_enh_L1-UEConTest | 35 | Huawei |  | Rel-12 | 68 |  |  |  |  |
| 2770 | 710 | **Inter-eNB Coordinated Multi-Point (CoMP) for LTE** | 264d? | 2013-12-15 A | 2014-12-15 A | 100% | 2014-03-14 | 2014-09-12 | 130.65d? |  | R3; R1 | 4738.38h | 4738.38h | COMP_LTE_IeNB | 32 | Samsung | Sung Hwan Won (sunghwan.won@samsung.com) | Rel-12 | 62 | Juha |  | COMP_LTE_IeNB |  |
| 2771 | 710.1 | Core part: Inter-eNB Coordinated Multi-Point (CoMP) for LTE | 165.5d? | 2013-12-15 A | 2014-12-15 A | 100% | 2014-03-14 | 2014-09-12 | 100.5d? | finish no earlier than 2014-12-15 | R3; R1 | 2648h | 2648h | COMP_LTE_IeNB-Core | 32 | Samsung | Sung Hwan Won (sunghwan.won@samsung.com) | Rel-12 | 62 | Juha |  | COMP_LTE_IeNB-Core | RP-141804 |
| 2772 | 711 | **Smart Congestion Mitigation in E-UTRAN** | 403d? | 2014-03-05 A | 2015-09-15 A | 100% | 2014-03-05 | 2014-09-12 | 138d? |  | R2; S1; C1 | 12376h | 12376h | SCM_LTE | 32 | LG Electronics | youngdae.lee@lge.com | Rel-12 | 63 | Yong-Jun |  | SCM_LTE |  |
| 2773 | 711.1 | Core part: Smart Congestion Mitigation in E-UTRAN | 137d? | 2014-03-06 A | 2014-09-12 A | 100% | 2014-03-06 | 2014-09-12 | 137d? | finish no earlier than 2014-09-12 | R2 | 1096h | 1096h | SCM_LTE-Core | 32 | LG Electronics | youngdae.lee@lge.com | Rel-12 | 63 | Yong-Jun |  | SCM_LTE-Core | RP-141292 |
| 2774 | 711.2 | Stage 1 Prioritization of Multimedia Telephony (MMTel) and Mobile Originating-SMS for Access Class Barring (ACB) | 3d? | 2014-03-05 A | 2014-03-07 A | 100% | 2014-03-05 | 2014-03-07 | 3d? | finish no earlier than 2013-12-11 | S1 | 24h | 24h |  | 33 |  |  | Rel-12 | 64 |  |  |  |  |
| 2775 | 711.3 | CT aspects of Smart Congestion Mitigation in E-UTRAN (Stage 3) | 66d? | 2014-06-13 A | 2014-09-11 A | 100% | 2014-06-13 | 2014-09-12 | 66d? | start no earlier than 2014-06-13 | C1 | 528h | 528h | SCM_LTE-CT | 33 | LG Electronics | Kim, Jaehyun (jaehyun7.kim@lge.com) | Rel-12 | 64 |  |  | SCM_LTE-CT |  |
| 2776 | 711.4 | UE Conformance Test Aspects - Smart Congestion Mitigation in E-UTRAN | 132d? | 2015-03-16 A | 2015-09-15 A | 100% |  |  |  | finish no earlier than 2015-09-15 | R5 | 1056h | 1056h | SCM_LTE-UEConTest | 34 | NTT DOCOMO |  | Rel-12 | 67 |  |  |  | RP-151445 |
| 2777 | 712 | **Positioning Enhancements for RF Pattern Matching in E-UTRA** | 36d? | 2014-04-25 A | 2014-06-13 A | 100% | 2014-04-25 | 2014-06-13 | 36d? |  | R3; R2 | 1152h | 1152h | LCS_LTE_RFPMT | 32 | Polaris Wireless | Gordon Scot (sgordon@polariswireless.com) | Rel-12 | 63 | Juha |  | LCS_LTE_RFPMT |  |
| 2778 | 712.1 | Core part: Positioning Enhancements for RF Pattern Matching in E-UTRA | 36d? | 2014-04-25 A | 2014-06-13 A | 100% | 2014-04-25 | 2014-06-13 | 36d? | finish no earlier than 2014-06-13 | R3; R2 | 576h | 576h | LCS_LTE_RFPMT-Core | 32 | Polaris Wireless | Gordon Scot (sgordon@polariswireless.com) | Rel-12 | 63 | Juha |  | LCS_LTE_RFPMT-Core | RP-140591 |
| 2779 | 713 | **Network-Assisted Interference Cancellation and Suppression for LTE** | 791d? | 2014-03-11 A | 2017-03-15 A | 100% | 2014-03-06 | 2015-06-12 | 332d? |  | R1; R2; R4; R3 | 25043.9h | 15467.9h | LTE_NAICS | 32 | MediaTek | Craig.Burnet@mediatek.com | Rel-12 | 63 | Patrick |  | LTE_NAICS |  |
| 2780 | 713.1 | Core part: Network-Assisted Interference Cancellation and Suppression for LTE | 113.67d? | 2014-07-11 A | 2014-12-15 A | 100% | 2014-07-11 | 2014-09-12 | 45.67d? | finish no earlier than 2014-12-15 | R1; R2; R4; R3 | 2803.87h | 2803.87h | LTE_NAICS-Core | 32 | MediaTek | Craig.Burnet@mediatek.com | Rel-12 | 63 | Patrick |  | LTE_NAICS-Core | RP-141866 |
| 2781 | 713.2 | Perf. part: Network-Assisted Interference Cancellation and Suppression for LTE | 399d? | 2014-03-11 A | 2015-09-15 A | 100% | 2014-03-06 | 2015-06-12 | 332d? | finish no earlier than 2015-09-15 | R4 | 3192h | 3192h | LTE_NAICS-Perf | 32 | MediaTek | Craig.Burnet@mediatek.com | Rel-12 | 63 | Issam |  | LTE_NAICS-Perf | RP-151296 |
| 2782 | 713.3 | UE Conformance Test Aspects: Network-Assisted Interference Cancellation and Suppression for LTE | 393d? | 2015-09-15 A | 2017-03-15 A | 100% |  |  |  | finish no earlier than 2017-03-15 | R5 | 3144h | 3144h | LTE_NAICS-UEConTest | 35 | Mediatek |  | Rel-12 | 69 |  |  |  |  |
| 2783 | 714 | **Performance requirements of interference cancellation and suppression receiver for SU-MIMO** | 467d? | 2014-03-06 A | 2015-12-15 A | 100% | 2014-03-06 | 2015-03-13 | 267d? |  | R4 | 7448h | 7448h | LTE_SUMIMO_RX | 32 | Huawei | Qian Cheng (Q.Cheng@Huawei.com) | Rel-12 | 63 | Issam |  | LTE_SUMIMO_RX |  |
| 2784 | 714.1 | Perf. part: Performance requirements of interference cancellation and suppression receiver for SU-MIMO | 267d? | 2014-03-06 A | 2015-03-15 A | 100% | 2014-03-06 | 2015-03-13 | 267d? | finish no earlier than 2015-03-15 | R4 | 2136h | 2136h | LTE_SUMIMO_RX-Perf | 32 | Huawei | Qian Cheng (Q.Cheng@Huawei.com) | Rel-12 | 63 | Issam |  | LTE_SUMIMO_RX-Perf | RP-150229 |
| 2785 | 714.2 | UE Conformance Test Aspects - Performance Requirements of Interference Cancellation and Suppression Receiver for SU-MIMO for E-UTRA | 197d? | 2015-03-16 A | 2015-12-15 A | 100% |  |  |  | finish no earlier than 2016-03-15 | R5 | 1576h | 1576h | LTE_SUMIMO_RX-UEConTest | 34 | Huawei |  | Rel-12 | 67 |  |  |  | RP-151245 |
| 2786 | 715 | **HSPA signalling enhancements for more efficient resource usage for LCR** | 274d? | 2012-12-11 A | 2013-12-20 A | 100% | 2012-12-10 | 2013-12-06 | 265d? |  | R1; R2; R3; R4 | 16832h | 16832h | LCR_TDD_HSPA_sign_enh | 30 | CATT | Yanping Xing (xingyanping@catt.cn) | Rel-12 | 58 | Patrick |  | LCR_TDD_HSPA_sign_enh |  |
| 2787 | 715.1 | Core part: HSPA signalling enhancements for more efficient resource usage for LCR TDD | 270d? | 2012-12-15 A | 2013-12-20 A | 100% | 2012-12-10 | 2013-12-06 | 265d? | finish no earlier than 2013-12-15 | R1; R2; R3 | 6480h | 6480h | LCR_TDD_HSPA_sign_enh-Core | 30 | CATT | Yanping Xing (xingyanping@catt.cn) | Rel-12 | 58 | Patrick |  | LCR_TDD_HSPA_sign_enh-Core | RP-131499 |
| 2788 | 715.2 | Perf. part: HSPA signalling enhancements for more efficient resource usage for LCR TDD | 198d? | 2012-12-11 A | 2013-09-06 A | 100% | 2012-12-11 | 2013-09-06 | 198d? | finish no earlier than 2013-09-06 | R4 | 1584h | 1584h | LCR_TDD_HSPA_sign_enh-Perf | 30 | CATT | Yanping Xing (xingyanping@catt.cn) | Rel-12 | 58 | Issam |  | LCR_TDD_HSPA_sign_enh-Perf | RP-130968 |
| 2789 | 716 | **HNB Positioning for UTRA** | 127d? | 2013-06-18 A | 2013-12-06 A | 100% | 2013-06-18 | 2013-12-06 | 127d? |  | R3 | 2032h | 2032h | UTRA_HNB_Pos | 31 | Alcatel-Lucent | Martin.Warner@alcatel-lucent.com | Rel-12 | 60 | Juha | HNB | UTRA_HNB_Pos |  |
| 2790 | 716.1 | Core part: HNB Positioning for UTRA | 127d? | 2013-06-18 A | 2013-12-06 A | 100% | 2013-06-18 | 2013-12-06 | 127d? | finish no earlier than 2013-12-06 | R3 | 1016h | 1016h | UTRA_HNB_Pos-Core | 31 | Alcatel-Lucent | Martin.Warner@alcatel-lucent.com | Rel-12 | 60 | Juha | HNB | UTRA_HNB_Pos-Core | RP-131974 |

Notes:
- 2766: Triggered by TR 36.872 Study on Small Cell Enhancements for E-UTRA and E-UTRAN Physical-layer aspects (UID_580041) / Impacted TSs and TRs: LTE
- 2767: ; CD:Tue 12/05/15->Mon 15/12/14; WID: RP-130848->RP-140522; Stat Rep: RP-141632->RP-141899 / Impacted TSs and TRs: 36.101, 36.104, 36.133, 36.211, 36.212, 36.213, 36.214, 36.300, 36.306, 36.321, 36.331, 36.413, 36.423, 36.443
- 2768: ; CD:Wed 18/03/15->Sun 15/03/15; WID: RP-130848->RP-140522; Stat Rep: RP-141632->RP-141899 1st Apr 15: Compl:40%->80% 1st Apr 15: CD:Sun 15/03/15->Mon 15/06/15 1st Apr 15: Stat Rep: RP-141899->RP-150173 03/07/15: Compl:80%->100% 03/07/15: Stat Rep: RP- / Impacted TSs and TRs: 36.101, 36.104, 36.133, 36.141
- 2769: tested Core part: LTE_SC_enh_L1-Core 29/09/15: Compl:0%->10% 29/09/15: CD:Wed 15/06/16->Thu 15/12/16 29/09/15: Stat Rep: -->RP-151247; 1/1/16: Compl:10%->40%; ...;...
- 2770: Stage 3. Rel-11 did not address support of a network interface for CoMP involving multiple eNBs with non-ideal backhaul (affected operators might not take advantage of performance benefit from inter-eNB CoMP operation). / Impacted TSs and TRs: LTE
- 2771: CD:Thu 11/12/14->Mon 15/12/14; Compl:85%->100%; Stat Rep: RP-140597->RP-141804 / Impacted TSs and TRs: 36.300, 36.423
- 2772: follow-up of TR 36.848 FS_SCM_LTE / Impacted TSs and TRs: LTE
- 2773: RP#65 completed / Impacted TSs and TRs: 36.331
- 2774: SP#63 SP-140065 CR under TEI12 / Impacted TSs and TRs: 22.011
- 2775: CP#65 completed / Impacted TSs and TRs: 24.173, 24.301, 24.341, 27.007
- 2776: 03/07/15: Compl:0%->60% 03/07/15: WID: RP-150202->RP-150797 03/07/15: Stat Rep: ->RP-150794 29/09/15: Compl:60%->100% 29/09/15: Stat Rep: RP-150794->RP-151445
- 2777: follow-up of TR 36.809 FS_LCS_LTE_RFPMT / Impacted TSs and TRs: LTE
- 2778: RP#64 completed / Impacted TSs and TRs: 36.305, 36.455
- 2779: follow-up of TR 36.866 FS_LTE_NAICS / Impacted TSs and TRs: LTE
- 2780: CD:Mon 08/12/14->Mon 15/12/14; Compl:95%->100%; Stat Rep: RP-141621->RP-141866 / Impacted TSs and TRs: 36.211, 36.213, 36.300, 36.331, 36.423
- 2781: CD:Fri 12/06/15->Mon 15/06/15; Compl:0%->25%; Stat Rep: RP-141621->RP-141866 1st Apr 15: Compl:25%->50% 1st Apr 15: Stat Rep: RP-141866->RP-150179 03/07/15: Compl:50%->85% 03/07/15: CD:Mon 15/06/15->Tue 15/09/15 03/07/15: Stat Rep: RP-150179->RP-150862 / Impacted TSs and TRs: 36.101
- 2782: tested: LTE_NAICS was a REL-12 RAN1 WI; 1/1/16: Compl:0%->35%; 1/1/16: WID: RP-151298->RP-151945; ...
- 2783: no Core part / Impacted TSs and TRs: LTE
- 2784: CD:Fri 13/03/15->Sun 15/03/15; Compl:50%->80%; Stat Rep: RP-141255->RP-141906 1st Apr 15: Compl:80%->100% 1st Apr 15: Stat Rep: RP-141906->RP-150229 / Impacted TSs and TRs: 36.101
- 2785: 03/07/15: Compl:0%->5% 03/07/15: Stat Rep: ->RP-150692 29/09/15: Compl:5%->55% 29/09/15: WID: RP-150245->RP-151463 29/09/15: Stat Rep: RP-150692->RP-1512451/1/16: Compl:55%->100%1/1/16: CD:Tue 15/03/16->Tue 15/1
- 2786: Stage 2/3. Triggered by Rel-11 TR 25.874 Study on HSPA feedback and signalling efficiency enhancements for LCR TDD (FS_LCRTDD_HSPAenh) UID_540026 / Impacted TSs and TRs: UTRA
- 2787: Prev CD:Fri 06/12/13; Prev %:100% / Impacted TSs and TRs: 25.222, 25.224, 25.331, 25.423, 25.433
- 2788: RP#61 completed / Impacted TSs and TRs: 25.102
- 2789: RP#62 completed / Impacted TSs and TRs: UTRA
- 2790: RP#62 closed at 85% completion. Not completed work on HNB positioning / No consensus (may be TEI12, if contribution and support). Updated WID RP-130868=>RP-132037 (HNB positiong was not addressed in this WI, however it was NOT remoded from the WID) / Impacted TSs and TRs: 25.305, 25.467, new TS 25.470

| ID | WBS | Task | Duration | Start | Finish | Complete | Remaining | Baseline start | Baseline finish | Baseline duration | Total slack | Constraint | Resources | Work | Actual work | Acronym | PCG approved | WI rapporteur name | WI rapporteur e-mail | Release | TSG approved | MCC resp | Acronym_3GU_Export | Status Report | Special Focus Doc | PCG stopped | TSG stopped |
| --- | --- | --- | --- | --- | --- | --- | --- | --- | --- | --- | --- | --- | --- | --- | --- | --- | --- | --- | --- | --- | --- | --- | --- | --- | --- | --- | --- |
| 2791 | 717 | **Dedicated Channel (DCH) enhancements for UMTS** | 722d? | 2013-09-15 A | 2016-06-15 A | 100% |  | 2013-09-10 | 2014-12-05 | 326d? |  |  | R1; R2; R3; R4 | 32048h | 32048h | UTRA_DCHenh | 31 | Qualcomm | arjunb@qti.qualcomm.com | Rel-12 | 61 | Patrick | UTRA_DCHenh |  |  |  |  |
| 2792 | 717.1 | Core part: Dedicated Channel (DCH) enhancements for UMTS | 115.25d? | 2013-11-18 A | 2014-09-12 A | 100% |  | 2013-11-18 | 2014-09-12 | 115.25d? |  | finish no earlier than 2014-09-12 | R1; R2; R3; R4 | 3688h | 3688h | UTRA_DCHenh-Core | 31 | Qualcomm | arjunb@qti.qualcomm.com | Rel-12 | 61 | Patrick | UTRA_DCHenh-Core | RP-141137 |  |  |  |
| 2793 | 717.2 | Perf. part: Dedicated Channel (DCH) enhancements for UMTS | 329d? | 2013-09-15 A | 2014-12-15 A | 100% |  | 2013-09-10 | 2014-12-05 | 326d? |  | finish no earlier than 2014-12-15 | R4 | 2632h | 2632h | UTRA_DCHenh-Perf | 31 | Qualcomm | arjunb@qti.qualcomm.com | Rel-12 | 61 | Issam | UTRA_DCHenh-Perf | RP-141970 |  |  |  |
| 2794 | 717.3 | UE Conformance Test Aspects - DCH Enhancements for UMTS | 328d? | 2015-03-16 A | 2016-06-15 A | 100% |  |  |  |  |  | finish no earlier than 2016-06-15 | R5 | 2624h | 2624h | UTRA_DCHenh-UEConTest | 34 | Qualcomm | NA | Rel-12 | 67 |  |  | RP-151279 |  |  |  |
| 2795 | 718 | **UMTS Mobility enhancements for heterogeneous networks** | 237.85d? | 2013-07-23 A | 2014-06-13 A | 100% |  | 2013-07-23 | 2014-06-13 | 237.85d? |  |  | R2; R3; R4 | 8040h | 8040h | UTRA_HetNet_mob | 31 | Huawei | Xudong Yang (yangxudong@huawei.com) | Rel-12 | 61 | Yong-Jun | UTRA_HetNet_mob |  |  |  |  |
| 2796 | 718.1 | Core part: UMTS Mobility enhancements for heterogeneous networks | 67d? | 2013-07-23 A | 2014-06-13 A | 100% |  | 2013-07-23 | 2014-06-13 | 67d? |  | finish no earlier than 2014-06-13 | R2; R3; R4 | 1608h | 1608h | UTRA_HetNet_mob-Core | 31 | Huawei | Xudong Yang (yangxudong@huawei.com) | Rel-12 | 61 | Yong-Jun | UTRA_HetNet_mob-Core | RP-140636 |  |  |  |
| 2797 | 718.2 | Perf. part: UMTS Mobility enhancements for heterogeneous networks | 201d? | 2013-09-09 A | 2014-06-13 A | 100% |  | 2013-09-09 | 2014-06-13 | 201d? |  | finish no earlier than 2014-06-13 | R4 | 1608h | 1608h | UTRA_HetNet_mob-Perf | 31 | Huawei | Xudong Yang (yangxudong@huawei.com) | Rel-12 | 61 | Issam | UTRA_HetNet_mob-Perf | RP-140636 |  |  |  |
| 2798 | 719 | **UMTS Heterogeneous Networks enhancements** | 271d? | 2013-12-06 A | 2014-12-15 A | 100% |  | 2013-12-06 | 2014-12-05 | 262d? |  |  | R1; R2; R3; R4 | 12408h | 12408h | UTRA_HetNet_enh | 32 | Huawei | carmela.cozzo@huawei.com | Rel-12 | 62 | Patrick | UTRA_HetNet_enh |  |  |  |  |
| 2799 | 719.1 | Core part: Heterogeneous Networks enhancements | 202d? | 2013-12-06 A | 2014-09-12 A | 100% |  | 2013-12-06 | 2014-09-12 | 202d? |  | finish no earlier than 2014-09-15 | R1 | 1616h | 1616h | UTRA_HetNet_enh-Core | 32 | Huawei | carmela.cozzo@huawei.com | Rel-12 | 62 | Patrick | UTRA_HetNet_enh-Core | RP-141702 |  |  |  |
| 2800 | 719.2 | Perf. part: Heterogeneous Networks enhancements | 265d? | 2013-12-15 A | 2014-12-15 A | 100% |  | 2013-12-09 | 2014-12-05 | 261d? |  | finish no earlier than 2014-12-15 | R4 | 2120h | 2120h | UTRA_HetNet_enh-Perf | 32 | Huawei | carmela.cozzo@huawei.com | Rel-12 | 62 | Issam | UTRA_HetNet_enh-Perf | RP-141898 |  |  |  |
| 2801 | 720 | **Enhanced Broadcast of System Information** | 271d? | 2013-12-06 A | 2014-12-15 A | 100% |  | 2013-12-06 | 2014-12-05 | 262d? |  |  | R2; R1; R3; R4 | 16385.6h | 16385.6h | UTRA_SIBenh | 32 | Ericsson | martin.van.der.zee@ericsson.com | Rel-12 | 62 | Yong-Jun | UTRA_SIBenh |  |  |  |  |
| 2802 | 720.1 | Core part: Enhanced Broadcast of System Information | 174.8d? | 2013-12-06 A | 2014-09-12 A | 100% |  | 2013-12-06 | 2014-09-12 | 174.8d? |  | finish no earlier than 2014-09-12 | R2; R1; R3; R4 | 5593.6h | 5593.6h | UTRA_SIBenh-Core | 32 | Ericsson | martin.van.der.zee@ericsson.com | Rel-12 | 62 | Yong-Jun | UTRA_SIBenh-Core | RP-141230 |  |  |  |
| 2803 | 720.2 | Perf. part: Enhanced Broadcast of System Information | 265d? | 2013-12-15 A | 2014-12-15 A | 100% |  | 2013-12-09 | 2014-12-05 | 261d? |  | finish no earlier than 2014-12-15 | R4 | 2120h | 2120h | UTRA_SIBenh-Perf | 32 | Ericsson | martin.van.der.zee@ericsson.com | Rel-12 | 62 | Issam | UTRA_SIBenh-Perf | RP-142080 |  |  |  |
| 2804 | 721 | **Further Enhanced Uplink (EUL) enhancements** | 329d? | 2013-12-15 A | 2015-03-15 A | 100% |  | 2013-12-09 | 2014-12-05 | 261d? |  |  | R2 | 13704h | 13704h | EDCH_enh | 32 | Ericsson | mark.curran@ericsson.com | Rel-12 | 62 | Yong-Jun | EDCH_enh |  |  |  |  |
| 2805 | 721.1 | Core part: Further Enhanced Uplink (EUL) enhancements | 264d? | 2013-12-15 A | 2014-12-15 A | 100% |  | 2014-04-29 | 2014-09-12 | 99d? |  | finish no earlier than 2014-12-15 | R2; R1; R3; R4 | 8448h | 8448h | EDCH_enh-Core | 32 | Ericsson | mark.curran@ericsson.com | Rel-12 | 62 | Yong-Jun | EDCH_enh-Core | RP-141860 |  |  |  |
| 2806 | 721.2 | Perf. part: Further Enhanced Uplink (EUL) enhancements | 328d? | 2013-12-15 A | 2015-03-15 A | 100% |  | 2013-12-09 | 2014-12-05 | 261d? |  | finish no earlier than 2015-03-15 | R4 | 2624h | 2624h | EDCH_enh-Perf | 32 | Ericsson | mark.curran@ericsson.com | Rel-12 | 62 | Issam | EDCH_enh-Perf | RP-150062 |  |  |  |
| 2807 | 722 | (Small) Technical Enhancements and Improvements for Rel-12 | 197.5d? | 2012-12-25 A | 2014-09-16 A | 100% |  | 2012-12-25 | 2014-09-17 | 197.5d? |  | finish no earlier than 2014-09-17 | SP; CP; RP; GP | 6320h | 6320h | TEI12 | 29 |  |  | Rel-12 | 56 |  | TEI12 |  |  |  |  |
| 2808 | 723 | (IETF) (Small) Technical Enhancements and Improvements for Rel-12 (draft-ietf-insipid-session-id) | 131d? | 2014-06-13 A | 2014-12-09 A | 100% |  |  |  |  |  | start no earlier than 2014-06-13 | C1-IETF | 1048h | 1048h | TEI12_IETF | 34 | Alcatel-Lucent |  | Rel-12 | 66 |  |  |  |  |  |  |
| 2809 | 724 | Test - (Small) Technical Enhancements and Improvements for Rel-12 | 295.5d? | 2014-10-24 A | 2015-12-11 A | 100% |  | 2014-10-24 | 2015-12-11 | 295.5d? |  | finish no earlier than 2015-12-11 | R5; G3new | 4728h | 4728h | TEI12_Test | 31 |  |  | Rel-12 | 61 | Ingbert | TEI12_Test |  |  |  |  |
| 2810 | 725 | Release 12 Studies | 296.5d? | 2013-08-05 A | 2014-09-17 | 80% | 59.3d? | 2013-08-05 | 2014-09-17 | 296.5d? | 1501d | finish no earlier than 2014-09-17 | SP; CP; GP; RP | 9488h | 7590.4h |  |  |  |  | Rel-12 |  |  |  |  |  |  |  |
| 2811 | 726 | Study on Alternatives to E.164 for Machine-Type Communications | 513d? | 2010-03-25 A | 2012-03-07 A | 100% |  | 2010-03-25 | 2012-03-07 | 513d? |  | finish no earlier than 2012-03-07 | S1 | 4080h | 4080h | FS_AMTC | 24 | T-Mobile USA | gary.jones@T-Mobile.com | Rel-12 | 47 | Alain | FS_AMTC |  | MTC, M2M |  |  |
| 2812 | 727 | Study on enhancements for Machine-Type Communications (MTC) | 720d? | 2010-06-10 A | 2013-03-06 A | 100% |  | 2010-06-10 | 2013-03-06 | 720d? |  | finish no earlier than 2013-03-06 | S1 | 5751.26h | 5751.26h | FS_MTCe | 25 | Huawei | laurence.meriau@huawei.com | Rel-12 | 48 | Alain | FS_MTCe |  | MTC, M2M |  |  |
| 2813 | 728 | Study on Integration of Single Sign-On (SSO) frameworks with 3GPP networks | 383d? | 2010-09-23 A | 2012-03-07 A | 100% |  | 2010-09-23 | 2012-03-07 | 383d? |  | finish no earlier than 2011-09-08 | S1 | 3041.15h | 3041.15h | FS_SSO_Int | 25 | InterDigital | christopher.wallace@interdigital.com | Rel-12 | 49 | Alain | FS_SSO_Int |  |  |  |  |
| 2814 | 729 | Study on Continuity of Data Sessions to Local Networks | 262.85d? | 2010-12-16 A | 2011-12-14 A | 100% |  | 2010-12-16 | 2011-12-14 | 262.85d? |  | finish no earlier than 2011-12-14 | S1 | 2084.27h | 2084.27h | FS_CSN | 26 | NEC | joerg.swetina@neclab.eu | Rel-12 | 50 | Alain | FS_CSN |  |  |  |  |
| 2815 | 730 | Study on non-MTC Mobile Data Applications Impacts | 262.77d? | 2010-12-16 A | 2011-12-14 A | 100% |  | 2010-12-16 | 2011-12-14 | 262.77d? |  | finish no earlier than 2011-12-14 | S1 | 2083.59h | 2083.59h | FS_MODAI | 26 | Huawei, China Mobile | Amar Deol (adeol@huawei.com), Gang Li | Rel-12 | 50 | Alain | FS_MODAI |  |  |  |  |
| 2816 | 731 | Study on Proximity-based Services | 384d? | 2011-09-22 A | 2013-03-05 A | 100% |  | 2011-09-22 | 2013-03-05 | 384d? |  | finish no earlier than 2012-12-12 | S1 | 3045.82h | 3045.82h | FS_ProSe | 27 | Qualcomm | Rich Hovey (rhovey@qualcomm.com) | Rel-12 | 53 | Alain | FS_ProSe |  | Public Safety (A-A) |  |  |
| 2817 | 732 | Study on User Plane Congestion management | 198d? | 2011-12-14 A | 2012-09-12 A | 100% |  | 2011-12-14 | 2012-09-12 | 198d? |  | finish no earlier than 2012-09-12 | S1 | 1568h | 1568h | FS_UPCON | 28 | KDDI | John Visser (jvisser@rogers.com) | Rel-12 | 54 | Alain | FS_UPCON |  |  |  |  |
| 2818 | 733 | Study on RAN Sharing Enhancements | 401d? | 2011-12-14 A | 2013-06-19 A | 100% |  | 2011-12-14 | 2013-06-19 | 401d? |  | finish no earlier than 2013-06-19 | S1 | 3192h | 3192h | FS_RSE | 28 | NEC | joerg.swetina@neclab.eu | Rel-12 | 54 | Alain | FS_RSE |  |  |  |  |
| 2819 | 734 | Deleted - Study on UICC/USIM enhancements | 588d? | 2009-12-10 A | 2012-03-07 A | 100% |  | 2009-12-10 | 2012-03-07 | 588d? |  | finish no earlier than 2012-03-07 | S1 | 4704h | 4704h | FS_U2e | 24 | Giesecke & Devrient | ilario.macchi@gi-de.com | Rel-12 | 46 | Alain | FS_U2e |  |  | PCG-28 | SP-55 |

Notes:
- 2791: Triggered by Rel-12 TR 25.702 Study on Dedicated Channel (DCH) enhancements for UMTS (FS_UTRA_DCHenh) UID_580040. Stage 2/3 / Impacted TSs and TRs: UTRA
- 2792: RP#65 completed / Impacted TSs and TRs: 25.101, 25.104, 25.133, 25.211, 25.212, 25.213, 25.214, 25.215, 25.306, 25.308, 25.321, 25.331, 25.423, 25.433
- 2793: ; Stat Rep: RP-141137->RP-141970 / Impacted TSs and TRs: 25.101, 25.104, 25.133
- 2794: 03/07/15: Compl:0%->15% 03/07/15: Stat Rep: ->RP-150764 29/09/15: Compl:15%->50% 29/09/15: CD:Tue 15/12/15->Wed 15/06/16 29/09/15: Stat Rep: RP-150764->RP-1512791/1/16: Compl:50%->65%;
- 2795: Triggered by Rel-12 TR 25.800 Study on UMTS heterogeneous networks (FS_UTRA_hetnet) UID_570024. Stage 2/3 / Impacted TSs and TRs: UTRA
- 2796: RP#64 completed. TS 25.300v100 for 1-step Approval / Impacted TSs and TRs: 25.101, 25.104, 25.133, 25.141, 25.304, 25.306, 25.331, 25.433, new TS 25.300
- 2797: RP#64 completed / Impacted TSs and TRs: 25.101, 25.104, 25.133, 25.141
- 2798: Triggered by the 2nd part of TR 25.800 (FS_UTRA_HetNet); the 1st part is addressed by UTRA_HetNet_mob UID_610026 / Impacted TSs and TRs: UTRA
- 2799: RP#65 completed. Updated WID RP-140463=>RP-141701 / Impacted TSs and TRs: 25.101, 25.211, 25.212, 25.213, 25.214, 25.300, 25.302, 25.306, 25.308, 25.319, 25.331, 25.423, 25.433
- 2800: ; Stat Rep: RP-141702->RP-141898 / Impacted TSs and TRs: 25.101, 25.104, 25.133, 25.141
- 2801: Triggered by Rel-12 UTRA TR 25.704 Study on Enhanced Broadcast of System Information (FS_UTRA_SIBenh) / Impacted TSs and TRs: UTRA
- 2802: RP#65 completed / Impacted TSs and TRs: 25.211, 25.212 , 25.213, 25.214, 25.301, 25.302, 25.304, 25.306, 25.321, 25.331, 25.433
- 2803: ; Stat Rep: RP-141230->RP-142080 / Impacted TSs and TRs: 25.101, 25.104, 25.133, 25.141
- 2804: Triggered by Rel-12 UTRA TR 25.700 Study on Further Enhanced Uplink (EUL) enhancements (FS_EDCH_enh) / Impacted TSs and TRs: UTRA
- 2805: ; Stat Rep: RP-141684->RP-141860 / Impacted TSs and TRs: 25.211, 25.212, 25.214, 25.304, 25.306, 25.308, 25.319, 25.321, 25.331, 25.423, 25.425, 25.433, 25.435
- 2806: ; CD:Wed 18/03/15->Sun 15/03/15; Stat Rep: RP-141684->RP-141860 1st Apr 15: Compl:75%->100% 1st Apr 15: Stat Rep: RP-141860->RP-150062 / Impacted TSs and TRs: 25.101, 25.104, 25.133, 25.141
- 2807: -
- 2808: Mar15: In WGLC; 21/3/17: 50%->100 / Impacted TSs and TRs: draft-ietf-insipid-session-id
- 2809: -
- 2810: -
- 2811: SP#55 completed. Determine an alternative to E.164 for identifying individual devices and route messages between those devices / Impacted TSs and TRs: 22.988
- 2812: SP#59 completed. TR 22.888 v100 for Information & Approval. Study addition of new MTC-related use cases and functionality and improvements to existing requirements in TS 22.368 / Impacted TSs and TRs: 22.888
- 2813: SP#55 completed. Linked to SA3 Study on Single Sign On (SSO) Application Security for IMS - based on SIP Digest (UID_480048), SA3 TR 33.924 Extended Identity Management (GBA-IdM) and SA3 TR 33.980 (LibSec) / Impacted TSs and TRs: 22.895
- 2814: SP#54 completed. Linked to SA1 Rel-11 Feature UID_490030 SIPTO Service Continuity of IP Data Session (SIPTO_SC) / Impacted TSs and TRs: 22.896
- 2815: SP#54 completed. Linked to UID_490036 SA2 Rel-11 TR 23.843 Study on Core Network Overload solutions (FS_CNO) / Impacted TSs and TRs: 22.801
- 2816: SP#59 completed / Impacted TSs and TRs: 22.803
- 2817: SP#57 completed. Linked to SAPP (Service Awareness and Privacy Policies), FS_UMONC (Study on Usage Monitoring Control Enhancement), QoS_SSL (QoS Control Based on Subscriber Spending Limits) / Impacted TSs and TRs: 22.805
- 2818: SP#60 completed. Extend Rel-6 Network Sharing UID_31018 (basic scenarios of network/RAN sharing) to cover more complex scenarios that arise due to recent needs for more dynamic co-operation among operators / Impacted TSs and TRs: 22.852
- 2819: SP#55 work stopped. Triggered by GSMA Smart SIM and 3GNBK projects, and to evolve from traditional USAT to multimedia USIM toolkit support, particularly to Smart Card Web Server / Impacted TSs and TRs: 22.817

| ID | WBS | Task | Duration | Start | Finish | Complete | Baseline start | Baseline finish | Baseline duration | Constraint | Resources | Work | Actual work | Acronym | PCG approved | Impacted TSs and TRs | WI rapporteur name | WI rapporteur e-mail | Release | TSG approved | MCC resp | Acronym_3GU_Export | Special Focus Doc | PCG stopped | TSG stopped | Status Report |
| --- | --- | --- | --- | --- | --- | --- | --- | --- | --- | --- | --- | --- | --- | --- | --- | --- | --- | --- | --- | --- | --- | --- | --- | --- | --- | --- |
| 2820 | 735 | **Study on IMS based Peer-to-Peer Content Distribution Services (Stage 2)** | 587d? | 2010-09-23 A | 2012-12-12 A | 100% | 2010-09-23 | 2012-12-12 | 587d? |  | S2; S1; S3 | 19472h | 19472h | FS_IMS_P2P_CDS | 25 | 23.844 | China Mobile | Yu Qing (yuqing@chinamobile.com) | Rel-12 | 49 | Maurice | FS_IMS_P2P_CDS |  |  |  |  |
| 2821 | 735.1 | SA1 part of Study on IMS based Peer-to-Peer Content Distribution Services (Stage 2) | 262d? | 2010-09-23 A | 2011-09-21 A | 100% | 2010-09-23 | 2011-09-21 | 262d? | finish no earlier than 2011-09-21 | S1 | 2080h | 2080h | FS_IMS_P2P_CDS | 25 | 23.844 | China Mobile | Yu Qing (yuqing@chinamobile.com) | Rel-12 | 49 | Maurice |  |  |  |  |  |
| 2822 | 735.2 | SA2 part of Study on IMS based Peer-to-Peer Content Distribution Services (Stage 2) | 347d? | 2010-09-23 A | 2012-06-20 A | 100% | 2010-09-23 | 2012-06-20 | 347d? | finish no earlier than 2012-06-08 | S2 | 2776h | 2776h | FS_IMS_P2P_CDS | 25 | 23.844 | China Mobile | Yu Qing (yuqing@chinamobile.com) | Rel-12 | 49 | Maurice |  |  |  |  |  |
| 2823 | 735.3 | SA3 part of Study on IMS based Peer-to-Peer Content Distribution Services (Stage 2) | 68d? | 2012-09-12 A | 2012-12-12 A | 100% | 2012-09-12 | 2012-12-12 | 68d? | finish no earlier than 2012-12-12 | S3 | 528h | 528h | FS_IMS_P2P_CDS | 29 | 33.844 | China Mobile | Zhu Judy(zhuhongru@chinamobile.com) | Rel-12 | 57 | Mirko |  |  |  |  |  |
| 2824 | 736 | **Study on Core Network Overload solutions** | 852d? | 2010-09-23 A | 2013-12-11 A | 100% | 2010-09-23 | 2013-12-11 | 852d? |  | S2 | 18240.6h | 18240.6h | FS_CNO | 25 | 23.843 | Huawei | Mirko.Schramm@huawei.com | Rel-12 | 49 | Maurice | FS_CNO |  |  |  |  |
| 2825 | 736.1 | Study on Core Network Overload solutions (Phase 1) | 587d? | 2010-09-23 A | 2012-12-12 A | 100% | 2010-09-23 | 2012-12-12 | 587d? | finish no earlier than 2012-12-12 | S2 | 4684.11h | 4684.11h | FS_CNO | 25 | 23.843 | Huawei | Mirko.Schramm@huawei.com | Rel-12 | 49 | Maurice |  |  |  |  |  |
| 2826 | 736.2 | Study on Core Network Overload solutions (Phase 2) | 844d? | 2010-09-23 A | 2013-12-11 A | 100% | 2010-09-23 | 2013-12-11 | 844d? | finish no earlier than 2013-12-11 | S2 | 6744h | 6744h | FS_CNO | 25 | 23.843 | Huawei | Mirko.Schramm@huawei.com | Rel-12 | 49 | Maurice |  |  |  |  |  |
| 2827 | 737 | Study on System Enhancements for Energy Efficiency | 399d? | 2010-12-16 A | 2012-06-20 A | 100% | 2010-12-16 | 2012-06-20 | 399d? | finish no earlier than 2012-06-20 | S2 | 3192h | 3192h | FS_SEEE | 26 | 23.866 | Huawei | frank.mademann@huawei.com | Rel-12 | 50 | Maurice | FS_SEEE |  |  |  |  |
| 2828 | 738 | Study on S2a Mobility based On GTP and WLAN access to EPC | 657d? | 2011-03-23 A | 2013-09-11 A | 100% | 2011-03-23 | 2013-09-11 | 657d? | finish no earlier than 2013-09-11 | S2 | 5165.94h | 5165.94h | FS_SaMOG | 26 | 23.852 | ZTE | Tricci So (tso@zteusa.com) | Rel-12 | 51 | Maurice | FS_SaMOG | WLAN |  |  |  |
| 2829 | 739 | Study on Optimized Offloading to WLAN in 3GPP-RAT Mobility | 326d? | 2012-06-18 A | 2013-09-11 A | 100% | 2012-06-18 | 2013-09-11 | 326d? | finish no earlier than 2013-09-11 | S2 | 2592h | 2592h | FS_WORM | 29 | 23.890 | BlackBerry | Steve Barrett (sbarrett@blackberry.com) | Rel-12 | 56 | Maurice | FS_WORM | WLAN |  |  |  |
| 2830 | 740 | Study on Application Based Charging | 190d? | 2012-06-18 A | 2013-03-06 A | 100% | 2012-06-18 | 2013-03-06 | 190d? | finish no earlier than 2013-03-06 | S2 | 1520h | 1520h | FS_ABC | 29 | 23.800 | Allot | Alla Goldner (agoldner@allot.com) | Rel-12 | 56 | Maurice | FS_ABC |  |  |  |  |
| 2831 | 741 | **Study on Multi Access PDN connectivity and IP flow Mobility** | 1141.96d? | 2008-08-08 A | 2012-12-12 A | 100% | 2008-08-08 | 2012-12-12 | 1141.96d? |  | S2; S1 | 27327.4h | 27327.4h | FS_MAPIM | 21 | 23.861 | Qualcomm | Gerardo Giaretta (gerardog@qualcomm.com) | Rel-12 | 41 | Maurice | FS_MAPIM |  |  |  |  |
| 2832 | 741.1 | SA1 part of Study on Multi Access PDN connectivity and IP flow Mobility | 22d? | 2008-08-08 A | 2011-09-21 A | 100% | 2008-08-08 | 2011-09-21 | 22d? | finish no earlier than 2011-09-21 | S1 | 160h | 160h | FS_MAPIM | 21 | 23.861 | Qualcomm | Gerardo Giaretta (gerardog@qualcomm.com) | Rel-12 | 41 | Maurice |  |  |  |  |  |
| 2833 | 741.2 | SA2 part of Study on Multi Access PDN connectivity and IP flow Mobility | 1113d? | 2008-09-18 A | 2012-12-12 A | 100% | 2008-09-18 | 2012-12-12 | 1113d? | finish no earlier than 2012-12-12 | S2 | 8896h | 8896h | FS_MAPIM | 21 | 23.861 | Qualcomm | Gerardo Giaretta (gerardog@qualcomm.com) | Rel-12 | 41 | Maurice |  |  |  |  |  |
| 2834 | 742 | Deleted - Study on IP Flow Mobility support for S2a and S2b Interfaces | 190d? | 2012-06-18 A | 2013-03-06 A | 100% | 2012-06-18 | 2013-03-06 | 190d? | finish no earlier than 2013-03-06 | S2 | 1520h | 1520h | FS_NBIFOM | 29 | 23.861 | ZTE | Tricci So (tso@zteusa.com) | Rel-12 | 56 | Maurice | FS_NBIFOM |  | PCG-30 | SP-59 |  |
| 2835 | 743 | Study on Extended IMS Media Plane Security features | 719d? | 2010-06-10 A | 2013-03-06 A | 100% | 2010-06-10 | 2013-03-06 | 719d? | finish no earlier than 2013-03-06 | S3 | 5736h | 5736h | FS_eMEDIASEC | 25 | 33.829 | Vodafone | Aguibou.Barry@vodafone.com | Rel-12 | 48 | Mirko | FS_eMEDIASEC |  |  |  |  |
| 2836 | 744 | Deleted - Study on Firewall traversal (Stage 2) | 854d? | 2011-06-17 A | 2014-09-17 A | 100% | 2011-06-17 | 2014-09-17 | 854d? | finish no earlier than 2014-09-17 | S3 | 6832h | 6832h | FS_Fire | 27 | 33.830 | Acme Packet | Prashant Kumar (PKumar@acmepacket.com) | Rel-12 | 53 | Mirko | FS_Fire |  | PCG-33 | SP-65 |  |
| 2837 | 745 | Study on Security on spoofed call detection and prevention (Stage 2) | 662d? | 2012-03-07 A | 2014-09-17 A | 100% | 2012-03-07 | 2014-09-17 | 662d? | finish no earlier than 2014-09-17 | S3 | 5296h | 5296h | FS_SPOOF | 28 | 33.831 | China Mobile | lixiangjun@chinamobile.com | Rel-12 | 55 | Mirko | FS_SPOOF |  |  |  |  |
| 2838 | 746 | Study on Security Assurance Methodology for 3GPP Network Elements | 466d? | 2012-09-13 A | 2014-06-18 A | 100% | 2012-09-13 | 2014-06-18 | 466d? | finish no earlier than 2014-03-07 | S3 | 3696h | 3696h | FS_SECAM | 29 | 33.805 | Orange | loic.habermacher@orange.com | Rel-12 | 57 | Mirko | FS_SECAM |  |  |  |  |
| 2839 | 747 | Study on Improved Support for Dynamic Adaptive Streaming over HTTP in 3GPP | 729d? | 2011-12-14 A | 2014-09-16 A | 100% | 2011-12-14 | 2014-09-17 | 729d? | finish no earlier than 2014-09-17 | S4 | 5824h | 5824h | FS_IS_DASH | 28 | 26.938 | Qualcomm | c_tstock@qualcomm.com | Rel-12 | 54 | Paolo | FS_IS_DASH |  |  |  |  |
| 2840 | 748 | Study on HTML5 for a new presentation layer in 3GPP services | 266d? | 2013-09-12 A | 2014-09-16 A | 100% | 2013-09-12 | 2014-09-17 | 266d? | finish no earlier than 2014-09-17 | S4 | 2128h | 2128h | FS_HTML5 | 31 | 26.907 | Samsung | Imed Bouazizi (i.bouazizi@sta.samsung.com) | Rel-12 | 61 | Paolo | FS_HTML5 |  |  |  |  |
| 2841 | 749 | Study on version handling | 716d? | 2010-03-25 A | 2012-12-12 A | 100% | 2010-03-25 | 2012-12-12 | 716d? | finish no earlier than 2012-12-12 | S5 | 5704h | 5704h | FS_OAM_VH | 24 | 32.830 | Ericsson | thomas.tovinger@ericsson.com | Rel-12 | 47 | Mirko | FS_OAM_VH |  |  |  |  |
| 2842 | 750 | Study on management of Heterogeneous Networks | 852d? | 2011-03-23 A | 2014-06-18 A | 100% | 2011-03-23 | 2014-06-18 | 852d? | finish no earlier than 2014-06-18 | S5 | 6816h | 6816h | FS_OAM_HetNet | 26 | 32.835 | Ericsson | ulf.hubinette@ericsson.com | Rel-12 | 51 | Mirko | FS_OAM_HetNet |  |  |  |  |
| 2843 | 751 | Study on OAM aspects of Network Sharing | 464d? | 2011-12-07 A | 2013-09-11 A | 100% | 2011-12-07 | 2013-09-11 | 464d? | finish no earlier than 2013-09-11 | S5 | 3696h | 3696h | FS_OAM_SHARE | 28 | 32.851 | Alcatel-Lucent, Huawei | Padma.Sudarsan@alcatel-lucent.com, zoulan@huawei.com | Rel-12 | 54 | Mirko | FS_OAM_SHARE |  |  |  |  |
| 2844 | 752 | Study on Enhanced Network Management (NM) centralized Coverage and Capacity Optimization | 590d? | 2011-09-21 A | 2014-09-17 A | 100% | 2011-09-21 | 2014-09-17 | 590d? | finish no earlier than 2014-09-17 | S5 | 4712h | 4712h | FS_SON_NM_CCO | 29 | 32.836 | Ericsson | robert.petersen@ericsson.com | Rel-12 | 56 | Mirko | FS_SON_NM_CCO | SON |  |  |  |
| 2845 | 753 | Study on WLAN management | 788d? | 2011-09-21 A | 2014-09-17 A | 100% | 2012-06-20 | 2014-09-17 | 590d? | finish no earlier than 2014-09-17 | S5 | 6304h | 6304h | FS_WLAN_OAM | 29 | 28.680, 28.681, 28.682, 28.683, 28.403 | Intel | joey.chou@intel.com | Rel-12 | 56 | Mirko | FS_WLAN_OAM | WLAN |  |  |  |
| 2846 | 754 | Study on Alarm Management | 201d? | 2012-12-07 A | 2013-09-11 A | 100% | 2012-12-07 | 2013-09-11 | 201d? | finish no earlier than 2013-09-11 | S5 | 1592h | 1592h | FS_OAM_AM | 30 | 32.859 | TeliaSonera | tommy.berggren@teliasonera.com | Rel-12 | 58 | Mirko | FS_OAM_AM |  |  |  |  |
| 2847 | 755 | Study on Indication of Network to Network Interface (NNI) Routeing scenarios in SIP requests | 400d? | 2012-12-10 A | 2014-06-13 A | 100% | 2012-12-10 | 2014-06-13 | 400d? | finish no earlier than 2014-03-06 | C3 | 3190.27h | 3190.27h | FS_NNI_RS | 30 | 24.802 | Ericsson | Jan.Holm@ericsson.com | Rel-12 | 58 | Adrian | FS_NNI_RS |  |  |  |  |
| 2848 | 756 | Study on Diameter Overload Control Mechanisms | 464d? | 2012-01-05 A | 2014-09-11 A | 100% | 2012-01-05 | 2014-09-12 | 464d? | finish no earlier than 2014-09-12 | C4 | 3712h | 3712h | FS_DOCME | 30 | 29.809 | Orange | lionel.morand@orange.com | Rel-12 | 58 | Kimmo | FS_DOCME |  |  |  |  |
| 2849 | 757 | Study on XML based access of AF to the PCRF | 203d? | 2013-03-01 A | 2013-12-04 A | 100% | 2013-03-01 | 2014-06-13 | 341d? | finish no earlier than 2014-06-13 | C3 | 1608h | 1608h | FS_XML_AF_PCRF | 30 | 29.817 | Alcatel-Lucent | horst.brinkman@alcatel-lucent.com | Rel-12 | 59 | Adrian | FS_XML_AF_PCRF |  |  |  |  |
| 2850 | 758 | Study on Technical aspects on Roaming End-to-end scenarios with VoLTE IMS and other networks | 328d? | 2013-09-09 A | 2014-12-09 A | 100% | 2013-09-09 | 2014-09-12 | 266d? | finish no earlier than 2014-12-09 | C3 | 2624h | 2624h | FS_REVOLTE_IMS | 31 | 29.949 | Deutsche Telekom | Roland Jesske (r.jesske@telekom.de) | Rel-12 | 61 | Adrian | FS_REVOLTE_IMS |  |  |  |  |
| 2851 | 759 | Study on Development of conformance requirements for the IP Multimedia Services Identity Module (ISIM) application support in ME | 263d? | 2013-12-09 A | 2014-12-09 A | 100% | 2013-12-09 | 2014-09-12 | 201d? | finish no earlier than 2014-12-09 | C6 | 2104h | 2104h | FS_ISIM_CR | 32 | 31.829 | Gemalto | ly-thanh.phan@gemalto.com | Rel-12 | 62 | Xavier | FS_ISIM_CR |  |  |  |  |
| 2852 | 760 | Study on Shared Data Update for Multiple Subscribers | 263d? | 2013-12-06 A | 2014-12-09 A | 100% | 2013-12-06 | 2014-09-12 | 201d? | finish no earlier than 2014-12-09 | C4 | 2104h | 2104h | FS_SHARED_SubData_UPD | 32 | 29.854 | Huawei | Susan Shi (susan.shishufeng@huawei.com) | Rel-12 | 62 | Kimmo | FS_SHARED_SubData_UPD |  |  |  |  |
| 2853 | 761 | Study on GERAN improvements for Machine-Type Communications | 661d? | 2010-05-24 A | 2012-11-23 A | 100% | 2010-05-24 | 2012-11-23 | 661d? | finish no earlier than 2012-11-23 | G1; G2 | 10576h | 10576h | FS_NIMTC_GERAN | 24 | 43.868 | Ericsson | paul.schliwa-bertling@ericsson.com | Rel-12 | 44 | Paolo | FS_NIMTC_GERAN | MTC, M2M |  |  |  |
| 2854 | 762 | Study on Voice services over Adaptive Multi-user channels on One Slot (VAMOS) enhancements | 267.67d? | 2010-10-27 A | 2014-05-30 A | 100% | 2010-10-27 | 2014-05-30 | 267.67d? | finish no earlier than 2014-05-30 | GP; G2; G1 | 6424h | 6424h | FS_eVAMOS | 27 | 43.801 | China Mobile, Huawei | Chao Luo (chluo@huawei.com), dengjuan@chinamobile.com | Rel-12 | 50 | Paolo | FS_eVAMOS |  |  |  |  |
| 2855 | 763 | Study on GERAN enhancements for Mobile Data Applications | 430d? | 2011-04-04 A | 2014-08-29 A | 100% | 2011-04-04 | 2014-08-29 | 430d? | finish no earlier than 2014-08-29 | G2; G1 | 6880h | 6880h | FS_GERAN_eMDA | 27 | 43.802 | Huawei | ming.fang@huawei.com | Rel-12 | 50 | Gert | FS_GERAN_eMDA |  |  |  |  |
| 2856 | 764 | Study on Inclusion of RF Pattern Matching Technologies as a positioning method in the E-UTRAN | 722d? | 2010-12-10 A | 2013-09-06 A | 100% | 2010-12-10 | 2013-09-06 | 722d? | finish no earlier than 2013-09-06 | R4 | 5776h | 5776h | FS_LCS_LTE_RFPMT | 26 | LTE 36.809 | Polaris Wireless | Scot Gordon (sgordon@polariswireless.com) | Rel-12 | 50 | Issam | FS_LCS_LTE_RFPMT |  |  |  | RP-131082 |
| 2857 | 765 | Study on Provision of low-cost MTC UEs based on LTE | 462d? | 2011-09-19 A | 2013-06-14 A | 100% | 2011-09-19 | 2013-06-14 | 462d? | finish no earlier than 2013-06-14 | R1; R2; R4 | 11088h | 11088h | FS_LC_MTC_LTE | 27 | LTE 36.888 | Vodafone | prakash.bhat@vodafone.com | Rel-12 | 53 | Patrick | FS_LC_MTC_LTE | MTC, M2M |  |  | RP-130583 |
| 2858 | 766 | Deleted - Study on Mobile Relay for E-UTRA | 881.5d? | 2005-05-19 A | 2014-06-23 A | 100% | 2005-05-19 | 2014-06-23 | 881.5d? | finish no earlier than 2014-06-23 | R3; R1 | 14104h | 14104h | FS_LTE_mobRelay | 27 | LTE 36.836 | CATT | Haijing Hu (huhaijing@catt.cn) | Rel-12 | 53 | Juha | FS_LTE_mobRelay |  | PCG-33 | RP-64 | RP-140726 |
| 2859 | 767 | Study on Scenarios and Requirements of LTE Small Cell Enhancements for E-UTRA and E-UTRAN | 66d? | 2012-09-11 A | 2012-12-07 A | 100% | 2012-09-11 | 2012-12-07 | 66d? | finish no earlier than 2012-12-07 | RP | 528h | 528h | FS_LTE_SC_enh_req | 29 | LTE 36.932 | China Mobile | Hai TANG (tanghai@chinamobile.com) | Rel-12 | 57 | Yong-Jun | FS_LTE_SC_enh_req | Small cell |  |  | RP-121651 |
| 2860 | 768 | Study on Small Cell Enhancements for E-UTRA and E-UTRAN – Physical-layer aspects | 265d? | 2012-09-11 A | 2013-09-06 A | 100% | 2012-09-11 | 2013-09-06 | 265d? | finish no earlier than 2013-09-06 | R1; R2; R4 | 6360h | 6360h | FS_LTE_SC_enh_L1 | 30 | LTE 36.872 | Huawei | Elean Fan (fanxiaoan@huawei.com) | Rel-12 | 58 | Patrick | FS_LTE_SC_enh_L1 | Small cell |  |  | RP-131618 |
| 2861 | 769 | Study on Small Cell Enhancements for E-UTRA and E-UTRAN – Higher-layer aspects | 265d? | 2012-12-10 A | 2013-12-06 A | 100% | 2012-12-10 | 2013-12-06 | 265d? | finish no earlier than 2013-12-06 | R2; R3 | 4240h | 4240h | FS_LTE_SC_enh_hilayer | 30 | LTE 36.842 | NTT DOCOMO | Hideaki Takahashi (h-takahashi@nttdocomo.co.jp) | Rel-12 | 58 | Yong-Jun | FS_LTE_SC_enh_hilayer | Small cell |  |  | RP-131619 |
| 2862 | 770 | Study on LTE Device-to-Device Proximity Services - Radio Aspects | 325d? | 2012-12-17 A | 2014-03-06 A | 100% | 2012-12-17 | 2014-03-06 | 325d? | finish no earlier than 2014-03-06 | R1; R2; R3; R4 | 10400h | 10400h | FS_LTE_D2D_Prox | 30 | LTE 36.843 | Qualcomm | Shailesh Patil (patil@qti.qualcomm.com) | Rel-12 | 58 | Patrick | FS_LTE_D2D_Prox | Public Safety (A-A) |  |  | RP-140416 |
| 2863 | 771 | Study on 3D-channel model for Elevation Beamforming and FD-MIMO studies for LTE | 463d? | 2012-12-10 A | 2014-09-12 A | 100% | 2012-12-10 | 2014-09-12 | 463d? | finish no earlier than 2014-09-12 | R1 | 3704h | 3704h | FS_LTE_3D_channel | 30 | LTE 36.873 | Nokia Networks | bishwarup.mondal@nsn.com | Rel-12 | 58 | Patrick | FS_LTE_3D_channel |  |  |  | RP-141206 |
| 2864 | 772 | Study on Energy Saving Enhancement for E-UTRAN | 397d? | 2012-12-10 A | 2014-06-13 A | 100% | 2012-12-10 | 2014-06-13 | 397d? | finish no earlier than 2014-06-13 | R3 | 3176h | 3176h | FS_Netw_Energy_enh_LTE | 30 | LTE 36.887 | China Mobile | Kimba Dit Adamou, Boubacar (jinba@chinamobile.com) | Rel-12 | 58 | Juha | FS_Netw_Energy_enh_LTE |  |  |  | RP-140604 |
| 2865 | 773 | Study on Expansion of LTE_FDD_1670_US to include 1670-1680MHz Band for LTE in the US | 469d? | 2013-03-01 A | 2014-12-15 A | 100% | 2013-03-01 | 2014-09-12 | 403d? | finish no earlier than 2014-12-15 | R4 | 3752h | 3752h | FS_LTE_FDD_1670_US | 30 | LTE 36.844 | LightSquared | masoud.olfat@lightsquared.com | Rel-13 | 59 | Issam | FS_LTE_FDD_1670_US |  |  |  | RP-141815 |
| 2866 | 774 | Study on Cell-specific Reference Signals (CRS) Interference Mitigation for homogenous deployments for LTE | 201d? | 2013-03-04 A | 2013-12-06 A | 100% | 2013-03-04 | 2013-12-06 | 201d? | finish no earlier than 2013-12-06 | R4 | 1608h | 1608h | FS_LTE_CRSIC | 30 | LTE 36.863 | Ericsson | shaohua.li@ericsson.com | Rel-12 | 59 | Issam | FS_LTE_CRSIC |  |  |  | RP-131623 |
| 2867 | 775 | Study on Network-Assisted Interference Cancellation and Suppression for LTE | 265d? | 2013-03-08 A | 2014-03-06 A | 100% | 2013-03-08 | 2014-03-06 | 265d? | finish no earlier than 2014-03-06 | R1; R4 | 4240h | 4240h | FS_LTE_NAICS | 30 | LTE 36.866 | MediaTek | jeff.zhuang@mediatek.com | Rel-12 | 59 | Patrick | FS_LTE_NAICS |  |  |  | RP-132108 |
| 2868 | 776 | Study on Coordinated Multi-Point (CoMP) operation for LTE with Non-Ideal Backhaul | 126d? | 2013-06-18 A | 2013-12-06 A | 100% | 2013-06-18 | 2013-12-06 | 126d? | finish no earlier than 2013-12-06 | R1 | 1008h | 1008h | FS_COMP_LTE_nibackhaul | 31 | LTE 36.874 | Samsung | Hyojin Lee (hyojin257.lee@samsung.com) | Rel-12 | 60 | Patrick | FS_COMP_LTE_nibackhaul |  |  |  | RP-131626 |
| 2869 | 777 | Study on Group Communication for LTE | 130d? | 2013-09-10 A | 2014-03-06 A | 100% | 2013-09-10 | 2014-03-06 | 130d? | finish no earlier than 2014-03-06 | R2; R3 | 2080h | 2080h | FS_LTE_GC | 31 | LTE 36.868 | Alcatel-Lucent | chandrika.worrall@alcatel-lucent.com | Rel-12 | 61 | Yong-Jun | FS_LTE_GC | Public Safety (A-A) |  |  | RP-140182 |
| 2870 | 778 | Study on Smart Congestion Mitigation in E-UTRAN | 130d? | 2013-09-09 A | 2014-03-06 A | 100% | 2013-09-09 | 2014-03-06 | 130d? | finish no earlier than 2014-03-06 | R2 | 1040h | 1040h | FS_SCM_LTE | 31 | LTE 36.848 | LG Electronics | youngdae.lee@lge.com | Rel-12 | 61 | Yong-Jun | FS_SCM_LTE |  |  |  | RP-140102 |
| 2871 | 779 | Study on RAN aspects of RAN Sharing Enhancements for LTE | 136d? | 2013-12-06 A | 2014-06-13 A | 100% | 2013-12-06 | 2014-06-13 | 136d? | finish no earlier than 2014-06-13 | R3 | 1088h | 1088h | FS_RSE-RAN_LTE | 32 | LTE 36.856 | NEC | Siva.Vakeesar@emea.nec.com | Rel-12 | 62 | Juha | FS_RSE-RAN_LTE |  |  |  | RP-140746 |
| 2872 | 780 | Study on RF and EMC requirements for active Antenna Array System (AAS) Base Station | 386d? | 2011-09-19 A | 2013-03-01 A | 100% | 2011-09-19 | 2013-03-01 | 386d? | finish no earlier than 2013-03-01 | R4; R1 | 6176h | 6176h | FS_AAS_BS_LTE_UTRA | 27 | UTRA, LTE 37.840 | Huawei | Ronnie.zhang@huawei.com | Rel-12 | 53 | Issam | FS_AAS_BS_LTE_UTRA |  |  |  | RP-130124 |
| 2873 | 781 | Study on LTE-HRPD (High Rate Packet Data in 3GPP2) inter-RAT SON | 340d? | 2012-03-02 A | 2013-06-14 A | 100% | 2012-03-02 | 2013-06-14 | 340d? | finish no earlier than 2013-06-14 | R3 | 2712h | 2712h | FS_LTE_HRPD_SON | 28 | UTRA, LTE 37.813 | China Telecom | Wu Jinlian (wujl@gsta.com) | Rel-12 | 55 | Juha | FS_LTE_HRPD_SON | SON |  |  | RP-130585 |
| 2874 | 782 | Study on Passive InterModulation (PIM) handling for UTRA and LTE Base Stations | 403d? | 2012-03-05 A | 2013-09-06 A | 100% | 2012-03-05 | 2013-09-06 | 403d? | finish no earlier than 2013-09-06 | R4; G1 | 6448h | 6448h | FS_BS_PIM | 28 | UTRA, LTE 37.808 | Ericsson | johan.skold@ericsson.com | Rel-12 | 55 | Issam | FS_BS_PIM |  |  |  | RP-131076 |
| 2875 | 783 | Study on WLAN/3GPP Radio Interworking | 264d? | 2012-12-10 A | 2013-12-06 A | 100% | 2012-12-10 | 2013-12-06 | 264d? | finish no earlier than 2013-12-06 | R2 | 2104h | 2104h | FS_UTRA_LTE_WLAN_interw | 30 | UTRA, LTE 37.834 | Intel | sasha.sirotkin@intel.com | Rel-12 | 58 | Yong-Jun | FS_UTRA_LTE_WLAN_interw | WLAN |  |  | RP-131611 |
| 2876 | 784 | Study on RAN Enhancements for UMTS/HSPA and LTE Interworking | 261d? | 2012-12-10 A | 2013-12-06 A | 100% | 2012-12-10 | 2013-12-06 | 261d? | finish no earlier than 2013-12-06 | R3 | 2088h | 2088h | FS_HSPA_LTE_interworking | 30 | UTRA, LTE 37.852 | China Unicom | Meng Zhang (zhangmeng68@chinaunicom.cn) | Rel-12 | 58 | Juha | FS_HSPA_LTE_interworking |  |  |  | RP-131612 |
| 2877 | 785 | Study on Next-Generation SON for UTRA and LTE | 397d? | 2012-12-10 A | 2014-06-13 A | 100% | 2012-12-10 | 2014-06-13 | 397d? | finish no earlier than 2014-06-13 | R3 | 3176h | 3176h | FS_UTRA_LTE_NG_SON | 30 | UTRA, LTE 37.822 | NSN | krzysztof.kordybach@nsn.com | Rel-12 | 58 | Juha | FS_UTRA_LTE_NG_SON | SON |  |  | RP-140747 |
| 2878 | 786 | Study on 2GHz FDD for UTRA and LTE in Region 1 (1980-2010MHz and 2170-2200MHz Bands) | 462d? | 2012-12-11 A | 2014-09-12 A | 100% | 2012-12-11 | 2014-09-12 | 462d? | finish no earlier than 2014-09-12 | R4 | 3696h | 3696h | FS_UTRA_LTE_1980_2170_REG1 | 30 | UTRA, LTE 37.846 | DISH Network | johny.kim@dish.com, mariam.sorond@dish.com | Rel-12 | 58 | Issam | FS_UTRA_LTE_1980_2170_REG1 |  |  |  | RP-141099 |
| 2879 | 787 | Study on Base Station specification structure | 136d? | 2012-12-10 A | 2013-06-14 A | 100% | 2012-12-10 | 2013-06-14 | 136d? | finish no earlier than 2013-06-14 | R4 | 1088h | 1088h | FS_BSspec_struc | 30 | UTRA, LTE, MSR 37.810 | Ericsson | johan.skold@ericsson.com | Rel-12 | 58 | Issam | FS_BSspec_struc |  |  |  | RP-130580 |
| 2880 | 788 | Study on RAN aspects of Machine Type and other mobile data applications Communications enhancements | 137d? | 2013-03-01 A | 2013-09-06 A | 100% | 2013-03-01 | 2013-09-06 | 137d? | finish no earlier than 2013-09-06 | R2 | 1096h | 1096h | FS_MTCe_RAN | 30 | UTRA, LTE 37.869 | ZTE | sergio.parolari@zteitaly.com | Rel-12 | 59 | Yong-Jun | FS_MTCe_RAN | MTC, M2M |  |  | RP-131081 |
| 2881 | 789 | Study on UMTS heterogeneous networks | 331d? | 2012-06-12 A | 2013-09-06 A | 100% | 2012-06-12 | 2013-09-06 | 331d? | finish no earlier than 2013-09-06 | R1; R2; R3 | 7944h | 7944h | FS_UTRA_HetNet | 29 | UTRA 25.800 | Huawei | carmela.cozzo@huawei.com | Rel-12 | 57 | Patrick | FS_UTRA_HetNet |  |  |  | RP-131606 |
| 2882 | 790 | Study on Scalable UMTS FDD bandwidth | 265d? | 2012-12-10 A | 2013-12-06 A | 100% | 2012-12-10 | 2013-12-06 | 265d? | finish no earlier than 2013-12-06 | R1; R4 | 4240h | 4240h | FS_UTRA_SCAL | 30 | UTRA TR 25.701 | China Unicom | Han Xiao (hanxiao91@chinaunicom.cn) | Rel-12 | 58 | Patrick | FS_UTRA_SCAL |  |  |  | RP-132035 |
| 2883 | 791 | Deleted - Study on Scalable UMTS FDD bandwidth by Filtering | 136d? | 2013-12-09 A | 2014-06-13 A | 100% | 2013-12-09 | 2014-06-13 | 136d? | finish no earlier than 2014-06-13 | R1 | 1088h | 1088h | FS_UTRA_SCAL_FILT | 32 | UTRA TR 25.701 | China Unicom | Han Xiao (hanxiao91@chinaunicom.cn) | Rel-12 | 62 | Patrick | FS_UTRA_SCAL_FILT |  | PCG-33 | RP-64 | RP-140988 |
| 2884 | 792 | Study on Dedicated Channel (DCH) enhancements for UMTS | 197d? | 2012-12-10 A | 2013-09-06 A | 100% | 2012-12-10 | 2013-09-06 | 197d? | finish no earlier than 2013-09-06 | R1 | 1576h | 1576h | FS_UTRA_DCHenh | 30 | UTRA TR 25.702 | Qualcomm | Arjun Bharadwaj (arjunb@qti.qualcomm.com) | Rel-12 | 58 | Patrick | FS_UTRA_DCHenh |  |  |  | RP-131073 |
| 2885 | 793 | Study on Further Enhanced Uplink (EUL) enhancements | 265d? | 2012-12-10 A | 2013-12-06 A | 100% | 2012-12-10 | 2013-12-06 | 265d? | finish no earlier than 2013-12-06 | R2; R1; R3 | 6360h | 6360h | FS_EDCH_enh | 30 | UTRA TR 25.700 | Ericsson | alessandro.caverni@ericsson.com | Rel-12 | 58 | Yong-Jun | FS_EDCH_enh |  |  |  | RP-131608 |
| 2886 | 794 | Study on HNB Emergency Warning Area for UTRA | 191d? | 2013-06-18 A | 2014-03-06 A | 100% | 2013-06-18 | 2014-03-06 | 191d? | finish no earlier than 2014-03-06 | R3 | 1520h | 1520h | FS_HNB_warn_area | 31 | UTRA TR 25.703 | Alcatel-Lucent, Ip.access | Martin.Warner@alcatel-lucent.com, Kit.kilgour@ipaccess.com | Rel-12 | 60 | Juha | FS_HNB_warn_area | HNB |  |  | RP-140129 |
| 2887 | 795 | Study on Enhanced Broadcast of System Information | 66d? | 2013-09-09 A | 2013-12-06 A | 100% | 2013-09-09 | 2013-12-06 | 66d? | finish no earlier than 2013-12-06 | R2; R1 | 1056h | 1056h | FS_UTRA_SIBenh | 31 | UTRA TR 25.704 | Ericsson | martin.van.der.zee@ericsson.com | Rel-12 | 61 | Yong-Jun | FS_UTRA_SIBenh |  |  |  | RP-131610 |
| 2888 | 796 | Release 11 Features | 342.75d? | 2013-06-02 A | 2014-09-16 A | 100% | 2013-06-02 | 2014-09-17 | 342.75d? | finish no earlier than 2014-09-17 | SP; CP; GP; RP | 10968h | 10968h |  |  |  |  |  | Rel-11 |  | All |  |  |  |  |  |

Notes:
- 2820: Triggered by TR 22.906 SA1 Study on IMS based Peer-to-Peer Content Distribution Services UID_450047
- 2821: SP#53 completed
- 2822: SP#56 completed. TR 23.844v100 for Information and Approval
- 2823: SP#58 completed. TR 33.844 v100 for Information and Approval
- 2824: SP#62 completed. Linked to CT4 TR 23.857 Study on EPC Nodes Restoration (UID_490014)
- 2825: Phase 1: complete study of overload control related to MAP /Diameter signalling, other 3GPP Core Network signalling optimization
- 2826: SP#62 completed
- 2827: SP#56 completed
- 2828: SP#61 completed. Covers generic non-3GPP access (e.g. WLAN, WIMAX, CDMA/HRPD). Spin-off Feature SaMOG_WLAN. Linked to Rel-8 Support for non-3GPP accesses, Rel-10 SMOG, Rel-11 BBAI
- 2829: SP#61 completed. Linked to UID_350027 SAE for support for non-3GPP accesses (SAES-SA-FP_n3GPP), UID_410043 MAPIM, UID_450041 IFOM, UID_530046 SaMOG
- 2830: SP#59 completed. Linked to Rel-11 Feature UID_500032 Service Awareness and Privacy Policies (SAPP)
- 2831: Spin-off Features MAPCON, IFOM. SP#58 completed FS_MAPIM part of 23.861 (continued under FS_NBIFOM)
- 2832: SP#53 completed
- 2833: SP#43 TR 23.861v100 for Information. SP#56 Rel-9 TR 23.861v130 renamed & progressed under new Study FS_NBIFOM. SP#58 completed the FS_MAPIM part of TR 23.861 (TR continued under FS_NBIFOM).
- 2834: SP#59 stopped (at 40% completion). SP#56 revives dormant Study FS_MAPIM. TR 23.861 title changed from (Multi Access PDN connectivity and IP flow mobility) to (Network based IP flow mobility)
- 2835: SP#59 completed. Continuation of Rel-9 Feature UID_430036 IMS Media Plane Security (MEDIASEC). Study solutions and extensions to features and functionality described in TR 33.828 and TS 33.328
- 2836: SP#65 stopped. Linked to Rel-12 Service and Media Reachability for Users over Restrictive Firewalls (SMURFs) UID_530043
- 2837: SP#65 completed. TR 33.831v100 for 1-step Approval. Linked to Rel-11 SPUCI TR 33.838
- 2838: SP#64 completed. Spin-off Rel-13 Feature SCAS. Study methodologies for specifying product security assurance and hardening requirements on 3GPP network elements (with associated test cases when feasible)
- 2839: SP#65 completed. TR 26.938v200 for Approval. SP#60 TR 26.938v100 for Information. Linked to Feature UID_470034 HTTP-based Streaming and Download Services
- 2840: SP#65 completed. TR 26.907v200 for Approval. SP#64 TR 26.907v100 for Information.
- 2841: SP#58 completed
- 2842: SP#64 completed
- 2843: SP#61 completed. Linked to Network Sharing UID_31018, SA1 22.951 (Service aspects and requirements for network sharing), SA2 23.251 (Network Sharing; Architecture)
- 2844: SP#65 completed. TR 32.836v200 for Approval. SP#63 split of Rel-12 SP-130045 WID (Enhanced NM Centralized Coverage and Capacity Optimization) into a Rel-12 Study (SP-140028) and a Rel-13 Normative WID (SP-140060)
- 2845: SP#65 revised WID SP-130042=>SP-140536 (split into Rel-12 Study & Rel-13 normative WI). Changed Title from "TR on WLAN impacts to Type-2 management interface to the 3GPP Network Manager". TR 32.841v200 for Approval. Completed; 14/09/15: WID:SP-140536->
- 2846: SP#61 completed
- 2847: CP#64 completed
- 2848: CP#65 completed. TR 29.809 v200 for Approval. Triggered by SA2 Rel-12 TR 23.843 Study on Core Network Overload solutions (FS_CNO) UID_490036. Coordinate with CT3, SA5
- 2849: CP#64 completed. Investigate introducing an XML-based protocol (e.g. SOAP, Restful HTTP, etc.) between AF and PCRF for non-IMS applications
- 2850: CP#65 completion 09/14=>12/14. CP#64 TR 29.949v100 for Information.Dec.14:95->100
- 2851: CP#65 completion 09/14=>12/14. Gathering of all ISIM-related conformance requirements and the assessment of CT6 coverage; June2015: Compl:30%->100
- 2852: CP#65 TR 29.854v200 for Approval. Completion 09/14=>12/14. Dec.14: 80->85%. Mar.15: 100%
- 2853: GP#56 completed. GP#44 approved WID
- 2854: GP#62 completed. TR 43.801v100 for 1-step Approval. GP#50 approved WID. Triggered by Rel-8 TR 45.914 Study Multi-User-Reusing One Timeslot (MUROS) UID_50590 and Rel-9 VAMOS UID_420002
- 2855: GP#63 completed. TR~43.802v200 for Approval. GP#50 approved WID (mobile coucou). Triggered by RAN#51 (Mar 2011) WID in RP-110454 (LTE RAN Enhancements for Diverse Data Applications) UID_510031
- 2856: RP#61 completed. Linked to Rel-10 WI on Inclusion of RF Pattern Matching Technologies as a positioning method in the UTRAN (LCS_UMTS_RFPMT) UID_460005
- 2857: RP#60 completed
- 2858: RP#64 stopped at 80% completion
- 2859: RP#58 completed. TR 36.932 v100 for Information and Approval
- 2860: RP#62 completed. RP#61 TR 36.872v100 for 1-step approval. Triggered by Rel-12 TR 36.932 Study on Scenarios and Requirements of LTE Small Cell Enhancements for E-UTRA and E-UTRAN UID_570023
- 2861: RP#62 completed. Triggered by Rel-12 TR 36.932 Study on Scenarios and Requirements of LTE Small Cell Enhancements for E-UTRA and E-UTRAN UID_570023
- 2862: RP#63 completed. TR 36.843 for 1-step approval (90% complete). Started normative work. Linked to Rel-12 TR 22.803 Study on Proximity-based Services (FS_ProSe) and Feature ProSe
- 2863: RP#65 completed. Updated WID RP-130811=>RP-141237. TR 36.873v210 for Approval. Enhance performance with 3D-beamforming or with FD-MIMO. Study new channel modelling in both vertical and horizontal dimensions awa user locations in the network
- 2864: RP#64 completed. Identify potential solutions for energy saving in E-UTRAN non-overlapping scenario. Evaluate possible enhancements in overlapping scenario, so that a subset can be used for further investigation/standardization
- 2865: CD:Thu 11/12/14->Mon 15/12/14; Compl:80%->100%; Stat Rep: RP-141453->RP-141815
- 2866: RP#62 completed. Updated WID RP-130393=>RP-131840
- 2867: RP#63 completed. TR 36.866 (90% complete) for Approval. Started normative work
- 2868: RP#62 completed. Extension of Rel-11 CoMP Operation for LTE Downlink UID_530332)
- 2869: RP#63 completed. Evaluate ability of LTE to meet public safety requirements agreed in SA for GC (GC is a key functionality of Land Mobile Radio/Private Mobile Radio and public safety systems)
- 2870: RP#63 completed
- 2871: RP#64 completed. TR 36.856v100 for 1-step approval. Triggered by SA1 Re-12 TR 22.852 Study on RAN Sharing Enhancements (FS_RSE) and Rel-13 Feature RSE (TS 22.101 Stage 1)
- 2872: RP#59 completed
- 2873: RP#60 completed
- 2874: RP#61 completed (Conclusion: no spin-off WI). Linked to Rel-10 WI on Multi-standard radio Base Station RF requirements for non-contiguous spectrum deployments (MSR_NC) UID_480025
- 2875: RP#62 completed. Evaluate LTE-WLAN/UTRA-WLAN i/w procedures while improving (non-)seamless mobility. Deployed WLAN often under-utilized; User experience suboptimal when UE connects to overloaded WLAN.
- 2876: RP#62 completed. TR 37.852v100 for Information & Approval
- 2877: RP#64 completed. The study of SON features for small cell functionality covered by the Rel-12 small cell enhancement SIs (e.g. dual connectivity) is not in the scope of this study item
- 2878: RP#65 completed. Within EU these bands can be used for terrestrial mobile as a complement to mobile satellite services. Study adding an FDD band into UTRA/E-UTRA in applicable countries of Region 1
- 2879: RP#60 completed (1-step approval). Study new BS spec structure to avoid duplicate work for new RF features (in case of identical features among different RATs); avoid future discussions on how to implement new featurES in CP-150single-RAT/multi-RAT specs
- 2880: RP#61 completed
- 2881: RP#62 completed
- 2882: RP#62 completed. TR 25.701v200 for Approval
- 2883: RP#64 stopped at 85% completion. Follow-up of Rel-12 Study on scalable UMTS FDD bandwidth (FS_UTRA_SCAL). The result is captured in the same TR 25.701
- 2884: RP#61 completed
- 2885: RP#62 completed. TR 25.700v100 for Approval. Identify potential solutions to increase the uplink capacity, coverage and end-user performance (e.g. latency, achievable rates, etc.)
- 2886: RP#63 completed. TR 25.703 v100 for 1-step approval
- 2887: RP#62 completed. TR 25.704v100 for Information & Approval. Study need to add capacity to present SI Broadcast mechanism unchanged since R99
- 2888: -

| ID | WBS | Task | Duration | Start | Finish | Complete | Baseline start | Baseline finish | Baseline duration | Constraint | Resources | Work | Actual work | Acronym | PCG approved | WI rapporteur name | WI rapporteur e-mail | Release | TSG approved | MCC resp | Acronym_3GU_Export | Special Focus Doc | PCG stopped | TSG stopped |
| --- | --- | --- | --- | --- | --- | --- | --- | --- | --- | --- | --- | --- | --- | --- | --- | --- | --- | --- | --- | --- | --- | --- | --- | --- |
| 2889 | 797 | **Advanced IP Interconnection of Services** | 650d? | 2010-03-25 A | 2012-09-12 A | 100% | 2010-03-25 | 2012-09-12 | 650d? |  | S1; S2; C1; C3 | 34381.9h | 34381.9h | IPXS | 24 | Telefónica | chris.friel@O2.com | Rel-11 | 47 | Alain | IPXS |  |  |  |
| 2890 | 797.1 | Stage 1 for Advanced IP Interconnection of Services | 392d | 2010-03-25 A | 2011-09-21 A | 100% | 2010-03-25 | 2011-09-21 | 392d | finish no earlier than 2011-09-21 | S1 | 3120h | 3120h | IPXS | 24 | Telefónica | chris.friel@O2.com | Rel-11 | 47 | Alain |  |  |  |  |
| 2891 | 797.2 | Stage 2 for Advanced IP Interconnection of Services | 263d? | 2010-12-16 A | 2011-12-14 A | 100% | 2010-12-16 | 2011-12-14 | 263d? | finish no earlier than 2012-03-21 | S2 | 2085.91h | 2085.91h | IPXS | 26 | Ericsson | fredrik.lindholm@ericsson.com | Rel-11 | 50 | Maurice |  |  |  |  |
| 2892 | 797.3 | **Stage 3 for Advanced IP Interconnection of Services** | 265d? | 2011-09-13 A | 2012-09-12 A | 100% | 2011-09-13 | 2012-09-12 | 265d? |  | C1; C3 | 8376h | 8376h | IPXS | 27 | Ericsson | christer.holmberg@ericsson.com | Rel-11 | 53 | Frederic |  |  |  |  |
| 2893 | 797.3.1 | CT1 part of Stage 3 for Advanced IP Interconnection of Services | 262d? | 2011-09-16 A | 2012-09-12 A | 100% | 2011-09-16 | 2012-09-12 | 262d? | finish no earlier than 2012-12-07 | C1 | 2048h | 2048h | IPXS | 27 | Ericsson | christer.holmberg@ericsson.com | Rel-11 | 53 | Frederic |  |  |  |  |
| 2894 | 797.3.2 | CT3 part of Stage 3 for Advanced IP Interconnection of Services | 262d? | 2011-09-13 A | 2012-09-07 A | 100% | 2011-09-13 | 2012-09-07 | 262d? | finish no earlier than 2012-09-07 | C3 | 2088h | 2088h | IPXS | 27 | Ericsson | christer.holmberg@ericsson.com | Rel-11 | 53 | Adrian |  |  |  |  |
| 2895 | 798 | **System Improvements to Machine-Type Communications** | 1119d? | 2009-12-10 A | 2014-03-06 A | 100% | 2009-12-10 | 2014-03-06 | 1119d? |  | S1; S2; S5; C1; C3; C4; C6; R2; R3; R5 | 198763h | 198763h | SIMTC | 25 | KPN | toon.norp@tno.nl | Rel-11 | 48 | Alain | SIMTC | MTC, M2M |  |  |
| 2896 | 798.1 | Stage 1 for SIMTC | 337d? | 2010-06-10 A | 2011-09-21 A | 100% | 2010-06-10 | 2011-09-21 | 337d? |  | S1 | 2683.46h | 2683.46h | SIMTC | 25 | KPN | toon.norp@tno.nl | Rel-11 | 48 | Alain |  | MTC, M2M |  |  |
| 2897 | 798.2 | TR on Stage 2 for SIMTC | 593d? | 2010-06-10 A | 2012-09-12 A | 100% | 2010-06-10 | 2012-09-12 | 593d? | finish no earlier than 2012-09-12 | S2 | 4736h | 4736h | SIMTC | 25 | Intel | puneet.jain@intel.com | Rel-11 | 48 | Maurice |  | MTC, M2M |  |  |
| 2898 | 798.3 | **BB1: Stage 2 Reachability Aspects of SIMTC** | 274d? | 2011-06-09 A | 2012-06-20 A | 100% | 2011-06-09 | 2012-06-20 | 274d? |  | S2 | 10773.1h | 10773.1h | SIMTC-Reach | 27 | Intel | puneet.jain@intel.com | Rel-11 | 52 | Maurice | SIMTC-Reach | MTC, M2M |  |  |
| 2899 | 798.3.1 | Deleted - MTC Feature Control (described in TS 22.368, clause 7.1.1 and 23.888, clause 5.7) | 137d? | 2011-06-10 A | 2011-12-14 A | 100% | 2011-06-10 | 2011-12-14 | 137d? | finish no earlier than 2011-11-09 | S2 | 1088h | 1088h | SIMTC-Reach | 27 | Intel | puneet.jain@intel.com | Rel-11 | 52 | Maurice |  | MTC, M2M | PCG-28 | SP-54 |
| 2900 | 798.3.2 | On-line device trigger | 273d? | 2011-06-09 A | 2012-06-20 A | 100% | 2011-06-09 | 2012-06-20 | 273d? | finish no earlier than 2012-06-20 | S2 | 2170.29h | 2170.29h | SIMTC-Reach | 27 | Intel | puneet.jain@intel.com | Rel-11 | 52 | Maurice |  | MTC, M2M |  |  |
| 2901 | 798.3.3 | MTC Addressing | 138d? | 2011-06-09 A | 2011-12-14 A | 100% | 2011-06-09 | 2011-12-14 | 138d? | finish no earlier than 2012-03-21 | S2 | 1097.24h | 1097.24h | SIMTC-Reach | 27 | Intel | puneet.jain@intel.com | Rel-11 | 52 | Maurice |  | MTC, M2M |  |  |
| 2902 | 798.3.4 | Identifiers – especially removal of MSISDN dependencies in the architecture | 273d? | 2011-06-09 A | 2012-06-20 A | 100% | 2011-06-09 | 2012-06-20 | 273d? | finish no earlier than 2012-06-20 | S2 | 2169.53h | 2169.53h | SIMTC-Reach | 27 | Intel | puneet.jain@intel.com | Rel-11 | 52 | Maurice |  | MTC, M2M |  |  |
| 2903 | 798.3.5 | MSISDN-less / PS-Only | 196d? | 2011-06-13 A | 2012-03-07 A | 100% | 2011-06-13 | 2012-03-07 | 196d? | finish no earlier than 2012-03-07 | S2 | 1568h | 1568h | SIMTC-Reach | 27 | Intel | puneet.jain@intel.com | Rel-11 | 52 | Maurice |  | MTC, M2M |  |  |
| 2904 | 798.3.6 | MTC related interfaces and functional entities to support above features (MTCsp, etc.) | 61d? | 2011-12-14 A | 2012-03-07 A | 100% | 2011-12-14 | 2012-03-07 | 61d? | finish no earlier than 2012-03-07 | S2 | 488h | 488h | SIMTC-Reach | 28 | Intel | puneet.jain@intel.com | Rel-11 | 54 | Maurice |  | MTC, M2M |  |  |
| 2905 | 798.4 | **BB1: Stage 3 (CS+PS) Reachability Aspects of SIMTC** | 325d? | 2011-09-19 A | 2012-12-07 A | 100% | 2011-09-19 | 2012-12-07 | 325d? |  | C1; C3; C4; C6 | 19112h | 19112h | SIMTC-ReachCSPS | 27 | Ericsson | mikael.wass@ericsson.com | Rel-11 | 53 | Frederic |  | MTC, M2M |  |  |
| 2906 | 798.4.1 | CT1 part of Stage 3 BB1: Reachability Aspects of SIMTC | 257d? | 2011-09-19 A | 2012-09-07 A | 100% | 2011-09-19 | 2012-09-07 | 257d? | finish no earlier than 2012-09-07 | C1 | 2048h | 2048h | SIMTC-ReachCSPS | 27 | Ericsson | mikael.wass@ericsson.com | Rel-11 | 53 | Frederic |  | MTC, M2M |  |  |
| 2907 | 798.4.2 | CT3 part of Stage 3 BB1: Reachability Aspects of SIMTC | 257d? | 2011-09-19 A | 2012-09-07 A | 100% | 2011-09-19 | 2012-09-07 | 257d? | finish no earlier than 2012-09-07 | C3 | 2048h | 2048h | SIMTC-ReachCSPS | 27 | Ericsson | mikael.wass@ericsson.com | Rel-11 | 53 | Adrian |  | MTC, M2M |  |  |
| 2908 | 798.4.3 | CT4 part of Stage 3 BB1: Reachability Aspects of SIMTC | 324d? | 2011-09-19 A | 2012-12-07 A | 100% | 2011-09-19 | 2012-12-07 | 324d? | finish no earlier than 2012-12-07 | C4 | 2568h | 2568h | SIMTC-ReachCSPS | 27 | Ericsson | mikael.wass@ericsson.com | Rel-11 | 53 | Kimmo |  | MTC, M2M |  |  |
| 2909 | 798.4.4 | CT6 part of Stage 3 BB1: Reachability Aspects of SIMTC | 257d? | 2011-09-19 A | 2012-09-07 A | 100% | 2011-09-19 | 2012-09-07 | 257d? | finish no earlier than 2012-09-07 | C6 | 2048h | 2048h | SIMTC-ReachCSPS | 27 | ST Ericsson | Andrzej Winiarski | Rel-11 | 53 | Xavier |  | MTC, M2M |  |  |
| 2910 | 798.5 | **Stage 2/3 for CS aspects for SIMTC** | 259d? | 2011-09-16 A | 2012-09-07 A | 100% | 2011-09-16 | 2012-09-07 | 259d? |  | C4; C1; C6 | 16544h | 16544h | SIMTC-CS | 27 | Ericsson | mikael.wass@ericsson.com | Rel-11 | 53 | Kimmo | SIMTC-CS | MTC, M2M |  |  |
| 2911 | 798.5.1 | Deleted - Stage 2 CS aspects for SIMTC | 258d? | 2011-09-16 A | 2012-09-06 A | 100% | 2011-09-16 | 2012-09-06 | 258d? | finish no earlier than 2012-09-07 | C4 | 2056h | 2056h | SIMTC-CS | 27 | Ericsson | mikael.wass@ericsson.com | Rel-11 | 53 | Kimmo |  | MTC, M2M | PCG-29 | CP-57 |
| 2912 | 798.5.2 | **Stage 3 CS aspects for SIMTC** | 259d? | 2011-09-16 A | 2012-09-07 A | 100% | 2011-09-16 | 2012-09-07 | 259d? |  | C1; C6 | 8272h | 8272h | SIMTC-CS | 27 | Ericsson | mikael.wass@ericsson.com | Rel-11 | 53 | Frederic |  | MTC, M2M |  |  |
| 2913 | 798.5.2.1 | CT1 part of Stage 3 CS aspects for SIMTC | 259d? | 2011-09-16 A | 2012-09-07 A | 100% | 2011-09-16 | 2012-09-07 | 259d? | start no earlier than 2011-09-16 | C1 | 2064h | 2064h | SIMTC-CS | 27 | Ericsson | mikael.wass@ericsson.com | Rel-11 | 53 | Frederic |  | MTC, M2M |  |  |
| 2914 | 798.5.2.2 | Deleted - CT6 part of Stage 3 CS aspects for SIMTC | 259d? | 2011-09-16 A | 2012-09-07 A | 100% | 2011-09-16 | 2012-09-07 | 259d? | start no earlier than 2011-09-16 | C6 | 2064h | 2064h | SIMTC-CS | 27 | Ericsson | mikael.wass@ericsson.com | Rel-11 | 53 | Xavier |  | MTC, M2M | PCG-29 | CP-57 |

Notes:
- 2889: CP#58 completed. Triggered by Rel-10 TR 22.893 UID_380083 Study on advanced requirements for IP interconnect (FS_IPXS)
- 2890: SP#53 completed / Impacted TSs and TRs: 22.101, 22.228
- 2891: SP#54 completed / Impacted TSs and TRs: 23.228
- 2892: CP#58 completed / Impacted TSs and TRs: Stage 3
- 2893: CP#58 completed / Impacted TSs and TRs: 24.229
- 2894: CP#57 completed / Impacted TSs and TRs: 29.165
- 2895: SP#58 completed. Updated WID SP-110877=>SP-120848. Enhancements to Rel-10 Feature UID_410031 (NIMTC) based on Rel-11 Study on enhancements to MTC
- 2896: SP#53 completed. SP#57 added MTC definitions in 21.905 / Impacted TSs and TRs: 22.368, 21.905 (MTC definitions)
- 2897: SP#57 completed. TR 23.888v200 for Approval. Was Rel-10 UID_450028 (TR on Stage 2 for NIMTC) / Impacted TSs and TRs: New TR 23.888
- 2898: SP#56 completed. SP#58 updated WID SP-110877=>S3-121111 (SA3 normative work on Security aspects of SIMTC incorporated in SA2 TS 23.682) / Impacted TSs and TRs: 23.221, New 23.368
- 2899: SP#54 work stopped
- 2900: SP#56 completed / Impacted TSs and TRs: New 23.682
- 2901: SP#54 completed / Impacted TSs and TRs: 23.221, New 23.682
- 2902: SP#56 completed / Impacted TSs and TRs: New 23.682
- 2903: SP#55 completed / Impacted TSs and TRs: 23.060, 23.272, New 23.682
- 2904: SP#55 completed / Impacted TSs and TRs: New 23.682
- 2905: 22/01: acronym modified / Impacted TSs and TRs: Stage 3
- 2906: 22/01: acronym modified / Impacted TSs and TRs: 23.040, 24.008, 24.301, 24.341, 24.368
- 2907: 22/01: acronym modified / Impacted TSs and TRs: 29.061, New TS 29.368
- 2908: 22/01: acronym modified / Impacted TSs and TRs: 23.003, 23.008, 29.002, 29.060, 29.230, New TS (29.336, 29.337)
- 2909: 22/01: acronym modified / Impacted TSs and TRs: 31.102
- 2910: CP#57 completed. Updated WID CP-120418=>CP-120617 / Impacted TSs and TRs: Stage 2/3
- 2911: CP#57 stopped / Impacted TSs and TRs: 23.012
- 2912: CP#57 completed / Impacted TSs and TRs: Stage 3
- 2913: CP#57 completed / Impacted TSs and TRs: 24.008, 24.301
- 2914: CP#57 stopped / Impacted TSs and TRs: 31.102

| ID | WBS | Task | Duration | Start | Finish | Complete | Baseline start | Baseline finish | Baseline duration | Constraint | Resources | Work | Actual work | Acronym | PCG approved | WI rapporteur name | WI rapporteur e-mail | Release | TSG approved | MCC resp | Special Focus Doc | Acronym_3GU_Export | Status Report | PCG stopped | TSG stopped |
| --- | --- | --- | --- | --- | --- | --- | --- | --- | --- | --- | --- | --- | --- | --- | --- | --- | --- | --- | --- | --- | --- | --- | --- | --- | --- |
| 2915 | 798.6 | **Stage 2/3 for SMS in MME architecture option and related PS-only service subscription** | 129d? | 2012-06-15 A | 2012-12-07 A | 100% | 2012-06-15 | 2012-12-07 | 129d? |  | C1; C4 | 3560h | 3560h | SIMTC-PS_Only | 29 | Ericsson | mikael.wass@ericsson.com | Rel-11 | 56 | Frederic | MTC, M2M | SIMTC-PS_Only |  |  |  |
| 2916 | 798.6.1 | CT1 part of Stage 2/3 for SMS in MME architecture option and related PS-only service subscription | 62d? | 2012-06-15 A | 2012-09-07 A | 100% | 2012-06-15 | 2012-09-07 | 62d? | finish no earlier than 2012-09-07 | C1 | 488h | 488h | SIMTC-PS_Only | 29 | Ericsson | mikael.wass@ericsson.com | Rel-11 | 56 | Frederic | MTC, M2M |  |  |  |  |
| 2917 | 798.6.2 | CT4 part of Stage 2/3 for SMS in MME architecture option and related PS-only service subscription | 129d? | 2012-06-15 A | 2012-12-07 A | 100% | 2012-06-15 | 2012-12-07 | 129d? | finish no earlier than 2012-12-07 | C4 | 1008h | 1008h | SIMTC-PS_Only | 29 | Ericsson | mikael.wass@ericsson.com | Rel-11 | 56 | Kimmo | MTC, M2M |  |  |  |  |
| 2918 | 798.7 | **RAN overload control for Machine-Type Communications** | 259d? | 2011-09-16 A | 2012-09-07 A | 100% | 2011-09-16 | 2012-09-07 | 259d? |  | R2; R3; C1; C6 | 20178.3h | 20178.3h | SIMTC-RAN_OC | 27 | Huawei | Jeff Gao (gaoyongqiang@huawei.com) | Rel-11 | 53 | Yong-Jun | MTC, M2M | SIMTC-RAN_OC |  |  |  |
| 2919 | 798.7.1 | Core part: RAN overload control for Machine-Type Communications | 258d? | 2011-09-19 A | 2012-09-07 A | 100% | 2011-09-19 | 2012-09-07 | 258d? | finish no earlier than 2012-09-07 | R2; R3 | 4128h | 4128h | SIMTC-RAN_OC-Core | 27 | Huawei | Jeff Gao (gaoyongqiang@huawei.com) | Rel-11 | 53 | Yong-Jun | MTC, M2M | SIMTC-RAN_OC-Core |  |  |  |
| 2920 | 798.7.2 | **Stage 3 (CS+PS) Extended Access Barring for UTRAN and E-UTRAN** | 259d? | 2011-09-16 A | 2012-09-07 A | 100% | 2011-09-16 | 2012-09-07 | 259d? |  | C1; C6 | 7762.29h | 7762.29h | SIMTC-RAN_OC | 27 | Ericsson | mikael.wass@ericsson.com | Rel-11 | 53 | Frederic | MTC, M2M |  |  |  |  |
| 2921 | 798.7.2.1 | CT1 part of Stage 3 Extended Access Barring for UTRAN and E-UTRAN | 198d? | 2011-09-16 A | 2012-06-15 A | 100% | 2011-09-16 | 2012-06-15 | 198d? | finish no earlier than 2012-09-14 | C1 | 1570.29h | 1570.29h | SIMTC-RAN_OC | 27 | Ericsson | mikael.wass@ericsson.com | Rel-11 | 53 | Frederic | MTC, M2M |  |  |  |  |
| 2922 | 798.7.2.2 | CT6 part of Stage 3 Extended Access Barring for UTRAN and E-UTRAN | 257d? | 2011-09-20 A | 2012-09-07 A | 100% | 2011-09-20 | 2012-09-07 | 257d? | finish no earlier than 2012-09-07 | C6 | 2048h | 2048h | SIMTC-RAN_OC | 27 | ST Ericsson | Andrzej Winiarski | Rel-11 | 53 | Xavier | MTC, M2M |  |  |  |  |
| 2923 | 798.8 | Test part: System Improvements for Machine-Type Communications | 130d? | 2013-09-09 A | 2014-03-06 A | 100% | 2013-09-09 | 2014-03-06 | 130d? | finish no earlier than 2014-03-06 | R5 | 1040h | 1040h | SIMTC-UEConTest | 31 | Ericsson | calle.hagenfeldt@ericsson.com | Rel-11 | 61 | Ingbert | MTC, M2M | SIMTC-UEConTest | RP-140075 |  |  |
| 2924 | 798.9 | BB5: Charging of SIMTC (Stage 2/3) | 269d? | 2011-12-07 A | 2012-12-12 A | 100% | 2011-12-07 | 2012-12-12 | 269d? | finish no earlier than 2012-12-12 | S5 | 2144h | 2144h | SIMTC-CH | 28 | Ericsson | patrik.teppo@ericsson.com | Rel-11 | 54 | Mirko | MTC, M2M | SIMTC-CH |  |  |  |
| 2925 | 798.10 | **Deleted - BB2: Stage 2 Signalling Optimizations of SIMTC** | 137d? | 2011-06-10 A | 2011-12-14 A | 100% | 2011-06-10 | 2011-12-14 | 137d? |  | S2 | 5240h | 5240h | SIMTC-Sig | 27 | Intel | puneet.jain@intel.com | Rel-11 | 52 | Maurice | MTC, M2M | SIMTC-Sig |  | PCG-28 | SP-55 |
| 2926 | 798.10.1 | Deleted - Effectively maintain connectivity for a large number of MTC Devices (TS 22.368, 7.1.1) | 137d? | 2011-06-10 A | 2011-12-14 A | 100% | 2011-06-10 | 2011-12-14 | 137d? | finish no earlier than 2011-12-07 | S2 | 1088h | 1088h | SIMTC-Sig | 27 | Intel | puneet.jain@intel.com | Rel-11 | 52 | Maurice | MTC, M2M |  |  | PCG-28 | SP-55 |
| 2927 | 798.10.2 | Deleted - Small Data Transmissions (TS 22.368, 7.2.5) | 137d? | 2011-06-10 A | 2011-12-14 A | 100% | 2011-06-10 | 2011-12-14 | 137d? | finish no earlier than 2011-12-07 | S2 | 1088h | 1088h | SIMTC-Sig | 27 | Intel | puneet.jain@intel.com | Rel-11 | 52 | Maurice | MTC, M2M |  |  | PCG-28 | SP-55 |
| 2928 | 798.10.3 | **Deleted - Stage 3 (CS+PS) Signalling Optimizations of SIMTC** | 62d? | 2011-09-16 A | 2011-12-09 A | 100% | 2011-09-16 | 2011-12-09 | 62d? |  | C1; C6 | 1968h | 1968h | SIMTC-Sig | 27 | Ericsson | mikael.wass@ericsson.com | Rel-11 | 53 | Frederic | MTC, M2M |  |  | PCG-28 | CP-55 |
| 2929 | 798.10.3.1 | Deleted - CT1 part of Stage 3 Signalling Optimizations of SIMTC | 62d? | 2011-09-16 A | 2011-12-09 A | 100% | 2011-09-16 | 2011-12-09 | 62d? | finish no earlier than 2011-12-02 | C1 | 488h | 488h | SIMTC-Sig | 27 | Ericsson | mikael.wass@ericsson.com | Rel-11 | 53 | Frederic | MTC, M2M |  |  | PCG-28 | CP-55 |
| 2930 | 798.10.3.2 | Deleted - CT6 part of Stage 3 Signalling Optimizations of SIMTC | 62d? | 2011-09-16 A | 2011-12-09 A | 100% | 2011-09-16 | 2011-12-09 | 62d? | finish no earlier than 2011-12-02 | C6 | 488h | 488h | SIMTC-Sig | 27 | ST Ericsson | Andrzej Winiarski | Rel-11 | 53 | Xavier | MTC, M2M |  |  | PCG-28 | CP-55 |
| 2931 | 798.11 | **Deleted - BB3: Stage 2 CN-based requirements and Power Considerations of SIMTC** | 139d? | 2011-06-08 A | 2011-12-14 A | 100% | 2011-06-08 | 2011-12-14 | 139d? |  | S2 | 6360h | 6360h | SIMTC-CN_Pow | 27 | Intel | puneet.jain@intel.com | Rel-11 | 52 | Maurice | MTC, M2M | SIMTC-CN_Pow |  | PCG-28 | SP-55 |
| 2932 | 798.11.1 | Deleted - Charging Requirements (TS 22.368, 7.1.5) | 137d? | 2011-06-10 A | 2011-12-14 A | 100% | 2011-06-10 | 2011-12-14 | 137d? | finish no earlier than 2012-03-21 | S2 | 1088h | 1088h | SIMTC-CN_Pow | 27 | Intel | puneet.jain@intel.com | Rel-11 | 52 | Maurice | MTC, M2M |  |  | PCG-28 | SP-55 |
| 2933 | 798.11.2 | Deleted - Lower Power Consumption (TS 22.368, 7.1.1) | 137d? | 2011-06-10 A | 2011-12-14 A | 100% | 2011-06-10 | 2011-12-14 | 137d? | finish no earlier than 2011-12-07 | S2 | 1088h | 1088h | SIMTC-CN_Pow | 27 | Intel | puneet.jain@intel.com | Rel-11 | 52 | Maurice | MTC, M2M |  |  | PCG-28 | SP-55 |
| 2934 | 798.11.3 | Deleted - MTC Monitoring (TS 22.368, 7.2.8) | 139d? | 2011-06-08 A | 2011-12-14 A | 100% | 2011-06-08 | 2011-12-14 | 139d? | finish no earlier than 2011-12-07 | S2 | 1104h | 1104h | SIMTC-CN_Pow | 27 | Intel | puneet.jain@intel.com | Rel-11 | 52 | Maurice | MTC, M2M |  |  | PCG-28 | SP-55 |
| 2935 | 798.11.4 | **Deleted - Stage 3 (CS+PS) CN-based requirements and Power Considerations of SIMTC** | 62d? | 2011-09-16 A | 2011-12-09 A | 100% | 2011-09-16 | 2011-12-09 | 62d? |  | C1; C6 | 1968h | 1968h | SIMTC-CN_Pow | 27 | Ericsson | mikael.wass@ericsson.com | Rel-11 | 53 | Frederic | MTC, M2M |  |  | PCG-28 | CP-55 |
| 2936 | 798.11.4.1 | Deleted - CT1 part of Stage 3 CN-based requirements and Power Considerations of SIMTC | 62d? | 2011-09-16 A | 2011-12-09 A | 100% | 2011-09-16 | 2011-12-09 | 62d? | finish no earlier than 2011-12-02 | C1 | 488h | 488h | SIMTC-CN_Pow | 27 | Ericsson | mikael.wass@ericsson.com | Rel-11 | 53 | Frederic | MTC, M2M |  |  | PCG-28 | CP-55 |
| 2937 | 798.11.4.2 | Deleted - CT6 part of Stage 3 CN-based requirements and Power Considerations of SIMTC | 62d? | 2011-09-16 A | 2011-12-09 A | 100% | 2011-09-16 | 2011-12-09 | 62d? | finish no earlier than 2011-12-02 | C6 | 488h | 488h | SIMTC-CN_Pow | 27 | ST Ericsson | Andrzej Winiarski | Rel-11 | 53 | Xavier | MTC, M2M |  |  | PCG-28 | CP-55 |
| 2938 | 798.12 | Deleted - TR on Security aspects of Machine-Type Communications | 662d? | 2009-12-10 A | 2012-06-20 A | 100% | 2009-12-10 | 2012-06-20 | 662d? | finish no earlier than 2012-06-20 | S3 | 5288h | 5288h |  | 25 | Samsung | Rajavelsamy R (rajvel@samsung.com) | Rel-11 | 49 | Mirko | MTC, M2M |  |  | PCG-29 | SP-56 |

Notes:
- 2915: CP#58 completed / Impacted TSs and TRs: Stage 2/3
- 2916: CP#57 completed / Impacted TSs and TRs: 23.040, 24.008, 24.011, 24.301, 29.018, 29.118
- 2917: CP#58 completed. TS 29.338 v200 for Approval / Impacted TSs and TRs: 23.003, 23.008, 23.012, 29.002, 29.272, 29.305, New TS 29.338
- 2918: Stage 2,3. TSG#57 completed / Impacted TSs and TRs: UTRA, LTE
- 2919: RP#57 completed / Impacted TSs and TRs: 25.304, 25.331, 25.413, 36.304, 36.331, 36.413
- 2920: CP#57 completed. Updated WID CP-120418=>CP-120617 / Impacted TSs and TRs: Stage 3
- 2921: CP#56 completed / Impacted TSs and TRs: 23.122, 24.008, 24.301
- 2922: CP#57 completed / Impacted TSs and TRs: 31.102
- 2923: RP#63 completed. Updated WID RP-131341=>RP-140077 (added affected TS 36.508). Testing for core part: SIMTC-Reach, SIMTC-CS, SIMTC-PS_Only, SIMTC-RAN_OC / Impacted TSs and TRs: 34.123-1, 34.123-2, 34.123-3, 36.508, 36.523-1, 36.523-2, 36.523-3
- 2924: SP#58 completed / Impacted TSs and TRs: 32.240, 32.251, 32.298, 32.299
- 2925: SP#54 work stopped. SP#58 updated WID SP-110877=>SP-120848 / Impacted TSs and TRs: TBD
- 2926: SP#54 work stopped / Impacted TSs and TRs: TBD
- 2927: SP#54 work stopped / Impacted TSs and TRs: TBD
- 2928: CP#54 work stopped / Impacted TSs and TRs: Stage 3
- 2929: - / Impacted TSs and TRs: 23.122, 24.008, 24.301, 24.368
- 2930: - / Impacted TSs and TRs: 31.102
- 2931: SP#54 work stopped / Impacted TSs and TRs: TBD
- 2932: SP#54 work stopped / Impacted TSs and TRs: TBD
- 2933: SP#54 work stopped / Impacted TSs and TRs: TBD
- 2934: SP#54 work stopped / Impacted TSs and TRs: TBD
- 2935: CP#54 work stopped / Impacted TSs and TRs: Stage 3
- 2936: - / Impacted TSs and TRs: 23.122, 24.008, 24.301, 24.368
- 2937: - / Impacted TSs and TRs: 31.101, 31.102
- 2938: Was Rel-10 UID_460023 (Security for NIMTC). SP#56 stopped (activity transferred to Rel-12 Feature MTCe under UID_560722). / Impacted TSs and TRs: New TR 33.868

| ID | WBS | Task | Type | Duration | Start | Finish | Complete | Baseline start | Baseline finish | Baseline duration | Constraint | Resources | Work | Actual work | Acronym | PCG approved | Impacted TSs and TRs | WI rapporteur name | Release | TSG approved | MCC resp | PCG stopped | TSG stopped | Special Focus Doc | Acronym_3GU_Export |
| --- | --- | --- | --- | --- | --- | --- | --- | --- | --- | --- | --- | --- | --- | --- | --- | --- | --- | --- | --- | --- | --- | --- | --- | --- | --- |
| 2939 | 798.13 | **Deleted - BB4: Secure Connection and Privacy of SIMTC** |  | 336d? | 2011-06-08 A | 2012-09-12 A | 100% | 2011-06-08 | 2012-09-12 | 336d? |  | S3 | 7424h | 7424h | SIMTC-Sec | 27 | TBD | Samsung | Rel-11 | 52 | Mirko | PCG-29 | CP-57 | MTC, M2M | SIMTC-Sec |
| 2940 | 798.13.1 | Deleted - Secure Connection MTC Feature (TS 22.368, 7.2.10) |  | 333d? | 2011-06-08 A | 2012-09-12 A | 100% | 2011-06-08 | 2012-09-12 | 333d? | finish no earlier than 2012-09-12 | S3 | 2656h | 2656h | SIMTC-Sec | 27 | TBD | Samsung | Rel-11 | 52 | Mirko | PCG-29 | CP-57 | MTC, M2M |  |
| 2941 | 798.13.2 | Deleted - MTC Location Privacy |  | 261d? | 2011-09-19 A | 2012-09-12 A | 100% | 2011-09-19 | 2012-09-12 | 261d? | finish no earlier than 2012-09-12 | S3 | 2080h | 2080h | SIMTC-Priv | 27 | TBD | Samsung | Rel-11 | 53 | Mirko | PCG-29 | CP-57 | MTC, M2M | SIMTC-Priv |
| 2942 | 798.14 | Deleted - Stage 2 on SA2 part for System Improvements to Machine-Type Communications |  | 260d? | 2010-06-10 A | 2011-06-08 A | 100% | 2010-06-10 | 2011-06-08 | 260d? | finish no earlier than 2011-06-08 | S2 | 2080h | 2080h | SIMTC | 25 | TBD | Intel | Rel-11 | 48 | Maurice | PCG-27 | SP-52 | MTC, M2M |  |
| 2943 | 798.15 | Deleted - Stage 2 on Security part for System Improvements to Machine-Type Communications |  | 260d? | 2010-06-10 A | 2011-06-08 A | 100% | 2010-06-10 | 2011-06-08 | 260d? | finish no earlier than 2011-06-08 | S3 | 2080h | 2080h | SIMTC | 25 | TBD | Samsung | Rel-11 | 48 | Mirko | PCG-27 | SP-52 | MTC, M2M |  |
| 2944 | 799 | **Unstructured Supplementary Service Data (USSD) simulation service in IMS** |  | 659d? | 2010-06-10 A | 2012-12-07 A | 100% | 2010-06-10 | 2012-12-07 | 659d? |  | S1; C1; C3 | 28112.1h | 28112.1h | USSI | 25 |  | Deutsche Telekom | Rel-11 | 48 | Alain |  |  |  | USSI |
| 2945 | 799.1 | Stage 1 for USSD simulation service in IMS | milestone | 0d? | 2010-06-10 A | 2010-06-10 A | 100% | 2010-06-10 | 2010-06-10 | 0d? | finish no earlier than 2010-06-10 | S1 |  |  | USSI | 25 | 22.173 | Deutsche Telekom | Rel-11 | 48 | Alain |  |  |  |  |
| 2946 | 799.2 | **Stage 3 for USSD simulation service in IMS** |  | 403d? | 2011-06-03 A | 2012-12-07 A | 100% | 2011-06-03 | 2012-12-07 | 403d? |  | C1; C3 | 12296.1h | 12296.1h | USSI | 27 |  | Deutsche Telekom | Rel-11 | 52 | Frederic |  |  |  |  |
| 2947 | 799.2.1 | CT1 part of Stage 3 for USSD simulation service in IMS |  | 402d? | 2011-06-03 A | 2012-12-07 A | 100% | 2011-06-03 | 2012-12-07 | 402d? | finish no earlier than 2012-12-07 | C1 | 3184.06h | 3184.06h | USSI | 27 | 24.173, 24.229, new TS 24.390 | Deutsche Telekom | Rel-11 | 52 | Frederic |  |  |  |  |
| 2948 | 799.2.2 | CT3 part of Stage 3 for USSD simulation service in IMS |  | 334d? | 2011-06-07 A | 2012-09-07 A | 100% | 2011-06-07 | 2012-09-07 | 334d? | finish no earlier than 2012-09-07 | C3 | 2664h | 2664h | USSI | 27 | 29.165 | Deutsche Telekom | Rel-11 | 52 | Adrian |  |  |  |  |
| 2949 | 800 | **QoS Control Based on Subscriber Spending Limits** |  | 459d? | 2010-09-23 A | 2012-06-20 A | 100% | 2010-09-23 | 2012-06-20 | 459d? |  | S1; S2; S5; C3 | 23152h | 23152h | QoS_SSL | 25 |  | Vodafone | Rel-11 | 49 | Alain |  |  |  | QoS_SSL |
| 2950 | 800.1 | Stage 1 for QoS Control Based on Subscriber Spending Limits |  | 262d? | 2010-09-23 A | 2011-09-21 A | 100% | 2010-09-23 | 2011-09-21 | 262d? | finish no earlier than 2011-09-21 | S1 | 2080h | 2080h | QoS_SSL | 25 | 22.115 | Vodafone | Rel-11 | 49 | Alain |  |  |  |  |
| 2951 | 800.2 | Stage 2 for QoS Control Based on Subscriber Spending Limits |  | 133d? | 2011-03-23 A | 2011-09-21 A | 100% | 2011-03-23 | 2011-09-21 | 133d? | finish no earlier than 2011-12-14 | S2 | 1048h | 1048h | QoS_SSL | 26 | 23.203 | Huawei | Rel-11 | 51 | Maurice |  |  |  |  |
| 2952 | 800.3 | Charging for QoS Control Based on Subscriber Spending Limits (Stage 2) |  | 397d? | 2010-12-16 A | 2012-06-20 A | 100% | 2010-12-16 | 2012-06-20 | 397d? | finish no earlier than 2012-06-20 | S5 | 3168h | 3168h | QoS_SSL | 26 | 32.240, 32.296 | Nokia Siemens Networks, Huawei | Rel-11 | 50 | Mirko |  |  |  |  |
| 2953 | 800.4 | CT3 aspects of QoS Control Based on Subscriber Spending Limits (Stage 3) |  | 273d? | 2011-06-03 A | 2012-06-15 A | 100% | 2011-06-03 | 2012-06-15 | 273d? | finish no earlier than 2012-06-15 | C3 | 2168h | 2168h | QoS_SSL-CT3 | 27 | 29.212, 29.213, 29.214, 29.215, new TS 29.219 | Huawei | Rel-11 | 52 | Adrian |  |  |  | QoS_SSL-CT3 |
| 2954 | 801 | **Optimized Service Charging and Allocation of Resources in IMS whilst Roaming** |  | 383d? | 2010-09-23 A | 2012-03-07 A | 100% | 2010-09-23 | 2012-03-07 | 383d? |  | S1; S2 | 14288h | 14288h | OSCAR | 25 |  | Vodafone | Rel-11 | 49 | Alain |  |  |  | OSCAR |
| 2955 | 801.1 | TR on Stage 2 aspects of Optimized Service Charging and Allocation of Resources in IMS whilst Roaming |  | 383d? | 2010-09-23 A | 2012-03-07 A | 100% | 2010-09-23 | 2012-03-07 | 383d? | finish no earlier than 2011-12-07 | S2 | 3040h | 3040h | OSCAR | 25 | new TR 23.849 | Vodafone | Rel-11 | 49 | Maurice |  |  |  |  |
| 2956 | 801.2 | Stage 1 for Optimized Service Charging and Allocation of Resources in IMS whilst Roaming |  | 262d? | 2010-09-23 A | 2011-09-21 A | 100% | 2010-09-23 | 2011-09-21 | 262d? | finish no earlier than 2011-09-21 | S1 | 2080h | 2080h | OSCAR | 25 | 22.115, 22.173, 22.228 | Vodafone | Rel-11 | 49 | Alain |  |  |  |  |
| 2957 | 801.3 | Deleted - Stage 2 for Optimized Service Charging and Allocation of Resources in IMS whilst Roaming |  | 380d? | 2010-09-28 A | 2012-03-07 A | 100% | 2010-09-28 | 2012-03-07 | 380d? | finish no earlier than 2012-03-07 | S2 | 3040h | 3040h | OSCAR | 25 | None | Vodafone | Rel-11 | 49 | Maurice | PCG-28 | SP-55 |  |  |
| 2958 | 802 | **Inclusion of Media Resource Broker (Stage 2/3)** |  | 463d? | 2011-09-16 A | 2013-06-14 A | 100% | 2011-09-16 | 2013-06-14 | 463d? |  | C1; C3; IETF | 30500h | 30500h | MRB | 27 | Stage 2/3 | AT&T | Rel-11 | 53 | Frederic |  |  |  | MRB |
| 2959 | 802.1 | Stage 2 for Inclusion of Media Resource Broker |  | 259d? | 2011-09-16 A | 2012-09-07 A | 100% | 2011-09-16 | 2012-09-07 | 259d? | finish no earlier than 2012-09-07 | C1 | 2049.98h | 2049.98h | MRB | 27 | 23.218 | AT&T | Rel-11 | 53 | Frederic |  |  |  |  |
| 2960 | 802.2 | **Stage 3 for Inclusion of Media Resource Broker** |  | 463d? | 2011-09-16 A | 2013-06-14 A | 100% | 2011-09-16 | 2013-06-14 | 463d? |  | C1; C3; IETF | 17338h | 17338h | MRB | 27 |  | AT&T | Rel-11 | 53 | Frederic |  |  |  |  |
| 2961 | 802.2.1 | CT1 part of Stage 3 for Inclusion of Media Resource Broker |  | 258d? | 2011-09-16 A | 2012-09-07 A | 100% | 2011-09-16 | 2012-09-07 | 258d? | finish no earlier than 2012-09-07 | C1 | 2049.98h | 2049.98h | MRB | 27 | 24.229, 29.165 | AT&T | Rel-11 | 53 | Frederic |  |  |  |  |
| 2962 | 802.2.2 | (IETF) Inclusion of Media Resource Broker [RFC 6917 (was draft-ietf-mediactrl-mrb)] |  | 462d? | 2011-09-16 A | 2013-06-14 A | 100% | 2011-09-16 | 2013-06-14 | 462d? | finish no earlier than 2013-06-14 | C1-IETF | 3688h | 3688h | MRB | 27 | RFC 6917 (was draft-ietf-mediactrl-mrb) | Keith Drage | Rel-11 | 53 | Frederic |  |  |  |  |
| 2963 | 802.2.3 | CT3 part of Stage 3 for Inclusion of Media Resource Broker |  | 62d? | 2012-06-15 A | 2012-09-07 A | 100% | 2012-06-15 | 2012-09-07 | 62d? | finish no earlier than 2012-09-07 | C3 | 488h | 488h | MRB | 29 | 29.165 | AT&T | Rel-11 | 56 | Adrian |  |  |  |  |

Notes:
- 2939: SP#57 stopped (activity transferred to Rel-12 Feature MTCe under UID_560522) / WI rapporteur e-mail: Rajavelsamy R (rajvel@samsung.com)
- 2940: SP#57 stopped (activity transferred to Rel-12 Feature MTCe / WI rapporteur e-mail: Rajavelsamy R (rajvel@samsung.com)
- 2941: SP#57 stopped (activity transferred to Rel-12 Feature MTCe / WI rapporteur e-mail: Rajavelsamy R (rajvel@samsung.com)
- 2942: SP#52 stopped / WI rapporteur e-mail: puneet.jain@intel.com
- 2943: SP#52 stopped / WI rapporteur e-mail: Rajavelsamy R (rajvel@samsung.com)
- 2944: CP#58 completed / WI rapporteur e-mail: kurt.bischinger@t-mobile.at
- 2945: SP#48 completed. Specify a CS domain USSD like service over IMS (see GSM Mobile User Initiated USSD) / WI rapporteur e-mail: kurt.bischinger@t-mobile.at
- 2946: SP#58 completed. No stage 2 impact, as reuse existing IMS architecture in TS 23.228 / WI rapporteur e-mail: reinhard.lauster@t-mobile.at
- 2947: CP#58 completed / WI rapporteur e-mail: reinhard.lauster@t-mobile.at, TS 24.390 Rapp: lili.yang@huawei.com
- 2948: CP#57 completed / WI rapporteur e-mail: reinhard.lauster@t-mobile.at
- 2949: TSG#56 completed / WI rapporteur e-mail: mona.mustapha@vodafone.com
- 2950: SP#53 completed. Use cases & service requirements to allow: 1) modification of QoS based on subscribers spending limits 2) enforcing of spending limits for roaming subscribers without having dedicated support in the visited network / WI rapporteur e-mail: mona.mustapha@vodafone.com
- 2951: SP#53 completed / WI rapporteur e-mail: Xu Xia (xiatony@huawei.com)
- 2952: SP#56 completed / WI rapporteur e-mail: Gerald.Goermer@nsn.com, shan.mingjun@huawei.com
- 2953: CP#56 completed / WI rapporteur e-mail: QiaoWeihua@huawei.com
- 2954: SP#55 completed (Stage 2/3 specified under CT1 Rel-11 Feature MRB (Inclusion of Media Resource Broker) UID_530021. Triggered by S1-102236/GSMA RILTE 10_007r1 (IREG LS_038 to 3GPP on Optimal Media Routing drawbacks) / WI rapporteur e-mail: mona.mustapha@vodafone.com
- 2955: SP#55 completed / WI rapporteur e-mail: Susana.Sabater@vodafone.com
- 2956: SP#53 completed / WI rapporteur e-mail: mona.mustapha@vodafone.com
- 2957: SP#55 no normative work in SA2. Stage 2/3 to be done in under CT1 Rel-11 Feature MRB (Inclusion of Media Resource Broker) UID_530021 / WI rapporteur e-mail: Susana.Sabater@vodafone.com
- 2958: Stage 1 and TR on Stage 2 in Rel-11 Feature OSCAR UID_490032 / WI rapporteur e-mail: Martin Dolly (md3135@att.com)
- 2959: CP#57 completed / WI rapporteur e-mail: Martin Dolly (md3135@att.com)
- 2960: CP#60 completed / WI rapporteur e-mail: Martin Dolly (md3135@att.com)
- 2961: CP#57 completed / WI rapporteur e-mail: Martin Dolly (md3135@att.com)
- 2962: CP#60 completed
- 2963: CP#57 completed / WI rapporteur e-mail: Martin Dolly (md3135@att.com)

| ID | WBS | Task | Duration | Start | Finish | Complete | Baseline start | Baseline finish | Baseline duration | Constraint | Resources | Work | Actual work | Acronym | PCG approved | WI rapporteur name | WI rapporteur e-mail | Release | TSG approved | MCC resp | Acronym_3GU_Export | Special Focus Doc | PCG stopped | TSG stopped |
| --- | --- | --- | --- | --- | --- | --- | --- | --- | --- | --- | --- | --- | --- | --- | --- | --- | --- | --- | --- | --- | --- | --- | --- | --- |
| 2964 | 803 | **Non Voice Emergency Services** | 323d? | 2010-12-16 A | 2012-03-07 A | 100% | 2010-12-16 | 2012-03-07 | 323d? |  | S1; S2 | 7736h | 7736h | NOVES | 26 | Qualcomm | dwilliams@qualcomm.com | Rel-11 | 50 | Alain | NOVES |  |  |  |
| 2965 | 803.1 | Stage 1 for Non Voice Emergency Services | 202d? | 2010-12-16 A | 2011-09-21 A | 100% | 2010-12-16 | 2011-09-21 | 202d? | finish no earlier than 2011-09-21 | S1 | 1600h | 1600h | NOVES | 26 | Qualcomm | dwilliams@qualcomm.com | Rel-11 | 50 | Alain |  |  |  |  |
| 2966 | 803.2 | Stage 2 for Non Voice Emergency Services (Support of IMS Emergency Sessions with Other Media on UTRAN and E-UTRAN) | 121d? | 2011-09-22 A | 2012-03-07 A | 100% | 2011-09-22 | 2012-03-07 | 121d? | finish no earlier than 2012-03-07 | S2 | 968h | 968h | NOVES-IMSESOM | 27 | Alcatel-Lucent | Deb.Barclay@alcatel-lucent.com | Rel-11 | 53 | Maurice | NOVES-IMSESOM |  |  |  |
| 2967 | 804 | **Support for 3GPP Voice Interworking with Enterprise IP-PBX** | 516d? | 2011-03-23 A | 2013-03-01 A | 100% | 2011-03-23 | 2013-03-01 | 516d? |  | S1; C1 | 12376h | 12376h | VINE | 26 | Tatara Systems | Phillip Brown (pbrown@tatarasystems.com) | Rel-11 | 51 | Alain | VINE |  |  |  |
| 2968 | 804.1 | Stage 1 for Support for 3GPP Voice Interworking with Enterprise IP-PBX | 133d? | 2011-03-23 A | 2011-09-21 A | 100% | 2011-03-23 | 2011-09-21 | 133d? | finish no earlier than 2011-09-21 | S1 | 1048h | 1048h | VINE | 26 | Tatara Systems | Phillip Brown (pbrown@tatarasystems.com) | Rel-11 | 51 | Alain |  |  |  |  |
| 2969 | 804.2 | Stage 2/3 for Support for 3GPP Voice Interworking with Enterprise IP-PBX | 385d? | 2011-09-20 A | 2013-03-01 A | 100% | 2011-09-20 | 2013-03-01 | 385d? | finish no earlier than 2013-03-01 | C1 | 3072h | 3072h | VINE-CT1 | 27 | Alcatel-Lucent | keith.drage@alcatel-lucent.com | Rel-11 | 53 | Frederic | VINE-CT1 |  |  |  |
| 2970 | 805 | **Anonymous Call Rejection in the CS domain** | 132d? | 2011-06-07 A | 2011-12-02 A | 100% | 2011-06-07 | 2011-12-02 | 132d? |  | S1; C4; C3 | 4616h | 4616h | ACR_CS | 27 | Alcatel-Lucent | Betsy.Covell@alcatel-lucent.com | Rel-11 | 52 | Alain | ACR_CS |  |  |  |
| 2971 | 805.1 | Stage 1 for Anonymous Call Rejection in the CS domain | 2d? | 2011-06-07 A | 2011-06-08 A | 100% | 2011-06-07 | 2011-06-08 | 2d? | finish no earlier than 2011-06-07 | S1 | 16h | 16h | ACR_CS | 27 | Alcatel-Lucent | Betsy.Covell@alcatel-lucent.com | Rel-11 | 52 | Alain |  |  |  |  |
| 2972 | 805.2 | **Core Network aspects of Anonymous Call Rejection in the CS domain** | 59d? | 2011-09-14 A | 2011-12-02 A | 100% | 2011-09-14 | 2011-12-02 | 59d? |  | C4; C3 | 1432h | 1432h | ACR_CS-CN | 27 | Alcatel-Lucent | bruno.landais@alcatel-lucent.com | Rel-11 | 53 | Kimmo | ACR_CS-CN |  |  |  |
| 2973 | 805.2.1 | CT4 part of Core Network aspects of Anonymous Call Rejection in the CS domain (Stage 2/3) | 59d? | 2011-09-14 A | 2011-12-02 A | 100% | 2011-09-14 | 2011-12-02 | 59d? | finish no earlier than 2011-12-02 | C4 | 464h | 464h | ACR_CS-CN | 27 | Alcatel-Lucent | bruno.landais@alcatel-lucent.com | Rel-11 | 53 | Kimmo |  |  |  |  |
| 2974 | 805.2.2 | CT3 part of Core Network aspects of Anonymous Call Rejection in the CS domain (Stage 3) | 3d? | 2011-09-14 A | 2011-09-16 A | 100% | 2011-09-14 | 2011-09-16 | 3d? | start no earlier than 2011-09-14 | C3 | 24h | 24h | ACR_CS-CN | 27 | Alcatel-Lucent | bruno.landais@alcatel-lucent.com | Rel-11 | 53 | Adrian |  |  |  |  |
| 2975 | 806 | **Support for BroadBand Forum Accesses Interworking** | 792d? | 2009-12-10 A | 2012-12-12 A | 100% | 2009-12-10 | 2012-12-12 | 792d? |  | S2; S1; C1; C3; C4; IETF | 97983.8h | 97983.8h | BBAI | 24 | Ericsson | peter.bleckert@ericsson.com | Rel-11 | 46 | Alain | BBAI | HNB, WLAN |  |  |
| 2976 | 806.1 | Stage 1 BB I: BBF interworking with home routed traffic for WLAN and H(e)NB | 76d? | 2009-12-10 A | 2010-03-25 A | 100% | 2009-12-10 | 2010-03-25 | 76d? | start no earlier than 2009-12-10 | S1 | 608h | 608h | BBAI | 24 | Ericsson | Olle.Eriksson@ericsson.com | Rel-11 | 46 | Alain |  | HNB, WLAN |  |  |
| 2977 | 806.2 | TR on Stage 2 for BBAI | 588d? | 2010-03-26 A | 2012-06-20 A | 100% | 2010-03-26 | 2012-06-20 | 588d? | finish no earlier than 2012-06-19 | S2 | 4704h | 4704h | BBAI | 24 | Ericsson | marco.spini@huawei.com | Rel-11 | 47 | Maurice |  | HNB, WLAN |  |  |
| 2978 | 806.3 | Stage 2 BB I: BBF interworking with home routed traffic for WLAN and H(e)NB | 588d? | 2010-03-26 A | 2012-06-20 A | 100% | 2010-03-26 | 2012-06-20 | 588d? | finish no earlier than 2012-06-20 | S2 | 4688.06h | 4688.06h | BBAI | 24 | Ericsson | stefan.rommer@ericsson.com | Rel-11 | 47 | Maurice |  | HNB, WLAN |  |  |
| 2979 | 806.4 | (IETF) Stage 2 BB I: BBF interworking with home routed traffic for WLAN and H(e)NB | 266d? | 2011-12-12 A | 2012-12-12 A | 100% | 2011-12-12 | 2012-12-12 | 266d? | finish no earlier than 2012-11-24 | S2-IETF | 2119.59h | 2119.59h | BBAI | 28 | Lionel Morand | Lionel Morand | Rel-11 | 54 | Maurice |  | HNB, WLAN |  |  |
| 2980 | 806.5 | **Stage 3 BB I - Core Network impacts: BBF interworking with home routed traffic for WLAN and H(e)NB** | 326d? | 2011-09-16 A | 2012-12-07 A | 100% | 2011-09-16 | 2012-12-07 | 326d? |  | C1; C3; C4 | 17288.2h | 17288.2h | BBAI_BBI-CT | 27 | Ericsson | Zu.Qiang@Ericsson.com | Rel-11 | 53 | Frederic | BBAI_BBI-CT | HNB, WLAN |  |  |
| 2981 | 806.5.1 | TR on Stage 3 BB I for BBAI; UE to network protocols | 198d? | 2011-09-16 A | 2012-06-15 A | 100% | 2011-09-16 | 2012-06-15 | 198d? | finish no earlier than 2012-06-15 | C1 | 1568.15h | 1568.15h | BBAI_BBI-CT | 27 | Ericsson | Zu.Qiang@Ericsson.com | Rel-11 | 53 | Frederic |  | HNB, WLAN |  |  |
| 2982 | 806.5.2 | TR on Stage 3 BB I for BBAI; Home (e)Node B – Security Gateway Interface | 77d? | 2012-03-02 A | 2012-06-15 A | 100% | 2012-03-02 | 2012-06-15 | 77d? | finish no earlier than 2012-06-01 | C4 | 608h | 608h | BBAI_BBI-CT | 28 | Ericsson | Zu.Qiang@Ericsson.com | Rel-11 | 55 | Kimmo |  | HNB, WLAN |  |  |
| 2983 | 806.5.3 | Deleted - (IETF) on Stage 3 BB I for BBAI; Home (e)Node B – Security Gateway Interface | 77d? | 2012-03-02 A | 2012-06-15 A | 100% | 2012-03-02 | 2012-06-15 | 77d? | finish no earlier than 2012-06-15 | C4-IETF | 616h | 616h | BBAI_BBI-CT | 28 | Lionel Morand |  | Rel-11 | 55 | Kimmo |  | HNB, WLAN | PCG-29 | CP-56 |
| 2984 | 806.5.4 | CT1 part of Stage 3 BB I: BBF interworking with home routed traffic for WLAN and H(e)NB | 258d? | 2011-09-16 A | 2012-09-07 A | 100% | 2011-09-16 | 2012-09-07 | 258d? | finish no earlier than 2012-09-07 | C1 | 2048h | 2048h | BBAI_BBI-CT | 27 | Ericsson | Zu.Qiang@Ericsson.com | Rel-11 | 53 | Frederic |  | HNB, WLAN |  |  |
| 2985 | 806.5.5 | CT3 part of Stage 3 BB I: BBF interworking with home routed traffic for WLAN and H(e)NB | 259d? | 2011-09-16 A | 2012-09-07 A | 100% | 2011-09-16 | 2012-09-07 | 259d? | finish no earlier than 2012-09-07 | C3 | 2048h | 2048h | BBAI_BBI-CT | 27 | Ericsson | Zu.Qiang@Ericsson.com | Rel-11 | 53 | Adrian |  | HNB, WLAN |  |  |
| 2986 | 806.5.6 | CT4 part of Stage 3 BB I: BBF interworking with home routed traffic for WLAN and H(e)NB | 326d? | 2011-09-16 A | 2012-12-07 A | 100% | 2011-09-16 | 2012-12-07 | 326d? | finish no earlier than 2012-12-07 | C4 | 2576h | 2576h | BBAI_BBI-CT | 27 | Ericsson | Zu.Qiang@Ericsson.com | Rel-11 | 53 | Kimmo |  | HNB, WLAN |  |  |
| 2987 | 806.6 | Stage 1 BB II: BBF interworking with offload in access network for WLAN and for H(e)NB | 262d? | 2010-09-23 A | 2011-09-21 A | 100% | 2010-09-23 | 2011-09-21 | 262d? | finish no earlier than 2011-09-21 | S1 | 2080h | 2080h | BBAI_BBII-CTofldS1 | 25 | Ericsson | Olle.Eriksson@ericsson.com | Rel-11 | 49 | Alain |  | HNB, WLAN |  |  |
| 2988 | 806.7 | Stage 2 BB II: BBF interworking with offload in access network for WLAN and for H(e)NB | 455d? | 2010-09-28 A | 2012-06-20 A | 100% | 2010-09-28 | 2012-06-20 | 455d? | finish no earlier than 2012-06-20 | S2 | 3640h | 3640h | BBAI_BBII-CTofldS2 | 24 | Ericsson | stefan.rommer@ericsson.com | Rel-11 | 47 | Maurice |  | HNB, WLAN |  |  |

Notes:
- 2964: SP#55 Stage 2 completed. Triggered by SA1 Rel-11 TR 22.871 Study on Non Voice Emergency Services (FS_NOVES)
- 2965: SP#53 completed / Impacted TSs and TRs: 22.101
- 2966: SP#55 completed / Impacted TSs and TRs: 23.060, 23.167, 23.203, 23.401
- 2967: SP#53 Stage 1 completed. CP#59 completed. Triggered by Rel-11 TR 22.809 Study on Support for 3GPP Voice Interworking with Enterprise IP-PBX (FS_VINE) UID_480033
- 2968: SP#53 completed / Impacted TSs and TRs: 22.228
- 2969: CP#59 completed / Impacted TSs and TRs: 23.218, 24.229
- 2970: CP#54 completed
- 2971: SP#52 completed under TEI11. Approved WID and CRs in SP-110376 (22.082 CR#0005, 22.085 CR#0004, 22.081 CR#0007, 22.088 CR#0003, 22.004 CR#0013) / Impacted TSs and TRs: 22.004, 22.081, 22.082, 22.085, 22.088
- 2972: CP#54 completed / Impacted TSs and TRs: Stage 2/3
- 2973: CP#54 completed / Impacted TSs and TRs: 23.018, 23.081, 23.082, 23.085, 23.088, 23.205, 23.231, 24.088, 29.002, 29.011
- 2974: CP#53 completed / Impacted TSs and TRs: 29.163, 29.292
- 2975: SP#57 updated WID SP-120419=>SP-120539 (removed BB3 objectives not implemented in Stage 2). SP#56 completed. Triggered by BBF WT 203, WT-134 (interworking btw 3GPP EPS and BBF's fixed broadband accesses)
- 2976: SP#57 updated WID SP-120419=>SP-120539 (removed BB3 objectives not implemented in Stage 2). SP#47 completed. Provide service requirements for supporting interworking between 3GPP EPS and the fixed broadband accesses defined by BBF / Impacted TSs and TRs: 22.278 CR#0058
- 2977: TR 23.839 not Approved in Rel-11; progressed in Rel-12 under P4C-TI (UID_560824) / Impacted TSs and TRs: new TR 23.839
- 2978: SP#56 completed / Impacted TSs and TRs: 23.203, new 23.139
- 2979: Solved by IANA-registration. No RFC needed
- 2980: CP#58 completed / Impacted TSs and TRs: Stage 3
- 2981: CP#56 completed. Identify additional FMC specific procedurES in CP-150addition to those in 24.302 (on access authentication & authorization and tunnel management; IP mobility mode selection; security aspects) / Impacted TSs and TRs: new TR 24.820
- 2982: CP#56 completed / Impacted TSs and TRs: new TR 29.839
- 2983: Draft removed from 3GPP documentation / Impacted TSs and TRs: draft-so-ipsecme-ikev2-cpext
- 2984: CP#57 completed / Impacted TSs and TRs: 24.229, new TS 24.139
- 2985: CP#57 completed / Impacted TSs and TRs: 29.212, 29.213, 29.215
- 2986: CP#58 completed / Impacted TSs and TRs: 23.008, 29.273, 29.274, new TS 29.139
- 2987: SP#53 completed. 22/01: acronym modified / Impacted TSs and TRs: 22.278
- 2988: SP#56 completed. 22/01: acronym modified / Impacted TSs and TRs: 23.203, 23.401, 23.402, 23.139

| ID | WBS | Task | Duration | Start | Finish | Complete | Baseline start | Baseline finish | Baseline duration | Constraint | Resources | Work | Actual work | Acronym | PCG approved | Impacted TSs and TRs | WI rapporteur name | WI rapporteur e-mail | Release | TSG approved | MCC resp | Special Focus Doc | Acronym_3GU_Export | PCG stopped | TSG stopped |
| --- | --- | --- | --- | --- | --- | --- | --- | --- | --- | --- | --- | --- | --- | --- | --- | --- | --- | --- | --- | --- | --- | --- | --- | --- | --- |
| 2989 | 806.8 | **Stage 3 BB II - Core Network impacts: BBF interworking with offload in access network for WLAN and for H(e)NB** | 259d? | 2011-09-16 A | 2012-09-07 A | 100% | 2011-09-16 | 2012-09-07 | 259d? |  | C3; C1; C4 | 12888h | 12888h | BBAI_BBII-CT | 27 | Stage 3 | Ericsson | Susana.Fernandez@ericsson.com | Rel-11 | 53 | Adrian | HNB, WLAN | BBAI_BBII-CT |  |  |
| 2990 | 806.8.1 | TR on Stage 3 BB II for 3GPP System to Fixed Broadband Access Network Interworking; UE to network protocols | 198d? | 2011-09-16 A | 2012-06-15 A | 100% | 2011-09-16 | 2012-06-15 | 198d? | finish no earlier than 2012-06-15 | C1 | 1576h | 1576h | BBAI_BBII-CT | 27 | 24.820 | Ericsson | Susana.Fernandez@ericsson.com | Rel-11 | 53 | Frederic | HNB, WLAN |  |  |  |
| 2991 | 806.8.2 | CT1 part of Stage 3 BB II: BBF interworking with offload in access network for WLAN and for H(e)NB | 259d? | 2011-09-16 A | 2012-09-07 A | 100% | 2011-09-16 | 2012-09-07 | 259d? | finish no earlier than 2012-09-07 | C1 | 2064h | 2064h | BBAI_BBII-CT | 27 | new TS 24.320 | Ericsson | Susana.Fernandez@ericsson.com | Rel-11 | 53 | Frederic | HNB, WLAN |  |  |  |
| 2992 | 806.8.3 | CT3 part of Stage 3 BB II: BBF interworking with offload in access network for WLAN and for H(e)NB | 259d? | 2011-09-16 A | 2012-09-07 A | 100% | 2011-09-16 | 2012-09-07 | 259d? | start no earlier than 2011-09-16 | C3 | 2056h | 2056h | BBAI_BBII-CT | 27 | 29.212, 29.213, 29.215 | Ericsson | Susana.Fernandez@ericsson.com | Rel-11 | 53 | Adrian | HNB, WLAN |  |  |  |
| 2993 | 806.8.4 | CT4 part of Stage 3 BB II: BBF interworking with offload in access network for WLAN and for H(e)NB | 122d? | 2011-09-16 A | 2012-03-02 A | 100% | 2011-09-16 | 2012-03-02 | 122d? | start no earlier than 2011-09-16 | C4 | 976h | 976h | BBAI_BBII-CT | 27 | 23.008, 29.273 | Ericsson | Susana.Fernandez@ericsson.com | Rel-11 | 53 | Kimmo | HNB, WLAN |  |  |  |
| 2994 | 806.9 | Deleted - Stage 1 BB III: BBF convergence and network based mobility | 262d? | 2010-09-23 A | 2011-09-21 A | 100% | 2010-09-23 | 2011-09-21 | 262d? | finish no earlier than 2011-09-21 | S1 | 2080h | 2080h |  | 25 | 22.278 | Huawei | Amar Deol (adeol@huawei.com) | Rel-11 | 49 | Alain | HNB, WLAN |  | PCG-29 | SP-57 |
| 2995 | 806.10 | Deleted - Stage 2 BB III: BBF convergence and network based mobility | 380d? | 2010-09-28 A | 2012-03-07 A | 100% | 2010-09-28 | 2012-03-07 | 380d? | finish no earlier than 2012-03-07 | S2 | 3040h | 3040h |  | 24 | 23.203, 23.401, 23.402, 23.139 | Huawei | marco.spini@huawei.com | Rel-11 | 47 | Maurice | HNB, WLAN |  | PCG-28 | SP-55 |
| 2996 | 806.11 | **Deleted - Stage 3 BB III - Core Network impacts: BBF convergence and network based mobility** | 122d? | 2011-09-16 A | 2012-03-02 A | 100% | 2011-09-16 | 2012-03-02 | 122d? |  | C3; C1; C4 | 6832h | 6832h |  | 27 | Stage 3 | Huawei | qiaoweihua@huawei.com | Rel-11 | 53 | Adrian | HNB, WLAN | BBAI_BBIII-CT | PCG-28 | CP-55 |
| 2997 | 806.11.1 | Deleted - TR on Stage 3 BB III for 3GPP System to Fixed Broadband Access Network Interworking; UE to network protocols | 122d? | 2011-09-16 A | 2012-03-02 A | 100% | 2011-09-16 | 2012-03-02 | 122d? | start no earlier than 2011-09-16 | C1 | 976h | 976h |  | 27 | new TR 24.820 | Huawei | qiaoweihua@huawei.com | Rel-11 | 53 | Frederic | HNB, WLAN |  | PCG-28 | CP-55 |
| 2998 | 806.11.2 | Deleted - CT1 part of Stage 3 BB III: BBF convergence and network based mobility | 122d? | 2011-09-16 A | 2012-03-02 A | 100% | 2011-09-16 | 2012-03-02 | 122d? | start no earlier than 2011-09-16 | C1 | 976h | 976h |  | 27 | TBD | Huawei | qiaoweihua@huawei.com | Rel-11 | 53 | Frederic | HNB, WLAN |  | PCG-28 | CP-55 |
| 2999 | 806.11.3 | Deleted - CT3 part of Stage 3 BB III: BBF convergence and network based mobility | 122d? | 2011-09-16 A | 2012-03-02 A | 100% | 2011-09-16 | 2012-03-02 | 122d? | start no earlier than 2011-09-16 | C3 | 976h | 976h |  | 27 | 29.212, 29.213, 29.215 | Huawei | qiaoweihua@huawei.com | Rel-11 | 53 | Adrian | HNB, WLAN |  | PCG-28 | CP-55 |
| 3000 | 806.11.4 | Deleted - CT4 part of Stage 3 BB III: BBF convergence and network based mobility | 122d? | 2011-09-16 A | 2012-03-02 A | 100% | 2011-09-16 | 2012-03-02 | 122d? | start no earlier than 2011-09-16 | C4 | 976h | 976h |  | 27 | 23.008, 29.273 | Huawei | qiaoweihua@huawei.com | Rel-11 | 53 | Kimmo | HNB, WLAN |  | PCG-28 | CP-55 |
| 3001 | 807 | **Single Radio Voice Call Continuity (SRVCC) aspect of enhancements for Multimedia Priority Service** | 398d? | 2010-06-10 A | 2011-12-14 A | 100% | 2010-06-10 | 2011-12-14 | 398d? |  | S2 | 8432h | 8432h | eMPS_SRVCC | 25 | Stage 2 | NTT DoCoMo | Atsushi Minokuchi (minokuchi@nttdocomo.co.jp) | Rel-11 | 48 | Maurice | Public Safety (I-A) | eMPS_SRVCC |  |  |
| 3002 | 807.1 | TR on SRVCC for eMPS | 260d? | 2010-06-10 A | 2011-06-08 A | 100% | 2010-06-10 | 2011-06-08 | 260d? | finish no earlier than 2011-06-08 | S2 | 2080h | 2080h | eMPS_SRVCC | 25 | new TR 23.854 | NTT DoCoMo | Atsushi Minokuchi (minokuchi@nttdocomo.co.jp) | Rel-11 | 48 | Maurice | Public Safety (I-A) |  |  |  |
| 3003 | 807.2 | Stage 2 on SRVCC for eMPS | 398d? | 2010-06-10 A | 2011-12-14 A | 100% | 2010-06-10 | 2011-12-14 | 398d? | finish no earlier than 2011-12-14 | S2 | 3168h | 3168h | eMPS_SRVCC | 25 | 23.216, 23.237 | NTT DoCoMo | Atsushi Minokuchi (minokuchi@nttdocomo.co.jp) | Rel-11 | 48 | Maurice | Public Safety (I-A) |  |  |  |
| 3004 | 808 | **Single Radio Video Call Continuity for 3G-CS** | 440d? | 2010-10-15 A | 2012-06-15 A | 100% | 2010-10-15 | 2012-06-15 | 440d? |  | S2; C1; C3; C4 | 26572.4h | 26572.4h | vSRVCC | 26 |  | Samsung | xiaowan.ke@samsung.com | Rel-11 | 50 | Maurice |  | vSRVCC |  |  |
| 3005 | 808.1 | Stage 2 for Single Radio Video Call Continuity for 3G-CS | 199.85d? | 2010-10-15 A | 2011-09-21 A | 100% | 2010-10-15 | 2011-09-21 | 199.85d? | finish no earlier than 2011-12-07 | S2 | 1580.41h | 1580.41h | vSRVCC | 26 | 23.203, 23.216, 23.237 | Samsung | xiaowan.ke@samsung.com | Rel-11 | 50 | Maurice |  |  |  |  |
| 3006 | 808.2 | **CN aspects of Single Radio Video Call Continuity for 3G-CS** | 275d? | 2011-06-03 A | 2012-06-15 A | 100% | 2011-06-03 | 2012-06-15 | 275d? |  | C1; C3; C4 | 10912h | 10912h | vSRVCC-CT | 27 |  | NEC | gottfried.punz@neclab.eu | Rel-11 | 52 | Frederic |  | vSRVCC-CT |  |  |
| 3007 | 808.2.1 | CT1 aspects of Single Radio Video Call Continuity for 3G-CS | 275d? | 2011-06-03 A | 2012-06-15 A | 100% | 2011-06-03 | 2012-06-15 | 275d? | finish no earlier than 2012-06-15 | C1 | 2184h | 2184h | vSRVCC-CT | 27 | 24.008, 24.237, 24.301 | NEC | gottfried.punz@neclab.eu | Rel-11 | 52 | Frederic |  |  |  |  |
| 3008 | 808.2.2 | CT3 aspects of Single Radio Video Call Continuity for 3G-CS | 134d? | 2011-06-03 A | 2011-12-02 A | 100% | 2011-06-03 | 2011-12-02 | 134d? | finish no earlier than 2011-12-02 | C3 | 1064h | 1064h | vSRVCC-CT | 27 | 29.211, 29.212, 29.213, 29.215 | NEC | gottfried.punz@neclab.eu | Rel-11 | 52 | Adrian |  |  |  |  |
| 3009 | 808.2.3 | CT4 aspects of Single Radio Video Call Continuity for 3G-CS | 134d? | 2011-06-03 A | 2011-12-02 A | 100% | 2011-06-03 | 2011-12-02 | 134d? | finish no earlier than 2011-12-02 | C4 | 1064h | 1064h | vSRVCC-CT | 27 | 29.280 | NEC | gottfried.punz@neclab.eu | Rel-11 | 52 | Kimmo |  |  |  |  |
| 3010 | 809 | **Network-provided Location information for IMS (NETLOC)** | 720d? | 2010-06-10 A | 2013-03-01 A | 100% | 2010-06-10 | 2013-03-01 | 720d? |  | S2; S1; S5; C3; C4; C1 | 57274.7h | 57274.7h | NWK-PL2IMS | 25 |  | T-Mobile | michele.zarri@t-mobile.co.uk | Rel-11 | 48 | Maurice |  | NWK-PL2IMS |  |  |
| 3011 | 809.1 | Stage 1 for Network-provided Location information for IMS | 203d? | 2010-12-15 A | 2011-09-21 A | 100% | 2010-12-15 | 2011-09-21 | 203d? | finish no earlier than 2011-09-21 | S1 | 1608h | 1608h | NWK-PL2IMS | 26 | 22.115 | n/a | n/a | Rel-11 | 50 | Alain |  |  |  |  |
| 3012 | 809.2 | TR on Stage 2 for Network-provided Location information for IMS | 395d? | 2010-06-10 A | 2011-12-14 A | 100% | 2010-06-10 | 2011-12-14 | 395d? | finish no earlier than 2011-12-06 | S2 | 3160h | 3160h | NWK-PL2IMS | 25 | new TR 23.842 | T-Mobile | michele.zarri@t-mobile.co.uk | Rel-11 | 48 | Maurice |  |  |  |  |
| 3013 | 809.3 | Stage 2 for Network-provided Location information for IMS | 455d? | 2010-06-15 A | 2012-03-07 A | 100% | 2010-06-15 | 2012-03-07 | 455d? | finish no earlier than 2012-03-07 | S2 | 3640h | 3640h | NWK-PL2IMS | 25 | 23.060, 23.203, 23.228, 23.401 | T-Mobile | michele.zarri@t-mobile.co.uk | Rel-11 | 48 | Maurice |  |  |  |  |
| 3014 | 809.4 | Charging for Network-provided Location information for IMS | 515d? | 2010-09-23 A | 2012-09-12 A | 100% | 2010-09-23 | 2012-09-12 | 515d? | finish no earlier than 2012-09-12 | S5 | 4120h | 4120h | NWK-PL2IMS_CH | 25 | Stage 2 (32.240, 32.260), Stage 3 (32.298, 32.299) | Nokia Siemens Networks | Gerald.Goermer@nsn.com | Rel-11 | 49 | Mirko |  | NWK-PL2IMS_CH |  |  |

Notes:
- 2989: CP#57 completed
- 2990: CP#56 completed
- 2991: CP#57 completed
- 2992: CP#57 completed
- 2993: CP#55 completed
- 2994: SP#57 stopped. Updated WID SP-120419=>SP-120539 (removed BB3 objectives not implemented in Stage 2). SP#53 completed
- 2995: SP#57 updated WID SP-120419=>SP-120539 (removed BB3 objectives not implemented in Stage 2). SP#55 stopped
- 2996: CP#55 stopped
- 2997: CP#55 stopped
- 2998: CP#55 stopped
- 2999: CP#55 stopped
- 3000: CP#55 stopped
- 3001: SP#54 completed. Analyze and if needed specify mechanisms for the priority handling of SRVCC with regard to LTE/EPC
- 3002: SP#52 completed
- 3003: SP#54 completed
- 3004: CP#56 completed. Provide Single Radio VIDEO Call Continuity from E-UTRAN to UTRAN-CS based on the agreed architecture alternative in TR 23.886
- 3005: SP#53 completed. Triggered by Feasibility Study on video call handover capability in TR 23.886 UID_470048 Study on Single Radio Video Call Continuity for 3G-CS (FS_vSRVCC)
- 3006: Stage 3. CP#56 completed
- 3007: CP#56 completed
- 3008: CP#54 completed
- 3009: CP#54 completed
- 3010: Covers the case where UE is served by a 3GPP RAN. Architecture making Cell/PLMN ID (UE is camped on) available to IMS nodes when the operator needs to record this information either to fulfil legal obligations or for charging.
- 3011: SP#53 completed
- 3012: SP#54 completed
- 3013: SP#55 completed
- 3014: SP#57 completed

| ID | WBS | Task | Type | Duration | Start | Finish | Complete | Baseline start | Baseline finish | Baseline duration | Constraint | Resources | Work | Actual work | Acronym | PCG approved | WI rapporteur name | WI rapporteur e-mail | Release | TSG approved | MCC resp | Acronym_3GU_Export | Special Focus Doc | PCG stopped | TSG stopped |
| --- | --- | --- | --- | --- | --- | --- | --- | --- | --- | --- | --- | --- | --- | --- | --- | --- | --- | --- | --- | --- | --- | --- | --- | --- | --- |
| 3015 | 809.5 | **CT aspects of Network-provided Location information for IMS (Stage 3)** |  | 266d? | 2012-03-02 A | 2013-03-01 A | 100% | 2012-03-02 | 2013-03-01 | 266d? |  | C3; C4; C1 | 10186.7h | 10186.7h | NWK-PL2IMS-CT | 28 | Huawei | Qiao Weihua (qiaoweihua@huawei.com) | Rel-11 | 55 | Adrian | NWK-PL2IMS_CT |  |  |  |
| 3016 | 809.5.1 | CT3 part of CT aspects of Network-provided Location information for IMS |  | 138d? | 2012-03-02 A | 2012-09-07 A | 100% | 2012-03-02 | 2012-09-07 | 138d? | finish no earlier than 2012-09-07 | C3 | 1088h | 1088h | NWK-PL2IMS-CT | 28 | Huawei | Qiao Weihua (qiaoweihua@huawei.com) | Rel-11 | 55 | Adrian |  |  |  |  |
| 3017 | 809.5.2 | CT4 part of CT aspects of Network-provided Location information for IMS |  | 77d? | 2012-03-02 A | 2012-06-15 A | 100% | 2012-03-02 | 2012-06-15 | 77d? | finish no earlier than 2012-06-01 | C4 | 608h | 608h | NWK-PL2IMS-CT | 28 | Huawei | Qiao Weihua (qiaoweihua@huawei.com) | Rel-11 | 55 | Kimmo |  |  |  |  |
| 3018 | 809.5.3 | CT1 part of CT aspects of Network-provided Location information for IMS |  | 266d? | 2012-03-02 A | 2013-03-01 A | 100% | 2012-03-02 | 2013-03-01 | 266d? | finish no earlier than 2013-06-14 | C1 | 2106.67h | 2106.67h | NWK-PL2IMS-CT | 28 | Huawei | Qiao Weihua (qiaoweihua@huawei.com) | Rel-11 | 55 | Frederic |  |  |  |  |
| 3019 | 810 | **Service Awareness and Privacy Policies** |  | 301.15d? | 2010-10-12 A | 2011-12-02 A | 100% | 2010-10-12 | 2011-12-02 | 301.15d? |  | S2; S1; C3 | 10667.6h | 10667.6h | SAPP | 26 | Allot | Alla Goldner (agoldner@allot.com) | Rel-11 | 50 | Maurice | SAPP |  |  |  |
| 3020 | 810.1 | Stage 1 for Service Awareness and Privacy Policies |  | 46.15d? | 2010-10-12 A | 2010-12-15 A | 100% | 2010-10-12 | 2010-12-15 | 46.15d? | finish no earlier than 2010-12-15 | S1 | 369.2h | 369.2h | SAPP | 26 | Allot | Alla Goldner (agoldner@allot.com) | Rel-11 | 50 | Maurice |  |  |  |  |
| 3021 | 810.2 | Stage 2 for Service Awareness and Privacy Policies |  | 199.85d? | 2010-10-15 A | 2011-09-21 A | 100% | 2010-10-15 | 2011-09-21 | 199.85d? | finish no earlier than 2011-09-21 | S2 | 1582.8h | 1582.8h | SAPP | 26 | Allot | Alla Goldner (agoldner@allot.com) | Rel-11 | 50 | Maurice |  |  |  |  |
| 3022 | 810.3 | CT3 part of Service Awareness and Privacy Policies |  | 187d? | 2011-03-18 A | 2011-12-02 A | 100% | 2011-03-18 | 2011-12-02 | 187d? | finish no earlier than 2011-12-02 | C3 | 1488h | 1488h | SAPP-CT3 | 26 | Allot | Alla Goldner (agoldner@allot.com) | Rel-11 | 51 | Adrian | SAPP-CT3 |  |  |  |
| 3023 | 811 | **VPLMN Autonomous CSG Roaming** |  | 307d? | 2010-10-15 A | 2011-12-14 A | 100% | 2010-10-15 | 2011-12-14 | 307d? |  | S2; C4 | 6974.61h | 6974.61h | VCSG | 26 | Qualcomm | AC Mahendran (ac@qualcomm.com) | Rel-11 | 50 | Maurice | VCSG |  |  |  |
| 3024 | 811.1 | Stage 2 for VPLMN Autonomous CSG Roaming |  | 260.85d? | 2010-10-15 A | 2011-12-14 A | 100% | 2010-10-15 | 2011-12-14 | 260.85d? | finish no earlier than 2011-12-07 | S2 | 2062.61h | 2062.61h | VCSG | 26 | Qualcomm | AC Mahendran (ac@qualcomm.com) | Rel-11 | 50 | Maurice |  |  |  |  |
| 3025 | 811.2 | CT aspects of VPLMN Autonomous CSG Roaming | milestone | 0d? | 2011-12-07 A | 2011-12-07 A | 100% | 2011-12-07 | 2011-12-07 | 0d? | finish no earlier than 2012-09-07 | C4 |  |  | VCSG-St3 | 27 | ZTE | Fei Lu (lu.fei1@zte.com.cn) | Rel-11 | 53 | Kimmo | VCSG-St3 |  |  |  |
| 3026 | 812 | **Data Identification in Access Network Discovery and Selection Function (ANDSF)** |  | 455d? | 2011-03-23 A | 2012-12-07 A | 100% | 2011-03-23 | 2012-12-07 | 455d? |  | S2; C1 | 12488h | 12488h | DIDA | 26 | Qualcomm | Gerardo Giaretta (gerardo@qualcomm.com) | Rel-11 | 51 | Maurice | DIDA |  |  |  |
| 3027 | 812.1 | TR on Stage 2 for Data Identification in ANDSF |  | 193d? | 2011-03-23 A | 2011-12-14 A | 100% | 2011-03-23 | 2011-12-14 | 193d? | finish no earlier than 2011-12-07 | S2 | 1544h | 1544h | DIDA | 26 | Qualcomm | Gerardo Giaretta (gerardo@qualcomm.com) | Rel-11 | 51 | Maurice |  |  |  |  |
| 3028 | 812.2 | Stage 2 for Data Identification in ANDSF |  | 253d? | 2011-03-24 A | 2012-03-07 A | 100% | 2011-03-24 | 2012-03-07 | 253d? | finish no earlier than 2012-03-07 | S2 | 2024h | 2024h | DIDA | 26 | Qualcomm | Gerardo Giaretta (gerardo@qualcomm.com) | Rel-11 | 51 | Maurice |  |  |  |  |
| 3029 | 812.3 | CT aspects of Data Identification in Access Network Discovery and Selection Function (ANDSF) Stage 3 |  | 205d? | 2012-03-02 A | 2012-12-07 A | 100% | 2012-03-02 | 2012-12-07 | 205d? | finish no earlier than 2012-12-07 | C1 | 1640h | 1640h | DIDA-CT | 28 | Qualcomm | Patrick Stupar (pstupar@qualcomm.com) | Rel-11 | 55 | Frederic | DIDA-CT |  |  |  |
| 3030 | 813 | **LOcation-Based Selection of gaTEways foR WLAN** |  | 327d? | 2011-03-23 A | 2012-06-15 A | 100% | 2011-03-23 | 2012-06-15 | 327d? |  | S2; C4 | 10170.5h | 10170.5h | LOBSTER | 26 | ZTE | zhu.chunhui@zte.com.cn | Rel-11 | 51 | Maurice | LOBSTER | WLAN |  |  |
| 3031 | 813.1 | Stage 2 for LOcation-Based Selection of gaTEways foR WLAN |  | 194d? | 2011-03-23 A | 2011-12-14 A | 100% | 2011-03-23 | 2011-12-14 | 194d? | finish no earlier than 2011-12-07 | S2 | 1546.52h | 1546.52h | LOBSTER | 26 | ZTE | zhu.chunhui@zte.com.cn | Rel-11 | 51 | Maurice |  | WLAN |  |  |
| 3032 | 813.2 | **CT aspects of LOcation-Based Selection of gaTEways foR WLAN** |  | 142d? | 2011-12-02 A | 2012-06-15 A | 100% | 2011-12-02 | 2012-06-15 | 142d? |  | C4 | 3392h | 3392h | LOBSTER-CT | 28 | ZTE | zhou.xingyue@zte.com.cn | Rel-11 | 54 | Kimmo | LOBSTER-CT | WLAN |  |  |
| 3033 | 813.2.1 | CT4 part of CT aspects of LOcation-Based Selection of gaTEways foR WLAN |  | 142d? | 2011-12-02 A | 2012-06-15 A | 100% | 2011-12-02 | 2012-06-15 | 142d? | finish no earlier than 2012-06-15 | C4 | 1128h | 1128h | LOBSTER-CT | 28 | ZTE | zhou.xingyue@zte.com.cn | Rel-11 | 54 | Kimmo |  | WLAN |  |  |
| 3034 | 813.2.2 | Deleted - CT1 part of CT aspects of LOcation-Based Selection of gaTEways foR WLAN |  | 142d? | 2011-12-02 A | 2012-06-15 A | 100% | 2011-12-02 | 2012-06-15 | 142d? | finish no earlier than 2012-06-15 | C1 | 1128h | 1128h | LOBSTER-CT | 28 | ZTE | zhou.xingyue@zte.com.cn | Rel-11 | 54 | Frederic |  | WLAN | PCG-29 | CP-56 |
| 3035 | 814 | **Single Radio Voice Call Continuity from UTRAN/GERAN to E-UTRAN/HSPA** |  | 929d? | 2011-09-12 A | 2015-03-15 A | 100% | 2011-09-12 | 2014-12-05 | 856d? |  | S2; C1; C3; C4; G2; R2; R3; R5 | 83776.8h | 83776.8h | rSRVCC | 27 | Orange | antoine.mouquet@orange-ftgroup.com | Rel-11 | 53 | Maurice | rSRVCC |  |  |  |
| 3036 | 814.1 | Stage 2 for Single Radio Voice Call Continuity from UTRAN/GERAN to E-UTRAN/HSPA |  | 197d? | 2011-09-22 A | 2012-06-20 A | 100% | 2011-09-22 | 2012-06-20 | 197d? | finish no earlier than 2012-06-20 | S2 | 1568h | 1568h | rSRVCC | 27 | Orange | antoine.mouquet@orange-ftgroup.com | Rel-11 | 53 | Maurice |  |  |  |  |
| 3037 | 814.2 | **CT aspects for Single Radio Voice Call Continuity from UTRAN/GERAN to E-UTRAN/HSPA (Stage 3)** |  | 259d? | 2011-09-16 A | 2012-09-07 A | 100% | 2011-09-16 | 2012-09-07 | 259d? |  | C1; C3; C4 | 12360h | 12360h | rSRVCC-CT | 27 | Ericsson | ivo.sedlacek@ericsson.com | Rel-11 | 53 | Frederic | rSRVCC-CT |  |  |  |
| 3038 | 814.2.1 | CT1 part for Single Radio Voice Call Continuity from UTRAN/GERAN to E-UTRAN/HSPA |  | 258d? | 2011-09-16 A | 2012-09-07 A | 100% | 2011-09-16 | 2012-09-07 | 258d? | finish no earlier than 2012-09-07 | C1 | 2048h | 2048h | rSRVCC-CT | 27 | Ericsson | ivo.sedlacek@ericsson.com | Rel-11 | 53 | Frederic |  |  |  |  |
| 3039 | 814.2.2 | CT3 part for Single Radio Voice Call Continuity from UTRAN/GERAN to E-UTRAN/HSPA |  | 257d? | 2011-09-19 A | 2012-09-07 A | 100% | 2011-09-19 | 2012-09-07 | 257d? | finish no earlier than 2012-09-07 | C3 | 2048h | 2048h | rSRVCC-CT | 27 | Ericsson | ivo.sedlacek@ericsson.com | Rel-11 | 53 | Adrian |  |  |  |  |
| 3040 | 814.2.3 | CT4 part for Single Radio Voice Call Continuity from UTRAN/GERAN to E-UTRAN/HSPA |  | 257d? | 2011-09-19 A | 2012-09-07 A | 100% | 2011-09-19 | 2012-09-07 | 257d? | finish no earlier than 2012-09-07 | C4 | 2048h | 2048h | rSRVCC-CT | 27 | Ericsson | ivo.sedlacek@ericsson.com | Rel-11 | 53 | Kimmo |  |  |  |  |
| 3041 | 814.3 | GERAN aspects of Single Radio Voice Call Continuity from UTRAN/GERAN to E-UTRAN/HSPA (Stage 3) |  | 476.1d? | 2011-09-12 A | 2013-06-28 A | 100% | 2011-09-12 | 2013-06-28 | 476.1d? | finish no earlier than 2013-11-22 | G2 | 2048h | 2048h | rSRVCC-GERAN | 27 | ZTE | li.jing4@zte.com.cn | Rel-11 | 51 | Gert | rSRVCC-GERAN |  |  |  |

Notes:
- 3015: Stage 3. 3/3: Acronym changed from "NWK-PL2IMS_CT"
- 3016: CP#57 completed. 3/3: Acronym changed from "NWK-PL2IMS_CT" / Impacted TSs and TRs: 29.212, 29.214, 29.215
- 3017: CP#57 completed. 3/3: Acronym changed from "NWK-PL2IMS_CT" / Impacted TSs and TRs: 23.008, 29.002, 29.060, 29.230, 29.272, 29.274, 29.305, 29.328, 29.329
- 3018: CP#57 completed. 3/3: Acronym changed from "NWK-PL2IMS_CT" / Impacted TSs and TRs: 24.229, 24.292
- 3019: CP#54 completed. Triggered by the SA1,SA2 Rel-10 TR 23.813 Study on Policy solutions and enhancements (FS_PP) UID_440047
- 3020: For deep packet inspection (i.e. Traffic Detection Functionality) SA1 indicated that no new requirements are needed (see Objective of FS_PP SA1,SA2 Rel-10 Study on Policy solutions and enhancements UID_440047 TR 23.813)
- 3021: SP#53 completed / Impacted TSs and TRs: 23.203
- 3022: CP#54 completed. Stage 3 to support Application Detection and Control Functionality. Update Gx / introduce Sd reference points and procedures. Update S9 reference point in roaming scenarios / Impacted TSs and TRs: 29.212, 29.213, 29.214, 29.215
- 3023: CP#56 completed. Linked to Rel-10 UID_450053 Enhanced Home NodeB / eNodeB (EHNB). Implements Rel-9 requirements for CSG support in SA1 TS 22.220
- 3024: SP#54 completed / Impacted TSs and TRs: 23.002, 23.060, 23.401
- 3025: CP#57 completed / Impacted TSs and TRs: 23.003, 23.007, 23.008, 23.012, 29.002, 29.230, 29.272
- 3026: SP#58 completed. Linked to Rel-10 IFOM (IP Flow Mobility and seamless WLAN offload) UID_450041. Defines IP flow mobility, seamless and non seamless WLAN offload and respective ANDSF extensions / Impacted TSs and TRs: Stage 2/3
- 3027: SP#54 completed / Impacted TSs and TRs: New TR 23.855
- 3028: SP#55 completed / Impacted TSs and TRs: 23.402
- 3029: CP#58 completed / Impacted TSs and TRs: 24.302, 24.312
- 3030: CP#56 completed. Related to UID_350027 SAE for support for non-3GPP accesses (SAES-SA-FP_n3GPP). Enhancements to ePDG and PDN GW selection functions for S2b and S2c based on UE location
- 3031: SP#54 completed / Impacted TSs and TRs: 23.402
- 3032: Stage 3. CP#56 completed / Impacted TSs and TRs: Stage 3
- 3033: CP#56 completed / Impacted TSs and TRs: 29.273
- 3034: CP#56 stopped / Impacted TSs and TRs: 24.302
- 3035: Stage 1 in Rel-8 TS 22.278 clause 7.1.4.2. Triggered by Rel-11 TR 23.885 Study on Single Radio Voice Call Continuity from UTRAN/GERAN to E-UTRAN/HSPA (FS_rSRVCC) UID_460030
- 3036: SP#56 completed / Impacted TSs and TRs: 23.216, 23.237
- 3037: CP#57 completed / Impacted TSs and TRs: Stage 3
- 3038: CP#57 completed / Impacted TSs and TRs: 23.009, 24.008, 24.229, 24.237, 24.292, 24.301
- 3039: CP#57 completed / Impacted TSs and TRs: 29.165, 29.292
- 3040: CP#57 completed / Impacted TSs and TRs: 23.003, 23.008, 29.002, 29.230, 29.272, 29.280, 29.303, 29.305, 29.328
- 3041: GP#60 completed. GP#51 approved WID / Impacted TSs and TRs: 44.018, 48.008

| ID | WBS | Task | Duration | Start | Finish | Complete | Baseline start | Baseline finish | Baseline duration | Constraint | Resources | Work | Actual work | Acronym | PCG approved | Impacted TSs and TRs | WI rapporteur name | Release | TSG approved | MCC resp | Acronym_3GU_Export | Status Report | Special Focus Doc | PCG stopped | TSG stopped |
| --- | --- | --- | --- | --- | --- | --- | --- | --- | --- | --- | --- | --- | --- | --- | --- | --- | --- | --- | --- | --- | --- | --- | --- | --- | --- |
| 3042 | 814.4 | **UTRAN aspects of Single Radio Voice Call Continuity from UTRAN/GERAN to E-UTRAN/HSPA** | 325d? | 2011-09-19 A | 2012-12-07 A | 100% | 2011-09-19 | 2012-12-07 | 325d? |  | R3; R2 | 10400h | 10400h | rSRVCC-RAN_UTRA | 27 | UTRA | Huawei | Rel-11 | 53 | Juha | rSRVCC-RAN_UTRA |  |  |  |  |
| 3043 | 814.4.1 | Core part: UTRAN aspects of Single Radio Voice Call Continuity from UTRAN/GERAN to E-UTRAN/HSPA | 325d? | 2011-09-19 A | 2012-12-07 A | 100% | 2011-09-19 | 2012-12-07 | 325d? | finish no earlier than 2012-12-07 | R3; R2 | 5200h | 5200h | rSRVCC-RAN_UTRA-Core | 27 | 25.331, 25.401, 25.413 | Huawei | Rel-11 | 53 | Juha | rSRVCC-RAN_UTRA-Core | RP-121553 |  |  |  |
| 3044 | 814.5 | Test part: Single Radio Voice Call Continuity from UTRAN/GERAN to E-UTRAN/HSPA | 196d? | 2014-06-15 A | 2015-03-15 A | 100% | 2014-06-13 | 2014-12-05 | 126d? | finish no earlier than 2015-03-15 | R5 | 1568h | 1568h | rSRVCC-UEConTest | 33 | 36.508, 36.523-1, 36.523-2, 36.523-3 | Ericsson | Rel-11 | 64 |  | rSRVCC-UEConTest | RP-150133 |  |  |  |
| 3045 | 815 | **S2a Mobility based On GTP and WLAN access to EPC** | 651d? | 2011-09-22 A | 2014-03-05 A | 100% | 2011-09-22 | 2014-03-05 | 651d? |  | S2; C4; C1; C3; IETF | 54000h | 54000h | SaMOG_WLAN | 27 | Stage 2/3 | ZTE | Rel-11 | 53 | Maurice | SaMOG_WLAN |  | WLAN |  |  |
| 3046 | 815.1 | Stage 2 for S2a Mobility based On GTP and WLAN access to EPC | 121d? | 2011-09-22 A | 2012-03-07 A | 100% | 2011-09-22 | 2012-03-07 | 121d? | finish no earlier than 2012-03-07 | S2 | 968h | 968h | SaMOG_WLAN | 27 | 23.002, 23.203, 23.402 | ZTE | Rel-11 | 53 | Maurice |  |  | WLAN |  |  |
| 3047 | 815.2 | **CN aspects of Mobility based On GTP & PMIPv6 for WLAN access to EPC** | 599d? | 2011-12-02 A | 2014-03-05 A | 100% | 2011-12-02 | 2014-03-05 | 599d? |  | C4; C1; C3; IETF | 26992h | 26992h | SaMOG_WLAN-CN | 28 | Stage 3 | Alcatel-Lucent | Rel-11 | 54 | Kimmo | SaMOG_WLAN-CN |  | WLAN |  |  |
| 3048 | 815.2.1 | CT4 part of CN aspects of Mobility based On GTP & PMIPv6 for WLAN access to EPC | 203d? | 2011-12-02 A | 2012-09-07 A | 100% | 2011-12-02 | 2012-09-07 | 203d? | finish no earlier than 2012-09-07 | C4 | 1608h | 1608h | SaMOG_WLAN-CN | 28 | 23.003, 23.007, 23.008, 29.273, 29.274, 29.281, 29.303 | Alcatel-Lucent | Rel-11 | 54 | Kimmo |  |  | WLAN |  |  |
| 3049 | 815.2.2 | Deleted - (IETF) CT4 part of CN aspects of Mobility based On GTP & PMIPv6 for WLAN access to EPC | 498d? | 2012-04-23 A | 2014-03-05 A | 100% | 2012-04-23 | 2014-03-05 | 498d? | finish no earlier than 2014-03-05 | C4-IETF | 3960h | 3960h | SaMOG_WLAN-CN | 29 | draft-ietf-radext-ieee802ext | Lionel Morand | Rel-11 | 56 | Kimmo |  |  | WLAN | PCG-32 | CP-53 |
| 3050 | 815.2.3 | Deleted - CT1 part of CN aspects of Mobility based On GTP & PMIPv6 for WLAN access to EPC | 142d? | 2011-12-02 A | 2012-06-15 A | 100% | 2011-12-02 | 2012-06-15 | 142d? | finish no earlier than 2012-06-15 | C1 | 1128h | 1128h | SaMOG_WLAN-CN | 28 | 24.302 | Alcatel-Lucent | Rel-11 | 54 | Frederic |  |  | WLAN | PCG-29 | CP-56 |
| 3051 | 815.2.4 | CT3 part of CN aspects of Mobility based On GTP & PMIPv6 for WLAN access to EPC | 142d? | 2011-12-02 A | 2012-06-15 A | 100% | 2011-12-02 | 2012-06-15 | 142d? | finish no earlier than 2012-09-07 | C3 | 1128h | 1128h | SaMOG_WLAN-CN | 28 | 29.212, 29.213, 29.215 | Alcatel-Lucent | Rel-11 | 54 | Adrian |  |  | WLAN |  |  |
| 3052 | 816 | **Roaming Architecture for Voice over IMS with Local Breakout** | 273d? | 2011-11-28 A | 2012-12-07 A | 100% | 2011-11-28 | 2012-12-07 | 273d? |  | S2; S5; C1; C3 | 16904h | 16904h | RAVEL | 28 | Stage 2/3 | Deutsche Telekom | Rel-11 | 54 | Maurice | RAVEL |  |  |  |  |
| 3053 | 816.1 | Stage 2 for Roaming Architecture for Voice over IMS with Local Breakout | 12d? | 2011-11-28 A | 2011-12-14 A | 100% | 2011-11-28 | 2011-12-14 | 12d? | finish no earlier than 2012-03-07 | S2 | 96h | 96h | RAVEL | 28 | 23.002, 23.228 | Deutsche Telekom | Rel-11 | 54 | Maurice |  |  |  |  |  |
| 3054 | 816.2 | Charging for Roaming Architecture for Voice over IMS with Local Breakout | 196d? | 2011-12-14 A | 2012-09-12 A | 100% | 2011-12-14 | 2012-09-12 | 196d? | finish no earlier than 2012-09-12 | S5 | 1568h | 1568h | RAVEL-CH | 28 | 32.240, 32.260, 32.298, 32.299 | Nokia Siemens Networks | Rel-11 | 54 | Mirko | RAVEL-CH |  |  |  |  |
| 3055 | 816.3 | **CT aspects of Roaming Architecture for Voice over IMS with Local Breakout (Stage 3)** | 205d? | 2012-03-02 A | 2012-12-07 A | 100% | 2012-03-02 | 2012-12-07 | 205d? |  | C1; C3 | 6504h | 6504h | RAVEL-CT | 28 | Stage 3 | Deutsche Telekom | Rel-11 | 55 | Frederic | RAVEL-CT |  |  |  |  |
| 3056 | 816.3.1 | CT1 part of CT aspects of Roaming Architecture for Voice over IMS with Local Breakout | 204d? | 2012-03-02 A | 2012-12-07 A | 100% | 2012-03-02 | 2012-12-07 | 204d? | finish no earlier than 2012-12-07 | C1 | 1608h | 1608h | RAVEL-CT | 28 | 24.229, 24.292, 24.237 | Deutsche Telekom | Rel-11 | 55 | Frederic |  |  |  |  |  |
| 3057 | 816.3.2 | CT3 part of CT aspects of Roaming Architecture for Voice over IMS with Local Breakout | 204d? | 2012-03-02 A | 2012-12-07 A | 100% | 2012-03-02 | 2012-12-07 | 204d? | finish no earlier than 2012-12-07 | C3 | 1616h | 1616h | RAVEL-CT | 28 | 29.165, 29.162, 29.079 | Deutsche Telekom | Rel-11 | 55 | Adrian |  |  |  |  |  |
| 3058 | 817 | **IMS Overload Control** | 659d? | 2012-06-18 A | 2014-12-09 A | 100% | 2012-06-18 | 2014-12-05 | 654d? |  | S2; C1; C3; IETF | 52408h | 52408h | IOC | 29 | Stage 2/3 | Orange, China Mobile | Rel-11 | 56 | Maurice | IOC |  |  |  |  |
| 3059 | 817.1 | Stage 2 for IMS Overload Control | 64d? | 2012-06-18 A | 2012-09-12 A | 100% | 2012-06-18 | 2012-09-12 | 64d? | finish no earlier than 2012-09-12 | S2 | 504h | 504h | IOC | 29 | 23.228 | Orange, China Mobile | Rel-11 | 56 | Maurice |  |  |  |  |  |
| 3060 | 817.2 | **Stage 3 for IMS Overload Control** | 601d? | 2012-09-05 A | 2014-12-09 A | 100% | 2012-09-05 | 2014-12-05 | 596d? |  | C1; C3; IETF | 30816h | 30816h | IOC | 29 |  | Alcatel-Lucent | Rel-11 | 57 | Frederic |  |  |  |  |  |
| 3061 | 817.2.1 | CT1 part of Stage 3 for IMS Overload Control | 70d? | 2012-09-05 A | 2012-12-07 A | 100% | 2012-09-05 | 2012-12-07 | 70d? | finish no earlier than 2012-12-07 | C1 | 544h | 544h | IOC | 29 | 24.229 | Alcatel-Lucent | Rel-11 | 57 | Frederic |  |  |  |  |  |
| 3062 | 817.2.2 | CT3 part of Stage 3 for IMS Overload Control | 70d? | 2012-09-05 A | 2012-12-07 A | 100% | 2012-09-05 | 2012-12-07 | 70d? | finish no earlier than 2012-12-07 | C3 | 552h | 552h | IOC | 29 | 29.165 | Alcatel-Lucent | Rel-11 | 57 | Adrian |  |  |  |  |  |
| 3063 | 817.2.3 | (IETF) CT part of Stage 3 for IMS Overload Control (soc-overload-control) | 361d? | 2013-07-29 A | 2014-12-09 A | 100% | 2013-07-29 | 2014-12-05 | 359d? | finish no earlier than 2014-12-09 | C1-IETF; C3-IETF | 5776h | 5776h | IOC | 29 | RFC 7339 | Keith Drage | Rel-11 | 57 | Frederic |  |  |  |  |  |
| 3064 | 817.2.4 | (IETF) CT part of Stage 3 for IMS Overload Control (soc-overload-rate-control) | 361d? | 2013-07-29 A | 2014-12-09 A | 100% | 2013-07-29 | 2014-12-05 | 359d? | finish no earlier than 2014-12-09 | C1-IETF; C3-IETF | 5776h | 5776h | IOC | 29 | RFC 7415 | Keith Drage | Rel-11 | 57 | Frederic |  |  |  |  |  |
| 3065 | 817.2.5 | (IETF) CT part of Stage 3 for IMS Overload Control (RFC 7200) | 234d? | 2013-07-29 A | 2014-06-13 A | 100% | 2013-07-29 | 2014-06-13 | 234d? | finish no earlier than 2014-06-13 | C1-IETF; C3-IETF | 3744h | 3744h | IOC | 29 | RFC 7200 (was draft-ietf-soc-load-control-event-package) | Keith Drage | Rel-11 | 57 | Frederic |  |  |  |  |  |
| 3066 | 818 | Rel-11 Security small Enhancements | 336d? | 2011-06-08 A | 2012-09-12 A | 100% | 2011-06-08 | 2012-09-12 | 336d? | finish no earlier than 2012-09-12 | S3 | 2680h | 2680h | SEC11 | 27 |  |  | Rel-11 | 52 | Mirko | SEC11 |  |  |  |  |
| 3067 | 819 | Lawful Interception in the 3GPP Rel-11 | 272d? | 2011-06-10 A | 2012-06-20 A | 100% | 2011-06-10 | 2012-06-20 | 272d? | finish no earlier than 2012-06-20 | S3 | 2176h | 2176h | LI11 | 27 | 33.106, 33.107, 33.108 | PIDS, Alcatel-Lucent | Rel-11 | 52 | Mirko | LI11 |  |  |  |  |

Notes:
- 3042: RP#58 completed / WI rapporteur e-mail: liwei.qiu@huawei.com
- 3043: RP#58 completed / WI rapporteur e-mail: liwei.qiu@huawei.com
- 3044: ; Stat Rep: RP-141167->RP-141771 1st Apr 15: Compl:40%->100% 1st Apr 15: Stat Rep: RP-141771->RP-150133 / WI rapporteur e-mail: calle.hagenfeldt@ericsson.com
- 3045: Triggered by Rel-11 TR 23.852 FS_SaMOG UID_510061, Rel-8 UID_350027 SAE for support for non-3GPP accesses (defines PMIP-S2a) / WI rapporteur e-mail: Chunhui Zhu (zhu.chunhui@zte.com.cn)
- 3046: SP#55 completed / WI rapporteur e-mail: zhu.chunhui@zte.com.cn
- 3047: - / WI rapporteur e-mail: bruno.landais@alcatel-lucent.com
- 3048: CP#57 completed / WI rapporteur e-mail: bruno.landais@alcatel-lucent.com
- 3049: CP#63 Draft removed from 3GPP documentation
- 3050: CP#56 stopped (no CT1 impact) / WI rapporteur e-mail: bruno.landais@alcatel-lucent.com
- 3051: CP#56 completed / WI rapporteur e-mail: bruno.landais@alcatel-lucent.com
- 3052: CP#58 completed. Triggered by Rel-11 TR 23.850 Study on Roaming Architecture for Voice over IMS with Local Breakout (FS_RAVEL). GSMA CPWP LS_in S5-102806 asked 3GPP SA5 to check if CS voice charging principles also apply to voice over IMS / WI rapporteur e-mail: michele.zarri@telekom.com
- 3053: SP#54 completed / WI rapporteur e-mail: michele.zarri@telekom.com
- 3054: Stage 2/3. SP#57 completed / WI rapporteur e-mail: Gerald.Goermer@nsn.com
- 3055: CP#58 completed / WI rapporteur e-mail: reinhard.lauster@)t-mobile.at
- 3056: CP#58 completed / WI rapporteur e-mail: reinhard.lauster@)t-mobile.at
- 3057: CP#58 completed / WI rapporteur e-mail: reinhard.lauster@)t-mobile.at
- 3058: SP#57 Stage 2 completed. Moved Rel-12=>Rel-11 as CT finished Stage 3. Linked to UID_410041 Study on IMS Evolution (TR 23.812). Solutions from IETF SOC WG and existing 3GPP procedures to be re-used if possible & backward compatibility ensured / WI rapporteur e-mail: Antoine MOUQUET, YU Qing
- 3059: SP#57 completed. Moved Rel-12=>Rel-11 as CT finished Stage 3. / WI rapporteur e-mail: antoine.mouquet@orange-ftgroup.com, YU Qing
- 3060: - / WI rapporteur e-mail: Keith Drage
- 3061: CP#58 completed / WI rapporteur e-mail: Keith Drage
- 3062: CP#58 completed / WI rapporteur e-mail: Keith Drage
- 3063: in RFC Ed-queue. Dec.14: 75->100. Mar15: impacted spec updated (was draft-ietf-soc-overload-control). Jun 15: RFC 7339 (was draft-ietf-soc-overload-control) / WI rapporteur e-mail: Keith Drage
- 3064: Submitted to IESG for publication. Dec14: 50->90%. Mar15: 100%. Impacted RFC updated (was draft-ietf-soc-overload-rate-control). Jun 15: RFC 7415 (was draft-ietf-soc-overload-rate-control) / WI rapporteur e-mail: Keith Drage
- 3065: CP#64 completed / WI rapporteur e-mail: Keith Drage
- 3066: SEC11 is an umbrella Feature for Security related TEI11 type of changes that are not part of any other dedicated feature
- 3067: Stage 1/2/3. SP#56 completed / WI rapporteur e-mail: Koen Jaspers (k.b.jaspers@minjus.nl), terry.jacobson@alcatel-lucent.com

| ID | WBS | Task | Duration | Start | Finish | Complete | Baseline start | Baseline finish | Baseline duration | Constraint | Resources | Work | Actual work | Acronym | PCG approved | WI rapporteur name | Release | TSG approved | MCC resp | Acronym_3GU_Export | Status Report | Special Focus Doc |
| --- | --- | --- | --- | --- | --- | --- | --- | --- | --- | --- | --- | --- | --- | --- | --- | --- | --- | --- | --- | --- | --- | --- |
| 3068 | 820 | **ZUC EEA3 and EIA3 (new Encryption & Integrity EPS security Algorithms)** | 857d? | 2009-06-04 A | 2012-09-07 A | 100% | 2009-06-04 | 2012-09-07 | 857d? |  | S3; R5 | 19488h | 19488h | EEA3_EIA3 | 23 | CATR | Rel-11 | 44 | Mirko | EEA3_EIA3 |  |  |
| 3069 | 820.1 | ZUC EEA3 and EIA3 | 663d? | 2009-06-04 A | 2011-12-14 A | 100% | 2009-06-04 | 2011-12-14 | 663d? | finish no earlier than 2011-09-21 | S3 | 5288h | 5288h | EEA3_EIA3 | 23 | CATR | Rel-11 | 44 | Mirko |  |  |  |
| 3070 | 820.2 | Conformance Test Aspects – ZUC (EEA3 and EIA3 Encryption & Integrity EPS security Algorithms) | 61d? | 2012-06-18 A | 2012-09-07 A | 100% | 2012-06-18 | 2012-09-07 | 61d? | finish no earlier than 2013-03-01 | R5 | 488h | 488h | EEA3_EIA3_UEConTest | 29 | CATR | Rel-11 | 56 | Ingbert | EEA3_EIA3_UEConTest | RP-120968 |  |
| 3071 | 821 | Specification of Protection against Unsolicited Communication for IMS (produced TR-only) | 456d? | 2010-06-10 A | 2012-03-07 A | 100% | 2010-06-10 | 2012-03-07 | 456d? | finish no earlier than 2012-03-07 | S3 | 3640h | 3640h | SPUCI | 25 | NEC | Rel-11 | 48 | Mirko | SPUCI |  |  |
| 3072 | 822 | H(e)NB security features for UE mobility scenarios (Stage 2) | 252d? | 2011-03-23 A | 2012-03-07 A | 100% | 2011-03-23 | 2012-03-07 | 252d? | finish no earlier than 2012-03-07 | S3 | 2008h | 2008h | HNB_mob_Sec | 26 | Huawei | Rel-11 | 51 | Mirko | HNB_mob_Sec |  | HNB |
| 3073 | 823 | **Generic Bootstrapping Architecture (GBA) extensions for re-use of SIP Digest credentials** | 203d? | 2011-12-02 A | 2012-09-07 A | 100% | 2011-12-02 | 2012-09-07 | 203d? |  | S3; C4; C1 | 11824h | 11824h | GBA-ext | 28 | Nokia | Rel-11 | 54 | Mirko | GBA-ext |  |  |
| 3074 | 823.1 | Stage 2 for GBA extensions for re-use of SIP Digest credentials | 61d? | 2011-12-14 A | 2012-03-07 A | 100% | 2011-12-14 | 2012-03-07 | 61d? | finish no earlier than 2012-02-28 | S3 | 488h | 488h | GBA-ext | 28 | Nokia | Rel-11 | 54 | Mirko |  |  |  |
| 3075 | 823.2 | **Stage 3 for GBA extensions for re-use of SIP Digest credentials** | 203d? | 2011-12-02 A | 2012-09-07 A | 100% | 2011-12-02 | 2012-09-07 | 203d? |  | C4; C1 | 6464h | 6464h | GBA-ext-St3 | 28 | Alcatel-Lucent | Rel-11 | 54 | Kimmo | GBA-ext-St3 |  |  |
| 3076 | 823.2.1 | CT4 part of Stage 3 for GBA extensions for re-use of SIP Digest credentials | 203d? | 2011-12-02 A | 2012-09-07 A | 100% | 2011-12-02 | 2012-09-07 | 203d? | finish no earlier than 2012-09-07 | C4 | 1608h | 1608h | GBA-ext-St3 | 28 | Alcatel-Lucent | Rel-11 | 54 | Kimmo |  |  |  |
| 3077 | 823.2.2 | CT1 part of Stage 3 for GBA extensions for re-use of SIP Digest credentials | 202d? | 2011-12-05 A | 2012-09-07 A | 100% | 2011-12-05 | 2012-09-07 | 202d? | finish no earlier than 2012-09-07 | C1 | 1608h | 1608h | GBA-ext-St3 | 28 | Alcatel-Lucent | Rel-11 | 54 | Frederic |  |  |  |
| 3078 | 824 | Extensions of Acoustic Test Specifications in TS 26.131 and TS 26.132 | 332d? | 2011-06-08 A | 2012-09-12 A | 100% | 2011-06-08 | 2012-09-12 | 332d? | finish no earlier than 2012-09-12 | S4 | 2648h | 2648h | Ext_ATS | 27 | Orange, Qualcomm | Rel-11 | 52 | Paolo | Ext_ATS |  |  |
| 3079 | 825 | **Enhancements to Multimedia: PSS, MMS, and MBMS Enhancements and Performance Improvements** | 397d? | 2011-09-07 A | 2013-03-06 A | 100% | 2011-09-07 | 2013-03-06 | 397d? |  | S4 | 10928.6h | 10928.6h | EMM | 27 | Qualcomm | Rel-11 | 53 | Paolo | EMM |  |  |
| 3080 | 825.1 | Enhancement to FEC for MBMS | 386d? | 2011-09-21 A | 2013-03-06 A | 100% | 2011-09-21 | 2013-03-06 | 386d? | finish no earlier than 2013-03-06 | S4 | 3048h | 3048h | EMM-EFEC | 27 | Qualcomm | Rel-11 | 53 | Paolo | EMM-EFEC |  |  |
| 3081 | 825.2 | Download Delivery Enhancements for MBMS | 325d? | 2011-09-21 A | 2012-12-12 A | 100% | 2011-09-21 | 2012-12-12 | 325d? | finish no earlier than 2012-12-12 | S4 | 2576.59h | 2576.59h | EMM-DDE | 27 | Qualcomm | Rel-11 | 53 | Paolo | EMM-DDE |  |  |
| 3082 | 825.3 | IMS-based PSS and MBMS Streaming Synchronization Enhancements | 268d? | 2011-09-07 A | 2012-09-12 A | 100% | 2011-09-07 | 2012-09-12 | 268d? | finish no earlier than 2012-09-12 | S4 | 2128h | 2128h | EMM-IPME | 27 | InterDigital Communications | Rel-11 | 53 | Paolo | EMM-IPME |  |  |
| 3083 | 826 | Mobile 3D Video Coding | 71d? | 2012-06-07 A | 2012-09-12 A | 100% | 2012-06-07 | 2012-09-12 | 71d? | finish no earlier than 2012-09-12 | S4 | 560h | 560h | M3DV | 29 | Orange | Rel-11 | 56 | Paolo | M3DV |  |  |
| 3084 | 827 | **Rel-11 Operations, Administration, Maintenance and Provisioning (OAM&P)** | 519d? | 2011-03-23 A | 2013-03-07 A | 100% | 2011-03-23 | 2013-03-06 | 519d? |  | S5 | 39394.5h | 39394.5h | OAM11 | 26 |  | Rel-11 | 51 | Mirko | OAM11 |  |  |
| 3085 | 827.1 | **Rel-11 Network Infrastructure Management** | 519d? | 2011-03-23 A | 2013-03-07 A | 100% | 2011-03-23 | 2013-03-06 | 519d? |  | S5 | 8256h | 8256h | OAM11-NIM | 26 |  | Rel-11 | 51 | Mirko | OAM11-NIM |  |  |
| 3086 | 827.1.1 | IRP framework enhancements to support Management of Converged Networks | 515d? | 2011-03-23 A | 2013-03-07 A | 100% | 2011-03-23 | 2013-03-06 | 515d? | finish no earlier than 2013-03-06 | S5 | 4104h | 4104h | OAM-FMC-IRP | 26 | Nokia Siemens Networks, Ericsson | Rel-11 | 51 | Mirko | OAM-FMC-IRP |  |  |
| 3087 | 827.2 | **Rel-11 Performance Management** | 458d? | 2011-03-23 A | 2012-12-12 A | 100% | 2011-03-23 | 2012-12-12 | 458d? |  | S5 | 14530.5h | 14530.5h | OAM11-PM | 26 |  | Rel-11 | 51 | Mirko | OAM11-PM |  |  |
| 3088 | 827.2.1 | IMS Performance Management enhancements | 252d? | 2011-03-23 A | 2012-03-07 A | 100% | 2011-03-23 | 2012-03-07 | 252d? | finish no earlier than 2012-09-12 | S5 | 2010.52h | 2010.52h | OAM-ePM-IMS | 26 | ZTE | Rel-11 | 51 | Mirko | OAM-ePM-IMS |  |  |
| 3089 | 827.2.2 | Enhanced Management of UE based network performance measurements | 455d? | 2011-03-23 A | 2012-12-12 A | 100% | 2011-03-23 | 2012-12-12 | 455d? | finish no earlier than 2012-12-12 | S5 | 3624h | 3624h | OAM-ePM-UE | 26 | Huawei, Ericsson, Nokia Siemens Networks | Rel-11 | 51 | Mirko | OAM-ePM-UE |  |  |
| 3090 | 827.2.3 | CN performance measurements enhancement | 334d? | 2011-06-08 A | 2012-09-12 A | 100% | 2011-06-08 | 2012-09-12 | 334d? | finish no earlier than 2012-09-12 | S5 | 2648h | 2648h | OAM-ePM-CN | 27 | China Mobile | Rel-11 | 52 | Mirko | OAM-ePM-CN |  |  |
| 3091 | 827.2.4 | Management of Carrier Aggregation for LTE | 325d? | 2011-09-21 A | 2012-12-12 A | 100% | 2011-09-21 | 2012-12-12 | 325d? | finish no earlier than 2012-12-12 | S5 | 2584h | 2584h | OAM-CA | 27 | Nokia Siemens Networks, Ericsson | Rel-11 | 53 | Mirko | OAM-CA |  | CA |

Notes:
- 3068: RP#57 completed testing / WI rapporteur e-mail: Yuan Qi (yuanqi@catr.cn)
- 3069: SP#53 completed new EPS algorithms e.g. for China / Impacted TSs and TRs: 33.401, New (35.221, 35.222, 35.223, 35.924) / WI rapporteur e-mail: Yuan Qi (yuanqi@catr.cn)
- 3070: RP#57 completed. Testing for SA3 TSs 33.401, new (35.221, 35.222, 35.223) / Impacted TSs and TRs: 36.523-1, 36.523-2, 36.523-3 / WI rapporteur e-mail: Ms Jun Chen (chenjun@catr.cn)
- 3071: SP#55 completed (No normative work). TR 33.838v200 for Approval & abandoned new TS 33.237. Continuation of Rel-9 UID_410027/410029. Builds on TR 33.937 Study of Mechanisms for PUCI / Impacted TSs and TRs: New TR 33.838, abandoned New TS 33.237 / WI rapporteur e-mail: Anand R. Prasad (anand@bq.jp.nec.com)
- 3072: SP#55 completed. Add HeNB Security extensions to Extended H(e)NB Features (EHNBF) UID_450053 / Impacted TSs and TRs: 33.320 / WI rapporteur e-mail: Marcus Wong (mwong@huawei.com)
- 3073: Stage 2/3. CP#57 completed / WI rapporteur e-mail: Silke.Holtmanns@nokia.com
- 3074: SP#55 completed / Impacted TSs and TRs: 33.220 / WI rapporteur e-mail: Silke.Holtmanns@nokia.com
- 3075: CP#57 completed / Impacted TSs and TRs: Stage 3 / WI rapporteur e-mail: jean-jacques.trottin@alcatel-lucent.com
- 3076: CP#57 completed / Impacted TSs and TRs: 29.109 / WI rapporteur e-mail: jean-jacques.trottin@alcatel-lucent.com
- 3077: CP#57 completed / Impacted TSs and TRs: 24.109 / WI rapporteur e-mail: jean-jacques.trottin@alcatel-lucent.com
- 3078: SP#57 completed / Impacted TSs and TRs: 26.131, 26.132 / WI rapporteur e-mail: stephane.ragot@orange-ftgroup.com, Andre Schevciw (aschevci@qualcomm.com)
- 3079: Stage 3. SP#59 completed / Impacted TSs and TRs: 26.140, 26.234, 26.247, New TR 26.951=>26.851 / WI rapporteur e-mail: Nikolai Leung (nleung@qualcomm.com)
- 3080: SP#59 completed / Impacted TSs and TRs: 26.346, new TR 26.947 / WI rapporteur e-mail: Thomas Stockhammer (c_tstock@qualcomm.com)
- 3081: SP#58 completed / Impacted TSs and TRs: 26.346, new TR 26.951=>26.851 / WI rapporteur e-mail: Nikolai Leung (nleung@qualcomm.com)
- 3082: SP#58 completed / Impacted TSs and TRs: 26.237, new TR 26.951=>26.851 / WI rapporteur e-mail: hang.liu@interdigital.com
- 3083: SP#57 completed. Triggered by UID_520036 Rel-11 Study on Mobile 3D Video Coding (FS_M3DVC) TR 26.905. / Impacted TSs and TRs: 26.140, 26.234, 26.244, 26.245, 26.247, 26.346, 26.430, 26.905 / WI rapporteur e-mail: gilles.teniou@orange.com
- 3084: OAM11 is an umbrella Feature also for OAM&P related TEI11 type of changes that are not part of any other dedicated feature/WI
- 3085: -
- 3086: SP#59 completed. Triggered by SA5 Studies TR 32.833, 32.828, 32.831 / Impacted TSs and TRs: 32.101/103/150, new (28.620/621/622/623/624/625/626/627/628/629/631/632/633/651/652/653/654/655/656/657/658/659/661/662/663/671/672/673/674/675/676/701/702/703/704/705/706/707/708/709/731/732/733/734/735/736/751/752/753, 32.107/156/157/853/854 / WI rapporteur e-mail: thomas.tovinger@ericsson.com, olaf.pollakowski@nsn.com
- 3087: -
- 3088: SP#55 completed / Impacted TSs and TRs: 32.409 / WI rapporteur e-mail: guo.wenjie1@zte.com.cn
- 3089: SP#58 completed / Impacted TSs and TRs: 32.421, 32.422, 32.423, 32.441, 32.442, 32.446 / WI rapporteur e-mail: Zou Lan (zlan@huawei.com), ulf.hubinette@ericsson.com, gyula.bodog@nsn.com
- 3090: SP#57 completed / Impacted TSs and TRs: 32.406, 32.407, 32.426 / WI rapporteur e-mail: Liang Shuangchun (liangshuangchun@cmdi.chinamobile.com), Li Jian (lijian@chinamobile.com)
- 3091: SP#58 completed. Updated WID SP-110636=>SP-120776. Stage 2 in Rel-10 RAN Feature UID_460007 Carrier Aggregation for LTE (LTE_CA) / Impacted TSs and TRs: 32.425 / WI rapporteur e-mail: yizhi.yao@nsn.com, per.elmdahl@ericsson.com

| ID | WBS | Task | Type | Duration | Start | Finish | Complete | Baseline start | Baseline finish | Baseline duration | Constraint | Resources | Work | Actual work | Acronym | PCG approved | Release | TSG approved | MCC resp | Special Focus Doc | Acronym_3GU_Export | WI rapporteur name | WI rapporteur e-mail |
| --- | --- | --- | --- | --- | --- | --- | --- | --- | --- | --- | --- | --- | --- | --- | --- | --- | --- | --- | --- | --- | --- | --- | --- |
| 3092 | 827.3 | **Rel-11 Self-Organizing Networks (SON) - OAM aspects** |  | 519d? | 2011-03-23 A | 2013-03-06 A | 100% | 2011-03-23 | 2013-03-06 | 519d? |  | S5 | 12456h | 12456h | OAM11-SON | 26 | Rel-11 | 51 | Mirko | SON | OAM11-SON |  |  |
| 3093 | 827.3.1 | UTRAN Self-Organizing Networks (SON) management |  | 388d? | 2011-03-23 A | 2012-09-12 A | 100% | 2011-03-23 | 2012-09-12 | 388d? | finish no earlier than 2012-09-12 | S5 | 3088h | 3088h | OAM-SON-UTRAN | 26 | Rel-11 | 51 | Mirko | SON | OAM-SON-UTRAN | Huawei | kai.zhangkai@huawei.com |
| 3094 | 827.3.2 | LTE Self-Organizing Networks (SON) coordination management |  | 387d? | 2011-09-21 A | 2013-03-06 A | 100% | 2011-09-21 | 2013-03-06 | 387d? | finish no earlier than 2013-03-06 | S5 | 3072h | 3072h | OAM-SON-LTE_COORD | 27 | Rel-11 | 53 | Mirko | SON | OAM-SON-LTE_COORD | Huawei, Nokia Siemens Networks | kai.zhangkai@huawei.com, clemens.suerbaum@nsn.com |
| 3095 | 827.3.3 | Inter-RAT Energy Saving Management |  | 269d? | 2011-12-07 A | 2012-12-12 A | 100% | 2011-12-07 | 2012-12-12 | 269d? | finish no earlier than 2012-12-12 | S5 | 2144h | 2144h | OAM-IRAT-ESM | 28 | Rel-11 | 54 | Mirko | SON | OAM-IRAT-ESM | Nokia Siemens Networks, Huawei | clemens.suerbaum@nsn.com, xiahaitao@huawei.com |
| 3096 | 828 | **Rel-11 Charging Management small Enhancements** |  | 717d? | 2010-03-25 A | 2012-12-12 A | 100% | 2010-03-25 | 2012-12-12 | 717d? |  | S5 | 11528h | 11528h | CH11 | 26 | Rel-11 | 51 | Mirko |  | CH11 |  |  |
| 3097 | 828.1 | Add solutions for Rc - reference point within the Online Charging System (OCS) |  | 392d? | 2010-03-25 A | 2011-09-21 A | 100% | 2010-03-25 | 2011-09-21 | 392d? | finish no earlier than 2011-08-26 | S5 | 3120h | 3120h | CH-Rc | 24 | Rel-11 | 47 | Mirko |  | CH-Rc | Huawei | shan.mingjun@huawei.com |
| 3098 | 828.2 | Charging for Policy Enhancements for Sponsored Connectivity and Coherent Access to Policy related Data Bases |  | 135d? | 2011-03-21 A | 2011-09-21 A | 100% | 2011-03-21 | 2011-09-21 | 135d? | finish no earlier than 2011-09-21 | S5 | 1064h | 1064h | PEST-CH | 26 | Rel-11 | 51 | Mirko |  | PEST-CH | Ericsson | patrik.teppo@@ericsson.com |
| 3099 | 828.3 | Unification of Charging session from SIP AS and SRVCC functions in IMS |  | 203d? | 2012-03-07 A | 2012-12-12 A | 100% | 2012-03-07 | 2012-12-12 | 203d? | finish no earlier than 2012-12-12 | S5 | 1608h | 1608h | UCHIMS_AS-SRVCC | 28 | Rel-11 | 55 | Mirko |  | UCHIMS_AS-SRVCC | Alcatel-Lucent | maryse.gardella@alcatel-lucent.com |
| 3100 | 829 | **Transit Inter Operator Identifier for IMS Interconnection Charging in multi operator environment** |  | 432d? | 2010-10-27 A | 2012-06-15 A | 100% | 2010-10-27 | 2012-06-15 | 432d? |  | S5; S1; C1 | 15921.1h | 15921.1h | IOI_IMS_CH | 26 | Rel-11 | 51 | Mirko |  | IOI_IMS_CH | Deutsche Telekom | matthias.seibel@telekom.de |
| 3101 | 829.1 | Stage 1 for Transit Inter Operator Identifier for IMS Interconnection Charging in multi operator environment |  | 237d? | 2010-10-27 A | 2011-09-21 A | 100% | 2010-10-27 | 2011-09-21 | 237d? |  | S1 | 1896h | 1896h | IOI_IMS_CH | 26 | Rel-11 | 51 | Dionisio |  |  | Deutsche Telekom | matthias.seibel@telekom.de |
| 3102 | 829.2 | Stage 2/3 SA5 part of Transit Inter Operator Identifier for IMS Interconnection Charging in multi operator environment |  | 187d? | 2010-10-27 A | 2011-12-07 A | 100% | 2010-10-27 | 2011-12-07 | 187d? | finish no earlier than 2012-03-21 | S5 | 1488h | 1488h | IOI_IMS_CH | 26 | Rel-11 | 51 | Mirko |  |  | Deutsche Telekom | matthias.seibel@telekom.de |
| 3103 | 829.3 | Stage 3 for Transit Inter Operator Identifier for IMS Interconnection Charging in multi operator environment |  | 273d? | 2011-06-07 A | 2012-06-15 A | 100% | 2011-06-07 | 2012-06-15 | 273d? | finish no earlier than 2012-06-01 | C1 | 2169.09h | 2169.09h | IOI_IMS_CH | 27 | Rel-11 | 52 | Frederic |  |  | Deutsche Telekom | martin.huelsemann@telekom.de] |
| 3104 | 830 | **User Data Convergence - Data Model** |  | 647d? | 2010-03-25 A | 2012-09-07 A | 100% | 2010-03-25 | 2012-09-07 | 647d? |  | C4; S1 | 22984h | 22984h | UDC_DM | 25 | Rel-11 | 48 | Kimmo |  | UDC_DM | Telecom Italia | mauro.ficaccio@telecomitalia.it |
| 3105 | 830.1 | Stage 1 for UDC Data Model |  | 392d? | 2010-03-25 A | 2011-09-21 A | 100% | 2010-03-25 | 2011-09-21 | 392d? | finish no earlier than 2010-06-10 | S1 | 3136h | 3136h | UDC_DM | 25 | Rel-11 | 48 | Alain |  |  | Telecom Italia | mauro.ficaccio@telecomitalia.it |
| 3106 | 830.2 | TR on User Data Convergence (UDC) Data Model |  | 593d? | 2010-06-04 A | 2012-09-07 A | 100% | 2010-06-04 | 2012-09-07 | 593d? | finish no earlier than 2012-09-07 | C4 | 4736h | 4736h | UDC_DM | 25 | Rel-11 | 48 | Kimmo |  |  | Telecom Italia | mauro.ficaccio@telecomitalia.it |
| 3107 | 830.3 | User Data Convergence (UDC) Data Model |  | 596d? | 2010-06-04 A | 2012-09-07 A | 100% | 2010-06-04 | 2012-09-07 | 596d? | finish no earlier than 2012-09-07 | C4 | 4760h | 4760h | UDC_DM | 25 | Rel-11 | 48 | Kimmo |  |  | Telecom Italia | mauro.ficaccio@telecomitalia.it |
| 3108 | 831 | Definition of the UICC Application for Hosting Party Module |  | 327d? | 2011-03-18 A | 2012-06-15 A | 100% | 2011-03-18 | 2012-06-15 | 327d? | finish no earlier than 2012-06-15 | C6 | 2608h | 2608h | HPM_UICC | 26 | Rel-11 | 51 | Xavier |  | HPM_UICC | Gemalto | Denis.Lheriteau@gemalto.com |
| 3109 | 832 | Usability improvement of Inter-IMS Network to Network Interface (II-NNI) specification for inter-connection by means of Option Item list |  | 273d? | 2011-06-07 A | 2012-06-15 A | 100% | 2011-06-07 | 2012-06-15 | 273d? | finish no earlier than 2012-06-01 | C3 | 2169.56h | 2169.56h | NNI_OI | 27 | Rel-11 | 52 | Adrian |  | NNI_OI | NTT | arai.kenjiro@lab.ntt.co.jp |
| 3110 | 833 | **enhanced Nodes Restoration for EPC (Stage 2/3)** |  | 668d? | 2011-06-03 A | 2013-12-06 A | 100% | 2011-06-03 | 2013-12-06 | 668d? |  | C4; C1; C3; IETF | 27728h | 27728h | eNR_EPC | 27 | Rel-11 | 52 | Kimmo |  | eNR_EPC | ZTE | lu.fei1@zte.com.cn |
| 3111 | 833.1 | CT4 part of enhanced Nodes Restoration for EPC |  | 402d? | 2011-06-03 A | 2012-12-07 A | 100% | 2011-06-03 | 2012-12-07 | 402d? | finish no earlier than 2012-12-07 | C4 | 3192h | 3192h | eNR_EPC | 27 | Rel-11 | 52 | Kimmo |  |  | ZTE | lu.fei1@zte.com.cn |
| 3112 | 833.2 | (IETF) CT4 part of enhanced Nodes Restoration for EPC (RFC 7077) |  | 266d? | 2012-12-07 A | 2013-12-06 A | 100% | 2012-12-07 | 2013-12-06 | 266d? | finish no earlier than 2013-12-06 | C4-IETF | 2104h | 2104h | eNR_EPC | 30 | Rel-11 | 58 | Kimmo |  |  | Lionel Morand | Lionel Morand |
| 3113 | 833.3 | CT1 part of enhanced Nodes Restoration for EPC |  | 66d? | 2011-12-02 A | 2012-03-02 A | 100% | 2011-12-02 | 2012-03-02 | 66d? | finish no earlier than 2012-06-15 | C1 | 528h | 528h | eNR_EPC | 28 | Rel-11 | 54 | Frederic |  |  | ZTE | lu.fei1@zte.com.cn |
| 3114 | 833.4 | CT3 part of enhanced Nodes Restoration for EPC |  | 67d? | 2012-09-10 A | 2012-12-07 A | 100% | 2012-09-10 | 2012-12-07 | 67d? | finish no earlier than 2012-12-07 | C3 | 528h | 528h | eNR_EPC | 29 | Rel-11 | 57 | Adrian |  |  | ZTE | lu.fei1@zte.com.cn |
| 3115 | 834 | **Reference Location Information (Stage 3)** |  | 78d? | 2011-06-03 A | 2011-09-16 A | 100% | 2011-06-03 | 2011-09-16 | 78d? |  | C4; C1 | 1860.74h | 1860.74h | RLI | 27 | Rel-11 | 52 | Kimmo |  | RLI | Huawei | susan.shishufeng@Huawei.com |
| 3116 | 834.1 | CT4 part of Reference Location Information (Stage 3) | milestone | 0d? | 2011-06-03 A | 2011-06-03 A | 100% | 2011-06-03 | 2011-06-03 | 0d? | finish no earlier than 2011-06-03 | C4 |  |  | RLI | 27 | Rel-11 | 52 | Kimmo |  |  | Huawei | susan.shishufeng@Huawei.com |
| 3117 | 834.2 | CT1 part of Reference Location Information (Stage 3) |  | 78d? | 2011-06-03 A | 2011-09-16 A | 100% | 2011-06-03 | 2011-09-16 | 78d? | finish no earlier than 2011-08-30 | C1 | 612.74h | 612.74h | RLI | 27 | Rel-11 | 52 | Frederic |  |  | Huawei | susan.shishufeng@Huawei.com |

Notes:
- 3092: -
- 3093: SP#57 completed. Updated WID SP-110518=>SP-120552 / Impacted TSs and TRs: UTRA 32.405, 32.500, 32.511, 32.521, 32.522, 32.526, 32.642, 32.646
- 3094: SP#59 completed / Impacted TSs and TRs: LTE 32.425, 32.500, 32.521, 32.522, 32.526, 32.762, 32.766
- 3095: SP#58 completed. Triggered by Rel-11 TR 32.834 (Study on OAM aspects of inter-RAT Energy Saving) UID_510045. Needs coordination with RAN WGs / Impacted TSs and TRs: 32.405, 32.551, 32.522, 32.526, 32.642, 32.646, 32.762, 32.766
- 3096: CH11 is an umbrella Feature also for OAM&P related TEI11 type of changes that are not part of any other dedicated feature/WI / Impacted TSs and TRs: TR 30.821
- 3097: SP#53 completed. Stage 3 (Stage 1 in 22.115). Triggered by Rel-10 TR 32.825 SA5 Study on Rc Reference Point Functionalities and Message Flows (UID_410044) / Impacted TSs and TRs: 32.296, 32.299
- 3098: SP#53 completed. Stage 3 / Impacted TSs and TRs: 32.251, 32.298, 32.299
- 3099: Stage 2/3. SP#58 completed / Impacted TSs and TRs: 32.260, 32.275, 32.298, 32.299
- 3100: Stage 2/3. CP#56 completed. Stage 1 in SA1 22.115
- 3101: SP#53 completed under IPXS / Impacted TSs and TRs: 22.115
- 3102: SP#54 completed / Impacted TSs and TRs: 32.240, 32.260, 32.298, 32.299
- 3103: CP#56 completed / Impacted TSs and TRs: 24.229
- 3104: CP#57 completed. SP#48 Stage 1 completed as Rel-10
- 3105: SP#53 completed under Rel-10 UDC / Impacted TSs and TRs: 22.101
- 3106: CP#57 completed / Impacted TSs and TRs: new TR 29.935
- 3107: CP#57 completed / Impacted TSs and TRs: 29.335
- 3108: CP#56 completed / Impacted TSs and TRs: 31.102, New TS 31.104
- 3109: CP#56 completed. Stage 3 (No architectural change, specify the list of selectable items related to control plane signalling directly for the same architecture) / Impacted TSs and TRs: 29.165
- 3110: Triggered by DRAFT TR 23.857 Study on EPC Nodes Restoration UID_490014
- 3111: CP#58 completed / Impacted TSs and TRs: 23.007, 23.008, 23.018, 29.274, 29.275
- 3112: CP#62 completed / Impacted TSs and TRs: RFC 7077 (was draft-ietf-netext-update-notifications)
- 3113: CP#55 completed / Impacted TSs and TRs: 29.118
- 3114: CP#58 completed / Impacted TSs and TRs: 29.212
- 3115: CP#53 completed. Stage 2 clause C.1.1 of SA2 TS 23.167 CR#0182 (WI code: TEI11)
- 3116: CP#52 completed / Impacted TSs and TRs: 23.008, 29.228, 29.328, 29.329
- 3117: CP#53 completed / Impacted TSs and TRs: 24.229

| ID | WBS | Task | Duration | Start | Finish | Complete | Baseline start | Baseline finish | Baseline duration | Constraint | Resources | Work | Actual work | Acronym | PCG approved | WI rapporteur name | WI rapporteur e-mail | Release | TSG approved | MCC resp | Acronym_3GU_Export | PCG stopped | TSG stopped | Special Focus Doc |
| --- | --- | --- | --- | --- | --- | --- | --- | --- | --- | --- | --- | --- | --- | --- | --- | --- | --- | --- | --- | --- | --- | --- | --- | --- |
| 3118 | 835 | **IMS Stage 3 IETF Protocol Alignment - phase 5** | 868d? | 2011-06-07 A | 2014-09-12 A | 100% | 2011-06-07 | 2014-12-05 | 927d? |  | C1; C3; IETF | 34260h | 34260h | IMSProtoc5 | 27 | Alcatel-Lucent | keith.drage@alcatel-lucent.com | Rel-11 | 52 | Frederic | IMSProtoc5 |  |  |  |
| 3119 | 835.1 | CT1 part of IMS Stage 3 IETF Protocol Alignment - phase 5 | 333d? | 2011-06-07 A | 2012-09-07 A | 100% | 2011-06-07 | 2012-09-07 | 333d? | finish no earlier than 2012-09-07 | C1 | 2648h | 2648h | IMSProtoc5 | 27 | Alcatel-Lucent | keith.drage@alcatel-lucent.com | Rel-11 | 52 | Frederic |  |  |  |  |
| 3120 | 835.2 | (IETF) CT1 part of IMS Stage 3 IETF Protocol Alignment - phase 5 (RFC 7315) | 356.5d? | 2013-03-01 A | 2014-09-12 A | 100% | 2013-03-01 | 2014-12-05 | 416.5d? | finish no earlier than 2014-09-12 | C1-IETF | 2812h | 2812h | IMSProtoc5 | 30 | Roland Jesske | Roland Jesske | Rel-11 | 59 | Frederic |  |  |  |  |
| 3121 | 835.3 | (IETF) CT1 part of IMS Stage 3 IETF Protocol Alignment - phase 5 (RFC 7135) | 203d? | 2013-09-06 A | 2014-06-13 A | 100% | 2013-09-06 | 2014-06-13 | 203d? | finish no earlier than 2014-06-13 | C1-IETF | 1608h | 1608h | IMSProtoc5 | 31 | Roland Jesske | Roland Jesske | Rel-11 | 61 |  |  |  |  |  |
| 3122 | 835.4 | CT3 part of IMS Stage 3 IETF Protocol Alignment - phase 5 | 333d? | 2011-06-07 A | 2012-09-07 A | 100% | 2011-06-07 | 2012-09-07 | 333d? | finish no earlier than 2012-09-07 | C3 | 2648h | 2648h | IMSProtoc5 | 27 | Alcatel-Lucent | keith.drage@alcatel-lucent.com | Rel-11 | 52 | Adrian |  |  |  |  |
| 3123 | 835.5 | Deleted - (IETF) CT3 part of IMS Stage 3 IETF Protocol Alignment - phase 5 (avasarala-dispatch-comm-div-notification) | 466d? | 2012-12-07 A | 2014-09-12 A | 100% | 2012-12-07 | 2014-12-05 | 526d? | finish no earlier than 2014-09-12 | C3-IETF | 3712h | 3712h | IMSProtoc5 | 30 | Andrew Allen | Andrew Allen | Rel-11 | 58 | Adrian |  | PCG-33 | CP-65 |  |
| 3124 | 836 | **Service Identification for RRC Improvements in GERAN (Stage 2/3)** | 258d? | 2011-09-19 A | 2012-09-07 A | 100% | 2011-09-19 | 2012-09-07 | 258d? |  | S2; C4; C3; G2 | 16216h | 16216h | SIRIG | 27 | China Mobile | zhanghao@chinamobile.com | Rel-11 | 51 | Maurice | SIRIG |  |  |  |
| 3125 | 836.1 | Stage 2 for Service Identification for RRC Improvements in GERAN | 61d? | 2012-06-18 A | 2012-09-07 A | 100% | 2012-06-18 | 2012-09-07 | 61d? | finish no earlier than 2012-09-07 | S2 | 480h | 480h | SIRIG | 29 |  |  | Rel-11 | 56 | Maurice |  |  |  |  |
| 3126 | 836.2 | **CN aspects of Service Identification for RRC Improvements in GERAN** | 203d? | 2011-12-02 A | 2012-09-07 A | 100% | 2011-12-02 | 2012-09-07 | 203d? |  | C4; C3 | 5464h | 5464h | SIRIG | 28 | China Mobile | zhanghao@chinamobile.com | Rel-11 | 54 | Kimmo |  |  |  |  |
| 3127 | 836.2.1 | CT4 part of CN aspects of Service Identification for RRC Improvements in GERAN | 203d? | 2011-12-02 A | 2012-09-07 A | 100% | 2011-12-02 | 2012-09-07 | 203d? | finish no earlier than 2012-09-07 | C4 | 1608h | 1608h | SIRIG | 28 | China Mobile | zhanghao@chinamobile.com | Rel-11 | 54 | Kimmo |  |  |  |  |
| 3128 | 836.2.2 | Deleted - CT3 part of CN aspects of Service Identification for RRC Improvements in GERAN | 77d? | 2012-03-02 A | 2012-06-15 A | 100% | 2012-03-02 | 2012-06-15 | 77d? | finish no earlier than 2012-06-01 | C3 | 608h | 608h | SIRIG | 28 | China Mobile | zhanghao@chinamobile.com | Rel-11 | 55 | Adrian |  | PCG-29 | CP-56 |  |
| 3129 | 836.3 | GERAN2 part of Service Identification for RRC Improvements in GERAN | 252d? | 2011-09-19 A | 2012-08-31 A | 100% | 2011-09-19 | 2012-08-31 | 252d? | finish no earlier than 2012-08-31 | G2 | 2016h | 2016h | SIRIG | 27 | China Mobile, Huawei | Juan Deng, Yang Zhao | Rel-11 | 51 | Gert |  |  |  |  |
| 3130 | 837 | **SAE Protocol Development - Phase 2** | 259d? | 2011-09-16 A | 2012-09-07 A | 100% | 2011-09-16 | 2012-09-07 | 259d? |  | C1 | 6168h | 6168h | SAES2 | 27 | Nokia Siemens Networks | robert.zaus@nsn.com | Rel-11 | 53 | Frederic | SAES2 |  |  |  |
| 3131 | 837.1 | SAE Protocol Development (Stage 3) - Phase 2 | 259d? | 2011-09-16 A | 2012-09-07 A | 100% | 2011-09-16 | 2012-09-07 | 259d? | finish no earlier than 2012-09-07 | C1 | 2048h | 2048h | SAES2 | 27 | Nokia Siemens Networks | robert.zaus@nsn.com | Rel-11 | 53 | Frederic |  |  |  |  |
| 3132 | 837.2 | CS Fallback in EPS - Phase 2 | 259d? | 2011-09-16 A | 2012-09-07 A | 100% | 2011-09-16 | 2012-09-07 | 259d? | finish no earlier than 2012-09-07 | C1 | 2048h | 2048h | SAES2-CSFB | 27 | Nokia Siemens Networks | robert.zaus@nsn.com | Rel-11 | 53 | Frederic | SAES2-CSFB |  |  |  |
| 3133 | 838 | **GCSMSC and GCR Redundancy for VGCS/VBS (Stage 2/3)** | 258d? | 2011-09-19 A | 2012-09-07 A | 100% | 2011-09-19 | 2012-09-07 | 258d? |  | C1 | 5680h | 5680h | RT_VGCS_Red | 27 | Nokia Siemens Networks | robert.zaus@nsn.com | Rel-11 | 53 | Frederic | RT_VGCS_Red |  |  |  |
| 3134 | 838.1 | CT1 part of GCSMSC and GCR Redundancy for VGCS/VBS | 258d? | 2011-09-19 A | 2012-09-07 A | 100% | 2011-09-19 | 2012-09-07 | 258d? | finish no earlier than 2012-09-07 | C1 | 2048h | 2048h | RT_VGCS_Red | 27 | Nokia Siemens Networks | robert.zaus@nsn.com | Rel-11 | 53 | Frederic |  |  |  |  |
| 3135 | 838.2 | Deleted - CT4 part of GCSMSC and GCR Redundancy for VGCS/VBS | 197d? | 2011-09-19 A | 2012-06-15 A | 100% | 2011-09-19 | 2012-06-15 | 197d? | finish no earlier than 2012-06-15 | C4 | 1568h | 1568h | RT_VGCS_Red | 27 | Nokia Siemens Networks | robert.zaus@nsn.com | Rel-11 | 53 | Kimmo |  | PCG-29 | CP-56 |  |
| 3136 | 839 | Support of RFC 6140 in IMS | 203d? | 2011-12-02 A | 2012-09-07 A | 100% | 2011-12-02 | 2012-09-07 | 203d? | finish no earlier than 2012-09-07 | C1 | 1608h | 1608h | GINI | 28 | Deutsche Telekom | martin.huelsemann@telekom.de | Rel-11 | 54 | Frederic | GINI |  |  |  |
| 3137 | 840 | **Enhancements for Multimedia Priority Service (MPS) – Gateway Control Priority** | 203d? | 2011-12-02 A | 2012-09-07 A | 100% | 2011-12-02 | 2012-09-07 | 203d? |  | C4; C3 | 6464h | 6464h | eMPS_Gateway | 28 | Telcordia | Viqar Shaikh | Rel-11 | 54 | Kimmo | eMPS_Gateway |  |  | Public Safety (I-A) |
| 3138 | 840.1 | CT4 part of Enhancements for Multimedia Priority Service (MPS) – Gateway Control Priority | 202d? | 2011-12-02 A | 2012-09-07 A | 100% | 2011-12-02 | 2012-09-07 | 202d? | finish no earlier than 2012-09-07 | C4 | 1608h | 1608h | eMPS_Gateway | 28 | Telcordia | Viqar Shaikh | Rel-11 | 54 | Kimmo |  |  |  | Public Safety (I-A) |
| 3139 | 840.2 | CT3 part of Enhancements for Multimedia Priority Service (MPS) – Gateway Control Priority | 202d? | 2011-12-02 A | 2012-09-07 A | 100% | 2011-12-02 | 2012-09-07 | 202d? | finish no earlier than 2012-09-07 | C3 | 1608h | 1608h | eMPS_Gateway | 28 | Telcordia | Viqar Shaikh | Rel-11 | 54 | Adrian |  |  |  | Public Safety (I-A) |
| 3140 | 841 | Inter-IMS Network to Network Interface (II-NNI) enhancements: SIP timers applicability (Stage 3) | 138d? | 2012-03-02 A | 2012-09-07 A | 100% | 2012-03-02 | 2012-09-07 | 138d? | start no earlier than 2012-03-02 | C3 | 1088h | 1088h | NNI_timers | 28 | Telecom Italia | antonio.ascolese@telecomitalia.it | Rel-11 | 55 | Adrian | NNI_timers |  |  |  |
| 3141 | 842 | AT commands for Universal Resource Identifier (URI) support | 188d? | 2012-06-15 A | 2013-03-01 A | 100% | 2012-06-15 | 2013-03-01 | 188d? | finish no earlier than 2013-03-01 | C1 | 1496h | 1496h | ATURI | 29 | Intel | frank.kowalewski@intel.com | Rel-11 | 56 | Frederic | ATURI |  |  |  |
| 3142 | 843 | PS Additional Number (Stage 3) | 62d? | 2012-06-15 A | 2012-09-07 A | 100% | 2012-06-15 | 2012-09-07 | 62d? | finish no earlier than 2012-09-07 | C4 | 488h | 488h | PSAN | 29 | Deutsche Telekom | Yvette.koza@t-mobile.at | Rel-11 | 56 | Kimmo | PSAN |  |  |  |
| 3143 | 844 | Generic IMS User Group Over Sh | 62d? | 2012-06-15 A | 2012-09-07 A | 100% | 2012-06-15 | 2012-09-07 | 62d? | finish no earlier than 2012-09-07 | C4 | 488h | 488h | GenUG_Sh | 29 | Alcatel-Lucent | jean-jacques.trottin@alcatel-lucent.com | Rel-11 | 56 | Kimmo | GenUG_Sh |  |  |  |

Notes:
- 3118: CP#57 completed
- 3119: CP#57 completed / Impacted TSs and TRs: 23.218, 24.229, 24.930
- 3120: CP#65 completed / Impacted TSs and TRs: RFC 7315 (was draft-drage-sipping-rfc3455bis), draft-mohali-dispatch-originating-cdiv-parameter
- 3121: CP#64 completed / Impacted TSs and TRs: RFC 7135 (was draft-polk-local-emergency-rph-namespace)
- 3122: CP#57 completed / Impacted TSs and TRs: 29.163, 29.165
- 3123: CP#64 Draft removed from 3GPP documentation / Impacted TSs and TRs: draft-avasarala-dispatch-comm-div-notification
- 3124: TSG#57, GP#55 completed. CT defined a generic solution (not only for GERAN) / Impacted TSs and TRs: GERAN
- 3125: SP#57 completed / Impacted TSs and TRs: 23.060, 23.251
- 3126: CP#57 completed
- 3127: CP#57 completed / Impacted TSs and TRs: 29.281
- 3128: CP#56 stopped (SA2 decided NO CT3 impact) / Impacted TSs and TRs: 29.212
- 3129: GP#55 completed. GP#51 approved WID / Impacted TSs and TRs: 48.018
- 3130: CP#57 completed. Stage 3 continuation of Rel-8 Feature SAES (3GPP System Architecture Evolution Specification - Evolved Packet System) UID_320005
- 3131: CP#57 completed / Impacted TSs and TRs: 23.122, 24.008, 24.167, 24.229, 24.301, 24.302, 24.303, 24.304, 24.305, 24.312, 29.018, 29.118
- 3132: CP#57 completed / Impacted TSs and TRs: 23.122, 24.008, 24.167, 24.229, 24.301, 24.302, 24.303, 24.304, 24.305, 24.312, 29.018, 29.118
- 3133: CP#57 completed. Stage 2/3 adding a CN internal functionality, not affecting Voice Group Call Service (VGCS)/VBS as perceived by service subscriber. Hence, no Stage 1 impact for VGCS/VBS (42.068, 42.069) / Impacted TSs and TRs: Stage 2/3
- 3134: CP#57 completed / Impacted TSs and TRs: 43.068, 43.069
- 3135: CP#56 stopped (no CT4 impact) / Impacted TSs and TRs: 29.002
- 3136: CP#57 completed. Stage 3. Support procedures and protocol extensions in RFC6140 "Registration for Multiple Phone Numbers in SIP" to IMS for complex UEs. Ensure co-existence with NGCN IP-PBX registration procedures already defined in IMS. / Impacted TSs and TRs: 24.229
- 3137: CP#57 completed. Stage 3. Stage 1 for MPS in 22.153. Details of any MGW actions for priority needs to be further studied within the scope of this WI. / Impacted TSs and TRs: Stage 3
- 3138: CP#57 completed / Impacted TSs and TRs: 23.333, 23.334, 29.232, 29.238, 29.332, 29.333, 29.334
- 3139: CP#57 completed / Impacted TSs and TRs: 29.162, 29.163, 29.292
- 3140: CP#57 completed / Impacted TSs and TRs: 29.165
- 3141: CP#59 completed. Define new AT cmd for URI addresses for IMS services (eg VoLTE). 27.007(AT cmd to control MT functions and GSM/UMTS/LTE network services from TE), 27.005(AT commands for SMS). Currently address types for AT cmd based on dialling# / Impacted TSs and TRs: 27.005, 27.007
- 3142: CP#57 completed. Stage 1 in Rel-11 SA1 TS 22.101 clause 17.7.3 (No Stage 2 needed since no architecture impact) / Impacted TSs and TRs: 23.003, 23.008, 29.002, 29.272, 29.230
- 3143: CP#57 completed / Impacted TSs and TRs: 29.364

| ID | WBS | Task | Duration | Start | Finish | Complete | Baseline start | Baseline finish | Baseline duration | Constraint | Resources | Work | Actual work | Acronym | PCG approved | WI rapporteur name | WI rapporteur e-mail | Release | TSG approved | MCC resp | Acronym_3GU_Export | PCG stopped | TSG stopped | Status Report |
| --- | --- | --- | --- | --- | --- | --- | --- | --- | --- | --- | --- | --- | --- | --- | --- | --- | --- | --- | --- | --- | --- | --- | --- | --- |
| 3144 | 845 | **IMS Operator Determined Call Barring** | 205d? | 2012-09-07 A | 2013-06-14 A | 100% | 2012-09-07 | 2013-06-14 | 205d? |  | C1; C4 | 5411.54h | 5411.54h | IODB | 29 | Orange | Youssef.Chadli@Orange.com | Rel-11 | 57 | Frederic | IODB |  |  |  |
| 3145 | 845.1 | CT1 part of IMS Operator Determined Call Barring | 203d? | 2012-09-10 A | 2013-06-14 A | 100% | 2012-09-10 | 2013-06-14 | 203d? | finish no earlier than 2013-06-14 | C1 | 1616h | 1616h | IODB | 29 | Orange | Youssef.Chadli@Orange.com | Rel-11 | 57 | Frederic |  |  |  |  |
| 3146 | 845.2 | CT4 part of IMS Operator Determined Call Barring | 69d? | 2012-09-07 A | 2013-03-12 A | 100% | 2012-09-07 | 2013-03-12 | 69d? | finish no earlier than 2012-12-07 | C4 | 515.54h | 515.54h | IODB | 29 | Orange | Youssef.Chadli@Orange.com | Rel-11 | 57 | Kimmo |  |  |  |  |
| 3147 | 846 | **Enhanced T.38 FAX support (Stage 3)** | 69d? | 2012-09-06 A | 2012-12-07 A | 100% | 2012-09-06 | 2012-12-07 | 69d? |  | C3; C1; C4 | 2728h | 2728h | MMTel_T.38_FAX | 29 | NEC | Naoaki Suzuki (n-suzuki@en.jp.nec.com) | Rel-11 | 57 | Adrian | MMTel_T.38_FAX |  |  |  |
| 3148 | 846.1 | CT3 part of Enhanced T.38 FAX support | 68d? | 2012-09-07 A | 2012-12-07 A | 100% | 2012-09-07 | 2012-12-07 | 68d? | finish no earlier than 2012-12-07 | C3 | 528h | 528h | MMTel_T.38_FAX | 29 | NEC | Naoaki Suzuki (n-suzuki@en.jp.nec.com) | Rel-11 | 57 | Adrian |  |  |  |  |
| 3149 | 846.2 | CT1 part of Enhanced T.38 FAX support | 67d? | 2012-09-07 A | 2012-12-07 A | 100% | 2012-09-07 | 2012-12-07 | 67d? | finish no earlier than 2012-12-07 | C1 | 528h | 528h | MMTel_T.38_FAX | 29 | NEC | Naoaki Suzuki (n-suzuki@en.jp.nec.com) | Rel-11 | 57 | Frederic |  |  |  |  |
| 3150 | 846.3 | CT4 part of Enhanced T.38 FAX support | 2d? | 2012-09-06 A | 2012-09-07 A | 100% | 2012-09-06 | 2012-09-07 | 2d? | finish no earlier than 2012-12-07 | C4 | 16h | 16h | MMTel_T.38_FAX | 29 | NEC | Naoaki Suzuki (n-suzuki@en.jp.nec.com) | Rel-11 | 57 | Kimmo |  |  |  |  |
| 3151 | 847 | **Deleted - Enhancement of the Protocols for SMS over SGs (Stage 3)** | 142d? | 2011-12-02 A | 2012-06-15 A | 100% | 2011-12-02 | 2012-06-15 | 142d? |  | C4; C1 | 5664h | 5664h | PROTOC_SMS_SGs | 28 | Alcatel-Lucent | jean-jacques.trottin@alcatel-lucent.com | Rel-11 | 54 | Kimmo | PROTOC_SMS_SGs | PCG-29 | CP-56 |  |
| 3152 | 847.1 | Deleted - TR Study on enhancement of protocols for SMS service over SGs | 142d? | 2011-12-02 A | 2012-06-15 A | 100% | 2011-12-02 | 2012-06-15 | 142d? | finish no earlier than 2012-06-15 | C4 | 1128h | 1128h | PROTOC_SMS_SGs | 28 | Alcatel-Lucent | jean-jacques.trottin@alcatel-lucent.com | Rel-11 | 54 | Kimmo |  | PCG-29 | CP-56 |  |
| 3153 | 847.2 | Deleted - CT4 part of Enhancement of the Protocols for SMS over SGs | 142d? | 2011-12-02 A | 2012-06-15 A | 100% | 2011-12-02 | 2012-06-15 | 142d? | finish no earlier than 2012-06-15 | C4 | 1128h | 1128h | PROTOC_SMS_SGs | 28 | Alcatel-Lucent | jean-jacques.trottin@alcatel-lucent.com | Rel-11 | 54 | Kimmo |  | PCG-29 | CP-56 |  |
| 3154 | 847.3 | Deleted - CT1 part of Enhancement of the Protocols for SMS over SGs | 142d? | 2011-12-02 A | 2012-06-15 A | 100% | 2011-12-02 | 2012-06-15 | 142d? | finish no earlier than 2012-06-15 | C1 | 1136h | 1136h | PROTOC_SMS_SGs | 28 | Alcatel-Lucent | jean-jacques.trottin@alcatel-lucent.com | Rel-11 | 54 | Frederic |  | PCG-29 | CP-56 |  |
| 3155 | 848 | **Full Support of Multi-Operator Core Network by GERAN** | 584d? | 2011-03-04 A | 2013-05-17 A | 100% | 2011-03-04 | 2013-05-17 | 584d? |  | G2; S2; C1 | 31293.3h | 31293.3h | Full_MOCN-GERAN | 26 | Alcatel-Lucent | michel.robert@alcatel-lucent.com | Rel-11 | 49 | Paolo | Full_MOCN-GERAN |  |  |  |
| 3156 | 848.1 | GERAN part of Full Support of Multi-Operator Core Network by GERAN | 584d? | 2011-03-04 A | 2013-05-17 A | 100% | 2011-03-04 | 2013-05-17 | 584d? | finish no earlier than 2013-06-07 | G2 | 4656.4h | 4656.4h | Full_MOCN-GERAN | 26 | Alcatel-Lucent | michel.robert@alcatel-lucent.com | Rel-11 | 49 | Gert |  |  |  |  |
| 3157 | 848.2 | Stage 2 for Full Support of Multi-Operator Core Network by GERAN | 160.8d? | 2011-06-08 A | 2012-03-07 A | 100% | 2011-06-08 | 2012-03-07 | 160.8d? | finish no earlier than 2012-03-07 | S2 | 1278.4h | 1278.4h | Full_MOCN-GERAN | 26 | Alcatel-Lucent | nicolas.drevon@alcatel-lucent.com | Rel-11 | 49 | Maurice |  |  |  |  |
| 3158 | 848.3 | **CN Stage 3 for Full Support of Multi-Operator Core Network by GERAN** | 403d? | 2011-06-03 A | 2012-12-07 A | 100% | 2011-06-03 | 2012-12-07 | 403d? |  | C1; C4 | 9838.51h | 9838.51h | Full_MOCN-GERAN | 26 | Alcatel-Lucent | jennifer.liu@alcatel-lucent.com | Rel-11 | 49 | Frederic |  |  |  |  |
| 3159 | 848.3.1 | CT1 part of CN Stage 3 for Full Support of Multi-Operator Core Network by GERAN | 362.8d? | 2011-06-03 A | 2012-12-07 A | 100% | 2011-06-03 | 2012-12-07 | 362.8d? | finish no earlier than 2012-12-07 | C1 | 2886.51h | 2886.51h | Full_MOCN-GERAN | 26 | Alcatel-Lucent | jennifer.liu@alcatel-lucent.com | Rel-11 | 49 | Frederic |  |  |  |  |
| 3160 | 848.3.2 | CT4 part of CN Stage 3 for Full Support of Multi-Operator Core Network by GERAN | 64d? | 2012-06-13 A | 2012-09-07 A | 100% | 2012-06-13 | 2012-09-07 | 64d? | finish no earlier than 2012-09-07 | C4 | 504h | 504h | Full_MOCN-GERAN | 29 | Alcatel-Lucent | michel.robert@alcatel-lucent.com | Rel-11 | 54 | Kimmo |  |  |  |  |
| 3161 | 848.4 | Stage 2 for Gateway Core Network Sharing for GERAN | 192d? | 2012-06-18 A | 2013-03-06 A | 100% | 2012-06-18 | 2013-03-06 | 192d? | finish no earlier than 2013-03-06 | S2 | 1504h | 1504h | Full_MOCN-GERAN-GWCN | 29 | Vodafone | chris.pudney@vodafone.com | Rel-11 | 56 | Maurice | Full_MOCN-GERAN-GWCN |  |  |  |
| 3162 | 849 | **Medium range/local area requirements for multicarrier BTS** | 264d? | 2011-11-25 A | 2012-11-23 A | 100% | 2011-11-25 | 2012-11-23 | 264d? |  | G1 | 6296h | 6296h | MRLA | 28 | Ericsson | Eric Nordström | Rel-11 | 52 | Paolo | MRLA |  |  |  |
| 3163 | 849.1 | Core part: Medium range/local area requirements for multicarrier BTS | 263d? | 2011-11-25 A | 2012-11-23 A | 100% | 2011-11-25 | 2012-11-23 | 263d? | finish no earlier than 2012-11-23 | G1 | 2096h | 2096h | MRLA-Core | 28 | Ericsson | Eric Nordström | Rel-11 | 52 | Paolo | MRLA-Core |  |  |  |
| 3164 | 849.2 | Perf. part: Medium range/local area requirements for multicarrier BTS | 262d? | 2011-11-28 A | 2012-11-23 A | 100% | 2011-11-28 | 2012-11-23 | 262d? | finish no earlier than 2012-11-23 | G1 | 2088h | 2088h | MRLA-Perf | 28 | Ericsson | Eric Nordström | Rel-11 | 52 | Paolo | MRLA-Perf |  |  |  |
| 3165 | 850 | Domain Specific Access Control in GERAN | 131d? | 2012-03-05 A | 2012-08-31 A | 100% | 2012-03-05 | 2012-08-31 | 131d? | finish no earlier than 2012-08-31 | G2 | 1048h | 1048h | GDSAC | 28 | Vodafone | chris.pudney@vodafone.com | Rel-11 | 53 | Gert | GDSAC |  |  |  |
| 3166 | 851 | **Extending 850 MHz Upper Band (814 – 849 MHz)** | 589d? | 2010-12-10 A | 2013-03-01 A | 100% | 2010-12-10 | 2013-03-01 | 589d? |  | R4; R2; R3; R5 | 33352h | 33352h | e850_UB | 26 | Sprint | John.J.Humbert@Sprint.com | Rel-11 | 50 | Issam | e850_UB |  |  |  |
| 3167 | 851.1 | Core part: Extending 850 MHz Upper Band (814 – 849 MHz) | 324d? | 2010-12-10 A | 2012-03-02 A | 100% | 2010-12-10 | 2012-03-02 | 324d? | finish no earlier than 2012-03-02 | R4; R2; R3 | 7776h | 7776h | e850_UB-Core | 26 | Sprint | John.J.Humbert@Sprint.com | Rel-11 | 50 | Issam | e850_UB-Core |  |  | RP-120075 |
| 3168 | 851.2 | Perf. part: Extending 850 MHz Upper Band (814 – 849 MHz) | 324d? | 2010-12-10 A | 2012-03-02 A | 100% | 2010-12-10 | 2012-03-02 | 324d? | finish no earlier than 2012-03-02 | R4 | 2592h | 2592h | e850_UB-Perf | 26 | Sprint | John.J.Humbert@Sprint.com | Rel-11 | 50 | Issam | e850_UB-Perf |  |  | RP-120076 |
| 3169 | 851.3 | Test part: Extending 850 MHz Upper Band (814 – 849 MHz) | 517d? | 2011-03-18 A | 2013-03-01 A | 100% | 2011-03-18 | 2013-03-01 | 517d? | finish no earlier than 2013-03-01 | R5 | 4136h | 4136h | e850_UB-UEConTest | 26 | Sprint | John.J.Humbert@Sprint.com | Rel-11 | 51 | Ingbert | e850_UB-UEConTest |  |  | RP-130043 |

Notes:
- 3144: LS_in C4-121615 GSMA IREG RILTE concluded that TS 22.041 clause 5.4 Stage 1 requirements are not covered by stage 3 specifications
- 3145: CP#60 completed. Handling of premium rate numbers remained OPEN in Rel-11 (shifted to Rel-12). CP-130384 LS_out sent to SA1 / GSMA informing this TSG CT decision. / Impacted TSs and TRs: New TS 24.315
- 3146: CP#58 completed / Impacted TSs and TRs: 23.008 , 23.015 , 29.328 , 29.329 , 29.364
- 3147: CP#58 completed. Linked to Rel-8 Feature: IMS Multimedia Telephony Service (IMS-MMTel) UID_7038. SA1 added FAX stage 1 requirement only in Rel-10 under TEI10 to TS 22.173 (CR#0064)
- 3148: CP#58 completed / Impacted TSs and TRs: 29.163
- 3149: CP#58 completed / Impacted TSs and TRs: 24.229
- 3150: CP#57 completed / Impacted TSs and TRs: 29.332
- 3151: CP#56 stopped. Reason: Protocols for SMS over SGs is replaced by the SIMTC SMS in MME solution (as solution not only for MTC user but for general subscribers) / Impacted TSs and TRs: Stage 3
- 3152: CP#56 stopped (abandonned new TR 29.818) / Impacted TSs and TRs: new TR 29.818
- 3153: CP#56 stopped (abandonned new TS 29.218 Diameter based protocols for SMS service over SGs) / Impacted TSs and TRs: 29.305, new TS 29.218
- 3154: CP#56 stopped / Impacted TSs and TRs: 23.040, 24.011, 43.068
- 3155: GP#58 completed. GP#49 approved WID. Standardization of management of MOCN supporting MSs/UES in CP-150GERAN. Continuation of Rel-10 MOCN-GERAN UID_490001 / Impacted TSs and TRs: GERAN
- 3156: GP#58 completed. GP#49 approved WID / Impacted TSs and TRs: 44.018, 44.060, 45.002, 45.008, 48.008, 48.018
- 3157: SP#55 completed / Impacted TSs and TRs: 23.251, 23.272
- 3158: CP#58 completed
- 3159: CP#58 completed / Impacted TSs and TRs: 24.008
- 3160: CP#57 completed / Impacted TSs and TRs: 23.003
- 3161: SP#59 completed. (23.251CR0062R2 as TEI11. TS 23.251 specifies both MOCN and GWCN for E-UTRAN and UTRAN, but GWCN is not yet supported on GERAN. Extend Full_MOCN-GERAN to also cover GWCN GERAN / Impacted TSs and TRs: 23.251
- 3162: GP#56 completed. GP#52 approved WID / Impacted TSs and TRs: GERAN
- 3163: Stage 3. GP#56 completed. GP#52 approved WID / Impacted TSs and TRs: 45.005
- 3164: Test spec. GP#56 completed. GP#52 approved WID / Impacted TSs and TRs: 51.021
- 3165: GP#55 completed. GP#53 approved WID. Work is dependent upon Full_MOCN-GERAN (UID_510001) / Impacted TSs and TRs: GERAN 44.018
- 3166: Stage 3. Triggered by R4 Rel-10 LTE TR 37.806 Study on Extending 850 MHz (UID_440016) / Impacted TSs and TRs: UTRA, LTE
- 3167: RP#55 completed / Impacted TSs and TRs: 25.101, 25.104, 25.113, 25.133, 25.141, 25.461, 25.466, 36.101, 36.104, 36.113, 36.124, 36.133, 36.141, 36.307, 36.331, 37.104, 37.113, 37.141
- 3168: RP#55 completed / Impacted TSs and TRs: 25.101, 25.104, 25.113, 25.133, 25.141, 25.461, 25.466, 36.101, 36.104, 36.124, 36.133, 36.141, 36.307, 36.331, 37.104, 37.113, 37.141
- 3169: RP#59 completed / Impacted TSs and TRs: 34.108, 34.121-1, 34.121-2, 34.123-1, 34.123-2, 34.123-3, 36.508, 36.521-1, 36.521-2, 36.521-3, 36.523-1, 36.523-2, 36.523-3

| ID | WBS | Task | Duration | Start | Finish | Complete | Baseline start | Baseline finish | Baseline duration | Constraint | Resources | Work | Actual work | Acronym | PCG approved | WI rapporteur name | WI rapporteur e-mail | Release | TSG approved | MCC resp | Special Focus Doc | Acronym_3GU_Export | Status Report |
| --- | --- | --- | --- | --- | --- | --- | --- | --- | --- | --- | --- | --- | --- | --- | --- | --- | --- | --- | --- | --- | --- | --- | --- |
| 3170 | 852 | **Further Self Optimizing Networks (SON) enhancements** | 325d? | 2011-09-19 A | 2012-12-07 A | 100% | 2011-09-19 | 2012-12-07 | 325d? |  | R3; R2 | 10400h | 10400h | SONenh2_LTE_UTRA | 27 | Nokia Siemens Networks | krzysztof.kordybach@nsn.com | Rel-11 | 53 | Juha | SON | SONenh2_LTE_UTRA |  |
| 3171 | 852.1 | Core part: Further Self Optimizing Networks (SON) enhancements | 325d? | 2011-09-19 A | 2012-12-07 A | 100% | 2011-09-19 | 2012-12-07 | 325d? | finish no earlier than 2012-12-07 | R3; R2 | 5200h | 5200h | SONenh2_LTE_UTRA-Core | 27 | Nokia Siemens Networks | krzysztof.kordybach@nsn.com | Rel-11 | 53 | Juha | SON | SONenh2_LTE_UTRA-Core | RP-121557 |
| 3172 | 853 | **Enhancement of Minimization of Drive Tests for E-UTRAN and UTRAN** | 590d? | 2011-09-19 A | 2013-12-06 A | 100% | 2011-09-19 | 2013-12-06 | 590d? |  | R2; R1; R3; R4; R5 | 35608h | 35608h | eMDT_UMTSLTE | 27 | MediaTek | Johan Johansson | Rel-11 | 53 | Yong-Jun |  | eMDT_UMTSLTE |  |
| 3173 | 853.1 | Core part: Enhancement of Minimization of Drive Tests for E-UTRAN and UTRAN | 325d? | 2011-09-19 A | 2012-12-07 A | 100% | 2011-09-19 | 2012-12-07 | 325d? | finish no earlier than 2012-12-07 | R2; R1; R3; R4 | 10400h | 10400h | eMDT_UMTSLTE-Core | 27 | MediaTek | Johan Johansson | Rel-11 | 53 | Yong-Jun |  | eMDT_UMTSLTE-Core | RP-121556 |
| 3174 | 853.2 | Test part: Enhancement of Minimization of Drive Tests for E-UTRAN and UTRAN | 202d? | 2013-03-04 A | 2013-12-06 A | 100% | 2013-03-04 | 2013-12-06 | 202d? | finish no earlier than 2013-12-06 | R5 | 1608h | 1608h | eMDT_UMTSLTE-UEConTest | 30 | NTT DoCoMo | masahiro.tamaoki.eu@nttdocomo.com | Rel-11 | 59 | Ingbert |  | eMDT_UMTSLTE-UEConTest | RP-131447 |
| 3175 | 854 | **Network Energy Saving for E-UTRAN** | 258d? | 2011-09-19 A | 2012-09-07 A | 100% | 2011-09-19 | 2012-09-07 | 258d? |  | R3; GP | 6224h | 6224h | Netw_Energy_LTE | 27 | China Mobile | yangning@chinamobile.com | Rel-11 | 53 | Juha |  | Netw_Energy_LTE |  |
| 3176 | 854.1 | Core part: Network Energy Saving for E-UTRAN | 257d? | 2011-09-19 A | 2012-09-07 A | 100% | 2011-09-19 | 2012-09-07 | 257d? | finish no earlier than 2012-09-07 | R3 | 2056h | 2056h | Netw_Energy_LTE-Core | 27 | China Mobile | yangning@chinamobile.com | Rel-11 | 53 | Juha |  | Netw_Energy_LTE-Core | RP-121016 |
| 3177 | 854.2 | GERAN part: Network Energy Saving for E-UTRAN | 5d? | 2012-08-27 A | 2012-08-31 A | 100% | 2012-08-27 | 2012-08-31 | 5d? | finish no earlier than 2012-08-31 | GP | 40h | 40h |  | 29 | Alcatel-Lucent | marguerite.woch@alcatel-lucent.com | Rel-11 | 55 | Paolo |  |  |  |
| 3178 | 855 | **E-UTRA medium range and MSR medium range/local area BS class requirements** | 325d? | 2011-09-19 A | 2012-12-07 A | 100% | 2011-09-19 | 2012-12-07 | 325d? |  | R4; G1 | 12432h | 12432h | medBS_class_LTE_MSR | 27 | Ericsson | johan.skold@ericsson.com | Rel-11 | 53 | Issam |  | medBS_class_LTE_MSR |  |
| 3179 | 855.1 | Core part: E-UTRA medium range and MSR medium range/local area BS class requirements | 323d? | 2011-09-19 A | 2012-12-07 A | 100% | 2011-09-19 | 2012-12-07 | 323d? | finish no earlier than 2012-12-07 | R4 | 2576h | 2576h | medBS_class_LTE_MSR-Core | 27 | Ericsson | johan.skold@ericsson.com | Rel-11 | 53 | Issam |  | medBS_class_LTE_MSR-Core | RP-121558 |
| 3180 | 855.2 | Perf. part: E-UTRA medium range and MSR medium range/local area BS class requirements | 321d? | 2011-09-23 A | 2012-12-07 A | 100% | 2011-09-23 | 2012-12-07 | 321d? | finish no earlier than 2012-12-07 | R4 | 2568h | 2568h | medBS_class_LTE_MSR-Perf | 27 | Ericsson | johan.skold@ericsson.com | Rel-11 | 53 | Issam |  | medBS_class_LTE_MSR-Perf | RP-121559 |
| 3181 | 855.3 | GERAN part: E-UTRA medium range and MSR medium range/local area BS class requirements | 261d? | 2011-11-28 A | 2012-11-23 A | 100% | 2011-11-28 | 2012-11-23 | 261d? | finish no earlier than 2012-11-23 | G1 | 2088h | 2088h | medBS_class_LTE_MSR-GERAN | 28 | Ericsson | Eric Nordström | Rel-11 | 52 | Paolo |  | medBS_class_LTE_MSR-GERAN |  |
| 3182 | 856 | **RF Requirements for Multi-Band and Multi-Standard Radio (MB-MSR) Base Station** | 553.1d? | 2012-02-06 A | 2014-03-06 A | 100% | 2012-02-06 | 2014-03-06 | 553.1d? |  | R4; G1 | 20915.2h | 20915.2h | MB_MSR_RF | 28 | Huawei | Liu Ye (leo.liuye@huawei.com) | Rel-11 | 55 | Issam |  | MB_MSR_RF |  |
| 3183 | 856.1 | Core part: RF Requirements for Multi-Band and Multi-Standard Radio (MB-MSR) Base Station | 223.1d? | 2012-02-06 A | 2012-12-07 A | 100% | 2012-02-06 | 2012-12-07 | 223.1d? | finish no earlier than 2012-12-07 | R4; G1 | 3569.6h | 3569.6h | MB_MSR_RF-Core | 28 | Huawei | Liu Ye (leo.liuye@huawei.com) | Rel-11 | 55 | Issam |  | MB_MSR_RF-Core | RP-121985 |
| 3184 | 856.2 | Perf. part: RF Requirements for Multi-Band and Multi-Standard Radio (MB-MSR) Base Station | 531d? | 2012-03-08 A | 2014-03-06 A | 100% | 2012-03-08 | 2014-03-06 | 531d? | finish no earlier than 2014-03-06 | R4; G1 | 8496h | 8496h | MB_MSR_RF-Perf | 28 | Huawei | Liu Ye (leo.liuye@huawei.com) | Rel-11 | 55 | Issam |  | MB_MSR_RF-Perf | RP-140064 |
| 3185 | 857 | **Further enhancements to H(e)NB mobility - Part 1** | 129d? | 2012-06-15 A | 2012-12-07 A | 100% | 2012-06-15 | 2012-12-07 | 129d? |  | R3; R2 | 4128h | 4128h | EHNB_enh1 | 29 | Alcatel-Lucent | Martin.Warner@alcatel-lucent.com | Rel-11 | 56 | Juha | HNB | EHNB_enh1 |  |
| 3186 | 857.1 | Core part: Further enhancements to H(e)NB mobility - Part 1 | 129d? | 2012-06-15 A | 2012-12-07 A | 100% | 2012-06-15 | 2012-12-07 | 129d? | finish no earlier than 2012-12-07 | R3; R2 | 2064h | 2064h | EHNB_enh1-Core | 29 | Alcatel-Lucent | Martin.Warner@alcatel-lucent.com | Rel-11 | 56 | Juha | HNB | EHNB_enh1-Core | RP-121563 |
| 3187 | 858 | **Further enhancements to H(e)NB mobility - Part 2** | 127d? | 2012-06-19 A | 2012-12-07 A | 100% | 2012-06-19 | 2012-12-07 | 127d? |  | R3; R2 | 4064h | 4064h | EHNB_enh2 | 29 | Alcatel-Lucent | Martin.Warner@alcatel-lucent.com | Rel-11 | 56 | Juha | HNB | EHNB_enh2 |  |
| 3188 | 858.1 | Core part: Further enhancements to H(e)NB mobility - Part 2 | 127d? | 2012-06-19 A | 2012-12-07 A | 100% | 2012-06-19 | 2012-12-07 | 127d? | finish no earlier than 2012-12-07 | R3; R2 | 2032h | 2032h | EHNB_enh2-Core | 29 | Alcatel-Lucent | Martin.Warner@alcatel-lucent.com | Rel-11 | 56 | Juha | HNB | EHNB_enh2-Core | RP-121564 |
| 3189 | 859 | **Network-Based Positioning Support for LTE** | 1391d? | 2009-03-05 A | 2014-06-13 A | 100% | 2009-03-05 | 2014-06-13 | 1391d? |  | R2; R1; R3; R4 | 91464h | 91464h | LCS_LTE-NBPS | 22 | TruePosition | terri.brooks@trueposition.com | Rel-11 | 43 | Yong-Jun |  | LCS_LTE-NBPS |  |
| 3190 | 859.1 | Core part: Network-Based Positioning Support for LTE | 1125d? | 2009-03-05 A | 2013-06-12 A | 100% | 2009-03-05 | 2013-06-12 | 1125d? | finish no earlier than 2013-06-12 | R2; R1; R3; R4 | 36000h | 36000h | LCS_LTE-NBPS-Core | 22 | TruePosition | terri.brooks@trueposition.com | Rel-11 | 43 | Yong-Jun |  | LCS_LTE-NBPS-Core | RP-130483 |
| 3191 | 859.2 | Perf. part: Network-Based Positioning Support for LTE | 1377d? | 2009-03-24 A | 2014-06-13 A | 100% | 2009-03-24 | 2014-06-13 | 1377d? | finish no earlier than 2014-06-13 | R4 | 11016h | 11016h | LCS_LTE-NBPS-Perf | 22 | TruePosition | terri.brooks@trueposition.com | Rel-11 | 43 | Yong-Jun |  | LCS_LTE-NBPS-Perf | RP-140626 |
| 3192 | 860 | **Service continuity improvements for MBMS for LTE** | 993d? | 2010-06-04 A | 2014-03-06 A | 100% | 2010-06-04 | 2014-03-06 | 993d? |  | R2; R3; R5 | 35496h | 35496h | MBMS_LTE_SC | 25 | Huawei | David.Lecompte@huawei.com | Rel-11 | 48 | Yong-Jun |  | MBMS_LTE_SC |  |
| 3193 | 860.1 | Core part: Service continuity improvements for MBMS for LTE | 596d? | 2010-06-04 A | 2012-09-07 A | 100% | 2010-06-04 | 2012-09-07 | 596d? | finish no earlier than 2012-09-07 | R2; R3 | 9536h | 9536h | MBMS_LTE_SC-Core | 25 | Huawei | David.Lecompte@huawei.com | Rel-11 | 48 | Yong-Jun |  | MBMS_LTE_SC-Core | RP-121001 |
| 3194 | 860.2 | Test part: Service continuity improvements for MBMS for LTE | 266d? | 2013-03-04 A | 2014-03-06 A | 100% | 2013-03-04 | 2014-03-06 | 266d? | finish no earlier than 2014-03-06 | R5 | 2128h | 2128h | MBMS_LTE_SC-UEConTest | 30 | Ericsson | leif.mattisson@ericsson.com | Rel-11 | 59 | Ingbert |  | MBMS_LTE_SC-UEConTest | RP-140074 |

Notes:
- 3170: Stage 1/2/3 / Impacted TSs and TRs: UTRA, LTE
- 3171: RP#58 completed / Impacted TSs and TRs: 25.331, 25.401, 25.410, 25.413, 25.423, 25.433, 36.300, 36.331, 36.413, 36.423
- 3172: Stage 2/3 / Impacted TSs and TRs: UTRA, LTE
- 3173: RP#58 completed / Impacted TSs and TRs: 25.133, 25.123, 25.304, 25.331, 25.413, 25.423, 36.133, 36.304, 36.306, 36.331, 36.413, 36.423, 37.320, 36.300
- 3174: RP#62 completed / Impacted TSs and TRs: 34.108, 34.109, 34.123-1, 34.123-2, 34.123-3, 36.508, 36.509, 36.523-1, 36.523-2, 36.523-3
- 3175: Stage 2/3 / Impacted TSs and TRs: LTE, GERAN
- 3176: RP#57 completed. Inter-RAT aspect can affect UTRA and GERAN as well / Impacted TSs and TRs: 25.413, 36.300, 36.413, 36.423
- 3177: GP#55 approved WID and completed. Stage 3. ChangES in CP-150RIM protocol and in SON Transfer RIM application to provide support for Energy Savings Indication feature / Impacted TSs and TRs: 48.018 [Serving GPRS Support Node (SGSN); BSS GPRS protocol (BSSGP)]
- 3178: Stage 3. GERAN BS RF requirements specs need aligned with RAN4 ongoing Rel-11 Feature UID_530037 E-UTRA medium range and MSR medium range/local area BS class requirements (medBS_class_LTE_MSR) / Impacted TSs and TRs: UTRA, LTE, GERAN
- 3179: RP#58 completed. TR 37.809 v200 for Approval / Impacted TSs and TRs: 25.104, 36.104, 37.104, new TR 37.809
- 3180: RP#58 completed / Impacted TSs and TRs: 25.141, 36.141, 37.141
- 3181: GP#56 completed. GP#52 approved WID / Impacted TSs and TRs: 45.005, 51.021
- 3182: - / Impacted TSs and TRs: UTRA, LTE, GERAN
- 3183: RP#58 completed / Impacted TSs and TRs: 25.104, 25.105, 36.104, 37.104, new TR 37.812
- 3184: RP#63 completed / Impacted TSs and TRs: 25.141, 25.142, 36.141, 37.141
- 3185: Stage 2/3. Triggered by FS_EHNB_enh (UTRA, LTE TR 37.803 under AI 12.3.2). Compare also Rel-10 WI HNB_HENB_mob_enh RP-110183 / Impacted TSs and TRs: UTRA, LTE
- 3186: RP#58 completed / Impacted TSs and TRs: 25.413, 25.467, 25.469, 36.300, 36.413, 36.423
- 3187: Stage 2/3. Legacy UE Handling (X2-GW, 20% complete, moved to Rel-12 UID_580030). Triggered by FS_EHNB_enh (UTRA, LTE TR 37.803 under AI 12.3.2) / Impacted TSs and TRs: UTRA, LTE
- 3188: RP#58 completed Legacy UE Handling (X2-GW, 20% complete, moved to Rel-12 UID_580030). Updated WID RP-121147=>RP-121712 / Impacted TSs and TRs: 25.413, 25.467, 25.469, 25.471
- 3189: - / Impacted TSs and TRs: LTE
- 3190: RP#60 completed / Impacted TSs and TRs: 36.214, 36.300, 36.305, 36.401, 36.413, 36.455, new TS (36.111, 36.456, 36.457, 36.458, 36.459)
- 3191: RP#64 completed. TS 36.112v100 for 1-step Approval / Impacted TSs and TRs: 36.111, new TS 36.112
- 3192: - / Impacted TSs and TRs: LTE
- 3193: RP#57 completed / Impacted TSs and TRs: 25.446, 36.300, 36.304, 36.321, 36.322, 36.323, 36.331, 36.440, 36.441, 36.442, 36.443, 36.444, 36.445
- 3194: RP#63 completed / Impacted TSs and TRs: 36.508, 36.523-1, 36.523-2, 36.523-3

| ID | WBS | Task | Duration | Start | Finish | Complete | Baseline start | Baseline finish | Baseline duration | Constraint | Resources | Work | Actual work | Acronym | PCG approved | WI rapporteur name | WI rapporteur e-mail | Release | TSG approved | MCC resp | Acronym_3GU_Export | Status Report | Special Focus Doc |
| --- | --- | --- | --- | --- | --- | --- | --- | --- | --- | --- | --- | --- | --- | --- | --- | --- | --- | --- | --- | --- | --- | --- | --- |
| 3195 | 861 | **Further Enhanced Non CA-based ICIC for LTE** | 991d? | 2011-03-22 A | 2014-12-15 A | 100% | 2011-03-22 | 2014-09-12 | 922d? |  | R1; R2; R3; R4; R5 | 63112h | 63112h | eICIC_enh_LTE | 26 | China Mobile | ShenXiaodong@chinamobile.com | Rel-11 | 51 | Patrick | eICIC_enh_LTE |  |  |
| 3196 | 861.1 | Core part: Further Enhanced Non CA-based ICIC for LTE | 456d? | 2011-03-22 A | 2012-12-07 A | 100% | 2011-03-22 | 2012-12-07 | 456d? | finish no earlier than 2012-12-07 | R1; R2; R3; R4 | 14592h | 14592h | eICIC_enh_LTE-Core | 26 | China Mobile | ShenXiaodong@chinamobile.com | Rel-11 | 51 | Patrick | eICIC_enh_LTE-Core | RP-121986 |  |
| 3197 | 861.2 | Perf. part: Further Enhanced Non CA-based ICIC for LTE | 715d? | 2011-03-23 A | 2013-12-06 A | 100% | 2011-03-23 | 2013-12-06 | 715d? | finish no earlier than 2013-12-06 | R4 | 5720h | 5720h | eICIC_enh_LTE-Perf | 26 | China Mobile | ShenXiaodong@chinamobile.com | Rel-11 | 51 | Issam | eICIC_enh_LTE-Perf | RP-131463 |  |
| 3198 | 861.3 | Test part: Further Enhanced Non CA-based ICIC for LTE | 395d? | 2013-06-15 A | 2014-12-15 A | 100% | 2013-06-18 | 2014-09-12 | 326d? | finish no earlier than 2014-12-15 | R5 | 3160h | 3160h | eICIC_enh_LTE-UEConTest | 31 | ZTE | Carolyn Taylor (carolyn.tayl@zte.com.cn) | Rel-11 | 60 | Ingbert | eICIC_enh_LTE-UEConTest | RP-141847 |  |
| 3199 | 862 | **New Band LTE Downlink FDD 716-728 MHz (Band 29, Carrier Aggregation of Band 2 and Band 29 and of Band 4 and Band 29)** | 456d? | 2011-03-22 A | 2012-12-07 A | 100% | 2011-03-22 | 2012-12-07 | 456d? |  | R4 | 10880h | 10880h | LTE_DL_FDD700 | 26 | AT&T | marc.grant@att.com | Rel-11 | 51 | Issam | LTE_DL_FDD700 |  | CA |
| 3200 | 862.1 | Core part: New Band LTE Downlink FDD 716-728 MHz (Band 29), Carrier Aggregation of Band 2 and Band 29 and of Band 4 and Band 29 | 453d? | 2011-03-22 A | 2012-12-07 A | 100% | 2011-03-22 | 2012-12-07 | 453d? | finish no earlier than 2012-12-07 | R4 | 3624h | 3624h | LTE_DL_FDD700-Core | 26 | AT&T | marc.grant@att.com | Rel-11 | 51 | Issam | LTE_DL_FDD700-Core | RP-121604 |  |
| 3201 | 862.2 | Perf. part: New Band LTE Downlink FDD 716-728 MHz (Band 29), Carrier Aggregation of Band 2 and Band 29 and of Band 4 and Band 29 | 451d? | 2011-03-29 A | 2012-12-07 A | 100% | 2011-03-29 | 2012-12-07 | 451d? | finish no earlier than 2012-12-07 | R4 | 3608h | 3608h | LTE_DL_FDD700-Perf | 26 | AT&T | marc.grant@att.com | Rel-11 | 51 | Issam | LTE_DL_FDD700-Perf | RP-121605 |  |
| 3202 | 863 | **LTE RAN Enhancements for Diverse Data Applications** | 657d? | 2011-03-18 A | 2013-09-06 A | 100% | 2011-03-18 | 2013-09-06 | 657d? |  | R2; R5 | 15248h | 15248h | LTE_eDDA | 26 | BlackBerry | Gordon Young (gyoung@rim.com) | Rel-11 | 51 | Yong-Jun | LTE_eDDA |  |  |
| 3203 | 863.1 | Core part: LTE RAN Enhancements for Diverse Data Applications | 456d? | 2011-03-18 A | 2012-12-07 A | 100% | 2011-03-18 | 2012-12-07 | 456d? | finish no earlier than 2012-12-07 | R2 | 3648h | 3648h | LTE_eDDA-Core | 26 | BlackBerry | Gordon Young (gyoung@rim.com) | Rel-11 | 51 | Yong-Jun | LTE_eDDA-Core | RP-121571 |  |
| 3204 | 863.2 | Test part: LTE RAN Enhancements for Diverse Data Applications | 136d? | 2013-03-04 A | 2013-09-06 A | 100% | 2013-03-04 | 2013-09-06 | 136d? | finish no earlier than 2013-09-06 | R5 | 1088h | 1088h | LTE_eDDA-UEConTest | 30 | BlackBerry | Enikő Sokondár (esokondar@rim.com) | Rel-11 | 59 | Ingbert | LTE_eDDA-UEConTest | RP-130946 |  |
| 3205 | 864 | **LTE E850 - Lower Band for Region 2 (non-US), Band 27** | 516d? | 2011-03-23 A | 2013-03-01 A | 100% | 2011-03-23 | 2013-03-01 | 516d? |  | R1; R2; R4; R5 | 28496h | 28496h | LTE_e850_LB | 26 | NII Holdings | bill.shvodian@nii.com | Rel-11 | 51 | Patrick | LTE_e850_LB |  |  |
| 3206 | 864.1 | Core part: LTE E850 - Lower Band for Region 2 (non-US), Band 27 | 328d? | 2011-06-15 A | 2012-09-07 A | 100% | 2011-06-15 | 2012-09-07 | 328d? | finish no earlier than 2012-09-07 | R1; R2; R4 | 7872h | 7872h | LTE_e850_LB-Core | 26 | NII Holdings | bill.shvodian@nii.com | Rel-11 | 51 | Patrick | LTE_e850_LB-Core | RP-120570 |  |
| 3207 | 864.2 | Perf. part: LTE E850 - Lower Band for Region 2 (non-US), Band 27 | 326d? | 2011-03-23 A | 2012-06-15 A | 100% | 2011-03-23 | 2012-06-15 | 326d? | finish no earlier than 2012-12-07 | R4 | 2608h | 2608h | LTE_e850_LB-Perf | 26 | NII Holdings | bill.shvodian@nii.com | Rel-11 | 51 | Issam | LTE_e850_LB-Perf | RP-120571 |  |
| 3208 | 864.3 | Test part: LTE E850 - Lower Band for Region 2 (non-US), Band 27 | 189d? | 2012-06-18 A | 2013-03-01 A | 100% | 2012-06-18 | 2013-03-01 | 189d? | finish no earlier than 2013-03-01 | R5 | 1504h | 1504h | LTE_e850_LB-UEConTest | 29 | NII Holdings | bill.shvodian@nii.com | Rel-11 | 56 | Ingbert | LTE_e850_LB-UEConTest | RP-130045 |  |
| 3209 | 865 | **LTE for 700 MHz Digital Dividend** | 538d? | 2011-06-07 A | 2013-06-14 A | 100% | 2011-06-07 | 2013-06-14 | 538d? |  | R4; R2; R3; R5 | 28032h | 28032h | LTE_APAC700 | 27 | Ericsson | olav.queseth@ericsson.com | Rel-11 | 52 | Issam | LTE_APAC700 |  |  |
| 3210 | 865.1 | Core part: LTE for 700 MHz Digital Dividend | 273d? | 2011-06-07 A | 2012-06-15 A | 100% | 2011-06-07 | 2012-06-15 | 273d? | finish no earlier than 2012-06-15 | R4; R2; R3 | 6552h | 6552h | LTE_APAC700-Core | 27 | Ericsson | olav.queseth@ericsson.com | Rel-11 | 52 | Issam | LTE_APAC700-Core | RP-120572 |  |
| 3211 | 865.2 | Perf. part: LTE for 700 MHz Digital Dividend | 271d? | 2011-06-09 A | 2012-06-15 A | 100% | 2011-06-09 | 2012-06-15 | 271d? | finish no earlier than 2012-06-15 | R4 | 2168h | 2168h | LTE_APAC700-Perf | 27 | Ericsson | olav.queseth@ericsson.com | Rel-11 | 52 | Issam | LTE_APAC700-Perf | RP-120573 |  |
| 3212 | 865.3 | Test part: LTE for 700 MHz Digital Dividend | 262d? | 2012-06-18 A | 2013-06-14 A | 100% | 2012-06-18 | 2013-06-14 | 262d? | finish no earlier than 2013-06-14 | R5 | 2096h | 2096h | LTE_APAC700-UEConTest | 29 | Ericsson | fredrik.sundstrom@ericsson.com | Rel-11 | 56 | Ingbert | LTE_APAC700-UEConTest | RP-130467 |  |
| 3213 | 866 | **Relays for LTE (part 2)** | 930d? | 2009-12-04 A | 2013-06-14 A | 100% | 2009-12-04 | 2013-06-14 | 930d? |  | R4 | 17496.4h | 17496.4h | LTE_Relay2 | 24 | Ericsson | christian.hoymann@ericsson.com | Rel-11 | 46 | Patrick | LTE_Relay2 |  |  |
| 3214 | 866.1 | Core part: Relays for LTE (part 2) | 333d? | 2011-06-07 A | 2012-09-07 A | 100% | 2011-06-07 | 2012-09-07 | 333d? | finish no earlier than 2012-09-07 | R4 | 2656.39h | 2656.39h | LTE_Relay2-Core | 27 | Ericsson | christian.hoymann@ericsson.com | Rel-11 | 52 | Issam | LTE_Relay2-Core | RP-121008 |  |
| 3215 | 866.2 | Perf. part: Relays for LTE (part 2) | 925d? | 2009-12-04 A | 2013-06-14 A | 100% | 2009-12-04 | 2013-06-14 | 925d? | finish no earlier than 2013-06-14 | R4 | 7400h | 7400h | LTE_Relay2-Perf | 24 | Ericsson | christian.hoymann@ericsson.com | Rel-11 | 46 | Issam | LTE_Relay2-Perf | RP-130487 |  |
| 3216 | 867 | **Signalling and Procedure for Interference Avoidance for in-device coexistence** | 325d? | 2011-09-19 A | 2012-12-07 A | 100% | 2011-09-19 | 2012-12-07 | 325d? |  | R2; R4 | 12976h | 12976h | SPIA_IDC_LTE | 27 | China Mobile | Zhenping HU | Rel-11 | 53 | Yong-Jun | SPIA_IDC_LTE |  |  |
| 3217 | 867.1 | Core part: Signalling and Procedure for Interference Avoidance for in-device coexistence | 325d? | 2011-09-19 A | 2012-12-07 A | 100% | 2011-09-19 | 2012-12-07 | 325d? | finish no earlier than 2012-12-07 | R2; R4 | 5200h | 5200h | SPIA_IDC_LTE-Core | 27 | China Mobile | Zhenping HU | Rel-11 | 53 | Yong-Jun | SPIA_IDC_LTE-Core | RP-121573 |  |
| 3218 | 867.2 | Perf. part: Signalling and Procedure for Interference Avoidance for in-device coexistence | 322d? | 2011-09-20 A | 2012-12-07 A | 100% | 2011-09-20 | 2012-12-07 | 322d? | finish no earlier than 2012-12-07 | R4 | 2576h | 2576h | SPIA_IDC_LTE-Perf | 27 | China Mobile | Zhenping HU | Rel-11 | 53 | Issam | SPIA_IDC_LTE-Perf | RP-121574 |  |

Notes:
- 3195: - / Impacted TSs and TRs: LTE
- 3196: RP#58 completed / Impacted TSs and TRs: 36.101, 36.133, 36.201, 36.211, 36.212, 36.213, 36.214, 36.300, 36.304, 36.321, 36.331, 36.413, 36.423
- 3197: RP#62 completed / Impacted TSs and TRs: 36.101, 36.104, 36.133, 36.141
- 3198: ; Stat Rep: RP-141131->RP-141847 / Impacted TSs and TRs: 36.508, 36.521-1, 36.521-2, 36.521-3, 36.523-1, 36.523-2, 36.523-3
- 3199: Stage 3 / Impacted TSs and TRs: LTE
- 3200: RP#58 completed / Impacted TSs and TRs: 36.101, 36.104, 36.141, 36.307
- 3201: RP#58 completed / Impacted TSs and TRs: 36.101, 36.104, 36.133, 36.141, 36.307
- 3202: Stage 2/3 / Impacted TSs and TRs: LTE
- 3203: RP#58 completed / Impacted TSs and TRs: 36.300, 36.321, 36.331, new TR 36.822
- 3204: RP#61 completed / Impacted TSs and TRs: 36.523-1, 36.523-2, 36.523-3
- 3205: Stage 3 / Impacted TSs and TRs: LTE
- 3206: RP#56 completed / Impacted TSs and TRs: 25.101, 25.104, 25.461, 25.466, 36.101, 36.104, 36.113, 36.124, 36.307, 37.104, 37.113
- 3207: RP#56 completed / Impacted TSs and TRs: 25.123, 25.133, 25.141, 36.133, 36.141, 37.141
- 3208: RP#59 completed / Impacted TSs and TRs: 36.508, 36.521-1, 36.521-2, 36.521-3, 36.523-2, 36.523-3, 37.571-1
- 3209: Stage 3. Asian Pacific American Caucus (APAC) Asia-Pacific Telecommunity (APT) Wireless Forum / Impacted TSs and TRs: LTE
- 3210: RP#56 completed. TR 36.820 v100 for Information and Approval / Impacted TSs and TRs: 25.461, 25.466, 36.101, 36.104, 36.113, 36.124, 36.133, 36.307, 37.104, 37.113, new TR 36.820
- 3211: RP#56 completed / Impacted TSs and TRs: 36.133, 36.141, 37.141
- 3212: RP#60 completed / Impacted TSs and TRs: 36.508, 36.521-1, 36.521-2, 36.521-3, 36.523-2, 36.523-3, 37.571-1
- 3213: Continuation of Rel-10 (open RAN4 Core & Perf parts) / Impacted TSs and TRs: LTE
- 3214: RP#57 completed. TS 36.116, TR 36.826 v100 for Information & Approval. RP#52 Core part not completed in Rel-10 / Impacted TSs and TRs: 36.133, new RAN4 (36.116, 36.826)
- 3215: RP#60 completed. New TS 36.117 v100 for 1-step Approval. RP#52 transferred completely from Rel-10 UID_460213 / Impacted TSs and TRs: 36.133, new TS 36.117 (E-UTRA Relay conformance testing)
- 3216: Stage 2/3 / Impacted TSs and TRs: LTE
- 3217: RP#58 completed / Impacted TSs and TRs: 36.133, 36.300, 36.306, 36.321, 36.331
- 3218: RP#58 completed / Impacted TSs and TRs: 36.133

| ID | WBS | Task | Duration | Start | Finish | Complete | Baseline start | Baseline finish | Baseline duration | Constraint | Resources | Work | Actual work | Acronym | PCG approved | WI rapporteur name | Release | TSG approved | MCC resp | Acronym_3GU_Export | Status Report | Special Focus Doc |
| --- | --- | --- | --- | --- | --- | --- | --- | --- | --- | --- | --- | --- | --- | --- | --- | --- | --- | --- | --- | --- | --- | --- |
| 3219 | 868 | **Coordinated Multi-Point Operation for LTE** | 860d? | 2011-09-19 A | 2014-12-15 A | 100% | 2011-09-19 | 2014-09-12 | 791d? |  | R1; R2; R3; R4; R5 | 66128h | 66128h | COMP_LTE | 27 | Huawei, Samsung | Rel-11 | 53 | Patrick | COMP_LTE |  |  |
| 3220 | 868.1 | Core part: Coordinated Multi-Point Operation for LTE – Uplink | 325d? | 2011-09-19 A | 2012-12-07 A | 100% | 2011-09-19 | 2012-12-07 | 325d? | finish no earlier than 2012-12-07 | R1; R2; R3; R4 | 10400h | 10400h | COMP_LTE_UL-Core | 27 | Huawei | Rel-11 | 53 | Patrick | COMP_LTE_UL-Core | RP-121575 |  |
| 3221 | 868.2 | Perf. part: Coordinated Multi-Point Operation for LTE – Uplink | 321d? | 2011-09-23 A | 2012-12-07 A | 100% | 2011-09-23 | 2012-12-07 | 321d? | finish no earlier than 2012-12-07 | R4 | 2568h | 2568h | COMP_LTE_UL-Perf | 27 | Huawei | Rel-11 | 53 | Issam | COMP_LTE_UL-Perf | RP-121576 |  |
| 3222 | 868.3 | Core part: Coordinated Multi-Point Operation for LTE – Downlink | 325d? | 2011-09-19 A | 2012-12-07 A | 100% | 2011-09-19 | 2012-12-07 | 325d? | finish no earlier than 2012-12-07 | R1; R2; R3; R4 | 10400h | 10400h | COMP_LTE_DL-Core | 27 | Samsung | Rel-11 | 53 | Patrick | COMP_LTE_DL-Core | RP-121577 |  |
| 3223 | 868.4 | Perf. part: Coordinated Multi-Point Operation for LTE – Downlink | 582d? | 2011-09-23 A | 2013-12-06 A | 100% | 2011-09-23 | 2013-12-06 | 582d? | finish no earlier than 2013-12-06 | R4 | 4656h | 4656h | COMP_LTE_DL-Perf | 27 | Samsung | Rel-11 | 53 | Issam | COMP_LTE_DL-Perf | RP-131465 |  |
| 3224 | 868.5 | Test part: Coordinated Multi-Point Operation for LTE | 463d? | 2013-03-15 A | 2014-12-15 A | 100% | 2013-03-04 | 2014-09-12 | 404d? | finish no earlier than 2014-12-15 | R5 | 3704h | 3704h | COMP_LTE-UEConTest | 30 | Samsung | Rel-11 | 59 | Ingbert | COMP_LTE-UEConTest | RP-141782 |  |
| 3225 | 869 | **Enhanced downlink control channel(s) for LTE Advanced** | 732d? | 2011-12-09 A | 2014-09-12 A | 100% | 2011-12-09 | 2014-09-12 | 731d? |  | R1; R2; R4; R5 | 38272h | 38272h | LTE_enh_dl_ctrl | 28 | Alcatel-Lucent | Rel-11 | 54 | Patrick | LTE_enh_dl_ctrl |  |  |
| 3226 | 869.1 | Core part: Enhanced downlink control channel(s) for LTE Advanced | 265d? | 2011-12-09 A | 2012-12-07 A | 100% | 2011-12-09 | 2012-12-07 | 265d? | finish no earlier than 2012-12-07 | R1; R2; R4 | 6360h | 6360h | LTE_enh_dl_ctrl-Core | 28 | Alcatel-Lucent | Rel-11 | 54 | Patrick | LTE_enh_dl_ctrl-Core | RP-121579 |  |
| 3227 | 869.2 | Perf. part: Enhanced downlink control channel(s) for LTE Advanced | 659d? | 2011-12-16 A | 2014-06-13 A | 100% | 2011-12-16 | 2014-06-13 | 659d? | finish no earlier than 2014-06-13 | R4 | 5272h | 5272h | LTE_enh_dl_ctrl-Perf | 28 | Alcatel-Lucent | Rel-11 | 54 | Issam | LTE_enh_dl_ctrl-Perf | RP-140651 |  |
| 3228 | 869.3 | Test part: Enhanced downlink control channel(s) for LTE Advanced | 402d? | 2013-03-04 A | 2014-09-12 A | 100% | 2013-03-04 | 2014-09-12 | 402d? | finish no earlier than 2014-09-12 | R5 | 3216h | 3216h | LTE_enh_dl_ctrl-UEConTest | 30 | Huawei | Rel-11 | 59 | Ingbert | LTE_enh_dl_ctrl-UEConTest | RP-141256 |  |
| 3229 | 870 | **Public Safety Broadband High Power UE for Band 14 for Region 2** | 403d? | 2012-03-05 A | 2013-09-06 A | 100% | 2012-03-05 | 2013-09-06 | 403d? |  | R4; R5 | 9144h | 9144h | LTE_B14_PSBB_HPUE | 28 | Motorola Solutions | Rel-11 | 55 | Issam | LTE_B14_PSBB_HPUE |  | Public Safety (A-A) |
| 3230 | 870.1 | Core part: Public Safety Broadband High Power UE for Band 14 for Region 2 | 201d? | 2012-03-05 A | 2012-12-07 A | 100% | 2012-03-05 | 2012-12-07 | 201d? | finish no earlier than 2012-12-07 | R4 | 1608h | 1608h | LTE_B14_PSBB_HPUE-Core | 28 | Motorola Solutions | Rel-11 | 55 | Issam | LTE_B14_PSBB_HPUE-Core | RP-121581 | Public Safety (A-A) |
| 3231 | 870.2 | Test part: Public Safety Broadband High Power UE for Band 14 for Region 2 | 138d? | 2013-03-04 A | 2013-09-06 A | 100% | 2013-03-04 | 2013-09-06 | 138d? | finish no earlier than 2013-09-06 | R5 | 1088h | 1088h | LTE_B14_PSBB_HPUE-UEConTest | 30 | Motorola Solutions | Rel-11 | 59 | Ingbert | LTE_B14_PSBB_HPUE-UEConTest | RP-130949 | Public Safety (A-A) |
| 3232 | 871 | **Improved Minimum Performance Requirements for E-UTRA: Interference Rejection** | 671d? | 2012-03-05 A | 2014-09-12 A | 100% | 2012-03-05 | 2014-09-12 | 670d? |  | R4; R5 | 14952h | 14952h | LTE_Interf_Rej | 28 | Renesas Mobile | Rel-11 | 55 | Issam | LTE_Interf_Rej |  |  |
| 3233 | 871.1 | Perf. part: Improved Minimum Performance Requirements for E-UTRA: Interference Rejection | 201d? | 2012-03-05 A | 2012-12-07 A | 100% | 2012-03-05 | 2012-12-07 | 201d? | finish no earlier than 2012-12-07 | R4 | 1608h | 1608h | LTE_Interf_Rej-Perf | 28 | Renesas Mobile | Rel-11 | 55 | Issam | LTE_Interf_Rej-Perf | RP-121582 |  |
| 3234 | 871.2 | Test part: Improved Minimum Performance Requirements for E-UTRA: Interference Rejection | 327d? | 2013-06-18 A | 2014-09-12 A | 100% | 2013-06-18 | 2014-09-12 | 327d? | finish no earlier than 2014-09-12 | R5 | 2608h | 2608h | LTE_Interf_Rej-UEConTest | 31 | Broadcom | Rel-11 | 60 | Ingbert | LTE_Interf_Rej-UEConTest | RP-141602 |  |
| 3235 | 872 | **Additional special subframe configuration for LTE TDD** | 341d? | 2012-03-05 A | 2013-06-14 A | 100% | 2012-03-05 | 2013-06-14 | 341d? |  | R4; R2; R3; R5 | 14808h | 14808h | LTE_TDD_add_subframe | 28 | China Mobile | Rel-11 | 55 | Issam | LTE_TDD_add_subframe |  |  |
| 3236 | 872.1 | Core part: Additional special subframe configuration for LTE TDD | 137d? | 2012-03-05 A | 2012-09-07 A | 100% | 2012-03-05 | 2012-09-07 | 137d? | finish no earlier than 2012-09-07 | R4; R2; R3 | 3288h | 3288h | LTE_TDD_add_subframe-Core | 28 | China Mobile | Rel-11 | 55 | Issam | LTE_TDD_add_subframe-Core | RP-121019 |  |
| 3237 | 872.2 | Test part: Additional special subframe configuration for LTE TDD | 76d? | 2013-03-04 A | 2013-06-14 A | 100% | 2013-03-04 | 2013-06-14 | 76d? | finish no earlier than 2013-09-13 | R5 | 608h | 608h | LTE_TDD_add_subframe-UEConTest | 30 | Huawei | Rel-11 | 59 | Ingbert | LTE_TDD_add_subframe-UEConTest | RP-130475 |  |
| 3238 | 873 | **Rel-11 LTE Carrier Aggregation** | 1062d? | 2010-12-10 A | 2014-12-15 A | 100% | 2010-12-10 | 2014-12-05 | 1054d? |  | R1; R2; R3; R4; R5 | 315760h | 315760h | LTE_CA_Rel-11 | 30 |  | Rel-11 | 58 | Patrick | LTE_CA_Rel-11 |  | CA |
| 3239 | 873.1 | **LTE Carrier Aggregation Enhancements** | 995d? | 2011-03-15 A | 2014-12-15 A | 100% | 2011-03-22 | 2014-12-05 | 982d? |  | R1; R2; R3; R4; R5 | 70824h | 70824h | LTE_CA_enh | 26 | Nokia | Rel-11 | 51 | Patrick | LTE_CA_enh |  | CA |
| 3240 | 873.1.1 | Core part: LTE Carrier Aggregation Enhancements | 646.25d? | 2011-03-22 A | 2013-08-27 A | 100% | 2011-03-22 | 2013-03-01 | 517d? | finish no earlier than 2013-03-01 | R1; R2; R4; R3 | 20680h | 20680h | LTE_CA_enh-Core | 26 | Nokia | Rel-11 | 51 | Patrick | LTE_CA_enh-Core | RP-130059 | CA |
| 3241 | 873.1.2 | Perf. part: LTE Carrier Aggregation Enhancements | 994d? | 2011-03-15 A | 2014-12-15 A | 100% | 2011-03-29 | 2014-12-05 | 977d? | finish no earlier than 2014-12-15 | R4 | 7936h | 7936h | LTE_CA_enh-Perf | 26 | Nokia | Rel-11 | 51 | Issam | LTE_CA_enh-Perf | RP-141969 | CA |
| 3242 | 873.1.3 | Test part: LTE Carrier Aggregation Enhancements | 326d? | 2013-06-18 A | 2014-09-12 A | 100% | 2013-06-18 | 2014-09-12 | 326d? | finish no earlier than 2014-09-12 | R5 | 2608h | 2608h | LTE_CA_enh-UEConTest | 31 | Microsoft | Rel-11 | 60 | Ingbert | LTE_CA_enh-UEConTest | RP-141443 | CA |
| 3243 | 873.2 | UE Conformance Test Aspects – LTE Advanced Carrier Aggregation of Intra-band contiguous and Inter-band configurations | 329d? | 2012-09-11 A | 2013-12-06 A | 100% | 2012-09-11 | 2013-12-06 | 329d? | finish no earlier than 2013-12-06 | R5 | 2624h | 2624h | LTE_CA_intraC_inter_UEConTest | 29 | Nokia | Rel-11 | 57 | Ingbert | LTE_CA_intraC_inter_UEConTest | RP-131446 | CA |

Notes:
- 3219: Stage 3. Triggered by Rel-11 TR 36.819 Study on Coordinated Multi-Point Operation for LTE (FS_CoMP_LTE) / Impacted TSs and TRs: LTE / WI rapporteur e-mail: Juho Lee (juho95.lee@samsung.com), david.mazzarese@huawei.com
- 3220: RP#58 completed / Impacted TSs and TRs: 36.101, 36.104, 36.133, 36.201, 36.211, 36.212, 36.213, 36.214, 36.300, 36.306, 36.321, 36.331, 36.423 / WI rapporteur e-mail: david.mazzarese@huawei.com
- 3221: RP#58 completed / Impacted TSs and TRs: 36.101, 36.104, 36.133, 36.141 / WI rapporteur e-mail: Xinwei Zhi (zhixinwei@huawei.com)
- 3222: RP#58 completed / Impacted TSs and TRs: 36.101, 36.104, 36.133, 36.201, 36.211, 36.212, 36.213, 36.214, 36.300, 36.306, 36.321, 36.331, 36.423 / WI rapporteur e-mail: Juho Lee (juho95.lee@samsung.com)
- 3223: RP#62 completed / Impacted TSs and TRs: 36.101, 36.104, 36.133, 36.141, 36.307 / WI rapporteur e-mail: xutao.zhou@samsung.com
- 3224: Impacted TSs and TRs: 36.508, 36.521-1, 36.521-2, 36.523-1, 36.523-2, 36.523-3 / WI rapporteur e-mail: Stoyan.Baev@partner.samsung.com
- 3225: Stage 3. RP#58 Core completed. Triggered by UID_510037 Rel-11 TR 36.871 Study on further Downlink MIMO enhancements for LTE-Advanced (FS_LTE_eDL_MIMO_enh) / Impacted TSs and TRs: LTE / WI rapporteur e-mail: sigen.ye@alcatel-lucent.com
- 3226: RP#58 completed / Impacted TSs and TRs: 36.101, 36.211, 36.212, 36.213, 36.331 / WI rapporteur e-mail: sigen.ye@alcatel-lucent.com
- 3227: RP#64 completed / Impacted TSs and TRs: 36.101, 36.104, 36.133, 36.141 / WI rapporteur e-mail: teck.hu@alcatel-lucent.com
- 3228: RP#65 completed / Impacted TSs and TRs: 36.508, 36.521-1, 36.521-2, 36.523-1, 36.523-2, 36.523-3 / WI rapporteur e-mail: Xu Kai (xk.xukai@huawei.com)
- 3229: Stage 3 / Impacted TSs and TRs: LTE / WI rapporteur e-mail: xiaowei.jin@motorolasolutions.com
- 3230: RP#58 completed. TR 36.837 v100 for Information and Approval / Impacted TSs and TRs: 36.101, new TR 36.837 / WI rapporteur e-mail: xiaowei.jin@motorolasolutions.com
- 3231: RP#61 completed / Impacted TSs and TRs: 36.521-1, 36.521-2 / WI rapporteur e-mail: xiaowei.jin@motorolasolutions.com
- 3232: RP#58 completed. Triggered by FS_enh_perf_UE_LTE. Adds Perf. requirements for demodulation of the already specified PDSCH with the transmission modes defined in Rel-8 to Rel-10 / Impacted TSs and TRs: LTE / WI rapporteur e-mail: Timo Roman
- 3233: RP#58 completed / Impacted TSs and TRs: 36.101 / WI rapporteur e-mail: Timo Roman
- 3234: RP#65 completed. TR 36.904 for 1-step Approval. Testing for 36.101 / Impacted TSs and TRs: 36.508, 36.521-1, 36.521-2, New TR 36.904 / WI rapporteur e-mail: jarkko.hellsten@kolumbus.fi
- 3235: Stage 3. Exists already for 1UL a WI LTE_CA_B3_B5 / Impacted TSs and TRs: LTE / WI rapporteur e-mail: Xiaodong Shen
- 3236: RP#57 completed / Impacted TSs and TRs: 36.211, 36.213, 36.331, 36.423 / WI rapporteur e-mail: Xiaodong Shen
- 3237: RP#60 completed / Impacted TSs and TRs: 36.508, 36.523-1, 36.523-2, 36.523-3 / WI rapporteur e-mail: Li Xiang (tricia.li@huawei.com)
- 3238: LTE_CA_Rel-11 / Impacted TSs and TRs: LTE
- 3239: Stage 3 / Impacted TSs and TRs: LTE / WI rapporteur e-mail: lars.e.lindh@nokia.com
- 3240: RP#59 completed. New TR 36.823 v100 for Information and Approval / Impacted TSs and TRs: 36.101, 36.104, 36.133, 36.201, 36.211, 36.212, 36.213, 36.300, 36.302, 36.306, 36.321, 36.331, 36.413, 36.423, new TR 36.823 / WI rapporteur e-mail: lars.e.lindh@nokia.com
- 3241: ; Stat Rep: RP-141377->RP-141969 / Impacted TSs and TRs: 36.101, 36.104, 36.133, 36.141 / WI rapporteur e-mail: lars.e.lindh@nokia.com
- 3242: SP#65 completed / Impacted TSs and TRs: 36.508, 36.521-1, 36.521-2, 36.521-3, 36.523-1, 36.523-2, 36.523-3 / WI rapporteur e-mail: jussi.kuusisto@microsoft.com
- 3243: RP#62 completed / Impacted TSs and TRs: 36.508, 36.521-1, 36.521-2, 36.521-3, 36.523-1, 36.523-2, 36.523-3, 37.571-1 / WI rapporteur e-mail: jussi.kuusisto@nokia.com

| ID | WBS | Task | Duration | Start | Finish | Complete | Baseline start | Baseline finish | Baseline duration | Constraint | Resources | Work | Actual work | PCG approved | Release | TSG approved | MCC resp | Special Focus Doc | Acronym | WI rapporteur name | WI rapporteur e-mail | Acronym_3GU_Export | Status Report |
| --- | --- | --- | --- | --- | --- | --- | --- | --- | --- | --- | --- | --- | --- | --- | --- | --- | --- | --- | --- | --- | --- | --- | --- |
| 3244 | 873.3 | **Rel-11 inter-band Carrier Aggregation** | 528d? | 2010-12-10 A | 2012-12-07 A | 100% | 2010-12-10 | 2012-12-07 | 528d? |  | R4 | 180968h | 180968h | 30 | Rel-11 | 58 | Issam | CA |  |  |  |  |  |
| 3245 | 873.3.1 | **LTE Advanced Carrier Aggregation of Band 3 and Band 7** | 528d? | 2010-12-10 A | 2012-12-07 A | 100% | 2010-12-10 | 2012-12-07 | 528d? |  | R4 | 12040h | 12040h | 25 | Rel-11 | 48 | Issam | CA | LTE_CA_B3_B7 | TeliaSonera | Ralf.Schuh@TeliaSonera.com | LTE_CA_B3_B7 |  |
| 3246 | 873.3.1.1 | Core part: LTE Advanced Carrier Aggregation of Band 3 and Band 7 | 456d? | 2010-12-10 A | 2012-09-07 A | 100% | 2010-12-10 | 2012-09-07 | 456d? | finish no earlier than 2012-09-07 | R4 | 3648h | 3648h | 25 | Rel-11 | 48 | Issam | CA | LTE_CA_B3_B7-Core | TeliaSonera | Ralf.Schuh@TeliaSonera.com | LTE_CA_B3_B7-Core | RP-121022 |
| 3247 | 873.3.1.2 | Perf. part: LTE Advanced Carrier Aggregation of Band 3 and Band 7 | 523d? | 2010-12-17 A | 2012-12-07 A | 100% | 2010-12-17 | 2012-12-07 | 523d? | finish no earlier than 2012-12-07 | R4 | 4168h | 4168h | 25 | Rel-11 | 48 | Issam | CA | LTE_CA_B3_B7-Perf | TeliaSonera | Ralf.Schuh@TeliaSonera.com | LTE_CA_B3_B7-Perf | RP-121023 |
| 3248 | 873.3.2 | **LTE Advanced Carrier Aggregation of Band 4 and Band 17** | 528d? | 2010-12-10 A | 2012-12-07 A | 100% | 2010-12-10 | 2012-12-07 | 528d? |  | R4 | 12064h | 12064h | 26 | Rel-11 | 50 | Issam | CA | LTE_CA_B4_B17 | AT&T | marc.grant@att.com | LTE_CA_B4_B17 |  |
| 3249 | 873.3.2.1 | Core part: LTE Advanced Carrier Aggregation of Band 4 and Band 17 | 459d? | 2010-12-10 A | 2012-09-07 A | 100% | 2010-12-10 | 2012-09-07 | 459d? | finish no earlier than 2012-09-07 | R4 | 3672h | 3672h | 26 | Rel-11 | 50 | Issam | CA | LTE_CA_B4_B17-Core | AT&T | marc.grant@att.com | LTE_CA_B4_B17-Core | RP-121024 |
| 3250 | 873.3.2.2 | Perf. part: LTE Advanced Carrier Aggregation of Band 4 and Band 17 | 521d? | 2010-12-17 A | 2012-12-07 A | 100% | 2010-12-17 | 2012-12-07 | 521d? | finish no earlier than 2012-12-07 | R4 | 4168h | 4168h | 26 | Rel-11 | 50 | Issam | CA | LTE_CA_B4_B17-Perf | AT&T | marc.grant@att.com | LTE_CA_B4_B17-Perf | RP-121595 |
| 3251 | 873.3.3 | **LTE Advanced Carrier Aggregation of Band 4 and Band 13** | 528d? | 2010-12-10 A | 2012-12-07 A | 100% | 2010-12-10 | 2012-12-07 | 528d? |  | R4 | 12040h | 12040h | 26 | Rel-11 | 50 | Issam | CA | LTE_CA_B4_B13 | Ericsson | christian.bergljung@ericsson.com | LTE_CA_B4_B13 |  |
| 3252 | 873.3.3.1 | Core part: LTE Advanced Carrier Aggregation of Band 4 and Band 13 | 456d? | 2010-12-10 A | 2012-09-07 A | 100% | 2010-12-10 | 2012-09-07 | 456d? | finish no earlier than 2012-09-07 | R4 | 3648h | 3648h | 26 | Rel-11 | 50 | Issam | CA | LTE_CA_B4_B13-Core | Ericsson | christian.bergljung@ericsson.com | LTE_CA_B4_B13-Core | RP-121026 |
| 3253 | 873.3.3.2 | Perf. part: LTE Advanced Carrier Aggregation of Band 4 and Band 13 | 521d? | 2010-12-21 A | 2012-12-07 A | 100% | 2010-12-21 | 2012-12-07 | 521d? | finish no earlier than 2012-12-07 | R4 | 4168h | 4168h | 26 | Rel-11 | 50 | Issam | CA | LTE_CA_B4_B13-Perf | Ericsson | christian.bergljung@ericsson.com | LTE_CA_B4_B13-Perf | RP-121594 |
| 3254 | 873.3.4 | **LTE Advanced Carrier Aggregation of Band 4 and Band 12** | 456d? | 2011-03-22 A | 2012-12-07 A | 100% | 2011-03-22 | 2012-12-07 | 456d? |  | R4; R2 | 18200h | 18200h | 26 | Rel-11 | 51 | Issam | CA | LTE_CA_B4_B12 | Leap Wireless | Bill Chandler (bchandler@cricketcommunications.com) | LTE_CA_B4_B12 |  |
| 3255 | 873.3.4.1 | Core part: LTE Advanced Carrier Aggregation of Band 4 and Band 12 | 456d? | 2011-03-22 A | 2012-12-07 A | 100% | 2011-03-22 | 2012-12-07 | 456d? | finish no earlier than 2012-12-07 | R4; R2 | 7296h | 7296h | 26 | Rel-11 | 51 | Issam | CA | LTE_CA_B4_B12-Core | Leap Wireless | Bill Chandler (bchandler@cricketcommunications.com) | LTE_CA_B4_B12-Core | RP-121592 |
| 3256 | 873.3.4.2 | Perf. part: LTE Advanced Carrier Aggregation of Band 4 and Band 12 | 451d? | 2011-03-29 A | 2012-12-07 A | 100% | 2011-03-29 | 2012-12-07 | 451d? | finish no earlier than 2012-12-07 | R4 | 3608h | 3608h | 26 | Rel-11 | 51 | Issam | CA | LTE_CA_B4_B12-Perf | Leap Wireless | Bill Chandler (bchandler@cricketcommunications.com) | LTE_CA_B4_B12-Perf | RP-121593 |
| 3257 | 873.3.5 | **LTE Advanced Carrier Aggregation of Band 5 and Band 12** | 456d? | 2011-03-22 A | 2012-12-07 A | 100% | 2011-03-22 | 2012-12-07 | 456d? |  | R4; R2 | 18200h | 18200h | 26 | Rel-11 | 51 | Issam | CA | LTE_CA_B5_B12 | US Cellular | sebastian.thalanany@uscellular.com | LTE_CA_B5_B12 |  |
| 3258 | 873.3.5.1 | Core part: LTE Advanced Carrier Aggregation of Band 5 and Band 12 | 456d? | 2011-03-22 A | 2012-12-07 A | 100% | 2011-03-22 | 2012-12-07 | 456d? | finish no earlier than 2012-12-07 | R4; R2 | 7296h | 7296h | 26 | Rel-11 | 51 | Issam | CA | LTE_CA_B5_B12-Core | US Cellular | sebastian.thalanany@uscellular.com | LTE_CA_B5_B12-Core | RP-121596 |
| 3259 | 873.3.5.2 | Perf. part: LTE Advanced Carrier Aggregation of Band 5 and Band 12 | 451d? | 2011-03-25 A | 2012-12-07 A | 100% | 2011-03-25 | 2012-12-07 | 451d? | finish no earlier than 2012-12-07 | R4 | 3608h | 3608h | 26 | Rel-11 | 51 | Issam | CA | LTE_CA_B5_B12-Perf | US Cellular | sebastian.thalanany@uscellular.com | LTE_CA_B5_B12-Perf | RP-121597 |
| 3260 | 873.3.6 | **LTE Advanced Carrier Aggregation of Band 7 and Band 20** | 389d? | 2011-03-22 A | 2012-09-07 A | 100% | 2011-03-22 | 2012-09-07 | 389d? |  | R4 | 9288h | 9288h | 26 | Rel-11 | 51 | Issam | CA | LTE_CA_B7_B20 | Huawei | Steven Chen | LTE_CA_B7_B20 |  |
| 3261 | 873.3.6.1 | Core part: LTE Advanced Carrier Aggregation of Band 7 and Band 20 | 386d? | 2011-03-22 A | 2012-09-07 A | 100% | 2011-03-22 | 2012-09-07 | 386d? | finish no earlier than 2012-09-07 | R4 | 3088h | 3088h | 26 | Rel-11 | 51 | Issam | CA | LTE_CA_B7_B20-Core | Huawei | Steven Chen | LTE_CA_B7_B20-Core | RP-121032 |
| 3262 | 873.3.6.2 | Perf. part: LTE Advanced Carrier Aggregation of Band 7 and Band 20 | 386d? | 2011-03-25 A | 2012-09-07 A | 100% | 2011-03-25 | 2012-09-07 | 386d? | finish no earlier than 2012-09-07 | R4 | 3088h | 3088h | 26 | Rel-11 | 51 | Issam | CA | LTE_CA_B7_B20-Perf | Huawei | Steven Chen | LTE_CA_B7_B20-Perf | RP-121033 |
| 3263 | 873.3.7 | **LTE Advanced Carrier Aggregation of Band 2 and Band 17** | 455d? | 2011-03-23 A | 2012-12-07 A | 100% | 2011-03-23 | 2012-12-07 | 455d? |  | R4 | 10336h | 10336h | 26 | Rel-11 | 51 | Issam | CA | LTE_CA_B2_B17 | AT&T | marc.grant@att.com | LTE_CA_B2_B17 |  |
| 3264 | 873.3.7.1 | Core part: LTE Advanced Carrier Aggregation of Band 2 and Band 17 | 386d? | 2011-03-23 A | 2012-09-07 A | 100% | 2011-03-23 | 2012-09-07 | 386d? | finish no earlier than 2012-09-07 | R4 | 3088h | 3088h | 26 | Rel-11 | 51 | Issam | CA | LTE_CA_B2_B17-Core | AT&T | marc.grant@att.com | LTE_CA_B2_B17-Core | RP-121034 |
| 3265 | 873.3.7.2 | Perf. part: LTE Advanced Carrier Aggregation of Band 2 and Band 17 | 451d? | 2011-03-25 A | 2012-12-07 A | 100% | 2011-03-25 | 2012-12-07 | 451d? | finish no earlier than 2012-12-07 | R4 | 3608h | 3608h | 26 | Rel-11 | 51 | Issam | CA | LTE_CA_B2_B17-Perf | AT&T | marc.grant@att.com | LTE_CA_B2_B17-Perf | RP-121585 |
| 3266 | 873.3.8 | **LTE Advanced Carrier Aggregation of Band 4 and Band 5** | 455d? | 2011-03-23 A | 2012-12-07 A | 100% | 2011-03-23 | 2012-12-07 | 455d? |  | R4 | 10856h | 10856h | 26 | Rel-11 | 51 | Issam | CA | LTE_CA_B4_B5 | AT&T | marc.grant@att.com | LTE_CA_B4_B5 |  |
| 3267 | 873.3.8.1 | Core part: LTE Advanced Carrier Aggregation of Band 4 and Band 5 | 451d? | 2011-03-23 A | 2012-12-07 A | 100% | 2011-03-23 | 2012-12-07 | 451d? | finish no earlier than 2012-12-07 | R4 | 3608h | 3608h | 26 | Rel-11 | 51 | Issam | CA | LTE_CA_B4_B5-Core | AT&T | marc.grant@att.com | LTE_CA_B4_B5-Core | RP-121757 |
| 3268 | 873.3.8.2 | Perf. part: LTE Advanced Carrier Aggregation of Band 4 and Band 5 | 451d? | 2011-03-25 A | 2012-12-07 A | 100% | 2011-03-25 | 2012-12-07 | 451d? | finish no earlier than 2012-12-07 | R4 | 3608h | 3608h | 26 | Rel-11 | 51 | Issam | CA | LTE_CA_B4_B5-Perf | AT&T | marc.grant@att.com | LTE_CA_B4_B5-Perf | RP-121589 |

Notes:
- 3244: LTE_CA_Rel-11 / Impacted TSs and TRs: LTE
- 3245: RP#57 completed. In Europe Band 3,7,20 are interesting for LTE and LTE-Advanced deployment. Different CA combinations for these bands are of high priority for Region 1 / Impacted TSs and TRs: LTE
- 3246: RP#57 completed. RP#59 new generic TR 36.850v100 for Information and Approval / Impacted TSs and TRs: 36.101, 36.104, 36.307, new generic TR 36.850
- 3247: RP#57 completed / Impacted TSs and TRs: 36.133, 36.141
- 3248: Stage 3. RP#57 Core completed. RP#58 Perf completed / Impacted TSs and TRs: LTE
- 3249: RP#57 completed. RP#59 new generic TR 36.850v100 for Information and Approval / Impacted TSs and TRs: 36.101, 36.104, 36.133, 36.141, 36.307, new generic TR 36.850
- 3250: RP#58 completed / Impacted TSs and TRs: 36.101, 36.104, 36.133, 36.307
- 3251: Stage 3. RP#57 Core completed. RP#58 Perf completed / Impacted TSs and TRs: LTE
- 3252: RP#57 completed / Impacted TSs and TRs: 36.101, 36.104, 36.133, 36.307, new generic TR 36.850
- 3253: RP#58 completed / Impacted TSs and TRs: 36.101, 36.133, 36.141
- 3254: Stage 3. RP#58 completed / Impacted TSs and TRs: LTE
- 3255: RP#58 completed. RP#59 new generic TR 36.850v100 for Information and Approval / Impacted TSs and TRs: 36.101, 36.104, 36.307, new generic TR 36.850
- 3256: RP#58 completed / Impacted TSs and TRs: 36.133, 36.141
- 3257: Stage 3. RP#58 completed / Impacted TSs and TRs: LTE
- 3258: RP#58 completed. RP#59 new generic TR 36.850v100 for Information and Approval / Impacted TSs and TRs: 36.101, 36.104, 36.133, 36.141, 36.307, new generic TR 36.850
- 3259: RP#58 completed / Impacted TSs and TRs: 36.101, 36.104, 36.133, 36.307
- 3260: Stage 3. RP#57 completed / Impacted TSs and TRs: LTE
- 3261: RP#57 completed. RP#59 new generic TR 36.850v100 for Information and Approval / Impacted TSs and TRs: 36.101, 36.104, 36.307, new generic TR 36.850
- 3262: RP#57 completed / Impacted TSs and TRs: 36.133, 36.141
- 3263: Stage 3. RP#57 Core completed. RP#58 Perf completed / Impacted TSs and TRs: LTE
- 3264: RP#57 completed. RP#59 new generic TR 36.850v100 for Information and Approval / Impacted TSs and TRs: 36.101, 36.104, 36.133, 36.141, 36.307, new generic TR 36.850
- 3265: RP#58 completed / Impacted TSs and TRs: 36.101, 36.104, 36.133, 36.307
- 3266: Stage 3. RP#58 completed / Impacted TSs and TRs: LTE
- 3267: RP#58 completed. RP#59 new generic TR 36.850v100 for Information and Approval / Impacted TSs and TRs: 36.101, 36.104, 36.133, 36.141, 36.307, new generic TR 36.850
- 3268: RP#58 completed / Impacted TSs and TRs: 36.101, 36.104, 36.133, 36.307

| ID | WBS | Task | Duration | Start | Finish | Complete | Baseline start | Baseline finish | Baseline duration | Constraint | Resources | Work | Actual work | Acronym | PCG approved | WI rapporteur name | WI rapporteur e-mail | Release | TSG approved | MCC resp | Special Focus Doc | Acronym_3GU_Export | Status Report |
| --- | --- | --- | --- | --- | --- | --- | --- | --- | --- | --- | --- | --- | --- | --- | --- | --- | --- | --- | --- | --- | --- | --- | --- |
| 3269 | 873.3.9 | **LTE Advanced Carrier Aggregation of Band 5 and Band 17** | 455d? | 2011-03-23 A | 2012-12-07 A | 100% | 2011-03-23 | 2012-12-07 | 455d? |  | R4 | 10856h | 10856h | LTE_CA_B5_B17 | 26 | AT&T | marc.grant@att.com | Rel-11 | 51 | Issam | CA | LTE_CA_B5_B17 |  |
| 3270 | 873.3.9.1 | Core part: LTE Advanced Carrier Aggregation of Band 5 and Band 17 | 451d? | 2011-03-23 A | 2012-12-07 A | 100% | 2011-03-23 | 2012-12-07 | 451d? | finish no earlier than 2012-12-07 | R4 | 3608h | 3608h | LTE_CA_B5_B17-Core | 26 | AT&T | marc.grant@att.com | Rel-11 | 51 | Issam | CA | LTE_CA_B5_B17-Core | RP-121598 |
| 3271 | 873.3.9.2 | Perf. part: LTE Advanced Carrier Aggregation of Band 5 and Band 17 | 451d? | 2011-03-25 A | 2012-12-07 A | 100% | 2011-03-25 | 2012-12-07 | 451d? | finish no earlier than 2012-12-07 | R4 | 3608h | 3608h | LTE_CA_B5_B17-Perf | 26 | AT&T | marc.grant@att.com | Rel-11 | 51 | Issam | CA | LTE_CA_B5_B17-Perf | RP-121599 |
| 3272 | 873.3.10 | **LTE Advanced Carrier Aggregation of Band 3 and Band 20** | 258d? | 2011-09-19 A | 2012-09-07 A | 100% | 2011-09-19 | 2012-09-07 | 258d? |  | R4 | 6168h | 6168h | LTE_CA_B3_B20 | 27 | Vodafone | tim.frost@vodafone.com | Rel-11 | 53 | Issam | CA | LTE_CA_B3_B20 |  |
| 3273 | 873.3.10.1 | Core part: LTE Advanced Carrier Aggregation of Band 3 and Band 20 | 256d? | 2011-09-19 A | 2012-09-07 A | 100% | 2011-09-19 | 2012-09-07 | 256d? | finish no earlier than 2012-09-07 | R4 | 2048h | 2048h | LTE_CA_B3_B20-Core | 27 | Vodafone | tim.frost@vodafone.com | Rel-11 | 53 | Issam | CA | LTE_CA_B3_B20-Core | RP-121046 |
| 3274 | 873.3.10.2 | Perf. part: LTE Advanced Carrier Aggregation of Band 3 and Band 20 | 257d? | 2011-09-20 A | 2012-09-07 A | 100% | 2011-09-20 | 2012-09-07 | 257d? | finish no earlier than 2012-09-07 | R4 | 2056h | 2056h | LTE_CA_B3_B20-Perf | 27 | Vodafone | tim.frost@vodafone.com | Rel-11 | 53 | Issam | CA | LTE_CA_B3_B20-Perf | RP-121047 |
| 3275 | 873.3.11 | **LTE Advanced Carrier Aggregation of Band 8 and Band 20** | 325d? | 2011-09-19 A | 2012-12-07 A | 100% | 2011-09-19 | 2012-12-07 | 325d? |  | R4 | 7752h | 7752h | LTE_CA_B8_B20 | 27 | Vodafone | Luis.Anaya@vodafone.com | Rel-11 | 53 | Issam | CA | LTE_CA_B8_B20 |  |
| 3276 | 873.3.11.1 | Core part: LTE Advanced Carrier Aggregation of Band 8 and Band 20 | 323d? | 2011-09-19 A | 2012-12-07 A | 100% | 2011-09-19 | 2012-12-07 | 323d? | finish no earlier than 2012-12-07 | R4 | 2584h | 2584h | LTE_CA_B8_B20-Core | 27 | Vodafone | Luis.Anaya@vodafone.com | Rel-11 | 53 | Issam | CA | LTE_CA_B8_B20-Core | RP-121600 |
| 3277 | 873.3.11.2 | Perf. part: LTE Advanced Carrier Aggregation of Band 8 and Band 20 | 321d? | 2011-09-23 A | 2012-12-07 A | 100% | 2011-09-23 | 2012-12-07 | 321d? | finish no earlier than 2012-12-07 | R4 | 2568h | 2568h | LTE_CA_B8_B20-Perf | 27 | Vodafone | Luis.Anaya@vodafone.com | Rel-11 | 53 | Issam | CA | LTE_CA_B8_B20-Perf | RP-121601 |
| 3278 | 873.3.12 | **LTE Advanced Carrier Aggregation of Band 3 and Band 5** | 258d? | 2011-09-19 A | 2012-09-07 A | 100% | 2011-09-19 | 2012-09-07 | 258d? |  | R4 | 6160h | 6160h | LTE_CA_B3_B5 | 27 | SK Telecom | Haesung Park | Rel-11 | 53 | Issam | CA | LTE_CA_B3_B5 |  |
| 3279 | 873.3.12.1 | Core part: LTE Advanced Carrier Aggregation of Band 3 and Band 5 | 256d? | 2011-09-19 A | 2012-09-07 A | 100% | 2011-09-19 | 2012-09-07 | 256d? | finish no earlier than 2012-09-07 | R4 | 2048h | 2048h | LTE_CA_B3_B5-Core | 27 | SK Telecom | Haesung Park | Rel-11 | 53 | Issam | CA | LTE_CA_B3_B5-Core | RP-121042 |
| 3280 | 873.3.12.2 | Perf. part: LTE Advanced Carrier Aggregation of Band 3 and Band 5 | 256d? | 2011-09-21 A | 2012-09-07 A | 100% | 2011-09-21 | 2012-09-07 | 256d? | finish no earlier than 2012-09-07 | R4 | 2048h | 2048h | LTE_CA_B3_B5-Perf | 27 | SK Telecom | Haesung Park | Rel-11 | 53 | Issam | CA | LTE_CA_B3_B5-Perf | RP-121043 |
| 3281 | 873.3.13 | **LTE Advanced Carrier Aggregation of Band 4 and Band 7** | 325d? | 2011-09-19 A | 2012-12-07 A | 100% | 2011-09-19 | 2012-12-07 | 325d? |  | R4 | 7744h | 7744h | LTE_CA_B4_B7 | 27 | Rogers Wireless | takwing.wan@rci.rogers.com | Rel-11 | 53 | Issam | CA | LTE_CA_B4_B7 |  |
| 3282 | 873.3.13.1 | Core part: LTE Advanced Carrier Aggregation of Band 4 and Band 7 | 322d? | 2011-09-19 A | 2012-12-07 A | 100% | 2011-09-19 | 2012-12-07 | 322d? | finish no earlier than 2012-12-07 | R4 | 2576h | 2576h | LTE_CA_B4_B7-Core | 27 | Rogers Wireless | takwing.wan@rci.rogers.com | Rel-11 | 53 | Issam | CA | LTE_CA_B4_B7-Core | RP-121590 |
| 3283 | 873.3.13.2 | Perf. part: LTE Advanced Carrier Aggregation of Band 4 and Band 7 | 321d? | 2011-09-23 A | 2012-12-07 A | 100% | 2011-09-23 | 2012-12-07 | 321d? | finish no earlier than 2012-12-07 | R4 | 2568h | 2568h | LTE_CA_B4_B7-Perf | 27 | Rogers Wireless | takwing.wan@rci.rogers.com | Rel-11 | 53 | Issam | CA | LTE_CA_B4_B7-Perf | RP-121591 |
| 3284 | 873.3.14 | **LTE Advanced Carrier Aggregation of Band 11 and Band 18** | 265d? | 2011-12-09 A | 2012-12-07 A | 100% | 2011-12-09 | 2012-12-07 | 265d? |  | R4; R2 | 10568h | 10568h | LTE_CA_B11_B18 | 28 | KDDI | Masaaki Obara (ms-obara@kddi.com) | Rel-11 | 54 | Issam | CA | LTE_CA_B11_B18 |  |
| 3285 | 873.3.14.1 | Core part: LTE Advanced Carrier Aggregation of Band 11 and Band 18 | 265d? | 2011-12-09 A | 2012-12-07 A | 100% | 2011-12-09 | 2012-12-07 | 265d? | finish no earlier than 2012-12-07 | R4; R2 | 4240h | 4240h | LTE_CA_B11_B18-Core | 28 | KDDI | Masaaki Obara (ms-obara@kddi.com) | Rel-11 | 54 | Issam | CA | LTE_CA_B11_B18-Core | RP-121602 |
| 3286 | 873.3.14.2 | Perf. part: LTE Advanced Carrier Aggregation of Band 11 and Band 18 | 261d? | 2011-12-15 A | 2012-12-07 A | 100% | 2011-12-15 | 2012-12-07 | 261d? | finish no earlier than 2012-12-07 | R4 | 2088h | 2088h | LTE_CA_B11_B18-Perf | 28 | KDDI | Masaaki Obara (ms-obara@kddi.com) | Rel-11 | 54 | Issam | CA | LTE_CA_B11_B18-Perf | RP-121603 |
| 3287 | 873.3.15 | **LTE Advanced Carrier Aggregation of Band 1 and Band 18** | 198d? | 2011-12-09 A | 2012-09-07 A | 100% | 2011-12-09 | 2012-09-07 | 198d? |  | R4; R2 | 7904h | 7904h | LTE_CA_B1_B18 | 28 | KDDI | Masaaki Obara (ms-obara@kddi.com) | Rel-11 | 54 | Issam | CA | LTE_CA_B1_B18 |  |
| 3288 | 873.3.15.1 | Core part: LTE Advanced Carrier Aggregation of Band 1 and Band 18 | 198d? | 2011-12-09 A | 2012-09-07 A | 100% | 2011-12-09 | 2012-09-07 | 198d? | finish no earlier than 2012-09-07 | R4; R2 | 3168h | 3168h | LTE_CA_B1_B18-Core | 28 | KDDI | Masaaki Obara (ms-obara@kddi.com) | Rel-11 | 54 | Issam | CA | LTE_CA_B1_B18-Core | RP-121052 |
| 3289 | 873.3.15.2 | Perf. part: LTE Advanced Carrier Aggregation of Band 1 and Band 18 | 196d? | 2011-12-13 A | 2012-09-07 A | 100% | 2011-12-13 | 2012-09-07 | 196d? | finish no earlier than 2012-12-07 | R4 | 1568h | 1568h | LTE_CA_B1_B18-Perf | 28 | KDDI | Masaaki Obara (ms-obara@kddi.com) | Rel-11 | 54 | Issam | CA | LTE_CA_B1_B18-Perf | RP-121053 |
| 3290 | 873.3.16 | **LTE Advanced Carrier Aggregation of Band 1 and Band 19** | 197d? | 2011-12-12 A | 2012-09-07 A | 100% | 2011-12-12 | 2012-09-07 | 197d? |  | R4; R2 | 6432h | 6432h | LTE_CA_B1_B19 | 28 | NTT DoCoMo | Hiromasa Umeda (umedah@nttdocomo.co.jp) | Rel-11 | 54 | Issam | CA | LTE_CA_B1_B19 |  |
| 3291 | 873.3.16.1 | Core part: LTE Advanced Carrier Aggregation of Band 1 and Band 19 | 137d? | 2012-03-05 A | 2012-09-07 A | 100% | 2012-03-05 | 2012-09-07 | 137d? | finish no earlier than 2012-09-07 | R4; R2 | 2192h | 2192h | LTE_CA_B1_B19-Core | 28 | NTT DoCoMo | Hiromasa Umeda (umedah@nttdocomo.co.jp) | Rel-11 | 54 | Issam | CA | LTE_CA_B1_B19-Core | RP-120552 |
| 3292 | 873.3.16.2 | Perf. part: LTE Advanced Carrier Aggregation of Band 1 and Band 19 | 136d? | 2011-12-12 A | 2012-06-15 A | 100% | 2011-12-12 | 2012-06-15 | 136d? | finish no earlier than 2012-12-07 | R4 | 1088h | 1088h | LTE_CA_B1_B19-Perf | 28 | NTT DoCoMo | Hiromasa Umeda (umedah@nttdocomo.co.jp) | Rel-11 | 54 | Issam | CA | LTE_CA_B1_B19-Perf | RP-120553 |

Notes:
- 3269: Stage 3. RP#58 completed / Impacted TSs and TRs: LTE
- 3270: RP#58 completed. RP#59 new generic TR 36.850v100 for Information and Approval / Impacted TSs and TRs: 36.101, 36.104, 36.133, 36.141, 36.307, new generic TR 36.850
- 3271: RP#58 completed / Impacted TSs and TRs: 36.101, 36.104, 36.133, 36.141, 36.307
- 3272: Stage 3. RP#57 completed / Impacted TSs and TRs: LTE
- 3273: RP#57 completed. RP#59 new generic TR 36.850v100 for Information and Approval / Impacted TSs and TRs: 36.101, 36.104, 36.133, 36.307, new generic TR 36.850
- 3274: RP#57 completed / Impacted TSs and TRs: 36.101, 36.104, 36.133, 36.141, 36.307
- 3275: Stage 3. RP#58 completed / Impacted TSs and TRs: LTE
- 3276: RP#58 completed. RP#59 new generic TR 36.850v100 for Information and Approval / Impacted TSs and TRs: 36.101, 36.104, 36.307, new generic TR 36.850
- 3277: RP#58 completed / Impacted TSs and TRs: 36.101, 36.104, 36.133, 36.141
- 3278: Stage 3. RP#57 completed / Impacted TSs and TRs: LTE
- 3279: RP#57 completed. RP#59 new generic TR 36.850v100 for Information and Approval / Impacted TSs and TRs: 36.101, 36.104, 36.133, 36.307, new generic TR 36.850
- 3280: RP#57 completed / Impacted TSs and TRs: 36.133, 36.141
- 3281: Stage 3. RP#58 completed / Impacted TSs and TRs: LTE
- 3282: RP#58 completed. RP#59 new generic TR 36.850v100 for Information and Approval / Impacted TSs and TRs: 36.101, 36.104, 36.133, 36.141, 36.307, 37.104, new generic TR 36.850
- 3283: RP#58 completed / Impacted TSs and TRs: 36.101, 36.104, 36.133, 36.141, 36.307
- 3284: Stage 3. RP#58 completed / Impacted TSs and TRs: LTE
- 3285: RP#58 completed. RP#59 new generic TR 36.850v100 for Information and Approval / Impacted TSs and TRs: 36.101, 36.104, 36.307, new generic TR 36.850
- 3286: RP#58 completed / Impacted TSs and TRs: 36.133
- 3287: Stage 3. RP#57 completed / Impacted TSs and TRs: LTE
- 3288: RP#57 completed. RP#59 new generic TR 36.850v100 for Information and Approval / Impacted TSs and TRs: 36.101, 36.104, 36.307, new generic TR 36.850
- 3289: RP#57 completed / Impacted TSs and TRs: 36.133, 36.141
- 3290: Stage 3. RP#56 completed. Updated WID RP-111765=>RP-120866 / Impacted TSs and TRs: LTE
- 3291: RP#56 completed. RP#59 new generic TR 36.850v100 for Information and Approval / Impacted TSs and TRs: 36.101, 36.104, 36.133, 36.307, new generic TR 36.850
- 3292: RP#56 completed / Impacted TSs and TRs: 36.133, 36.141

| ID | WBS | Task | Duration | Start | Finish | Complete | Baseline start | Baseline finish | Baseline duration | Constraint | Resources | Work | Actual work | Acronym | PCG approved | WI rapporteur name | Release | TSG approved | MCC resp | Special Focus Doc | Acronym_3GU_Export | Status Report |
| --- | --- | --- | --- | --- | --- | --- | --- | --- | --- | --- | --- | --- | --- | --- | --- | --- | --- | --- | --- | --- | --- | --- |
| 3293 | 873.3.17 | **LTE Advanced Carrier Aggregation of Band 1 and Band 21** | 265d? | 2011-12-09 A | 2012-12-07 A | 100% | 2011-12-09 | 2012-12-07 | 265d? |  | R4; R2 | 9496h | 9496h | LTE_CA_B1_B21 | 28 | NTT DoCoMo | Rel-11 | 54 | Issam | CA | LTE_CA_B1_B21 |  |
| 3294 | 873.3.17.1 | Core part: LTE Advanced Carrier Aggregation of Band 1 and Band 21 | 198d? | 2011-12-09 A | 2012-09-07 A | 100% | 2011-12-09 | 2012-09-07 | 198d? | finish no earlier than 2012-09-07 | R4; R2 | 3168h | 3168h | LTE_CA_B1_B21-Core | 28 | NTT DoCoMo | Rel-11 | 54 | Issam | CA | LTE_CA_B1_B21-Core | RP-121054 |
| 3295 | 873.3.17.2 | Perf. part: LTE Advanced Carrier Aggregation of Band 1 and Band 21 | 263d? | 2011-12-13 A | 2012-12-07 A | 100% | 2011-12-13 | 2012-12-07 | 263d? | finish no earlier than 2012-12-07 | R4 | 2088h | 2088h | LTE_CA_B1_B21-Perf | 28 | NTT DoCoMo | Rel-11 | 54 | Issam | CA | LTE_CA_B1_B21-Perf | RP-121055 |
| 3296 | 873.3.18 | **LTE Advanced Carrier Aggregation of Band 3 and Band 8** | 204d? | 2012-03-05 A | 2012-12-07 A | 100% | 2012-03-05 | 2012-12-07 | 204d? |  | R4 | 4864h | 4864h | LTE_CA_B3_B8 | 28 | KT | Rel-11 | 55 | Issam | CA | LTE_CA_B3_B8 |  |
| 3297 | 873.3.18.1 | Core part: LTE Advanced Carrier Aggregation of Band 3 and Band 8 | 201d? | 2012-03-05 A | 2012-12-07 A | 100% | 2012-03-05 | 2012-12-07 | 201d? | finish no earlier than 2012-12-07 | R4 | 1608h | 1608h | LTE_CA_B3_B8-Core | 28 | KT | Rel-11 | 55 | Issam | CA | LTE_CA_B3_B8-Core | RP-121586 |
| 3298 | 873.3.18.2 | Perf. part: LTE Advanced Carrier Aggregation of Band 3 and Band 8 | 203d? | 2012-03-06 A | 2012-12-07 A | 100% | 2012-03-06 | 2012-12-07 | 203d? | finish no earlier than 2012-12-07 | R4 | 1624h | 1624h | LTE_CA_B3_B8-Perf | 28 | KT | Rel-11 | 55 | Issam | CA | LTE_CA_B3_B8-Perf | RP-121587 |
| 3299 | 873.4 | **Rel-11 intra-band Carrier Aggregation** | 334d? | 2011-06-07 A | 2012-09-07 A | 100% | 2011-06-07 | 2012-09-07 | 334d? |  | RP | 18864h | 18864h |  | 30 |  | Rel-11 | 58 |  | CA |  |  |
| 3300 | 873.4.1 | **LTE Advanced Carrier Aggregation in Band 38** | 334d? | 2011-06-07 A | 2012-09-07 A | 100% | 2011-06-07 | 2012-09-07 | 334d? |  | R4 | 7976h | 7976h | LTE_CA_B38 | 27 | Huawei | Rel-11 | 52 | Issam | CA | LTE_CA_B38 |  |
| 3301 | 873.4.1.1 | Core part: LTE Advanced Carrier Aggregation in Band 38 | 331d? | 2011-06-07 A | 2012-09-07 A | 100% | 2011-06-07 | 2012-09-07 | 331d? | finish no earlier than 2012-09-07 | R4 | 2648h | 2648h | LTE_CA_B38-Core | 27 | Huawei | Rel-11 | 52 | Issam | CA | LTE_CA_B38-Core | RP-121060 |
| 3302 | 873.4.1.2 | Perf. part: LTE Advanced Carrier Aggregation in Band 38 | 333d? | 2011-06-08 A | 2012-09-07 A | 100% | 2011-06-08 | 2012-09-07 | 333d? | finish no earlier than 2012-09-07 | R4 | 2656h | 2656h | LTE_CA_B38-Perf | 27 | Huawei | Rel-11 | 52 | Issam | CA | LTE_CA_B38-Perf | RP-121061 |
| 3303 | 873.4.2 | **LTE Advanced Carrier Aggregation in Band 41** | 197d? | 2011-06-07 A | 2012-03-02 A | 100% | 2011-06-07 | 2012-03-02 | 197d? |  | R4 | 4720h | 4720h | LTE_CA_B41 | 27 | Clearwire | Rel-11 | 52 | Issam | CA | LTE_CA_B41 |  |
| 3304 | 873.4.2.1 | Core part: LTE Advanced Carrier Aggregation in Band 41 | 196d? | 2011-06-07 A | 2012-03-02 A | 100% | 2011-06-07 | 2012-03-02 | 196d? | finish no earlier than 2012-02-23 | R4 | 1568h | 1568h | LTE_CA_B41-Core | 27 | Clearwire | Rel-11 | 52 | Issam | CA | LTE_CA_B41-Core | RP-120126 |
| 3305 | 873.4.2.2 | Perf. part: LTE Advanced Carrier Aggregation in Band 41 | 197d? | 2011-06-07 A | 2012-03-02 A | 100% | 2011-06-07 | 2012-03-02 | 197d? | finish no earlier than 2012-03-02 | R4 | 1576h | 1576h | LTE_CA_B41-Perf | 27 | Clearwire | Rel-11 | 52 | Issam | CA | LTE_CA_B41-Perf | RP-120127 |
| 3306 | 873.4.3 | **LTE Advanced Carrier Aggregation in Band 7** | 258d? | 2011-09-19 A | 2012-09-07 A | 100% | 2011-09-19 | 2012-09-07 | 258d? |  | R4 | 6168h | 6168h | LTE_CA_B7 | 27 | China Unicom | Rel-11 | 53 | Issam | CA | LTE_CA_B7 |  |
| 3307 | 873.4.3.1 | Core part: LTE Advanced Carrier Aggregation in Band 7 | 256d? | 2011-09-19 A | 2012-09-07 A | 100% | 2011-09-19 | 2012-09-07 | 256d? | finish no earlier than 2012-09-07 | R4 | 2048h | 2048h | LTE_CA_B7-Core | 27 | China Unicom | Rel-11 | 53 | Issam | CA | LTE_CA_B7-Core | RP-121062 |
| 3308 | 873.4.3.2 | Perf. part: LTE Advanced Carrier Aggregation in Band 7 | 257d? | 2011-09-20 A | 2012-09-07 A | 100% | 2011-09-20 | 2012-09-07 | 257d? | finish no earlier than 2012-09-07 | R4 | 2056h | 2056h | LTE_CA_B7-Perf | 27 | China Unicom | Rel-11 | 53 | Issam | CA | LTE_CA_B7-Perf | RP-121063 |
| 3309 | 874 | **UE Over The Air (Antenna) conformance testing methodology - Laptop mounted equipment Free Space test** | 1842d? | 2009-09-18 A | 2016-09-15 A | 100% | 2009-09-18 | 2014-12-05 | 1374d? |  | R4; R5 | 45192h | 45192h | UEAnt_FSTest | 23 | CATR | Rel-11 | 45 | Issam |  | UEAnt_FSTest |  |
| 3310 | 874.1 | Core part: UE Over The Air (Antenna) conformance testing methodology - Laptop mounted equipment Free Space test | 583d? | 2009-09-18 A | 2011-12-09 A | 100% | 2009-09-18 | 2011-12-09 | 583d? | finish no earlier than 2011-12-09 | R4 | 4664h | 4664h | UEAnt_FSTest-Core | 23 | CATR | Rel-11 | 45 | Issam |  | UEAnt_FSTest-Core | RP-111456 |
| 3311 | 874.2 | Test part: UE Over The Air (Antenna) conformance testing methodology - Laptop mounted equipment Free Space test | 1388d? | 2011-06-15 A | 2016-09-15 A | 100% | 2011-06-07 | 2014-12-05 | 926d? | finish no earlier than 2016-09-15 | R5 | 11056h | 11056h | UEAnt_FSTest-UEConTest | 27 | ZTE | Rel-11 | 52 | Ingbert |  | UEAnt_FSTest-UEConTest | RP-151187 |
| 3312 | 875 | **Eight carrier HSDPA** | 589d? | 2010-09-15 A | 2012-12-07 A | 100% | 2010-09-15 | 2012-12-07 | 589d? |  | R1; R2; R3; R4 | 37768h | 37768h | 8C_HSDPA | 26 | Ericsson | Rel-11 | 50 | Patrick |  | 8C_HSDPA |  |
| 3313 | 875.1 | Core part: Eight carrier HSDPA | 461d? | 2010-09-15 A | 2012-06-15 A | 100% | 2010-09-15 | 2012-06-15 | 461d? | finish no earlier than 2012-06-15 | R1; R2; R3; R4 | 14752h | 14752h | 8C_HSDPA-Core | 26 | Ericsson | Rel-11 | 50 | Patrick |  | 8C_HSDPA-Core | RP-120971 |
| 3314 | 875.2 | Perf. part: Eight carrier HSDPA | 523d? | 2010-12-15 A | 2012-12-07 A | 100% | 2010-12-15 | 2012-12-07 | 523d? | finish no earlier than 2012-12-07 | R4 | 4168h | 4168h | 8C_HSDPA-Perf | 26 | Ericsson | Rel-11 | 50 | Issam |  | 8C_HSDPA-Perf | RP-120972 |
| 3315 | 876 | **UE demodulation performance requirements under multiple-cell scenario for 1.28Mcps TDD** | 324d? | 2010-12-10 A | 2012-03-02 A | 100% | 2010-12-10 | 2012-03-02 | 324d? |  | R4; R5 | 7760h | 7760h | LCR_TDD_UE_demod_mc | 26 | China Mobile | Rel-11 | 50 | Issam |  | LCR_TDD_UE_demod_mc |  |
| 3316 | 876.1 | Perf. part: UE demodulation performance requirements under multiple-cell scenario for 1.28Mcps TDD | 201d? | 2010-12-10 A | 2011-09-16 A | 100% | 2010-12-10 | 2011-09-16 | 201d? | finish no earlier than 2011-09-16 | R4 | 1608h | 1608h | LCR_TDD_UE_demod_mc-Perf | 26 | China Mobile | Rel-11 | 50 | Issam |  | LCR_TDD_UE_demod_mc-Perf | RP-110996 |
| 3317 | 876.2 | Test part: UE demodulation performance requirements under multiple-cell scenario for 1.28Mcps TDD | 121d? | 2011-09-19 A | 2012-03-02 A | 100% | 2011-09-19 | 2012-03-02 | 121d? | finish no earlier than 2012-02-23 | R5 | 968h | 968h | LCR_TDD_UE_demod_mc-UEConTest | 27 | China Mobile | Rel-11 | 53 | Ingbert |  | LCR_TDD_UE_demod_mc-UEConTest | RP-120052 |

Notes:
- 3293: Stage 3. RP#57 completed. Updated WID RP-111764=>RP-121173 / Impacted TSs and TRs: LTE / WI rapporteur e-mail: Hiromasa Umeda (umedah@nttdocomo.co.jp)
- 3294: RP#57 completed. RP#59 new generic TR 36.850v100 for Information and Approval / Impacted TSs and TRs: 36.101, 36.104, 36.133, 36.307, new generic TR 36.850 / WI rapporteur e-mail: Hiromasa Umeda (umedah@nttdocomo.co.jp)
- 3295: RP#57 completed / Impacted TSs and TRs: 36.133, 36.141 / WI rapporteur e-mail: Hiromasa Umeda (umedah@nttdocomo.co.jp)
- 3296: Stage 3. RP#58 completed / Impacted TSs and TRs: LTE / WI rapporteur e-mail: Chungwoo HWANG (cwhwang@kt.com)
- 3297: RP#58 completed. RP#59 new generic TR 36.850v100 for Information and Approval / Impacted TSs and TRs: 36.101, 36.104, 36.133, 36.307, new generic TR 36.850 / WI rapporteur e-mail: Chungwoo HWANG (cwhwang@kt.com)
- 3298: RP#58 completed / Impacted TSs and TRs: 36.133, 36.141 / WI rapporteur e-mail: Chungwoo HWANG (cwhwang@kt.com)
- 3299: LTE_CA_Rel-11 / Impacted TSs and TRs: LTE
- 3300: Stage 3. RP#57 completed. WI only covers intra-band contiguous and not non-contiguous aspects / Impacted TSs and TRs: LTE / WI rapporteur e-mail: ronnie.zhang@huawei.com
- 3301: RP#57 completed. TR 36.830 v100 for Information & Approval / Impacted TSs and TRs: 36.101, 36.104, 36.133, 36.141, 36.307, 37.104, 37.141, new TR 36.833-1-38 [instead of 36.830] / WI rapporteur e-mail: ronnie.zhang@huawei.com
- 3302: RP#57 completed / Impacted TSs and TRs: 36.101, 36.104, 36.133, 36.141, 36.307, 37.104, 37.141 / WI rapporteur e-mail: ronnie.zhang@huawei.com
- 3303: RP#55 completed. WI only covers intra-band contiguous and not non-contiguous aspects. / Impacted TSs and TRs: LTE / WI rapporteur e-mail: michael.hart@clearwire.com
- 3304: RP#55 completed. Updated WID RP-110673=>RP-120249. TR 36.827 v100 for Information + Approval / Impacted TSs and TRs: 36.101, 36.104, 36.133, 36.141, 36.307, 37.104, new TR 36.833-1-41 [instead of 36.827] / WI rapporteur e-mail: michael.hart@clearwire.com
- 3305: RP#55 completed / Impacted TSs and TRs: 36.101, 36.104, 36.133, 36.141, 36.307 / WI rapporteur e-mail: michael.hart@clearwire.com
- 3306: Stage 3. RP#57 completed. Updated WID RP-111356=>RP-121193. WI only covers intra-band contiguous and not non-contiguous aspects / Impacted TSs and TRs: LTE / WI rapporteur e-mail: Zhangchao Ma (mazc@chinaunicom.cn), Zhonghao Zhang (zhangzh306@chinaunicom.cn)
- 3307: RP#57 completed. TR 36.831 v100 for Information & Approval / Impacted TSs and TRs: 36.101, 36.104, 36.133, 36.141, 36.307, 37.104, 37.141, new TR 36.833-1-07 [instead of 36.831] / WI rapporteur e-mail: Zhangchao Ma (mazc@chinaunicom.cn), Zhonghao Zhang (zhangzh306@chinaunicom.cn)
- 3308: RP#57 completed / Impacted TSs and TRs: 36.101, 36.104, 36.133, 36.141, 36.307, 37.104, 37.141 / WI rapporteur e-mail: Zhangchao Ma (mazc@chinaunicom.cn), Zhonghao Zhang (zhangzh306@chinaunicom.cn)
- 3309: - / Impacted TSs and TRs: UTRA / WI rapporteur e-mail: Guo Lin (guolin@emcite.com)
- 3310: RP#54 completed / Impacted TSs and TRs: 25.144, 25.914, 34.114 / WI rapporteur e-mail: Guo Lin (guolin@emcite.com)
- 3311: 1st Apr 15: CD:Mon 15/06/15->Wed 15/06/16 1st Apr 15: Stat Rep: RP-141846->RP-150068 03/07/15: Stat Rep: RP-150068->RP-150603 29/09/15: Stat Rep: RP-150603->RP-151187 / Impacted TSs and TRs: 34.114 / WI rapporteur e-mail: carolyn.tayl@zte.com.cn
- 3312: Stage 3 / Impacted TSs and TRs: UTRA / WI rapporteur e-mail: johan.hultell@ericsson.com
- 3313: RP#57 completed / Impacted TSs and TRs: 25.101, 25.104, 25.133, 25.211, 25.212, 25.213, 25.214, 25.215, 25.308, 25.331, 25.423, 25.433, 26.306 / WI rapporteur e-mail: johan.hultell@ericsson.com
- 3314: RP#57 completed / Impacted TSs and TRs: 25.101, 25.104, 25.133, 25.141 / WI rapporteur e-mail: johan.hultell@ericsson.com
- 3315: Stage 3 / Impacted TSs and TRs: UTRA / WI rapporteur e-mail: Li Nan (linan@chinamobile.com)
- 3316: RP#53 completed. TR 25.873v100 for Approval / Impacted TSs and TRs: 25.102, new TR 25.873 / WI rapporteur e-mail: Li Nan (linan@chinamobile.com)
- 3317: RP#55 completed / Impacted TSs and TRs: 34.108, 34.122 / WI rapporteur e-mail: Ma Shuai (mashuai@chinamobile.com)

| ID | WBS | Task | Duration | Start | Finish | Complete | Baseline start | Baseline finish | Baseline duration | Constraint | Resources | Work | Actual work | Acronym | PCG approved | WI rapporteur name | WI rapporteur e-mail | Release | TSG approved | MCC resp | Acronym_3GU_Export | Status Report |
| --- | --- | --- | --- | --- | --- | --- | --- | --- | --- | --- | --- | --- | --- | --- | --- | --- | --- | --- | --- | --- | --- | --- |
| 3318 | 877 | **Uplink Transmit Diversity for HSPA** | 929d? | 2010-12-10 A | 2014-06-13 A | 100% | 2010-12-10 | 2014-06-13 | 929d? |  | R1; R4; R2; R3; R5 | 83568.3h | 83568.3h | HSPA_UL_TxDiv | 26 | Huawei | zongjie.wang@huawei.com | Rel-11 | 50 | Patrick | HSPA_UL_TxDiv |  |
| 3319 | 877.1 | Core part: Uplink Transmit Diversity for HSPA - Closed Loop | 528d? | 2010-12-10 A | 2012-12-07 A | 100% | 2010-12-10 | 2012-12-07 | 528d? | finish no earlier than 2012-12-07 | R1; R4; R2; R3 | 16896h | 16896h | HSPA_UL_TxDiv-CL-Core | 26 | Huawei | zongjie.wang@huawei.com | Rel-11 | 50 | Patrick | HSPA_UL_TxDiv-CL-Core | RP-121542 |
| 3320 | 877.2 | Perf. part: Uplink Transmit Diversity for HSPA - Closed Loop | 721d? | 2010-12-14 A | 2013-09-06 A | 100% | 2010-12-14 | 2013-09-06 | 721d? | finish no earlier than 2013-09-06 | R4 | 5760.31h | 5760.31h | HSPA_UL_TxDiv-CL-Perf | 26 | Huawei | zongjie.wang@huawei.com | Rel-11 | 50 | Issam | HSPA_UL_TxDiv-CL-Perf | RP-130477 |
| 3321 | 877.3 | Core part: Uplink Transmit Diversity for HSPA - Open Loop | 528d? | 2010-12-10 A | 2012-12-07 A | 100% | 2010-12-10 | 2012-12-07 | 528d? | finish no earlier than 2012-12-07 | R4; R1; R2; R3 | 16896h | 16896h | HSPA_UL_TxDiv-OL-Core | 26 | Huawei | zongjie.wang@huawei.com | Rel-11 | 50 | Patrick | HSPA_UL_TxDiv-OL-Core | RP-121544 |
| 3322 | 877.4 | Perf. part: Uplink Transmit Diversity for HSPA - Open Loop | 521d? | 2010-12-14 A | 2012-12-07 A | 100% | 2010-12-14 | 2012-12-07 | 521d? | finish no earlier than 2012-12-07 | R4 | 4168h | 4168h | HSPA_UL_TxDiv-OL-Perf | 26 | Huawei | zongjie.wang@huawei.com | Rel-11 | 50 | Issam | HSPA_UL_TxDiv-OL-Perf | RP-121545 |
| 3323 | 877.5 | Test part: Uplink Transmit Diversity for HSPA | 336d? | 2013-03-04 A | 2014-06-13 A | 100% | 2013-03-04 | 2014-06-13 | 336d? | finish no earlier than 2014-06-13 | R5 | 2688h | 2688h | HSPA_UL_TxDiv-UEConTest | 30 | Qualcomm | Shubhang Vora (svora@qti.qualcomm.com) | Rel-11 | 59 | Ingbert | HSPA_UL_TxDiv-UEConTest | RP-140767 |
| 3324 | 878 | **Introduction of New Configuration for 4C-HSDPA** | 328d? | 2011-03-22 A | 2012-06-15 A | 100% | 2011-03-22 | 2012-06-15 | 328d? |  | R4; R2 | 10928h | 10928h | 4C_HSDPA_Config | 26 | Telus Communications | jorge.delrio@telus.com | Rel-11 | 51 | Issam | 4C_HSDPA_Config |  |
| 3325 | 878.1 | Core part: Introduction of New Configuration for 4C-HSDPA | 192d? | 2011-03-22 A | 2011-12-09 A | 100% | 2011-03-22 | 2011-12-09 | 192d? | finish no earlier than 2011-12-09 | R4; R2 | 3072h | 3072h | 4C_HSDPA_Config-Core | 26 | Telus Communications | jorge.delrio@telus.com | Rel-11 | 51 | Issam | 4C_HSDPA_Config-Core | RP-111463 |
| 3326 | 878.2 | Perf. part: Introduction of New Configuration for 4C-HSDPA | 326d? | 2011-03-24 A | 2012-06-15 A | 100% | 2011-03-24 | 2012-06-15 | 326d? | finish no earlier than 2012-06-15 | R4 | 2608h | 2608h | 4C_HSDPA_Config-Perf | 26 | Telus Communications | jorge.delrio@telus.com | Rel-11 | 51 | Issam | 4C_HSDPA_Config-Perf | RP-120475 |
| 3327 | 879 | **Non-contiguous 4C-HSDPA operation** | 516d? | 2011-03-23 A | 2013-03-01 A | 100% | 2011-03-23 | 2013-03-01 | 516d? |  | R4; R2; R3 | 24360h | 24360h | NC_4C_HSDPA | 26 | Ericsson | muhammad.kazmi@ericsson.com | Rel-11 | 51 | Issam | NC_4C_HSDPA |  |
| 3328 | 879.1 | Core part: Non-contiguous 4C-HSDPA operation | 328d? | 2011-06-15 A | 2012-09-07 A | 100% | 2011-06-15 | 2012-09-07 | 328d? | finish no earlier than 2012-09-07 | R4; R2; R3 | 7872h | 7872h | NC_4C_HSDPA-Core | 26 | Ericsson | muhammad.kazmi@ericsson.com | Rel-11 | 51 | Issam | NC_4C_HSDPA-Core | RP-120842 |
| 3329 | 879.2 | Perf. part: Non-contiguous 4C-HSDPA operation | 513d? | 2011-03-23 A | 2013-03-01 A | 100% | 2011-03-23 | 2013-03-01 | 513d? | finish no earlier than 2013-03-01 | R4 | 4104h | 4104h | NC_4C_HSDPA-Perf | 26 | Ericsson | muhammad.kazmi@ericsson.com | Rel-11 | 51 | Issam | NC_4C_HSDPA-Perf | RP-130049 |
| 3330 | 880 | **Further Enhancements to CELL_FACH** | 1057d? | 2011-03-18 A | 2015-03-15 A | 100% | 2011-03-18 | 2014-09-12 | 924d? |  | R1; R2; R3; R4; R5 | 66320h | 66320h | Cell_FACH_enh | 26 | Qualcomm | Ravi Agarwal | Rel-11 | 51 | Patrick | Cell_FACH_enh |  |
| 3331 | 880.1 | Core part: Further Enhancements to CELL_FACH | 458d? | 2011-03-18 A | 2012-12-07 A | 100% | 2011-03-18 | 2012-12-07 | 458d? | finish no earlier than 2012-12-07 | R2; R1; R3; R4 | 14656h | 14656h | Cell_FACH_enh-Core | 26 | Qualcomm | Ravi Agarwal | Rel-11 | 51 | Yong-Jun | Cell_FACH_enh-Core | RP-121547 |
| 3332 | 880.2 | Perf. part: Further Enhancements to CELL_FACH | 717d? | 2011-03-24 A | 2013-12-06 A | 100% | 2011-03-24 | 2013-12-06 | 717d? | finish no earlier than 2013-12-06 | R4 | 5728h | 5728h | Cell_FACH_enh-Perf | 26 | Qualcomm | Heechoon Lee (heechoon@qti.qualcomm.com) | Rel-11 | 51 | Issam | Cell_FACH_enh-Perf | RP-131459 |
| 3333 | 880.3 | Test part: Further Enhancements to CELL_FACH | 457d? | 2013-06-15 A | 2015-03-15 A | 100% | 2013-06-18 | 2014-09-12 | 327d? | finish no earlier than 2015-03-15 | R5 | 3656h | 3656h | Cell_FACH_enh-UEConTest | 31 | Ericsson | leif.mattisson@ericsson.com | Rel-11 | 60 | Ingbert | Cell_FACH_enh-UEConTest | RP-150132 |
| 3334 | 881 | **HSDPA Multiflow Data Transmission** | 924d? | 2011-09-19 A | 2015-03-15 A | 100% | 2011-09-19 | 2014-12-05 | 851d? |  | R2; R1; R3; R4; R5 | 54136h | 54136h | HSDPA_MFTX | 27 | Nokia Siemens Networks | Alexander Sayenko | Rel-11 | 53 | Yong-Jun | HSDPA_MFTX |  |
| 3335 | 881.1 | Core part: HSDPA Multiflow Data Transmission | 325d? | 2011-09-19 A | 2012-12-07 A | 100% | 2011-09-19 | 2012-12-07 | 325d? | finish no earlier than 2012-12-07 | R2; R1; R3; R4 | 10400h | 10400h | HSDPA_MFTX-Core | 27 | Nokia Siemens Networks | Alexander Sayenko | Rel-11 | 53 | Yong-Jun | HSDPA_MFTX-Core | RP-121551 |
| 3336 | 881.2 | Perf. part: HSDPA Multiflow Data Transmission | 519d? | 2011-09-20 A | 2013-09-06 A | 100% | 2011-09-20 | 2013-09-06 | 519d? | finish no earlier than 2013-09-06 | R4 | 4152h | 4152h | HSDPA_MFTX-Perf | 27 | Nokia Siemens Networks | kamil.bechta@nsn.com | Rel-11 | 53 | Issam | HSDPA_MFTX-Perf | RP-130959 |
| 3337 | 881.3 | Test part: HSDPA Multiflow Data Transmission | 328d? | 2013-12-15 A | 2015-03-15 A | 100% | 2013-12-06 | 2014-12-05 | 262d? | finish no earlier than 2015-03-15 | R5 | 2624h | 2624h | HSDPA_MFTX-UEConTest | 32 | Qualcomm | Shubhang Vora (svora@qti.qualcomm.com) | Rel-11 | 62 | Ingbert | HSDPA_MFTX-UEConTest | RP-150126 |
| 3338 | 882 | **Four Branch MIMO transmission for HSDPA** | 590d? | 2011-09-19 A | 2013-12-06 A | 100% | 2011-09-19 | 2013-12-06 | 590d? |  | R1; R2; R3; R4 | 33968h | 33968h | 4Tx_HSDPA | 27 | Ericsson | johan.hultell@ericsson.com | Rel-11 | 53 | Patrick | 4Tx_HSDPA |  |
| 3339 | 882.1 | Core part: Four Branch MIMO transmission for HSDPA | 325d? | 2011-09-19 A | 2012-12-07 A | 100% | 2011-09-19 | 2012-12-07 | 325d? | finish no earlier than 2012-12-07 | R1; R2; R3; R4 | 10400h | 10400h | 4Tx_HSDPA-Core | 27 | Ericsson | johan.hultell@ericsson.com | Rel-11 | 53 | Patrick | 4Tx_HSDPA-Core | RP-121549 |
| 3340 | 882.2 | Perf. part: Four Branch MIMO transmission for HSDPA | 586d? | 2011-09-21 A | 2013-12-06 A | 100% | 2011-09-21 | 2013-12-06 | 586d? | finish no earlier than 2013-12-06 | R4 | 4688h | 4688h | 4Tx_HSDPA-Perf | 27 | Ericsson | johan.hultell@ericsson.com | Rel-11 | 53 | Issam | 4Tx_HSDPA-Perf | RP-131460 |
| 3341 | 883 | **MIMO with 64QAM for HSUPA** | 464d? | 2011-12-09 A | 2013-09-06 A | 100% | 2011-12-09 | 2013-09-06 | 464d? |  | R1; R2; R3; R4 | 26984h | 26984h | MIMO_64QAM_HSUPA | 28 | Nokia Siemens Networks | Karri Ranta-aho | Rel-11 | 54 | Patrick | MIMO_64QAM_HSUPA |  |
| 3342 | 883.1 | Core part: MIMO with 64QAM for HSUPA | 265d? | 2011-12-09 A | 2012-12-07 A | 100% | 2011-12-09 | 2012-12-07 | 265d? | finish no earlier than 2012-12-07 | R1; R2; R3; R4 | 8480h | 8480h | MIMO_64QAM_HSUPA-Core | 28 | Nokia Siemens Networks | Karri Ranta-aho | Rel-11 | 54 | Patrick | MIMO_64QAM_HSUPA-Core | RP-121554 |
| 3343 | 883.2 | Perf. part: MIMO with 64QAM for HSUPA | 457d? | 2011-12-13 A | 2013-09-06 A | 100% | 2011-12-13 | 2013-09-06 | 457d? | finish no earlier than 2013-09-06 | R4 | 3656h | 3656h | MIMO_64QAM_HSUPA-Perf | 28 | Nokia Siemens Networks | kamil.bechta@nsn.com | Rel-11 | 54 | Issam | MIMO_64QAM_HSUPA-Perf | RP-130960 |

Notes:
- 3318: Stage 2/3 / Impacted TSs and TRs: UTRA
- 3319: RP#58 completed / Impacted TSs and TRs: 25.101, 25.104, 25.133, 25.211, 25.212, 25.213, 25.214, 25.215, 25.306, 25.319, 25.321, 25.331, 25.423, 25.433
- 3320: RP#61 completed / Impacted TSs and TRs: 25.101, 25.104, 25.133, 25.141
- 3321: RP#58 completed / Impacted TSs and TRs: 25.101, 25.133, 25.306, 25.319, 25.321, 25.331, 25.423, 25.433
- 3322: RP#58 completed / Impacted TSs and TRs: 25.101, 25.133
- 3323: RP#64 completed / Impacted TSs and TRs: 34.121-1, 34.121-2, 34.123-1, 34.123-2, 34.123-3
- 3324: - / Impacted TSs and TRs: UTRA
- 3325: RP#54 completed. RP#62 existing TS 25.317 replaced by new TS 25.327 / Impacted TSs and TRs: 25.101, 25.104, 25.141, 25.317 replaced by new TS 25.327
- 3326: RP#56 completed. RP#62 existing TS 25.317 replaced by new TS 25.327 / Impacted TSs and TRs: 25.101, 25.104, 25.141, 25.317 replaced by new TS 25.327
- 3327: - / Impacted TSs and TRs: UTRA
- 3328: RP#56 completed / Impacted TSs and TRs: 25.101, 25.104, 25.133, 25.331, 25.423, 25.433
- 3329: RP#59 completed / Impacted TSs and TRs: 25.101, 25.104, 25.133, 25.141
- 3330: - / Impacted TSs and TRs: UTRA
- 3331: RP#58 completed / Impacted TSs and TRs: 25.101, 25.104, 25.133, 25.211, 25.212, 25.213, 25.214, 25.306, 25.308, 25.319, 25.321, 25.331, 25.423, 25.433
- 3332: RP#62 completed / Impacted TSs and TRs: 25.101, 25.104, 25.133, 25.141
- 3333: ; Stat Rep: RP-141164->RP-141770 1st Apr 15: Compl:92%->100% 1st Apr 15: Stat Rep: RP-141770->RP-150132 / Impacted TSs and TRs: 34.108, 34.121-1, 34.121-2, 34.123-1, 34.123-2, 34.123-3, 36.508, 36.523-1, 36.523-2, 36.523-3
- 3334: Stage 2,3 / Impacted TSs and TRs: UTRA
- 3335: RP#58 completed / Impacted TSs and TRs: 25.101, 25.104, 25.133, 25.211, 25.212, 25.214, 25.306, 25.308, 25.321, 25.331, 25.423, 25.433
- 3336: RP#61 completed / Impacted TSs and TRs: 25.101, 25.104, 25.133, 25.141
- 3337: ; Stat Rep: RP-141136->RP-141961 1st Apr 15: Compl:90%->100% 1st Apr 15: Stat Rep: RP-141961->RP-150126 / Impacted TSs and TRs: 34.108, 34.121-1, 34.121-2, 34.123-1, 34.123-2, 34.123-3
- 3338: Stage 3 / Impacted TSs and TRs: UTRA
- 3339: RP#58 completed / Impacted TSs and TRs: 25.101, 25.104, 25.133, 25.211, 25.212, 25.213, 25.214, 25.215, 25.308, 25.331, 25.423, 25.433, 26.306
- 3340: RP#62 completed / Impacted TSs and TRs: 25.101, 25.104, 25.133, 25.141
- 3341: Specified UE and BS performance requirements for uplink MIMO together with QPSK and 16QAM modulations for E-DCH/HSUPA. 64QAM is for future releases / Impacted TSs and TRs: UTRA
- 3342: RP#58 completed / Impacted TSs and TRs: 25.101, 25.104, 25.133, 25.211, 25.212, 25.213, 25.214, 25.215, 25.308, 25.321, 25.331, 25.423, 25.433, 26.306
- 3343: RP#61 completed / Impacted TSs and TRs: 25.101, 25.104, 25.133, 25.141

| ID | WBS | Task | Type | Duration | Start | Finish | Complete | Baseline start | Baseline finish | Baseline duration | Constraint | Resources | Work | Actual work | Acronym | PCG approved | Impacted TSs and TRs | WI rapporteur name | Release | TSG approved | MCC resp | Acronym_3GU_Export | Status Report | Special Focus Doc | PCG stopped | TSG stopped |
| --- | --- | --- | --- | --- | --- | --- | --- | --- | --- | --- | --- | --- | --- | --- | --- | --- | --- | --- | --- | --- | --- | --- | --- | --- | --- | --- |
| 3344 | 884 | **HSDPA Dual-Band Multi-Carrier combinations** |  | 198d? | 2011-12-09 A | 2012-09-07 A | 100% | 2011-12-09 | 2012-09-07 | 198d? |  | R4; R2 | 7920h | 7920h | HSDPA_DB_MC | 28 | UTRA | Ericsson | Rel-11 | 54 | Issam | HSDPA_DB_MC |  |  |  |  |
| 3345 | 884.1 | Core part: HSDPA Dual-Band Multi-Carrier combinations |  | 198d? | 2011-12-09 A | 2012-09-07 A | 100% | 2011-12-09 | 2012-09-07 | 198d? | finish no earlier than 2012-09-07 | R4; R2 | 3168h | 3168h | HSDPA_DB_MC-Core | 28 | 25.101, 25.104, 25.141, 25.317 replaced by new TS 25.327 | Ericsson | Rel-11 | 54 | Issam | HSDPA_DB_MC-Core | RP-120987 |  |  |  |
| 3346 | 884.2 | Perf. part: HSDPA Dual-Band Multi-Carrier combinations |  | 198d? | 2011-12-09 A | 2012-09-07 A | 100% | 2011-12-09 | 2012-09-07 | 198d? | finish no earlier than 2012-09-07 | R4 | 1584h | 1584h | HSDPA_DB_MC-Perf | 28 | 25.101, 25.104, 25.141 | Ericsson | Rel-11 | 54 | Issam | HSDPA_DB_MC-Perf | RP-120988 |  |  |  |
| 3347 | 885 | Split TTCN Test Models for IMS testing in TS 34.229-3 |  | 201d? | 2013-12-09 A | 2014-09-12 A | 100% | 2013-12-09 | 2014-09-12 | 201d? | finish no earlier than 2014-09-12 | R5 | 1608h | 1608h | IMS-CCR_Test2 | 32 | 34.229-3, New TS 34.229-4 | Spirent | Rel-11 | 62 | Ingbert | IMS-CCR_Test2 | RP-141155 |  |  |  |
| 3348 | 886 | (Small) Technical Enhancements and Improvements for Rel-11 |  | 595d? | 2010-06-18 A | 2012-09-20 A | 100% | 2010-06-18 | 2012-09-20 | 595d? | finish no earlier than 2012-09-20 | SP; CP; RP; GP | 19040h | 19040h | TEI11 | 25 |  |  | Rel-11 | 48 | All | TEI11 |  |  |  |  |
| 3349 | 887 | Test - (Small) Technical Enhancements and Improvements for Rel-11 |  | 397d? | 2012-06-15 A | 2013-12-11 A | 100% | 2012-06-15 | 2013-12-11 | 397d? | finish no earlier than 2013-12-11 | R5; G3new | 6352h | 6352h | TEI11_Test | 29 |  |  | Rel-11 | 56 | Ingbert | TEI11_Test |  |  |  |  |
| 3350 | 888 | (IETF) (Small) Technical Enhancements and Improvements for Rel-11 (RFC 7077) |  | 333d? | 2012-09-07 A | 2013-12-06 A | 100% | 2012-09-07 | 2013-12-06 | 333d? | finish no earlier than 2013-11-28 | C4-IETF | 2632.95h | 2632.95h | TEI11_IETF | 29 | RFC 7077 (was draft-ietf-netext-update-notifications) | Lionel Morand | Rel-11 | 57 | Kimmo | TEI11_IETF |  |  |  |  |
| 3351 | 889 | Release 11 Studies | milestone | 0d? | 2009-12-10 A | 2009-12-10 A | 100% | 2009-12-10 | 2012-09-14 | 727d? | finish no earlier than 2012-12-07 | SP; CP; GP; RP |  |  |  |  |  |  | Rel-11 |  | All |  |  |  |  |  |
| 3352 | 890 | Study on IMS based Peer-to-Peer Content Distribution Services |  | 195d? | 2009-09-11 A | 2010-06-10 A | 100% | 2009-05-12 | 2010-06-10 | 284d? | finish no earlier than 2010-06-10 | S1; S2 | 3120h | 3120h | FS_IMS_P2P | 23 | 22.906 | China Mobile | Rel-11 | 45 | Alain | FS_IMS_P2P |  |  |  |  |
| 3353 | 891 | Study on Non Voice Emergency Services |  | 467d? | 2009-12-10 A | 2011-09-21 A | 100% | 2009-12-10 | 2011-09-21 | 467d? | finish no earlier than 2011-09-21 | S1 | 3720h | 3720h | FS_NOVES | 24 | 22.871 | Qualcomm | Rel-11 | 46 | Alain | FS_NOVES |  |  |  |  |
| 3354 | 892 | Study on Support for 3GPP Voice Interworking with Enterprise IP-PBX |  | 130d? | 2010-09-23 A | 2011-03-23 A | 100% | 2010-09-23 | 2011-03-23 | 130d? | finish no earlier than 2011-02-21 | S1; S2 | 2080h | 2080h | FS_VINE | 25 | 22.809 | Tatara Systems | Rel-11 | 48 | Alain | FS_VINE |  |  |  |  |
| 3355 | 893 | Study on IMS Network-Independent Public User Identities |  | 185d? | 2010-09-23 A | 2011-06-08 A | 100% | 2010-09-23 | 2011-06-08 | 185d? | finish no earlier than 2011-06-08 | S1 | 1480h | 1480h | FS_INIPUI | 25 | 22.894 | Vodafone | Rel-11 | 49 | Alain | FS_INIPUI |  |  |  |  |
| 3356 | 894 | Study on IMS Evolution |  | 849d? | 2008-09-18 A | 2011-12-14 A | 100% | 2008-09-18 | 2011-12-14 | 849d? | finish no earlier than 2011-12-07 | S2 | 6784h | 6784h | FS_eIMS | 21 | 23.812 | China Mobile | Rel-11 | 41 | Maurice | FS_eIMS |  |  |  |  |
| 3357 | 895 | Study on Policy solutions and enhancements |  | 521d? | 2009-06-12 A | 2011-06-10 A | 100% | 2000-01-03 | 2002-01-03 | 525d? | finish no earlier than 2011-06-10 | S2; S1 | 8336h | 8336h | FS_PP | 23 | 23.813 | AT&T | Rel-11 | 44 | Maurice | FS_PP |  |  |  |  |
| 3358 | 896 | Study on IPv6 Migration |  | 525d? | 2009-06-04 A | 2011-06-08 A | 100% | 2009-06-04 | 2011-06-08 | 525d? | finish no earlier than 2011-06-08 | S2 | 4200h | 4200h | FS_IP6M | 23 | 23.975 | China Mobile | Rel-11 | 44 | Maurice | FS_IP6M |  |  |  |  |
| 3359 | 897 | Study on Single Radio Voice Call Continuity from UTRAN/GERAN to E-UTRAN/HSPA |  | 528d? | 2009-12-10 A | 2011-12-14 A | 100% | 2009-12-10 | 2011-12-14 | 528d? | finish no earlier than 2011-09-21 | S2 | 4208h | 4208h | FS_rSRVCC | 24 | 23.885 | Orange | Rel-11 | 46 | Maurice | FS_rSRVCC |  |  |  |  |
| 3360 | 898 | Study on Roaming Architecture for Voice over IMS with Local Breakout |  | 194d? | 2011-03-23 A | 2011-12-14 A | 100% | 2011-03-23 | 2011-12-14 | 194d? | finish no earlier than 2011-12-07 | S2 | 1535.79h | 1535.79h | FS_RAVEL | 26 | 23.850 | Deutsche Telekom | Rel-11 | 51 | Maurice | FS_RAVEL |  |  |  |  |
| 3361 | 899 | Study on UTRAN key management enhancements |  | 1102d? | 2007-12-20 A | 2012-03-07 A | 100% | 2007-12-20 | 2012-03-07 | 1102d? | finish no earlier than 2012-02-20 | S3 | 8808.12h | 8808.12h | FS_UKM | 21 | 33.859 | Ericsson | Rel-11 | 38 | Mirko | FS_UKM |  |  |  |  |
| 3362 | 900 | Study on Single Sign On (SSO) Application Security for IMS - based on SIP Digest |  | 532d? | 2010-06-10 A | 2012-06-20 A | 100% | 2010-06-10 | 2012-06-20 | 532d? | finish no earlier than 2012-06-20 | S3 | 4247.09h | 4247.09h | FS_SSO_APS | 25 | 33.914 converted to 33.804 | Nokia | Rel-11 | 48 | Mirko | FS_SSO_APS |  |  |  |  |
| 3363 | 901 | Study on Mobile 3D Video Coding |  | 273d? | 2011-06-08 A | 2012-06-20 A | 100% | 2011-06-08 | 2012-06-20 | 273d? | finish no earlier than 2012-06-20 | S4 | 2168h | 2168h | FS_M3DVC | 27 | 26.905 | Orange | Rel-11 | 52 | Paolo | FS_M3DVC |  |  |  |  |
| 3364 | 902 | Study on Management of Converged Networks |  | 591d? | 2010-06-10 A | 2012-09-12 A | 100% | 2010-06-10 | 2012-09-12 | 591d? | finish no earlier than 2012-09-12 | S5 | 4720h | 4720h | FS_ManCon | 25 | 32.833 | Nokia Siemens Networks | Rel-11 | 48 | Mirko | FS_ManCon |  |  |  |  |
| 3365 | 903 | Study on User Data Convergence (UDC) information model handling and provisioning: Example Use Cases |  | 321d? | 2010-09-23 A | 2011-12-14 A | 100% | 2010-09-23 | 2011-12-14 | 321d? | finish no earlier than 2011-12-14 | S5 | 2560h | 2560h | FS_UDC_AppUseCase | 25 | 32.901 | Alcatel-Lucent | Rel-11 | 49 | Mirko | FS_UDC_AppUseCase |  |  |  |  |
| 3366 | 904 | Study on OAM aspects of inter-RAT Energy Saving |  | 194d? | 2011-03-23 A | 2011-12-14 A | 100% | 2011-03-23 | 2011-12-14 | 194d? | start no earlier than 2011-03-23 | S5 | 1528h | 1528h | FS_OAM_ES_iRAT | 26 | 32.834 | Nokia Siemens Networks | Rel-11 | 51 | Mirko | FS_OAM_ES_iRAT |  | SON |  |  |
| 3367 | 905 | Study on impacts on UE-Core Network signalling from Energy Saving |  | 261d? | 2010-06-04 A | 2011-06-03 A | 100% | 2010-06-04 | 2011-06-03 | 261d? | finish no earlier than 2011-06-03 | C1 | 2088h | 2088h | FS_UE-CN_ES | 25 | 24.826 | NEC | Rel-11 | 48 | Frederic | FS_UE-CN_ES |  |  |  |  |
| 3368 | 906 | Study on EPC Nodes Restoration |  | 588d? | 2010-09-17 A | 2012-12-07 A | 100% | 2010-09-17 | 2012-12-07 | 588d? | finish no earlier than 2012-12-07 | C4 | 4664h | 4664h | FS_EPC_NR | 25 | 23.857 | ZTE | Rel-11 | 49 | Kimmo | FS_EPC_NR |  |  |  |  |
| 3369 | 907 | Study on Signal Precoding enhancements for EGPRS2 DL |  | 394d? | 2010-09-03 A | 2012-03-02 A | 100% | 2010-09-03 | 2012-03-02 | 394d? | finish no earlier than 2012-03-02 | G1; G2 | 6304h | 6304h | FS_SPEED | 25 | GERAN 45.860 | Ericsson | Rel-11 | 46 | Paolo | FS_SPEED |  |  |  |  |
| 3370 | 908 | Study on Coordinated Multi-Point operation for LTE |  | 203d? | 2010-12-10 A | 2011-09-16 A | 100% | 2010-12-10 | 2011-09-16 | 203d? | finish no earlier than 2011-09-16 | R1; R2; R3 | 4872h | 4872h | FS_CoMP_LTE | 24 | LTE 36.819 | Samsung | Rel-11 | 47 | Patrick | FS_CoMP_LTE | RP-111343 |  |  |  |
| 3371 | 909 | Study on Signalling and procedure for interference avoidance for in-device coexistence |  | 338d? | 2010-06-04 A | 2011-09-16 A | 100% | 2010-06-04 | 2011-09-16 | 338d? | finish no earlier than 2011-09-16 | R2; R4 | 5408h | 5408h | FS_SPIA_IDC | 25 | LTE 36.816 | China Mobile | Rel-11 | 48 | Yong-Jun | FS_SPIA_IDC | RP-111057 |  |  |  |
| 3372 | 910 | Study on HetNet mobility enhancements for LTE |  | 391d? | 2011-03-18 A | 2012-09-07 A | 100% | 2011-03-18 | 2012-09-07 | 391d? | finish no earlier than 2012-09-07 | R2; R1; R3; R4 | 12512h | 12512h | FS_HetNet_eMOB_LTE | 26 | LTE 36.839 | Alcatel-Lucent | Rel-11 | 51 | Yong-Jun | FS_HetNet_eMOB_LTE | RP-121085 |  |  |  |
| 3373 | 911 | Study on further Downlink MIMO enhancements for LTE-Advanced |  | 193d? | 2011-03-18 A | 2011-12-09 A | 100% | 2011-03-18 | 2011-12-09 | 193d? | finish no earlier than 2011-12-09 | R1 | 1544h | 1544h | FS_LTE_eDL_MIMO_enh | 26 | LTE 36.871 | Alcatel-Lucent | Rel-11 | 51 | Patrick | FS_LTE_eDL_MIMO_enh | RP-111550 |  |  |  |
| 3374 | 912 | Study on Further Enhancements to LTE TDD for DL-UL Interference Management and Traffic Adaptation |  | 328d? | 2011-03-22 A | 2012-06-15 A | 100% | 2011-03-22 | 2012-06-15 | 328d? | finish no earlier than 2012-06-15 | R1; R4 | 5248h | 5248h | FS_LTE_TDD_eIMTA | 26 | LTE 36.828 | CATT | Rel-11 | 51 | Patrick | FS_LTE_TDD_eIMTA | RP-120587 | Small cell |  |  |
| 3375 | 913 | Study on LTE Coverage Enhancements |  | 197d? | 2011-09-19 A | 2012-06-15 A | 100% | 2011-09-19 | 2012-06-15 | 197d? | finish no earlier than 2012-06-15 | R1; R2 | 3152h | 3152h | FS_Cov_Enh_LTE | 27 | LTE 36.824 | China Telecom | Rel-11 | 53 | Patrick | FS_Cov_Enh_LTE | RP-120589 |  |  |  |
| 3376 | 914 | Study on Enhanced performance requirement for LTE UE |  | 121d? | 2011-09-19 A | 2012-03-02 A | 100% | 2011-09-19 | 2012-03-02 | 121d? | finish no earlier than 2012-03-02 | R4; R1 | 1936h | 1936h | FS_enh_perf_UE_LTE | 27 | LTE 36.829 | NTT DoCoMo | Rel-11 | 53 | Issam | FS_enh_perf_UE_LTE | RP-120167 |  |  |  |
| 3377 | 915 | Study on Measurements of radio performances for LTE terminals - Total Radiated Power (TRP) and Total Radiated Sensitivity (TRS) test methodology |  | 136d? | 2012-03-05 A | 2012-09-07 A | 100% | 2012-03-05 | 2012-09-07 | 136d? | finish no earlier than 2012-09-07 | R4 | 1088h | 1088h | FS_LTE_OTA | 28 | LTE 25.914, New TR 37.902 | CATR | Rel-11 | 55 | Issam | FS_LTE_OTA | RP-121083 |  |  |  |
| 3378 | 916 | Study on Measurement of Radiated Performance for MIMO and multi-antenna reception for HSPA and LTE terminals |  | 712.8d? | 2009-03-06 A | 2012-03-02 A | 100% | 2009-03-06 | 2012-03-02 | 712.8d? | finish no earlier than 2012-03-02 | R4 | 5702.4h | 5702.4h | FS_HSPA_LTE_measRP_MIMO_multi-antenna | 22 | UTRA, LTE 37.976 | Vodafone | Rel-11 | 43 | Issam | FS_HSPA_LTE_measRP_MIMO_multi-antenna | RP-120154 |  |  |  |
| 3379 | 917 | Study on Extending 850 MHz |  | 860d? | 2009-05-30 A | 2012-09-07 A | 100% | 2009-05-30 | 2012-09-07 | 860d? | finish no earlier than 2012-09-07 | R4 | 6880h | 6880h | FS_e850 | 23 | UTRA, LTE 37.806 | Ericsson | Rel-11 | 44 | Issam | FS_e850 | RP-121080 |  |  |  |
| 3380 | 918 | Study on RAN improvements for Machine-Type Communications |  | 523d? | 2009-09-18 A | 2011-09-16 A | 100% | 2009-09-18 | 2011-09-16 | 523d? | finish no earlier than 2011-09-16 | R2; R1; R3; R4 | 16736h | 16736h | FS_NIMTC_RAN | 23 | UTRA, LTE 37.868 | Huawei | Rel-11 | 45 | Yong-Jun | FS_NIMTC_RAN | RP-111052 | MTC, M2M |  |  |
| 3381 | 919 | Study on UE Application Layer Data Throughput Performance |  | 264d? | 2010-09-16 A | 2011-09-16 A | 100% | 2010-09-16 | 2011-09-16 | 264d? | finish no earlier than 2011-09-16 | R5; R4 | 4224h | 4224h | FS_UE_App_Data_Perf | 26 | UTRA, LTE 37.901 | Spirent | Rel-11 | 50 | Ingbert | FS_UE_App_Data_Perf | RP-111543 |  |  |  |
| 3382 | 920 | Study on further enhancements for HNB and HeNB |  | 330d? | 2011-03-18 A | 2012-06-15 A | 100% | 2011-03-18 | 2012-06-15 | 330d? | finish no earlier than 2012-06-15 | R3; R2 | 5280h | 5280h | FS_EHNB_enh | 26 | UTRA, LTE 37.803 | Alcatel-Lucent | Rel-11 | 51 | Juha | FS_EHNB_enh | RP-120579 | HNB |  |  |
| 3383 | 921 | Study on Interference analysis between 800~900 MHz bands |  | 326d? | 2011-03-23 A | 2012-06-15 A | 100% | 2011-03-23 | 2012-06-15 | 326d? | finish no earlier than 2012-06-15 | R4 | 2608h | 2608h | FS_B800_B900_Interf_LTE | 26 | UTRA, LTE impacts TR 37.804 | LG Uplus | Rel-11 | 51 | Issam | FS_B800_B900_Interf_LTE | RP-120586 |  |  |  |
| 3384 | 922 | Study on UMTS/LTE in 900 MHz band (Japan, Korea) |  | 272d? | 2011-06-07 A | 2012-06-15 A | 100% | 2011-06-07 | 2012-06-15 | 272d? | finish no earlier than 2012-06-15 | R4 | 2176h | 2176h | FS_UTRA_LTE_900MHz | 27 | UTRA, LTE 37.804 | NTT DoCoMo | Rel-11 | 52 | Issam | FS_UTRA_LTE_900MHz | RP-120580 |  |  |  |
| 3385 | 923 | Study on Uplink MIMO |  | 203d? | 2010-12-10 A | 2011-09-16 A | 100% | 2010-12-10 | 2011-09-16 | 203d? | finish no earlier than 2011-09-16 | R1 | 1624h | 1624h | FS_UTRA_UL_MIMO | 26 | UTRA 25.871 | Qualcomm | Rel-11 | 50 | Patrick | FS_UTRA_UL_MIMO | RP-111048 |  |  |  |
| 3386 | 924 | Study on HSDPA Multipoint Transmission |  | 203d? | 2010-12-10 A | 2011-09-16 A | 100% | 2010-12-10 | 2011-09-16 | 203d? | finish no earlier than 2011-09-16 | R1; R2; R3 | 4872h | 4872h | FS_HSDPA_MP_TX | 26 | UTRA 25.872 | Nokia Siemens Networks | Rel-11 | 50 | Patrick | FS_HSDPA_MP_TX | RP-111049 |  |  |  |
| 3387 | 925 | Study on UE Over The Air (OTA) test method with Head and Hand Phantoms |  | 258d? | 2011-09-19 A | 2012-09-07 A | 100% | 2011-09-19 | 2012-09-07 | 258d? | finish no earlier than 2012-09-07 | R4; R5 | 4128h | 4128h | FS_OTA_phantoms_UTRA | 27 | UTRA 25.914 | Nokia | Rel-11 | 53 | Issam | FS_OTA_phantoms_UTRA | RP-121078 |  |  |  |
| 3388 | 926 | Study on HSPA feedback and signalling efficiency enhancements for LCR TDD |  | 199d? | 2011-12-07 A | 2012-09-07 A | 100% | 2011-12-07 | 2012-09-07 | 199d? | finish no earlier than 2012-09-07 | R1 | 1584h | 1584h | FS_LCRTDD_HSPAenh | 28 | UTRA 25.874 | TD Tech | Rel-11 | 54 | Patrick | FS_LCRTDD_HSPAenh | RP-121079 |  |  |  |
| 3389 | 927 | Deleted - Study on Enhanced Uplink Transmission for LTE |  | 328d? | 2011-03-22 A | 2012-06-15 A | 100% | 2011-03-22 | 2012-06-15 | 328d? | finish no earlier than 2012-06-15 | R1 | 2624h | 2624h | FS_eUL_TX_LTE | 26 | LTE 36.8xy | Huawei | Rel-11 | 51 | Patrick | FS_eUL_TX_LTE | RP-120585 |  | PCG-29 | RP-56 |
| 3390 | 928 | Release 10 Features |  | 728d? | 2008-12-11 A | 2011-09-21 A | 100% | 2008-12-11 | 2011-09-21 | 728d? | finish no earlier than 2011-09-21 | CP; GP; RP; SP | 23296h | 23296h |  |  |  |  | Rel-10 |  |  |  |  |  |  |  |

Notes:
- 3344: Stage 3 / WI rapporteur e-mail: muhammad.kazmi@ericsson.com
- 3345: RP#57 completed. RP#62 existing TS 25.317 replaced by new TS 25.327 / WI rapporteur e-mail: muhammad.kazmi@ericsson.com
- 3346: RP#57 completed / WI rapporteur e-mail: muhammad.kazmi@ericsson.com
- 3347: SP#65 completed. TS 34.229-4 for Approval. Split out of old TS 34.229-3 a new TS 34.229-4 / WI rapporteur e-mail: richard.catmur@spirent.com
- 3348: SP#50 EU-Alert is introduced under Public Warning System in parallel with the already existing ETWS and CMAS. SA1 22.268 CR#9r1 adds EU-ALERT specific requirements & CT1 23.041 CRs#
- 3349: -
- 3350: CP#62 completed / WI rapporteur e-mail: Lionel Morand
- 3351: -
- 3352: SP#48 completed. 3/3/15: start date corrected (was 05/09) / WI rapporteur e-mail: Li Gang (ligangyf@chinamobile.com)
- 3353: SP#53 completed. Spin-off Feature UID_500030 Non Voice Emergency Services (NOVES) / WI rapporteur e-mail: dwilliams@qualcomm.com
- 3354: SP#51 completed. Support Interworking between 3GPP networks and Enterprise environments to provide enterprise voice services via 3GPP mobile devices / WI rapporteur e-mail: Phillip Brown (pbrown@tatarasystems.com)
- 3355: SP#52 completed / WI rapporteur e-mail: mona.mustapha@vodafone.com
- 3356: SP#54 completed / WI rapporteur e-mail: Li Gang (ligangyf@chinamobile.com), Yu Qing (yuqing@chinamobile.com)
- 3357: SP#52 completed. 3/3/15: start and finish dates corrected (was start on Jan-00, ends on Jan-02) / WI rapporteur e-mail: farooq.bari@att.com
- 3358: SP#52 completed / WI rapporteur e-mail: Li Lianyuan (lilianyuan@chinamobile.com), Liu Hong (liuhongyfw@chinamobile.com)
- 3359: SP#54 completed. Study on "reverse direction" from UTRAN/GERAN to E-UTRAN/HSPA (Rel-8 SRVCC was in the other direction E-UTRAN/HSPA to GERAN/UTRAN) / WI rapporteur e-mail: delphin.barankanira@orange-ftgroup.com
- 3360: SP#54 completed. Linked to Rel-11 OSCAR (Optimized Service Charging and Allocation of ResourcES in CP-150IMS whilst Roaming) UID_490032. Related to LBO/home routing decision / WI rapporteur e-mail: michele.zarri@telekom.com
- 3361: SP#55 completed / WI rapporteur e-mail: karl.norrman@ericsson.com
- 3362: SP#56 completed. SP#55 TR 33.914v200 approved (converted 33.804). Study reuse of non-UICC credentials (in particular SIP Digest) to provide security for access to applications. Provide reference material for IMS based non-UICC based SSO to applications / WI rapporteur e-mail: Silke.Holtmanns@nokia.com
- 3363: SP#56 completed. Extends Rel-10 work on 3D video formats UID_480044 Improved Video Coding Support for PSS and MBMS / WI rapporteur e-mail: gilles.teniou@orange-ftgroup.com
- 3364: SP#57 completed. TR 32.833v200 for Approval / WI rapporteur e-mail: Jörg Schmidt (J.Schmidt@nsn.com)
- 3365: SP#54 completed / WI rapporteur e-mail: Nick Mazzarella (njmazzarella@alcatel-lucent.com)
- 3366: SP#54 completed. Triggered by Rel-10 UID_430044 TR 32.826 Study on Energy Savings Management (FS_OAM_ESM) and UID_470037 OAM aspects of Energy Saving in Radio Networks (OAM-ES) / WI rapporteur e-mail: clemens.suerbaum@nsn.com
- 3367: CP#52 completed. Linked to SA5 UID_430044 (FS_OAM-ESM) & UID_470037 (OAM-ES), RAN3 UID_470015 (FS_Energy_LTE), RAN1 UID_460016 (FS_Energy_UMTS) / WI rapporteur e-mail: gottfried.punz@nw.neclab.eu
- 3368: CP#58 completed. Continue work in Rel-11 especially to cover handling of Idle mode Signalling Reduction (ISR). Linked to SA2 UID_490036 Study on Core Network Overload solutions / WI rapporteur e-mail: lu.fei1@zte.com.cn
- 3369: GP#53 completed (03/12). GP#46 approved WID. / WI rapporteur e-mail: marten.sundberg@ericsson.com
- 3370: RP#53 completed / WI rapporteur e-mail: bruno.clerckx@samsung.com
- 3371: RP#53 completed. Studied coexistence scenario of LTE and Industrial, Scientific and Medical (ISM) Radio within the same device working in adjacent frequencies / WI rapporteur e-mail: Zhenping Hu (huzhenping@chinamobile.com)
- 3372: RP#57 completed. TR 36.839 v100 for Information & Approval / WI rapporteur e-mail: sudeep.palat@alcatel-lucent.com
- 3373: RP#54 completed / WI rapporteur e-mail: federico.boccardi@alcatel-lucent.com
- 3374: RP#56 completed. TR 36.828 for Information and Approval / WI rapporteur e-mail: Zukang Shen (shenzukang@catt.cn)
- 3375: RP#56 completed. TR 36.824 v200 for Approval / WI rapporteur e-mail: Peng Chen (chenpeng@ctbri.com.cn)
- 3376: RP#55 completed. TR 36.829 v100 for Information + Approval / WI rapporteur e-mail: Yuta Sagae
- 3377: RP#57 completed / WI rapporteur e-mail: Xudong An (anxudong@emcite.com)
- 3378: RP#55 completed. TR 37.976 v200 for Approval / WI rapporteur e-mail: Tim.frost@vodafone.com
- 3379: RP#57 completed. TR 37.806 v200 for Approval / WI rapporteur e-mail: christian.bergljung@ericsson.com
- 3380: RP#53 completed. TR 37.868v100 for Approval (No WID change: RAN overload only). Triggered by TR 22.868 Study on Facilitating Machine to Machine Communication in GSM and UMTS (M2M) UID_7027 and Rel-10 NIMTC UID_410030 / WI rapporteur e-mail: Jeff Gao (gaoyq@huawei.com)
- 3381: RP#54 completed / WI rapporteur e-mail: ron.borsato@spirent.com
- 3382: RP#56 completed. TR 37.803 v200 for Approval / WI rapporteur e-mail: Martin.Warner@alcatel-lucent.com
- 3383: RP#56 completed. Impacts TR 37.804 Study on UMTS/LTE in 900 MHz band (Japan, Korea) UID_520018 / WI rapporteur e-mail: Koo Yeon Sang (yskoo@lguplus.co.kr)
- 3384: RP#56 completed. Updated WID RP-111751=>RP-120617. TR 37.804 v100 for Information and Approval. Linked to Study on Interference analysis between 800~900 MHz bands UID_510038 / WI rapporteur e-mail: Masahiro Fujii (fujiima@nttdocomo.co.jp)
- 3385: RP#53 completed (1-step Approval) / WI rapporteur e-mail: Sharad Sambhwani
- 3386: RP#53 completed / WI rapporteur e-mail: karri.ranta-aho@nsn.com
- 3387: RP#57 completed / WI rapporteur e-mail: petri.j.vasenkari@nokia.com
- 3388: RP#57 completed. TR 25.874 v100 for Information & Approval / WI rapporteur e-mail: limei.wei@td-tech.com
- 3389: RP#56 stopped. RP-120856 discussion: most content moved to Rel-11 Coordinated Multi-Point Operation for LTE Uplink (COMP_LTE_UL) and RAN1 has no time to look at it / WI rapporteur e-mail: Yongxing Zhou
- 3390: -

| ID | WBS | Task | Duration | Start | Finish | Complete | Baseline start | Baseline finish | Baseline duration | Constraint | Resources | Work | Actual work | Acronym | PCG approved | WI rapporteur name | WI rapporteur e-mail | Release | TSG approved | MCC resp | Special Focus Doc | Acronym_3GU_Export | PCG stopped | TSG stopped | Status Report |
| --- | --- | --- | --- | --- | --- | --- | --- | --- | --- | --- | --- | --- | --- | --- | --- | --- | --- | --- | --- | --- | --- | --- | --- | --- | --- |
| 3391 | 929 | **Enhancements for Multimedia Priority Service** | 1311d? | 2006-03-13 A | 2011-03-18 A | 100% | 2006-03-13 | 2011-03-18 | 1311d? |  | S1; S2; C4; C3; C1 | 72120h | 72120h | eMPS | 21 | Telcordia | jgarraha@telcordia.com | Rel-10 | 39 | Alain | Public Safety (I-A) | eMPS |  |  |  |
| 3392 | 929.1 | Stage 1 on enhancements for Multimedia Priority Service | 584d? | 2006-03-13 A | 2008-06-05 A | 100% | 2006-03-13 | 2008-06-05 | 584d? | start no earlier than 2006-03-12 | S1 | 4672h | 4672h | ePRIOR-St1 | 21 | Telcordia | jgarraha@telcordia.com | Rel-10 | 39 | Alain | Public Safety (I-A) | ePRIOR |  |  |  |
| 3393 | 929.2 | **Stage 2 on enhancements for Multimedia Priority Service** | 206d? | 2009-12-10 A | 2010-09-23 A | 100% | 2009-12-10 | 2010-09-23 | 206d? |  | S2 | 6592h | 6592h | ePRIOR-St2 | 24 | Telcordia, NTT DoCoMo | Vijay Varma, Katsutoshi Nishida | Rel-10 | 46 | Maurice | Public Safety (I-A) |  |  |  |  |
| 3394 | 929.2.1 | Stage 2 on eMPS for CSFB | 206d? | 2009-12-10 A | 2010-09-23 A | 100% | 2009-12-10 | 2010-09-23 | 206d? | finish no earlier than 2010-09-24 | S2 | 1648h | 1648h | ePRIOR-St2 | 24 | Telcordia, NTT DoCoMo | Vijay Varma, Katsutoshi Nishida | Rel-10 | 46 | Maurice | Public Safety (I-A) |  |  |  |  |
| 3395 | 929.2.2 | Stage 2 on eMPS for EPS Bearer Service | 206d? | 2009-12-10 A | 2010-09-23 A | 100% | 2009-12-10 | 2010-09-23 | 206d? | finish no earlier than 2010-12-09 | S2 | 1648h | 1648h | ePRIOR-St2 | 24 | Telcordia, NTT DoCoMo | Vijay Varma, Katsutoshi Nishida | Rel-10 | 46 | Maurice | Public Safety (I-A) |  |  |  |  |
| 3396 | 929.2.3 | Stage 2 on eMPS for IMS Aspects | 206d? | 2009-12-10 A | 2010-09-23 A | 100% | 2009-12-10 | 2010-09-23 | 206d? | finish no earlier than 2010-12-09 | S2 | 1648h | 1648h | ePRIOR-St2 | 24 | Telcordia, NTT DoCoMo | Vijay Varma, Katsutoshi Nishida | Rel-10 | 46 | Maurice | Public Safety (I-A) |  |  |  |  |
| 3397 | 929.3 | Deleted - TR 23.854 on Stage 2 on enhancements for Multimedia Priority Service | 266d? | 2009-12-10 A | 2010-12-16 A | 100% | 2009-12-10 | 2010-12-16 | 266d? | finish no earlier than 2011-03-17 | S2 | 2128h | 2128h |  | 24 | Telcordia, NTT DoCoMo | Vijay Varma, Katsutoshi Nishida | Rel-10 | 46 | Maurice | Public Safety (I-A) |  | PCG-27 | SP-50 |  |
| 3398 | 929.4 | **Stage 3 on enhancements for Multimedia Priority Service** | 131d? | 2010-09-17 A | 2011-03-18 A | 100% | 2010-09-17 | 2011-03-18 | 131d? |  | C4; C3; C1 | 6288h | 6288h | eMPS-CN | 25 | Ericsson | Philip.hodges@ericsson.com | Rel-10 | 49 | Kimmo | Public Safety (I-A) | eMPS-CN |  |  |  |
| 3399 | 929.4.1 | CT4 part on Stage 3 on enhancements for Multimedia Priority Service | 131d? | 2010-09-17 A | 2011-03-18 A | 100% | 2010-09-17 | 2011-03-18 | 131d? | start no earlier than 2010-09-17 | C4 | 1048h | 1048h | eMPS-CN | 25 | Ericsson | Philip.hodges@ericsson.com | Rel-10 | 49 | Kimmo | Public Safety (I-A) |  |  |  |  |
| 3400 | 929.4.2 | CT3 part on Stage 3 on enhancements for Multimedia Priority Service | 131d? | 2010-09-17 A | 2011-03-18 A | 100% | 2010-09-17 | 2011-03-18 | 131d? | start no earlier than 2010-09-17 | C3 | 1048h | 1048h | eMPS-CN | 25 | Ericsson | Philip.hodges@ericsson.com | Rel-10 | 49 | Adrian | Public Safety (I-A) |  |  |  |  |
| 3401 | 929.4.3 | CT1 part on Stage 3 on enhancements for Multimedia Priority Service | 131d? | 2010-09-17 A | 2011-03-18 A | 100% | 2010-09-17 | 2011-03-18 | 131d? | start no earlier than 2010-09-17 | C1 | 1048h | 1048h | eMPS-CN | 25 | Ericsson | Philip.hodges@ericsson.com | Rel-10 | 49 | Frederic | Public Safety (I-A) |  |  |  |  |
| 3402 | 930 | **Network Improvements for Machine-Type Communications** | 1365d? | 2008-09-18 A | 2013-11-22 A | 100% | 2008-09-18 | 2013-11-22 | 1365d? |  | S1; S2; S5; C1; C4; C6; G2; R2; R3; R5; G3new | 149017h | 149017h | NIMTC | 21 | KPN | toon.norp@tno.nl | Rel-10 | 41 | Alain | MTC, M2M | NIMTC |  |  |  |
| 3403 | 930.1 | Stage 1 for Network Improvements for Machine-Type Communications | 397d? | 2008-09-18 A | 2010-03-25 A | 100% | 2008-09-18 | 2010-03-25 | 397d? | finish no earlier than 2009-12-10 | S1 | 3176h | 3176h | NIMTC | 21 | KPN | toon.norp@tno.nl | Rel-10 | 41 | Alain | MTC, M2M |  |  |  |  |
| 3404 | 930.2 | Deleted - TR on Stage 2 for Network Improvements for Machine-Type Communications | 321d? | 2009-09-24 A | 2010-12-16 A | 100% | 2009-09-24 | 2010-12-16 | 321d? | finish no earlier than 2010-11-30 | S2 | 2568h | 2568h | NIMTC | 23 | Samsung | erik.guttman@partner.samsung.com | Rel-10 | 45 | Maurice | MTC, M2M |  | PCG-26 | SP-50 |  |
| 3405 | 930.3 | Stage 2 for Network Improvements for Machine-Type Communications | 19d? | 2010-08-30 A | 2010-09-23 A | 100% | 2010-08-30 | 2010-09-23 | 19d? | finish no earlier than 2010-09-17 | S2 | 152h | 152h | NIMTC | 23 | Samsung | erik.guttman@partner.samsung.com | Rel-10 | 45 | Maurice | MTC, M2M |  |  |  |  |
| 3406 | 930.4 | Deleted - Security for Network Improvements for Machine-Type Communications | 193.15d? | 2009-12-10 A | 2010-09-23 A | 100% | 2009-12-10 | 2010-09-23 | 193.15d? | finish no earlier than 2010-09-23 | S3 | 1545.2h | 1545.2h | NIMTC | 24 | Samsung | Rajavelsamy R (rajvel@samsung.com) | Rel-10 | 46 | Mirko | MTC, M2M |  | PCG-25 | SP-49 |  |
| 3407 | 930.5 | Charging for Network Improvements for Machine-Type Communication | 3d? | 2011-03-21 A | 2011-03-23 A | 100% | 2011-03-21 | 2011-03-23 | 3d? | start no earlier than 2011-03-21 | S5 | 24h | 24h | NIMTC-CH | 26 | Ericsson | patrik.teppo@@ericsson.com | Rel-10 | 51 | Mirko | MTC, M2M | NIMTC-CH |  |  |  |
| 3408 | 930.6 | **CN part of Stage 3 for Network Improvements for Machine-Type Communications** | 261d? | 2010-06-04 A | 2011-06-03 A | 100% | 2010-06-04 | 2011-06-03 | 261d? |  | C1; C4; C6 | 12976h | 12976h | NIMTC-CN | 25 | Ericsson | mikael.wass@ericsson.com | Rel-10 | 48 | Frederic | MTC, M2M | NIMTC-CN |  |  |  |
| 3409 | 930.6.1 | CT1 part of Stage 3 for Network Improvements for Machine-Type Communications | 261d? | 2010-06-04 A | 2011-06-03 A | 100% | 2010-06-04 | 2011-06-03 | 261d? | finish no earlier than 2011-06-03 | C1 | 2088h | 2088h | NIMTC-CN | 25 | Ericsson | mikael.wass@ericsson.com | Rel-10 | 48 | Frederic | MTC, M2M |  |  |  |  |
| 3410 | 930.6.2 | Deleted - CT3 part of Stage 3 for Network Improvements for Machine-Type Communications | 261d? | 2010-06-04 A | 2011-06-03 A | 100% | 2010-06-04 | 2011-06-03 | 261d? | finish no earlier than 2010-12-10 | C3 | 2088h | 2088h | NIMTC-CN | 25 | Ericsson | mikael.wass@ericsson.com | Rel-10 | 48 | Adrian | MTC, M2M |  | PCG-27 | CP-52 |  |
| 3411 | 930.6.3 | CT4 part of Stage 3 for Network Improvements for Machine-Type Communications | 261d? | 2010-06-04 A | 2011-06-03 A | 100% | 2010-06-04 | 2011-06-03 | 261d? | finish no earlier than 2011-03-18 | C4 | 2088h | 2088h | NIMTC-CN | 25 | Ericsson | mikael.wass@ericsson.com | Rel-10 | 48 | Kimmo | MTC, M2M |  |  |  |  |
| 3412 | 930.6.4 | CT6 part of Stage 3 for Network Improvements for Machine-Type Communications | 56d? | 2011-03-18 A | 2011-06-03 A | 100% | 2011-03-18 | 2011-06-03 | 56d? | finish no earlier than 2011-06-03 | C6 | 448h | 448h | NIMTC-CN | 26 | Sagem-Orga | heiko.kruse@sagem-orga.com | Rel-10 | 51 | Xavier | MTC, M2M |  |  |  |  |
| 3413 | 930.7 | GERAN part of Network Improvements for Machine-Type Communications (Stage 3) | 261d? | 2010-09-03 A | 2011-09-02 A | 100% | 2010-09-03 | 2011-09-02 | 261d? | finish no earlier than 2011-09-02 | G2 | 2088h | 2088h | NIMTC | 25 | Vodafone, Ericsson | leo.patanapongpibul@vodafone.com, john.diachina@ericsson.com | Rel-10 | 47 | Gert | MTC, M2M |  |  |  |  |
| 3414 | 930.8 | MS Conformance Test Aspects for GERAN - Network Improvements for Machine-Type Communications | 333d? | 2012-08-27 A | 2013-11-22 A | 100% | 2012-08-27 | 2013-11-22 | 333d? | finish no earlier than 2013-11-22 | G3new | 2656h | 2656h | NIMTC_GERAN-MSTest | 29 | ST-Ericsson | hakan.e.grunditz@stericsson.com | Rel-10 | 55 | Ingbert | MTC, M2M | NIMTC_GERAN-MSTest |  |  |  |
| 3415 | 930.9 | RAN mechanisms to avoid CN overload due to Machine-Type Communications | 131d? | 2010-09-17 A | 2011-03-18 A | 100% | 2010-09-17 | 2011-03-18 | 131d? | finish no earlier than 2011-03-18 | R2; R3 | 2096h | 2096h | NIMTC-RAN_overload | 25 | Huawei | Jeff Gao (gaoyq@huawei.com) | Rel-10 | 49 | Yong-Jun | MTC, M2M | NIMTC-RAN_overload |  |  | RP-110063 |
| 3416 | 930.10 | UE Conformance Test Aspects - Network Improvements for Machine-Type Communications | 202d? | 2012-09-11 A | 2013-06-14 A | 100% | 2012-09-11 | 2013-06-14 | 202d? | finish no earlier than 2013-06-14 | R5 | 1616h | 1616h | NIMTC-UEConTest | 29 | Ericsson | calle.hagenfeldt@ericsson.com | Rel-10 | 57 | Ingbert | MTC, M2M | NIMTC-UEConTest |  |  | RP-130465 |

Notes:
- 3391: CP#51 completed. SP#49 moved Stage 1 from Rel-9 & Completed Stage 2. SP#40 Stage 1 completed. Continuation of Rel-8 Feature PRIOR (UID_340044)
- 3392: 22/01: acronym modified / Impacted TSs and TRs: 22.153, 22.278
- 3393: 22/01: acronym modified
- 3394: 22/01: acronym modified / Impacted TSs and TRs: 23.002, 23.203, 23.221, 23.228, 23.272, 23.401
- 3395: 22/01: acronym modified / Impacted TSs and TRs: 23.002, 23.203, 23.221, 23.228, 23.272, 23.401
- 3396: 22/01: acronym modified / Impacted TSs and TRs: 23.002, 23.203, 23.221, 23.228, 23.272, 23.401
- 3397: SP#49 TR 23.854 v100 for Information. SP#50 moved to Rel-11 SRVCC aspect of enhancements for Multimedia Priority Service UID_480135 (place holder for solution alternatives and agreed functions to be reflected in affected existing TS) / Impacted TSs and TRs: new TR 23.854
- 3398: CP#51 completed / Impacted TSs and TRs: Stage 3
- 3399: CP#51 completed / Impacted TSs and TRs: 23.008, 29.002, 29.228, 29.229, 29.272, 29.274, 29.277, 29.328, 29.329
- 3400: CP#51 completed / Impacted TSs and TRs: 29.212, 29.213, 29.214
- 3401: CP#51 completed / Impacted TSs and TRs: 24.008, 24.229, 24.301
- 3402: Triggered by Rel-8 UID_7027 Study on Facilitating Machine to Machine Communication in GSM and UMTS (FS_M2M) TR 22.868
- 3403: SP#47 completed / Impacted TSs and TRs: 22.011, New 22.368
- 3404: SP#50 updated WID SP-090832=>SP-100863 (TR 23.888 not submitted for approval to conclude Rel-10 NIMTC as it will continue to serve as basis for Rel-11 SIMTC work item) / Impacted TSs and TRs: New TR 23.888
- 3405: SP#49 completed / Impacted TSs and TRs: 23.060, 23.236, 23.401
- 3406: SP#49 stopped (activity transferred to Rel-11 Feature SIMTC under UID_490028 "TR on Security aspects of Machine-Type Communications". / Impacted TSs and TRs: New TR 33.868
- 3407: SP#51 completed / Impacted TSs and TRs: 32.251, 32.298, 32.299
- 3408: CP#52 completed / Impacted TSs and TRs: Stage 3
- 3409: CP#52 completed / Impacted TSs and TRs: 23.122, 24.008, 24.301, New 24.368
- 3410: CP#52 stopped (SA2 decided to move impact from CT3 to CT4). Updated WID CP-110147=>CP-110442 (no CT3 impact) / Impacted TSs and TRs: 29.212, 29.213, 29.215
- 3411: CP#52 completed / Impacted TSs and TRs: 23.003, 23.008, 29.002, 29.060, 29.230, 29.272, 29.274, 29.275, 29.282
- 3412: CP#52 completed / Impacted TSs and TRs: 31.102
- 3413: GP#51 completed. GP#47 approved WID / Impacted TSs and TRs: 44.018, 44.060
- 3414: GP#60 completed. GP#55 approved WID. Testing for CT1 part of Stage 3 for NIMTC UID_480105, GERAN part of NIMTC (Stage 3) UID_490003 / Impacted TSs and TRs: 51.010-1, 51.010-2
- 3415: RP#51 completed / Impacted TSs and TRs: UTRA, LTE 25.331, 25.413, 36.331, 36.413
- 3416: RP#60 completed. Testing for CT1 part of Stage 3 UID_480105, RAN mechanisms to avoid CN overload due to MTC UID_490024 / Impacted TSs and TRs: 34.123-1, 34.123-2, 34.123-3, 36.523-1, 36.523-2, 36.523-3

| ID | WBS | Task | Duration | Start | Finish | Complete | Baseline start | Baseline finish | Baseline duration | Constraint | Resources | Work | Actual work | Acronym | PCG approved | WI rapporteur name | Release | TSG approved | MCC resp | Acronym_3GU_Export | Special Focus Doc |
| --- | --- | --- | --- | --- | --- | --- | --- | --- | --- | --- | --- | --- | --- | --- | --- | --- | --- | --- | --- | --- | --- |
| 3417 | 931 | **Multi Access PDN Connectivity** | 527d? | 2009-03-13 A | 2011-03-18 A | 100% | 2009-03-13 | 2011-03-18 | 527d? |  | S2; C4; C1; C3 | 23680h | 23680h | MAPCON | 22 | Telecom Italia | Rel-10 | 43 | Maurice | MAPCON |  |
| 3418 | 931.1 | Stage 2 for Multi Access PDN Connectivity | 401d? | 2009-03-13 A | 2010-09-23 A | 100% | 2009-03-13 | 2010-09-23 | 401d? |  | S2 | 3208h | 3208h | MAPCON |  | Telecom Italia | Rel-10 | 43 | Maurice |  |  |
| 3419 | 931.2 | **CT aspects of Multi Access PDN Connectivity** | 90d? | 2010-11-15 A | 2011-03-18 A | 100% | 2010-11-15 | 2011-03-18 | 90d? |  | C4; C1; C3 | 3608h | 3608h | MAPCON-St3 | 26 | ZTE | Rel-10 | 50 | Kimmo | MAPCON-St3 |  |
| 3420 | 931.2.1 | CT4 aspects of Multi Access PDN Connectivity | 20d? | 2010-11-15 A | 2010-12-10 A | 100% | 2010-11-15 | 2010-12-10 | 20d? | start no earlier than 2010-12-10 | C4 | 160h | 160h | MAPCON-St3 | 26 | ZTE | Rel-10 | 50 | Kimmo |  |  |
| 3421 | 931.2.2 | CT1 aspects of Multi Access PDN Connectivity | 71d? | 2010-12-10 A | 2011-03-18 A | 100% | 2010-12-10 | 2011-03-18 | 71d? | start no earlier than 2010-12-10 | C1 | 568h | 568h | MAPCON-St3 | 26 | ZTE | Rel-10 | 50 | Frederic |  |  |
| 3422 | 931.2.3 | CT3 aspects of Multi Access PDN Connectivity | 90d? | 2010-11-15 A | 2011-03-18 A | 100% | 2010-11-15 | 2011-03-18 | 90d? | finish no earlier than 2011-03-18 | C3 | 720h | 720h | MAPCON-St3 | 26 | ZTE | Rel-10 | 50 | Adrian |  |  |
| 3423 | 932 | **IMS Service Continuity – Inter Device Transfer enhancements** | 924d? | 2009-06-04 A | 2012-12-07 A | 100% | 2009-06-04 | 2012-12-07 | 924d? |  | S1; S2; C1; IETF | 41168h | 41168h | IMS_SC_eIDT | 23 | Huawei | Rel-10 | 44 | Alain | IMS_SC_eIDT |  |
| 3424 | 932.1 | Stage 1 - IMS Service Continuity – Inter Device Transfer enhancements | 211d? | 2009-06-04 A | 2010-03-25 A | 100% | 2009-06-04 | 2010-03-25 | 211d? | finish no earlier than 2010-03-25 | S1 | 1688h | 1688h | IMS_SC_eIDT | 23 | Huawei | Rel-10 | 44 | Alain |  |  |
| 3425 | 932.2 | Stage 2 - IMS Inter-UE Transfer enhancements | 261d? | 2009-09-24 A | 2010-09-23 A | 100% | 2009-09-24 | 2010-09-23 | 261d? | finish no earlier than 2010-09-23 | S2 | 2088h | 2088h | IMS_SC_eIDT | 23 | Huawei | Rel-10 | 45 | Maurice |  |  |
| 3426 | 932.3 | Stage 3 - IMS Inter-UE Transfer enhancements | 261d? | 2010-03-19 A | 2011-03-18 A | 100% | 2010-03-19 | 2011-03-18 | 261d? | start no earlier than 2010-03-19 | C1 | 2088h | 2088h | IMS_SC_eIDT | 24 | Huawei | Rel-10 | 47 | Frederic |  |  |
| 3427 | 932.4 | (IETF) Stage 3 - IMS Inter-UE Transfer enhancements | 717d? | 2010-03-19 A | 2012-12-07 A | 100% | 2010-03-19 | 2012-12-07 | 717d? | finish no earlier than 2012-12-04 | C1-IETF | 5736h | 5736h | IMS_SC_eIDT | 27 | christer.holmberg@ericsson.com | Rel-10 | 52 | Frederic |  |  |
| 3428 | 933 | **IP-Short-Message-Gateway enhancements for CPM-SMS Interworking** | 257d? | 2009-09-24 A | 2010-09-17 A | 100% | 2009-09-24 | 2010-09-17 | 257d? |  | S1; S2; C3 | 9904.8h | 9904.8h | CPM-SMS | 23 | China Mobile | Rel-10 | 45 | Alain | CPM-SMS |  |
| 3429 | 933.1 | Stage 1 for CPM-SMS | 131d? | 2009-09-24 A | 2010-03-25 A | 100% | 2009-09-24 | 2010-03-25 | 131d? | finish no earlier than 2010-03-25 | S1 | 1048h | 1048h | CPM-SMS | 23 | China Mobile | Rel-10 | 45 | Alain |  |  |
| 3430 | 933.2 | Stage 2 for CPM-SMS | 130.1d? | 2009-09-24 A | 2010-03-25 A | 100% | 2009-09-24 | 2010-03-25 | 130.1d? | finish no earlier than 2010-03-25 | S2 | 1040.8h | 1040.8h | CPM-SMS | 23 | Orange | Rel-10 | 45 | Maurice |  |  |
| 3431 | 933.3 | Stage 3 for IP-Short-Message-Gateway enhancements for CPM-SMS Interworking | 206d? | 2009-12-04 A | 2010-09-17 A | 100% | 2009-12-04 | 2010-09-17 | 206d? | finish no earlier than 2010-09-17 | C3 | 1648h | 1648h | CPM-SMS | 24 | Ericsson | Rel-10 | 46 | Adrian |  |  |
| 3432 | 934 | **Completion of Communications on Not Logged-in** | 387d? | 2009-09-24 A | 2011-03-18 A | 100% | 2009-09-24 | 2011-03-18 | 387d? |  | S1; C1; C3 | 11992h | 11992h | CCNL | 23 | Deutsche Telekom | Rel-10 | 45 | Alain | CCNL |  |
| 3433 | 934.1 | Stage 1 for Completion of Communications on Not Logged-in | 1d? | 2009-09-24 A | 2009-09-24 A | 100% | 2009-09-24 | 2009-09-24 | 1d? | start no earlier than 2009-09-24 | S1 | 8h | 8h | CCNL | 23 | Deutsche Telekom | Rel-10 | 45 | Alain |  |  |
| 3434 | 934.2 | CT1 part of Stage 3 for Completion of Communications on Not Logged-in | 261d? | 2010-03-19 A | 2011-03-18 A | 100% | 2010-03-19 | 2011-03-18 | 261d? | finish no earlier than 2011-03-18 | C1 | 2088h | 2088h | CCNL | 24 | Deutsche Telekom | Rel-10 | 47 | Frederic |  |  |
| 3435 | 934.3 | CT3 part of Stage 3 for Completion of Communications on Not Logged-in | 76d? | 2010-06-04 A | 2010-09-17 A | 100% | 2010-06-04 | 2010-09-17 | 76d? | finish no earlier than 2010-09-17 | C3 | 608h | 608h | CCNL | 25 | Deutsche Telekom | Rel-10 | 48 | Adrian |  |  |
| 3436 | 935 | **Local IP Access and Selected Internet IP Traffic Offload** | 390d? | 2009-09-24 A | 2011-03-23 A | 100% | 2009-09-24 | 2011-03-23 | 390d? |  | S2; S1; S3; S5; C4; C1 | 66128h | 66128h | LIPA_SIPTO | 23 | Huawei, China Mobile | Rel-10 | 45 | Maurice | LIPA_SIPTO | HNB |
| 3437 | 935.1 | Stage 1 for Local IP Access and Selected Internet IP Traffic Offload | 131d? | 2009-09-24 A | 2010-03-25 A | 100% | 2009-09-24 | 2010-03-25 | 131d? | finish no earlier than 2010-03-25 | S1 | 1048h | 1048h | LIPA_SIPTO | 23 | Huawei, China Mobile | Rel-10 | 45 | Alain |  | HNB |
| 3438 | 935.2 | TR on Local IP Access and Selected Internet IP Traffic Offload | 387d? | 2009-09-24 A | 2011-03-18 A | 100% | 2009-09-24 | 2011-03-18 | 387d? | finish no earlier than 2011-03-18 | S2 | 3096h | 3096h | LIPA_SIPTO | 23 | Huawei, China Mobile | Rel-10 | 45 | Maurice |  | HNB |
| 3439 | 935.3 | Security for Local IP Access and Selected Internet IP Traffic Offload | 261d? | 2009-09-24 A | 2010-09-23 A | 100% | 2009-09-24 | 2010-09-23 | 261d? | finish no earlier than 2010-09-23 | S3 | 2088h | 2088h | LIPA_SIPTO | 23 | Huawei, Qualcomm | Rel-10 | 45 | Mirko |  | HNB |
| 3440 | 935.4 | OAM&P for Local IP Access and Selected Internet IP Traffic Offload | 390d? | 2009-09-24 A | 2011-03-23 A | 100% | 2009-09-24 | 2011-03-23 | 390d? | finish no earlier than 2011-03-23 | S5 | 3120h | 3120h | LIPA_SIPTO | 23 | Huawei, China Mobile | Rel-10 | 45 | Mirko |  | HNB |
| 3441 | 935.5 | Charging for Local IP Access and Selected Internet IP Traffic Offload | 335d? | 2009-12-10 A | 2011-03-23 A | 100% | 2009-12-10 | 2011-03-23 | 335d? | finish no earlier than 2011-03-23 | S5 | 2680h | 2680h | LIPA_SIPTO | 24 | Huawei, China Mobile | Rel-10 | 46 | Mirko |  | HNB |

Notes:
- 3417: CP#51 completed. SP#49 Stage 2 completed. Triggered by TR 23.861 UID_410043 FS_MAPIM. Stage 1 in Rel-9 22.278 (6.2 - IP session control) / WI rapporteur e-mail: ivano.guardini@telecomitalia.it
- 3418: SP#49 completed. Triggered by TR 23.861 UID_410043 FS_MAPIM. Stage 1 in Rel-9 22.278 (6.2 - IP session control) / Impacted TSs and TRs: 23.237, 23.401, 23.402 / WI rapporteur e-mail: ivano.guardini@telecomitalia.it
- 3419: CP#51 completed / WI rapporteur e-mail: Xingyue (Joy) Zhou (zhou.xingyue@zte.com.cn)
- 3420: CP#50 completed / Impacted TSs and TRs: 29.273, 29.272, 29.002, 23.008 / WI rapporteur e-mail: Xingyue (Joy) Zhou (zhou.xingyue@zte.com.cn)
- 3421: CP#51 completed / Impacted TSs and TRs: 24.302, 24.312 / WI rapporteur e-mail: Xingyue (Joy) Zhou (zhou.xingyue@zte.com.cn)
- 3422: CP#51 completed / Impacted TSs and TRs: 29.215 / WI rapporteur e-mail: Xingyue (Joy) Zhou (zhou.xingyue@zte.com.cn)
- 3423: CP#51 completed. SP#47 Stage 1 completed. Rel-9 set Inter-Device Transfer requirements UID_410033 (IMS_SCC-IDT). Adds IDT scenarios and requirements / WI rapporteur e-mail: Amar Deol (adeol@huawei.com)
- 3424: SP#47 completed / Impacted TSs and TRs: 22.228 / WI rapporteur e-mail: Amar Deol (adeol@huawei.com)
- 3425: SP#49 completed / Impacted TSs and TRs: 23.237, 23.292, new 23.831 / WI rapporteur e-mail: Lee Valerius (lvalerius@huawei.com)
- 3426: CP#51 completed. WID updated CP-100334=>CP-110285 / Impacted TSs and TRs: 24.216, 24.229, 24.237, new (24.837, 24.337) / WI rapporteur e-mail: georg.mayer@huawei.com
- 3427: CP#58 completed / Impacted TSs and TRs: RFC 6809 (was draft-ietf-sipcore-proxy-feature) / WI rapporteur e-mail: christer.holmberg@ericsson.com
- 3428: CP#49 completed. SP#47 Stage 1 completed. IP-SM-GW enhancements for interworking with OMA CPM / WI rapporteur e-mail: Qing Huang (huangqing@chinamobile.com)
- 3429: SP#47 completed. External requirements (Stage 1 in OMA-RD-CPM-V1_0-20090310-C) / Impacted TSs and TRs: 22.340 / WI rapporteur e-mail: Qing Huang
- 3430: SP#47 completed / Impacted TSs and TRs: 23.204, new TR 23.824 / WI rapporteur e-mail: antoine.mouquet@orange-ftgroup.com
- 3431: CP#49 completed. Linked to Rel-8 UID_340031 Service-Level Interworking for Messaging Services (MESSIW) 23.204 / Impacted TSs and TRs: 29.311 / WI rapporteur e-mail: Jan Holm
- 3432: CP#51 completed. SP#45 Stage 1 completed / WI rapporteur e-mail: Kurt Bischinger
- 3433: SP#45 completed / Impacted TSs and TRs: 22.173 CR#0056r1 / WI rapporteur e-mail: Kurt Bischinger
- 3434: CP#51 completed / Impacted TSs and TRs: 24.173, 24.642 / WI rapporteur e-mail: martin.huelsemann@telekom.de
- 3435: CP#49 completed / Impacted TSs and TRs: 29.165 / WI rapporteur e-mail: martin.huelsemann@telekom.de
- 3436: TSG#51 completed. Updated WID SP-100696=>SP-110131. SP#49 Stage 2 & Security completed. UID_400035 Enhanced Home NodeB/eNodeB (EHNB) formerly covered Local IP Access to Internet and Local access to Home Network from the Home NodeB/eNodeB / WI rapporteur e-mail: patrice.hede@huawei.com, Tao Sun (suntao@chinamobile.com)
- 3437: SP#47 completed / Impacted TSs and TRs: 22.101, 22.220 / WI rapporteur e-mail: Amar Deol (adeolf@huawei.com), Gang Li (ligangyf@chinamobile.com)
- 3438: SP#51 completed. TR 23.829 for Approval / Impacted TSs and TRs: New TR 23.829 / WI rapporteur e-mail: patrice.hede@huawei.com, Tao Sun (suntao@chinamobile.com)
- 3439: SP#49 completed / Impacted TSs and TRs: 33.102, 33.107, 33.108, 33.320, 33.401 / WI rapporteur e-mail: Marcus Wong (mwong@huawei.com), Brian Rosenberg (bmr@qualcomm.com)
- 3440: SP#51 completed. Updated WID SP-100696=>SP-110131 / Impacted TSs and TRs: 32.581, 32.582, 32.584, 32.591, 32.592, 32.642, 32.646, 32.772, 32.782 / WI rapporteur e-mail: Zou Lan (zlan@huawei.com), Chen Gang (chengang@chinamobile.com)
- 3441: SP#51 completed. Updated WID SP-100696=>SP-110131 / Impacted TSs and TRs: 32.251 / WI rapporteur e-mail: shan.mingjun@huawei.com, Ai Chen (chenai@chinamobile.com)

| ID | WBS | Task | Duration | Start | Finish | Complete | Baseline start | Baseline finish | Baseline duration | Constraint | Resources | Work | Actual work | Acronym | PCG approved | WI rapporteur name | WI rapporteur e-mail | Release | TSG approved | MCC resp | Special Focus Doc | Acronym_3GU_Export |
| --- | --- | --- | --- | --- | --- | --- | --- | --- | --- | --- | --- | --- | --- | --- | --- | --- | --- | --- | --- | --- | --- | --- |
| 3442 | 935.6 | **Stage 2/3 for Local IP Access** | 387d? | 2009-09-24 A | 2011-03-18 A | 100% | 2009-09-24 | 2011-03-18 | 387d? |  | S2; C4; C1 | 17968h | 17968h | LIPA | 23 | Huawei, China Mobile | patrice.hede@huawei.com, Tao Sun (suntao@chinamobile.com) | Rel-10 | 45 | Maurice | HNB | LIPA |
| 3443 | 935.6.1 | Stage 2 for Local IP Access | 261d? | 2009-09-24 A | 2010-09-23 A | 100% | 2009-09-24 | 2010-09-23 | 261d? | finish no earlier than 2010-08-10 | S2 | 2088h | 2088h | LIPA | 23 | Huawei, China Mobile | patrice.hede@huawei.com, Tao Sun (suntao@chinamobile.com) | Rel-10 | 45 | Maurice | HNB |  |
| 3444 | 935.6.2 | **Stage 3 for Local IP Access** | 206d? | 2010-06-04 A | 2011-03-18 A | 100% | 2010-06-04 | 2011-03-18 | 206d? |  | C4; C1 | 6592h | 6592h | LIPA | 25 | China Mobile | Zhang Hao (zhanghao@chinamobile.com) | Rel-10 | 48 | Kimmo | HNB |  |
| 3445 | 935.6.2.1 | CT4 part of Stage 3 for Local IP Access | 206d? | 2010-06-04 A | 2011-03-18 A | 100% | 2010-06-04 | 2011-03-18 | 206d? | finish no earlier than 2011-03-18 | C4 | 1648h | 1648h | LIPA | 25 | China Mobile | Zhang Hao (zhanghao@chinamobile.com) | Rel-10 | 48 | Kimmo | HNB |  |
| 3446 | 935.6.2.2 | CT1 part of Stage 3 for Local IP Access | 206d? | 2010-06-04 A | 2011-03-18 A | 100% | 2010-06-04 | 2011-03-18 | 206d? | finish no earlier than 2011-03-18 | C1 | 1648h | 1648h | LIPA | 25 | China Mobile | Zhang Hao (zhanghao@chinamobile.com) | Rel-10 | 48 | Frederic | HNB |  |
| 3447 | 935.7 | **Stage 2/3 for SIPTO for macro networks** | 387d? | 2009-09-24 A | 2011-03-18 A | 100% | 2009-09-24 | 2011-03-18 | 387d? |  | S2; C4; C1 | 17408h | 17408h | SIPTO | 23 | Huawei, China Mobile | patrice.hede@huawei.com, Tao Sun (suntao@chinamobile.com) | Rel-10 | 45 | Maurice | HNB | SIPTO |
| 3448 | 935.7.1 | Stage 2 for SIPTO for macro networks | 261d? | 2009-09-24 A | 2010-09-23 A | 100% | 2009-09-24 | 2010-09-23 | 261d? | finish no earlier than 2010-09-23 | S2 | 2088h | 2088h | SIPTO | 23 | Huawei, China Mobile | patrice.hede@huawei.com, Tao Sun (suntao@chinamobile.com) | Rel-10 | 45 | Maurice | HNB |  |
| 3449 | 935.7.2 | **Stage 3 for SIPTO for macro networks** | 206d? | 2010-06-04 A | 2011-03-18 A | 100% | 2010-06-04 | 2011-03-18 | 206d? |  | C4; C1 | 6032h | 6032h | SIPTO | 25 | Huawei | Caixia Qi (qcxmay@huawei.com) | Rel-10 | 48 | Kimmo | HNB |  |
| 3450 | 935.7.2.1 | CT4 part of Stage 3 for SIPTO for macro networks | 206d? | 2010-06-04 A | 2011-03-18 A | 100% | 2010-06-04 | 2011-03-18 | 206d? | finish no earlier than 2011-03-18 | C4 | 1648h | 1648h | SIPTO | 25 | Huawei | Caixia Qi (qcxmay@huawei.com) | Rel-10 | 48 | Kimmo | HNB |  |
| 3451 | 935.7.2.2 | CT1 part of Stage 3 for SIPTO for macro networks | 136d? | 2010-06-04 A | 2010-12-10 A | 100% | 2010-06-04 | 2010-12-10 | 136d? | finish no earlier than 2011-03-18 | C1 | 1088h | 1088h | SIPTO | 25 | Huawei | Caixia Qi (qcxmay@huawei.com) | Rel-10 | 48 | Frederic | HNB |  |
| 3452 | 936 | **IP Flow Mobility and seamless WLAN offload** | 390d? | 2009-09-24 A | 2011-03-23 A | 100% | 2009-09-24 | 2011-03-23 | 390d? |  | S2; S1; S5; C1; C3 | 26808h | 26808h | IFOM | 23 | Qualcomm | Gerardo Giaretta (gerardo@qualcomm.com) | Rel-10 | 45 | Maurice | WLAN | IFOM |
| 3453 | 936.1 | Stage 1 for IP Flow Mobility and seamless WLAN offload | 56d? | 2009-09-24 A | 2009-12-10 A | 100% | 2009-09-24 | 2009-12-10 | 56d? | finish no earlier than 2009-12-10 | S1 | 448h | 448h | IFOM | 23 | Qualcomm | David Williams (dwilliam@qualcomm.com) | Rel-10 | 45 | Alain | WLAN |  |
| 3454 | 936.2 | Stage 2 for IP Flow Mobility and seamless WLAN offload | 261d? | 2009-09-24 A | 2010-09-23 A | 100% | 2009-09-24 | 2010-09-23 | 261d? | finish no earlier than 2010-09-23 | S2 | 2088h | 2088h | IFOM | 23 | Qualcomm | Gerardo Giaretta (gerardo@qualcomm.com) | Rel-10 | 45 | Maurice | WLAN |  |
| 3455 | 936.3 | Charging for IP Flow Mobility and seamless WLAN offload | 260d? | 2010-03-25 A | 2011-03-23 A | 100% | 2010-03-25 | 2011-03-23 | 260d? | finish no earlier than 2011-03-23 | S5 | 2080h | 2080h | IFOM | 24 | Alcatel-Lucent | maryse.gardella@alcatel-lucent.com | Rel-10 | 47 | Mirko | WLAN |  |
| 3456 | 936.4 | **Stage 3 for IP Flow Mobility and seamless WLAN offload** | 206d? | 2010-06-04 A | 2011-03-18 A | 100% | 2010-06-04 | 2011-03-18 | 206d? |  | C1; C3 | 6592h | 6592h | IFOM-CT | 25 | Qualcomm | Patrick Stupar (pstupar@qualcomm.com) | Rel-10 | 48 | Frederic | WLAN | IFOM-CT |
| 3457 | 936.4.1 | CT1 part of Stage 3 for IP Flow Mobility and seamless WLAN offload | 206d? | 2010-06-04 A | 2011-03-18 A | 100% | 2010-06-04 | 2011-03-18 | 206d? | finish no earlier than 2011-03-18 | C1 | 1648h | 1648h | IFOM-CT | 25 | Qualcomm | Patrick Stupar (pstupar@qualcomm.com) | Rel-10 | 48 | Frederic | WLAN |  |
| 3458 | 936.4.2 | CT3 part of Stage 3 for IP Flow Mobility and seamless WLAN offload | 206d? | 2010-06-04 A | 2011-03-18 A | 100% | 2010-06-04 | 2011-03-18 | 206d? | finish no earlier than 2011-03-18 | C3 | 1648h | 1648h | IFOM-CT | 25 | Qualcomm | Patrick Stupar (pstupar@qualcomm.com) | Rel-10 | 48 | Adrian | WLAN |  |
| 3459 | 937 | **Enabling Coder Selection and Rate Adaptation for UTRAN and E-UTRAN for Load Adaptive Applications** | 827.4d? | 2009-07-15 A | 2012-09-07 A | 100% | 2009-07-15 | 2012-09-07 | 827.4d? |  | S2; S4; C4; C3; C1; IETF | 85939.2h | 85939.2h | ECSRA_LAA | 23 | Qualcomm | AC Mahendran (ac@qualcomm.com) | Rel-10 | 45 | Maurice |  | ECSRA_LAA |
| 3460 | 937.1 | TR on Enabling Coder Selection and Rate Adaptation for UTRAN and E-UTRAN for Load Adaptive Applications | 186d? | 2010-01-07 A | 2010-09-23 A | 100% | 2010-01-07 | 2010-09-23 | 186d? | finish no earlier than 2010-09-23 | S2; S4 | 2976h | 2976h | ECSRA_LAA | 23 | Qualcomm | AC Mahendran (ac@qualcomm.com) | Rel-10 | 45 | Maurice |  |  |
| 3461 | 937.2 | SA4 review of TR on Enabling Coder Selection and Rate Adaptation for UTRAN and E-UTRAN for Load Adaptive Applications | 320d? | 2009-09-24 A | 2010-12-15 A | 100% | 2009-09-24 | 2010-12-15 | 320d? | finish no earlier than 2010-12-15 | S4 | 2560h | 2560h | ECSRA_LAA | 23 | Qualcomm | AC Mahendran (ac@qualcomm.com) | Rel-10 | 45 | Paolo |  |  |
| 3462 | 937.3 | Stage 2 for Enabling Coder Selection and Rate Adaptation for UTRAN and E-UTRAN for Load Adaptive Applications | 261d? | 2009-09-24 A | 2010-09-23 A | 100% | 2009-09-24 | 2010-09-23 | 261d? | finish no earlier than 2010-09-23 | S2 | 2088h | 2088h | ECSRA_LAA | 23 | Qualcomm | AC Mahendran (ac@qualcomm.com) | Rel-10 | 45 | Maurice |  |  |
| 3463 | 937.4 | SA4 aspects of Enabling Coder Selection and Rate Adaptation for UTRAN and E-UTRAN for Load Adaptive Applications | 130d? | 2010-09-23 A | 2011-03-23 A | 100% | 2010-09-23 | 2011-03-23 | 130d? | finish no earlier than 2011-03-23 | S4 | 1040h | 1040h | ECSRA_LAA | 25 | Qualcomm | AC Mahendran (ac@qualcomm.com) | Rel-10 | 49 | Paolo |  |  |
| 3464 | 937.5 | **CN aspects of Enabling Coder Selection and Rate Adaptation for UTRAN and E-UTRAN for Load Adaptive Applications** | 827.4d? | 2009-07-15 A | 2012-09-07 A | 100% | 2009-07-15 | 2012-09-07 | 827.4d? |  | C4; C3; C1 | 37560h | 37560h | ECSRA_LAA-CN | 25 | Ericsson | philip.hodges@ericsson.com | Rel-10 | 49 | Kimmo |  | ECSRA_LAA-CN |
| 3465 | 937.5.1 | CT4 part of CN aspects of Enabling Coder Selection and Rate Adaptation for UTRAN and E-UTRAN for Load Adaptive Applications | 186d? | 2010-09-17 A | 2011-06-03 A | 100% | 2010-09-17 | 2011-06-03 | 186d? | start no earlier than 2010-09-17 | C4 | 1488h | 1488h | ECSRA_LAA-CN | 25 | Ericsson | philip.hodges@ericsson.com | Rel-10 | 49 | Kimmo |  |  |
| 3466 | 937.5.2 | (IETF) CT3, CT4 part of CN aspects of Enabling Coder Selection and Rate Adaptation for UTRAN and E-UTRAN for Load Adaptive Applications | 827.4d? | 2009-07-15 A | 2012-09-07 A | 100% | 2009-07-15 | 2012-09-07 | 827.4d? | finish no earlier than 2012-09-07 | C3-IETF; C4-IETF | 13238.4h | 13238.4h | ECSRA_LAA-CN | 27 | Lionel Morand |  | Rel-10 | 53 | Adrian |  |  |
| 3467 | 937.5.3 | CT3 part of CN aspects of Enabling Coder Selection and Rate Adaptation for UTRAN and E-UTRAN for Load Adaptive Applications | 186d? | 2010-09-17 A | 2011-06-03 A | 100% | 2010-09-17 | 2011-06-03 | 186d? | finish no earlier than 2011-06-03 | C3 | 1488h | 1488h | ECSRA_LAA-CN | 25 | Ericsson | philip.hodges@ericsson.com | Rel-10 | 49 | Adrian |  |  |
| 3468 | 937.5.4 | CT1 part of CN aspects of Enabling Coder Selection and Rate Adaptation for UTRAN and E-UTRAN for Load Adaptive Applications | 186d? | 2010-09-17 A | 2011-06-03 A | 100% | 2010-09-17 | 2011-06-03 | 186d? | start no earlier than 2010-09-17 | C1 | 1488h | 1488h | ECSRA_LAA-CN | 25 | Ericsson | philip.hodges@ericsson.com | Rel-10 | 49 | Frederic |  |  |

Notes:
- 3442: -
- 3443: SP#49 completed (has impacts to RAN) / Impacted TSs and TRs: 23.060, 23.401
- 3444: CP#51 completed
- 3445: CP#51 completed / Impacted TSs and TRs: 23.008, 23.015, 29.002, 29.060, 29.272, 29.274, 29.281, 29.303
- 3446: CP#51 completed / Impacted TSs and TRs: 24.008, 24.301
- 3447: -
- 3448: SP#49 completed (SIPTO GW selection for wild card APN and for GERAN. Serving-GW selection for SIPTO. Corrections and Clarifications of the SIPTO procedure) / Impacted TSs and TRs: 23.060, 23.401
- 3449: CP#51 completed. Updated WID CP-100419=>CP-110091
- 3450: CP#51 completed. Updated WID CP-100419=>CP-110091 / Impacted TSs and TRs: 23.003, 23.008, 29.002, 29.272, 29.303
- 3451: CP#50 completed / Impacted TSs and TRs: 24.008, 24.301
- 3452: SP#51 completed. Triggered by Rel-10 TR 23.861 (UID_410043 Study on Multi Access PDN connectivity and IP flow mobility - MAPIM)
- 3453: SP#46 completed / Impacted TSs and TRs: 22.278
- 3454: SP#49 completed / Impacted TSs and TRs: 23.203, 23.402, new 23.261
- 3455: SP#51 completed / Impacted TSs and TRs: 32.240, 32.251, 32.252, 32.298, 32.299
- 3456: CP#51 completed / Impacted TSs and TRs: Stage 3
- 3457: CP#51 completed / Impacted TSs and TRs: 24.008, 24.301, 24.302, 24.303, 24.312, 24.327
- 3458: CP#51 completed / Impacted TSs and TRs: 29.212, 29.213, 29.214, 29.215
- 3459: CP#52 completed. Triggered by Rel-9 UID_440013 Vocoder rate adaptation for LTE / Impacted TSs and TRs: UTRA, LTE
- 3460: SP#48 completed / Impacted TSs and TRs: new 23.860
- 3461: SP#50 completed / Impacted TSs and TRs: new 23.860
- 3462: SP#49 completed / Impacted TSs and TRs: 23.060, 23.203, 23.228, 23.401
- 3463: SP#51 completed / Impacted TSs and TRs: 26.114
- 3464: CP#52 completed / Impacted TSs and TRs: Stage 2/3
- 3465: CP#52 completed / Impacted TSs and TRs: 23.334, 29.334, 29.238, 23.333, 29.333, 29.232, 29.332
- 3466: CP#57 completed / Impacted TSs and TRs: RFC 6679 (was draft-ietf-avtcore-ecn-for-rtp)
- 3467: CP#52 completed / Impacted TSs and TRs: 29.162, 29.163, 29.213, 29.235, 29.292
- 3468: CP#52 completed / Impacted TSs and TRs: 24.229

| ID | WBS | Task | Type | Duration | Start | Finish | Complete | Baseline start | Baseline finish | Baseline duration | Constraint | Resources | Work | Actual work | Acronym | PCG approved | Impacted TSs and TRs | WI rapporteur name | WI rapporteur e-mail | Release | TSG approved | MCC resp | Special Focus Doc | Acronym_3GU_Export | PCG stopped | TSG stopped |
| --- | --- | --- | --- | --- | --- | --- | --- | --- | --- | --- | --- | --- | --- | --- | --- | --- | --- | --- | --- | --- | --- | --- | --- | --- | --- | --- |
| 3469 | 938 | **Extended H(e)NB features** |  | 467d? | 2008-12-11 A | 2010-09-23 A | 100% | 2008-12-11 | 2010-09-23 | 467d? |  | S1; S2; S3 | 15552h | 15552h | EHNBF | 23 | UTRA, LTE | NEC | joerg.swetina@neclab.eu | Rel-10 | 45 | Alain | HNB | EHNBF |  |  |
| 3470 | 938.1 | Stage 1 of Extended H(e)NB features |  | 131d? | 2009-09-24 A | 2010-03-25 A | 100% | 2009-09-24 | 2010-03-25 | 131d? | finish no earlier than 2010-03-25 | S1 | 1048h | 1048h | EHNBF | 23 | 22.220 | NEC | joerg.swetina@neclab.eu | Rel-10 | 45 | Alain | HNB |  |  |  |
| 3471 | 938.2 | IMS aspects of Architecture for Home NodeB |  | 336d? | 2008-12-11 A | 2010-03-25 A | 100% | 2008-12-11 | 2010-03-25 | 336d? | finish no earlier than 2010-03-25 | S2 | 2688h | 2688h | EHNB-IMS | 22 | New 23.832 | Alcatel-Lucent | Nicolas Drevon | Rel-10 | 42 | Maurice | HNB | EHNB-IMS |  |  |
| 3472 | 938.3 | Extended H(e)NB Security features (Stage 2) |  | 76d? | 2010-06-10 A | 2010-09-23 A | 100% | 2010-06-10 | 2010-09-23 | 76d? | finish no earlier than 2010-09-23 | S3 | 608h | 608h | EHNBF-Sec | 25 | 33.320 | Huawei | Marcus Wong (mwong@huawei.com) | Rel-10 | 48 | Mirko | HNB | EHNBF-Sec |  |  |
| 3473 | 939 | **Optimal Media Routing** |  | 314d? | 2010-03-25 A | 2011-06-08 A | 100% | 2010-03-25 | 2011-06-08 | 314d? |  | S2; S5; C3; C1 | 22696h | 22696h | OMR | 24 |  | Alcatel-Lucent | andy.bennett@alcatel-lucent.com | Rel-10 | 46 | Maurice |  | OMR |  |  |
| 3474 | 939.1 | Stage 2 for Optimal Media Routing | milestone | 0d? | 2010-03-25 A | 2010-03-25 A | 100% | 2010-03-25 | 2010-03-25 | 0d? |  | S2 |  |  | OMR | 24 | 23.228 | Alcatel-Lucent | andy.bennett@alcatel-lucent.com | Rel-10 | 46 | Maurice |  |  |  |  |
| 3475 | 939.2 | **Stage 3 for Optimal Media Routing** |  | 261d? | 2010-06-04 A | 2011-06-03 A | 100% | 2010-06-04 | 2011-06-03 | 261d? |  | C3; C1; C4 | 11648h | 11648h | OMR | 25 |  | Alcatel-Lucent | jim.calme@alcatel-lucent.com | Rel-10 | 48 | Adrian |  |  |  |  |
| 3476 | 939.2.1 | CT3 part of Stage 3 for Optimal Media Routeing |  | 261d? | 2010-06-04 A | 2011-06-03 A | 100% | 2010-06-04 | 2011-06-03 | 261d? | finish no earlier than 2011-06-03 | C3 | 2088h | 2088h | OMR | 25 | 29.162, 29.163, 29.165, 29.235, new TS 29.079 | Alcatel-Lucent | jim.calme@alcatel-lucent.com | Rel-10 | 48 | Adrian |  |  |  |  |
| 3477 | 939.2.2 | CT1 part of Stage 3 for Optimal Media Routeing |  | 206d? | 2010-06-04 A | 2011-03-18 A | 100% | 2010-06-04 | 2011-03-18 | 206d? | finish no earlier than 2011-03-18 | C1 | 1648h | 1648h | OMR | 25 | 24.229 | Alcatel-Lucent | jim.calme@alcatel-lucent.com | Rel-10 | 48 | Frederic |  |  |  |  |
| 3478 | 939.2.3 | Deleted - CT4 part of Stage 3 for Optimal Media Routeing |  | 206d? | 2010-06-04 A | 2011-03-18 A | 100% | 2010-06-04 | 2011-03-18 | 206d? | finish no earlier than 2011-03-18 | C4 | 1648h | 1648h | OMR | 25 |  | Alcatel-Lucent | jim.calme@alcatel-lucent.com | Rel-10 | 48 | Kimmo |  |  | PCG-26 | CP-51 |
| 3479 | 939.3 | Charging for Optimal Media Routing |  | 125d? | 2010-12-16 A | 2011-06-08 A | 100% | 2010-12-16 | 2011-06-08 | 125d? | finish no earlier than 2011-06-08 | S5 | 1000h | 1000h | OMR | 26 | 32.260, 32.298, 32.299 | Alcatel-Lucent | maryse.gardella@alcatel-lucent.com | Rel-10 | 50 | Mirko |  |  |  |  |
| 3480 | 940 | **IMS Emergency Session Enhancements** |  | 312d? | 2010-03-25 A | 2011-06-03 A | 100% | 2010-03-25 | 2011-06-03 | 312d? |  | S1; S2; C1 | 9552h | 9552h | IESE | 24 |  | Deutsche Telekom, T-Mobile | michele.zarri@t-mobile.co.uk | Rel-10 | 47 | Maurice | Public Safety (I-A) | IESE |  |  |
| 3481 | 940.1 | Stage 1 for IMS Emergency Session Enhancements |  | 1d? | 2010-03-25 A | 2010-03-25 A | 100% | 2010-03-25 | 2010-03-25 | 1d? | start no earlier than 2010-03-25 | S1 | 8h | 8h | IESE | 24 | 22.101 CR#0343 | Deutsche Telekom, T-Mobile | Kurt Bischinger | Rel-10 | 47 | Alain | Public Safety (I-A) |  |  |  |
| 3482 | 940.2 | Stage 2 for IMS Emergency Session Enhancements |  | 131d? | 2010-03-25 A | 2010-09-23 A | 100% | 2010-03-25 | 2010-09-23 | 131d? | finish no earlier than 2010-09-23 | S2 | 1048h | 1048h | IESE | 24 | 23.167 | Deutsche Telekom, T-Mobile | michele.zarri@t-mobile.co.uk | Rel-10 | 47 | Maurice | Public Safety (I-A) |  |  |  |
| 3483 | 940.3 | Stage 3 for IMS Emergency Session Enhancements |  | 126d? | 2010-12-10 A | 2011-06-03 A | 100% | 2010-12-10 | 2011-06-03 | 126d? | finish no earlier than 2011-06-03 | C1 | 1008h | 1008h | IESE | 26 | 24.229 | Deutsche Telekom | reinhard.lauster@t-mobile.at | Rel-10 | 50 | Frederic | Public Safety (I-A) |  |  |  |
| 3484 | 941 | **S2b Mobility based on GTP** |  | 202d? | 2010-06-10 A | 2011-03-18 A | 100% | 2010-06-10 | 2011-03-18 | 202d? |  | S2; C4; C3; C1 | 12800h | 12800h | SMOG | 25 |  | Alcatel-Lucent | bruno.landais@alcatel-lucent.com | Rel-10 | 48 | Maurice | WLAN | SMOG |  |  |
| 3485 | 941.1 | Stage 2 for S2b Mobility based on GTP |  | 76d? | 2010-06-10 A | 2010-09-23 A | 100% | 2010-06-10 | 2010-09-23 | 76d? | finish no earlier than 2010-09-23 | S2 | 608h | 608h | SMOG | 25 | 23.002, 23.203, 23.402 | Alcatel-Lucent | bruno.landais@alcatel-lucent.com | Rel-10 | 48 | Maurice | WLAN |  |  |  |
| 3486 | 941.2 | **Stage 3 for S2b Mobility based on GTP** |  | 131d? | 2010-09-17 A | 2011-03-18 A | 100% | 2010-09-17 | 2011-03-18 | 131d? |  | C4; C3; C1 | 5728h | 5728h | SMOG-St3 | 25 |  | Alcatel-Lucent | bruno.landais@alcatel-lucent.com | Rel-10 | 49 | Kimmo | WLAN | SMOG-St3 |  |  |
| 3487 | 941.2.1 | CT4 part of Stage 3 for S2b Mobility based on GTP |  | 131d? | 2010-09-17 A | 2011-03-18 A | 100% | 2010-09-17 | 2011-03-18 | 131d? | finish no earlier than 2011-03-18 | C4 | 1048h | 1048h | SMOG-St3 | 25 | 23.003, 23.007, 23.008, 29.273, 29.274, 29.281, 29.303 | Alcatel-Lucent | bruno.landais@alcatel-lucent.com | Rel-10 | 49 | Kimmo | WLAN |  |  |  |
| 3488 | 941.2.2 | CT3 part of Stage 3 for S2b Mobility based on GTP |  | 131d? | 2010-09-17 A | 2011-03-18 A | 100% | 2010-09-17 | 2011-03-18 | 131d? | finish no earlier than 2011-03-18 | C3 | 1048h | 1048h | SMOG-St3 | 25 | 29.212, 29.213, 29.215 | Alcatel-Lucent | bruno.landais@alcatel-lucent.com | Rel-10 | 49 | Adrian | WLAN |  |  |  |
| 3489 | 941.2.3 | CT1 part of Stage 3 for S2b Mobility based on GTP |  | 61d? | 2010-09-17 A | 2010-12-10 A | 100% | 2010-09-17 | 2010-12-10 | 61d? | finish no earlier than 2010-12-10 | C1 | 488h | 488h | SMOG-St3 | 25 | 24.302 | Alcatel-Lucent | bruno.landais@alcatel-lucent.com | Rel-10 | 49 | Frederic | WLAN |  |  |  |
| 3490 | 942 | **Policy Enhancements for Sponsored Connectivity and Coherent Access to Policy related Databases** |  | 113.15d? | 2010-10-12 A | 2011-03-18 A | 100% | 2010-10-12 | 2011-03-18 | 113.15d? |  | S2; C3 | 2378.4h | 2378.4h | PEST | 26 |  | Qualcomm | AC Mahendran (ac@qualcomm.com) | Rel-10 | 50 | Maurice |  | PEST |  |  |
| 3491 | 942.1 | Stage 2 for Policy Enhancements for Sponsored Connectivity and Coherent Access to Policy related Databases | milestone | 0d? | 2010-10-12 A | 2010-12-15 A | 100% | 2010-10-12 | 2010-12-15 | 0d? | finish no earlier than 2010-12-15 | S2 |  |  | PEST | 26 | 23.002, 23.203 | Qualcomm | AC Mahendran (ac@qualcomm.com) | Rel-10 | 50 | Maurice |  |  |  |  |
| 3492 | 942.2 | CT3 aspects of Policy Enhancements for Sponsored Connectivity and Coherent Access to Policy related Databases |  | 71d? | 2010-12-10 A | 2011-03-18 A | 100% | 2010-12-10 | 2011-03-18 | 71d? | finish no earlier than 2011-03-18 | C3 | 568h | 568h | PEST-CT3 | 26 | 29.212, 29.213, 29.214, 29.215 | ZTE | zhou.xiaoyun@zte.com.cn | Rel-10 | 50 | Adrian |  | PEST-CT3 |  |  |

Notes:
- 3469: SP#49 completed. Adds extensions to Rel-9 functionality in UID_400035 Enhanced Home NodeB / eNodeB (EHNB)
- 3470: SP#47 completed
- 3471: SP#47 completed. Chosen solution has no normative impacts
- 3472: SP#49 completed
- 3473: CP#52 completed. SP#47 Stage 2 completed. Triggered by TR 23.894 (UID_370050 Study on System enhancements for the use of IMS servicES in CP-150local breakout)
- 3474: SP#47 completed
- 3475: CP#51 completion 03/11=>06/11. WID updated CP-100327=>CP-110134
- 3476: CP#52 completed
- 3477: CP#51 completed. WID updated CP-100327=>CP-110134
- 3478: CP#51 stopped (CT4 specs not impacted). WID updated CP-100327=>CP-110134
- 3479: SP#52 completed. Stage 3: Linked to CT3 TS 29.079 OMR within the IMS; Stage 3 (UID_480110)
- 3480: CP#52 completed. SP#49 completed. Source of external requirements: ETSI TISPAN TS 181.019 (Business Communication Requirements)
- 3481: SP#47 completed
- 3482: SP#49 completed
- 3483: CP#52 completed
- 3484: CP#51 completed. SP#49 Stage 2 completed. Related to Rel-10 UID_470049 Study on S2b mobility based on GTP (TR23.834), UID_350027 SAE for support for non-3GPP accesses. Stage1 in Rel-8 UID_320022 Reqs for evolution of 3GPP system architecture (AIPN-SAE)
- 3485: SP#49 completed
- 3486: CP#51 Stage 3 completed
- 3487: CP#51 completed
- 3488: CP#51 completed
- 3489: CP#50 completed
- 3490: CP#51 completed. SP#50 Stage 2 completed. Triggered by the SA1,SA2 Rel-10 TR 23.813 Study on Policy solutions and enhancements (FS_PP) UID_440047. Provides Video Call seamless service continuity for 3G/LTE terminal user
- 3491: SP#51 updated WID SP-100702=>SP-110196. SP#49 work completed as SA2 CRs approved under TEI10 (SP-10557)
- 3492: CP#51 completed

| ID | WBS | Task | Duration | Start | Finish | Complete | Baseline start | Baseline finish | Baseline duration | Constraint | Resources | Work | Actual work | Acronym | PCG approved | WI rapporteur name | WI rapporteur e-mail | Release | TSG approved | MCC resp | Acronym_3GU_Export | PCG stopped | TSG stopped |
| --- | --- | --- | --- | --- | --- | --- | --- | --- | --- | --- | --- | --- | --- | --- | --- | --- | --- | --- | --- | --- | --- | --- | --- |
| 3493 | 943 | **Lawful Interception in the 3GPP Rel-10** | 315d? | 2010-03-25 A | 2011-06-08 A | 100% | 2010-03-25 | 2011-06-08 | 315d? |  | S3 | 20480h | 20480h | LI10 | 24 | PIDS, BT | Koen Jaspers (k.b.jaspers@minjus.nl), alex.leadbeater@bt.com | Rel-10 | 47 | Mirko | LI10 |  |  |
| 3494 | 943.1 | LI for CAT (Customer Alerting Tones) | 315d? | 2010-03-25 A | 2011-06-08 A | 100% | 2010-03-25 | 2011-06-08 | 315d? | finish no earlier than 2011-03-23 | S3 | 2520h | 2520h | LI10 | 24 | PIDS, BT | Koen Jaspers (k.b.jaspers@minjus.nl), alex.leadbeater@bt.com | Rel-10 | 47 | Mirko |  |  |  |
| 3495 | 943.2 | LI for CRS (Customized Ringing Signal) | 315d? | 2010-03-25 A | 2011-06-08 A | 100% | 2010-03-25 | 2011-06-08 | 315d? | finish no earlier than 2011-03-23 | S3 | 2520h | 2520h | LI10 | 24 | PIDS, BT | Koen Jaspers (k.b.jaspers@minjus.nl), alex.leadbeater@bt.com | Rel-10 | 47 | Mirko |  |  |  |
| 3496 | 943.3 | LI for EPS enhancements | 315d? | 2010-03-25 A | 2011-06-08 A | 100% | 2010-03-25 | 2011-06-08 | 315d? | finish no earlier than 2011-03-23 | S3 | 2520h | 2520h | LI10 | 24 | PIDS, BT | Koen Jaspers (k.b.jaspers@minjus.nl), alex.leadbeater@bt.com | Rel-10 | 47 | Mirko |  |  |  |
| 3497 | 943.4 | LI for VCC (Voice Call Continuity) | 260d? | 2010-03-25 A | 2011-03-23 A | 100% | 2010-03-25 | 2011-03-23 | 260d? | finish no earlier than 2011-03-23 | S3 | 2080h | 2080h | LI10 | 24 | PIDS, BT | Koen Jaspers (k.b.jaspers@minjus.nl), alex.leadbeater@bt.com | Rel-10 | 47 | Mirko |  |  |  |
| 3498 | 943.5 | LI for MEDIASEC (IMS Media security) | 260d? | 2010-03-25 A | 2011-03-23 A | 100% | 2010-03-25 | 2011-03-23 | 260d? | finish no earlier than 2011-03-23 | S3 | 2080h | 2080h | LI10 | 24 | PIDS, BT | Koen Jaspers (k.b.jaspers@minjus.nl), alex.leadbeater@bt.com | Rel-10 | 47 | Mirko |  |  |  |
| 3499 | 943.6 | LI for H(e)NB also with Local IP Access and Selected IP Traffic Offload (LIPA, SIPTO) | 260d? | 2010-03-25 A | 2011-03-23 A | 100% | 2010-03-25 | 2011-03-23 | 260d? | finish no earlier than 2011-03-23 | S3 | 2080h | 2080h | LI10 | 24 | PIDS, BT | Koen Jaspers (k.b.jaspers@minjus.nl), alex.leadbeater@bt.com | Rel-10 | 47 | Mirko |  |  |  |
| 3500 | 943.7 | LI for MBMS enhancements | 260d? | 2010-03-25 A | 2011-03-23 A | 100% | 2010-03-25 | 2011-03-23 | 260d? | finish no earlier than 2011-03-23 | S3 | 2080h | 2080h | LI10 | 24 | PIDS, BT | Koen Jaspers (k.b.jaspers@minjus.nl), alex.leadbeater@bt.com | Rel-10 | 47 | Mirko |  |  |  |
| 3501 | 943.8 | LI for LCLS (Local Call Local Switch) | 260d? | 2010-03-25 A | 2011-03-23 A | 100% | 2010-03-25 | 2011-03-23 | 260d? | finish no earlier than 2011-03-23 | S3 | 2080h | 2080h | LI10 | 24 | PIDS, BT | Koen Jaspers (k.b.jaspers@minjus.nl), alex.leadbeater@bt.com | Rel-10 | 47 | Mirko |  |  |  |
| 3502 | 944 | Optimization of IMS based PSS and MBMS User Service | 260d? | 2010-03-25 A | 2011-03-23 A | 100% | 2010-03-25 | 2011-03-23 | 260d? | finish no earlier than 2011-03-23 | S4 | 2080h | 2080h | OPT_IMS_PSS_MBMS_US | 24 | Ericsson | markus.kampmann@ericsson.com | Rel-10 | 47 | Paolo | OPT_IMS_PSS_MBMS_US |  |  |
| 3503 | 945 | **HTTP-based Streaming and Download Services** | 392d? | 2010-03-25 A | 2011-09-21 A | 100% | 2010-03-25 | 2011-09-21 | 392d? |  | S4; IETF | 10468.8h | 10468.8h | HTTP_SDS | 24 | Qualcomm | Thomas Stockhammer (c_tstock@qualcomm.com) | Rel-10 | 47 | Paolo | HTTP_SDS |  |  |
| 3504 | 945.1 | HTTP-based Streaming and Download Services in 3GPP | 315d? | 2010-03-25 A | 2011-06-08 A | 100% | 2010-03-25 | 2011-06-08 | 315d? | finish no earlier than 2011-05-26 | S4 | 2520h | 2520h | HTTP_SDS | 24 | Qualcomm | Thomas Stockhammer (c_tstock@qualcomm.com) | Rel-10 | 47 | Paolo |  |  |  |
| 3505 | 945.2 | (IETF) HTTP-based Streaming and Download Services in 3GPP | 211.6d? | 2010-03-25 A | 2011-09-21 A | 100% | 2010-03-25 | 2011-09-21 | 211.6d? | start no earlier than 2010-03-25 | S4-IETF | 1676.8h | 1676.8h | HTTP_SDS | 27 |  |  | Rel-10 | 52 | Paolo |  |  |  |
| 3506 | 946 | PSS and MBMS enhancements | 205d? | 2010-06-10 A | 2011-03-23 A | 100% | 2010-06-10 | 2011-03-23 | 205d? | finish no earlier than 2011-03-23 | S4 | 1640h | 1640h | MBS_Enh | 25 | Ericsson | Markus.Kampmann@ericsson.com | Rel-10 | 48 | Paolo | MBS_Enh |  |  |
| 3507 | 947 | Enhancements and Addition of Audio Tests to 26.131 and 26.132 | 260d? | 2010-06-10 A | 2011-06-08 A | 100% | 2010-06-10 | 2011-06-08 | 260d? | finish no earlier than 2011-06-08 | S4 | 2080h | 2080h | EAAT | 25 | Vodafone | ramin.afchar@vodafone.com | Rel-10 | 48 | Paolo | EAAT |  |  |
| 3508 | 948 | Video Coding Enhancements in MTSI | 3d? | 2011-03-21 A | 2011-03-23 A | 100% | 2011-03-21 | 2011-03-23 | 3d? | start no earlier than 2011-03-21 | S4 | 24h | 24h | VCEM | 26 | Ericsson | frederic.gabin@ericsson.com | Rel-10 | 51 | Paolo | VCEM |  |  |
| 3509 | 949 | **Rel-10 Operations, Administration, Maintenance and Provisioning (OAM&P)** | 467d? | 2009-12-10 A | 2011-09-21 A | 100% | 2009-12-10 | 2011-09-21 | 467d? |  | S5; C4 | 54144h | 54144h | OAM10 | 24 |  |  | Rel-10 | 46 | Mirko | OAM10 |  |  |
| 3510 | 949.1 | **Rel-10 Network Infrastructure Management** | 467d? | 2009-12-10 A | 2011-09-21 A | 100% | 2009-12-10 | 2011-09-21 | 467d? |  | S5 | 14592h | 14592h | OAM10-NIM | 24 |  |  | Rel-10 | 46 | Mirko | OAM10-NIM |  |  |
| 3511 | 949.1.1 | Common RAT Network Resource Model (NRM) | 390d? | 2009-12-10 A | 2011-06-08 A | 100% | 2009-12-10 | 2011-06-08 | 390d? | finish no earlier than 2011-06-08 | S5 | 3120h | 3120h | RAT_NRM_common | 24 | Ericsson | robert.petersen@ericsson.com | Rel-10 | 46 | Mirko | RAT_NRM_common |  |  |
| 3512 | 949.1.2 | IRP Solution Set specification organisation improvements | 260d? | 2010-03-25 A | 2011-03-23 A | 100% | 2010-03-25 | 2011-03-23 | 260d? | finish no earlier than 2011-03-23 | S5 | 2080h | 2080h | OAM-IRP-SS | 24 | Nokia Siemens Networks, Huawei | Jörg Schmidt (J.Schmidt@nsn.com), Lan Zou (zlan@huawei.com) | Rel-10 | 47 | Mirko | OAM-IRP-SS |  |  |
| 3513 | 949.1.3 | Deleted - Service Oriented Architecture (SOA) for IRP continuation from Rel-9 | 260d? | 2010-03-25 A | 2011-03-23 A | 100% | 2010-03-25 | 2011-03-23 | 260d? | finish no earlier than 2011-06-08 | S5 | 2080h | 2080h | OAM-SOA-IRP | 24 | Nokia Siemens Networks, Ericsson | Jörg Schmidt (J.Schmidt@NSN.com), edwin.tse@ericsson.com | Rel-10 | 47 | Mirko | OAM-SOA-IRP | PCG-26 | SP-51 |
| 3514 | 949.1.4 | IRP Overview, Profiles & Usage Guide | 260d? | 2010-06-10 A | 2011-06-08 A | 100% | 2010-06-10 | 2011-06-08 | 260d? | finish no earlier than 2011-06-08 | S5 | 2080h | 2080h | OAM-NIM-IRP_OPU | 25 | Nokia Siemens Networks | Jörg Schmidt (J.Schmidt@NSN.com) | Rel-10 | 48 | Mirko | OAM-NIM-IRP_OPU |  |  |
| 3515 | 949.1.5 | Alarm Correlation and Root Cause Analysis | 133d? | 2011-03-23 A | 2011-09-21 A | 100% | 2011-03-23 | 2011-09-21 | 133d? | finish no earlier than 2011-09-21 | S5 | 1048h | 1048h | OAM-AC-RCA | 26 | Ericsson | brendan.hassett@ericsson.com | Rel-10 | 51 | Mirko | OAM-AC-RCA |  |  |
| 3516 | 949.1.6 | Inventory Management Network Resource Model enhancements | 56d? | 2011-03-23 A | 2011-06-08 A | 100% | 2011-03-23 | 2011-06-08 | 56d? | start no earlier than 2011-03-23 | S5 | 448h | 448h | OAM-IM-NMR | 26 | Nokia Siemens Networks | olaf.pollakowski@nsn.com | Rel-10 | 51 | Mirko | OAM-IM-NMR |  |  |

Notes:
- 3493: SP#52 completed / Impacted TSs and TRs: 33.106 (LI requirements), 33.107 (LI architecture and functions), 33.108 (Handover interface for LI)
- 3494: SP#52 completed / Impacted TSs and TRs: 33.106, 33.107, 33.108
- 3495: SP#52 completed / Impacted TSs and TRs: 33.106, 33.107, 33.108
- 3496: SP#52 completed / Impacted TSs and TRs: 33.106, 33.107, 33.108
- 3497: SP#51 completed / Impacted TSs and TRs: 33.106, 33.107, 33.108
- 3498: SP#51 completed / Impacted TSs and TRs: 33.106, 33.107, 33.108
- 3499: SP#51 completed / Impacted TSs and TRs: 33.106, 33.107, 33.108
- 3500: SP#51 completed / Impacted TSs and TRs: 33.106, 33.107, 33.108
- 3501: SP#51 completed / Impacted TSs and TRs: 33.106, 33.107, 33.108
- 3502: SP#51 completed. Work to enhance UID_430046 Rel-9 IMS_PSS_MBMS_US_EXT / Impacted TSs and TRs: 26.237
- 3503: SP#52 completed. Work to enhance UID_430038 Rel-9 PSS and MBMS extensions
- 3504: SP#52 completed / Impacted TSs and TRs: 26.234, 26.244, 26.346, new TS 26.247
- 3505: SP#53/IETF#81: Draft not included in 3GPP documentation. Dec.14: IETF RFC added / Impacted TSs and TRs: RFC 6381 (was draft-gellens-mime-bucket-bis)
- 3506: SP#51 completed. Linked to Rel-9 Feature UID_430038 PSS and MBMS extensions (PMA-MBS_Ext). / Impacted TSs and TRs: 26.234, 26.346
- 3507: SP#52 completed. Reduce fragmentation in acoustic testing (3GPP SA4, ETSI STQ, GCF CAG, CTIA) & Review existing acoustic tests to determine need for new spec / Impacted TSs and TRs: 26.131, 26.132
- 3508: SP#51 completed. Linked to Rel-7 UID_7040 Multimedia Telephony Service for IMS - Media handling and interaction in MTSI (MTSI-MHI) / Impacted TSs and TRs: 26.114
- 3509: OAM10 is an umbrella Feature also for OAM&P related TEI10 type of changes that are not part of any other dedicated feature/WI / Impacted TSs and TRs: TR 30.820
- 3510: umbrella BB
- 3511: SP#52 completed. Share equipment btw several RATs (RET,TMA,repeaters) to reduce costs. With existing modelling is difficult to see that several cells are affected when an antenna tilt is changed etc / Impacted TSs and TRs: 32.616, 32.642, 32.646, 32.652, 32.656, 32.762, 32.766 new (32.791, 32.792, 32.796)
- 3512: SP#51 completed / Impacted TSs and TRs: 32.153, new (32.111-6,32.126,32.176,32.306,32.316,32.326,32.336,32.346,32.356,32.366,32.376,32.386,32.396,32.416,32.446,32.506/26/36,32.606,32.616,32.626,32.636,32.646,32.656,32.666,32.676,32.696,32.716,32.726,32.736,32.746,32.756,32.766,32.776,32.786)
- 3513: SP#51 work stopped (Reason: lack of progress). Continuation of Rel-9 UID_440065 SOA for IRP (covering SOA Architecture & SOA-supporting Solution Set) to address SOA conforming Registration & Discovery capabilities / Impacted TSs and TRs: 32.101, 32.150
- 3514: SP#52 completed. Updated WID SP-100777=>SP-110277 / Impacted TSs and TRs: new TS 32.103
- 3515: SP#53 completed. Triggered by Rel-10 TR 32.832 Study on Alarm Correlation and Alarm Root Cause Analysis UID_480045 & TR 32.829 Study on Harmonization of 3GPP Alarm IRP and TMF Interface Program Fault Management UID_460038 / Impacted TSs and TRs: 32.111-1, 32.111-2, 32.111-6
- 3516: SP#52 completed. Inventory NRM specified in Rel-6 is mainly hardware related. Rel-10 TR 32.828 recommends extending the scope of inventory NRM. Additionally, NGMN Top OPE Recs, v1.0 sets inventory enhancements as one of top 10 priority items / Impacted TSs and TRs: 32.690, 32.691, 32.692, 32.696

| ID | WBS | Task | Duration | Start | Finish | Complete | Baseline start | Baseline finish | Baseline duration | Constraint | Resources | Work | Actual work | Acronym | PCG approved | Release | TSG approved | MCC resp | Special Focus Doc | Acronym_3GU_Export | WI rapporteur name |
| --- | --- | --- | --- | --- | --- | --- | --- | --- | --- | --- | --- | --- | --- | --- | --- | --- | --- | --- | --- | --- | --- |
| 3517 | 949.2 | **Rel-10 Self-Organizing Networks (SON) - OAM aspects** | 390d? | 2009-12-10 A | 2011-06-08 A | 100% | 2009-12-10 | 2011-06-08 | 390d? |  | S5 | 11000h | 11000h | OAM10-SON | 24 | Rel-10 | 46 | Mirko | SON | OAM10-SON |  |
| 3518 | 949.2.1 | SON Self-optimization management continuation | 390d? | 2009-12-10 A | 2011-06-08 A | 100% | 2009-12-10 | 2011-06-08 | 390d? | finish no earlier than 2011-03-23 | S5 | 3120h | 3120h | LTE-SON-OAM_SO | 24 | Rel-10 | 46 | Mirko | SON | LTE-SON-OAM_SO | Huawei |
| 3519 | 949.2.2 | SON Self-healing management | 335d? | 2009-12-10 A | 2011-03-23 A | 100% | 2009-12-10 | 2011-03-23 | 335d? | finish no earlier than 2011-03-23 | S5 | 2680h | 2680h | LTE-SON-OAM_SH | 24 | Rel-10 | 46 | Mirko | SON | LTE-SON-OAM_SH | ZTE |
| 3520 | 949.2.3 | OAM aspects of Energy Saving in Radio Networks | 260d? | 2010-03-25 A | 2011-03-23 A | 100% | 2010-03-25 | 2011-03-23 | 260d? | finish no earlier than 2011-03-23 | S5 | 2080h | 2080h | OAM-ES | 24 | Rel-10 | 47 | Mirko | SON | OAM-ES | Nokia Siemens Networks |
| 3521 | 949.3 | Rel-10 Subscription Management (SuM) evolution | 260d? | 2010-03-25 A | 2011-03-23 A | 100% | 2010-03-25 | 2011-03-23 | 260d? | finish no earlier than 2011-03-23 | S5 | 2080h | 2080h | OAM10-SuM | 24 | Rel-10 | 47 | Mirko |  | OAM10-SuM | Ericsson |
| 3522 | 949.4 | **Rel-10 Performance Management** | 315d? | 2010-03-25 A | 2011-06-08 A | 100% | 2010-03-25 | 2011-06-08 | 315d? |  | S5; C4 | 19000h | 19000h |  | 24 | Rel-10 | 47 | Mirko |  |  |  |
| 3523 | 949.4.1 | Key Performance Indicators (KPIs) for IMS | 260d? | 2010-03-25 A | 2011-03-23 A | 100% | 2010-03-25 | 2011-03-23 | 260d? | finish no earlier than 2011-03-23 | S5 | 2080h | 2080h | OAM-PM-KPI_IMS | 24 | Rel-10 | 47 | Mirko |  | OAM-PM-KPI_IMS | China Mobile |
| 3524 | 949.4.2 | Key Performance Indicators (KPIs) for EPC | 260d? | 2010-03-25 A | 2011-03-23 A | 100% | 2010-03-25 | 2011-03-23 | 260d? | finish no earlier than 2011-03-23 | S5 | 2080h | 2080h | OAM-PM-KPI_EPC | 24 | Rel-10 | 47 | Mirko |  | OAM-PM-KPI_EPC | China Mobile |
| 3525 | 949.4.3 | **Management of UE based network performance measurements** | 315d? | 2010-03-25 A | 2011-06-08 A | 100% | 2010-03-25 | 2011-06-08 | 315d? |  | S5; C4 | 7720h | 7720h | OAM-PM-UE | 24 | Rel-10 | 47 | Mirko |  | OAM-PM-UE | Huawei, Nokia Siemens Networks, Ericsson |
| 3526 | 949.4.3.1 | SA5 aspects of Management of UE based network performance measurements | 315d? | 2010-03-25 A | 2011-06-08 A | 100% | 2010-03-25 | 2011-06-08 | 315d? | finish no earlier than 2011-06-08 | S5 | 2520h | 2520h |  | 24 | Rel-10 | 47 | Mirko |  |  | Huawei, Nokia Siemens Networks, Ericsson |
| 3527 | 949.4.3.2 | CN aspects of Management of UE based network performance measurements | 20d? | 2011-02-21 A | 2011-03-18 A | 100% | 2011-02-21 | 2011-03-18 | 20d? | start no earlier than 2011-02-21 | C4 | 160h | 160h |  | 26 | Rel-10 | 51 | Kimmo |  |  | Nokia Siemens Networks |
| 3528 | 949.4.4 | 3G HNB and LTE HeNB Subsystem performance measurements | 260d? | 2010-03-25 A | 2011-03-23 A | 100% | 2010-03-25 | 2011-03-23 | 260d? | finish no earlier than 2011-03-23 | S5 | 2080h | 2080h | OAM-PM-HeNS | 24 | Rel-10 | 47 | Mirko | HNB | OAM-PM-HeNS | China Mobile |
| 3529 | 950 | **Rel-10 Charging Management small Enhancements** | 470d? | 2009-06-04 A | 2011-03-23 A | 100% | 2009-06-04 | 2011-03-23 | 470d? |  | S5 | 7520h | 7520h | CH10 | 24 | Rel-10 | 47 | Mirko | WLAN | CH10 |  |
| 3530 | 950.1 | IWLAN mobility charging | 470d? | 2009-06-04 A | 2011-03-23 A | 100% | 2009-06-04 | 2011-03-23 | 470d? | finish no earlier than 2011-03-23 | S5 | 3760h | 3760h | eIWLAN_Mob | 23 | Rel-10 | 44 | Mirko | WLAN | eIWLAN_Mob | Orange |
| 3531 | 951 | **Advice of Charge (AoC) service support enhancements** | 312d? | 2010-03-25 A | 2011-06-03 A | 100% | 2010-03-25 | 2011-06-03 | 312d? |  | S5; C1 | 8560h | 8560h | eAoC | 24 | Rel-10 | 47 | Mirko |  | eAoC | Deutsche Telekom |
| 3532 | 951.1 | SA5 part - AoC enhancements | 260d? | 2010-03-25 A | 2011-03-23 A | 100% | 2010-03-25 | 2011-03-23 | 260d? | finish no earlier than 2011-03-23 | S5 | 2080h | 2080h | eAoC | 24 | Rel-10 | 47 | Mirko |  |  | Deutsche Telekom |
| 3533 | 951.2 | CT1 part - AoC enhancements (Stage 3) | 186d? | 2010-09-17 A | 2011-06-03 A | 100% | 2010-09-17 | 2011-06-03 | 186d? | finish no earlier than 2011-06-03 | C1 | 1488h | 1488h | eAoC | 25 | Rel-10 | 49 | Frederic |  |  | Deutsche Telekom |
| 3534 | 952 | IMS Stage 3 IETF Protocol Alignment - phase 4 | 261d? | 2010-03-19 A | 2011-03-18 A | 100% | 2010-03-19 | 2011-03-18 | 261d? | finish no earlier than 2011-03-18 | C1 | 2088h | 2088h | IMSProtoc4 | 24 | Rel-10 | 47 | Frederic |  | IMSProtoc4 | Alcatel-Lucent |
| 3535 | 953 | Enhanced User Data Convergence (UDC) Model | 206d? | 2010-06-04 A | 2011-03-18 A | 100% | 2010-06-04 | 2011-03-18 | 206d? | finish no earlier than 2011-03-18 | C4 | 1648h | 1648h | eUDC | 25 | Rel-10 | 48 | Kimmo |  | eUDC | China Mobile |
| 3536 | 954 | **Further improvements of II-NNI Stage 3 based on operational feedback and evolution of other specifications** | 724d? | 2010-06-04 A | 2013-03-01 A | 100% | 2010-06-04 | 2013-03-01 | 724d? |  | C3 | 10625.9h | 10625.9h | II-NNI2 | 25 | Rel-10 | 48 | Adrian |  | II-NNI2 | Orange |
| 3537 | 954.1 | Further improvements of II-NNI Stage 3 | 206d? | 2010-06-04 A | 2011-03-18 A | 100% | 2010-06-04 | 2011-03-18 | 206d? | start no earlier than 2010-06-04 | C3 | 1648h | 1648h | II-NNI2 | 25 | Rel-10 | 48 | Adrian |  |  | Orange |
| 3538 | 954.2 | (IETF) Further improvements of II-NNI Stage 3 (RFC 6794) | 230d? | 2012-04-20 A | 2013-03-01 A | 100% | 2012-04-20 | 2013-03-01 | 230d? | finish no earlier than 2013-03-01 | C3-IETF | 1832h | 1832h | II-NNI2 | 29 | Rel-10 | 56 | Adrian |  |  | Lionel Morand |
| 3539 | 954.3 | (IETF) Further improvements of II-NNI Stage 3 (RFC 6809) | 170d? | 2012-04-20 A | 2012-12-07 A | 100% | 2012-04-20 | 2012-12-07 | 170d? | finish no earlier than 2012-12-04 | C3-IETF | 1353.89h | 1353.89h | II-NNI2 | 29 | Rel-10 | 56 | Adrian |  |  | christer.holmberg@ericsson.com |
| 3540 | 955 | AT Commands for IMS-configuration | 206d? | 2010-06-04 A | 2011-03-18 A | 100% | 2010-06-04 | 2011-03-18 | 206d? |  | C1 | 1648h | 1648h | AT_IMS | 25 | Rel-10 | 48 | Frederic |  | AT_IMS | Ericsson |
| 3541 | 956 | AT Commands for USIM Application Toolkit (USAT) | 131d? | 2010-09-17 A | 2011-03-18 A | 100% | 2010-09-17 | 2011-03-18 | 131d? |  | C1 | 52.4h | 52.4h | AT_UICC | 25 | Rel-10 | 49 | Frederic |  | AT_UICC | ST-Ericsson |
| 3542 | 957 | Communication Control for IMS by USIM (Stage 3) | 131d? | 2010-09-17 A | 2011-03-18 A | 100% | 2010-09-17 | 2011-03-18 | 131d? | start no earlier than 2010-09-17 | C6 | 1048h | 1048h | CC_IMS_USIM | 25 | Rel-10 | 49 | Xavier |  | CC_IMS_USIM | Gemalto |
| 3543 | 958 | Dynamic view of SIP message for Inter-IMS Network to Network Interface (II-NNI) (Stage 3) | 126d? | 2010-12-10 A | 2011-06-03 A | 100% | 2010-12-10 | 2011-06-03 | 126d? | finish no earlier than 2011-06-03 | C3 | 1008h | 1008h | NNI_DV | 26 | Rel-10 | 50 | Adrian |  | NNI_DV | NTT |
| 3544 | 959 | Introduction of Smart Card Web Server launch functionality | 71d? | 2010-12-10 A | 2011-03-18 A | 100% | 2010-12-10 | 2011-03-18 | 71d? | finish no earlier than 2011-03-18 | C6 | 568h | 568h | SCWS_L | 26 | Rel-10 | 50 | Xavier |  | SCWS_L | Telecom Italia |
| 3545 | 960 | USAT using AT Commands | 71d? | 2010-12-10 A | 2011-03-18 A | 100% | 2010-12-10 | 2011-03-18 | 71d? | finish no earlier than 2011-03-18 | C6 | 568h | 568h | USAT_AT | 26 | Rel-10 | 50 | Xavier |  | USAT_AT | Giesecke & Devrient |

Notes:
- 3517: umbrella BB
- 3518: SP#52 completed. Cont'd Rel-9 SON self-optimization management UID_390007 / Impacted TSs and TRs: 32.425, 32.521, 32.522, 32.526, 32.762, 32.766 / WI rapporteur e-mail: Lan Zou (zlan@huawei.com)
- 3519: SP#51 completed. WID updated SP-100776=>SP-110150. Work moved to Rel-10 after split of the Rel-9 UID_390007 SON self-optimization (removed Self-Healing handling) / Impacted TSs and TRs: 32.522, 32.526, 32.762, 32.766, new TS 32.541 / WI rapporteur e-mail: zhu.weihong@zte.com.cn
- 3520: SP#51 completed. WID updated SP-100226=>SP-110128. Triggered by Rel-10 TR 32.826 Study on Telecommunication Management; Energy Savings Management (FS_OAM_ESM) UID_430044 / Impacted TSs and TRs: 32.425, 32.522, 32.526, 32.626, 32.762, 32.766, new TS 32.551 / WI rapporteur e-mail: clemens.suerbaum@nsn.com
- 3521: SP#51 completed / Impacted TSs and TRs: 32.172, 32.175, 32.176 / WI rapporteur e-mail: leo.yang@ericsson.com
- 3522: umbrella BB
- 3523: SP#51 completed / Impacted TSs and TRs: new 32.454 / WI rapporteur e-mail: Li Jian (lijian@chinamobile.com), Liang Shuangchun (liangshuangchun@cmdi.chinamobile.com)
- 3524: SP#51 completed / Impacted TSs and TRs: new 32.455 / WI rapporteur e-mail: Li Jian (lijian@chinamobile.com), Liang Shuangchun (liangshuangchun@cmdi.chinamobile.com)
- 3525: SP#52 completed. Stage 2/3. Linked to UID_460003 Minimization of drive tests for E-UTRAN and UTRAN (MDT_UMTSLTE) / WI rapporteur e-mail: Zou Lan (zlan@huawei.com), gyula.bodog@nsn.com, ulf.hubinette@ericsson.com
- 3526: SP#52 completed / Impacted TSs and TRs: 32.421, 32.422, 32.423, 32.441, 32.442, 32.446 / WI rapporteur e-mail: Zou Lan (zlan@huawei.com), gyula.bodog@nsn.com, ulf.hubinette@ericsson.com
- 3527: CP#51 completed under the SA5 WI code / Impacted TSs and TRs: 23.008 (CR#0330), 29.002 (CR#1007), 29.230 (CR#0207), 29.272 (CR#0329) / WI rapporteur e-mail: ulrich.wiehe@nsn.com
- 3528: SP#51 completed / Impacted TSs and TRs: 32.582, 32.592, new (32.452, 32.453) / WI rapporteur e-mail: Chen Gang (chengang@chinamobile.com)
- 3529: CH10 is an umbrella Feature also for OAM&P related TEI10 type of changes that are not part of any other dedicated feature/WI / Impacted TSs and TRs: TR 30.820
- 3530: SP#51 completed. RAT differentiation for charging. Completes Rel-8 Feature IWLAN_Mob UID_370049 Mobility between 3GPP-WLAN Interworking and 3GPP Systems. Cooperation with CT1,CT3 on affected protocols / Impacted TSs and TRs: 32.240, 32.252, 32.298, 32.299 / WI rapporteur e-mail: Jean-Luc Garcia (jl.garcia@orange-ftgroup.com)
- 3531: CP#52 completed. SP#51 completed SA5. Continuation of Rel-8 BB UID_80042: Advice of Charge (AoC) support in IMS Charging (IMSTSS). Stage 2/3 work / WI rapporteur e-mail: matthias.seibel@telekom.de
- 3532: SP#51 completed. SA1 Stage 1 in 22.115 / Impacted TSs and TRs: 32.275, 32.280, 32.298, 32.299 / WI rapporteur e-mail: matthias.seibel@telekom.de
- 3533: CP#52 completed. SA1 Stage 1 in 22.115, 22.173, 22.024. Add mobile-specific CAI format and volume charging elements. Extensions to existing AoC XML / Impacted TSs and TRs: 24.647 / WI rapporteur e-mail: reinhard.lauster@t-mobile.at
- 3534: CP#51 completed. Ensure protocol alignment between 3GPP Stage 3 IMS work and IETF. Review capabilities provided in SIP by IETF and document whether these capabilities are supported in the IM CN Subsystem or not / Impacted TSs and TRs: 23.218, 24.229, 24.930 / WI rapporteur e-mail: keith.drage@alcatel-lucent.com
- 3535: CP#51 completed. Specify CRUD (Create/Read/Update/Delete) operations based on SOAP protocol, which may be used by the applications having no high real-time requirement to the data access operations / Impacted TSs and TRs: 29.335 / WI rapporteur e-mail: Lan Sizhong (lansizhong@chinamobile.com)
- 3536: Improvements of Rel-9 Feature UID_440027 Operational description of the Inter-IMS Network to Network Interface (II-NNI) / WI rapporteur e-mail: beata.dobrowolska@orange-ftgroup.com
- 3537: CP#51 completed / Impacted TSs and TRs: 29.165 / WI rapporteur e-mail: beata.dobrowolska@orange-ftgroup.com
- 3538: CP#59 completed AUTH 48 RFC-to-be-6794 / Impacted TSs and TRs: RFC 6794 (was draft-ietf-sip-session-policy-framework) / WI rapporteur e-mail: Lionel Morand
- 3539: CP#58 completed / Impacted TSs and TRs: RFC 6809 (was draft-ietf-sipcore-proxy-feature) / WI rapporteur e-mail: Christer Holmberg
- 3540: CP#51 completed. Specify 1) IMS-related AT-commands to configure MT and 2) IMS-related unsolicited response codes from MT to present to end-user / Impacted TSs and TRs: 27.007 / WI rapporteur e-mail: atle.monrad@ericsson.com
- 3541: CP#51 completed / Impacted TSs and TRs: 27.007 / WI rapporteur e-mail: magnus.mk.karlsson@stericsson.com
- 3542: CP#51 completed. Stage 1 in TS 22.038 USAT service description. Linked to CT6's UID_1273 Rel-5 BB Provisioning of IP-based multimedia services (24.229, 31.103) and UID_390021 Rel-8 BB CT6 aspects of SAE (31.102, 31.111) / Impacted TSs and TRs: 31.102, 31.103, 31.111 / WI rapporteur e-mail: Denis.Lheriteau@gemalto.com
- 3543: CP#52 completed. Linked to CT3 Rel-10 Feature UID_480014 Further improvements of II-NNI Stage 3 based on operational feedback and evolution of other specifications (II-NNI2) / Impacted TSs and TRs: 29.165 / WI rapporteur e-mail: arai.kenjiro@lab.ntt.co.jp
- 3544: CP#51 completed. Define a solution which allows enabling to launch Smart Card Web Server servicES in CP-150an easy and simple manner / Impacted TSs and TRs: 31.102 / WI rapporteur e-mail: davide.pratone@telecomitalia.it
- 3545: CP#51 completed. Stage 3 based on SA1 22.038CR#37r1 (Make USAT proactive capability reqs applicable to ME as a whole without regard to any particular configuration; e.g. a modem connected to an external display) / Impacted TSs and TRs: Stage 3 31.102, 31.111 / WI rapporteur e-mail: enric.fort@gi-de.com

| ID | WBS | Task | Type | Duration | Start | Finish | Complete | Baseline start | Baseline finish | Baseline duration | Constraint | Resources | Work | Actual work | Acronym | PCG approved | WI rapporteur name | WI rapporteur e-mail | Release | TSG approved | MCC resp | Acronym_3GU_Export | Status Report | Special Focus Doc | PCG stopped | TSG stopped |
| --- | --- | --- | --- | --- | --- | --- | --- | --- | --- | --- | --- | --- | --- | --- | --- | --- | --- | --- | --- | --- | --- | --- | --- | --- | --- | --- |
| 3546 | 961 | **Single Radio Voice Call Continuity (SRVCC) enhancements (Stage 3)** |  | 528d? | 2010-12-10 A | 2012-12-07 A | 100% | 2010-12-10 | 2012-12-07 | 528d? |  | C1; C4; IETF | 17295.4h | 17295.4h | eSRVCC | 26 | China Mobile | Jiang Y (jiangyi@chinamobile.com) | Rel-10 | 50 | Frederic | eSRVCC |  |  |  |  |
| 3547 | 961.1 | CT1 part of Stage 3 for SRVCC enhancements |  | 71d? | 2010-12-10 A | 2011-03-18 A | 100% | 2010-12-10 | 2011-03-18 | 71d? | finish no earlier than 2011-03-18 | C1 | 568h | 568h | eSRVCC | 26 | China Mobile | Jiang Y (jiangyi@chinamobile.com) | Rel-10 | 50 | Frederic |  |  |  |  |  |
| 3548 | 961.2 | CT4 part of Stage 3 for SRVCC enhancements |  | 71d? | 2010-12-10 A | 2011-03-18 A | 100% | 2010-12-10 | 2011-03-18 | 71d? | finish no earlier than 2011-03-18 | C4 | 568h | 568h | eSRVCC | 26 | China Mobile | Jiang Y (jiangyi@chinamobile.com) | Rel-10 | 50 | Kimmo |  |  |  |  |  |
| 3549 | 961.3 | (IETF) CT1 part of Stage 3 for SRVCC enhancements (RFC 6809) |  | 436.8d? | 2010-12-10 A | 2012-12-07 A | 100% | 2010-12-10 | 2012-12-07 | 436.8d? | finish no earlier than 2013-03-01 | C1-IETF | 3487.38h | 3487.38h | eSRVCC | 27 | christer.holmberg@ericsson.com | christer.holmberg@ericsson.com | Rel-10 | 52 | Frederic |  |  |  |  |  |
| 3550 | 962 | **Single Radio Voice Call Continuity (SRVCC) in alerting phase (Stage 3)** |  | 589d? | 2010-12-10 A | 2013-03-01 A | 100% | 2010-12-10 | 2013-03-01 | 589d? |  | C1; R5 | 11440h | 11440h | aSRVCC | 26 | ZTE | li.shitao@zte.com.cn | Rel-10 | 50 | Frederic | aSRVCC |  |  |  |  |
| 3551 | 962.1 | CT aspects of Single Radio Voice Call Continuity (SRVCC) in alerting phase (Stage 3) |  | 126d? | 2010-12-10 A | 2011-06-03 A | 100% | 2010-12-10 | 2011-06-03 | 126d? | finish no earlier than 2011-06-03 | C1 | 1008h | 1008h | aSRVCC | 26 | ZTE | li.shitao@zte.com.cn | Rel-10 | 50 | Frederic |  |  |  |  |  |
| 3552 | 962.2 | Conformance test aspects SRVCC in alerting phase |  | 126d? | 2012-09-11 A | 2013-03-01 A | 100% | 2012-09-11 | 2013-03-01 | 126d? | finish no earlier than 2013-03-01 | R5 | 1008h | 1008h | aSRVCC-UEConTest | 29 | NTT DoCoMo | Takao.Shimizu.rp@nttdocomo.com | Rel-10 | 57 | Ingbert | aSRVCC-UEConTest | RP-130042 |  |  |  |
| 3553 | 963 | **PCRF failure and restoration** |  | 71d? | 2010-12-10 A | 2011-03-18 A | 100% | 2010-12-10 | 2011-03-18 | 71d? |  | C4; C3 | 2130h | 2130h | PCRF_FR | 26 | NEC | Toshiyuki Tamura (tamurato@aj.jp.nec.com) | Rel-10 | 50 | Kimmo | PCRF_FR |  |  |  |  |
| 3554 | 963.1 | CT4 part of PCRF failure and restoration |  | 71d? | 2010-12-10 A | 2011-03-18 A | 100% | 2010-12-10 | 2011-03-18 | 71d? | finish no earlier than 2011-03-18 | C4 | 568h | 568h | PCRF_FR | 26 | NEC | Toshiyuki Tamura (tamurato@aj.jp.nec.com) | Rel-10 | 50 | Kimmo |  |  |  |  |  |
| 3555 | 963.2 | CT3 part of PCRF failure and restoration |  | 53.25d? | 2010-12-10 A | 2011-03-18 A | 100% | 2010-12-10 | 2011-03-18 | 53.25d? | start no earlier than 2010-12-10 | C3 | 426h | 426h | PCRF_FR | 26 | NEC | Toshiyuki Tamura (tamurato@aj.jp.nec.com) | Rel-10 | 50 | Adrian |  |  |  |  |  |
| 3556 | 964 | Formalization of WLAN Files | milestone | 0d? | 2011-02-23 A | 2011-03-18 A | 100% | 2011-02-23 | 2011-03-18 | 0d? | start no earlier than 2011-03-16 | C1 |  |  | FoWF | 26 | Deutsche Telekom | dieter.jacobsohn@telekom.de | Rel-10 | 51 | Frederic | FoWF |  | WLAN |  |  |
| 3557 | 965 | CS and IMS Interworking for CAT service - Early Session model |  | 58d? | 2011-03-16 A | 2011-06-03 A | 100% | 2011-03-16 | 2011-06-03 | 58d? |  | C3 | 464h | 464h | CIIC_ES | 26 | ZTE | li.shitao@zte.com.cn | Rel-10 | 51 | Adrian | CIIC_ES |  |  |  |  |
| 3558 | 966 | EPC Node Restoration without Idle mode Signalling Reduction (ISR) activated |  | 3d? | 2011-03-16 A | 2011-03-18 A | 100% | 2011-03-16 | 2011-03-18 | 3d? | finish no earlier than 2011-03-18 | C4 | 24h | 24h | EPC_NR | 26 | Alcatel-Lucent | bruno.landais@alcatel-lucent.com | Rel-10 | 51 | Kimmo | EPC_NR |  |  |  |  |
| 3559 | 967 | EPC Node Restoration with Idle mode Signalling Reduction (ISR) activated |  | 58d? | 2011-03-16 A | 2011-06-03 A | 100% | 2011-03-16 | 2011-06-03 | 58d? | finish no earlier than 2011-03-18 | C4 | 464h | 464h | EPC_NR_ISR | 26 | NEC | Toshiyuki Tamura (tamurato@aj.jp.nec.com) | Rel-10 | 51 | Kimmo | EPC_NR_ISR |  |  |  |  |
| 3560 | 968 | Mobile Terminating Roaming Forwarding with pre-paging |  | 58d? | 2011-03-16 A | 2011-06-03 A | 100% | 2011-03-16 | 2011-06-03 | 58d? | finish no earlier than 2011-03-18 | C4 | 464h | 464h | MTRF | 26 | Ericsson | philip.hodges@ericsson.com | Rel-10 | 51 | Kimmo | MTRF |  |  |  |  |
| 3561 | 969 | **UICC access to IMS Specification** |  | 58d? | 2011-03-16 A | 2011-06-03 A | 100% | 2011-03-16 | 2011-06-03 | 58d? |  | C6; C1 | 1416h | 1416h | IMS-UICC-S | 26 | Gemalto | Denis.Lheriteau@gemalto.com | Rel-10 | 51 | Xavier | IMS-UICC-S |  |  |  |  |
| 3562 | 969.1 | CT6 part of UICC access to IMS Specification |  | 3d? | 2011-03-16 A | 2011-03-18 A | 100% | 2011-03-16 | 2011-03-18 | 3d? | start no earlier than 2011-03-16 | C6 | 24h | 24h | IMS-UICC-S | 26 | Gemalto | Denis.Lheriteau@gemalto.com | Rel-10 | 51 | Xavier |  |  |  |  |  |
| 3563 | 969.2 | CT1 part of UICC access to IMS Specification |  | 58d? | 2011-03-16 A | 2011-06-03 A | 100% | 2011-03-16 | 2011-06-03 | 58d? | start no earlier than 2011-03-16 | C1 | 464h | 464h | IMS-UICC-S | 26 | Gemalto | Denis.Lheriteau@gemalto.com | Rel-10 | 51 | Frederic |  |  |  |  |  |
| 3564 | 970 | Deleted - Testing for Terminal support of Rel-10 USIM, ISIM and USAT features |  | 463d? | 2012-03-05 A | 2013-12-03 A | 100% | 2012-03-05 | 2013-12-03 | 463d? | finish no earlier than 2013-06-14 | C6 | 3704h | 3704h | USIM_R10_Test | 28 | Gemalto | Denis.Praca@gemalto.com | Rel-10 | 55 | Xavier | USIM_R10_Test |  |  | PCG-32 | CP-62 |
| 3565 | 971 | **CN aspects of Local Call Local Switch** |  | 472d? | 2009-05-29 A | 2011-03-18 A | 100% | 2009-05-29 | 2011-03-18 | 472d? |  | C4 | 13008h | 13008h | LCLS-CN | 23 | Vodafone | David.Hutton@vodafone.com | Rel-10 | 44 | Kimmo | LCLS-CN |  |  |  |  |
| 3566 | 971.1 | TR on CN aspects of Local Call Local Switch |  | 341d? | 2009-05-29 A | 2010-09-16 A | 100% | 2009-05-29 | 2010-09-16 | 341d? | finish no earlier than 2010-09-17 | C4 | 2728h | 2728h | LCLS-CN | 23 | Vodafone | David.Hutton@vodafone.com | Rel-10 | 44 | Kimmo |  |  |  |  |  |
| 3567 | 971.2 | Stage 2/3 for CN aspects of Local Call Local Switch |  | 131d? | 2010-09-17 A | 2011-03-18 A | 100% | 2010-09-17 | 2011-03-18 | 131d? | finish no earlier than 2011-03-18 | C4 | 1048h | 1048h | LCLS-CN | 25 | Vodafone | David.Hutton@vodafone.com | Rel-10 | 49 | Kimmo |  |  |  |  |  |
| 3568 | 971.3 | Deleted - CT3 aspects of Local Call Local Switch |  | 341d? | 2009-05-29 A | 2010-09-16 A | 100% | 2009-05-29 | 2010-09-16 | 341d? | finish no earlier than 2010-09-17 | C3 | 2728h | 2728h | LCLS-CN | 23 | Vodafone | David.Hutton@vodafone.com | Rel-10 | 44 | Adrian |  |  |  | PCG-25 | CP-49 |
| 3569 | 971.4 | Deleted - CT1 aspects of Local Call Local Switch |  | 341d? | 2009-05-29 A | 2010-09-16 A | 100% | 2009-05-29 | 2010-09-16 | 341d? | finish no earlier than 2010-09-17 | C1 | 2728h | 2728h | LCLS-CN | 23 | Vodafone | David.Hutton@vodafone.com | Rel-10 | 44 | Frederic |  |  |  | PCG-25 | CP-49 |
| 3570 | 972 | Local Call Local Switch | milestone | 0d? | 2007-05-07 A | 2007-05-07 A | 100% | 2007-05-07 | 2011-05-20 | 1055.8d? |  | GP; G2 |  |  | LCLS | 22 | Huawei | wang_zhixi@huawei.com | Rel-10 | 41 | Paolo | LCLS |  |  |  |  |

Notes:
- 3546: Triggered by SA2 TR 23.856 Study on Single Radio Voice Call Continuity enhancements (FS_eSRVCC) UID_440049
- 3547: CP#51 completed / Impacted TSs and TRs: 24.229, 24.237
- 3548: CP#51 completed / Impacted TSs and TRs: 23.003, 23.008, 29.002, 29.230, 29.272, 29.305, 29.328, 29.329
- 3549: CP#58 completed / Impacted TSs and TRs: RFC 6809 (was draft-ietf-sipcore-proxy-feature)
- 3550: Builds on Rel-8 UID_390057 (IMS-Cont) TS 23.216 Stage 2. Provide Stage 3 for SRVCC PS-CS transfer of a call in alerting phase. Stage 2 TEI10 in TS 23.237 (6.3.2.1.4c/d, 6.3.2.1.7a/b)
- 3551: CP#52 completed / Impacted TSs and TRs: 24.008, 24.237
- 3552: RP#59 completed / Impacted TSs and TRs: 36.523-1, 36.523-2, 36.523-3, 34.229-1, 34.229-2, 34.229-3
- 3553: CP#51 completed. Triggered by CT3 TR 29.816 Study on Policy and Charging Rules Function (PCRF) failure and restoration (FS_PCRF-FR) UID_450013 / Impacted TSs and TRs: Stage 2/3 work
- 3554: CP#51 completed / Impacted TSs and TRs: Stage 2 23.007, Stage 3 29.230
- 3555: CP#51 completed / Impacted TSs and TRs: Stage 3 29.212, 29.213, 29.214, 29.215
- 3556: CP#51 completed. TS 24.235 for Info+Approval. Define the ME files as specified in 24.234 in OMA Device Management structure / Impacted TSs and TRs: Stage 3: 24.234, New 24.235
- 3557: CP#52 completed. Stage 1 in Rel-8 TS 22.182 Customized Alerting Tones (CAT) service. Stage 3 TS 24.182 defines 3 impl models: Gateway, Forking, Early Session. Specify missing CAT service interworking procedures btw CS & IMS networks / Impacted TSs and TRs: Stage 3 29.163, 29.235, 29.292
- 3558: CP#51 completed. Triggered by DRAFT TR 23.857 Study on EPC Nodes Restoration (FS_EPC_NR) UID_490014 / Impacted TSs and TRs: Stage 2/3: 23.007, 29.274
- 3559: CP#52 completed. Triggered by DRAFT TR 23.857 Study on EPC Nodes Restoration (FS_EPC_NR) UID_490014 / Impacted TSs and TRs: Stage 2/3: 23.007, 29.274
- 3560: CP#52 completed. Provides Stage 2/3 alternative solution to Mobile Terminating Roaming Retry to solve roaming events during paging, in particular to support CSFB. Hence, no new Stage 1 requirements exist / Impacted TSs and TRs: Stage 2/3: 23.012, 23.018, 23.116, 29.002
- 3561: CP#52 completed. Triggered by Rel-10 TR 31.828 Study on UICC access to IMS (FS_IMS-UICC) UID_480017. Specify mechanism in UICC and ME to make use of IMS functionality implemented in ME for case a) an ISIM is present b) no ISIM is present in UICC
- 3562: CP#51 completed / Impacted TSs and TRs: 31.102, 31.103, 31.111
- 3563: CP#52 completed / Impacted TSs and TRs: 24.229
- 3564: CP#62 stopped (at 70% completion 06/13). Testing for New featurES in CP-150Rel-10 specifications for USIM, ISIM applications and USIM Application Toolkit (USAT) in TS 31.102, 31.103, 31.111 / Impacted TSs and TRs: 31.121, 31.124, New TS 31.ABC (Conformance Testing of specific features)
- 3565: CP#51 completed / Impacted TSs and TRs: GERAN Stage 2/3
- 3566: CP#49 completed / Impacted TSs and TRs: new TR 23.889
- 3567: CP#51 completed / Impacted TSs and TRs: 23.003, 23.009, 23.205, 23.231, 29.002, 29.205, 29.232, new TS 23.284
- 3568: CP#49 stopped. Result of study TR 23.889: no CT3 specification impact
- 3569: CP#49 stopped. Result of study TR 23.889: no CT1 specification impact
- 3570: GP#50 completed. GP#41 WID approved / Impacted TSs and TRs: GERAN Stage 3: 48.008, 48.103

| ID | WBS | Task | Duration | Start | Finish | Complete | Baseline start | Baseline finish | Baseline duration | Constraint | Resources | Work | Actual work | Acronym | PCG approved | WI rapporteur name | Release | TSG approved | MCC resp | Acronym_3GU_Export | Status Report | Special Focus Doc |
| --- | --- | --- | --- | --- | --- | --- | --- | --- | --- | --- | --- | --- | --- | --- | --- | --- | --- | --- | --- | --- | --- | --- |
| 3571 | 973 | **Tightened Link Level Performance Requirements for Single Antenna MS** | 659d? | 2010-09-03 A | 2013-03-01 A | 100% | 2010-09-03 | 2013-03-01 | 659d? |  | G1; G2; C1; G3new | 30856h | 30856h | TIGHTER | 25 | Renesas Mobile | Rel-10 | 46 | Paolo | TIGHTER |  |  |
| 3572 | 973.1 | CT1 part for TIGHTER | 196d? | 2010-09-03 A | 2011-06-03 A | 100% | 2010-09-03 | 2011-06-03 | 196d? | finish no earlier than 2011-06-03 | C1 | 1568h | 1568h | TIGHTER | 25 | Renesas Mobile | Rel-10 | 46 | Frederic |  |  |  |
| 3573 | 973.2 | TIGHTER Performance Requirements | 186d? | 2010-09-03 A | 2011-05-20 A | 100% | 2010-09-03 | 2011-05-20 | 186d? | finish no earlier than 2011-05-20 | G1; G2 | 2976h | 2976h | TIGHTER | 25 | Renesas Mobile | Rel-10 | 46 | Paolo |  |  |  |
| 3574 | 973.3 | TIGHTER Testing | 654d? | 2010-09-08 A | 2013-03-01 A | 100% | 2010-09-08 | 2013-03-01 | 654d? | finish no earlier than 2013-03-01 | G3new | 5224h | 5224h | TIGHTER | 25 | Renesas Mobile | Rel-10 | 46 | Ingbert |  |  |  |
| 3575 | 974 | **Support of Multi-Operator Core Network by GERAN** | 206d? | 2010-05-21 A | 2011-03-04 A | 100% | 2010-05-21 | 2011-03-04 | 206d? |  | G2; S2; C1 | 8392h | 8392h | MOCN-GERAN | 25 | Alcatel-Lucent | Rel-10 | 47 | Gert | MOCN-GERAN |  |  |
| 3576 | 974.1 | Stage 2 for Support of Multi-Operator Core Network by GERAN | 150d? | 2010-05-21 A | 2010-12-16 A | 100% | 2010-05-21 | 2010-12-16 | 150d? | finish no earlier than 2010-12-15 | S2 | 1200h | 1200h | MOCN-GERAN | 25 | Alcatel-Lucent | Rel-10 | 47 | Maurice |  |  |  |
| 3577 | 974.2 | CT1 part of Stage 3 for Support of Multi-Operator Core Network by GERAN | 146d? | 2010-05-21 A | 2010-12-10 A | 100% | 2010-05-21 | 2010-12-10 | 146d? | finish no earlier than 2010-12-10 | C1 | 1168h | 1168h | MOCN-GERAN | 25 | Alcatel-Lucent | Rel-10 | 47 | Frederic |  |  |  |
| 3578 | 974.3 | GERAN2 part of Stage 3 for Support of Multi-Operator Core Network by GERAN | 135d? | 2010-08-30 A | 2011-03-04 A | 100% | 2010-08-30 | 2011-03-04 | 135d? | finish no earlier than 2011-03-04 | G2 | 1080h | 1080h | MOCN-GERAN | 25 | Alcatel-Lucent | Rel-10 | 47 | Gert |  |  |  |
| 3579 | 975 | **Enhancements of Iur-g interface** | 196d? | 2010-09-03 A | 2011-06-03 A | 100% | 2010-09-03 | 2011-06-03 | 196d? |  | G2; R3 | 5752h | 5752h | eIurg | 25 | China Mobile, ZTE | Rel-10 | 47 | Gert | eIurg |  |  |
| 3580 | 975.1 | GERAN part for Enhancements of Iur-g interface (Stage 2/3) | 131d? | 2010-09-03 A | 2011-03-04 A | 100% | 2010-09-03 | 2011-03-04 | 131d? | finish no earlier than 2011-03-04 | G2 | 1048h | 1048h | eIurg-GERAN | 25 | China Mobile, ZTE | Rel-10 | 47 | Gert | eIurg-GERAN |  |  |
| 3581 | 975.2 | Core part: Enhancements of Iur-g interface (Stage 2/3) | 196d? | 2010-09-03 A | 2011-06-03 A | 100% | 2010-09-03 | 2011-06-03 | 196d? | finish no earlier than 2011-06-03 | R3 | 1568h | 1568h | eIurg-RAN | 25 | ZTE | Rel-10 | 49 | Juha | eIurg-RAN | RP-110526 |  |
| 3582 | 976 | 1.28 Mcps TDD Repeater | 599d? | 2007-12-04 A | 2010-03-19 A | 100% | 2007-12-04 | 2010-03-19 | 599d? | finish no earlier than 2010-03-19 | R4 | 4792h | 4792h | RANimp-Repeaters1.28TDD | 21 | RITT | Rel-10 | 38 | Issam | RANimp-Repeaters1.28TDD | RP-100039 |  |
| 3583 | 977 | 1.28 Mcps TDD Multi-carrier HSUPA | 321d? | 2009-09-18 A | 2010-12-10 A | 100% | 2009-09-18 | 2010-12-10 | 321d? | finish no earlier than 2010-12-10 | R1; R2; R3; R4 | 10272h | 10272h | TDD_MC_HSUPA | 23 | CATR | Rel-10 | 45 | Patrick | TDD_MC_HSUPA | RP-101079 |  |
| 3584 | 978 | **1.28 Mcps TDD Home NodeB RF requirements** | 266d? | 2009-12-04 A | 2010-12-10 A | 100% | 2009-12-04 | 2010-12-10 | 266d? |  | R4 | 5304h | 5304h | HNB_LCRTDD_RF | 24 | TD Tech | Rel-10 | 46 | Issam | HNB_LCRTDD_RF |  | HNB |
| 3585 | 978.1 | Core part: 1.28Mcps TDD Home NodeB RF requirements | 131d? | 2009-12-04 A | 2010-06-04 A | 100% | 2009-12-04 | 2010-06-04 | 131d? | finish no earlier than 2010-12-10 | R4 | 1048h | 1048h | HNB_LCRTDD_RF-Core | 24 | TD Tech | Rel-10 | 46 | Issam | HNB_LCRTDD_RF-Core | RP-100446 | HNB |
| 3586 | 978.2 | Perf. part: 1.28Mcps TDD Home NodeB RF requirements | 266d? | 2009-12-04 A | 2010-12-10 A | 100% | 2009-12-04 | 2010-12-10 | 266d? | finish no earlier than 2010-12-10 | R4 | 2128h | 2128h | HNB_LCRTDD_RF-Perf | 24 | TD Tech | Rel-10 | 46 | Issam | HNB_LCRTDD_RF-Perf | RP-101081 | HNB |
| 3587 | 979 | **Multi-User Multiple-Input and Multiple-Output (MU-MIMO) for 1.28Mcps TDD** | 316d? | 2010-03-19 A | 2011-06-03 A | 100% | 2010-03-19 | 2011-06-03 | 316d? |  | R1; R2; R3; R4 | 17224h | 17224h | MUMIMO_LCR_TDD | 24 | CATT | Rel-10 | 47 | Patrick | MUMIMO_LCR_TDD |  |  |
| 3588 | 979.1 | Core part: MU-MIMO for 1.28Mcps TDD | 191d? | 2010-03-19 A | 2010-12-10 A | 100% | 2010-03-19 | 2010-12-10 | 191d? | finish no earlier than 2010-12-10 | R1; R2; R3 | 4584h | 4584h | MUMIMO_LCR_TDD-Core | 24 | CATT | Rel-10 | 47 | Patrick | MUMIMO_LCR_TDD-Core | RP-101085 |  |
| 3589 | 979.2 | Perf. part: MU-MIMO for 1.28Mcps TDD | 316d? | 2010-03-19 A | 2011-06-03 A | 100% | 2010-03-19 | 2011-06-03 | 316d? | finish no earlier than 2011-06-03 | R4 | 2528h | 2528h | MUMIMO_LCR_TDD-Perf | 24 | CATT | Rel-10 | 47 | Issam | MUMIMO_LCR_TDD-Perf | RP-110520 |  |
| 3590 | 980 | **AGNSS Minimum Performance for UTRAN** | 523d? | 2009-09-18 A | 2011-09-16 A | 100% | 2009-09-18 | 2011-09-16 | 523d? |  | R4; R5 | 13624h | 13624h | AGNSSPerf_UTRAN | 23 | Thales | Rel-10 | 45 | Issam | AGNSSPerf_UTRAN |  |  |
| 3591 | 980.1 | AGNSS Minimum Performance Specification Development | 321d? | 2009-09-18 A | 2010-12-10 A | 100% | 2009-09-18 | 2010-12-10 | 321d? | finish no earlier than 2010-12-10 | R4 | 2568h | 2568h | AGNSSPerf_UTRAN | 23 | Thales | Rel-10 | 45 | Issam | AGNSSPerf_UTRAN | RP-101078 |  |
| 3592 | 980.2 | AGNSS test case development for UMTS | 336d? | 2010-06-04 A | 2011-09-16 A | 100% | 2010-06-04 | 2011-09-16 | 336d? | finish no earlier than 2011-09-16 | R5 | 2688h | 2688h | AGNSSPerf_UTRAN | 25 | Thales | Rel-10 | 48 | Ingbert | AGNSSPerf_UTRAN | RP-110979 |  |
| 3593 | 981 | **Inclusion of RF Pattern Matching Technologies as positioning method in the UTRAN** | 336d? | 2009-12-04 A | 2011-03-18 A | 100% | 2009-12-04 | 2011-03-18 | 336d? |  | R2; R3 | 10752h | 10752h | LCS_UMTS_RFPMT | 24 | Polaris Wireless | Rel-10 | 46 | Yong-Jun | LCS_UMTS_RFPMT | RP-110048 |  |
| 3594 | 981.1 | Core part: Inclusion of RF Pattern Matching Technologies as positioning method in the UTRAN | 336d? | 2009-12-04 A | 2011-03-18 A | 100% | 2009-12-04 | 2011-03-18 | 336d? | finish no earlier than 2011-03-18 | R2; R3 | 5376h | 5376h | LCS_UMTS_RFPMT-Core | 24 | Polaris Wireless | Rel-10 | 46 | Yong-Jun | LCS_UMTS_RFPMT-Core | RP-110048 |  |

Notes:
- 3571: GP#46 approved WID / Impacted TSs and TRs: GERAN / WI rapporteur e-mail: carsten.juncker@renesasmobile.com
- 3572: CP#52 completed / Impacted TSs and TRs: 24.008 / WI rapporteur e-mail: marko.niemi@renesasmobile.com
- 3573: GP#50 completed / Impacted TSs and TRs: 45.005, 45.015 / WI rapporteur e-mail: carsten.juncker@renesasmobile.com
- 3574: GP#57 completed / Impacted TSs and TRs: 51.010 / WI rapporteur e-mail: carsten.juncker@renesasmobile.com
- 3575: GP#47 approved WID. 900 MHz spectrum re-farming to other RATs lead operators to reduce GSM capacity and therefore share their GSM networks. Hence the need for the most suitable (GE)RAN sharing method / Impacted TSs and TRs: GERAN / WI rapporteur e-mail: michel.robert@alcatel-lucent.com
- 3576: SP#50 completed / Impacted TSs and TRs: 23.251 / WI rapporteur e-mail: michel.robert@alcatel-lucent.com
- 3577: CP#50 completed / Impacted TSs and TRs: 24.008 CR#1644 / WI rapporteur e-mail: michel.robert@alcatel-lucent.com
- 3578: GP#49 completed / Impacted TSs and TRs: 48.008 CR#0325, 48.018 CR#0303 / WI rapporteur e-mail: michel.robert@alcatel-lucent.com
- 3579: GP#47 approved WID / Impacted TSs and TRs: GERAN,UTRA / WI rapporteur e-mail: Ms Juan Deng (dengjuan@chinamobile.com), Xinhui Wang (wangxinhui@zte.com.cn)
- 3580: GP#49 completed. GP#48 updated WID GP-101659=>GP-101758 (restricting the scope to GERAN BSC and TD-SCDMA RNC only). GP#47 approved WID / Impacted TSs and TRs: 43.130, 48.008 / WI rapporteur e-mail: Ms Juan Deng (dengjuan@chinamobile.com), Xinhui Wang (wangxinhui@zte.com.cn)
- 3581: RP#52 completed / Impacted TSs and TRs: UTRA Stage 2 (25.401, 25.420), Stage 3 (25.423) / WI rapporteur e-mail: Liu Junqiang (liu.junqiang@zte.com.cn)
- 3582: RP#47 completed / Impacted TSs and TRs: UTRA 25.113, New 25.116, 25.153 (testing) / WI rapporteur e-mail: qinyan@chinattl.com
- 3583: RP#50 completed / Impacted TSs and TRs: UTRA 25.102, 25.105, 25.123, 25.221, 25.222, 25.223, 25.224, 25.225, 25.306, 25.319, 25.321, 25.331, 25.423, 25.427, 25.433 / WI rapporteur e-mail: Aihui Song (songaihui@mail.ritt.com.cn)
- 3584: RP#50 completed. Triggered by FS_RAN-HNBLCRTDD UID_410016 Study on 1.28 Mcps TDD Home NodeB (TR 25.866) / Impacted TSs and TRs: UTRA / WI rapporteur e-mail: Li Rong (lirong@td-tech.com)
- 3585: RP#48 completed / Impacted TSs and TRs: 25.105 / WI rapporteur e-mail: Li Rong (lirong@td-tech.com)
- 3586: RP#50 completed. TR 25.968 v100 for Approval / Impacted TSs and TRs: 25.142, new TR 25.968 / WI rapporteur e-mail: Li Rong (lirong@td-tech.com)
- 3587: RP#52 completed / Impacted TSs and TRs: UTRA / WI rapporteur e-mail: Yanping Xing (xingyanping@datangmobile.cn)
- 3588: RP#50 completed / Impacted TSs and TRs: 25.221, 25.222, 25.224, 25.306, 25.308, 25.319, 25.331, 25.423, 25.425, 25.433, 25.435 / WI rapporteur e-mail: Yanping Xing (xingyanping@datangmobile.cn)
- 3589: RP#52 completed / Impacted TSs and TRs: 25.102, 25.105, 25.142 / WI rapporteur e-mail: Sanjun Feng (fengsanjun@datangmobile.cn)
- 3590: RP#53 completed. Triggered by Rel-7 UID_20050 (GNSS in UTRAN) and Rel-8 UID_400051 (Support for Additional NSS). Linked to GERAN Rel-9 UID_38002 (AGNSS Performances and Testing Procedures) / Impacted TSs and TRs: UTRA / WI rapporteur e-mail: Michel.monnerat@thalesaleniaspace.com
- 3591: RP#50 completed / Impacted TSs and TRs: new 25.172 / WI rapporteur e-mail: Michel.monnerat@thalesaleniaspace.com
- 3592: RP#53 completed / Impacted TSs and TRs: 34.108, 34.109, 34.123-1, 34.123-2, 34.123-3, 36.37.571-5, new 34.172 / WI rapporteur e-mail: Michel.monnerat@thalesaleniaspace.com
- 3593: RP#51 completed. Triggered by Study UID_380079 Evaluation of the inclusion of Path Loss Based Technology in the UTRAN (25.907) / Impacted TSs and TRs: UTRA / WI rapporteur e-mail: Norman Shaw (nshaw@polariswireless.com)
- 3594: RP#51 completed / Impacted TSs and TRs: 25.305, 25.453 / WI rapporteur e-mail: Norman Shaw (nshaw@polariswireless.com)

| ID | WBS | Task | Duration | Start | Finish | Complete | Baseline start | Baseline finish | Baseline duration | Constraint | Resources | Work | Actual work | Acronym | PCG approved | WI rapporteur name | WI rapporteur e-mail | Release | TSG approved | MCC resp | Acronym_3GU_Export | Status Report | PCG stopped | TSG stopped | Special Focus Doc |
| --- | --- | --- | --- | --- | --- | --- | --- | --- | --- | --- | --- | --- | --- | --- | --- | --- | --- | --- | --- | --- | --- | --- | --- | --- | --- |
| 3595 | 982 | **Four carrier HSDPA** | 992d? | 2009-12-04 A | 2013-09-06 A | 100% | 2009-12-04 | 2013-09-06 | 992d? |  | R1; R2; R3; R4; R5 | 57872h | 57872h | 4C_HSDPA | 24 | Qualcomm | Arjun Bharadwaj (arjunb@qualcomm.com) | Rel-10 | 46 | Patrick | 4C_HSDPA |  |  |  |  |
| 3596 | 982.1 | Core part: Four carrier HSDPA | 336d? | 2009-12-04 A | 2011-03-18 A | 100% | 2009-12-04 | 2011-03-18 | 336d? | finish no earlier than 2011-03-18 | R1; R2; R3; R4 | 10752h | 10752h | 4C_HSDPA-Core | 24 | Qualcomm | Arjun Bharadwaj (arjunb@qualcomm.com) | Rel-10 | 46 | Patrick | 4C_HSDPA-Core | RP-110046 |  |  |  |
| 3597 | 982.2 | Perf. part: Four carrier HSDPA | 466d? | 2009-12-04 A | 2011-09-16 A | 100% | 2009-12-04 | 2011-09-16 | 466d? | finish no earlier than 2011-09-16 | R4 | 3728h | 3728h | 4C_HSDPA-Perf | 24 | Qualcomm | Arjun Bharadwaj (arjunb@qualcomm.com) | Rel-10 | 46 | Issam | 4C_HSDPA-Perf | RP-110986 |  |  |  |
| 3598 | 982.3 | Test part: Four carrier HSDPA | 464d? | 2011-12-02 A | 2013-09-06 A | 100% | 2011-12-02 | 2013-09-06 | 464d? | finish no earlier than 2013-09-06 | R5 | 3712h | 3712h | 4C_HSDPA-UEConTest | 28 | Qualcomm | Shubhang Vora (svora@qualcomm.com) | Rel-10 | 54 | Ingbert | 4C_HSDPA-UEConTest | RP-130940 |  |  |  |
| 3599 | 983 | **Performance Requirements for two-antenna 1.28Mcps TDD Type 1 and Type 2 UE receiver** | 316d? | 2010-03-19 A | 2011-06-03 A | 100% | 2010-03-19 | 2011-06-03 | 316d? |  | R4 | 5504h | 5504h | 2ant_UE_LCR_TDD | 24 | TD Tech | dafei.wang@td-tech.com | Rel-10 | 47 | Issam | 2ant_UE_LCR_TDD |  |  |  |  |
| 3600 | 983.1 | Core part: Performance Requirements for two-antenna 1.28Mcps TDD Type 1 and Type 2 UE receiver | 56d? | 2010-03-19 A | 2010-06-04 A | 100% | 2010-03-19 | 2010-06-04 | 56d? | finish no earlier than 2010-06-04 | R4 | 448h | 448h | 2ant_UE_LCR_TDD-Core | 24 | TD Tech | dafei.wang@td-tech.com | Rel-10 | 47 | Issam | 2ant_UE_LCR_TDD-Core | RP-100454 |  |  |  |
| 3601 | 983.2 | Perf. part: Performance Requirements for two-antenna 1.28Mcps TDD Type 1 and Type 2 UE receiver | 316d? | 2010-03-19 A | 2011-06-03 A | 100% | 2010-03-19 | 2011-06-03 | 316d? | finish no earlier than 2011-06-03 | R4 | 2528h | 2528h | 2ant_UE_LCR_TDD-Perf | 24 | TD Tech | dafei.wang@td-tech.com | Rel-10 | 47 | Issam | 2ant_UE_LCR_TDD-Perf | RP-110521 |  |  |  |
| 3602 | 984 | **Automatic Neighbour Relation (ANR) for UTRAN** | 663d? | 2010-06-04 A | 2012-12-07 A | 100% | 2010-06-04 | 2012-12-07 | 663d? |  | R3; R2; R5 | 22672h | 22672h | ANR_UTRAN | 25 | ZTE | Zhai.hengxing@zte.com.cn | Rel-10 | 48 | Juha | ANR_UTRAN |  |  |  |  |
| 3603 | 984.1 | Core part: Automatic Neighbour Relation (ANR) for UTRAN | 261d? | 2010-06-04 A | 2011-06-03 A | 100% | 2010-06-04 | 2011-06-03 | 261d? | finish no earlier than 2011-06-03 | R3; R2 | 4176h | 4176h | ANR_UTRAN-Core | 25 | ZTE | Zhai.hengxing@zte.com.cn | Rel-10 | 48 | Juha | ANR_UTRAN-Core | RP-110522 |  |  |  |
| 3604 | 984.2 | Test part: Automatic Neighbour Relation (ANR) for UTRAN | 323d? | 2011-09-19 A | 2012-12-07 A | 100% | 2011-09-19 | 2012-12-07 | 323d? | finish no earlier than 2012-12-07 | R5 | 2584h | 2584h | ANR_UTRAN-UEConTest | 27 | Ericsson | leif.mattisson@ericsson.com | Rel-10 | 53 | Ingbert | ANR_UTRAN-UEConTest | RP-121529 |  |  |  |
| 3605 | 985 | **Support of New Band Combinations for Dual-Band Dual Cell HSDPA** | 261d? | 2010-06-04 A | 2011-06-03 A | 100% | 2010-06-04 | 2011-06-03 | 261d? |  | R4; R2 | 9568h | 9568h | DB_DC_HSDPA | 25 | AT&T | Vince Spatafora (vs5785@att.com) | Rel-10 | 48 | Issam | DB_DC_HSDPA |  |  |  |  |
| 3606 | 985.1 | Core part: Support of New Band Combinations for Dual-Band Dual Cell HSDPA | 261d? | 2010-06-04 A | 2011-06-03 A | 100% | 2010-06-04 | 2011-06-03 | 261d? | finish no earlier than 2011-06-03 | R4; R2 | 4176h | 4176h | DB_DC_HSDPA-Core | 25 | AT&T | Vince Spatafora (vs5785@att.com) | Rel-10 | 48 | Issam | DB_DC_HSDPA-Core | RP-110523 |  |  |  |
| 3607 | 985.2 | Deleted - Perf. part: Support of New Band Combinations for Dual-Band Dual Cell HSDPA | 76d? | 2010-06-04 A | 2010-09-17 A | 100% | 2010-06-04 | 2010-09-17 | 76d? | finish no earlier than 2010-09-17 | R4; R2 | 1216h | 1216h | DB_DC_HSDPA-Perf | 25 | AT&T | Vince Spatafora (vs5785@att.com) | Rel-10 | 48 | Issam | DB_DC_HSDPA-Perf | RP-100759 | PCG-25 | RP-49 |  |
| 3608 | 986 | **MIMO operation with non-MIMO coexistence in HSDPA** | 459d? | 2010-06-04 A | 2012-03-02 A | 100% | 2010-06-04 | 2012-03-02 | 459d? |  | R4; R5 | 12936h | 12936h | MIMO_HSDPA | 25 | Qualcomm | Heechoon Lee | Rel-10 | 48 | Issam | MIMO_HSDPA |  |  |  |  |
| 3609 | 986.1 | Core part: MIMO operation with non-MIMO coexistence in HSDPA | 186d? | 2010-09-17 A | 2011-06-03 A | 100% | 2010-09-17 | 2011-06-03 | 186d? | finish no earlier than 2011-06-03 | R4 | 1488h | 1488h | MIMO_HSDPA-Core | 25 | Qualcomm | Heechoon Lee | Rel-10 | 49 | Issam | MIMO_HSDPA-Core | RP-110524 |  |  |  |
| 3610 | 986.2 | Perf. part: MIMO operation with non-MIMO coexistence in HSDPA | 261d? | 2010-06-04 A | 2011-06-03 A | 100% | 2010-06-04 | 2011-06-03 | 261d? | finish no earlier than 2011-06-03 | R4 | 2088h | 2088h | MIMO_HSDPA-Perf | 25 | Qualcomm | Heechoon Lee | Rel-10 | 48 | Issam | MIMO_HSDPA-Perf | RP-110525 |  |  |  |
| 3611 | 986.3 | Test part: MIMO operation with non-MIMO coexistence in HSDPA | 252d? | 2011-03-18 A | 2012-03-02 A | 100% | 2011-03-18 | 2012-03-02 | 252d? | finish no earlier than 2012-03-02 | R5 | 2016h | 2016h | MIMO_HSDPA-UEConTest | 26 | Qualcomm | Shubhang Vora (svora@qualcomm.com) | Rel-10 | 51 | Ingbert | MIMO_HSDPA-UEConTest | RP-120042 |  |  |  |
| 3612 | 987 | Interfrequency detected set measurements for UMTS | 61d? | 2010-09-17 A | 2010-12-10 A | 100% | 2010-09-17 | 2010-12-10 | 61d? | finish no earlier than 2010-12-10 | R2; R4 | 976h | 976h | Interf_dset_meas_UMTS | 25 | Nokia | Chris.callender@nokia.com | Rel-10 | 49 | Yong-Jun | Interf_dset_meas_UMTS | RP-101093 |  |  |  |
| 3613 | 988 | **Carrier Aggregation for LTE** | 793d? | 2009-12-04 A | 2012-12-07 A | 100% | 2009-12-04 | 2012-12-07 | 793d? |  | R1; R2; R3; R4; R5 | 51024h | 51024h | LTE_CA | 24 | Nokia | Asbjorn.grovlen@nokia.com | Rel-10 | 46 | Patrick | LTE_CA |  |  |  | CA |
| 3614 | 988.1 | Core part: Carrier Aggregation for LTE | 391d? | 2009-12-04 A | 2011-06-03 A | 100% | 2009-12-04 | 2011-06-03 | 391d? | finish no earlier than 2011-06-03 | R1; R2; R3; R4 | 12512h | 12512h | LTE_CA-Core | 24 | Nokia | lars.e.lindh@nokia.com | Rel-10 | 46 | Patrick | LTE_CA-Core | RP-110535 |  |  | CA |
| 3615 | 988.2 | Perf. part: Carrier Aggregation for LTE | 528d? | 2009-12-04 A | 2011-12-09 A | 100% | 2009-12-04 | 2011-12-09 | 528d? | finish no earlier than 2011-12-09 | R4 | 4224h | 4224h | LTE_CA-Perf | 24 | Nokia | lars.e.lindh@nokia.com | Rel-10 | 46 | Issam | LTE_CA-Perf | RP-111452 |  |  | CA |
| 3616 | 988.3 | Test part: Carrier Aggregation for LTE | 321d? | 2011-09-19 A | 2012-12-07 A | 100% | 2011-09-19 | 2012-12-07 | 321d? | finish no earlier than 2012-12-07 | R5 | 2568h | 2568h | LTE_CA-UEConTest | 27 | Nokia | jussi.kuusisto@nokia.com | Rel-10 | 53 | Ingbert | LTE_CA-UEConTest | RP-121528 |  |  | CA |
| 3617 | 989 | **Enhanced Downlink Multiple Antenna Transmission for LTE** | 930d? | 2009-12-04 A | 2013-06-14 A | 100% | 2009-12-04 | 2013-06-14 | 930d? |  | R1; R2; R4; R5 | 44624h | 44624h | LTE_eDL_MIMO | 24 | NTT DoCoMo | Hidekazu Taoka (taoka@nttdocomo.com) | Rel-10 | 46 | Patrick | LTE_eDL_MIMO |  |  |  |  |
| 3618 | 989.1 | Core part: Enhanced Downlink Multiple Antenna Transmission for LTE | 336d? | 2009-12-04 A | 2011-03-18 A | 100% | 2009-12-04 | 2011-03-18 | 336d? | finish no earlier than 2011-03-18 | R1; R2; R4 | 8064h | 8064h | LTE_eDL_MIMO-Core | 24 | NTT DoCoMo | Hidekazu Taoka (taoka@nttdocomo.com) | Rel-10 | 46 | Patrick | LTE_eDL_MIMO-Core | RP-110067 |  |  |  |
| 3619 | 989.2 | Perf. part: Enhanced Downlink Multiple Antenna Transmission for LTE | 589d? | 2009-12-04 A | 2012-03-02 A | 100% | 2009-12-04 | 2012-03-02 | 589d? | finish no earlier than 2012-03-02 | R4 | 4712h | 4712h | LTE_eDL_MIMO-Perf | 24 | NTT DoCoMo | Hidekazu Taoka (taoka@nttdocomo.com) | Rel-10 | 46 | Issam | LTE_eDL_MIMO-Perf | RP-120053 |  |  |  |
| 3620 | 989.3 | Test part: Enhanced Downlink Multiple Antenna Transmission for LTE | 261d? | 2012-06-18 A | 2013-06-14 A | 100% | 2012-06-18 | 2013-06-14 | 261d? | finish no earlier than 2013-06-14 | R5 | 2088h | 2088h | LTE_eDL_MIMO-UEConTest | 29 | ZTE | Carolyn Taylor (carolyn.tayl@zte.com.cn) | Rel-10 | 56 | Ingbert | LTE_eDL_MIMO-UEConTest | RP-130464 |  |  |  |

Notes:
- 3595: RP#53 completed / Impacted TSs and TRs: UTRA
- 3596: RP#51 completed. RP#52 TR 25.864 v200 for Approval / Impacted TSs and TRs: 25.101, 25.104, 25.133, 25.211, 25.212, 25.213, 25.214, 25.215, 25.308, 25.331, 25.423, 25.433, 26.306, new TR 25.864
- 3597: RP#53 completed / Impacted TSs and TRs: 25.101, 25.104, 25.133, 25.141
- 3598: RP#61 completed / Impacted TSs and TRs: 34.108, 34.121-1, 34.121-2, 34.123-1, 34.123-2, 34.123-3
- 3599: Stage 3. RP#52 completed / Impacted TSs and TRs: UTRA
- 3600: RP#48 completed / Impacted TSs and TRs: 25.102
- 3601: RP#52 completed / Impacted TSs and TRs: 25.102
- 3602: RP#52 Core completed. Automatic Neighbour Relation (ANR) function for UTRAN relieves operators from the burden of manually managing the Neighbour cell Relations (NRs) / Impacted TSs and TRs: UTRA
- 3603: RP#52 completed / Impacted TSs and TRs: 25.331, 25.413, 25.423, new TS 25.484 (Stage 2)
- 3604: RP#58 completed / Impacted TSs and TRs: 34.108, 34.123-1, 34.123-2, 34.123-3
- 3605: RP#52 completed. Rel-9 Dual-Band Dual-Cell HSDPA (UID_430015 Support for different bands for Dual-Cell HSDPA) has one combination per region in principle. This work adds additional combinations: Band I and XI (Region 3) and Band II and V (Region 2) / Impacted TSs and TRs: UTRA
- 3606: RP#52 completed. RP#62 existing TS 25.317 replaced by new TS 25.327 / Impacted TSs and TRs: 25.101, 25.104, 25.141, 25.317 replaced by new TS 25.327
- 3607: RP#49 stopped (Reason: no need for Performance work) / Impacted TSs and TRs: 25.101, 25.104, 25.141, 25.317
- 3608: RP#52 completed. RP#49 updated WID RP-100687=>RP-100993 (changed Title: MIMO Testing in HSDPA => MIMO operation with non-MIMO coexistence in HSDPA) / Impacted TSs and TRs: UTRA
- 3609: RP#52 completed / Impacted TSs and TRs: 25.104
- 3610: RP#52 completed / Impacted TSs and TRs: 25.101, 25.141
- 3611: RP#55 completed / Impacted TSs and TRs: 34.108, 34.121-1, 34.121-2, 34.123-1, 34.123-2, 34.123-3
- 3612: RP#50 completed / Impacted TSs and TRs: UTRA 25.133, 25.331
- 3613: - / Impacted TSs and TRs: LTE
- 3614: RP#52 completed. RP#56 new RAN4 TR (36.807, 36.808) v200 for Approval / Impacted TSs and TRs: 36.101, 36.104, 36.133, 36.211, 36.212, 36.213, 36.300, 36.302, 36.306, 36.321, 36.331, 36.413, 36.423, 37.104, new RAN4 TR (36.807, 36.808)
- 3615: RP#54 completed / Impacted TSs and TRs: 36.101, 36.104, 36.133, 36.141, 37.141
- 3616: RP#58 completed / Impacted TSs and TRs: 36.508, 36.521-1, 36.521-2, 36.521-3, 36.523-1, 36.523-2, 36.523-3, 37.571-1, 37.571-3, 37.571-5
- 3617: - / Impacted TSs and TRs: LTE
- 3618: RP#51 completed. RP#56 new RAN4 TR 36.807 v200 for Approval / Impacted TSs and TRs: 36.101, 36.104, 36.133, 36.201, 36.211, 36.212, 36.213, 36.300, 36.306, 36.321, 36.331, new RAN4 TR 36.807
- 3619: RP#55 completed / Impacted TSs and TRs: 36.101, 36.104, 36.133, 36.141
- 3620: RP#60 completed. Testing for 36.101, 36.133 / Impacted TSs and TRs: 36.508, 36.521-1, 36.521-2

| ID | WBS | Task | Duration | Start | Finish | Complete | Baseline start | Baseline finish | Baseline duration | Constraint | Resources | Work | Actual work | Acronym | PCG approved | WI rapporteur name | WI rapporteur e-mail | Release | TSG approved | MCC resp | Acronym_3GU_Export | Status Report | PCG stopped | TSG stopped |
| --- | --- | --- | --- | --- | --- | --- | --- | --- | --- | --- | --- | --- | --- | --- | --- | --- | --- | --- | --- | --- | --- | --- | --- | --- |
| 3621 | 990 | **Uplink Multiple Antenna Transmission for LTE** | 3445d? | 2000-01-03 A | 2013-03-01 A | 100% | 2000-01-03 | 2013-03-01 | 3445d? |  | R1; R2; R4; R5 | 125976h | 125976h | LTE_UL_MIMO | 24 | Huawei | Mattias.wennstrom@huawei.com | Rel-10 | 46 | Patrick | LTE_UL_MIMO |  |  |  |
| 3622 | 990.1 | Core part: UL multiple antenna transmission for LTE | 391d? | 2000-01-03 A | 2001-06-29 A | 100% | 2000-01-03 | 2001-06-29 | 391d? |  | R1; R2; R4 | 9384h | 9384h | LTE_UL_MIMO-Core | 24 | Huawei | Mattias.wennstrom@huawei.com | Rel-10 | 46 | Patrick | LTE_UL_MIMO-Core | RP-110537 |  |  |
| 3623 | 990.2 | Perf. part: UL multiple antenna transmission for LTE | 466d? | 2009-12-04 A | 2011-09-16 A | 100% | 2009-12-04 | 2011-09-16 | 466d? | finish no earlier than 2011-09-16 | R4 | 3728h | 3728h | LTE_UL_MIMO-Perf | 24 | Huawei | Mattias.wennstrom@huawei.com | Rel-10 | 46 | Issam | LTE_UL_MIMO-Perf | RP-110992 |  |  |
| 3624 | 990.3 | Test part: UL multiple antenna transmission for LTE | 328d? | 2011-12-02 A | 2013-03-01 A | 100% | 2011-12-02 | 2013-03-01 | 328d? | finish no earlier than 2013-03-01 | R5 | 2624h | 2624h | LTE_UL_MIMO-UEConTest | 28 | Huawei | Zhang Xin (suzanna.zhang@huawei.com) | Rel-10 | 54 | Ingbert | LTE_UL_MIMO-UEConTest | RP-130038 |  |  |
| 3625 | 991 | **Relays for LTE** | 394d? | 2009-12-04 A | 2011-06-08 A | 100% | 2009-12-04 | 2011-06-08 | 394d? |  | R1; R2; R4; S2; S3; C4; C6 | 36856h | 36856h | LTE_Relay | 24 | Ericsson | christian.hoymann@ericsson.com | Rel-10 | 46 | Patrick | LTE_Relay |  |  |  |
| 3626 | 991.1 | Core part: Relays for LTE | 391d? | 2009-12-04 A | 2011-06-03 A | 100% | 2009-12-04 | 2011-06-03 | 391d? | finish no earlier than 2011-06-03 | R1; R2; R4 | 9384h | 9384h | LTE_Relay-Core | 24 | Ericsson | christian.hoymann@ericsson.com | Rel-10 | 46 | Patrick | LTE_Relay-Core | RP-110540 |  |  |
| 3627 | 991.2 | Deleted - Perf. part: Relays for LTE | 391d? | 2009-12-04 A | 2011-06-03 A | 100% | 2009-12-04 | 2011-06-03 | 391d? | finish no earlier than 2011-09-16 | R4 | 3128h | 3128h | LTE_Relay-Perf | 24 | Ericsson | christian.hoymann@ericsson.com | Rel-10 | 46 | Issam | LTE_Relay-Perf | RP-110541 | PCG-27 | RP-52 |
| 3628 | 991.3 | Stage 2 for Relays for LTE | 3d? | 2011-06-06 A | 2011-06-08 A | 100% | 2011-06-06 | 2011-06-08 | 3d? | start no earlier than 2011-06-06 | S2 | 24h | 24h | LTE_Relay | 27 | Vodafone | chris.pudney@vodafone.com | Rel-10 | 52 | Maurice | LTE_Relay |  |  |  |
| 3629 | 991.4 | **LTE Relay Nodes Security** | 69d? | 2010-12-16 A | 2011-03-22 A | 100% | 2010-12-16 | 2011-03-22 | 69d? |  | S3; C6 | 2232h | 2232h | LTE_Relay-Sec | 26 | Qualcomm | Adrian Escott (aescott@qualcomm.com) | Rel-10 | 50 | Mirko | LTE_Relay-Sec |  |  |  |
| 3630 | 991.4.1 | TR on LTE Relay Nodes Security | 69d? | 2010-12-16 A | 2011-03-22 A | 100% | 2010-12-16 | 2011-03-22 | 69d? | finish no earlier than 2011-03-23 | S3 | 552h | 552h | LTE_Relay-Sec | 26 | Qualcomm | Adrian Escott (aescott@qualcomm.com) | Rel-10 | 50 | Mirko |  |  |  |  |
| 3631 | 991.4.2 | Security for LTE Relay Nodes (Stage 2) | 69d? | 2010-12-16 A | 2011-03-22 A | 100% | 2010-12-16 | 2011-03-22 | 69d? | finish no earlier than 2011-03-23 | S3 | 552h | 552h | LTE_Relay-Sec | 26 | Qualcomm | Adrian Escott (aescott@qualcomm.com) | Rel-10 | 50 | Mirko |  |  |  |  |
| 3632 | 991.4.3 | CT6 aspects of LTE Relay Node Security | 3d? | 2011-03-16 A | 2011-03-18 A | 100% | 2011-03-16 | 2011-03-18 | 3d? | start no earlier than 2011-03-16 | C6 | 24h | 24h | LTE_Relay-Sec | 26 | n/a | n/a | Rel-10 | 51 | Xavier |  |  |  |  |
| 3633 | 991.5 | Core Network Impacts for Relay Nodes | 3d? | 2011-03-16 A | 2011-03-18 A | 100% | 2011-03-16 | 2011-03-18 | 3d? | finish no earlier than 2011-03-18 | C4 | 24h | 24h | LTE_Relay-CN | 26 | Vodafone | David.Hutton@vodafone.com | Rel-10 | 51 | Kimmo | LTE_Relay-CN |  |  |  |
| 3634 | 992 | **Enhanced Inter-Cell Interference Control (ICIC) for non-Carrier Aggregation (CA) based deployments of heterogeneous networks for LTE** | 1119d? | 2010-03-19 A | 2014-06-13 A | 100% | 2010-03-19 | 2014-06-13 | 1119d? |  | R1; R2; R3; R4; R5 | 64384h | 64384h | eICIC_LTE | 24 | China Mobile | Xiaodong XU (xuxiaodong@chinamobile.com) | Rel-10 | 47 | Patrick | eICIC_LTE |  |  |  |
| 3635 | 992.1 | Core part: Enhanced Inter-Cell Interference Control (ICIC) for non-Carrier Aggregation (CA) based deployments of heterogeneous networks for LTE | 316d? | 2010-03-19 A | 2011-06-03 A | 100% | 2010-03-19 | 2011-06-03 | 316d? | finish no earlier than 2011-06-03 | R1; R2; R3; R4 | 10112h | 10112h | eICIC_LTE-Core | 24 | China Mobile | Xiaodong XU (xuxiaodong@chinamobile.com) | Rel-10 | 47 | Patrick | eICIC_LTE-Core | RP-110543 |  |  |
| 3636 | 992.2 | Perf. part: Enhanced Inter-Cell Interference Control (ICIC) for non-Carrier Aggregation (CA) based deployments of heterogeneous networks for LTE | 589d? | 2010-03-19 A | 2012-06-15 A | 100% | 2010-03-19 | 2012-06-15 | 589d? | finish no earlier than 2012-06-15 | R4 | 4712h | 4712h | eICIC_LTE-Perf | 24 | China Mobile | Xiaodong XU (xuxiaodong@chinamobile.com) | Rel-10 | 47 | Issam | eICIC_LTE-Perf | RP-120461 |  |  |
| 3637 | 992.3 | Test part: Enhanced Inter-Cell Interference Control (ICIC) for non-Carrier Aggregation (CA) based deployments of heterogeneous networks for LTE | 600d? | 2012-03-05 A | 2014-06-13 A | 100% | 2012-03-05 | 2014-06-13 | 600d? | finish no earlier than 2014-06-13 | R5 | 4800h | 4800h | eICIC_LTE-UEConTest | 28 | Qualcomm | Anjali Mishra (ajha@qualcomm.com) | Rel-10 | 55 | Ingbert | eICIC_LTE-UEConTest | RP-140766 |  |  |
| 3638 | 993 | **LTE TDD in 2600MHz for US** | 191d? | 2010-03-19 A | 2010-12-10 A | 100% | 2010-03-19 | 2010-12-10 | 191d? |  | R4; R2; R3; R5 | 11344h | 11344h | LTE_TDD_2600_US | 24 | Clearwire | michael.hart@clearwire.com | Rel-10 | 47 | Issam | LTE_TDD_2600_US |  |  |  |
| 3639 | 993.1 | Core part: LTE TDD in 2600MHz for US | 129d? | 2010-03-19 A | 2010-09-15 A | 100% | 2010-03-19 | 2010-09-17 | 131d? | finish no earlier than 2010-09-17 | R4; R2; R3 | 3096h | 3096h | LTE_TDD_2600_US-Core | 24 | Clearwire | michael.hart@clearwire.com | Rel-10 | 47 | Issam | LTE_TDD_2600_US-Core | RP-100782 |  |  |
| 3640 | 993.2 | Perf. part: LTE TDD in 2600MHz for US | 131d? | 2010-03-19 A | 2010-09-17 A | 100% | 2010-03-19 | 2010-09-17 | 131d? | finish no earlier than 2010-09-17 | R4 | 1048h | 1048h | LTE_TDD_2600_US-Perf | 24 | Clearwire | michael.hart@clearwire.com | Rel-10 | 47 | Issam | LTE_TDD_2600_US-Perf | RP-100783 |  |  |
| 3641 | 993.3 | UE conformance test part: LTE TDD in 2600MHz for US | 136d? | 2010-06-04 A | 2010-12-10 A | 100% | 2010-06-04 | 2010-12-10 | 136d? | finish no earlier than 2010-12-10 | R5 | 1088h | 1088h | LTE_TDD_2600_US-UEConTest | 25 | Clearwire | michael.hart@clearwire.com | Rel-10 | 48 | Ingbert | LTE_TDD_2600_US-UEConTest | RP-101071 |  |  |
| 3642 | 994 | **Adding 2 GHz band LTE FDD (Band 23) for Ancillary Terrestrial Component (ATC) of Mobile Satellite Service (MSS) in North America** | 454d? | 2010-03-19 A | 2011-12-09 A | 100% | 2010-03-19 | 2011-12-09 | 454d? |  | R2; R4; R5 | 19568h | 19568h | S_Band_LTE_ATC_MSS | 24 | DBSD | Mariam.Sorond@ico.com | Rel-10 | 47 | Yong-Jun | S_Band_LTE_ATC_MSS |  |  |  |
| 3643 | 994.1 | Core part: Adding 2 GHz band LTE FDD (Band 23) for ATC of MSS in North America | 316d? | 2010-03-19 A | 2011-06-03 A | 100% | 2010-03-19 | 2011-06-03 | 316d? | finish no earlier than 2011-06-03 | R4; R2 | 5056h | 5056h | S_Band_LTE_ATC_MSS-Core | 24 | DBSD | Mariam.Sorond@ico.com | Rel-10 | 47 | Issam | S_Band_LTE_ATC_MSS-Core | RP-110545 |  |  |
| 3644 | 994.2 | Perf. part: Adding 2 GHz band LTE FDD (Band 23) for ATC of MSS in North America | 316d? | 2010-03-19 A | 2011-06-03 A | 100% | 2010-03-19 | 2011-06-03 | 316d? | finish no earlier than 2011-06-03 | R4 | 2528h | 2528h | S_Band_LTE_ATC_MSS-Perf | 24 | DBSD | Mariam.Sorond@ico.com | Rel-10 | 47 | Issam | S_Band_LTE_ATC_MSS-Perf | RP-110546 |  |  |
| 3645 | 994.3 | Test part: Adding 2 GHz band LTE FDD (Band 23) for ATC of MSS in North America | 137d? | 2011-06-07 A | 2011-12-09 A | 100% | 2011-06-07 | 2011-12-09 | 137d? | finish no earlier than 2011-12-09 | R5 | 1088h | 1088h | S_Band_LTE_ATC_MSS-UEConTest | 27 | DBSD | Mariam.Sorond@ico.com | Rel-10 | 52 | Ingbert | S_Band_LTE_ATC_MSS-UEConTest | RP-111444 |  |  |

Notes:
- 3621: - / Impacted TSs and TRs: LTE
- 3622: RP#52 completed. TR 36.817 v110 for Approval. RP#56 new TR 36.807 v200 for Approval / Impacted TSs and TRs: 36.101, 36.104, 36.133, 36.201, 36.211, 36.212, 36.213, 36.300, 36.306, 36.321, 36.331, new RAN4 (TR 36.807, 36.817)
- 3623: RP#53 completed / Impacted TSs and TRs: 36.101, 36.104, 36.133, 36.141, 36.817
- 3624: RP#59 completed / Impacted TSs and TRs: 36.508, 36.521-1, 36.521-2, 36.521-3, 36.523-1, 36.523-2, 36.523-3
- 3625: RP#52 completed (open RAN4 Core & Perf parts moved to new Rel-11) / Impacted TSs and TRs: LTE
- 3626: RP#52 completed. Updated WID RP-101417=>RP-101911 (contains only Core part completed in Rel-10). Open RAN4 Core & Perf parts moved to new Rel-11 / Impacted TSs and TRs: 36.201, 36.211, 36.212, 36.213, 36.300, 36.321, 36.323, 36.331, New RAN1 TS 36.216
- 3627: RP#52 stopped at 30% (no CRs so far) . Transferred completely to Rel-11 together with remaining core part / Impacted TSs and TRs: 36.133, New TS 36.117 (E-UTRA Relay conformance testing)
- 3628: SP#52 SP-110338 (S2-85/S2-112851) 23.401 Cat F CR#2128 Completion of Relay procedure overview / Impacted TSs and TRs: 23.401
- 3629: -
- 3630: SP#51 completed / Impacted TSs and TRs: 33.816
- 3631: SP#51 completed (impacting Stage 3 in CT and RAN) / Impacted TSs and TRs: 33.401 (CR#0437,0438), CT1 24.301, CT4 (29.272, 29.274), CT6 31.102, RAN2 (36.331, 36.323), RAN3 36.413
- 3632: CP#51 completed / Impacted TSs and TRs: 31.101, 31.102
- 3633: CP#51 completed / Impacted TSs and TRs: 23.003, 23.008, 29.303, 29.230, 29.272
- 3634: RP#56 completed / Impacted TSs and TRs: LTE
- 3635: RP#52 completed / Impacted TSs and TRs: 36.101, 36.133, 36.201, 36.211, 36.212, 36.213, 36.214, 36.300, 36.321, 36.331, 36.413, 36.423
- 3636: RP#56 completed / Impacted TSs and TRs: 36.101, 36.133
- 3637: RP#64 completed / Impacted TSs and TRs: 36.508, 36.521-1, 36.521-2, 36.521-3, 36.523-1, 36.523-2, 36.523-3
- 3638: RP#50 Testing completed. RP#49 Core+Perf completed / Impacted TSs and TRs: LTE
- 3639: RP#49 completed 1st Apr 15: CD:Fri 17/09/10->Wed 15/09/10 / Impacted TSs and TRs: 25.461, 25.466, 36.101, 36.104, 36.113, 36.124, 36.133, 36.141, 36.307, 36.331, 37.104, 37.113, 37.141, new TR 36.812
- 3640: RP#49 completed / Impacted TSs and TRs: 36.101, 36.104, 36.133, 36.141, 36.307, 37.104, 37.141, new TR 36.812
- 3641: RP#50 completed / Impacted TSs and TRs: 36.508, 36.521-1, 36.521-2, 36.521-3, 36.523-1, 36.523-2, 36.523-3
- 3642: RP#52 completed. Updated WID RP-101401=>RP-110775 (changed in Title "LTE" to "LTE FDD (Band 23)" / Impacted TSs and TRs: LTE
- 3643: RP#52 completed / Impacted TSs and TRs: 25.101, 25.104, 25.141, 25.461, 25.466, 36.101, 36.104, 36.113, 36.124, 36.133, 36.307, 37.104, 37.141, new TR 36.811
- 3644: RP#52 completed / Impacted TSs and TRs: 36.101, 36.104, 36.113, 36.124, 36.133, 36.141, 36.307, 36.811
- 3645: RP#54 completed / Impacted TSs and TRs: 36.508, 36.521-1, 36.521-2, 36.521-3, 36.523-1, 36.523-2, 36.523-3

| ID | WBS | Task | Duration | Start | Finish | Complete | Baseline start | Baseline finish | Baseline duration | Constraint | Resources | Work | Actual work | Acronym | PCG approved | WI rapporteur name | WI rapporteur e-mail | Release | TSG approved | MCC resp | Acronym_3GU_Export | Status Report | Special Focus Doc |
| --- | --- | --- | --- | --- | --- | --- | --- | --- | --- | --- | --- | --- | --- | --- | --- | --- | --- | --- | --- | --- | --- | --- | --- |
| 3646 | 995 | **Adding L-Band (Band 24) LTE for Ancillary Terrestrial Component (ATC) of Mobile Satellite Service (MSS) in North America** | 463d? | 2009-12-11 A | 2011-09-16 A | 100% | 2009-12-11 | 2011-09-16 | 463d? |  | R4; R2; R5 | 18864h | 18864h | L_Band_LTE_ATC_MSS | 24 | LightSquared | Eric.Jacks@lightsquared.com, Maqbool.Aliani@lightsquared.com | Rel-10 | 47 | Issam | L_Band_LTE_ATC_MSS |  |  |
| 3647 | 995.1 | Core part: Adding L-Band (Band 24) LTE for ATC of MSS in North America | 261d? | 2009-12-11 A | 2010-12-10 A | 100% | 2009-12-11 | 2010-12-10 | 261d? | finish no earlier than 2010-12-10 | R4; R2 | 4176h | 4176h | L_Band_LTE_ATC_MSS-Core | 24 | LightSquared | Eric.Jacks@lightsquared.com, Maqbool.Aliani@lightsquared.com | Rel-10 | 47 | Issam | L_Band_LTE_ATC_MSS-Core | RP-101117 |  |
| 3648 | 995.2 | Perf. part: Adding L-Band (Band 24) LTE for ATC of MSS in North America | 316d? | 2010-03-19 A | 2011-06-03 A | 100% | 2010-03-19 | 2011-06-03 | 316d? | finish no earlier than 2011-06-03 | R4 | 2528h | 2528h | L_Band_LTE_ATC_MSS-Perf | 24 | LightSquared | Eric.Jacks@lightsquared.com, Maqbool.Aliani@lightsquared.com | Rel-10 | 47 | Issam | L_Band_LTE_ATC_MSS-Perf | RP-110548 |  |
| 3649 | 995.3 | Test part: Adding L-Band (Band 24) LTE for ATC of MSS in North America | 131d? | 2011-03-18 A | 2011-09-16 A | 100% | 2011-03-18 | 2011-09-16 | 131d? | finish no earlier than 2011-09-16 | R5 | 1048h | 1048h | L_Band_LTE_ATC_MSS-UEConTest | 26 | LightSquared | masoud.olfat@lightsquared.com | Rel-10 | 51 | Ingbert | L_Band_LTE_ATC_MSS-UEConTest | RP-110980 |  |
| 3650 | 996 | **LTE Self Optimizing Networks (SON) enhancements** | 316d? | 2010-03-19 A | 2011-06-03 A | 100% | 2010-03-19 | 2011-06-03 | 316d? |  | R3; R2; R4 | 15168h | 15168h | SONenh_LTE | 24 | Nokia Siemens Networks | krzysztof.kordybach@nsn.com | Rel-10 | 47 | Juha | SONenh_LTE |  | SON |
| 3651 | 996.1 | Core part: LTE Self Optimizing Networks (SON) enhancements | 316d? | 2010-03-19 A | 2011-06-03 A | 100% | 2010-03-19 | 2011-06-03 | 316d? | finish no earlier than 2011-06-03 | R3; R2; R4 | 7584h | 7584h | SONenh_LTE-Core | 24 | Nokia Siemens Networks | krzysztof.kordybach@nsn.com | Rel-10 | 47 | Juha | SONenh_LTE-Core | RP-110547 | SON |
| 3652 | 997 | **Further enhancements to MBMS for LTE** | 459d? | 2010-06-04 A | 2012-03-02 A | 100% | 2010-06-04 | 2012-03-02 | 459d? |  | R2; R3; R5 | 14840h | 14840h | MBMS_LTE_enh | 25 | Huawei | Ms Zhao Junhui (zhaojh@huawei.com) | Rel-10 | 48 | Yong-Jun | MBMS_LTE_enh |  |  |
| 3653 | 997.1 | Core part: Further enhancements to MBMS for LTE | 206d? | 2010-06-04 A | 2011-03-18 A | 100% | 2010-06-04 | 2011-03-18 | 206d? | finish no earlier than 2011-03-18 | R2; R3 | 3296h | 3296h | MBMS_LTE_enh-Core | 25 | Huawei | Ms Zhao Junhui (zhaojh@huawei.com) | Rel-10 | 48 | Yong-Jun | MBMS_LTE_enh-Core | RP-110083 |  |
| 3654 | 997.2 | Test part: Further enhancements to MBMS for LTE | 66d? | 2011-12-02 A | 2012-03-02 A | 100% | 2011-12-02 | 2012-03-02 | 66d? | finish no earlier than 2012-03-02 | R5 | 528h | 528h | MBMS_LTE_enh-UEConTest | 28 | Huawei | Zhang Xin (suzanna.zhang@huawei.com) | Rel-10 | 54 | Ingbert | MBMS_LTE_enh-UEConTest | RP-120049 |  |
| 3655 | 998 | **UMTS/LTE 3500 MHz** | 1456d? | 2007-11-30 A | 2013-06-14 A | 100% | 2007-11-30 | 2013-06-14 | 1456d? |  | R4; R2; R3; R5 | 87360h | 87360h | RInImp8-UMTSLTE3500 | 21 | Ericsson | johan.skold@ericsson.com | Rel-10 | 38 | Issam | RInImp8-UMTSLTE3500 |  |  |
| 3656 | 998.1 | Core part: UMTS/LTE 3500 MHz | 994d? | 2007-11-30 A | 2011-09-16 A | 100% | 2007-11-30 | 2011-09-16 | 994d? | finish no earlier than 2011-09-16 | R4; R2; R3 | 23856h | 23856h | RInImp8-UMTSLTE3500 | 21 | Ericsson | johan.skold@ericsson.com | Rel-10 | 38 | Issam | RInImp8-UMTSLTE3500 | RP-110987 |  |
| 3657 | 998.2 | Conformance Test Aspects – LTE 3500 | 1189d? | 2008-12-05 A | 2013-06-14 A | 100% | 2008-12-05 | 2013-06-14 | 1189d? | finish no earlier than 2013-06-14 | R5 | 9512h | 9512h | LTE-UEConTest_LTE3500 | 22 | Ericsson | fredrik.sundstrom@ericsson.com | Rel-10 | 42 | Ingbert | LTE-UEConTest_LTE3500 | RP-130461 |  |
| 3658 | 998.3 | Conformance Test Aspects – UMTS 3500 | 925d? | 2008-12-05 A | 2012-06-15 A | 100% | 2008-12-05 | 2012-06-15 | 925d? | finish no earlier than 2012-06-15 | R5 | 7400h | 7400h | RInImp-UEConTest_UMTS3500 | 22 | Ericsson | fredrik.sundstrom@ericsson.com | Rel-10 | 42 | Ingbert | RInImp-UEConTest_UMTS3500 | RP-120450 |  |
| 3659 | 999 | **Minimization of Drive Tests for E-UTRAN and UTRAN** | 854d? | 2009-12-04 A | 2013-03-01 A | 100% | 2009-12-04 | 2013-03-01 | 854d? |  | R2; R4; R3; R5 | 39784h | 39784h | MDT_UMTSLTE | 24 | Nokia Siemens Networks | malgorzata.tomala@nsn.com | Rel-10 | 46 | Yong-Jun | MDT_UMTSLTE |  |  |
| 3660 | 999.1 | Core part: Minimization of Drive Tests for E-UTRAN and UTRAN | 391d? | 2009-12-04 A | 2011-06-03 A | 100% | 2009-12-04 | 2011-06-03 | 391d? | finish no earlier than 2011-06-03 | R2; R4; R3 | 9384h | 9384h | MDT_UMTSLTE-Core | 24 | Nokia Siemens Networks | malgorzata.tomala@nsn.com | Rel-10 | 46 | Yong-Jun | MDT_UMTSLTE-Core | RP-110528 |  |
| 3661 | 999.2 | Test part: Minimization of Drive Tests for E-UTRAN | 384d? | 2011-09-19 A | 2013-03-01 A | 100% | 2011-09-19 | 2013-03-01 | 384d? | finish no earlier than 2013-03-01 | R5 | 3072h | 3072h | MDT_UMTSLTE-UEConTest | 27 | Ericsson | leif.mattisson@ericsson.com | Rel-10 | 53 | Ingbert | MDT_UMTSLTE-UEConTest | RP-130036 |  |
| 3662 | 1000 | **HNB and HeNB Mobility Enhancements** | 718d? | 2010-03-19 A | 2012-12-07 A | 100% | 2010-03-19 | 2012-12-07 | 718d? |  | R3; R2; R5 | 23016h | 23016h | HNB_HENB_mob_enh | 24 | Alcatel-Lucent | Martin,Warner@alcatel-lucent.com | Rel-10 | 47 | Juha | HNB_HENB_mob_enh |  | HNB |
| 3663 | 1000.1 | Core part: HNB and HeNB Mobility Enhancements | 261d? | 2010-03-19 A | 2011-03-18 A | 100% | 2010-03-19 | 2011-03-18 | 261d? | start no earlier than 2010-03-19 | R3; R2 | 4176h | 4176h | HNB_HENB_mob_enh-Core | 24 | Alcatel-Lucent | Martin.Warner@alcatel-lucent.com | Rel-10 | 47 | Juha | HNB_HENB_mob_enh-Core | RP-110058 | HNB |
| 3664 | 1000.2 | Test part: HeNB Mobility Enhancements | 201d? | 2012-03-05 A | 2012-12-07 A | 100% | 2012-03-05 | 2012-12-07 | 201d? | finish no earlier than 2012-12-07 | R5 | 1608h | 1608h | HNB_HENB_mob_enh-UEConTest_LTE | 28 | Qualcomm | Anjali Mishra (ajha@qualcom.com) | Rel-10 | 55 | Ingbert | HNB_HENB_mob_enh-UEConTest_LTE | RP-121533 | HNB |
| 3665 | 1001 | **Expanded 1900 MHz Band for UTRA and LTE** | 596d? | 2010-06-04 A | 2012-09-07 A | 100% | 2010-06-04 | 2012-09-07 | 596d? |  | R4; R2; R5 | 25312h | 25312h | E1900 | 25 | Sprint | nick.j.baustert@sprint.com | Rel-10 | 48 | Issam | E1900 |  |  |
| 3666 | 1001.1 | Core part: Expanded 1900 MHz Band for UTRA and LTE | 261d? | 2010-06-04 A | 2011-06-03 A | 100% | 2010-06-04 | 2011-06-03 | 261d? | finish no earlier than 2011-06-03 | R4; R2 | 4176h | 4176h | E1900-Core | 25 | Sprint | nick.j.baustert@sprint.com | Rel-10 | 48 | Issam | E1900-Core | RP-110529 |  |
| 3667 | 1001.2 | Perf. part: Expanded 1900 MHz Band for UTRA and LTE | 261d? | 2010-06-04 A | 2011-06-03 A | 100% | 2010-06-04 | 2011-06-03 | 261d? | finish no earlier than 2011-06-03 | R4; R2 | 4176h | 4176h | E1900-Perf | 25 | Sprint | nick.j.baustert@sprint.com | Rel-10 | 48 | Issam | E1900-Perf | RP-110530 |  |
| 3668 | 1001.3 | Test part: Expanded 1900 MHz Band for UTRA and LTE | 333d? | 2011-06-07 A | 2012-09-07 A | 100% | 2011-06-07 | 2012-09-07 | 333d? | finish no earlier than 2012-09-07 | R5 | 2656h | 2656h | E1900-UEConTest | 27 | Sprint | nick.j.baustert@sprint.com | Rel-10 | 52 | Ingbert | E1900-UEConTest | RP-120957 |  |
| 3669 | 1002 | **Multi-Standard Radio Base Station RF requirements for non-contiguous spectrum deployments** | 389d? | 2010-06-04 A | 2011-11-25 A | 100% | 2010-06-04 | 2011-11-25 | 389d? |  | R4; G1 | 16160h | 16160h | MSR_NC | 25 | Ericsson | johan.skold@ericsson.com | Rel-10 | 48 | Issam | MSR_NC |  |  |
| 3670 | 1002.1 | Core part: Multi-Standard Radio BS RF requirements for non-contiguous spectrum deployments | 261d? | 2010-06-04 A | 2011-06-03 A | 100% | 2010-06-04 | 2011-06-03 | 261d? | finish no earlier than 2011-06-03 | R4 | 2088h | 2088h | MSR_NC-Core | 25 | Ericsson | johan.skold@ericsson.com | Rel-10 | 48 | Issam | MSR_NC-Core | RP-110531 |  |
| 3671 | 1002.2 | Perf. part: Multi-Standard Radio BS RF requirements for non-contiguous spectrum deployments | 336d? | 2010-06-04 A | 2011-09-16 A | 100% | 2010-06-04 | 2011-09-16 | 336d? | finish no earlier than 2011-09-16 | R4 | 2688h | 2688h | MSR_NC-Perf | 25 | Ericsson | johan.skold@ericsson.com | Rel-10 | 48 | Issam | MSR_NC-Perf | RP-110988 |  |

Notes:
- 3646: RP#53 completed / Impacted TSs and TRs: LTE
- 3647: RP#51 completed / Impacted TSs and TRs: 25.101, 25.104, 25.141, 25.461, 25.466, 34.124, 36.101, 36.104, 36.113, 36.124, 36.133, 36.307, 37.104, 37.141, new RAN4 TR 36.813
- 3648: RP#52 completed / Impacted TSs and TRs: 34.121-1, 36.101, 36.104, 36.113, 36.124, 36.133, 36.141, 36.307, 36.521-1, 36.813
- 3649: RP#53 completed / Impacted TSs and TRs: 36.508, 36.521-1, 36.521-2, 36.521-3, 36.523-2
- 3650: RP#52 completed / Impacted TSs and TRs: LTE
- 3651: RP#52 completed (Stage 1,2,3) / Impacted TSs and TRs: 36.300, 36.331, 36.413, 36.423
- 3652: RP#51 completed. SA2 decided not to support MBR>GBR in Rel-10 MBMS. For SA2, MBR=GBR in Rel-10 MBMS. Hence RAN removed enabling statistical multiplexing gains for variable bit rate services in Objectives / Impacted TSs and TRs: LTE
- 3653: RP#51 completed / Impacted TSs and TRs: 25.446, 36.300, 36.321, 36.322, 36.323, 36.331, 36.440, 36.441, 36.442, 36.443, 36.444, 36.445
- 3654: RP#55 completed / Impacted TSs and TRs: 36.508, 36.523-1, 36.523-2, 36.523-3
- 3655: - / Impacted TSs and TRs: UTRA, LTE
- 3656: RP#53 completed. TR 37.801v200 for Approval / Impacted TSs and TRs: 25.101, 25.104, 25.113, 25.133, 25.141, 25.307, 25.307, 25.331, 25.461, 25.463, 34.124, 36.101, 36.104, 36.113, 36.141, 36.331, new 37.801
- 3657: RP#60 completed / Impacted TSs and TRs: 36.508, 36.521-1, 36.521-2, 36.521-3
- 3658: RP#56 completed / Impacted TSs and TRs: 34.108, 34.121-1, 34.121-2
- 3659: Triggered by UID_430021 TR 36.805 (Study on Minimization of drive-tests in NGN) / Impacted TSs and TRs: UTRA, LTE
- 3660: RP#52 completed / Impacted TSs and TRs: 25.133, 25.215, 25.304, 25.331, 25.423, 36.133, 36.214, 36.300, 36.304, 36.331, 36.413, 36.423, new 37.320 (Stage 2)
- 3661: RP#59 completed. Testing for LTE only / Impacted TSs and TRs: LTE 34.108, 34.109, 34.123-1, 34.123-2, 34.123-3, 36.508, 36.509, 36.523-1, 36.523-2, 36.523-3
- 3662: - / Impacted TSs and TRs: UTRA, LTE
- 3663: RP#51 completed / Impacted TSs and TRs: 25.413, 25.467, 25.469, 36.300, 36.413, 36.423, new 25.471
- 3664: RP#58 completed / Impacted TSs and TRs: 34.108, 34.123-1, 34.123-2, 34.123-3, 36.508, 36.523-1, 36.523-2, 36.523-3
- 3665: Expand UTRA and E-UTRA band 2 to include frequencies between 1910 1915 MHz and 1990-1995 MHz (US FCC allocation) / Impacted TSs and TRs: UTRA, LTE
- 3666: RP#52 completed / Impacted TSs and TRs: 25.101, 25.104, 25.113, 25.133, 25.141, 25.461, 25.466, 36.101, 36.104, 36.113, 36.124, 36.133, 36.141, 36.307, 36.331, new TR 36.818
- 3667: RP#52 completed / Impacted TSs and TRs: 25.101, 25.104, 25.113, 25.133, 25.141, 25.461, 25.466, 36.101, 36.104, 36.113, 36.124, 36.133, 36.141, 36.307, 36.331, new TR 36.818
- 3668: RP#57 completed / Impacted TSs and TRs: 34.108, 34.121-1, 34.121-2, 34.123-1, 34.123-2, 34.123-3, 36.508, 36.521-1, 36.521-2, 36.521-3, 36.523-1, 36.523-2, 36.523-3
- 3669: - / Impacted TSs and TRs: UTRA, LTE, GERAN
- 3670: RP#52 completed / Impacted TSs and TRs: 25.104, 36.104, 37.104, new TR 37.802
- 3671: RP#53 completed / Impacted TSs and TRs: 25.141, 36.141, 37.141, 37.802

| ID | WBS | Task | Type | Duration | Start | Finish | Complete | Remaining | Baseline start | Baseline finish | Baseline duration | Total slack | Constraint | Resources | Work | Actual work | Acronym | PCG approved | WI rapporteur name | WI rapporteur e-mail | Release | TSG approved | MCC resp | Acronym_3GU_Export | Impacted TSs and TRs | PCG stopped | TSG stopped | Status Report | Special Focus Doc |
| --- | --- | --- | --- | --- | --- | --- | --- | --- | --- | --- | --- | --- | --- | --- | --- | --- | --- | --- | --- | --- | --- | --- | --- | --- | --- | --- | --- | --- | --- |
| 3672 | 1002.3 | **GERAN part: Multi-Standard Radio BS RF requirements for non-contiguous spectrum deployments** |  | 324d? | 2010-09-03 A | 2011-11-25 A | 100% |  | 2010-09-03 | 2011-11-25 | 324d? |  |  | G1 | 5160h | 5160h | MSR_NC-GERAN | 25 | Ericsson | mats.y.samuelsson@ericsson.com | Rel-10 | 47 | Paolo | MSR_NC-GERAN |  |  |  |  |  |
| 3673 | 1002.3.1 | GERAN Core part: Multi-Standard Radio BS RF requirements for non-contiguous spectrum deployments |  | 261d? | 2010-09-03 A | 2011-09-02 A | 100% |  | 2010-09-03 | 2011-09-02 | 261d? |  | finish no earlier than 2011-09-02 | G1 | 2088h | 2088h | MSR_NC-GERAN | 25 | Ericsson | mats.y.samuelsson@ericsson.com | Rel-10 | 47 | Paolo |  | 45.005 |  |  |  |  |
| 3674 | 1002.3.2 | GERAN BS Test part: Multi-Standard Radio BS RF requirements for non-contiguous spectrum deployments |  | 62d? | 2011-09-02 A | 2011-11-25 A | 100% |  | 2011-09-02 | 2011-11-25 | 62d? |  | finish no earlier than 2011-11-25 | G1 | 496h | 496h | MSR_NC-GERAN | 28 | Ericsson | mats.y.samuelsson@ericsson.com | Rel-10 | 52 | Paolo |  | 51.021 |  |  |  |  |
| 3675 | 1003 | (Small) Technical Enhancements and Improvements for Rel-10 |  | 470d? | 2009-06-04 A | 2011-03-23 A | 100% |  | 2009-06-04 | 2011-03-23 | 470d? |  | finish no earlier than 2011-03-23 | SP; CP; RP; GP | 15040h | 15040h | TEI10 | 23 |  |  | Rel-10 | 44 |  | TEI10 |  |  |  |  |  |
| 3676 | 1004 | (IETF) (Small) Technical Enhancements and Improvements for Rel-10 (draft-atarius) |  | 1244d? | 2009-06-04 A | 2014-12-09 | 75% | 312.5d? | 2009-06-04 | 2014-12-05 | 1242d? | 1440d | finish no earlier than 2014-12-09 | C1-IETF | 9952h | 7452h | TEI10_IETF | 27 | Andrew Allen | Andrew Allen | Rel-10 | 52 | Frederic | TEI10_IETF | draft-atarius-dispatch-meid-urn |  |  |  |  |
| 3677 | 1005 | (IETF) (Small) Technical Enhancements and Improvements for Rel-10 (RFC6275) |  | 562d? | 2009-06-04 A | 2011-07-29 A | 100% |  | 2009-06-04 | 2011-07-29 | 562d? |  | finish no earlier than 2011-07-29 | C1-IETF | 4496h | 4496h | TEI10_IETF1 | 27 |  |  | Rel-10 | 53 | Frederic | TEI10_IETF1 | RFC 6275 (was draft-ietf-mext-rfc3775bis) |  |  |  |  |
| 3678 | 1006 | Test - (Small) Technical Enhancements and Improvements for Rel-10 |  | 271d? | 2011-12-01 A | 2012-12-07 A | 100% |  | 2011-12-01 | 2012-12-07 | 271d? |  | finish no earlier than 2012-12-07 | R5; G3new | 4336h | 4336h | TEI10_Test | 28 | n/a |  | Rel-10 | 54 | Ingbert | TEI10_Test |  |  |  |  |  |
| 3679 | 1007 | **Deleted - Registration in Densely-populated area (RED)** |  | 665d? | 2007-03-12 A | 2009-09-24 A | 100% |  | 2007-03-12 | 2009-09-24 | 665d? |  |  | S1 | 9544h | 9544h | RED |  | NTT DoCoMo | tanakai@nttdocomo.co.jp | Rel-10 | 35 | Alain | RED |  | PCG-24 | SP-46 |  |  |
| 3680 | 1007.1 | Deleted - Stage 1 for RED |  | 4d? | 2007-03-12 A | 2007-03-15 A | 100% |  | 2007-03-12 | 2007-03-15 | 4d? |  | start no earlier than 2007-03-12 | S1 | 32h | 32h | RED |  | NTT DoCoMo | takakurat@s1.nttdocomo.co.jp | Rel-10 | 35 | Alain |  | 22.101 CR#0207 | PCG-24 | SP-46 |  |  |
| 3681 | 1007.2 | Deleted - Stage 2 for RED |  | 524d? | 2007-09-25 A | 2009-09-24 A | 100% |  | 2007-09-25 | 2009-09-24 | 524d? |  | finish no earlier than 2009-09-24 | S2 | 4192h | 4192h | RED |  | NTT DoCoMo | tanakai@nttdocomo.co.jp | Rel-10 | 37 | Maurice |  | draft TR 23.880 withdrawn, 23.002, 23.060, 23.221, 23.236 | PCG-23 | SP-45 |  |  |
| 3682 | 1008 | **Deleted - Network Selection for non-3GPP Access** |  | 471d? | 2007-12-07 A | 2009-09-24 A | 100% |  | 2007-12-07 | 2009-09-24 | 471d? |  |  | S1; C6 | 15072h | 15072h | N3GtoNSP | 21 | Telefónica O2 | chris.friel@O2.com | Rel-10 | 38 | Alain | N3GtoNSP |  | PCG-23 | SP-45 |  |  |
| 3683 | 1008.1 | Deleted - Stage 1 for N3GtoNSP |  | 471d? | 2007-12-07 A | 2009-09-24 A | 100% |  | 2007-12-07 | 2009-09-24 | 471d? |  | finish no earlier than 2009-12-10 | S1 | 3768h | 3768h | N3GtoNSP | 21 | Telefónica O2 | chris.friel@O2.com | Rel-10 | 38 | Alain |  | 22.011 | PCG-23 | SP-45 |  |  |
| 3684 | 1008.2 | Deleted - CT6 issues for N3GtoNSP |  | 471d? | 2007-12-07 A | 2009-09-24 A | 100% |  | 2007-12-07 | 2009-09-24 | 471d? |  | finish no earlier than 2009-12-04 | C6 | 3768h | 3768h | N3GtoNSP | 21 | Telefónica O2 | chris.friel@O2.com | Rel-10 | 38 | Xavier |  | 36.300 | PCG-23 | CP-45 |  |  |
| 3685 | 1009 | **Deleted - GTP-based S8 chaining** |  | 337d? | 2008-12-11 A | 2010-03-25 A | 100% |  | 2008-12-11 | 2010-03-25 | 337d? |  |  | S2 | 5392h | 5392h | GTPchaining | 22 | Huawei | Haining Wang (wanghaining@huawei.com) | Rel-10 | 42 | Maurice | GTPchaining |  | PCG-24 | SP-47 |  |  |
| 3686 | 1009.1 | Deleted - Stage 2 for GTPchaining |  | 337d? | 2008-12-11 A | 2010-03-25 A | 100% |  | 2008-12-11 | 2010-03-25 | 337d? |  | finish no earlier than 2010-03-25 | S2 | 2696h | 2696h | GTPchaining | 22 | Huawei | Haining Wang (wanghaining@huawei.com) | Rel-10 | 42 | Maurice |  | 23.402 | PCG-24 | SP-47 |  |  |
| 3687 | 1010 | Deleted - UTRAN 2 ms TTI uplink range improvement |  | 272d? | 2009-03-06 A | 2010-03-19 A | 100% |  | 2009-03-06 | 2010-03-19 | 272d? |  | finish no earlier than 2010-03-19 | R1; R2; R3; R4 | 8704h | 8704h | RANimp-2mTTI_ULimp | 22 | Nokia Siemens Networks | Karri Ranta-aho (karri.ranta-aho@nsn.com) | Rel-10 | 43 | Patrick | RANimp-2mTTI_ULimp | 25.133, 25.212, 25.214, 25.321, 25.331 | PCG-24 | RP-47 | RP-100040 |  |
| 3688 | 1011 | Deleted - Enhanced Home NodeB / eNodeB continuation of Rel-9 |  | 337d? | 2008-12-11 A | 2010-03-25 A | 100% |  | 2008-12-11 | 2010-03-25 | 337d? |  |  | S2 | 2696h | 2696h | eEHNB | 23 | Alcatel-Lucent | Nicolas Drevon | Rel-10 | 44 | Maurice | eEHNB |  | PCG-24 | SP-47 |  | HNB |
| 3689 | 1012 | **Deleted - Fixed Wireless Customer-Premises Equipment (CPE) RF Requirements** |  | 391d? | 2009-12-04 A | 2011-06-03 A | 100% |  | 2009-12-04 | 2011-06-03 | 391d? |  |  | R4; R5 | 12512h | 12512h | FW_CPE_RF | 24 | Verizon Wireless | zheng.zhao@verizonwireless.com | Rel-10 | 46 | Issam | FW_CPE_RF | LTE | PCG-27 | RP-52 |  |  |
| 3690 | 1012.1 | Deleted - Core part: Fixed Wireless Customer-Premises Equipment (CPE) RF Requirements |  | 391d? | 2009-12-04 A | 2011-06-03 A | 100% |  | 2009-12-04 | 2011-06-03 | 391d? |  | finish no earlier than 2011-06-03 | R4 | 3128h | 3128h | FW_CPE_RF-Core | 24 | Verizon Wireless | zheng.zhao@verizonwireless.com | Rel-10 | 46 | Issam | FW_CPE_RF-Core | 36.101 | PCG-27 | RP-52 | RP-110539 |  |
| 3691 | 1012.2 | Deleted - Test part: Fixed Wireless Customer-Premises Equipment (CPE) RF Requirements |  | 391d? | 2009-12-04 A | 2011-06-03 A | 100% |  | 2009-12-04 | 2011-06-03 | 391d? |  | finish no earlier than 2011-06-03 | R5 | 3128h | 3128h | FW_CPE_RF-UEConTest | 24 | Verizon Wireless | zheng.zhao@verizonwireless.com | Rel-10 | 46 | Ingbert | FW_CPE_RF-UEConTest | 36.521-1 | PCG-27 | RP-52 | RP-110504 |  |
| 3692 | 1013 | **Deleted - Latency reductions for LTE** |  | 266d? | 2009-12-04 A | 2010-12-10 A | 100% |  | 2009-12-04 | 2010-12-10 | 266d? |  |  | R2; R1 | 8512h | 8512h | LTE_LATRED | 24 | Ericsson | henrik.enbuske@ericsson.com | Rel-10 | 46 | Yong-Jun | LTE_LATRED | LTE | PCG-26 | RP-50 |  |  |
| 3693 | 1013.1 | Deleted - Core part: Latency reductions for LTE |  | 266d? | 2009-12-04 A | 2010-12-10 A | 100% |  | 2009-12-04 | 2010-12-10 | 266d? |  | finish no earlier than 2010-12-10 | R2; R1 | 4256h | 4256h | LTE_LATRED-Core | 24 | Ericsson | henrik.enbuske@ericsson.com | Rel-10 | 46 | Yong-Jun | LTE_LATRED-Core | 36.213, 36.300, 36.306, 36.321, 36.331 | PCG-26 | RP-50 | RP-101112 |  |
| 3694 | 1014 | **Deleted - Enhanced Interference Management for Home NodeBs** |  | 131d? | 2010-03-19 A | 2010-09-17 A | 100% |  | 2010-03-19 | 2010-09-17 | 131d? |  |  | R3 | 2096h | 2096h | HNB_IM | 24 | Qualcomm | Andrei Radulescu (aradules@qualcomm.com) | Rel-10 | 47 | Juha | HNB_IM | UTRA | PCG-25 | RP-49 | RP-100754 | HNB |
| 3695 | 1014.1 | Deleted - Core part: Enhanced Interference Management for Home NodeBs |  | 131d? | 2010-03-19 A | 2010-09-17 A | 100% |  | 2010-03-19 | 2010-09-17 | 131d? |  | finish no earlier than 2010-09-17 | R3 | 1048h | 1048h | HNB_IM-Core | 24 | Qualcomm | Andrei Radulescu (aradules@qualcomm.com) | Rel-10 | 47 | Juha | HNB_IM-Core | 25.413, 25.467, 25.469 | PCG-25 | RP-49 | RP-100754 | HNB |
| 3696 | 1015 | Release 10 Studies | milestone | 0d? | 2009-03-12 A | 2009-03-12 A | 100% |  | 2009-03-12 | 2011-03-23 | 531d? |  | finish no earlier than 2011-03-23 | CP; GP; RP; SP |  |  |  |  |  |  | Rel-10 |  |  |  |  |  |  |  |  |

Notes:
- 3672: -
- 3673: GP#51 completed. GP#47 approved WID
- 3674: GP#52 completed
- 3675: -
- 3676: Not completed internet-draft, waiting for draft-montemurro to complete
- 3677: SP#53/IETF#81: RFC 6275 completed
- 3678: -
- 3679: SP#35 Stage 1 completed. SP#45 Stage 2 work stopped. SP#46 work stopped/abandoned
- 3680: SP#35 completed. SP#46 work stopped/abandoned
- 3681: SP#45 Stage 2 work stopped
- 3682: SP#45 work stopped/abandoned
- 3683: SP#45 work stopped/abandoned
- 3684: SP#45 work stopped/abandoned
- 3685: SP#47 work stopped (depending on ongoing related CT4 work). Stage 1 in UID_320022 Rel-8 Requirements for evolution of the 3GPP system architecture (AIPN-SAE): 22.278, 22.011, 22.246
- 3686: SP#47 work stopped
- 3687: RP#47 work stopped/abandoned (no CR approved). Cell sets the TTI (Transmission Time Interval) to 2 ms
- 3688: SP#47 deleted (SA2 work moved under SA1 UID_450053). SP#44 Umbrella Feature created to host WIs moved out of Rel-9 (SA2 UID_420034 on IMS aspects of Architecture for Home NodeB)
- 3689: RP#52 work stopped (lack of contributions). Add new power classES in CP-150E-UTRAN UL to allow CPE type applications to be operated at higher max output power
- 3690: RP#52 work stopped at 55% (lack of contributions)
- 3691: RP#52 work stopped (lack of contributions)
- 3692: RP#50 work stopped (RP-101266)
- 3693: RP#50 work stopped (RP-101266)
- 3694: RP#49 stopped (no further standardization needed). Ensure that Enhanced Interference Management methods identified in Rel-9 for HNBs do not fail in deployments with a large penetration of CSG-aware UEs
- 3695: RP#49 stopped (no further standardization needed)
- 3696: -

| ID | WBS | Task | Type | Duration | Start | Finish | Complete | Baseline start | Baseline finish | Baseline duration | Constraint | Resources | Work | Actual work | Acronym | Impacted TSs and TRs | WI rapporteur name | Release | TSG approved | MCC resp | Acronym_3GU_Export | PCG approved | Status Report | PCG stopped | TSG stopped |
| --- | --- | --- | --- | --- | --- | --- | --- | --- | --- | --- | --- | --- | --- | --- | --- | --- | --- | --- | --- | --- | --- | --- | --- | --- | --- |
| 3697 | 1016 | **Study on enhanced voice service requirements for the Evolved Packet System (EPS)** |  | 670d? | 2007-09-03 A | 2010-03-25 A | 100% | 2007-09-03 | 2010-03-25 | 670d? |  | S1; S4 | 18744h | 18744h | FS_EV_EPS | 22.813 | France Telecom | Rel-10 | 37 | Alain | FS_EV_EPS |  |  |  |  |
| 3698 | 1016.1 | Use cases definition and service and system requirements |  | 334d? | 2007-09-03 A | 2008-12-11 A | 100% | 2007-09-03 | 2008-12-11 | 334d? | finish no earlier than 2008-12-11 | S1 | 2672h | 2672h | FS_EV_EPS-S1 | 22.813 | France Telecom | Rel-10 | 37 | Alain | FS_EV_EPS-S1 |  |  |  |  |
| 3699 | 1016.2 | Codec specific part of FS_EV_EPS |  | 669d? | 2007-09-03 A | 2010-03-25 A | 100% | 2007-09-03 | 2010-03-25 | 669d? | finish no earlier than 2010-03-25 | S4 | 5352h | 5352h | FS_EV_EPS-S4 | 22.813 | Ericsson | Rel-10 | 37 | Paolo | FS_EV_EPS-S4 |  |  |  |  |
| 3700 | 1017 | Study on advanced requirements for IP interconnect |  | 528d? | 2007-12-04 A | 2009-12-10 A | 100% | 2007-12-04 | 2009-12-10 | 528d? | finish no earlier than 2009-12-10 | S1 | 4224h | 4224h | FS_IPXS | 22.893 | Telefónica O2 | Rel-10 | 38 | Alain | FS_IPXS | 21 |  |  |  |
| 3701 | 1018 | Study on Personal Broadcast Service |  | 397d? | 2008-09-18 A | 2010-03-25 A | 100% | 2008-09-18 | 2010-03-25 | 397d? | finish no earlier than 2010-03-25 | S1 | 3168h | 3168h | FS_PBS | 22.947 | ETRI | Rel-10 | 41 | Alain | FS_PBS | 21 |  |  |  |
| 3702 | 1019 | Study on LCS support in SAE for non-3GPP accesses |  | 397d? | 2008-09-18 A | 2010-03-25 A | 100% | 2008-09-18 | 2010-03-25 | 397d? | finish no earlier than 2010-03-25 | S1 | 3168h | 3168h | FS_LCS_n3GPP | 22.814 | SK Telecom | Rel-10 | 41 | Alain | FS_LCS_n3GPP | 21 |  |  |  |
| 3703 | 1020 | Study on Haptic Services |  | 272d? | 2009-03-12 A | 2010-03-25 A | 100% | 2009-03-12 | 2010-03-25 | 272d? | finish no earlier than 2010-03-25 | S1 | 2168h | 2168h | FS_Haptics | 22.987 | SK Telecom | Rel-10 | 43 | Alain | FS_Haptics | 22 |  |  |  |
| 3704 | 1021 | Study on System enhancements for the use of IMS services in Local BreakOut and Optimal Routing of Media |  | 575d? | 2007-10-01 A | 2009-12-10 A | 100% | 2007-10-01 | 2009-12-10 | 575d? | finish no earlier than 2009-12-10 | S2 | 4600h | 4600h | FS_IMS_LBO_ORM | 23.894 | Telecom Italia, BT | Rel-10 | 37 | Maurice | FS_IMS_LBO_ORM |  |  |  |  |
| 3705 | 1022 | Study on Intra Domain Connection of RAN Nodes to Multiple CN Nodes |  | 533d? | 2008-03-12 A | 2010-03-25 A | 100% | 2008-03-12 | 2010-03-25 | 533d? | finish no earlier than 2010-03-25 | S2 | 4264h | 4264h | FS_IDC | 23.924 (was 23.823) | China Mobile | Rel-10 | 39 | Maurice | FS_IDC | 21 |  |  |  |
| 3706 | 1023 | Study on Single Radio Voice Call Continuity enhancements |  | 341d? | 2009-06-04 A | 2010-09-23 A | 100% | 2009-06-04 | 2010-09-23 | 341d? | finish no earlier than 2010-09-23 | S2 | 2728h | 2728h | FS_eSRVCC | 23.856 | China Mobile | Rel-10 | 44 | Maurice | FS_eSRVCC | 23 |  |  |  |
| 3707 | 1024 | Study on Single Radio Video Call Continuity for 3G-CS |  | 131d? | 2010-03-25 A | 2010-09-23 A | 100% | 2010-03-25 | 2010-09-23 | 131d? | finish no earlier than 2010-09-23 | S2 | 1048h | 1048h | FS_vSRVCC | 23.886 | Samsung | Rel-10 | 47 | Maurice | FS_vSRVCC | 24 |  |  |  |
| 3708 | 1025 | Study on S2b Mobility based on GTP |  | 56d? | 2010-03-25 A | 2010-06-10 A | 100% | 2010-03-25 | 2010-06-10 | 56d? | finish no earlier than 2010-06-07 | S2 | 448h | 448h | FS_SMOG | 23.834 | Alcatel-Lucent | Rel-10 | 47 | Maurice | FS_SMOG | 24 |  |  |  |
| 3709 | 1026 | Study on Surround Sound codec extension for PSS and MBMS |  | 530d? | 2009-03-12 A | 2011-03-23 A | 100% | 2009-03-12 | 2011-03-23 | 530d? | finish no earlier than 2011-03-23 | S4 | 4240h | 4240h | FS_SS_PSS_MBMS | 26.950 | Fraunhofer Gesellschaft | Rel-10 | 43 | Paolo | FS_SS_PSS_MBMS | 22 |  |  |  |
| 3710 | 1027 | Study on Improved Video Coding Support |  | 205d? | 2010-06-10 A | 2011-03-23 A | 100% | 2010-06-10 | 2011-03-23 | 205d? | finish no earlier than 2011-03-23 | S4 | 1640h | 1640h | FS_IVCS | 26.904 | Nokia, ETRI | Rel-10 | 48 | Paolo | FS_IVCS | 25 |  |  |  |
| 3711 | 1028 | Study on Rc Reference Point Functionalities and Message Flows |  | 397d? | 2008-09-18 A | 2010-03-25 A | 100% | 2008-09-18 | 2010-03-25 | 397d? | finish no earlier than 2010-03-23 | S5 | 3170.08h | 3170.08h | FS_OAM_Rc | 32.825 | Huawei | Rel-10 | 41 | Mirko | FS_OAM_Rc | 21 |  |  |  |
| 3712 | 1029 | Study on Telecommunication Management; Energy Savings Management |  | 271d? | 2009-03-12 A | 2010-03-25 A | 100% | 2009-03-12 | 2010-03-25 | 271d? | finish no earlier than 2010-03-25 | S5 | 2168h | 2168h | FS_OAM_ESM | 32.826 | Orange, Vodafone | Rel-10 | 43 | Mirko | FS_OAM_ESM | 22 |  |  |  |
| 3713 | 1030 | Study on Integration of Device Management Information with Itf-N |  | 211d? | 2009-06-04 A | 2010-03-25 A | 100% | 2009-06-04 | 2010-03-25 | 211d? | finish no earlier than 2010-03-25 | S5 | 1688h | 1688h | FS_IDMI_Itf-N | 32.827 | Motorola | Rel-10 | 44 | Mirko | FS_IDMI_Itf-N | 23 |  |  |  |
| 3714 | 1031 | Study on Alignment of 3GPP Generic NRM IRP and TMF Shared Information Data (SID) model |  | 335d? | 2009-12-10 A | 2011-03-23 A | 100% | 2009-12-10 | 2011-03-23 | 335d? | finish no earlier than 2011-03-23 | S5 | 2680h | 2680h | FS_3GNRM_TMFSID | 32.828 | Nokia Siemens Networks | Rel-10 | 46 | Mirko | FS_3GNRM_TMFSID | 24 |  |  |  |
| 3715 | 1032 | Study on Harmonization of 3GPP Alarm IRP and TMF Interface Program (TIP) Fault Management |  | 335d? | 2009-12-10 A | 2011-03-23 A | 100% | 2009-12-10 | 2011-03-23 | 335d? | finish no earlier than 2011-03-23 | S5 | 2680h | 2680h | FS_3G_TMF_FM | 32.829 | Nokia Siemens Networks, Alcatel-Lucent | Rel-10 | 46 | Mirko | FS_3G_TMF_FM | 24 |  |  |  |
| 3716 | 1033 | Study on Alarm Correlation and Alarm Root Cause Analysis |  | 205d? | 2010-06-10 A | 2011-03-23 A | 100% | 2010-06-10 | 2011-03-23 | 205d? | finish no earlier than 2011-03-23 | S5 | 1640h | 1640h | FS_AC_ARCA | 32.832 | Ericsson | Rel-10 | 48 | Mirko | FS_AC_ARCA | 25 |  |  |  |
| 3717 | 1034 | Study on Alignment of 3GPP PM IRP and TMF Interface Program (TIP) PM |  | 205d? | 2010-06-10 A | 2011-03-23 A | 100% | 2010-06-10 | 2011-03-23 | 205d? | finish no earlier than 2011-03-23 | S5 | 1640h | 1640h | FS_3G_TMF_PM | 32.831 | Alcatel-Lucent | Rel-10 | 48 | Mirko | FS_3G_TMF_PM | 25 |  |  |  |
| 3718 | 1035 | Study on Policy and Charging Rules Function (PCRF) failure and restoration |  | 261d? | 2009-08-18 A | 2010-09-17 A | 100% | 2009-08-18 | 2010-09-17 | 261d? | finish no earlier than 2010-09-17 | C3 | 2088h | 2088h | FS_PCRF-FR | 29.816 | NEC | Rel-10 | 45 | Adrian | FS_PCRF-FR | 23 |  |  |  |
| 3719 | 1036 | Study on User Data Convergence (UDC) evolution |  | 206d? | 2010-06-04 A | 2011-03-18 A | 100% | 2010-06-04 | 2011-03-18 | 206d? | finish no earlier than 2011-03-18 | C4 | 1648h | 1648h | FS_UDCe | 23.845 | Alcatel-Lucent | Rel-10 | 48 | Kimmo | FS_UDCe | 25 |  |  |  |
| 3720 | 1037 | Study on UICC access to IMS |  | 206d? | 2010-06-04 A | 2011-03-18 A | 100% | 2010-06-04 | 2011-03-18 | 206d? | finish no earlier than 2011-03-18 | C6 | 1648h | 1648h | FS_IMS-UICC | 31.828 | Gemalto | Rel-10 | 48 | Xavier | FS_IMS-UICC | 25 |  |  |  |
| 3721 | 1038 | Study on Uplink Tx Diversity for HSPA |  | 208.4d? | 2009-08-18 A | 2010-06-04 A | 100% | 2009-08-18 | 2010-06-04 | 208.4d? | finish no earlier than 2010-06-04 | R4 | 1667.2h | 1667.2h | FS_UL-TxDiv-HSPA | UTRA 25.863 | Qualcomm | Rel-10 | 45 | Issam | FS_UL-TxDiv-HSPA | 23 | RP-100499 |  |  |
| 3722 | 1039 | Study on Solutions for Energy Saving within UTRA Node B |  | 206d? | 2009-12-04 A | 2010-09-17 A | 100% | 2009-12-04 | 2010-09-17 | 206d? | finish no earlier than 2010-09-17 | R1; R3 | 3296h | 3296h | FS_Energy_UMTS | UTRA 25.927 | Vodafone | Rel-10 | 46 | Patrick | FS_Energy_UMTS | 24 | RP-100796 |  |  |
| 3723 | 1040 | Study on Potential solutions for energy saving for E-UTRAN |  | 348.75d? | 2010-02-02 A | 2011-06-03 A | 100% | 2010-02-02 | 2011-06-03 | 348.75d? | finish no earlier than 2011-06-03 | R3; R2 | 5580h | 5580h | FS_Energy_LTE | LTE 36.927 | China Mobile | Rel-10 | 47 | Juha | FS_Energy_LTE | 24 | RP-110597 |  |  |
| 3724 | 1041 | Study on Improvements of distributed antenna for 1.28Mcps TDD |  | 200.55d? | 2010-03-05 A | 2010-12-10 A | 100% | 2010-03-05 | 2010-12-10 | 200.55d? | finish no earlier than 2010-12-10 | R1; R2; R3 | 4813.2h | 4813.2h | FS_distr_ant_LCR_TDD | UTRA 25.865 | ZTE | Rel-10 | 47 | Patrick | FS_distr_ant_LCR_TDD | 24 | RP-101287 |  |  |
| 3725 | 1042 | Deleted - Study on Unauthenticated PS Emergency Calls |  | 471d? | 2008-06-05 A | 2010-03-25 A | 100% | 2008-06-05 | 2010-03-25 | 471d? | finish no earlier than 2010-03-25 | S1 | 3768h | 3768h | FS_UAPSEC | 22.984 | Nokia Siemens Networks | Rel-10 | 40 | Alain | FS_UAPSEC | 21 |  | PCG-24 | SP-47 |
| 3726 | 1043 | Deleted - Study on enhancements to IMS border functions for IMS Interconnection of services |  | 586d? | 2008-09-18 A | 2010-12-15 A | 100% | 2008-09-18 | 2010-12-15 | 586d? | finish no earlier than 2010-12-15 | S2 | 4688h | 4688h | FS_eIMS_IBCF | 23.848 | Starent Networks | Rel-10 | 41 | Maurice | FS_eIMS_IBCF | 21 |  | PCG-26 | SP-50 |
| 3727 | 1044 | Deleted - Study on EPC Charging enhancement |  | 211d? | 2009-06-04 A | 2010-03-25 A | 100% | 2009-06-04 | 2010-03-25 | 211d? | finish no earlier than 2010-03-25 | S5 | 1688h | 1688h | FS_EPCcharg |  | Nokia Siemens Networks | Rel-10 | 44 | Mirko | FS_EPCcharg | 23 |  | PCG-24 | SP-47 |
| 3728 | 1045 | Deleted - Study on Interworking Proxy between GTP based and PMIP based interfaces |  | 186d? | 2009-09-18 A | 2010-06-04 A | 100% | 2009-09-18 | 2010-06-04 | 186d? | finish no earlier than 2010-06-04 | C4 | 1488h | 1488h | FS_GTP-MIP-IW | 29.875 | NTT DoCoMo | Rel-10 | 45 | Kimmo | FS_GTP-MIP-IW | 23 |  | PCG-25 | CP-48 |
| 3729 | 1046 | Release 9 Features | milestone | 0d? | 2000-01-01 A | 2000-01-01 A | 100% | 2000-01-01 | 2000-01-01 | 0d? |  | CP; GP; RP; SP |  |  |  |  |  | Rel-9 |  |  |  |  |  |  |  |

Notes:
- 3697: SP#47 completed. TR 22.813-100 for Approval. Spin-off Feature UID_470030 Codec for Enhanced Voice Services / WI rapporteur e-mail: philippe.lottin@orange.com
- 3698: SP#47 completed. TR 22.813-100 for Approval / WI rapporteur e-mail: philippe.lottin@orange.com
- 3699: SP#47 completed. TR 22.813-100 for Approval / WI rapporteur e-mail: stefan.bruhn@ericson.com
- 3700: SP#46 completed. Linked to Rel-8 Feature UID_380060 IP Interconnection of Services (IPinterc). Spin-off Feature Rel-11 UID_470051 Advanced IP Interconnection of Services / WI rapporteur e-mail: chris.friel@O2.com
- 3701: SP#47 completed / WI rapporteur e-mail: Jaihyung Cho
- 3702: SP#47 completed / WI rapporteur e-mail: jinhan.song@sktelecom.com
- 3703: SP#47 completed. Covers Mobile/Fixed/Cordless/etc terminals. Haptic (human-machine tactile communication) extend service offering & richness of user experience beyond current visual & auditory senses / WI rapporteur e-mail: jinhan.song@sktelecom.com
- 3704: SP#46 completed. Spin-off Feature UID_460028 Optimal Media Routeing (OMR). Linked to Study on Multimedia Session Continuity UID_350051, Study on Centralized IMS Service Control UID_330012, IMS inter-operator service interconnection interface UID_360011 / WI rapporteur e-mail: mario.madella@telecomitalia.it, victor.kueh@bt.com
- 3705: SP#47 completed. Concluded no further normative work expected. Linked to 23.236 / WI rapporteur e-mail: LIU HONG (liuhongyfw@chinamobile.com)
- 3706: SP#49 completed (Conclusion: select the SIP anchoring based solution for normative work CR (TEI10) introducing and completing stage-2). Analyzed performance of Rel-8 SRVCC solution from E-UTRAN/HSPA to UTRAN/GERAN / WI rapporteur e-mail: Hou zhiqiang (houzhiqiang@chinamobile.com), Jiang Yi (jiangyi@chinamobile.com)
- 3707: SP#49 completed. TR 23.886v100 for Approval. Related to Rel-8 UID_350030 Single Radio Voice Call Continuity for 3GPP (SAES-SRVCC). Study how to provide Video Call seamless service continuity for 3G/LTE terminal user / WI rapporteur e-mail: Haris Zisimopoulos (haris.z@samsung.com)
- 3708: SP#48 completed. Triggered by Rel-8 UID_350027 SAE for support for non-3GPP accesses. Nature of relationship: S2b one of the interfaces defined for non-3GPP accesses support in EPS. Stage 1 in Rel-8 UID_320022 (AIPN-SAE) 22.278,22.101 / WI rapporteur e-mail: bruno.landais@alcatel-lucent.com
- 3709: SP#51 completed. Extend Rel-8 UID_34043 (Extending PSS and MBMS User Services for optimized Mobile TV) / WI rapporteur e-mail: jan.plogsties@iis.franhofer.de
- 3710: SP#51 completed. Extends Rel-9 Improved Video Support for PSS and MBMS (UID_430039) / WI rapporteur e-mail: imed.bouazizi@nokia.com, jaihyung@etri.re.kr
- 3711: SP#47 completed / WI rapporteur e-mail: shan.mingjun@huawei.com
- 3712: SP#47 completed. Study result might impact Feature UID_420011 Self Organising Networks (SON) / WI rapporteur e-mail: Jean-Michel Cornilly (Orange)
- 3713: SP#47 completed / WI rapporteur e-mail: Yizhi Yao (yzyao@motorola.com)
- 3714: SP#51 completed / WI rapporteur e-mail: olaf.pollakowski@nsn.com
- 3715: SP#51 completed / WI rapporteur e-mail: olaf.pollakowski@nsn.com, Padma.Sudarsan@alcatel-lucent.com
- 3716: SP#51 completed / WI rapporteur e-mail: edwin.tse@ericsson.com
- 3717: SP#51 completed / WI rapporteur e-mail: Padma.Sudarsan@alcatel-lucent.com
- 3718: CP#49 completed / WI rapporteur e-mail: gottfried.punz@nw.neclab.eu
- 3719: CP#51 completed. Study UDC evolution from FeaturES in CP-150Rel-9 UID_400034 and Rel-10 UID_480011 UDC Data Model / WI rapporteur e-mail: jean-jacques.trottin@alcatel-lucent.com
- 3720: CP#51 completed / WI rapporteur e-mail: Denis.Lheriteau@gemalto.com
- 3721: RP#48 completed / WI rapporteur e-mail: Heechoon Lee (heechoon@qualcomm.com)
- 3722: RP#49 completed. Based on ETSI EE TS 102 706. / WI rapporteur e-mail: Prakash.bhat@vodafone.com
- 3723: RP#52 completed / WI rapporteur e-mail: Yang Ning (yangning@chinamobile.com)
- 3724: RP#50 completed. TR 25.865 v101 for Approval / WI rapporteur e-mail: huang.he4@zte.com.cn
- 3725: SP#47 work stopped/abandoned / WI rapporteur e-mail: Juergen.Merkel@nsn.com
- 3726: SP#50 work stopped. Additional work may be addressed as part of the Rel-11 Feature UID_470051 Advanced IP Interconnection of Services (IPXS) / WI rapporteur e-mail: Rajat Ghai (rghai@starentnetworks.com)
- 3727: SP#47 work stopped. Issue covered by Rel-10 UID_460039 Charging for LIPA_SIPTO and UID_4700xy Charging for IFOM / WI rapporteur e-mail: Gerald.Goermer@nsn.com
- 3728: CP#48 work stopped/abandoned / WI rapporteur e-mail: takaaki.matsuura.sp@s1.nttdocomo.com
- 3729: -

| ID | WBS | Task | Duration | Start | Finish | Complete | Baseline start | Baseline finish | Baseline duration | Constraint | Resources | Work | Actual work | Acronym | PCG approved | WI rapporteur name | WI rapporteur e-mail | Release | TSG approved | MCC resp | Special Focus Doc | Acronym_3GU_Export | Status Report |
| --- | --- | --- | --- | --- | --- | --- | --- | --- | --- | --- | --- | --- | --- | --- | --- | --- | --- | --- | --- | --- | --- | --- | --- |
| 3730 | 1047 | **Enhanced Home NodeB / eNodeB** | 921d? | 2008-06-05 A | 2011-12-09 A | 100% | 2008-06-05 | 2011-12-09 | 921d? |  | S1; S2; S3; S5; C1; C6; R2; R3; R4; R5; GP | 113136h | 113136h | EHNB | 21 | T-Mobile | michael.kurz@t-mobile.at | Rel-9 | 40 | Alain | HNB | EHNB |  |
| 3731 | 1047.1 | Stage 1 for EHNB | 261d? | 2008-06-05 A | 2009-06-04 A | 100% | 2008-06-05 | 2009-06-04 | 261d? | finish no earlier than 2009-06-04 | S1 | 2088h | 2088h | EHNB | 21 | T-Mobile | michael.kurz@t-mobile.at | Rel-9 | 40 | Alain | HNB |  |  |
| 3732 | 1047.2 | Architecture aspects of EHNB | 266d? | 2008-09-18 A | 2009-09-24 A | 100% | 2008-09-18 | 2009-09-24 | 266d? | finish no earlier than 2009-09-22 | S2 | 2128h | 2128h | EHNB | 21 | T-Mobile | sebastian.speicher@telekom.de | Rel-9 | 41 | Maurice | HNB |  |  |
| 3733 | 1047.3 | Security aspects of Enhanced Home NodeB / eNodeB | 262d? | 2008-12-11 A | 2009-12-10 A | 100% | 2008-12-11 | 2009-12-10 | 262d? | finish no earlier than 2009-12-10 | S3 | 2096h | 2096h | EHNB-Sec | 22 | Huawei | Marcus Wong (mwong@huawei.com) | Rel-9 | 42 | Mirko | HNB | EHNB-Sec |  |
| 3734 | 1047.4 | CT1 aspects - Support of Home NB and Home eNB enhancements | 321d? | 2009-09-18 A | 2010-12-10 A | 100% | 2009-09-18 | 2010-12-10 | 321d? | finish no earlier than 2010-12-10 | C1 | 2568h | 2568h | EHNB-CT1 | 23 | Qualcomm | Ramachandran Subramanian (rsubrama@qualcomm.com) | Rel-9 | 45 | Frederic | HNB | EHNB-CT1 |  |
| 3735 | 1047.5 | CT6 aspects - Support of Home NB and Home eNB enhancements | 131d? | 2009-09-18 A | 2010-03-19 A | 100% | 2009-09-18 | 2010-03-19 | 131d? | finish no earlier than 2010-03-19 | C6 | 1048h | 1048h | EHNB-CT6 | 23 | Qualcomm | Ramachandran Subramanian (rsubrama@qualcomm.com) | Rel-9 | 45 | Xavier | HNB | EHNB-CT6 |  |
| 3736 | 1047.6 | 3G HNB Gateway and LTE HeNB Gateway OAM&P | 336d? | 2008-12-11 A | 2010-03-25 A | 100% | 2008-12-11 | 2010-03-25 | 336d? | finish no earlier than 2010-03-25 | S5 | 2688h | 2688h | HNB-OAM_GW | 22 | China Mobile | GangChen (chengang@chinamobile.com) | Rel-9 | 42 | Mirko | HNB | HNB-OAM_GW |  |
| 3737 | 1047.7 | 3G HNB and LTE HeNB OAM&P Type 1 Interface | 272d? | 2009-03-12 A | 2010-03-25 A | 100% | 2009-03-12 | 2010-03-25 | 272d? | finish no earlier than 2010-03-25 | S5 | 2168h | 2168h | HNB_eHNB-OAM_Type1 | 22 | Huawei | Zou Lan (zlan@huawei.com) | Rel-9 | 43 | Mirko | HNB | HNB_eHNB-OAM_Type1 |  |
| 3738 | 1047.8 | 3G HNB and LTE HeNB OAM&P Type 2 Interface | 225d? | 2009-05-15 A | 2010-03-25 A | 100% | 2009-05-15 | 2010-03-25 | 225d? | finish no earlier than 2010-03-25 | S5 | 1800h | 1800h | HNB_eHNB-OAM_Type2 | 23 | Ericsson | edwin.tse@ericsson.com | Rel-9 | 44 | Mirko | HNB | HNB_eHNB-OAM_Type2 |  |
| 3739 | 1047.9 | LTE FDD Home eNodeB RF Requirements | 336d? | 2008-12-05 A | 2010-03-19 A | 100% | 2008-12-05 | 2010-03-19 | 336d? | finish no earlier than 2010-03-19 | R4 | 2688h | 2688h | HeNB-RF_FDD | 22 | Motorola | Ying Cai (yingcai@motorola.com) | Rel-9 | 42 | Issam | HNB | HeNB-RF_FDD | RP-100035 |
| 3740 | 1047.10 | LTE TDD Home eNodeB RF Requirements | 271d? | 2009-03-06 A | 2010-03-19 A | 100% | 2009-03-06 | 2010-03-19 | 271d? | finish no earlier than 2010-03-19 | R4 | 2168h | 2168h | HeNB-RF_TDD | 22 | China Mobile | Nan Li (linan@chinamobile.com) | Rel-9 | 43 | Issam | HNB | HeNB-RF_TDD | RP-100036 |
| 3741 | 1047.11 | Home NB and Home eNB enhancements - RAN3 aspects | 197d? | 2009-03-06 A | 2009-12-04 A | 100% | 2009-03-06 | 2009-12-04 | 197d? | finish no earlier than 2009-12-04 | R3 | 1576h | 1576h | EHNB-RAN3 | 22 | Alcatel-Lucent | Martin Warner (mw15@alcatel-lucent.com) | Rel-9 | 43 | Juha | HNB | EHNB-RAN3 | RP-091050 |
| 3742 | 1047.12 | Home NB and Home eNB enhancements - RAN2 aspects | 271d? | 2009-03-06 A | 2010-03-19 A | 100% | 2009-03-06 | 2010-03-19 | 271d? | finish no earlier than 2010-03-19 | R2 | 2168h | 2168h | EHNB-RAN2 | 22 | Huawei | Yang Xudong (yangxudong@huawei.com) | Rel-9 | 43 | Yong-Jun | HNB | EHNB-RAN2 | RP-100037 |
| 3743 | 1047.13 | Conformance Test Aspects – Home NB enhancements for FDD | 322d? | 2010-09-17 A | 2011-12-09 A | 100% | 2010-09-17 | 2011-12-09 | 322d? | finish no earlier than 2011-12-09 | R5 | 2568h | 2568h | EHNB-UTRA_FDD_UEConTest | 25 | Huawei | trica_li@huawei.com | Rel-9 | 49 | Ingbert | HNB | EHNB-UTRA_FDD_UEConTest | RP-111679 |
| 3744 | 1047.14 | Conformance Test Aspects – Home eNB enhancements | 201d? | 2010-12-10 A | 2011-09-16 A | 100% | 2010-12-10 | 2011-09-16 | 201d? | finish no earlier than 2011-09-16 | R5 | 1608h | 1608h | EHNB-LTE_UEConTest | 26 | Qualcomm | Mrs Lena Chaponniere (lchaponn@qualcomm.com) | Rel-9 | 50 | Ingbert | HNB | EHNB-LTE_UEConTest | RP-110972 |
| 3745 | 1047.15 | Home NB and Home eNB enhancements - GERAN aspects | 341d? | 2009-05-18 A | 2010-09-03 A | 100% | 2009-05-18 | 2010-09-03 | 341d? | finish no earlier than 2010-09-03 | GP | 2728h | 2728h | EHNB-GERAN | 23 | Nokia Siemens Networks | leonardo.provvedi@roke.co.uk | Rel-9 | 42 | Paolo | HNB | EHNB-GERAN |  |
| 3746 | 1048 | **Value-Added Services for Short Message Service** | 586d? | 2007-09-10 A | 2009-12-04 A | 100% | 2007-09-10 | 2009-12-04 | 586d? |  | S1; C4; C1 | 20264h | 20264h | VAS4SMS |  | China Mobile | Wu Bin (wubin@chinamobile.com) | Rel-9 | 37 | Alain |  | VAS4SMS |  |
| 3747 | 1048.1 | Stage 1 for VAS4SMS | 133d? | 2007-09-10 A | 2008-03-12 A | 100% | 2007-09-10 | 2008-03-12 | 133d? | finish no earlier than 2008-03-21 | S1 | 1064h | 1064h | VAS4SMS |  | China Mobile | Wu Bin (wubin@chinamobile.com) | Rel-9 | 37 | Alain |  |  |  |
| 3748 | 1048.2 | CT4 aspects of VAS4SMS Interface and Signalling Flow | 322d? | 2008-09-12 A | 2009-12-04 A | 100% | 2008-09-12 | 2009-12-04 | 322d? | finish no earlier than 2009-12-04 | C4 | 2568h | 2568h | VAS4SMS | 21 | China Mobile | Wu Bin (wubin@chinamobile.com) | Rel-9 | 41 | Kimmo |  |  |  |
| 3749 | 1048.3 | CT1 aspects of VAS4SMS Interface and Signalling Flow | 321d? | 2008-09-09 A | 2009-12-04 A | 100% | 2008-09-09 | 2009-12-04 | 321d? | finish no earlier than 2009-12-04 | C1 | 2568h | 2568h | VAS4SMS | 21 | China Mobile | Wu Bin (wubin@chinamobile.com) | Rel-9 | 41 | Frederic |  |  |  |
| 3750 | 1049 | **Definition of End-User Identity** | 334d? | 2007-09-03 A | 2008-12-11 A | 100% | 2007-09-03 | 2008-12-11 | 334d? |  | S1 | 5344h | 5344h | EUI |  | Nokia Siemens Networks | Juergen.Merkel@nsn.com | Rel-9 | 38 | Alain |  | EUI |  |
| 3751 | 1049.1 | Stage 1 for Definition of End-User Identity | 334d? | 2007-09-03 A | 2008-12-11 A | 100% | 2007-09-03 | 2008-12-11 | 334d? | finish no earlier than 2008-12-11 | S1 | 2672h | 2672h | EUI | 21 | Nokia Siemens Networks | Juergen.Merkel@nsn.com | Rel-9 | 38 | Alain |  |  |  |
| 3752 | 1050 | **Customized Ringing Signal** | 522d? | 2007-12-06 A | 2009-12-03 A | 100% | 2007-12-06 | 2009-12-03 | 522d? |  | S1; C1 | 11296h | 11296h | CRS | 21 | SK Telecom, China Mobile | Donghee Shim (SK Telecom), Jianping Zheng (China Mobile) | Rel-9 | 38 | Alain |  | CRS |  |
| 3753 | 1050.1 | Stage 1 for Customized Ringing Signal | 266d? | 2007-12-06 A | 2008-12-11 A | 100% | 2007-12-06 | 2008-12-11 | 266d? | finish no earlier than 2008-12-11 | S1 | 2128h | 2128h | CRS | 21 | SK Telecom, China Mobile | Donghee Shim (SK Telecom), Jianping Zheng (China Mobile) | Rel-9 | 38 | Alain |  |  |  |
| 3754 | 1050.2 | Stage 3 for IMS Customized Ringing Signal (CRS) Service | 136d? | 2009-05-29 A | 2009-12-03 A | 100% | 2009-05-29 | 2009-12-03 | 136d? | finish no earlier than 2010-06-04 | C1 | 816h | 816h | CRS | 23 | China Mobile | wangzhao | Rel-9 | 44 | Frederic |  |  |  |

Notes:
- 3730: RP#54 Testing completed / Impacted TSs and TRs: UTRA, LTE
- 3731: CP#49 the SA1-reqs are moving. CT1 will align when the work in SA1 is clear. (was SP#44 completed.) / Impacted TSs and TRs: 22.220, 22.011
- 3732: SP#45 completed / Impacted TSs and TRs: 23.401, 23.402, 23.060, New 23.830
- 3733: SP#46 completed / Impacted TSs and TRs: New 33.320
- 3734: CP#50 completed (Roaming aspects for manual CSG selection, Support of temporary users and CSG membership changes, Support of user controlled and operator controlled lists) / Impacted TSs and TRs: 23.122, 24.008, 24.285, 24.301
- 3735: CP#47 completed. Storing of CSG related data items on the USIM / Impacted TSs and TRs: 31.102
- 3736: SP#47 completed / Impacted TSs and TRs: 32.632, 32.633, 32.635, New (32.771, 32.772, 32.773, 32.775, 32.781, 32.782, 32.783, 32.785)
- 3737: SP#47 completed / Impacted TSs and TRs: 32.581, 32.582, 32.583, 32.584, New (32.591, 32.592, 32.593, 32.594)
- 3738: SP#47 completed / Impacted TSs and TRs: New (32.571, 32.572)
- 3739: RP#47 completed / Impacted TSs and TRs: 36.104, 36.141, New TR 36.921
- 3740: RP#47 completed / Impacted TSs and TRs: 36.104, 36.141, 36.300, 36.331, 36.413, New TR 36.922
- 3741: RP#46 completed (based on high priority items specified in RP-090995) / Impacted TSs and TRs: 25.413, 25.467, 25.467, 25.468, 25.469, 25.469, 36.401, 36.413, New 25.444
- 3742: RP#47 completed / Impacted TSs and TRs: 25.304, 25.331, 25.367, 36.300, 36.304, 36.331
- 3743: UTRA. RP#54 completed. Testing for UID_430026 Support of Home NB and Home eNB enhancements RAN2 aspects (25.304, 25.331, 25.367) / Impacted TSs and TRs: 34.108, 34.121-1, 34.121-2, 34.123-1, 34.123-2, 34.123-3
- 3744: RP#53 completed / Impacted TSs and TRs: 36.508, 36.523-1, 36.523-2, 36.523-3
- 3745: GP#47 completed. GP#42 WID approved / Impacted TSs and TRs: 43.055, 43.129, 44.018, 44.060, 45.008, 48.008, 48.018
- 3746: CP#46 completed
- 3747: SP#39 completed. SP#43 Feature moved to Rel-9 / Impacted TSs and TRs: new 22.142
- 3748: CP#46 completed / Impacted TSs and TRs: new 23.142
- 3749: CP#46 completed / Impacted TSs and TRs: 23.040
- 3750: SP#42 closed. Stage 1 work closed at 5% completion due to lack of input (added only the EUI definition in 21.905)
- 3751: SP#42 closed. Stage 1 work closed at 5% completion due to lack of input (added only the EUI definition in 21.905) / Impacted TSs and TRs: 21.905
- 3752: CP#48 completed
- 3753: SP#42 completed. / Impacted TSs and TRs: 22.173, new 22.183
- 3754: CP#48 completed / Impacted TSs and TRs: 24.173, new 24.183

| ID | WBS | Task | Type | Duration | Start | Finish | Complete | Baseline start | Baseline finish | Baseline duration | Constraint | Resources | Work | Actual work | Acronym | PCG approved | Impacted TSs and TRs | WI rapporteur name | Release | TSG approved | MCC resp | Special Focus Doc | Acronym_3GU_Export | Status Report |
| --- | --- | --- | --- | --- | --- | --- | --- | --- | --- | --- | --- | --- | --- | --- | --- | --- | --- | --- | --- | --- | --- | --- | --- | --- |
| 3755 | 1051 | **Public Warning System** |  | 1315d? | 2007-12-06 A | 2012-12-07 A | 100% | 2007-12-06 | 2012-12-07 | 1315d? |  | S1; C1; C4; R2; R3; R5 | 73920h | 73920h | PWS | 21 | LTE | T-Mobile | Rel-9 | 38 | Alain | Public Safety (I-A) | PWS |  |
| 3756 | 1051.1 | Stage 1 for Public Warning System |  | 266d? | 2007-12-06 A | 2008-12-11 A | 100% | 2007-12-06 | 2008-12-11 | 266d? | finish no earlier than 2008-12-11 | S1 | 2128h | 2128h | PWS | 21 | 22.268 | T-Mobile | Rel-9 | 38 | Alain | Public Safety (I-A) |  |  |
| 3757 | 1051.2 | **Stage 3 for Public Warning System** |  | 137d? | 2009-05-29 A | 2009-12-04 A | 100% | 2009-05-29 | 2009-12-04 | 137d? |  | C1; C4 | 4368h | 4368h | PWS-St3 | 23 |  | Qualcomm | Rel-9 | 44 | Frederic | Public Safety (I-A) | PWS-St3 |  |
| 3758 | 1051.2.1 | CT1 aspects of Stage 3 for Public Warning System |  | 137d? | 2009-05-29 A | 2009-12-04 A | 100% | 2009-05-29 | 2009-12-04 | 137d? | finish no earlier than 2009-12-04 | C1 | 1088h | 1088h | PWS-St3 | 23 | 23.041 | Qualcomm | Rel-9 | 44 | Frederic | Public Safety (I-A) |  |  |
| 3759 | 1051.2.2 | CT4 aspects of Stage 3 for Public Warning System |  | 136d? | 2009-05-30 A | 2009-12-04 A | 100% | 2009-05-30 | 2009-12-04 | 136d? | finish no earlier than 2009-12-04 | C4 | 1088h | 1088h | PWS-St3 | 23 | 29.168 | Qualcomm | Rel-9 | 44 | Kimmo | Public Safety (I-A) |  |  |
| 3760 | 1051.3 | Public Warning System (PWS) – RAN aspects |  | 136d? | 2009-05-30 A | 2009-12-04 A | 100% | 2009-05-30 | 2009-12-04 | 136d? | finish no earlier than 2009-12-04 | R2; R3 | 2176h | 2176h | PWS-RAN | 23 | LTE 36.300, 36.302, 36.331, 36.413 | AT&T | Rel-9 | 44 | Yong-Jun | Public Safety (I-A) | PWS-RAN | RP-091052 |
| 3761 | 1051.4 | Conformance Test Aspects – Public Warning System (PWS) – RAN aspects for LTE |  | 267d? | 2011-12-02 A | 2012-12-07 A | 100% | 2011-12-02 | 2012-12-07 | 267d? | finish no earlier than 2012-12-07 | R5 | 2128h | 2128h | PWS-RAN_UEConTest | 28 | 36.508, 36.523-1, 36.523-2, 36.523-3 | Qualcomm | Rel-9 | 54 | Ingbert | Public Safety (I-A) | PWS-RAN_UEConTest | RP-121525 |
| 3762 | 1052 | **Support of Personal Area Networks and Enhancements to Personal Network Management** |  | 523d? | 2008-06-05 A | 2010-06-04 A | 100% | 2008-06-05 | 2010-06-04 | 523d? |  | S1; C1 | 12544h | 12544h | PAN_EPNM | 21 |  | Vodafone | Rel-9 | 40 | Alain |  | PAN_EPNM |  |
| 3763 | 1052.1 | Stage 1 for Support of Personal Area Networks and Enhancements to Personal Network Management | milestone | 0d? | 2008-06-05 A | 2008-06-05 A | 100% | 2008-06-05 | 2008-06-05 | 0d? | finish no earlier than 2008-06-05 | S1 |  |  | PAN_EPNM | 21 | 22.259 | Vodafone | Rel-9 | 40 | Alain |  |  |  |
| 3764 | 1052.2 | Stage 2 for Support of Personal Area Networks and Enhancements to Personal Network Management |  | 196d? | 2009-03-06 A | 2009-12-04 A | 100% | 2009-03-06 | 2009-12-04 | 196d? | finish no earlier than 2009-12-04 | C1 | 1568h | 1568h | PAN_EPNM | 22 | 23.259 | Huawei | Rel-9 | 43 | Frederic |  |  |  |
| 3765 | 1052.3 | Stage 3 for Support of Personal Area Networks and Enhancements to Personal Network Management |  | 326d? | 2009-03-09 A | 2010-06-04 A | 100% | 2009-03-09 | 2010-06-04 | 326d? | finish no earlier than 2010-06-04 | C1 | 2608h | 2608h | PAN_EPNM | 22 | 24.259 | Huawei | Rel-9 | 43 | Frederic |  |  |  |
| 3766 | 1053 | **Multi-Media Telephony Service enhancements** |  | 472d? | 2008-06-05 A | 2010-03-25 A | 100% | 2008-06-05 | 2010-03-25 | 472d? |  | S1; S5; C1 | 17840h | 17840h | eMMTel | 21 |  | France Telecom | Rel-9 | 40 | Alain |  | eMMTel |  |
| 3767 | 1053.1 | Stage 1 for eMMTel |  | 136d? | 2008-06-05 A | 2008-12-11 A | 100% | 2008-06-05 | 2008-12-11 | 136d? | start no earlier than 2008-06-05 | S1 | 1088h | 1088h | eMMTel | 21 | 22.173 | France Telecom | Rel-9 | 40 | Alain |  |  |  |
| 3768 | 1053.2 | Multimedia Telephony (MMTel) Service and Supplementary Services - Online Charging and completion for Offline Charging (all supplementary services) |  | 272d? | 2009-03-12 A | 2010-03-25 A | 100% | 2009-03-12 | 2010-03-25 | 272d? | finish no earlier than 2010-03-25 | S5 | 2168h | 2168h | eMMTel-SS-CH | 22 | 32.275, 32.298, 32.299 | Alcatel-Lucent | Rel-9 | 43 | Mirko |  | eMMTel-SS-CH |  |
| 3769 | 1053.3 | Support of Real-time Transfer of Tariff Information (RTTI) in IMS charging |  | 271d? | 2009-03-12 A | 2010-03-25 A | 100% | 2009-03-12 | 2010-03-25 | 271d? | finish no earlier than 2010-03-25 | S5 | 2168h | 2168h | IMSTSS-RTTI-CH | 22 | 32.240, 32.280, 32.298, 32.299 | Orange | Rel-9 | 43 | Mirko |  | IMSTSS-RTTI-CH |  |
| 3770 | 1053.4 | Stage 3 - Enhancements for Completion of Communications Supplementary service |  | 136d? | 2009-05-30 A | 2009-12-04 A | 100% | 2009-05-30 | 2009-12-04 | 136d? | finish no earlier than 2009-12-04 | C1 | 1088h | 1088h | eMMTel-CC | 23 | 24.642 | France Telecom | Rel-9 | 44 | Frederic |  | eMMTel-CC |  |
| 3771 | 1054 | **User Data Convergence (UDC)** |  | 527d? | 2008-06-05 A | 2010-06-10 A | 100% | 2008-06-05 | 2010-06-10 | 527d? |  | S1; S5; C4 | 25056h | 25056h | UDC | 21 |  | Nokia Siemens Networks | Rel-9 | 40 | Alain |  | UDC |  |
| 3772 | 1054.1 | Stage 1 for User Data Convergence (UDC) |  | 136d? | 2008-06-05 A | 2008-12-11 A | 100% | 2008-06-05 | 2008-12-11 | 136d? | start no earlier than 2008-06-05 | S1 | 1088h | 1088h | UDC | 21 | 22.101, new 22.985 | Nokia Siemens Networks | Rel-9 | 40 | Alain |  |  |  |
| 3773 | 1054.2 | **Stage 2/3 for User Data Convergence (UDC) Technical Realization** |  | 272d? | 2009-03-06 A | 2010-03-19 A | 100% | 2009-03-06 | 2010-03-19 | 272d? |  | C4 | 5376h | 5376h | UDC-CN | 22 |  | Ericsson | Rel-9 | 43 | Kimmo |  | UDC-CN |  |
| 3774 | 1054.2.1 | User Data Convergence (UDC) Technical Realization (Stage 2) |  | 271d? | 2009-03-06 A | 2010-03-19 A | 100% | 2009-03-06 | 2010-03-19 | 271d? | finish no earlier than 2010-03-19 | C4 | 2168h | 2168h | UDC-CN | 22 | new 23.335 | Ericsson | Rel-9 | 43 | Kimmo |  |  |  |
| 3775 | 1054.2.2 | User Data Convergence (UDC) Protocol Description |  | 130d? | 2009-09-18 A | 2010-03-19 A | 100% | 2009-09-18 | 2010-03-19 | 130d? | finish no earlier than 2010-03-19 | C4 | 1040h | 1040h | UDC-CN | 23 | new 29.335 | China Mobile, Ericsson | Rel-9 | 45 | Kimmo |  |  |  |
| 3776 | 1054.3 | **User Data Convergence (UDC) Modelling and Management** |  | 266d? | 2009-06-04 A | 2010-06-10 A | 100% | 2009-06-04 | 2010-06-10 | 266d? |  | S5 | 5944h | 5944h | UDC-MMAN | 23 |  | T-Mobile, China Mobile, Ericsson | Rel-9 | 44 | Mirko |  | UDC-MMAN |  |
| 3777 | 1054.3.1 | UDC – Framework for Model Handling and Management |  | 266d? | 2009-06-04 A | 2010-06-10 A | 100% | 2009-06-04 | 2010-06-10 | 266d? | finish no earlier than 2010-06-10 | S5 | 2128h | 2128h | UDC-MMAN-MFRM | 23 | 32.172, new 32.181 | T-Mobile | Rel-9 | 44 | Mirko |  | UDC-MMAN-MFRM |  |
| 3778 | 1054.3.2 | UDC – Common Baseline Information Model |  | 211d? | 2009-06-04 A | 2010-03-25 A | 100% | 2009-06-04 | 2010-03-25 | 211d? | finish no earlier than 2010-03-25 | S5 | 1688h | 1688h | UDC-MMAN-CBIM | 23 | 32.172, new 32.182 | China Mobile, Ericsson | Rel-9 | 44 | Mirko |  | UDC-MMAN-CBIM |  |

Notes:
- 3755: TSG#46 completed. Larger scope than Rel-8 Feature UID_370051 (ETWS). Triggered by TR 22.968 Study UID_320025 (FS_PWS) / WI rapporteur e-mail: Mark.Younge@t-mobile.com
- 3756: SP#42 completed / WI rapporteur e-mail: Mark.Younge@t-mobile.com
- 3757: RP#46 completed / WI rapporteur e-mail: Ramachandran Subramanian (rsubrama@qualcomm.com)
- 3758: CP#46 completed / WI rapporteur e-mail: Ramachandran Subramanian (rsubrama@qualcomm.com)
- 3759: CP#46 completed / WI rapporteur e-mail: Ramachandran Subramanian (rsubrama@qualcomm.com)
- 3760: RP#46 completed / WI rapporteur e-mail: don.zelmer@att.com
- 3761: RP#58 completed / WI rapporteur e-mail: Shubhang Vora (svora@qualcomm.com)
- 3762: CP#48 completed / WI rapporteur e-mail: armin.toepfer@vodafone.com
- 3763: SP#40 completed / WI rapporteur e-mail: armin.toepfer@vodafone.com
- 3764: CP#46 completed / WI rapporteur e-mail: Lili Yang (kadyyang@huawei.com)
- 3765: CP#48 completed / WI rapporteur e-mail: Lili Yang (kadyyang@huawei.com)
- 3766: SP#47 completed / WI rapporteur e-mail: philippe.lottin@orange.com
- 3767: SP#42 completed / WI rapporteur e-mail: philippe.lottin@orange.com
- 3768: SP#47 completed / WI rapporteur e-mail: maryse.gardella@alcatel-lucent.com
- 3769: SP#47 completed. Linked to SA5 Rel-8 UID_380042 AoC support in IMS Charging (IMSTSS) / WI rapporteur e-mail: Jean-Luc Garcia (jl.garcia@orange-ftgroup.com)
- 3770: CP#46 completed / WI rapporteur e-mail: Youssef.chadli@orange-ftgroup.com
- 3771: SP#48 completed. Triggered by Rel-8 SA5 Study of Common Profile Storage Framework of User Data for network services and management (UID_320006) TR 32.808 / WI rapporteur e-mail: juergen.merkel@nsn.com
- 3772: SP#42 completed / WI rapporteur e-mail: juergen.merkel@nsn.com
- 3773: - / WI rapporteur e-mail: emiliano.merino@ericsson.com
- 3774: CP#47 completed / WI rapporteur e-mail: emiliano.merino@ericsson.com
- 3775: CP#47 completed / WI rapporteur e-mail: Lan Si Zhong (lansizhong@chinamobile.com), emiliano.merino@ericsson.com
- 3776: SP#48 completed / WI rapporteur e-mail: istvan.aba@t-mobile.at, lansizhong@chinamobile.com, miguel.a.garcia@ericsson.com
- 3777: SP#48 completed / WI rapporteur e-mail: istvan.aba@t-mobile.at
- 3778: SP#47 completed / WI rapporteur e-mail: Lan Si Zhong, Miguel Garcia

| ID | WBS | Task | Duration | Start | Finish | Complete | Baseline start | Baseline finish | Baseline duration | Constraint | Resources | Work | Actual work | Acronym | PCG approved | WI rapporteur name | WI rapporteur e-mail | Release | TSG approved | MCC resp | Acronym_3GU_Export | Status Report | Special Focus Doc |
| --- | --- | --- | --- | --- | --- | --- | --- | --- | --- | --- | --- | --- | --- | --- | --- | --- | --- | --- | --- | --- | --- | --- | --- |
| 3779 | 1055 | **IMS Services Centralization and Continuity** | 393d? | 2008-09-18 A | 2010-03-19 A | 100% | 2008-09-18 | 2010-03-19 | 393d? |  | S1; S2; C1 | 30992h | 30992h | IMS_SCC | 21 | NEC | joerg.swetina@neclab.eu | Rel-9 | 41 | Alain | IMS_SCC |  |  |
| 3780 | 1055.1 | Stage 1 - Inter-Device Transfer – Requirements | 61d? | 2008-09-18 A | 2008-12-11 A | 100% | 2008-09-18 | 2008-12-11 | 61d? | finish no earlier than 2009-06-18 | S1 | 488h | 488h | IMS_SCC-IDT | 21 | NEC | joerg.swetina@neclab.eu | Rel-9 | 41 | Alain | IMS_SCC-IDT |  |  |
| 3781 | 1055.2 | **Stage 2/3 for IMS Service Continuity Enhancements: Service, Policy and Interactions** | 393d? | 2008-09-18 A | 2010-03-19 A | 100% | 2008-09-18 | 2010-03-19 | 393d? |  | S2; C1 | 9456h | 9456h | IMS_SCC-SPI | 21 | Huawei | HengLiang Zhang (hl_zhang@huawei.com) | Rel-9 | 41 | Maurice | IMS_SCC-SPI |  |  |
| 3782 | 1055.2.1 | Stage 2 for IMS Service Continuity Enhancements: Service, Policy and Interactions | 186d? | 2008-09-18 A | 2009-06-04 A | 100% | 2008-09-18 | 2009-06-04 | 186d? | finish no earlier than 2009-06-04 | S2 | 1488h | 1488h | IMS_SCC-SPI | 21 | Huawei | HengLiang Zhang (hl_zhang@huawei.com) | Rel-9 | 41 | Maurice |  |  |  |
| 3783 | 1055.2.2 | Stage 3 for IMS Service Continuity Enhancements: Service, Policy, Interactions and Inter UE Transfer | 212d? | 2009-05-29 A | 2010-03-19 A | 100% | 2009-05-29 | 2010-03-19 | 212d? | finish no earlier than 2010-03-19 | C1 | 1696h | 1696h | IMS_SCC-SPI | 23 | Qualcomm | Roozbeh Atarius (ratarius@qualcomm.com) | Rel-9 | 44 | Frederic |  |  |  |
| 3784 | 1055.3 | **Stage 2/3 for IMS Centralized Services** | 393d? | 2008-09-18 A | 2010-03-19 A | 100% | 2008-09-18 | 2010-03-19 | 393d? |  | S2; C1 | 9448h | 9448h | IMS_SCC-ICS | 21 | Alcatel-Lucent | andy.bennett@alcatel-lucent.com | Rel-9 | 41 | Maurice | IMS_SCC-ICS |  |  |
| 3785 | 1055.3.1 | Stage 2 for IMS Centralized Services | 186d? | 2008-09-18 A | 2009-06-04 A | 100% | 2008-09-18 | 2009-06-04 | 186d? | finish no earlier than 2009-06-04 | S2 | 1488h | 1488h | IMS_SCC-ICS | 21 | Alcatel-Lucent | andy.bennett@alcatel-lucent.com | Rel-9 | 41 | Maurice |  |  |  |
| 3786 | 1055.3.2 | Stage 3 for Enhancements to IMS Centralized Services | 212d? | 2009-05-29 A | 2010-03-19 A | 100% | 2009-05-29 | 2010-03-19 | 212d? | finish no earlier than 2010-03-19 | C1 | 1688h | 1688h | IMS_SCC-ICS | 23 | Nokia Siemens Networks | Peter.Leis@nsn.com | Rel-9 | 44 | Frederic |  |  |  |
| 3787 | 1055.4 | Stage 3 - IMS Centralized Services support via I1 interface | 271d? | 2009-03-06 A | 2010-03-19 A | 100% | 2009-03-06 | 2010-03-19 | 271d? | finish no earlier than 2010-03-19 | C1 | 2168h | 2168h | IMS_SCC-ICS_I1 | 22 | Huawei | Lili Yang(kadyyang@huawei.com) | Rel-9 | 43 | Frederic | IMS_SCC-ICS_I1 |  |  |
| 3788 | 1056 | **Service Specific Access Control in EPS** | 922d? | 2008-12-11 A | 2012-06-15 A | 100% | 2008-12-11 | 2012-06-15 | 922d? |  | S1; C1; R5 | 26000h | 26000h | SSAC | 22 | NTT DoCoMo | Frederic Thepot (thepot@docomolab-euro.com) | Rel-9 | 42 | Alain | SSAC |  |  |
| 3789 | 1056.1 | Stage 1 for Service Specific Access Control in EPS | 1d? | 2008-12-11 A | 2008-12-11 A | 100% | 2008-12-11 | 2008-12-11 | 1d? | start no earlier than 2008-12-11 | S1 | 8h | 8h | SSAC | 22 | NTT DoCoMo | Frederic Thepot (thepot@docomolab-euro.com) | Rel-9 | 42 | Alain |  |  |  |
| 3790 | 1056.2 | Stage 3 for Service Specific Access Control in EPS | 212d? | 2009-05-29 A | 2010-03-19 A | 100% | 2009-05-29 | 2010-03-19 | 212d? | finish no earlier than 2010-03-19 | C1 | 1696h | 1696h | SSAC | 23 | NTT DoCoMo | Hideyuki Yamashita (yamashitahi@s1.nttdocomo.co.jp) | Rel-9 | 44 | Frederic |  |  |  |
| 3791 | 1056.3 | Conformance Test Aspects - Service Specific Access Control | 272d? | 2011-06-07 A | 2012-06-15 A | 100% | 2011-06-07 | 2012-06-15 | 272d? | finish no earlier than 2012-06-15 | R5 | 2168h | 2168h | SSAC_UEConTest | 27 | NTT DoCoMo | Takao.Shimizu.rp@nttdocomo.com | Rel-9 | 52 | Ingbert | SSAC_UEConTest | RP-120447 |  |
| 3792 | 1057 | **Support for IMS Emergency Calls over GPRS and EPS** | 3785d? | 2000-01-03 A | 2014-06-13 A | 100% | 2000-01-03 | 2014-06-13 | 3785d? |  | S1; S2; S3; C1; C3; C4; R2; R3; R5; IETF | 293512h | 293512h | IMS_EMER_GPRS_EPS | 21 | Alcatel-Lucent | Deborah Barclay | Rel-9 | 38 | Maurice | IMS_EMER_GPRS_EPS |  | Public Safety (I-A) |
| 3793 | 1057.1 | Stage 1 for IMS Emergency Calls over GPRS and EPS | 239d? | 2008-01-14 A | 2008-12-11 A | 100% | 2008-01-14 | 2008-12-11 | 239d? | finish no earlier than 2008-12-11 | S1 | 1912h | 1912h | IMS_EMER_GPRS_EPS | 21 | Alcatel-Lucent | Deborah Barclay | Rel-9 | 38 | Alain |  |  | Public Safety (I-A) |
| 3794 | 1057.2 | Stage 2 for IMS Emergency Calls over GPRS and EPS | 364d? | 2008-01-14 A | 2009-06-04 A | 100% | 2008-01-14 | 2009-06-04 | 364d? | finish no earlier than 2009-06-04 | S2 | 2912h | 2912h | IMS_EMER_GPRS_EPS | 21 | Alcatel-Lucent | Deborah Barclay | Rel-9 | 38 | Maurice |  |  | Public Safety (I-A) |
| 3795 | 1057.3 | Security aspects for IMS Emergency Calls over GPRS and EPS | 391d? | 2008-12-12 A | 2010-06-10 A | 100% | 2008-12-12 | 2010-06-10 | 391d? | finish no earlier than 2010-03-25 | S3 | 3128h | 3128h | IMS_EMER_GPRS_EPS-Sec | 22 | Alcatel-Lucent | Deborah Barclay | Rel-9 | 42 | Mirko | IMS_EMER_GPRS_EPS-Sec |  | Public Safety (I-A) |
| 3796 | 1057.4 | **Stage 3 for IMS Emergency Calls over GPRS and EPS** | 801d? | 2009-05-29 A | 2012-06-15 A | 100% | 2009-05-29 | 2012-06-15 | 801d? |  | C1; C3; C4; R5 | 33331.7h | 33331.7h | IMS_EMER_GPRS_EPS | 23 | Alcatel-Lucent | Frank Alfano (falfano@alcatel-lucent.com) | Rel-9 | 44 | Frederic |  |  | Public Safety (I-A) |
| 3797 | 1057.4.1 | CT1 aspects - Stage 3 for IMS Emergency Calls over GPRS and EPS | 212d? | 2009-05-29 A | 2010-03-19 A | 100% | 2009-05-29 | 2010-03-19 | 212d? | finish no earlier than 2010-03-19 | C1 | 1696h | 1696h | IMS_EMER_GPRS_EPSC1 | 23 | Alcatel-Lucent | Frank Alfano (falfano@alcatel-lucent.com) | Rel-9 | 44 | Frederic |  |  | Public Safety (I-A) |
| 3798 | 1057.4.2 | Conformance Test Aspects - CT1 aspects for IMS Emergency Calls over GPRS and EPS | 532d? | 2010-06-04 A | 2012-06-15 A | 100% | 2010-06-04 | 2012-06-15 | 532d? | finish no earlier than 2012-06-15 | R5 | 4256h | 4256h | IMS_EMER_GPRS_EPS_UEConTest | 25 | Samsung | stoyan.baev@partner.samsung.com | Rel-9 | 48 | Ingbert | IMS_EMER_GPRS_EPS_UEConTest | RP-120445 | Public Safety (I-A) |
| 3799 | 1057.4.3 | CT3 aspects - Stage 3 for IMS Emergency Calls over GPRS and EPS | 82d? | 2009-05-29 A | 2009-09-18 A | 100% | 2009-05-29 | 2009-09-18 | 82d? | start no earlier than 2009-05-29 | C3 | 651.68h | 651.68h | IMS_EMER_GPRS_EPSC3 | 23 | Alcatel-Lucent | Frank Alfano (falfano@alcatel-lucent.com) | Rel-9 | 44 | Adrian |  |  | Public Safety (I-A) |
| 3800 | 1057.4.4 | CT4 aspects - Stage 3 for IMS Emergency Calls over GPRS and EPS | 137d? | 2009-05-29 A | 2009-12-04 A | 100% | 2009-05-29 | 2009-12-04 | 137d? | finish no earlier than 2009-12-04 | C4 | 1096h | 1096h | IMS_EMER_GPRS_EPSC4 | 23 | Alcatel-Lucent | Frank Alfano (falfano@alcatel-lucent.com) | Rel-9 | 44 | Kimmo |  |  | Public Safety (I-A) |
| 3801 | 1057.5 | Support for IMS Emergency Calls over LTE | 207d? | 2000-01-03 A | 2000-10-16 A | 100% | 2000-01-03 | 2000-10-16 | 207d? |  | R2; R3 | 3312h | 3312h | IMS_EMER_LTE | 22 | Alcatel-Lucent | Sudeep Palat (spalat@alcatel-lucent.com) | Rel-9 | 42 | Yong-Jun | IMS_EMER_LTE | RP-090698 | Public Safety (I-A) |
| 3802 | 1057.6 | Conformance Test Aspects – Support for IMS Emergency Calls over LTE | 187d? | 2010-03-25 A | 2010-12-10 A | 100% | 2010-03-25 | 2010-12-10 | 187d? | finish no earlier than 2010-12-10 | R5 | 1496h | 1496h | IMS_EMER_LTE_UEConTest | 24 | Ericsson | leif.mattisson@ericsson.com | Rel-9 | 47 | Ingbert | IMS_EMER_LTE_UEConTest | RP-101068 | Public Safety (I-A) |

Notes:
- 3779: CP#47 completed
- 3780: SP#42 completed / Impacted TSs and TRs: 22.101, 22.228
- 3781: -
- 3782: SP#57 Removal of the MSC server assisted mid-call feature from Rel-9 by 23.237CR#0433 (CT1 proposed moving this feature to Rel-10). SP#44 completed. TR 23.838 for Approval / Impacted TSs and TRs: 23.237, 23.292, 23.216, new 23.838
- 3783: CP#47 completed / Impacted TSs and TRs: 24.216, 24.229, 24.237
- 3784: -
- 3785: SP#44 completed. TR 23.883 for Information + Approval / Impacted TSs and TRs: 23.292, new 23.883
- 3786: CP#47 completed / Impacted TSs and TRs: 24.292, 24.604, 24.607, 24.608, 24.611, 24.623
- 3787: CP#47 completed / Impacted TSs and TRs: 24.237, 24.292, new 24.294
- 3788: CP#47 completed. Triggered by TR 22.986 Study on Service Specific Access Control in EPS. As EPS is a PS-Domain only system, Domain Specific Access Control (DSAC) doesn't apply, hence SSAC allows restriction of voice and non-voice calls separately
- 3789: SP#42 completed. If UE supports E-UTRA and IMS, SSAC is a mandatory Rel-9 function (during congestion in emergency case earthquake/tsunami improves mobile communications). / Impacted TSs and TRs: 22.011 CR0136
- 3790: CP#47 completed / Impacted TSs and TRs: 24.173, 27.007
- 3791: RP#56 completed. Testing for Stage 3 for Service Specific Access Control in EPS (24.173, 27.007) UID_440040 / Impacted TSs and TRs: 34.229-1, 34.229-2, 34.229-3
- 3792: RP#56 completed testing. CP#47 completed. SP#48 completed / Impacted TSs and TRs: GERAN, LTE
- 3793: SP#42 completed / Impacted TSs and TRs: 22.101
- 3794: SP#44 completed / Impacted TSs and TRs: 23.869, 23.060, 23.167, 23.203, 23.221, 23.228, 23.271, 23.401, 23.402
- 3795: SP#48 completed / Impacted TSs and TRs: 33.401, 33.402
- 3796: RP#56 completed testing. CP#47 completed / Impacted TSs and TRs: GERAN, LTE
- 3797: CP#47 completed / Impacted TSs and TRs: 23.122, 24.008, 24.229, 24.301, 24.302
- 3798: RP#56 completed / Impacted TSs and TRs: 34.108, 34.123-1, 34.123-2, 34.123-3, 34.229-1, 34.229-2, 34.229-3, 36.508, 36.523-1, 36.523-2, 36.523-3
- 3799: CP#45 completed / Impacted TSs and TRs: 29.212, 29.213, 29.214, 29.215
- 3800: CP#46 completed / Impacted TSs and TRs: 23.003, 23.008, 29.060, 29.272, 29.273, 29.274, 29.275, 29.276
- 3801: RP#45 completed / Impacted TSs and TRs: 36.331, 36.413
- 3802: RP#50 completed / Impacted TSs and TRs: 36.508, 36.523-1, 36.523-2, 36.523-3

| ID | WBS | Task | Type | Duration | Start | Finish | Complete | Baseline start | Baseline finish | Baseline duration | Constraint | Resources | Work | Actual work | Acronym | PCG approved | WI rapporteur name | WI rapporteur e-mail | Release | TSG approved | MCC resp | Special Focus Doc | Acronym_3GU_Export | Status Report |
| --- | --- | --- | --- | --- | --- | --- | --- | --- | --- | --- | --- | --- | --- | --- | --- | --- | --- | --- | --- | --- | --- | --- | --- | --- |
| 3803 | 1057.7 | **Single Radio Voice Call Continuity (SRVCC) support for IMS Emergency Calls** |  | 1511d? | 2008-09-18 A | 2014-06-13 A | 100% | 2008-09-18 | 2014-06-13 | 1511d? |  | S2; C1; C4; C3; IETF | 112300h | 112300h | IMS_EMER_GPRS_EPS-SRVCC | 21 | China Mobile | Yu Qing (Yuqing@chinamobile.com) | Rel-9 | 41 | Maurice | Public Safety (I-A) | IMS_EMER_GPRS_EPS-SRVCC |  |
| 3804 | 1057.7.1 | SRVCC support for IMS Emergency Calls |  | 322d? | 2008-09-18 A | 2009-12-10 A | 100% | 2008-09-18 | 2009-12-10 | 322d? | finish no earlier than 2009-12-10 | S2 | 2576h | 2576h | IMS_EMER_GPRS_EPS-SRVCC | 21 | China Mobile | Yu Qing (Yuqing@chinamobile.com) | Rel-9 | 41 | Maurice | Public Safety (I-A) |  |  |
| 3805 | 1057.7.2 | **CT aspects of SRVCC support for IMS Emergency Calls** |  | 1330d? | 2009-05-29 A | 2014-06-13 A | 100% | 2009-05-29 | 2014-06-13 | 1330d? |  | C1; C4; C3; IETF | 49284h | 49284h | IMS_EMER_GPRS_EPS-SRVCC | 24 | China Mobile | jiangyi@chinamobile.com | Rel-9 | 46 | Frederic | Public Safety (I-A) |  |  |
| 3806 | 1057.7.2.1 | CT1 aspects of SRVCC support for IMS Emergency Calls |  | 137d? | 2009-05-29 A | 2009-12-04 A | 100% | 2009-05-29 | 2009-12-04 | 137d? | finish no earlier than 2009-12-04 | C1 | 1096h | 1096h | IMS_EMER_GPRS_EPS-SRVCC | 23 | China Mobile | jiangyi@chinamobile.com | Rel-9 | 44 | Frederic | Public Safety (I-A) |  |  |
| 3807 | 1057.7.2.2 | CT4 aspects of SRVCC support for IMS Emergency Calls |  | 137d? | 2009-05-29 A | 2009-12-04 A | 100% | 2009-05-29 | 2009-12-04 | 137d? | finish no earlier than 2009-12-04 | C4 | 1096h | 1096h | IMS_EMER_GPRS_EPS-SRVCC | 23 | China Mobile | jiangyi@chinamobile.com | Rel-9 | 44 | Kimmo | Public Safety (I-A) |  |  |
| 3808 | 1057.7.2.3 | CT3 aspects of SRVCC support for IMS Emergency Calls |  | 1d? | 2009-12-04 A | 2009-12-04 A | 100% | 2009-12-04 | 2009-12-04 | 1d? | finish no earlier than 2009-12-04 | C3 | 8h | 8h | IMS_EMER_GPRS_EPS-SRVCC | 24 | China Mobile | jiangyi@chinamobile.com | Rel-9 | 46 | Kimmo | Public Safety (I-A) |  |  |
| 3809 | 1057.7.2.4 | (IETF) CT3 aspects of SRVCC support for IMS Emergency Calls (RFC 7254) |  | 568d? | 2012-04-20 A | 2014-06-13 A | 100% | 2012-04-20 | 2014-06-13 | 568d? | finish no earlier than 2014-06-13 | C3-IETF | 4524h | 4524h | IMS_EMER_GPRS_EPS-SRVCC | 29 | Andrew Allen | Andrew Allen | Rel-9 | 56 | Adrian | Public Safety (I-A) |  |  |
| 3810 | 1058 | **LCS for LTE and EPS** |  | 981d? | 2008-06-05 A | 2012-03-02 A | 100% | 2008-06-05 | 2012-03-02 | 981d? |  | S2; C1; C4; R2; R1; R3; R4; R5 | 83592h | 83592h | LCS_LTE_EPS | 22 |  |  | Rel-9 | 43 | Maurice | Public Safety (I-A) | LCS_LTE_EPS |  |
| 3811 | 1058.1 | **LCS Control Plane Solution for EPS** |  | 468d? | 2008-06-05 A | 2010-03-19 A | 100% | 2008-06-05 | 2010-03-19 | 468d? |  | S2; C4; C1 | 16712h | 16712h | LCS_EPS-CPS | 21 | Polaris Wireless | Robert Gross (rgross@polariswireless.com) | Rel-9 | 40 | Maurice | Public Safety (I-A) | LCS_EPS-CPS |  |
| 3812 | 1058.1.1 | Stage 2 for LCS Control Plane Solution for EPS |  | 261d? | 2008-06-05 A | 2009-06-04 A | 100% | 2008-06-05 | 2009-06-04 | 261d? | finish no earlier than 2009-06-04 | S2 | 2088h | 2088h | LCS_EPS-CPS | 21 | Polaris Wireless | Robert Gross (rgross@polariswireless.com) | Rel-9 | 40 | Maurice | Public Safety (I-A) |  |  |
| 3813 | 1058.1.2 | CT4 aspects of Control Plane LCS in the EPC |  | 212d? | 2009-05-29 A | 2010-03-19 A | 100% | 2009-05-29 | 2010-03-19 | 212d? | finish no earlier than 2010-03-19 | C4 | 1696h | 1696h | LCS_EPS-CPS | 23 | Polaris Wireless | Robert Gross (rgross@polariswireless.com) | Rel-9 | 44 | Kimmo | Public Safety (I-A) |  |  |
| 3814 | 1058.1.3 | CT1 aspects of Control Plane LCS in the EPC |  | 212d? | 2009-05-29 A | 2010-03-19 A | 100% | 2009-05-29 | 2010-03-19 | 212d? | finish no earlier than 2010-03-19 | C1 | 1696h | 1696h | LCS_EPS-CPS | 23 | Polaris Wireless | Robert Gross (rgross@polariswireless.com) | Rel-9 | 44 | Frederic | Public Safety (I-A) |  |  |
| 3815 | 1058.2 | Positioning Support for LTE | milestone | 0d? | 2008-12-05 A | 2008-12-05 A | 100% | 2008-12-05 | 2010-06-04 | 392d? | finish no earlier than 2010-06-04 | R2; R1; R3; R4 |  |  | LCS_LTE | 22 | Qualcomm | Nathan Tenny (ntenny@qualcomm.com) | Rel-9 | 42 | Yong-Jun | Public Safety (I-A) | LCS_LTE | RP-100442 |
| 3816 | 1058.3 | Conformance Test Aspects – Positioning Support for LTE |  | 512d? | 2010-03-19 A | 2012-03-02 A | 100% | 2010-03-19 | 2012-03-02 | 512d? | finish no earlier than 2012-03-02 | R5 | 4096h | 4096h | LCS_LTE_UEConTest | 24 | Qualcomm | Shubhang Vora (svoral@qualcomm.com) | Rel-9 | 47 | Ingbert | Public Safety (I-A) | LCS_LTE_UEConTest | RP-120034 |
| 3817 | 1059 | **MBMS support in EPS** |  | 921d? | 2008-06-05 A | 2011-12-09 A | 100% | 2008-06-05 | 2011-12-09 | 921d? |  | S2; S3; S5; C3; C4; R2; R3; R4; R5 | 82896h | 82896h | MBMS_EPS | 21 | China Mobile | Liu Hong (liuhongyfw@chinamobile.com) | Rel-9 | 40 | Maurice |  | MBMS_EPS |  |
| 3818 | 1059.1 | Stage 2 for MBMS support in EPS |  | 261d? | 2008-06-05 A | 2009-06-04 A | 100% | 2008-06-05 | 2009-06-04 | 261d? | finish no earlier than 2009-06-04 | S2 | 2088h | 2088h | MBMS_EPS | 21 | China Mobile | Liu Hong (liuhongyfw@chinamobile.com) | Rel-9 | 40 | Maurice |  |  |  |
| 3819 | 1059.2 | Security for MBMS support in EPS |  | 261d? | 2008-12-11 A | 2009-12-10 A | 100% | 2008-12-11 | 2009-12-10 | 261d? | finish no earlier than 2009-12-10 | S3 | 2088h | 2088h | MBMS_EPS | 22 | China Mobile | Liu Hong (liuhongyfw@chinamobile.com) | Rel-9 | 42 | Mirko |  |  |  |
| 3820 | 1059.3 | MBMS Charging in EPS |  | 201d? | 2009-03-06 A | 2009-12-10 A | 100% | 2009-03-06 | 2009-12-10 | 201d? | finish no earlier than 2009-12-10 | S5 | 1600h | 1600h | MBMS_EPS | 22 | ZTE | guo.wenjie1@zte.com.cn | Rel-9 | 43 | Mirko |  |  |  |
| 3821 | 1059.4 | CT4 aspects of MBMS support in EPS (Stage 3) |  | 137d? | 2009-05-29 A | 2009-12-04 A | 100% | 2009-05-29 | 2009-12-04 | 137d? | finish no earlier than 2009-12-04 | C4 | 1096h | 1096h | MBMS_EPS | 23 | China Mobile, ZTE | wangjingyf@chinamobile.com, lu.fei1@zte.com.cn | Rel-9 | 44 | Kimmo |  |  |  |
| 3822 | 1059.5 | CT3 aspects of MBMS support in EPS (Stage 3) |  | 137d? | 2009-05-29 A | 2009-12-04 A | 100% | 2009-05-29 | 2009-12-04 | 137d? | start no earlier than 2009-05-29 | C3 | 1096h | 1096h | MBMS_EPS | 23 | ZTE, China Mobile | zhou.xiaoyun@zte.com.cn, wangjingyf@chinamobile.com | Rel-9 | 44 | Adrian |  |  |  |
| 3823 | 1059.6 | MBMS support in LTE |  | 272d? | 2009-03-06 A | 2010-03-19 A | 100% | 2009-03-06 | 2010-03-19 | 272d? | finish no earlier than 2010-03-19 | R2; R3; R4 | 6528h | 6528h | MBMS_LTE | 22 | Huawei | arnaud.meylan@huawei.com | Rel-9 | 43 | Yong-Jun |  | MBMS_LTE | RP-100033 |
| 3824 | 1059.7 | Conformance Test Aspects – MBMS support in LTE |  | 262d? | 2010-12-10 A | 2011-12-09 A | 100% | 2010-12-10 | 2011-12-09 | 262d? | finish no earlier than 2011-12-09 | R5 | 2088h | 2088h | MBMS_LTE-UEConTest | 26 | Huawei | Zhang Xin (zhangxin0208@huawei.com) | Rel-9 | 50 | Ingbert |  | MBMS_LTE-UEConTest | RP-111437 |
| 3825 | 1060 | **Access Network Discovery and Selection Function enhancements** |  | 333d? | 2008-12-11 A | 2010-03-19 A | 100% | 2008-12-11 | 2010-03-19 | 333d? |  | S2; C1 | 7384h | 7384h | eANDSF | 22 | Motorola | Apostolis Salkintzis (salki@motorola.com) | Rel-9 | 42 | Maurice |  | eANDSF |  |
| 3826 | 1060.1 | Stage 2 for Access Network Discovery and Selection Function enhancements |  | 126d? | 2008-12-11 A | 2009-06-04 A | 100% | 2008-12-11 | 2009-06-04 | 126d? | finish no earlier than 2009-06-04 | S2 | 1008h | 1008h | eANDSF | 22 | Motorola | Apostolis Salkintzis (salki@motorola.com) | Rel-9 | 42 | Maurice |  |  |  |
| 3827 | 1060.2 | CT1 aspects of Access Network Discovery and Selection Function enhancements |  | 131d? | 2009-09-18 A | 2010-03-19 A | 100% | 2009-09-18 | 2010-03-19 | 131d? | finish no earlier than 2010-03-19 | C1 | 1048h | 1048h | eANDSF | 23 | Panasonic | benjamin.limck@sg.panasonic.com | Rel-9 | 45 | Frederic |  |  |  |

Notes:
- 3803: CP#56 added IETF dependency
- 3804: SP#46 completed / Impacted TSs and TRs: 23.870, 23.216, 23.237
- 3805: CP#46 completed
- 3806: CP#46 completed / Impacted TSs and TRs: 24.229, 24.237
- 3807: CP#46 completed / Impacted TSs and TRs: 29.205, 29.280
- 3808: CP#46 completed / Impacted TSs and TRs: 29.163
- 3809: CP#64 completed / Impacted TSs and TRs: RFC 7254 (was draft-montemurro-gsma-imei-urn)
- 3810: - / Impacted TSs and TRs: LTE
- 3811: Triggered by abandoned Study UID_380068 (FS_LCS_EPS). Linked to Feature UID_380064 Support for IMS Emergency Calls over GPRS and EPS
- 3812: SP#44 completed / Impacted TSs and TRs: 23.891, 23.271, 23.401, 23.402
- 3813: CP#47 completed (IANA registrations outstanding). Stage 3 SLs and SLg interfaces & transport of positioning messages between E-SMLC and MME in the scope of UID_420006 (Positioning Support for LTE) / Impacted TSs and TRs: 24.080, 29.002, 29.272, 29.230, new 24.171, 29.171, 29.172, 29.173
- 3814: CP#47 completed / Impacted TSs and TRs: 24.301
- 3815: RP#48 completed. UID_400038 (LCS Control Plane Solution for EPS) depends on this WI / Impacted TSs and TRs: 34.213, 36.133, 36.211, 36.214, 36.300, 36.305, 36.331, 36.355, 36.410, 36.413, 36.455, new 36.171
- 3816: RP#55 completed. RP#56 TS 37.571-4 v200 for Approval / Impacted TSs and TRs: 36.508, 36.509, new (37.571-1, 37.571-2, 37.571-3, 37.571-4, 37.571-5)
- 3817: RP#47 completed. SP#46, CP#46 completed / Impacted TSs and TRs: LTE
- 3818: SP#44 completed / Impacted TSs and TRs: 23.246
- 3819: SP#46 completed / Impacted TSs and TRs: 33.246
- 3820: SP#46 completed / Impacted TSs and TRs: 32.273, 32.251, 32.298, 32.299
- 3821: CP#46 completed / Impacted TSs and TRs: 29.274, 29.281, 23.007, 23.008
- 3822: CP#46 completed / Impacted TSs and TRs: 29.061
- 3823: RP#47 completed / Impacted TSs and TRs: 25.446, 36.101, 36.104, 36.141, 36.300, 36.304, 36.321, 36.322, 36.323, 36.331, 36.440, 36.441, 36.442, 36.444, 36.445
- 3824: RP#54 completed / Impacted TSs and TRs: 36.508, 36.521-1, 36.521-2, 36.523-1, 36.523-2, 36.523-3
- 3825: CP#47 completed. No new Rel-9 use cases defined. Implement service requirements not covered in Rel-8 / Impacted TSs and TRs: 22.278, SA3 33.402 CR#0055
- 3826: SP#44 completed / Impacted TSs and TRs: 23.402, 23.002
- 3827: CP#47 completed / Impacted TSs and TRs: 24.302, 24.312

| ID | WBS | Task | Duration | Start | Finish | Complete | Baseline start | Baseline finish | Baseline duration | Constraint | Resources | Work | Actual work | Acronym | PCG approved | WI rapporteur name | WI rapporteur e-mail | Release | TSG approved | MCC resp | Acronym_3GU_Export | Impacted TSs and TRs | Status Report |
| --- | --- | --- | --- | --- | --- | --- | --- | --- | --- | --- | --- | --- | --- | --- | --- | --- | --- | --- | --- | --- | --- | --- | --- |
| 3828 | 1061 | **Multiple PDN Connection to the Same APN for PMIP-based Interfaces** | 267d? | 2009-03-13 A | 2010-03-19 A | 100% | 2009-03-13 | 2010-03-19 | 267d? |  | S2; C4; C1 | 8392h | 8392h | MUPSAP | 22 | Samsung | erik.guttman@partner.samsung.com | Rel-9 | 43 | Maurice | MUPSAP |  |  |
| 3829 | 1061.1 | Stage 2 for Multiple PDN Connection to the Same APN for PMIP-based Interfaces | 61d? | 2009-03-13 A | 2009-06-04 A | 100% | 2009-03-13 | 2009-06-04 | 61d? | finish no earlier than 2009-06-04 | S2 | 488h | 488h | MUPSAP | 22 | Samsung | erik.guttman@partner.samsung.com | Rel-9 | 43 | Maurice |  | 23.060, 23.203, 23.401, 23.402 |  |
| 3830 | 1061.2 | CT4 aspects of Multiple PDN Connection to the Same APN for PMIP-based Interfaces | 56d? | 2009-09-18 A | 2009-12-04 A | 100% | 2009-09-18 | 2009-12-04 | 56d? | finish no earlier than 2009-12-04 | C4 | 448h | 448h | MUPSAP | 23 | Samsung | Surjyakanta Mohapatra (surjya.kanta@samsung.com) | Rel-9 | 45 | Kimmo |  | 29.275, 23.008, 29.282 |  |
| 3831 | 1061.3 | CT1 aspects of Multiple PDN Connection to the Same APN for PMIP-based Interfaces | 131d? | 2009-09-18 A | 2010-03-19 A | 100% | 2009-09-18 | 2010-03-19 | 131d? | finish no earlier than 2010-03-19 | C1 | 1048h | 1048h | MUPSAP | 23 | Samsung | Surjyakanta Mohapatra (surjya.kanta@samsung.com) | Rel-9 | 45 | Frederic |  | 24.302 |  |
| 3832 | 1062 | **System aspects of vocoder rate adaptation for LTE** | 1403.68d? | 2007-05-07 A | 2012-09-12 A | 100% | 2007-05-07 | 2012-09-12 | 1403.68d? |  | S2; S4; C1; C3; R2; IETF | 108798h | 108798h | LTEimp-Vocoder | 23 | Qualcomm | AC Mahendran (ac@qualcomm.com) | Rel-9 | 45 | Maurice | LTEimp-Vocoder | LTE |  |
| 3833 | 1062.1 | SA2 system aspects of vocoder rate adaptation for LTE | 81d? | 2009-06-04 A | 2009-09-24 A | 100% | 2009-06-04 | 2009-09-24 | 81d? | start no earlier than 2009-06-04 | S2 | 648h | 648h | LTEimp-Vocoder | 23 | Qualcomm | AC Mahendran (ac@qualcomm.com) | Rel-9 | 45 | Maurice |  | 23.401 CR#1103r3 |  |
| 3834 | 1062.2 | SA4 system aspects of vocoder rate adaptation for LTE | 136d? | 2009-06-04 A | 2009-12-10 A | 100% | 2009-06-04 | 2009-12-10 | 136d? | finish no earlier than 2009-12-07 | S4 | 1088h | 1088h | LTEimp-Vocoder | 23 | Qualcomm | Nikolai Leung | Rel-9 | 45 | Paolo |  | 26.114 |  |
| 3835 | 1062.3 | Vocoder rate adaptation for LTE | 81d? | 2009-05-30 A | 2009-09-18 A | 100% | 2009-05-30 | 2009-09-18 | 81d? | finish no earlier than 2009-09-18 | R2 | 648h | 648h | LTEimp-Vocoder | 23 | Alcatel-Lucent | Sudeep Palat (spalat@alcatel-lucent.com) | Rel-9 | 44 | Yong-Jun |  | 36.300 CR#0114 | RP-090704 |
| 3836 | 1062.4 | (IETF) SA4 system aspects of vocoder rate adaptation for LTE | 677.6d? | 2009-06-04 A | 2012-09-12 A | 100% | 2009-06-04 | 2012-09-12 | 677.6d? | finish no earlier than 2012-09-14 | S4-IETF | 5420.8h | 5420.8h | LTEimp-Vocoder | 27 | Lionel Morand |  | Rel-9 | 52 | Paolo |  | RFC 6679 (was draft-ietf-avtcore-ecn-for-rtp) |  |
| 3837 | 1062.5 | (IETF) CT aspects of vocoder rate adaptation for LTE | 1400.68d? | 2007-05-07 A | 2012-09-07 A | 100% | 2007-05-07 | 2012-09-07 | 1400.68d? | finish no earlier than 2012-09-07 | C1-IETF; C3-IETF; C4-IETF | 33616.3h | 33616.3h | LTEimp-Vocoder | 27 | Lionel Morand |  | Rel-9 | 52 | Frederic |  | RFC 6679 (was draft-ietf-avtcore-ecn-for-rtp) |  |
| 3838 | 1063 | Access Security Enhancements | 505d? | 2007-07-02 A | 2009-06-04 A | 100% | 2007-07-02 | 2009-06-04 | 505d? | finish no earlier than 2009-06-03 | S3 | 4040h | 4040h | ACCSEC2 |  | Ericsson | Bengt.Sahlin@ericsson.com | Rel-9 | 26 | Mirko | ACCSEC2 | 33.102, 43.020 |  |
| 3839 | 1064 | **Protection against Unsolicited Communication for IMS (PUCI)** | 322d? | 2008-09-18 A | 2009-12-10 A | 100% | 2008-09-18 | 2009-12-10 | 322d? |  | S3; S1 | 8216h | 8216h | PUCI | 21 | NEC | Anand R. Prasad (anand@bq.jp.nec.com) | Rel-9 | 41 | Alain | PUCI |  |  |
| 3840 | 1064.1 | Stage 1 for PUCI | 61d? | 2008-09-18 A | 2008-12-11 A | 100% | 2008-09-18 | 2008-12-11 | 61d? | finish no earlier than 2009-06-18 | S1 | 488h | 488h | PUCI | 21 | NEC | Anand R. Prasad (anand@bq.jp.nec.com) | Rel-9 | 41 | Alain |  | 22.228 |  |
| 3841 | 1064.2 | SA3 work on PUCI | 322d? | 2008-09-18 A | 2009-12-10 A | 100% | 2008-09-18 | 2009-12-10 | 322d? | finish no earlier than 2009-12-10 | S3 | 2576h | 2576h | PUCI | 21 | NEC | Anand R. Prasad (anand@bq.jp.nec.com) | Rel-9 | 41 | Mirko |  | New 33.937 |  |
| 3842 | 1065 | **IMS Media Plane Security** | 922d? | 2009-03-13 A | 2012-09-14 A | 100% | 2009-03-13 | 2012-09-14 | 922d? |  | S3; C1; C4; C3; IETF | 67928h | 67928h | MEDIASEC | 22 | Vodafone | Peter.Howard@vodafone.com | Rel-9 | 43 | Mirko | MEDIASEC |  |  |
| 3843 | 1065.1 | SA3 aspects of IMS Media Plane Security | 271d? | 2009-03-13 A | 2010-03-25 A | 100% | 2009-03-13 | 2010-03-25 | 271d? | finish no earlier than 2010-03-25 | S3 | 2168h | 2168h | MEDIASEC | 22 | Vodafone | Peter.Howard@vodafone.com | Rel-9 | 43 | Mirko |  | New 33.828, 33.328 |  |
| 3844 | 1065.2 | (IETF) SA3, CT1, CT3 aspects of IMS Media Plane Security | 919d? | 2009-03-18 A | 2012-09-14 A | 100% | 2009-03-18 | 2012-09-14 | 919d? | finish no earlier than 2012-09-14 | S3-IETF; C1-IETF; C3-IETF | 22056h | 22056h | MEDIASEC | 27 | Peter Dawes |  | Rel-9 | 52 | Mirko |  | draft-dawes-dispatch-mediasec-parameter |  |
| 3845 | 1065.3 | **CN aspects of IMS Media Plane Security** | 186d? | 2009-09-18 A | 2010-06-04 A | 100% | 2009-09-18 | 2010-06-04 | 186d? |  | C1; C4; C3 | 6824h | 6824h | MEDIASEC_CORE | 23 | Vodafone | peter.dawes@vodafone.com | Rel-9 | 45 | Frederic | MEDIASEC_CORE |  |  |
| 3846 | 1065.3.1 | CT1 aspects of IMS Media Plane Security | 33d? | 2009-09-18 A | 2010-03-19 A | 100% | 2009-09-18 | 2010-03-19 | 33d? | finish no earlier than 2010-03-19 | C1 | 264h | 264h | MEDIASEC_CORE | 23 | Vodafone | peter.dawes@vodafone.com | Rel-9 | 45 | Frederic |  | 23.218, 24.229 |  |
| 3847 | 1065.3.2 | CT4 aspects of IMS Media Plane Security | 131d? | 2009-09-18 A | 2010-03-19 A | 100% | 2009-09-18 | 2010-03-19 | 131d? | finish no earlier than 2010-03-19 | C4 | 1048h | 1048h | MEDIASEC_CORE | 23 | Vodafone | peter.dawes@vodafone.com | Rel-9 | 45 | Kimmo |  | 29.238, 23.334, 29.334 |  |
| 3848 | 1065.3.3 | CT3 aspects of IMS Media Plane Security | 131d? | 2009-12-04 A | 2010-06-04 A | 100% | 2009-12-04 | 2010-06-04 | 131d? | finish no earlier than 2010-06-04 | C3 | 1048h | 1048h | MEDIASEC_CORE | 24 | Vodafone | peter.dawes@vodafone.com | Rel-9 | 46 | Adrian |  | 29.162 |  |
| 3849 | 1066 | **GBAPush enhancements (Generic push layer)** | 533d? | 2008-03-12 A | 2010-03-25 A | 100% | 2008-03-12 | 2010-03-25 | 533d? |  | S3 | 8528h | 8528h | eGBAPush | 23 | Ericsson | Rolf Blom | Rel-9 | 44 | Mirko | eGBAPush | New 33.224 |  |
| 3850 | 1066.1 | SA3 part of eGBAPush (Generic push layer) | 533d? | 2008-03-12 A | 2010-03-25 A | 100% | 2008-03-12 | 2010-03-25 | 533d? | finish no earlier than 2010-03-25 | S3 | 4264h | 4264h | eGBAPush | 21 | Ericsson | Rolf Blom | Rel-9 | 39 | Mirko |  | New 33.224 |  |
| 3851 | 1067 | Extended Identity Management | 136d? | 2009-06-04 A | 2009-12-10 A | 100% | 2009-06-04 | 2009-12-10 | 136d? | finish no earlier than 2009-12-10 | S3 | 1088h | 1088h | GBA-IdM | 23 | Nokia | Silke.Holtmanns@nokia.com | Rel-9 | 44 | Mirko | GBA-IdM | New 33.924, CT4 29.109 (added service code) |  |

Notes:
- 3828: CP#47 completed. Continues Rel-8 SAES Stage 2 UID_320005. Stage 1 in 22.278 (EPS Service requirements)
- 3829: SP#44 completed
- 3830: CP#46 completed
- 3831: CP#47 completed
- 3832: Triggered by RAN2 UID_440013 Vocoder rate adaptation for LTE
- 3833: SP#45 completed (CR adding support for Explicit Congestion Notification)
- 3834: SP#46 completed
- 3835: RP#45 completed
- 3836: SP#57 completed
- 3837: CP#57 completed
- 3838: SP#44 completed. Stopped TR 33.801. CRs 33.102,43.020 on A5/2 removal done long time ago. A5/4 introduction CRs will be done under UID_440057 128 bit encryption for GSM and GPRS. SP#26 approved WID (improved GERAN security)
- 3839: SP#46 TR 33.937 completed but no specification work done in Rel-9. Related work in OMA Categorization Based Content Screening
- 3840: SP#42 completed
- 3841: SP#46 completed. No normative work done in Rel-9
- 3842: -
- 3843: SP#47 completed
- 3844: CP#57 completed, ietf-draft discontinued, documented within 3GPP
- 3845: CP#48 completed
- 3846: CP#47 completed
- 3847: CP#47 completed
- 3848: CP#48 completed
- 3849: SP#43 umbrella to host 33.224, moved from Rel-8 to Rel-9. SP#47 completed
- 3850: SP#47 completed
- 3851: SP#46 completed. Stage 1 not identified (GBA Liberty Interworking has been outlined and GBAOpenID interworking is analogous)

| ID | WBS | Task | Duration | Start | Finish | Complete | Baseline start | Baseline finish | Baseline duration | Constraint | Resources | Work | Actual work | Acronym | PCG approved | WI rapporteur name | Release | TSG approved | MCC resp | Acronym_3GU_Export | PCG stopped | TSG stopped |
| --- | --- | --- | --- | --- | --- | --- | --- | --- | --- | --- | --- | --- | --- | --- | --- | --- | --- | --- | --- | --- | --- | --- |
| 3852 | 1068 | **Network Domain Security (NDS) enhancements to support backhaul security** | 924d? | 2009-06-04 A | 2012-12-07 A | 100% | 2009-06-04 | 2012-12-07 | 924d? |  | S3; IETF | 23452.8h | 23452.8h | NDS_Backhaul | 23 | Vodafone | Rel-9 | 44 | Mirko | NDS_Backhaul |  |  |
| 3853 | 1068.1 | SA3 part of Network Domain Security (NDS) enhancements to support backhaul security | 211d? | 2009-06-04 A | 2010-03-25 A | 100% | 2009-06-04 | 2010-03-25 | 211d? | finish no earlier than 2010-03-25 | S3 | 1688h | 1688h | NDS_Backhaul | 23 | Vodafone | Rel-9 | 44 | Mirko |  |  |  |
| 3854 | 1068.2 | (IETF) SA3 part of Network Domain Security (NDS) enhancements to support backhaul security | 740.6d? | 2009-06-04 A | 2012-12-07 A | 100% | 2009-06-04 | 2012-12-07 | 740.6d? | finish no earlier than 2012-12-07 | S3-IETF | 5924.8h | 5924.8h | NDS_Backhaul | 27 | Bengt Sahlin | Rel-9 | 52 | Mirko |  |  |  |
| 3855 | 1068.3 | Deleted - CT4 part of Network Domain Security (NDS) enhancements to support backhaul security | 132d? | 2009-06-04 A | 2009-12-04 A | 100% | 2009-06-04 | 2009-12-04 | 132d? | finish no earlier than 2009-12-04 | C4 | 1056h | 1056h | NDS_Backhaul | 23 | Vodafone | Rel-9 | 44 | Kimmo |  | PCG-24 | CP-46 |
| 3856 | 1069 | **128 bit encryption for GSM and GPRS** | 136d? | 2009-06-04 A | 2009-12-10 A | 100% | 2009-06-04 | 2009-12-10 | 136d? |  | S3; C1; C4; G2; G3new | 10392h | 10392h | A5/4-GEA4 | 23 | Ericsson | Rel-9 | 44 | Mirko | A5/4-GEA4 |  |  |
| 3857 | 1069.1 | SA3 part of 128 bit encryption for GSM and GPRS | 136d? | 2009-06-04 A | 2009-12-10 A | 100% | 2009-06-04 | 2009-12-10 | 136d? | finish no earlier than 2010-01-06 | S3 | 1088h | 1088h | A5/4-GEA4 | 23 | Ericsson | Rel-9 | 44 | Mirko |  |  |  |
| 3858 | 1069.2 | CT1 part of 128 bit encryption for GSM and GPRS | 77d? | 2009-06-04 A | 2009-09-18 A | 100% | 2009-06-04 | 2009-09-18 | 77d? | start no earlier than 2009-06-04 | C1 | 616h | 616h | A5/4-GEA4 | 23 | Ericsson | Rel-9 | 44 | Frederic |  |  |  |
| 3859 | 1069.3 | CT4 part of 128 bit encryption for GSM and GPRS | 136d? | 2009-06-04 A | 2009-12-10 A | 100% | 2009-06-04 | 2009-12-10 | 136d? | start no earlier than 2009-06-04 | C4 | 1088h | 1088h | A5/4-GEA4 | 23 | Ericsson | Rel-9 | 44 | Kimmo |  |  |  |
| 3860 | 1069.4 | GERAN2 part of 128 bit encryption for GSM and GPRS | 67d? | 2009-06-04 A | 2009-09-04 A | 100% | 2009-06-04 | 2009-09-04 | 67d? | finish no earlier than 2009-09-04 | G2 | 536h | 536h | A5/4-GEA4 | 23 | Ericsson | Rel-9 | 44 | Gert |  |  |  |
| 3861 | 1069.5 | GERAN3new (testing) part of 128 bit encryption for GSM and GPRS | 122d? | 2009-06-04 A | 2009-11-20 A | 100% | 2009-06-04 | 2009-11-20 | 122d? | finish no earlier than 2009-11-20 | G3new | 976h | 976h | A5/4-GEA4 | 23 | Ericsson | Rel-9 | 44 | Ingbert |  |  |  |
| 3862 | 1069.6 | Deleted - SA2 part of 128 bit encryption for GSM and GPRS | 81d? | 2009-06-04 A | 2009-09-24 A | 100% | 2009-06-04 | 2009-09-24 | 81d? | finish no earlier than 2009-09-24 | S2 | 648h | 648h | A5/4-GEA4 | 23 | Ericsson | Rel-9 | 44 | Maurice |  | PCG-23 | SP-45 |
| 3863 | 1070 | Timed Graphics | 337d? | 2008-12-11 A | 2010-03-25 A | 100% | 2008-12-11 | 2010-03-25 | 337d? | finish no earlier than 2010-03-25 | S4 | 2696h | 2696h | TG | 22 | Ericsson | Rel-9 | 42 | Paolo | TG |  |  |
| 3864 | 1071 | Managing MTSI Media Adaptation | 197d? | 2009-03-12 A | 2009-12-10 A | 100% | 2009-03-12 | 2009-12-10 | 197d? | finish no earlier than 2009-12-10 | S4 | 1568h | 1568h | M3A | 22 | Samsung | Rel-9 | 43 | Paolo | M3A |  |  |
| 3865 | 1072 | **PSS and MBMS Aspects** | 272d? | 2009-03-12 A | 2010-03-25 A | 100% | 2009-03-12 | 2010-03-25 | 272d? |  | S4 | 6512h | 6512h | PMA | 23 | Ericsson, Nokia | Rel-9 | 44 | Paolo | PMA |  |  |
| 3866 | 1072.1 | PSS and MBMS extensions | 271d? | 2009-03-12 A | 2010-03-25 A | 100% | 2009-03-12 | 2010-03-25 | 271d? | finish no earlier than 2010-03-25 | S4 | 2168h | 2168h | PMA-MBS_Ext | 22 | Ericsson | Rel-9 | 43 | Paolo | PMA-MBS_Ext |  |  |
| 3867 | 1072.2 | Improved Video Support for PSS and MBMS | 271d? | 2009-03-12 A | 2010-03-25 A | 100% | 2009-03-12 | 2010-03-25 | 271d? | finish no earlier than 2010-03-25 | S4 | 2168h | 2168h | PMA-IVS | 22 | Nokia | Rel-9 | 43 | Paolo | PMA-IVS |  |  |
| 3868 | 1073 | IMS based PSS and MBMS User Service extensions | 197d? | 2009-03-12 A | 2009-12-10 A | 100% | 2009-03-12 | 2009-12-10 | 197d? | finish no earlier than 2009-12-10 | S4 | 1576h | 1576h | IMS_PSS_MBMS_US_EXT | 22 | Ericsson | Rel-9 | 43 | Paolo | IMS_PSS_MBMS_US_EXT |  |  |
| 3869 | 1074 | Syndicated Feed Reception within 3GPP environments | 136d? | 2009-06-04 A | 2009-12-10 A | 100% | 2009-06-04 | 2009-12-10 | 136d? | start no earlier than 2009-06-04 | S4 | 1088h | 1088h | SFR | 23 | Ericsson | Rel-9 | 44 | Paolo | SFR |  |  |
| 3870 | 1075 | Distortion Measurement Test Methods and Requirements | 131d? | 2009-09-24 A | 2010-03-25 A | 100% | 2009-09-24 | 2010-03-25 | 131d? | finish no earlier than 2010-03-25 | S4 | 1048h | 1048h | DTMR | 23 | Motorola | Rel-9 | 45 | Paolo | DTMR |  |  |
| 3871 | 1076 | **Rel-9 Operations, Administration, Maintenance and Provisioning (OAM&P)** | 601d? | 2008-02-22 A | 2010-06-10 A | 100% | 2008-02-22 | 2010-06-10 | 601d? |  | S5 | 36890.4h | 36890.4h | OAM9 | 22 |  | Rel-9 | 42 | Mirko | OAM9 |  |  |
| 3872 | 1076.1 | **Rel-9 Network Infrastructure Management** | 337d? | 2008-12-11 A | 2010-03-25 A | 100% | 2008-12-11 | 2010-03-25 | 337d? |  | S5 | 8760h | 8760h | OAM9-NIM | 22 |  | Rel-9 | 42 | Mirko | OAM9-NIM |  |  |
| 3873 | 1076.1.1 | Software Management for Network Elements | 336d? | 2008-12-11 A | 2010-03-25 A | 100% | 2008-12-11 | 2010-03-25 | 336d? | finish no earlier than 2010-03-25 | S5 | 2688h | 2688h | OAM9-NE_SWM | 22 | Huawei, Nokia Siemens Networks | Rel-9 | 42 | Mirko | OAM9-NE_SWM |  |  |
| 3874 | 1076.1.2 | Service Oriented Architecture (SOA) for IRP | 211d? | 2009-06-04 A | 2010-03-25 A | 100% | 2009-06-04 | 2010-03-25 | 211d? | finish no earlier than 2010-03-25 | S5 | 1688h | 1688h |  | 23 | Ericsson, Nokia Siemens Networks | Rel-9 | 44 | Mirko |  |  |  |
| 3875 | 1076.1.3 | IRP SOAP Solution Sets continuation from Rel-8 | 211d? | 2009-06-04 A | 2010-03-25 A | 100% | 2009-06-04 | 2010-03-25 | 211d? | finish no earlier than 2010-03-25 | S5 | 1688h | 1688h |  | 23 | Ericsson | Rel-9 | 44 | Mirko |  |  |  |

Notes:
- 3852: Continuation of Rel-8 UID_390044 SAE security architecture. Covers gaps in backhaul security in SAE (also applicable to UTRAN and GERAN backhaul) / WI rapporteur e-mail: Peter.Howard@vodafone.com
- 3853: SP#47 completed / Impacted TSs and TRs: 33.102, 33.210, 33.310, 33.401, 33.402 / WI rapporteur e-mail: Peter.Howard@vodafone.com
- 3854: CP#58 completed / Impacted TSs and TRs: RFC 6712 (was draft-ietf-pkix-cmp-transport-protocols)
- 3855: CP#46 completed. No impact on CT4 specs / WI rapporteur e-mail: Peter.Howard@vodafone.com
- 3856: Allow 128 as an alternative to 64 bit keys (Stage 2/3 + Test spec) / WI rapporteur e-mail: Karl Norrman
- 3857: SP#46 completed / Impacted TSs and TRs: 33.102,43.020, New 55.226 / WI rapporteur e-mail: Karl Norrman
- 3858: CP#45 completed / Impacted TSs and TRs: 24.008,44.064 / WI rapporteur e-mail: Karl Norrman
- 3859: CP#46 completed. Kc128 enhancements are carried as UMTS keys => no impact on CT4 29.002, 29.060 / WI rapporteur e-mail: Karl Norrman
- 3860: GP#43 WID approved + completed / Impacted TSs and TRs: 44.018,48.008,48.018,48.058 / WI rapporteur e-mail: Karl Norrman
- 3861: GP#44 completed. GP#43 WID approved / Impacted TSs and TRs: 51.010 / WI rapporteur e-mail: Karl Norrman
- 3862: SP#45 work stopped/abandoned / Impacted TSs and TRs: 23.060 / WI rapporteur e-mail: Karl Norrman
- 3863: SP#47 completed. Provide graphics in parallel to a video stream (without requiring an umbrella scene descriptor such as 3GPP DIMS in TS 26.142) / Impacted TSs and TRs: 26.114, 26.140, 26.234, 26.244, 26.245, 26.346, New 26.430 / WI rapporteur e-mail: clinton.priddle@ericsson.com
- 3864: SP#46 completed. Work extending Rel-8 UID_34041 MTSI Video - Dynamic Rate Adaptation/Signalling of Image Size. Update speech/video adaptation algorithms used by network to control MTSI client terminal in congestion or poor transmission conditions. / Impacted TSs and TRs: 26.114 / WI rapporteur e-mail: kyunghun.jung@samsung.com
- 3865: Umbrella WI / WI rapporteur e-mail: Clinton.Priddle@ericsson.com, imed.bouazizi@nokia.com
- 3866: SP#47 completed. Extends Rel-8 UID_34043 (PSS_MBMS_OMTV) & ensures compatibility with UID_34046 (IMS_PSS_MBMS_US) / Impacted TSs and TRs: 26.234, 26.346 / WI rapporteur e-mail: Clinton.Priddle@ericsson.com
- 3867: SP#47 completed / Impacted TSs and TRs: 26.234, 26.244, 26.346, new 26.903 / WI rapporteur e-mail: imed.bouazizi@nokia.com
- 3868: SP#46 completed. Work extending Rel-8 UID_34046 (IMS_PSS_MBMS_US), SA2 UID_410034 IMSSCC-SPI (IMS Service Continuity Enhancements: Service, Policy and Interactions) / Impacted TSs and TRs: 26.237 / WI rapporteur e-mail: Markus Kampmann
- 3869: SP#46 completed. TS 26.150v100 for Approval. RSS optimized for mobile use. Reuse/reference OMA's enabler DCD. / Impacted TSs and TRs: New 26.150 / WI rapporteur e-mail: Thorsten.Lohmar@ericsson.com
- 3870: SP#47 completed / Impacted TSs and TRs: 26.131, 26.132 / WI rapporteur e-mail: Stephen Kendall (wcsk01@motorola.com)
- 3871: OAM9 is an umbrella Feature also for OAM&P related TEI9 type of changes that are not part of any other dedicated feature/WI / Impacted TSs and TRs: TR 30.819
- 3872: SP#42 umbrella BB created to host OAM WIs
- 3873: SP#47 completed / Impacted TSs and TRs: 32.531, 32.532, 32.533, new 32.537 / WI rapporteur e-mail: Bidipta Das (bidipta@huawei.com), Clemens Suerbaum (clemens.suerbaum@nsn.com)
- 3874: SP#47 completed (covering SOA Architecture & SOA-supporting Solution Set). Triggered by UID_400029 Study on Service Oriented Architecture (SOA) for IRP (TR 32.824) / Impacted TSs and TRs: 32.101, 32.102, 32.150 / WI rapporteur e-mail: edwin.tse@ericsson.com, Jörg Schmidt (joerg@cox.net)
- 3875: SP#47 completed. Continuation of Rel-8 UID_400030 IRP SOAP Solution Sets / Impacted TSs and TRs: New (32.127/ 327/ 337/ 357/ 387/ 397/ 447/ 397/ 447/ 507/ 537), 32.121,32.122,32.123,32,32.321,32.322,32.323,32.325,32.331,32.332,32.333,32.335,32.351,32.352,32.353,32.381,32.382,32.383,32.385,32.391,32.392,32.393,32.395,32.441,32.442,32.443 / WI rapporteur e-mail: John Power

| ID | WBS | Task | Duration | Start | Finish | Complete | Baseline start | Baseline finish | Baseline duration | Constraint | Resources | Work | Actual work | Acronym | PCG approved | Release | TSG approved | MCC resp | Acronym_3GU_Export | Impacted TSs and TRs | WI rapporteur name | Special Focus Doc | PCG stopped | TSG stopped |
| --- | --- | --- | --- | --- | --- | --- | --- | --- | --- | --- | --- | --- | --- | --- | --- | --- | --- | --- | --- | --- | --- | --- | --- | --- |
| 3876 | 1076.2 | **Rel-9 Performance Management** | 327d? | 2009-03-12 A | 2010-06-10 A | 100% | 2009-03-12 | 2010-06-10 | 327d? |  | S5 | 7890.41h | 7890.41h | OAM9-PM | 22 | Rel-9 | 42 | Mirko | OAM9-PM |  |  |  |  |  |
| 3877 | 1076.2.1 | Enhancement of UTRAN Performance Measurements | 136d? | 2009-06-04 A | 2009-12-10 A | 100% | 2009-06-04 | 2009-12-10 | 136d? | start no earlier than 2009-06-04 | S5 | 1088h | 1088h |  | 23 | Rel-9 | 44 | Mirko |  | 32.405 | China Mobile |  |  |  |
| 3878 | 1076.2.2 | Enhancement of E-UTRAN Performance Measurements | 327d? | 2009-03-12 A | 2010-06-10 A | 100% | 2009-03-12 | 2010-06-10 | 327d? | finish no earlier than 2010-06-10 | S5 | 2616h | 2616h |  | 22 | Rel-9 | 43 | Mirko |  | 32.425 | Motorola, Huawei |  |  |  |
| 3879 | 1076.2.3 | Enhancement of EPC Performance Measurements | 197d? | 2009-03-12 A | 2009-12-10 A | 100% | 2009-03-12 | 2009-12-10 | 197d? | finish no earlier than 2010-03-25 | S5 | 1570.41h | 1570.41h |  | 22 | Rel-9 | 43 | Mirko |  | 32.426 | China Mobile |  |  |  |
| 3880 | 1076.3 | **Rel-9 Self-Organizing Networks (SON) - OAM aspects** | 601d? | 2008-02-22 A | 2010-06-10 A | 100% | 2008-02-22 | 2010-06-10 | 601d? |  | S5 | 11736h | 11736h | OAM9-SON | 22 | Rel-9 | 43 | Mirko | OAM9-SON |  |  | SON |  |  |
| 3881 | 1076.3.1 | SON self-optimization management (moved from Rel-8 LTE_SON-OAM) | 600d? | 2008-02-22 A | 2010-06-10 A | 100% | 2008-02-22 | 2010-06-10 | 600d? | finish no earlier than 2010-06-10 | S5 | 4800h | 4800h |  | 21 | Rel-9 | 39 | Mirko |  | 32.425, new (32.521, 32.522, 32.523, 32.525) | Huawei | SON |  |  |
| 3882 | 1076.3.2 | Automatic Radio Network Configuration Data Preparation | 266d? | 2009-06-04 A | 2010-06-10 A | 100% | 2009-06-04 | 2010-06-10 | 266d? | finish no earlier than 2010-06-10 | S5 | 2128h | 2128h |  | 23 | Rel-9 | 44 | Mirko |  | 32.501, 32.502, 32.503, 32.505, new 32.507 | Nokia Siemens Networks | SON |  |  |
| 3883 | 1076.4 | Rel-9 Subscription Management (SuM) evolution | 266d? | 2009-06-04 A | 2010-06-10 A | 100% | 2009-06-04 | 2010-06-10 | 266d? | finish no earlier than 2010-06-10 | S5 | 2128h | 2128h | OAM9-SuM | 23 | Rel-9 | 44 | Mirko | OAM9-SuM | 32.140, 32.141, 32.152, 32.172, 32.175 | Ericsson |  |  |  |
| 3884 | 1076.5 | Deleted - Rel-9 Trace | 196d? | 2009-03-13 A | 2009-12-10 A | 100% | 2009-03-13 | 2009-12-10 | 196d? | finish no earlier than 2009-12-10 | S5 | 1568h | 1568h | OAM9-Trace | 22 | Rel-9 | 42 | Mirko | OAM9-Trace |  |  |  | PCG-24 | SP-46 |
| 3885 | 1077 | Rel-9 Charging Management small Enhancements | 211d? | 2009-06-04 A | 2010-03-25 A | 100% | 2009-06-04 | 2010-03-25 | 211d? |  | S5 | 1688h | 1688h | CH9 | 23 | Rel-9 | 44 | Mirko | CH9 | TR 30.819 |  |  |  |  |
| 3886 | 1078 | **CS-IBCF and CS-TrGW definition in 3GPP specifications** | 472d? | 2008-05-30 A | 2010-03-19 A | 100% | 2008-05-30 | 2010-03-19 | 472d? |  | C3; C4 | 14490.3h | 14490.3h | CS-IBCF | 21 | Rel-9 | 40 | Adrian | CS-IBCF |  | Telecom Italia |  |  |  |
| 3887 | 1078.1 | CT3 aspects of CS-IBCF and CS-TrGW definition in 3GPP specifications | 472d? | 2008-05-30 A | 2010-03-19 A | 100% | 2008-05-30 | 2010-03-19 | 472d? | finish no earlier than 2009-12-04 | C3 | 3770.34h | 3770.34h | CS-IBCF | 21 | Rel-9 | 40 | Adrian |  | 29.235 | Telecom Italia |  |  |  |
| 3888 | 1078.2 | CT4 aspects of CS-IBCF and CS-TrGW definition in 3GPP specifications | 396d? | 2008-05-30 A | 2009-12-04 A | 100% | 2008-05-30 | 2009-12-04 | 396d? | finish no earlier than 2009-12-04 | C4 | 3168h | 3168h | CS-IBCF | 21 | Rel-9 | 40 | Kimmo |  | 23.231, 29.232, new 29.238 | Telecom Italia |  |  |  |
| 3889 | 1079 | **IMS – Interconnection Border Control Function (IBCF) – Transition Gateway (TrGW); Ix Interface; Stage 3** | 322d? | 2008-09-12 A | 2009-12-04 A | 100% | 2008-09-12 | 2009-12-04 | 322d? |  | C4; C3 | 10086.4h | 10086.4h | IMS_IBCF | 21 | Rel-9 | 41 | Kimmo | IMS_IBCF |  | Alcatel-Lucent |  |  |  |
| 3890 | 1079.1 | CT4 part of IMS – Interconnection Border Control Function (IBCF) – Transition Gateway (TrGW); Ix Interface; Stage 3 | 321d? | 2008-09-12 A | 2009-12-04 A | 100% | 2008-09-12 | 2009-12-04 | 321d? | finish no earlier than 2009-12-04 | C4 | 2568h | 2568h | IMS_IBCF | 21 | Rel-9 | 41 | Kimmo |  | new 29.238 | Alcatel-Lucent |  |  |  |
| 3891 | 1079.2 | CT3 part of IMS – Interconnection Border Control Function (IBCF) – Transition Gateway (TrGW); Ix Interface; Stage 3 | 295.8d? | 2008-09-12 A | 2009-12-04 A | 100% | 2008-09-12 | 2009-12-04 | 295.8d? | finish no earlier than 2010-03-19 | C3 | 2366.4h | 2366.4h | IMS_IBCF | 21 | Rel-9 | 41 | Adrian |  | 29.162, 29.235 | Alcatel-Lucent |  |  |  |
| 3892 | 1080 | IMS Application Level Gateway Control Function (ALGCF) – IMS Access Media Gateway (IMA-MGW); Iq Interface; Stage 2 and Stage 3 | 321d? | 2008-09-12 A | 2009-12-04 A | 100% | 2008-09-12 | 2009-12-04 | 321d? | finish no earlier than 2009-12-04 | C4 | 2568h | 2568h | IMS_AGCF | 21 | Rel-9 | 41 | Kimmo | IMS_AGCF | New 23.334, 29.334 | Alcatel-Lucent |  |  |  |
| 3893 | 1081 | **Enhancements of IMS Customized Alerting Tone (CAT) Service** | 392d? | 2008-12-05 A | 2010-06-04 A | 100% | 2008-12-05 | 2010-06-04 | 392d? |  | C1 | 5846.4h | 5846.4h | eCAT | 22 | Rel-9 | 42 | Frederic | eCAT |  | China Mobile |  |  |  |
| 3894 | 1081.1 | Stage 3 for Enhancements of IMS Customized Alerting Tone (CAT) Service | 391d? | 2008-12-05 A | 2010-06-04 A | 100% | 2008-12-05 | 2010-06-04 | 391d? | finish no earlier than 2010-06-04 | C1 | 3128h | 3128h | eCAT-SS | 22 | Rel-9 | 42 | Frederic | eCAT-SS | 24.182 | China Mobile |  |  |  |
| 3895 | 1082 | **Completion of IMS Restoration Procedures** | 212d? | 2009-05-29 A | 2010-03-19 A | 100% | 2009-05-29 | 2010-03-19 | 212d? |  | C3; C4; C1 | 10176h | 10176h | eIMS_RP | 23 | Rel-9 | 44 | Kimmo | eIMS_RP |  | Ericsson |  |  |  |
| 3896 | 1082.1 | CT4 aspects of Completion of IMS Restoration Procedures | 212d? | 2009-05-29 A | 2010-03-19 A | 100% | 2009-05-29 | 2010-03-19 | 212d? | finish no earlier than 2010-03-19 | C4 | 1696h | 1696h | eIMS_RP | 23 | Rel-9 | 44 | Kimmo |  | 23.380, 23.820 | Ericsson |  |  |  |
| 3897 | 1082.2 | CT1 aspects of Completion of IMS Restoration Procedures | 212d? | 2009-05-29 A | 2010-03-19 A | 100% | 2009-05-29 | 2010-03-19 | 212d? | finish no earlier than 2010-03-19 | C1 | 1696h | 1696h | eIMS_RP | 23 | Rel-9 | 44 | Kimmo |  | 24.229 | Ericsson |  |  |  |
| 3898 | 1082.3 | CT3 aspects of Completion of IMS Restoration Procedures | 212d? | 2009-05-29 A | 2010-03-19 A | 100% | 2009-05-29 | 2010-03-19 | 212d? | finish no earlier than 2010-03-19 | C3 | 1696h | 1696h | eIMS_RP | 24 | Rel-9 | 46 | Kimmo |  | 29.061, 29.212, 29.213, 29.214, 29.215 | Ericsson |  |  |  |
| 3899 | 1083 | **IMS Stage 3 IETF Protocol Alignment - phase 3** | 1458d? | 2009-05-29 A | 2014-12-05 A | 100% | 2009-05-29 | 2014-12-05 | 1455d? |  | C1; IETF | 40216h | 40216h | IMSProtoc3 | 23 | Rel-9 | 44 | Frederic | IMSProtoc3 |  | Alcatel-Lucent |  |  |  |
| 3900 | 1083.1 | CT1 aspects of IMS Stage 3 - IETF Protocol Alignment - phase 3 | 212d? | 2009-05-29 A | 2010-03-19 A | 100% | 2009-05-29 | 2010-03-19 | 212d? | finish no earlier than 2010-03-19 | C1 | 1696h | 1696h | IMSProtoc3 | 23 | Rel-9 | 44 | Frederic |  | 23.218, 24.229, 24.930 | Alcatel-Lucent |  |  |  |
| 3901 | 1083.2 | (IETF) CT1 IMS Stage 3 - IETF Protocol Alignment (RFC 7329) | 1242d? | 2009-05-29 A | 2014-12-05 A | 100% | 2009-05-29 | 2014-12-05 | 1240d? | finish no earlier than 2014-12-09 | C1-IETF | 9936h | 9936h | IMSProtoc3 | 27 | Rel-9 | 52 | Frederic |  | RFC 7329 (was draft-kaplan-insipid-session-id) | christer.holmberg@ericsson.com |  |  |  |
| 3902 | 1083.3 | (IETF) CT1 IMS Stage 3 - IETF Protocol Alignment (RFC 7044) | 659d? | 2011-09-13 A | 2014-03-07 A | 100% | 2011-09-13 | 2014-03-07 | 659d? | finish no earlier than 2014-02-10 | C1-IETF | 5256h | 5256h | IMSProtoc3 | 27 | Rel-9 | 53 | Frederic |  | RFC 7044 (was draft-ietf-sipcore-rfc4244bis) | christer.holmberg@ericsson.com |  |  |  |

Notes:
- 3876: SP#42 umbrella BB created to host OAM WIs
- 3877: SP#46 completed / WI rapporteur e-mail: liangshuangchun@cmdi.chinamobile.com, lijian@chinamobile.com, Bao Haitao
- 3878: SP#48 completed / WI rapporteur e-mail: Yizhi Yao (yzyao@motorola.com),Lan Zou (zlan@huawei.com)
- 3879: SP#46 completed / WI rapporteur e-mail: Li Jian (lijian@chinamobile.com), Liang Shuangchun (liangshuangchun@cmdi.chinamobile.com)
- 3880: SP#43 umbrella BB created to host OAM WIs
- 3881: SP#48 completed / WI rapporteur e-mail: Lan Zou (zlan@huawei.com)
- 3882: SP#48 completed / WI rapporteur e-mail: clemens.suerbaum@nsn.com
- 3883: SP#48 completed / WI rapporteur e-mail: frode.nergard@ericsson.com
- 3884: SP#46 stopped (no work in Rel-9)
- 3885: CH9 is an umbrella Feature also for OAM&P related TEI9 type of changes that are not part of any other dedicated feature/WI
- 3886: CP#47 completed. Rel-8 UID_380061 (Ipinterc) covers Stage 1 in SA1 22.101, 22.228 / WI rapporteur e-mail: mauro.ficaccio@telecomitalia.it
- 3887: CP#47 completed / WI rapporteur e-mail: mauro.ficaccio@telecomitalia.it
- 3888: CP#46 completed / WI rapporteur e-mail: mauro.ficaccio@telecomitalia.it
- 3889: CP#46 completed / WI rapporteur e-mail: bruno.landais@alcatel-lucent.fr
- 3890: CP#46 completed / WI rapporteur e-mail: bruno.landais@alcatel-lucent.fr
- 3891: CP#46 completed / WI rapporteur e-mail: bruno.landais@alcatel-lucent.fr
- 3892: CP#46 completed / WI rapporteur e-mail: bruno.landais@alcatel-lucent.fr
- 3893: CP#48 completed. Stage 1 in 22.182 / WI rapporteur e-mail: Jiang Yi
- 3894: CP#48 completed / WI rapporteur e-mail: Jiang Yi
- 3895: CP#47 completed. Continuation of Rel-8 Feature UID_400012 IMS Restoration Procedures / WI rapporteur e-mail: Emiliano Merino (emiliano.merino@ericsson.com)
- 3896: CP#47 completed / WI rapporteur e-mail: Emiliano Merino (emiliano.merino@ericsson.com)
- 3897: CP#47 completed / WI rapporteur e-mail: Emiliano Merino (emiliano.merino@ericsson.com)
- 3898: CP#47 completed / WI rapporteur e-mail: Emiliano Merino (emiliano.merino@ericsson.com)
- 3899: CP#47 completed / WI rapporteur e-mail: Keith Drage (drage@alcatel-lucent.com)
- 3900: CP#47 completed / WI rapporteur e-mail: Keith Drage (drage@alcatel-lucent.com)
- 3901: CP#65 completed / WI rapporteur e-mail: christer.holmberg@ericsson.com
- 3902: CP#63 completed / WI rapporteur e-mail: christer.holmberg@ericsson.com

| ID | WBS | Task | Type | Duration | Start | Finish | Complete | Baseline start | Baseline finish | Baseline duration | Constraint | Resources | Work | Actual work | Acronym | PCG approved | WI rapporteur name | WI rapporteur e-mail | Release | TSG approved | MCC resp | Acronym_3GU_Export | TSG stopped | Special Focus Doc | Status Report |
| --- | --- | --- | --- | --- | --- | --- | --- | --- | --- | --- | --- | --- | --- | --- | --- | --- | --- | --- | --- | --- | --- | --- | --- | --- | --- |
| 3903 | 1084 | **Operational description of the Inter-IMS Network to Network Interface (II-NNI)** |  | 1460d? | 2009-05-29 A | 2014-12-09 A | 100% | 2009-05-29 | 2014-12-05 | 1455d? |  | C3; IETF | 58408h | 58408h | II-NNI | 23 | Orange | sebastien.daudet@orange-ftgroup.com | Rel-9 | 44 | Adrian | II-NNI |  |  |  |
| 3904 | 1084.1 | Operational description of the Inter-IMS Network to Network Interface |  | 267d? | 2009-05-29 A | 2010-06-04 A | 100% | 2009-05-29 | 2010-06-04 | 267d? | start no earlier than 2009-05-29 | C3 | 2136h | 2136h | II-NNI | 23 | Orange |  | Rel-9 | 44 | Adrian |  |  |  |  |
| 3905 | 1084.2 | (IETF) Operational description of the Inter-IMS Network to Network Interface (RFC 7329) |  | 633d? | 2012-04-20 A | 2014-09-12 A | 100% | 2012-04-20 | 2014-12-05 | 693d? | finish no earlier than 2014-09-12 | C3-IETF | 5040h | 5040h | II-NNI | 29 | christer.holmberg@ericsson.com | christer.holmberg@ericsson.com | Rel-9 | 56 | Adrian |  |  |  |  |
| 3906 | 1084.3 | (IETF) Operational description of the Inter-IMS Network to Network Interface (RFC 7316) |  | 634d? | 2012-04-20 A | 2014-09-12 A | 100% | 2012-04-20 | 2014-12-05 | 694d? | finish no earlier than 2014-12-09 | C3-IETF | 5064h | 5064h | II-NNI | 29 | Keith Drage | Keith Drage | Rel-9 | 56 | Adrian |  |  |  |  |
| 3907 | 1084.4 | (IETF) Operational description of the Inter-IMS Network to Network Interface |  | 696d? | 2012-04-20 A | 2014-12-09 A | 100% | 2012-04-20 | 2014-12-05 | 694d? | finish no earlier than 2014-12-09 | C3-IETF | 5560h | 5560h | II-NNI | 29 | Roland Jesske | Roland Jesske | Rel-9 | 56 | Adrian |  |  |  |  |
| 3908 | 1084.5 | (IETF) Operational description of the Inter-IMS Network to Network Interface |  | 696d? | 2012-04-20 A | 2014-12-09 A | 100% | 2012-04-20 | 2014-12-05 | 694d? | finish no earlier than 2014-12-09 | C3-IETF | 5536h | 5536h | II-NNI | 29 | Roland Jesske | Roland Jesske | Rel-9 | 56 | Adrian |  |  |  |  |
| 3909 | 1084.6 | (IETF) Operational description of the Inter-IMS Network to Network Interface |  | 697d? | 2012-04-20 A | 2014-12-09 A | 100% | 2012-04-20 | 2014-12-05 | 695d? | finish no earlier than 2014-12-09 | C3-IETF | 5560h | 5560h | II-NNI | 29 | Keith Drage | Keith Drage | Rel-9 | 56 | Adrian |  |  |  |  |
| 3910 | 1084.7 | Deleted - (IETF) Operational description of the Inter-IMS Network to Network Interface |  | 433d? | 2012-04-20 A | 2013-12-06 A | 100% | 2012-04-20 | 2014-12-05 | 694d? | finish no earlier than 2013-12-06 | C3-IETF | 3456h | 3456h | II-NNI | 29 | Peter Dawes | peter.dawes@vodafone.com | Rel-9 | 56 | Adrian |  | SP-69 |  |  |
| 3911 | 1084.8 | Deleted - (IETF) Operational description of the Inter-IMS Network to Network Interface (avasarala-dispatch-comm-div-notification) |  | 340d? | 2013-03-01 A | 2014-06-13 A | 100% | 2013-03-01 | 2014-06-13 | 340d? | finish no earlier than 2014-06-13 | C3-IETF | 2696h | 2696h | II-NNI | 30 | Andrew Allen | Andrew Allen | Rel-9 | 59 | Adrian |  | SP-69 |  |  |
| 3912 | 1085 | Definition of Ml interface for Control Plane LCS (Stage 3) |  | 131d? | 2009-09-18 A | 2010-03-19 A | 100% | 2009-09-18 | 2010-03-19 | 131d? | finish no earlier than 2010-03-19 | C1 | 1048h | 1048h | EMC2 | 23 | Alcatel-Lucent | Keith Drage (drage@alcatel-lucent.com) | Rel-9 | 45 | Frederic | EMC2 |  | Public Safety (I-A) |  |
| 3913 | 1086 | PCC enhancements |  | 56d? | 2009-09-18 A | 2009-12-04 A | 100% | 2009-09-18 | 2009-12-04 | 56d? | finish no earlier than 2009-12-04 | C3 | 448h | 448h | PCC-Enh | 23 | Huawei | Wei Weihua (weiwh@huawei.com) | Rel-9 | 45 | Adrian | PCC-Enh |  |  |  |
| 3914 | 1087 | 3GPP IMS Conferencing Management Object (MO) |  | 2d? | 2009-12-03 A | 2009-12-04 A | 100% | 2009-12-03 | 2009-12-04 | 2d? | start no earlier than 2009-12-03 | C1 | 16h | 16h | IMS_ConfMO | 24 |  |  | Rel-9 | 46 | Frederic | IMS_ConfMO |  |  |  |
| 3915 | 1088 | In Case of Emergency (ICE) Graphics |  | 3d? | 2010-03-17 A | 2010-03-19 A | 100% | 2010-03-17 | 2010-03-19 | 3d? | finish no earlier than 2010-03-19 | C6 | 24h | 24h | ICE_Graphics | 24 | Sagem-Orga | heiko.kruse@sagem-orga.com | Rel-9 | 47 | Xavier | ICE_Graphics |  |  |  |
| 3916 | 1089 | **Rel-9 Improvements of the Radio Interface** |  | 397d? | 2008-09-12 A | 2010-03-19 A | 100% | 2008-09-12 | 2010-03-19 | 397d? |  | RP; GP | 19744h | 19744h | RInImp9 | 21 |  |  | Rel-9 | 41 | Issam | RInImp9 |  |  |  |
| 3917 | 1089.1 | LCR TDD UE OTA Performance Requirements |  | 186d? | 2008-09-12 A | 2009-05-29 A | 100% | 2008-09-12 | 2009-05-29 | 186d? | finish no earlier than 2009-05-29 | R4 | 1488h | 1488h | RInImp9-RFLCROTA | 21 | RITT | Wu Xiang (wuxiang@chinattl.com) | Rel-9 | 41 | Issam | RInImp9-RFLCROTA |  |  | RP-090389 |
| 3918 | 1089.2 | **RF requirements for Multicarrier and Multi-RAT BS** |  | 347d? | 2008-11-21 A | 2010-03-19 A | 100% | 2008-11-21 | 2010-03-19 | 347d? |  | R4; G1 | 10336h | 10336h | RInImp9-RFmulti | 21 | Ericsson | Johan.skold@ericsson.com | Rel-9 | 41 | Issam | RInImp9-RFmulti |  |  |  |
| 3919 | 1089.2.1 | RAN4 part of RF requirements for Multicarrier and Multi RAT BS |  | 337d? | 2008-12-05 A | 2010-03-19 A | 100% | 2008-12-05 | 2010-03-19 | 337d? | finish no earlier than 2010-03-19 | R4 | 2696h | 2696h | RInImp9-Rfmulti | 22 | Ericsson | johan.skold@ericsson.com | Rel-9 | 42 | Issam |  |  |  | RP-100027 |
| 3920 | 1089.2.2 | GERAN part of RF requirements for Multicarrier and Multi RAT BS |  | 261d? | 2008-11-21 A | 2009-11-20 A | 100% | 2008-11-21 | 2009-11-20 | 261d? | finish no earlier than 2009-11-20 | G1 | 2088h | 2088h | RInImp9-RFmulti-GERAN | 22 | Ericsson | mats.y.samuelsson@ericsson.com | Rel-9 | 40 | Paolo | RInImp9-RFmulti-GERAN |  |  |  |
| 3921 | 1089.3 | Extended UMTS/LTE 800 MHz | milestone | 0d? | 2008-12-05 A | 2008-12-05 A | 100% | 2008-12-05 | 2009-09-18 | 207d? |  | R4; R2; R3 |  |  | RInImp9-UMTSLTE800 | 22 | NTT DoCoMo | Shingo Suwa (suwas@nttdocomo.co.jp) | Rel-9 | 42 | Issam | RInImp9-UMTSLTE800 |  |  | RP-090687 |
| 3922 | 1089.4 | UMTS/LTE 800 MHz for Europe | milestone | 0d? | 2009-03-06 A | 2009-03-06 A | 100% | 2009-03-06 | 2010-03-19 | 272d? | finish no earlier than 2010-03-19 | R4; R2; R3 |  |  | RInImp9-UMTSLTE800EU | 22 | Ericsson | olav.queseth@ericsson.com | Rel-9 | 43 | Issam | RInImp9-UMTSLTE800EU |  |  | RP-100028 |
| 3923 | 1089.5 | Performance requirement for LCR TDD with UE speeds up to 350 km/h |  | 196d? | 2009-03-06 A | 2009-12-04 A | 100% | 2009-03-06 | 2009-12-04 | 196d? | finish no earlier than 2009-12-04 | R4 | 1568h | 1568h | RInImp9-LCRTDD350 | 22 | CATT | Yuexia Song (songyuexia@catt.cn) | Rel-9 | 43 | Issam | RInImp9-LCRTDD350 |  |  | RP-091035 |
| 3924 | 1089.6 | Extended UMTS/LTE 1500 MHz | milestone | 0d? | 2009-05-30 A | 2009-05-30 A | 100% | 2009-05-30 | 2010-03-19 | 211d? | finish no earlier than 2010-03-19 | R4; R2; R3 |  |  | UMTSLTE1500 | 23 | NTT DoCoMo | Shingo Suwa (suwas@nttdocomo.co.jp) | Rel-9 | 44 | Issam | UMTSLTE1500 |  |  | RP-100029 |
| 3925 | 1090 | **Rel-9 Improvements of the Radio Interface - UE Conformance Testing** |  | 350d? | 2009-05-19 A | 2010-09-17 A | 100% | 2009-05-19 | 2010-09-17 | 350d? |  | R5 | 8184h | 8184h |  | 23 |  |  | Rel-9 | 44 | Ingbert |  |  |  |  |
| 3926 | 1090.1 | Conformance Test Aspects – UMTS/LTE in 800 MHz for Europe |  | 350d? | 2009-05-19 A | 2010-09-17 A | 100% | 2009-05-19 | 2010-09-17 | 350d? | finish no earlier than 2010-09-17 | R5 | 2800h | 2800h | RInImp-UEConTest-UMTSLTE800EU | 23 | Ericsson | fredrik.sundstrom@ericsson.com | Rel-9 | 44 | Ingbert | RInImp-UEConTest-UMTSLTE800EU |  |  | RP-100736 |
| 3927 | 1090.2 | Conformance Test Aspects – Extended UMTS/LTE 1500 MHz |  | 186d? | 2009-09-18 A | 2010-06-04 A | 100% | 2009-09-18 | 2010-06-04 | 186d? | finish no earlier than 2010-06-04 | R5 | 1488h | 1488h | UMTSLTE1500_UEConTest | 23 | NTT DoCoMo | Nguyen Dung Dao (dao@nttdocomo.co.jp) | Rel-9 | 45 | Ingbert | UMTSLTE1500_UEConTest |  |  | RP-100487 |
| 3928 | 1090.3 | TDD UE Over The Air (Antenna) conformance testing methodology |  | 81d? | 2009-05-30 A | 2009-09-18 A | 100% | 2009-05-30 | 2009-09-18 | 81d? | finish no earlier than 2009-09-18 | R5 | 648h | 648h | UEAnt_TDDTest | 23 | CATR | Qu Yan (quyan@emcite.com) | Rel-9 | 44 | Ingbert | UEAnt_TDDTest |  |  | RP-090727 |
| 3929 | 1090.4 | Conformance Test Aspects – Performance requirement for LCR TDD with UE speeds up to 350 km/h |  | 56d? | 2010-03-19 A | 2010-06-04 A | 100% | 2010-03-19 | 2010-06-04 | 56d? | finish no earlier than 2010-06-04 | R5 | 448h | 448h | RInImp9-LCRTDD350_UEConTest | 24 | CATT | Xiaozhong Chen (chexiaozhong@datangmobile.cn) | Rel-9 | 47 | Ingbert | RInImp9-LCRTDD350_UEConTest |  |  | RP-100496 |
| 3930 | 1091 | Conformance Test Aspects – SMS over IMS in E-UTRAN |  | 131d? | 2009-09-18 A | 2010-03-19 A | 100% | 2009-09-18 | 2010-03-19 | 131d? | finish no earlier than 2010-06-18 | R5 | 1048h | 1048h | SMSoverIMS_UEConTest | 23 | Alcatel-Lucent | Nidal Khrais (khrais@alcatel-lucent.com) | Rel-9 | 45 | Ingbert | SMSoverIMS_UEConTest |  |  | RP-100072 |

Notes:
- 3903: -
- 3904: CP#48 completed / Impacted TSs and TRs: 29.165
- 3905: CP#65 complete / Impacted TSs and TRs: RFC 7329 (was draft-kaplan-insipid-session-id)
- 3906: CP#65 complete / Impacted TSs and TRs: RFC 7316 (was draft-vanelburg-dispatch-private-network-ind)
- 3907: In RFC Editors Queue. Dec.14: 75->90; 7/3/16: 90%->100 / Impacted TSs and TRs: draft-ietf-salud-alert-info-urns
- 3908: In RFC Editors Queue. Mar15: 90->100%. RFC updated (was draft-ietf-cuss-sip-uui). Jun 15: RFC 7433 (was draft-ietf-cuss-sip-uui) / Impacted TSs and TRs: RFC 7433
- 3909: In RFC Editors Queue. Dec.14: 75->90. Mar15: 90->100%. RFC updated (was draft-ietf-cuss-sip-uui-isdni). June 15: RFC 7434 (was draft-ietf-cuss-sip-uui-isdn) / Impacted TSs and TRs: RFC 7434
- 3910: CP#62 removed from Rel-8 to Rel-11. Not completed internet-draft / Impacted TSs and TRs: Rel-12 remains draft-dawes-sipping-debug
- 3911: CP#64 Draft removed from 3GPP documentation / Impacted TSs and TRs: draft-avasarala-dispatch-comm-div-notification
- 3912: CP#47 completed [Stage 3 for Rel-7 Emergency Calls (EMC1)]. Related to Rel-9 UID_400038 LCS Control Plane Solution for EPS. Stage 2 in Rel-9 UID_400038 (23.271), UID_410037 (23.167) / Impacted TSs and TRs: 24.229
- 3913: CP#46 completed / Impacted TSs and TRs: 29.212, 29.213, 29.215
- 3914: CP#46 completed. Linked to Rel-6 UID_11051 (IMS Management objects) under the Feature UID_32021 (IMS Phase 2). MO compatible with OMA DM v1.2 & upwards and defined using OMA DM Device Description Framework (OMA-ERELD _DM-V1_2) / Impacted TSs and TRs: New 24.166
- 3915: CP#47 approved WID and completed. Added capability to store ICE graphical information (picture). Linked to CT6 Rel-8 ICE Feature UID_380059 In Case of Emergency numbers storage and easy access on UICC / Impacted TSs and TRs: 31.102 CR#0433
- 3916: RP#41 umbrella Feature created to host Rel-9 WIs / Impacted TSs and TRs: GERAN, UTRA, LTE
- 3917: RP#44 completed technical work (RAN4 internal TR abandoned) / Impacted TSs and TRs: UTRA (no TR 25.8xy produced)
- 3918: RP#47 completed. RF requirements specification applicable to Multi-Standard Radio (MSR) Base Station with multiple carriers and/or multiple 3GPP Radio Access Technologies (RAT) / Impacted TSs and TRs: GERAN, UTRA, LTE
- 3919: RP#48 completed / Impacted TSs and TRs: UTRA, LTE 25.104, 25.105, 36.104, new 37.104, 37.113, 37.141, 37.900
- 3920: GP#44 Core spec completed. GP#40 WID approved / Impacted TSs and TRs: GERAN 45.005, 51.021
- 3921: RP#45 completed / Impacted TSs and TRs: UTRA, LTE 25.101, 25.104, 25.113, 25.133, 34.124, 36.101, 36.104, 36.113, 36.124, 36.133, 36.141, 25.306, 25.307, 25.331, 36.331, 25.461, 25.466, new 36.800
- 3922: RP#47 completed / Impacted TSs and TRs: UTRA, LTE 25.101, 25.104, 25.113, 25.133, 25.141, 34.124, 36.101, 36.104, 36.113, 36.124, 36.133, 36.141, new 36.810, 25.306, 25.307, 25.331, 36.331, 25.461, 25.466
- 3923: RP#46 completed / Impacted TSs and TRs: UTRA 25.102, 25.105, 25.142
- 3924: RP#47 completed. For potential deployment in Japan / Impacted TSs and TRs: UTRA, LTE 25.101, 25.104, 25.113, 25.133, 25.141, 25.306, 25.307, 25.331, 25.461, 25.466, 34.124, 36.101, 36.104, 36.113, 36.124, 36.133, 36.141, 36.331, new (36.821, 36.307)
- 3925: - / Impacted TSs and TRs: UTRA, LTE
- 3926: RP#49 completed. Testing for UID_430009 UMTS/LTE 800 MHz for Europe / Impacted TSs and TRs: UTRA, LTE 34.108, 34.121-1, 34.121-2, 36.508, 36.521-1, 36.521-2, 36.521-3
- 3927: RP#48 completed / Impacted TSs and TRs: UTRA, LTE 34.108, 34.121-1, 34.121-2, 34.123-1, 34.123-2, 36.508, 36.521-1, 36.521-2, 36.521-3, 36.523-1, 36.523-2, 36.523-3
- 3928: RP#45 completed. Finalized TDD UE test methodology based on R4 TR 25.914 (UE and MS antenna performance evaluation method) and TS 25.144 Over the Air (Antenna) minimum performance requirements for the speech mode (terminal close to head) / Impacted TSs and TRs: UTRA 34.114
- 3929: RP#48 completed. Testing for UID_430010 Performance requirement for LCR TDD with UE speeds up to 350 km/h / Impacted TSs and TRs: UTRA 34.122
- 3930: RP#47 completed / Impacted TSs and TRs: LTE 34.229-1, 34.229-2, 34.229-3

| ID | WBS | Task | Type | Duration | Start | Finish | Complete | Baseline start | Baseline finish | Baseline duration | Constraint | Resources | Work | Actual work | PCG approved | Release | TSG approved | MCC resp | Acronym | WI rapporteur name | WI rapporteur e-mail | Status Report | Acronym_3GU_Export | Special Focus Doc |
| --- | --- | --- | --- | --- | --- | --- | --- | --- | --- | --- | --- | --- | --- | --- | --- | --- | --- | --- | --- | --- | --- | --- | --- | --- |
| 3931 | 1092 | **Rel-9 RAN improvements** |  | 395d? | 2009-03-06 A | 2010-09-08 A | 100% | 2000-01-03 | 2010-03-19 | 2667d? |  | RP | 12640h | 12640h | 22 | Rel-9 | 43 | Issam |  |  |  |  |  |  |
| 3932 | 1092.1 | Dual-Cell HSUPA | milestone | 0d? | 2009-03-06 A | 2009-03-06 A | 100% | 2009-03-06 | 2010-03-19 | 272d? | finish no earlier than 2010-03-19 | R1; R2; R3; R4 |  |  | 22 | Rel-9 | 43 | Patrick | RANimp-DC_HSUPA | Nokia Siemens Networks | Karri Ranta-aho (karri.ranta-aho@nsn.com) | RP-100030 | RANimp-DC_HSUPA |  |
| 3933 | 1092.2 | Support for different bands for Dual-Cell HSDPA | milestone | 0d? | 2009-03-06 A | 2009-03-06 A | 100% | 2009-03-06 | 2009-12-04 | 197d? |  | R4; R2; R3 |  |  | 22 | Rel-9 | 43 | Issam | RANimp-MultiBand_DC_HSDPA | Nokia Siemens Networks | Tuomo Säynäjäkangas (tuomo.saynajakangas@nsn.com) | RP-091038 | RANimp-MultiBand_DC_HSDPA |  |
| 3934 | 1092.3 | Combination of DC-HSDPA with MIMO | milestone | 0d? | 2009-03-06 A | 2009-03-06 A | 100% | 2009-03-06 | 2009-12-04 | 197d? |  | R1; R2; R3; R4 |  |  | 22 | Rel-9 | 43 | Patrick | RANimp-DC_MIMO | Ericsson | johan.bergman@ericsson.com | RP-091039 | RANimp-DC_MIMO |  |
| 3935 | 1092.4 | Transmit Antenna Array (TxAA) extension for non-MIMO UEs | milestone | 0d? | 2009-03-06 A | 2009-03-06 A | 100% | 2009-03-06 | 2009-12-04 | 197d? |  | R1; R2; R3; R4 |  |  | 22 | Rel-9 | 43 | Patrick | RANimp-TxAA_nonMIMO | Nokia | Arto Lehti (arto.lehti@nokia.com) | RP-091040 | RANimp-TxAA_nonMIMO |  |
| 3936 | 1092.5 | Cell Portion for 1.28 Mcps TDD |  | 395d? | 2009-03-06 A | 2010-09-08 A | 100% | 2000-01-03 | 2000-07-07 | 136d? | finish no earlier than 2009-03-06 | R3; R1; R4 | 9480h | 9480h | 23 | Rel-9 | 44 | Juha | CP_LCRTDD | CATT | Ying Zhang (zhangying2@datangmobile.cn) | RP-091041 | CP_LCRTDD |  |
| 3937 | 1093 | **Rel-9 RAN improvements - UE Conformance Testing** |  | 588d? | 2010-09-17 A | 2012-12-07 A | 100% | 2010-09-17 | 2012-12-07 | 588d? |  | R5 | 11848h | 11848h | 25 | Rel-9 | 49 | Ingbert |  |  |  |  |  |  |
| 3938 | 1093.1 | Conformance Test Aspects – Combination of DC-HSDPA with MIMO |  | 186d? | 2010-09-17 A | 2011-06-03 A | 100% | 2010-09-17 | 2011-06-03 | 186d? | finish no earlier than 2011-06-03 | R5 | 1488h | 1488h | 25 | Rel-9 | 49 | Ingbert | RANimp-DC_MIMO_UEConTest | Ericsson | leif.mattisson@ericsson.com | RP-110510 | RANimp-DC_MIMO_UEConTest |  |
| 3939 | 1093.2 | Conformance Test Aspects – Dual-Cell HSUPA |  | 453d? | 2011-03-18 A | 2012-12-07 A | 100% | 2011-03-18 | 2012-12-07 | 453d? | finish no earlier than 2012-12-07 | R5 | 3624h | 3624h | 26 | Rel-9 | 51 | Ingbert | RANimp-DC_HSUPA_UEConTest | Ericsson | leif.mattisson@ericsson.com | RP-121524 | RANimp-DC_HSUPA_UEConTest |  |
| 3940 | 1093.3 | Conformance Test Aspects – Support for different bands for Dual-Cell HSDPA |  | 254d? | 2011-03-18 A | 2012-03-02 A | 100% | 2011-03-18 | 2012-03-02 | 254d? | finish no earlier than 2012-03-02 | R5 | 2032h | 2032h | 26 | Rel-9 | 51 | Ingbert | RANimp-MultiBand_DC_HSDPA_UEConTest | Ericsson | leif.mattisson@ericsson.com | RP-120036 | RANimp-MultiBand_DC_HSDPA_UEConTest |  |
| 3941 | 1094 | **LTE improvements** |  | 587d? | 2009-03-06 A | 2011-06-03 A | 100% | 2009-03-06 | 2011-06-03 | 587d? |  | R1; R2; R4; R5 | 21840h | 21840h | 22 | Rel-9 | 42 | Patrick | LTEimp |  |  |  | LTEimp |  |
| 3942 | 1094.1 | LTE Pico NodeB RF Requirements |  | 196d? | 2009-03-06 A | 2009-12-04 A | 100% | 2009-03-06 | 2009-12-04 | 196d? | finish no earlier than 2010-03-05 | R4 | 1568h | 1568h | 22 | Rel-9 | 43 | Issam | LTEimp-Pico_eNB-RF | Huawei | Liyan Yin (yinliyan@huawei.com) | RP-091045 | LTEimp-Pico_eNB-RF |  |
| 3943 | 1094.2 | Enhanced Dual-Layer transmission for LTE | milestone | 0d? | 2009-03-06 A | 2009-03-06 A | 100% | 2009-03-06 | 2010-03-19 | 272d? | finish no earlier than 2010-03-18 | R1; R2; R4 |  |  | 22 | Rel-9 | 43 | Patrick | LTEimp-eDL | China Mobile | Xu Xiaodong (xuxiaodong@chinamobile.com) | RP-100034 | LTEimp-eDL |  |
| 3944 | 1094.3 | UE Conformance Test Aspects – Enhanced Dual-layer transmission for LTE TDD |  | 186d? | 2010-09-17 A | 2011-06-03 A | 100% | 2010-09-17 | 2011-06-03 | 186d? | finish no earlier than 2011-06-03 | R5 | 1488h | 1488h | 25 | Rel-9 | 49 | Ingbert | LTEimp-eDL_UEConTest | China Mobile | Shanpeng Xiao (xiaoshanpeng@chinamobile.com) | RP-110509 | LTEimp-eDL_UEConTest |  |
| 3945 | 1095 | Rel-9 Self-Organizing Networks (SON) | milestone | 0d? | 2009-03-06 A | 2009-03-06 A | 100% | 2009-03-06 | 2010-03-19 | 272d? | finish no earlier than 2010-03-19 | R3; R2 |  |  | 22 | Rel-9 | 42 | Juha | SON | Nokia Siemens Networks | krzysztof.kordybach@nsn.com | RP-100038 | SON | SON |
| 3946 | 1096 | **AGNSS Performances and Testing Procedures** |  | 787d? | 2008-05-16 A | 2011-05-20 A | 100% | 2008-05-16 | 2011-05-20 | 787d? |  | G1; G3new | 22664h | 22664h |  | Rel-9 |  | Paolo | AGNSSPTP | Thales | Michel.monnerat@thalesaleniaspace.com |  | AGNSSPTP |  |
| 3947 | 1096.1 | AGNSS Minimum Performances |  | 472d? | 2008-05-16 A | 2010-03-05 A | 100% | 2008-05-16 | 2010-03-05 | 472d? | finish no earlier than 2010-03-05 | G1 | 3776h | 3776h |  | Rel-9 |  | Paolo | AGNSSPTP-Perfreq | Thales | Michel.monnerat@thalesaleniaspace.com |  | AGNSSPTP-Perfreq |  |
| 3948 | 1096.2 | AGNSS Testing Procedures |  | 787d? | 2008-05-16 A | 2011-05-20 A | 100% | 2008-05-16 | 2011-05-20 | 787d? | finish no earlier than 2011-05-20 | G3new | 6296h | 6296h |  | Rel-9 |  | Ingbert | AGNSSPTP-MStest | Thales | Michel.monnerat@thalesaleniaspace.com |  | AGNSSPTP-MStest |  |
| 3949 | 1097 | **Voice services over Adaptive Multi-user channels on One Slot** |  | 860d? | 2008-11-21 A | 2012-03-02 A | 100% | 2008-11-21 | 2012-03-02 | 860d? |  | GP; G1; G2; G3new | 71592h | 71592h | 22 | Rel-9 | 42 | Paolo | VAMOS | Nokia Siemens Networks, China Mobile | juergen.hofmann@nsn.com, liuxiaoyu@chinamobile.com |  | VAMOS |  |
| 3950 | 1097.1 | Stage 2 for Voice services over Adaptive Multi-user channels on One Slot |  | 392d? | 2008-11-21 A | 2010-05-21 A | 100% | 2008-11-21 | 2010-05-21 | 392d? | finish no earlier than 2010-05-21 | GP; G1; G2 | 9408h | 9408h | 22 | Rel-9 | 40 | Paolo | VAMOS | Nokia Siemens Networks, China Mobile | juergen.hofmann@nsn.com, liuxiaoyu@chinamobile.com |  |  |  |
| 3951 | 1097.2 | Stage 3 for Voice services over Adaptive Multi-user channels on One Slot |  | 596d? | 2008-11-24 A | 2011-03-04 A | 100% | 2008-11-24 | 2011-03-04 | 596d? | finish no earlier than 2011-03-04 | GP; G1; G2 | 14304h | 14304h | 22 | Rel-9 | 40 | Paolo | VAMOS | Nokia Siemens Networks, China Mobile | juergen.hofmann@nsn.com, liuxiaoyu@chinamobile.com |  |  |  |
| 3952 | 1097.3 | VAMOS Radio Performance Requirements |  | 651d? | 2008-11-24 A | 2011-05-20 A | 100% | 2008-11-24 | 2011-05-20 | 651d? | finish no earlier than 2011-05-20 | GP; G1; G2 | 15624h | 15624h | 22 | Rel-9 | 40 | Paolo | VAMOS | Nokia Siemens Networks, China Mobile | juergen.hofmann@nsn.com, liuxiaoyu@chinamobile.com |  |  |  |
| 3953 | 1097.4 | VAMOS - MS conformance testing |  | 392d? | 2010-09-03 A | 2012-03-02 A | 100% | 2010-09-03 | 2012-03-02 | 392d? | finish no earlier than 2012-03-02 | G3new | 3128h | 3128h | 25 | Rel-9 | 47 | Ingbert | VAMOS_MStest | BlackBerry | Raveendra Seetharam (rseetharam@rim.com) |  | VAMOS_MStest |  |
| 3954 | 1097.5 | VAMOS - BTS conformance testing |  | 201d? | 2010-11-26 A | 2011-09-02 A | 100% | 2010-11-26 | 2011-09-02 | 201d? | finish no earlier than 2011-09-02 | G1 | 1608h | 1608h | 26 | Rel-9 | 48 | Paolo | VAMOS_BTStest | Nokia Siemens Networks | eddie.riddington@nsn.com |  | VAMOS_BTStest |  |

Notes:
- 3931: RP#47 completed / Impacted TSs and TRs: UTRA
- 3932: RP#47 completed / Impacted TSs and TRs: 25.101, 25.104, 25.133, 25.211, 25.212, 25.213, 25.214, 25.215, 25.319, 25.306, 25.321, 25.331, 25.423, 25.433
- 3933: RP#46 completed. RP#62 existing TS 25.317 replaced by new TS 25.327 / Impacted TSs and TRs: 25.101, 25.104, 25.133, 25.306, 25.308, 25.331, 25.423, 25.433, new 25.317 replaced by new TS 25.327
- 3934: RP#46 completed / Impacted TSs and TRs: 25.101, 25.104, 25.133, 25.211, 25.212, 25.213, 25.214, 25.215, 25.308, 25.321, 25.331, 26.306, 25.423, 25.433
- 3935: RP#46 completed / Impacted TSs and TRs: 25.101, 25.104, 25.211, 25.212, 25.213, 25.214, 25.215, 25.308, 25.306, 25.321, 25.331, 25.423, 25.433
- 3936: RP#46 completed / Impacted TSs and TRs: 25.102, 25.105, 25.123, 25.225, 25.423, 25.433
- 3937: -
- 3938: UTRA. RP#52 completed. Testing for Rel-9 UID_430016 Combination of DC-HSDPA with MIMO / Impacted TSs and TRs: UTRA 34.108, 34.121-1, 34.121-2, 34.123-1, 34.123-2, 34.123-3
- 3939: RP#58 completed. Testing for Rel-9 UID_430014 Dual-Cell HSUPA / Impacted TSs and TRs: UTRA 34.108, 34.121-1, 34.121-2, 34.123-1, 34.123-2, 34.123-3
- 3940: RP#55 completed. Testing for Rel-9 UID_430015 Support for different bands for Dual-Cell HSDPA / Impacted TSs and TRs: UTRA 34.108, 34.121-1, 34.121-2, 34.123-1, 34.123-2, 34.123-3
- 3941: - / Impacted TSs and TRs: LTE
- 3942: RP#46 completed / Impacted TSs and TRs: 36.104, 36.141, new 36.931
- 3943: RP#47 completed / Impacted TSs and TRs: 36.101, 36.211, 36.212, 36.213, 36.331
- 3944: RP#52 completed. Testing for UID_430029 (Enhanced Dual-Layer transmission for LTE) / Impacted TSs and TRs: 36.508, 36.521-1, 36.521-2
- 3945: RP#47 completed / Impacted TSs and TRs: LTE 25.413, 36.300, 36.413, 36.423, 48.018, New 36.902
- 3946: GP#46 still ongoing MS testing. Linked to Rel-10 RAN4 UID_450027 (AGNSS Minimum Performance for UTRAN)
- 3947: GP#45 completed (open performance requirements alignment GPS/Galileo) / Impacted TSs and TRs: 45.005
- 3948: GP#50 completed / Impacted TSs and TRs: 51.010-1, new 51.010-7
- 3949: Triggered by UID_50590 (MUROS) Study on Multi-User Reusing-One-Slot
- 3950: GP#46 completed. GP#40 WID approved / Impacted TSs and TRs: 45.001
- 3951: GP#49 completed. GP#40 WID approved / Impacted TSs and TRs: 24.008, 44.018, 45.002, 45.003, 45.004, 45.008, 48.008, 48.058
- 3952: GP#50 completed. GP#40 WID approved / Impacted TSs and TRs: 45.005
- 3953: GP#53 completed. GP#47 WID approved / Impacted TSs and TRs: 51.010-1, 51.010-2
- 3954: GP#51 completed. GP#48 WID approved / Impacted TSs and TRs: 51.021

| ID | WBS | Task | Type | Duration | Start | Finish | Complete | Baseline start | Baseline finish | Baseline duration | Constraint | Resources | Work | Actual work | Acronym | PCG approved | WI rapporteur name | WI rapporteur e-mail | Release | TSG approved | MCC resp | Acronym_3GU_Export | PCG stopped | TSG stopped | Special Focus Doc | Status Report |
| --- | --- | --- | --- | --- | --- | --- | --- | --- | --- | --- | --- | --- | --- | --- | --- | --- | --- | --- | --- | --- | --- | --- | --- | --- | --- | --- |
| 3955 | 1098 | **Cell Broadcast protocol Base Station Controller – Cell Broadcast Centre (BSC-CBC)** |  | 222d? | 2009-05-15 A | 2010-03-19 A | 100% | 2009-05-15 | 2010-03-19 | 222d? |  | GP; C1 | 7024h | 7024h | CEBRO | 23 | Ericsson | claes-goran.persson@ericsson.com | Rel-9 | 42 | Paolo | CEBRO |  |  |  |  |
| 3956 | 1098.1 | GERAN part of Cell Broadcast protocol Base Station Controller – Cell Broadcast Centre |  | 212d? | 2009-05-15 A | 2010-03-05 A | 100% | 2009-05-15 | 2010-03-05 | 212d? | finish no earlier than 2010-03-05 | GP | 1696h | 1696h | CEBRO | 23 | Ericsson | claes-goran.persson@ericsson.com | Rel-9 | 42 | Paolo |  |  |  |  |  |
| 3957 | 1098.2 | CT1 part of Cell Broadcast protocol Base Station Controller – Cell Broadcast Centre |  | 222d? | 2009-05-15 A | 2010-03-19 A | 100% | 2009-05-15 | 2010-03-19 | 222d? | finish no earlier than 2010-03-19 | C1 | 1776h | 1776h | CEBRO | 23 | Ericsson | claes-goran.persson@ericsson.com | Rel-9 | 42 | Frederic |  |  |  |  |  |
| 3958 | 1099 | Hybrid Location |  | 136d? | 2009-05-18 A | 2009-11-20 A | 100% | 2009-05-18 | 2009-11-20 | 136d? | finish no earlier than 2009-11-20 | GP | 1088h | 1088h | HILT | 23 | TruePosition | Matt Ward (mward@trueposition.com) | Rel-9 | 42 | Paolo | HILT |  |  |  |  |
| 3959 | 1100 | (Small) Technical Enhancements and Improvements for Rel-9 |  | 325d? | 2008-09-15 A | 2009-12-10 A | 100% | 2008-09-15 | 2009-12-10 | 325d? | finish no earlier than 2009-12-10 | SP; CP; RP; GP | 10400h | 10400h | TEI9 | 22 |  |  | Rel-9 | 42 | All | TEI9 |  |  |  |  |
| 3960 | 1101 | Test - (Small) Technical Enhancements and Improvements for Rel-9 |  | 286d? | 2009-11-20 A | 2010-12-24 A | 100% | 2009-11-20 | 2010-12-24 | 286d? | finish no earlier than 2010-12-24 | R5; G3new | 4576h | 4576h | TEI9_Test | 24 |  |  | Rel-9 | 44 | Ingbert | TEI9_Test |  |  |  |  |
| 3961 | 1102 | **Deleted - Services Alignment and Migration** |  | 467d? | 2006-12-06 A | 2008-09-18 A | 100% | 2006-12-06 | 2008-09-18 | 467d? |  | S1 | 7472h | 7472h | ServAl |  | Telefónica O2 | chris.friel@O2.com | Rel-9 | 33 | Alain | ServAl | PCG-21 | SP-41 |  |  |
| 3962 | 1102.1 | Deleted - Stage 1 for ServAl |  | 467d? | 2006-12-06 A | 2008-09-18 A | 100% | 2006-12-06 | 2008-09-18 | 467d? | finish no earlier than 2008-12-11 | S1 | 3736h | 3736h |  | 21 | Telefónica O2 | chris.friel@O2.com | Rel-9 | 33 | Alain |  | PCG-21 | SP-41 |  |  |
| 3963 | 1103 | Deleted - Harmonization of Gq'/Rx for Common IMS |  | 304d? | 2008-01-14 A | 2009-03-12 A | 100% | 2008-01-14 | 2009-03-12 | 304d? | finish no earlier than 2009-03-12 | S2 | 2432h | 2432h | IMS_Comm_GqRx_Harm | 21 | Alcatel-Lucent | geoffrey.cristallo@alcatel-lucent.be | Rel-9 | 38 | Maurice | IMS_Comm_GqRx_Harm | PCG-22 | SP-43 |  |  |
| 3964 | 1104 | Deleted - Support of WiMAX - LTE Mobility |  | 407d? | 2008-06-06 A | 2009-12-25 A | 100% | 2008-06-06 | 2009-12-25 | 407d? | start no earlier than 2008-06-06 | R2 | 3248h | 3248h | WiMAX_LTE_Mobility | 21 | Samsung |  | Rel-9 | 38 | Yong-Jun | WiMAX_LTE_Mobility | PCG-21 | SP-39 |  |  |
| 3965 | 1105 | Deleted - Support of WiMAX - UMTS Mobility |  | 407d? | 2008-06-06 A | 2009-12-25 A | 100% | 2008-06-06 | 2009-12-25 | 407d? | start no earlier than 2008-06-06 | R2 | 3248h | 3248h | WiMAX_UMTS_Mobility | 21 | Intel |  | Rel-9 | 38 | Yong-Jun | WiMAX_UMTS_Mobility | PCG-21 | SP-39 |  |  |
| 3966 | 1106 | Deleted - Definition of 3GPP UICC services over the new high-speed interface | milestone | 0d? | 2010-03-19 A | 2010-03-19 A | 100% | 2010-03-19 | 2010-03-19 | 0d? |  | C6 |  |  | UICCHS | 21 | Gemalto | Denis.Lheriteau@gemalto.com | Rel-9 | 38 | Xavier | UICCHS | PCG-24 | CP-47 |  |  |
| 3967 | 1107 | **Deleted - SAES Enhancements (non RAN aspects)** |  | 381d? | 2007-06-25 A | 2008-12-08 A | 100% | 2007-06-25 | 2008-12-08 | 381d? |  | S2 | 11664h | 11664h | SAES_Ph2 | 21 | Nokia Siemens Networks |  | Rel-9 | 39 | Maurice | SAES_Ph2 | PCG-21 | SP-39 |  |  |
| 3968 | 1107.1 | Deleted - Functions and procedures for SAE to support LTE MBMS |  | 381d? | 2007-06-25 A | 2008-12-08 A | 100% | 2007-06-25 | 2008-12-08 | 381d? | finish no earlier than 2008-12-08 | S2 | 3048h | 3048h | SAES_Ph2 |  |  |  | Rel-9 | 35 | Maurice |  | PCG-21 | SP-39 |  |  |
| 3969 | 1107.2 | Deleted - CS over EPS |  | 194d? | 2008-03-12 A | 2008-12-08 A | 100% | 2008-03-12 | 2008-12-08 | 194d? | finish no earlier than 2008-12-08 | S2 | 1552h | 1552h | SAES_Ph2 | 21 |  |  | Rel-9 | 39 | Maurice |  | PCG-21 | SP-39 |  |  |
| 3970 | 1107.3 | **Deleted - SAE for generic support for non-3GPP accesses** |  | 251d? | 2007-06-25 A | 2008-06-09 A | 100% | 2007-06-25 | 2008-06-09 | 251d? |  | S2 | 4016h | 4016h | SAES_Ph2 | 21 |  |  | Rel-9 | 39 | Maurice |  | PCG-21 | SP-39 |  |  |
| 3971 | 1107.3.1 | Deleted - Single Radio Aspects of SAE for Optimized Handover with WiMAX |  | 251d? | 2007-06-25 A | 2008-06-09 A | 100% | 2007-06-25 | 2008-06-09 | 251d? | finish no earlier than 2008-06-09 | S2 | 2008h | 2008h | SAES_Ph2 | 21 |  |  | Rel-9 | 39 | Maurice |  | PCG-21 | SP-39 |  |  |
| 3972 | 1108 | Deleted - Lawful Interception in the 3GPP Rel-9 |  | 211d? | 2009-06-04 A | 2010-03-25 A | 100% | 2009-06-04 | 2010-03-25 | 211d? | finish no earlier than 2010-03-25 | S3 | 1688h | 1688h | LI9 | 23 | PIDS, Nortel | Koen Jaspers, Ronald Ryan | Rel-9 | 44 | Mirko | LI9 | PCG-24 | SP-47 |  |  |
| 3973 | 1109 | Release 9 Studies | milestone | 0d? | 2008-06-05 A | 2008-06-05 A | 100% | 2008-06-05 | 2010-03-19 | 468d? |  | CP; RP; SP |  |  |  |  |  |  | Rel-9 |  |  |  |  |  |  |  |
| 3974 | 1110 | Study on Service Specific Access Control in EPS |  | 136d? | 2008-06-05 A | 2008-12-11 A | 100% | 2008-06-05 | 2008-12-11 | 136d? | start no earlier than 2008-06-05 | S1 | 1088h | 1088h | FS_SSAC | 21 | NTT DoCoMo | Shin-ichi Isobe (isobes@nttdocomo.co.jp) | Rel-9 | 40 | Alain | FS_SSAC |  |  |  |  |
| 3975 | 1111 | Study on CS Domain Services over EPS access |  | 492d? | 2007-04-25 A | 2009-03-12 A | 100% | 2007-04-25 | 2009-03-12 | 492d? | finish no earlier than 2009-03-12 | S2 | 3936h | 3936h | FS_CSoPS |  | T-Mobile | Karl-Heinz.Nenner@T-Mobile.net | Rel-9 | 35 | Maurice | FS_CSoPS |  |  |  |  |
| 3976 | 1112 | Study on Extended Support of IMS Emergency Calls |  | 319d? | 2007-09-24 A | 2008-12-11 A | 100% | 2007-09-24 | 2008-12-11 | 319d? | finish no earlier than 2009-06-18 | S2 | 2552h | 2552h | FS_IMS-eCall |  | Qualcomm | Stephen Edge | Rel-9 | 37 | Maurice | FS_IMS-eCall |  |  | Public Safety (I-A) |  |
| 3977 | 1113 | Study on Service Continuity for Emergency Voice Calls |  | 721d? | 2006-06-08 A | 2009-03-12 A | 100% | 2006-06-08 | 2009-03-12 | 721d? | finish no earlier than 2009-03-12 | S2 | 5768h | 5768h | FS_VCCEm |  | Nortel | Ricky Kaura (rkaura@nortel.com) | Rel-9 | 32 | Maurice | FS_VCCEm |  |  | Public Safety (I-A) |  |
| 3978 | 1114 | Study on Security Aspects of Remote Provisioning and Change of Subscription for M2M Equipment |  | 1483.15d? | 2004-04-06 A | 2009-12-10 A | 100% | 2004-04-06 | 2009-12-10 | 1483.15d? | finish no earlier than 2009-12-10 | S3; C6 | 23730.4h | 23730.4h | FS_UM2M |  | Ericsson | vesa.lehtovirta@ericsson.com | Rel-9 | 37 | Mirko | FS_UM2M |  |  | MTC, M2M |  |
| 3979 | 1115 | Study on System Maintenance over Itf-N |  | 602d? | 2007-06-07 A | 2009-09-24 A | 100% | 2007-06-07 | 2009-09-24 | 602d? | finish no earlier than 2009-09-24 | S5 | 4808h | 4808h | FS_OAM-Maint-Itf-N |  | ZTE | Shuqiang Huang (huangsq@zte.com.cn) | Rel-9 | 36 | Mirko | FS_OAM-Maint-Itf-N |  |  |  |  |
| 3980 | 1116 | Study on Self-Organizing Networks (SON) related OAM interfaces for Home NodeB |  | 522d? | 2007-06-07 A | 2009-06-04 A | 100% | 2007-06-07 | 2009-06-04 | 522d? | finish no earlier than 2009-12-10 | S5 | 4168h | 4168h | FS_OAM-SON-HNB |  | Huawei | Zou Lan (zlan@huawei.com) | Rel-9 | 36 | Mirko | FS_OAM-SON-HNB |  |  | HNB, SON |  |
| 3981 | 1117 | Study on Self-healing of Self-Organizing Networks (SON) |  | 416d? | 2008-02-22 A | 2009-09-24 A | 100% | 2008-02-22 | 2009-09-24 | 416d? | finish no earlier than 2009-09-24 | S5 | 3320.15h | 3320.15h | FS_OAM-SON-SH | 21 | ZTE | zhu.weihong@zte.com.cn | Rel-9 | 39 | Mirko | FS_OAM-SON-SH |  |  | SON |  |
| 3982 | 1118 | Study on Service Oriented Architecture (SOA) for IRP |  | 262d? | 2008-06-05 A | 2009-06-04 A | 100% | 2008-06-05 | 2009-06-04 | 262d? | finish no earlier than 2009-05-20 | S5 | 2088h | 2088h | FS_OAM_SOA_IRP | 21 | Ericsson | edwin.tse@ericsson.com | Rel-9 | 40 | Mirko | FS_OAM_SOA_IRP |  |  |  |  |
| 3983 | 1119 | Study on Evaluation of the inclusion of Path Loss Based Technology in the UTRAN |  | 516d? | 2007-12-17 A | 2009-12-04 A | 100% | 2007-12-17 | 2009-12-04 | 516d? | finish no earlier than 2009-09-18 | R4 | 4120h | 4120h | FS_RAN-Pathloss | 21 | Polaris Wireless | Norman Shaw (nshaw@polariswireless.com) | Rel-9 | 38 | Issam | FS_RAN-Pathloss |  |  |  | RP-091080 |
| 3984 | 1120 | Study on LTE-Advanced |  | 781.2d? | 2007-03-23 A | 2010-03-19 A | 100% | 2007-03-23 | 2010-03-19 | 781.2d? | finish no earlier than 2010-03-19 | R1; R2; R3; R4 | 24998.4h | 24998.4h | FS_RAN_LTEA | 21 | NTT DoCoMo | Tetsushi Abe | Rel-9 | 39 | Patrick | FS_RAN_LTEA |  |  | CA | RP-100080 |
| 3985 | 1121 | Study on 1.28 Mcps TDD Home NodeB |  | 387d? | 2008-02-20 A | 2009-12-04 A | 100% | 2008-02-20 | 2009-12-04 | 387d? | finish no earlier than 2009-12-04 | R4 | 3096h | 3096h | FS_RAN-HNBLCRTDD | 21 | TD Tech | Li Rong (lirong@td-tech.com) | Rel-9 | 41 | Issam | FS_RAN-HNBLCRTDD |  |  | HNB | RP-091081 |
| 3986 | 1122 | Study on E-UTRAN Mobility Evaluation and Enhancement |  | 126d? | 2008-12-05 A | 2009-05-29 A | 100% | 2008-12-05 | 2009-05-29 | 126d? | finish no earlier than 2009-05-29 | R1 | 1008h | 1008h | FS_EUTRAN_mob | 22 | Qualcomm | Rajat Prakash (rprakash@qualcomm.com) | Rel-9 | 42 | Patrick | FS_EUTRAN_mob |  |  |  | RP-090426 |
| 3987 | 1123 | Study on Minimization of drive-tests in Next Generation Networks |  | 196d? | 2009-03-06 A | 2009-12-04 A | 100% | 2009-03-06 | 2009-12-04 | 196d? | finish no earlier than 2009-12-04 | R2 | 1568h | 1568h | FS_NGN_min_drive-tests | 22 | Qualcomm | Masato Kitazoe (mkitazoe@qualcomm.com) | Rel-9 | 43 | Yong-Jun | FS_NGN_min_drive-tests |  |  |  | RP-091084 |
| 3988 | 1124 | Study on Enhanced Interference Management for HNBs |  | 61d? | 2009-03-06 A | 2009-05-29 A | 100% | 2009-03-06 | 2009-05-29 | 61d? | start no earlier than 2009-03-06 | R4 | 488h | 488h | FS_eInterfMgmt_HNB | 22 | Qualcomm | Farhad Meshkati (fmeshkat@qualcomm.com) | Rel-9 | 43 | Issam | FS_eInterfMgmt_HNB |  |  | HNB | RP-090429 |
| 3989 | 1125 | Study on Enhanced Interference Management Mechanisms for HNBs |  | 81d? | 2009-05-30 A | 2009-09-18 A | 100% | 2009-05-30 | 2009-09-18 | 81d? | finish no earlier than 2009-09-18 | R3 | 648h | 648h | FS_eInterfMgmtMchsm_HNB | 23 | Qualcomm | Farhad Meshkati (fmeshkat@qualcomm.com) | Rel-9 | 44 | Juha | FS_eInterfMgmtMchsm_HNB |  |  | HNB | RP-090733 |
| 3990 | 1126 | Deleted - Study on Protection against SMS and MMS spam |  | 862d? | 2006-06-08 A | 2009-09-24 A | 100% | 2006-06-08 | 2009-09-24 | 862d? | finish no earlier than 2009-09-24 | S3 | 6896h | 6896h | FS_CPSMal |  | Orange | eric.gauthier@orange.ch | Rel-9 | 32 | Mirko | FS_CPSMal | PCG-23 | SP-45 |  |  |
| 3991 | 1127 | Release 8 Features |  | 914.3d? | 2006-09-19 A | 2010-03-19 A | 100% | 2006-09-19 | 2010-03-19 | 914.3d? | start no earlier than 2000-01-03 | CP; GP; RP; SP | 29257.6h | 29257.6h |  |  |  |  | Rel-8 |  |  |  |  |  |  |  |

Notes:
- 3955: CP#47 completed. GP#45 completed. GP#42 WID approved
- 3956: GP#45 completed. GP#42 WID approved / Impacted TSs and TRs: new 48.049
- 3957: CP#47 completed / Impacted TSs and TRs: 23.041
- 3958: GP#44 completed. GP#42 WID approved (Hybrid Integrated Location Technology=HILT) / Impacted TSs and TRs: 43.059, 48.071
- 3959: SP#46 completed
- 3960: GP#44 created
- 3961: SP#41 closed (no tangible result of this work; no CR against TR 22.983). Triggered by Study UID_370086 (FSServAl)
- 3962: SP#41 closed (no tangible result of this work; no CR against TR 22.983) / Impacted TSs and TRs: 22.983
- 3963: SP#43 stopped. LS_out to TISPAN informs about stopping this activity / Impacted TSs and TRs: 23.822, 23.203
- 3964: RP#39: No agreed WID / Impacted TSs and TRs: 36.306, 36.331, 36.413, 36.300, 36.214, 36.133, 36.304
- 3965: RP#39: No agreed WID / Impacted TSs and TRs: 25.306, 25.331, 25.413
- 3966: CP#47 work stopped/abandoned / Impacted TSs and TRs: 31.xyz
- 3967: SP#39 created to host Rel-9 Wis. BUT no agreed WID
- 3968: SP#39 SAE functionality moved to Rel-9. WID returned to SA2 for re-consideration & remove MBMS for EPS from Rel 8
- 3969: SP#39 SAE functionality moved to Rel-9. BUT no agreed WID
- 3970: SP#39 SAE functionality moved to Rel-9. BUT no agreed WID
- 3971: SP#39 SAE functionality moved to Rel-9. BUT no agreed WID
- 3972: SP#47 stopped. WI + new topics moved to Rel-10 / Impacted TSs and TRs: 33.106, 33.107, 33.108
- 3973: -
- 3974: SP#42 completed. Spin-off Feature UID_420020 (SSAC) / Impacted TSs and TRs: 22.986
- 3975: SP#43 completed. Linked to Combinational Services UID_31064, Services Alignment and Migration (ServAl) UID_330017 and 3GPP System Architecture Evolution (SAES) UID_3208 / Impacted TSs and TRs: 23.879
- 3976: SP#42 completed / Impacted TSs and TRs: 23.868
- 3977: SP#43 completed / Impacted TSs and TRs: 23.826
- 3978: SP#46 completed. Triggered by the SA1 Rel-8 Study on Facilitating Machine to Machine Communication in GSM and UMTS (FS_M2M) UID_7027 in TR 22.868. / Impacted TSs and TRs: 33.812
- 3979: SP#45 completed / Impacted TSs and TRs: 32.822
- 3980: SP#44 completed. Linked to SA5 TR 32.816 Study of Management for LTE and SAE (UID_340036) / Impacted TSs and TRs: 32.821
- 3981: SP#45 completed. Linked to SA5 TR 32.816 Study of Management for LTE and SAE (UID_340036) / Impacted TSs and TRs: 32.823
- 3982: SP#44 completed. Spin-off implementation WI UID_440064 Service Oriented Architecture (SOA) for IRP / Impacted TSs and TRs: 32.824
- 3983: RP#46 completed / Impacted TSs and TRs: 25.907
- 3984: RP#47 completed / Impacted TSs and TRs: 36.913 , New 36.814, 36.912, R2 36.806 (Relay architectures for E-UTRA), R4 36.815 (LTE-Advanced feasibility studies in RAN4)
- 3985: RP#46 completed / Impacted TSs and TRs: 25.866
- 3986: RP#44 closed (RP-090452 R1 LS to RAN on Conclusions for LTE Mobility Study Item - no further Rel-9 action / no TR needed) / Impacted TSs and TRs: none
- 3987: RP#46 completed / Impacted TSs and TRs: 36.805
- 3988: RP#44 completed. Linked to UID_420008 LTE FDD Home eNodeB RF Requirements. Spin-off RAN3 UID_440015 Study on Enhanced Interference Management Mechanisms for HNBs / Impacted TSs and TRs: 25.967
- 3989: RP#45 completed. Triggered by RAN4 UID_430027 Study on Enhanced Interference Management for HNBs / Impacted TSs and TRs: 25.967
- 3990: SP#45 work stopped/abandoned / Impacted TSs and TRs: 33.9xx
- 3991: -

| ID | WBS | Task | Duration | Start | Finish | Complete | Baseline start | Baseline finish | Baseline duration | Constraint | Resources | Work | Actual work | Acronym | WI rapporteur name | WI rapporteur e-mail | Release | TSG approved | MCC resp | Acronym_3GU_Export | PCG approved |
| --- | --- | --- | --- | --- | --- | --- | --- | --- | --- | --- | --- | --- | --- | --- | --- | --- | --- | --- | --- | --- | --- |
| 3992 | 1128 | **3GPP System Architecture Evolution Specification - Evolved Packet System (non RAN aspects)** | 1618d? | 2006-04-12 A | 2012-06-15 A | 100% | 2006-04-12 | 2012-06-15 | 1618d? |  | S1; S2; S3; S5; C1; C3; C4; C6; IETF | 512323h | 510115h | SAES | T-Mobile | michael.kurz@t-mobile.at | Rel-8 | 32 | Alain | SAES |  |
| 3993 | 1128.1 | Requirements for evolution of the 3GPP system architecture | 395d? | 2006-06-08 A | 2007-12-12 A | 100% | 2006-06-08 | 2007-12-12 | 395d? | finish no earlier than 2007-11-30 | S1 | 3160h | 3160h | AIPN-SAE | T-Mobile | michael.kurz@t-mobile.at | Rel-8 | 32 | Alain | AIPN-SAE |  |
| 3994 | 1128.2 | **High level and common (for all accesses) functions** | 629d? | 2007-01-02 A | 2009-05-29 A | 100% | 2007-01-02 | 2009-05-29 | 629d? |  | S2; S3; C1; C3; C4 | 62664h | 62664h | EPS-ComF | Nokia Siemens Networks | balazs.bertenyi@nsn.com | Rel-8 | 37 | Maurice | EPS-ComF |  |
| 3995 | 1128.2.1 | Stage 2 for High level functions | 370d? | 2007-01-02 A | 2008-06-02 A | 100% | 2007-01-02 | 2008-06-02 | 370d? | finish no earlier than 2008-06-02 | S2 | 2960h | 2960h | SAES-SA-HLF | Motorola | Irfan.Ali@motorola.com | Rel-8 | 35 | Maurice | SAES-SA-HLF |  |
| 3996 | 1128.2.2 | Stage 2 Security Architecture | 197d? | 2008-03-12 A | 2008-12-11 A | 100% | 2008-03-12 | 2008-12-11 | 197d? | finish no earlier than 2008-12-11 | S3 | 1576h | 1576h | SAES | Nokia Siemens Networks | marc.blommaert.ext@nsn.com | Rel-8 | 39 | Mirko |  | 21 |
| 3997 | 1128.2.3 | Stage 3 (CT1) for SAE impact on services, network functions and capabilities | 545d? | 2007-02-05 A | 2009-03-06 A | 100% | 2007-02-05 | 2009-03-06 | 545d? | finish no earlier than 2009-03-06 | C1 | 4360h | 4360h | SAES | Nokia Siemens Networks | robert.zaus@nsn.com | Rel-8 | 34 | Frederic |  |  |
| 3998 | 1128.2.4 | Stage 3 SAE impact on existing capabilities | 480d? | 2007-02-05 A | 2008-12-05 A | 100% | 2007-02-05 | 2008-12-05 | 480d? | finish no earlier than 2008-12-12 | C3 | 3840h | 3840h | SAES | Huawei | Wei Weihua (weiwh@huawei.com) | Rel-8 | 34 | Adrian |  |  |
| 3999 | 1128.2.5 | Stage 3 (CT4) of SAE impact on existing capabilities | 545d? | 2007-02-05 A | 2009-03-06 A | 100% | 2007-02-05 | 2009-03-06 | 545d? | finish no earlier than 2009-03-06 | C4 | 4360h | 4360h | SAES | Huawei | shahab.lavasani@huawei.com | Rel-8 | 34 | Kimmo |  |  |
| 4000 | 1128.2.6 | Stage 2/3 for Network selection procedures | 480d? | 2007-02-05 A | 2008-12-05 A | 100% | 2007-02-05 | 2008-12-05 | 480d? | finish no earlier than 2009-03-06 | C1 | 3840h | 3840h | SAES | Nokia Siemens Networks | robert.zaus@nsn.com | Rel-8 | 34 | Frederic |  |  |
| 4001 | 1128.2.7 | Stage 3 EPC interworking with external PDNs (SGi) | 605d? | 2007-02-05 A | 2009-05-29 A | 100% | 2007-02-05 | 2009-05-29 | 605d? | finish no earlier than 2009-05-29 | C3 | 4840h | 4840h | SAES-St3-intwk | Huawei | Wei Weihua (weiwh@huawei.com) | Rel-8 | 34 | Adrian | SAES-St3-intwk |  |
| 4002 | 1128.2.8 | Stage 3 PCC within SAE | 605d? | 2007-02-05 A | 2009-05-29 A | 100% | 2007-02-05 | 2009-05-29 | 605d? | finish no earlier than 2009-05-29 | C3 | 4840h | 4840h | SAES-St3-PCC | Ericsson | j.javier.pastor@ericsson.com | Rel-8 | 34 | Adrian | SAES-St3-PCC |  |
| 4003 | 1128.2.9 | Stage 3 for SAE / LTE identities | 545d? | 2007-02-05 A | 2009-03-06 A | 100% | 2007-02-05 | 2009-03-06 | 545d? | finish no earlier than 2009-03-06 | C4 | 4360h | 4360h | SAES | Huawei | shahab.lavasani@huawei.com | Rel-8 | 34 | Kimmo |  |  |
| 4004 | 1128.2.10 | Unified guidelines for Diameter usage within 3GPP | 316d? | 2007-09-21 A | 2008-12-05 A | 100% | 2007-09-21 | 2008-12-05 | 316d? | finish no earlier than 2008-12-05 | C3 | 2528h | 2528h | SAES-DIAM | Huawei | Javier Gonzalez Gallego | Rel-8 | 37 | Adrian | SAES-DIAM |  |
| 4005 | 1128.3 | **SAE for LTE access** | 569d? | 2007-01-02 A | 2009-03-06 A | 100% | 2007-01-02 | 2009-03-06 | 569d? |  | S2; C1; C3; C4 | 80584h | 80584h | SAES-LTE | Motorola | Irfan.Ali@motorola.com | Rel-8 | 35 | Maurice | SAES-LTE |  |
| 4006 | 1128.3.1 | CT4 Stage 3 for protocol between EPCs | 545d? | 2007-02-05 A | 2009-03-06 A | 100% | 2007-02-05 | 2009-03-06 | 545d? | finish no earlier than 2009-03-06 | C4 | 4360h | 4360h | SAES-LTE | Huawei | shahab.lavasani@huawei.com | Rel-8 | 34 | Kimmo |  |  |
| 4007 | 7.2.2.1 | **SAES-SA-FP_LTE with GTP variant** | 569d? | 2007-01-02 A | 2009-03-06 A | 100% | 2007-01-02 | 2009-03-06 | 569d? |  | S2; C4 | 16448h | 16448h | SAES-SA-FP_LTE-GTP | Nokia Siemens Networks | balazs.bertenyi@nsn.com | Rel-8 | 35 | Maurice | SAES-SA-FP_LTE-GTP |  |
| 4008 | 1128.3.2.1 | Stage 2 for SAES-SA-FP_LTE with GTP variant | 373d? | 2007-01-02 A | 2008-06-05 A | 100% | 2007-01-02 | 2008-06-05 | 373d? | finish no earlier than 2008-06-02 | S2 | 2984h | 2984h | SAES-SA-FP_LTE-GTP-St2 | Nokia Siemens Networks | balazs.bertenyi@nsn.com | Rel-8 | 37 | Maurice | SAES-SA-FP_LTE-GTP-St2 |  |
| 4009 | 1128.3.2.2 | CT4 Stage 3 for GTP v2 protocol | 545d? | 2007-02-05 A | 2009-03-06 A | 100% | 2007-02-05 | 2009-03-06 | 545d? | finish no earlier than 2009-03-06 | C4 | 4360h | 4360h | SAES-SA-FP_LTE-GTP | Huawei | shahab.lavasani@huawei.com | Rel-8 | 34 | Kimmo | SAES-SA-FP_LTE-GTP |  |
| 4010 | 7.2.2.2 | **SAES-SA-FP_LTE with PMIP variant** | 569d? | 2007-01-02 A | 2009-03-06 A | 100% | 2007-01-02 | 2009-03-06 | 569d? |  | S2; C4 | 20288h | 20288h | SAES-SA-FP_LTE-IETF | Nokia Siemens Networks | balazs.bertenyi@nsn.com | Rel-8 | 34 | Maurice | SAES-SA-FP_LTE-IETF |  |
| 4011 | 1128.3.3.1 | Stage 2 for SAES-SA-FP_LTE with PMIP variant | 373d? | 2007-01-02 A | 2008-06-05 A | 100% | 2007-01-02 | 2008-06-05 | 373d? | finish no earlier than 2008-06-02 | S2 | 2984h | 2984h | SAES-SA-FP_LTE-IETF-St2 | Nokia Siemens Networks | balazs.bertenyi@nsn.com | Rel-8 | 37 | Maurice | SAES-SA-FP_LTE-IETF-St2 |  |
| 4012 | 1128.3.3.2 | CT4 Stage 3 for PMIP protocol within EPC | 545d? | 2007-02-05 A | 2009-03-06 A | 100% | 2007-02-05 | 2009-03-06 | 545d? | finish no earlier than 2009-03-06 | C4 | 4360h | 4360h | SAES-SA-FP_LTE-IETF | Huawei | shahab.lavasani@huawei.com | Rel-8 | 37 | Kimmo | SAES-SA-FP_LTE-IETF |  |
| 4013 | 1128.3.3.3 | Mobile IPv4 (MIPv4) based Mobility protocols | 480d? | 2007-02-05 A | 2008-12-05 A | 100% | 2007-02-05 | 2008-12-05 | 480d? | finish no earlier than 2008-12-05 | C4 | 3840h | 3840h | SAES-SA-FP_LTE-IETF | Motorola | Lewis Milton | Rel-8 | 41 | Kimmo |  |  |
| 4014 | 1128.3.4 | Stage 3 for UE Non-Access-Stratum (NAS) mobility procedures in idle and active mode | 545d? | 2007-02-05 A | 2009-03-06 A | 100% | 2007-02-05 | 2009-03-06 | 545d? | finish no earlier than 2009-03-06 | C1 | 4360h | 4360h | SAES-LTE | Nokia Siemens Networks | robert.zaus@nsn.com | Rel-8 | 34 | Frederic |  |  |
| 4015 | 1128.3.5 | Stage 3 for Session management, bearer control and QoS aspects | 545d? | 2007-02-05 A | 2009-03-06 A | 100% | 2007-02-05 | 2009-03-06 | 545d? | finish no earlier than 2009-03-06 | C1 | 4360h | 4360h | SAES-LTE | Nokia Siemens Networks | robert.zaus@nsn.com | Rel-8 | 34 | Frederic |  |  |
| 4016 | 1128.3.6 | Stage 3 for security aspects of LTE Access | 545d? | 2007-02-05 A | 2009-03-06 A | 100% | 2007-02-05 | 2009-03-06 | 545d? | finish no earlier than 2009-03-06 | C1 | 4360h | 4360h | SAES-LTE | Nokia Siemens Networks | robert.zaus@nsn.com | Rel-8 | 34 | Frederic |  |  |
| 4017 | 1128.3.7 | Stage 3 for QoS mechanisms | 480d? | 2007-02-05 A | 2008-12-05 A | 100% | 2007-02-05 | 2008-12-05 | 480d? | finish no earlier than 2008-12-12 | C3 | 3840h | 3840h | SAES-LTE | Ericsson | j.javier.pastor@ericsson.com | Rel-8 | 34 | Adrian |  |  |
| 4018 | 1128.3.8 | Stage 3 for EPC - HSS interface | 545d? | 2007-02-05 A | 2009-03-06 A | 100% | 2007-02-05 | 2009-03-06 | 545d? | finish no earlier than 2009-03-06 | C4 | 4360h | 4360h | SAES-LTE | Huawei | shahab.lavasani@huawei.com | Rel-8 | 34 | Kimmo |  |  |

Notes:
- 3992: Role model for SAE/LTE system wide project management by SA2 in SP-060166
- 3993: SP#38 completed / Impacted TSs and TRs: 22.011, 22.246, New 22.278
- 3994: CP#44 completed
- 3995: SP#40 completed / Impacted TSs and TRs: New 23.402
- 3996: SP#42 completed / Impacted TSs and TRs: 33.210, 33.310, New 33.401
- 3997: CP#43 completed / Impacted TSs and TRs: 24.229, 27.007, New 24.305
- 3998: CP#42 completed / Impacted TSs and TRs: 29.061
- 3999: CP#43 completed / Impacted TSs and TRs: New (29.274, 29.275)
- 4000: CP#42 completed / Impacted TSs and TRs: 23.122, New 24.302
- 4001: CP#44 completed / Impacted TSs and TRs: 29.061
- 4002: CP#44 completed / Impacted TSs and TRs: 29.212, 29.213, 29.214, New 29.215
- 4003: CP#43 completed / Impacted TSs and TRs: 23.003
- 4004: CP#42 completed / Impacted TSs and TRs: New 29.909
- 4005: CP#43 completed
- 4006: CP#43 completed / Impacted TSs and TRs: 29.274, 29.275
- 4007: CP#43 completed
- 4008: SP#40 completed / Impacted TSs and TRs: 23.401, 23.060, 23.002, 23.246, 23.203, 23.107, 23.234, 23.271
- 4009: CP#43 completed / Impacted TSs and TRs: 29.274
- 4010: CP#43 completed
- 4011: SP#40 completed
- 4012: CP#43 completed / Impacted TSs and TRs: 29.275, 29.282
- 4013: CP#42 completed / Impacted TSs and TRs: 29.279
- 4014: CP#43 completed / Impacted TSs and TRs: 24.007, 24.301
- 4015: CP#43 completed / Impacted TSs and TRs: 24.007, 24.301
- 4016: CP#43 completed / Impacted TSs and TRs: 24.008, 24.301
- 4017: CP#42 completed / Impacted TSs and TRs: 29.213
- 4018: CP#43 completed / Impacted TSs and TRs: 29.272

| ID | WBS | Task | Type | Duration | Start | Finish | Complete | Baseline start | Baseline finish | Baseline duration | Constraint | Resources | Work | Actual work | Acronym | WI rapporteur name | WI rapporteur e-mail | Release | TSG approved | MCC resp | Acronym_3GU_Export | Impacted TSs and TRs | PCG approved | TSG stopped |
| --- | --- | --- | --- | --- | --- | --- | --- | --- | --- | --- | --- | --- | --- | --- | --- | --- | --- | --- | --- | --- | --- | --- | --- | --- |
| 4019 | 1128.4 | **SAE for Interoperation between LTE and legacy cellular PS accesses** |  | 545d? | 2007-02-05 A | 2009-03-06 A | 100% | 2007-02-05 | 2009-03-06 | 545d? |  | S2; C1; C4 | 48872h | 48872h | SAES-SA-FP_3GPP | Motorola | Irfan.Ali@motorola.com | Rel-8 | 35 | Maurice | SAES-SA-FP_3GPP |  |  |  |
| 4020 | 1128.4.1 | Stage 2 for Interoperation between LTE and 2G/3G |  | 424d? | 2007-02-05 A | 2008-09-18 A | 100% | 2007-02-05 | 2008-09-18 | 424d? | finish no earlier than 2008-09-11 | S2 | 3392h | 3392h | EPSto2_3G | Motorola | Irfan.Ali@motorola.com | Rel-8 | 37 | Maurice | EPSto2_3G | 23.401, 23.402 |  |  |
| 4021 | 1128.4.2 | Stage 3 for Inter-system mobility between E-UTRAN and 2G/3G |  | 545d? | 2007-02-05 A | 2009-03-06 A | 100% | 2007-02-05 | 2009-03-06 | 545d? | finish no earlier than 2009-03-06 | C1 | 4360h | 4360h | SAES-SA-FP_3GPP | Nokia Siemens Networks | robert.zaus@nsn.com | Rel-8 | 38 | Frederic | SAES-SA-FP_3GPP | 24.008, 24.301 | 21 |  |
| 4022 | 1128.4.3 | Stage 2 GPRS enhancements for LTE access |  | 272d? | 2007-09-04 A | 2008-09-18 A | 100% | 2007-09-04 | 2008-09-18 | 272d? | start no earlier than 2007-09-04 | S2 | 2176h | 2176h | SAES-GPRS_LTE | Vodafone | chris.pudney@vodafone.com | Rel-8 | 34 | Maurice | SAES-GPRS_LTE | 23.401 |  |  |
| 4023 | 1128.4.4 | Stage 2 GPRS for EPC (23.060, etc.) |  | 179d? | 2008-01-14 A | 2008-09-18 A | 100% | 2008-01-14 | 2008-09-18 | 179d? | finish no earlier than 2008-09-18 | S2 | 1432h | 1432h | SAES-SA-FP_3GPP | Nokia Siemens Networks | balazs.bertenyi@nsn.com | Rel-8 | 39 | Maurice |  | 23.060 | 21 |  |
| 4024 | 1128.4.5 | Stage 3 for EPC - GPRS |  | 545d? | 2007-02-05 A | 2009-03-06 A | 100% | 2007-02-05 | 2009-03-06 | 545d? | finish no earlier than 2009-03-06 | C4 | 4360h | 4360h | SAES-SA-FP_3GPP | Huawei | shahab.lavasani@huawei.com | Rel-8 | 34 | Kimmo |  | 29.274, 29.275, 29.281 |  |  |
| 4025 | 1128.4.6 | Stage 3 for EPC to UTRAN |  | 545d? | 2007-02-05 A | 2009-03-06 A | 100% | 2007-02-05 | 2009-03-06 | 545d? | finish no earlier than 2009-03-06 | C4 | 4360h | 4360h | SAES-SA-FP_3GPP | Huawei | shahab.lavasani@huawei.com | Rel-8 | 38 | Kimmo |  | 29.274, 29.275, 29.281 | 21 |  |
| 4026 | 1128.4.7 | Stage 3 for EPC to 3GPP2 |  | 545d? | 2007-02-05 A | 2009-03-06 A | 100% | 2007-02-05 | 2009-03-06 | 545d? | finish no earlier than 2009-03-06 | C4 | 4360h | 4360h | SAES-SA-FP_3GPP | Huawei | shahab.lavasani@huawei.com | Rel-8 | 38 | Kimmo |  | 29.277, 29.276 | 21 |  |
| 4027 | 1128.4.8 | Stage 2 for Interoperation between LTE and CDMA2000 |  | 329d? | 2007-06-18 A | 2008-09-18 A | 100% | 2007-06-18 | 2008-09-18 | 329d? | finish no earlier than 2008-04-25 | S2 | 2632h | 2632h | EPStoC2k | Motorola, Vodafone | Irfan.Ali@motorola.com, chris.pudney@vodafone.com | Rel-8 | 37 | Maurice | EPStoC2k | 23.401, 23.402 |  |  |
| 4028 | 1128.4.9 | Stage 3 for Inter-system mobility between E-UTRAN and CDMA2000 |  | 545d? | 2007-02-05 A | 2009-03-06 A | 100% | 2007-02-05 | 2009-03-06 | 545d? | finish no earlier than 2009-03-06 | C1 | 4360h | 4360h | SAES-SA-FP_3GPP | Nokia Siemens Networks | robert.zaus@nsn.com | Rel-8 |  | Frederic |  | 24.301, 24.302 |  |  |
| 4029 | 1128.4.10 | Stage 3 for MME - SGSN signalling free protocol |  | 545d? | 2007-02-05 A | 2009-03-06 A | 100% | 2007-02-05 | 2009-03-06 | 545d? | finish no earlier than 2009-03-06 | C4 | 4360h | 4360h | SAES-SA-FP_3GPP | Huawei | shahab.lavasani@huawei.com | Rel-8 | 34 | Kimmo |  | 29.272, 29.274 |  |  |
| 4030 | 1128.5 | **SAE for support for non-3GPP accesses** |  | 1429d? | 2007-01-02 A | 2012-06-15 A | 100% | 2007-01-02 | 2012-06-15 | 1429d? |  | S2; S3; C1; C4; IETF | 123829h | 123829h | SAES-SA-FP_n3GPP | Motorola | Irfan.Ali@motorola.com | Rel-8 | 35 | Maurice | SAES-SA-FP_n3GPP |  |  |  |
| 4031 | 7.2.4.1 | Stage 2 for Host-based Mobility aspects |  | 373d? | 2007-01-02 A | 2008-06-05 A | 100% | 2007-01-02 | 2008-06-05 | 373d? | finish no earlier than 2008-04-11 | S2 | 2984h | 2984h | SAES-SA-FP_n3GPP-HBMob | Motorola | Irfan.Ali@motorola.com | Rel-8 |  | Maurice | SAES-SA-FP_n3GPP-HBMob | 23.402 |  |  |
| 4032 | 7.2.4.2 | Stage 2 for Network-based Mobility aspects |  | 448d? | 2007-01-02 A | 2008-09-18 A | 100% | 2007-01-02 | 2008-09-18 | 448d? | finish no earlier than 2008-09-18 | S2 | 3584h | 3584h | SAES-SA-FP_n3GPP-NBMob | Motorola | Irfan.Ali@motorola.com | Rel-8 |  | Maurice | SAES-SA-FP_n3GPP-NBMob | 23.402 |  |  |
| 4033 | 1128.5.3 | Stage 3 for Mobility management based on DSMIPv6 |  | 480d? | 2007-02-05 A | 2008-12-05 A | 100% | 2007-02-05 | 2008-12-05 | 480d? | finish no earlier than 2008-12-05 | C1 | 3840h | 3840h | SAES-SA-FP_n3GPP | Nokia Siemens Networks | robert.zaus@nsn.com | Rel-8 |  | Frederic |  | 24.303 |  |  |
| 4034 | 1128.5.4 | (IETF) Stage 3 for Mobility management based on DSMIPv6 (draft-ietf-mip6-hiopt) |  | 589d? | 2007-02-05 A | 2012-06-15 A | 100% | 2007-02-05 | 2012-06-15 | 589d? | finish no earlier than 2012-09-14 | C1-IETF | 4712h | 4712h | SAES-SA-FP_n3GPP | Mark Jones |  | Rel-8 | 52 | Frederic |  | RFC 6610 (was draft-ietf-mip6-hiopt) | 27 |  |
| 4035 | 1128.5.5 | (IETF) Stage 3 for Mobility management based on DSMIPv6 (RFC6275) |  | 356d? | 2007-02-05 A | 2011-07-29 A | 100% | 2007-02-05 | 2011-07-29 | 356d? | finish no earlier than 2011-07-29 | C1-IETF | 2848h | 2848h | SAES-SA-FP_n3GPP |  |  | Rel-8 | 52 | Frederic |  | RFC 6275 (was draft-ietf-mext-rfc3775bis) | 27 |  |
| 4036 | 1128.5.6 | Stage 3 for Mobility management based on MIP v4 |  | 480d? | 2007-02-05 A | 2008-12-05 A | 100% | 2007-02-05 | 2008-12-05 | 480d? | start no earlier than 2007-02-05 | C1 | 3840h | 3840h | SAES-SA-FP_n3GPP | Nokia Siemens Networks | robert.zaus@nsn.com | Rel-8 | 39 | Frederic |  | 24.304 | 21 |  |
| 4037 | 1128.5.7 | Stage 3 for Inter-system mobility between E-UTRAN and non 3GPP accesses |  | 545d? | 2007-02-05 A | 2009-03-06 A | 100% | 2007-02-05 | 2009-03-06 | 545d? | finish no earlier than 2009-03-06 | C1 | 4360h | 4360h | SAES-SA-FP_n3GPP | Nokia Siemens Networks | robert.zaus@nsn.com | Rel-8 | 38 | Frederic |  | 24.008, 24.301 | 21 |  |
| 4038 | 1128.5.8 | Stage 2 for Optimized Dual-Radio Handover with WiMAX |  | 249d? | 2007-06-25 A | 2008-06-05 A | 100% | 2007-06-25 | 2008-06-05 | 249d? | finish no earlier than 2008-06-09 | S2 | 1992h | 1992h | SAES-SA-FP_n3GPP-OptWIMAX | Motorola | Irfan.Ali@motorola.com | Rel-8 |  | Maurice | SAES-SA-FP_n3GPP-OptWIMAX | 23.402 |  |  |
| 4039 | 1128.5.9 | Stage 2 Security aspects for non-3GPP Access |  | 197d? | 2008-03-12 A | 2008-12-11 A | 100% | 2008-03-12 | 2008-12-11 | 197d? | finish no earlier than 2008-12-11 | S3 | 1576h | 1576h | SAES-SA-FP_n3GPP | Nokia Siemens Networks | marc.blommaert.ext@nsn.com | Rel-8 | 39 | Mirko |  | 33.402, 33.210, 33.310 | 21 |  |
| 4040 | 1128.5.10 | Stage 3 security aspects for DSMIPv6 Access |  | 480d? | 2007-02-05 A | 2008-12-05 A | 100% | 2007-02-05 | 2008-12-05 | 480d? | finish no earlier than 2008-12-05 | C1 | 3840h | 3840h | SAES-SA-FP_n3GPP | Nokia Siemens Networks | robert.zaus@nsn.com | Rel-8 | 37 | Frederic |  | 24.303 |  |  |
| 4041 | 1128.5.11 | Stage 3 security aspects for MIPv4 Access |  | 480d? | 2007-02-05 A | 2008-12-05 A | 100% | 2007-02-05 | 2008-12-05 | 480d? | finish no earlier than 2008-12-05 | C1 | 3840h | 3840h | SAES-SA-FP_n3GPP | Nokia Siemens Networks | robert.zaus@nsn.com | Rel-8 | 39 | Frederic |  | 24.304 | 21 |  |
| 4042 | 1128.5.12 | Stage 3 for Access to the EPC via non-3GPP access networks |  | 545d? | 2007-02-05 A | 2009-03-06 A | 100% | 2007-02-05 | 2009-03-06 | 545d? | finish no earlier than 2009-03-06 | C1 | 4360h | 4360h | SAES-SA-FP_n3GPP | Nokia Siemens Networks | robert.zaus@nsn.com | Rel-8 |  | Frederic |  | 24.302, 24.312 |  |  |
| 4043 | 1128.5.13 | Stage 3 for interfaces within EPC |  | 383d? | 2007-09-19 A | 2009-03-06 A | 100% | 2007-09-19 | 2009-03-06 | 383d? | finish no earlier than 2009-03-06 | C4 | 3064h | 3064h | SAES-SA-FP_n3GPP | Huawei | shahab.lavasani@huawei.com | Rel-8 | 37 | Kimmo |  | 29.274, 29.281 |  |  |
| 4044 | 1128.5.14 | Stage 3 for Interfaces EPC - non-3GPP IP access |  | 545d? | 2007-02-05 A | 2009-03-06 A | 100% | 2007-02-05 | 2009-03-06 | 545d? | finish no earlier than 2009-03-06 | C4 | 4360h | 4360h | SAES-SA-FP_n3GPP | Huawei | shahab.lavasani@huawei.com | Rel-8 | 34 | Kimmo |  | 29.273, 29.275 |  |  |
| 4045 | 1128.5.15 | (IETF) Stage 3 for Interfaces EPC - non-3GPP IP access |  | 1224.6d? | 2007-02-05 A | 2012-06-15 A | 100% | 2007-02-05 | 2012-06-15 | 1224.6d? | finish no earlier than 2012-06-15 | C4-IETF | 9788.8h | 9788.8h | SAES-SA-FP_n3GPP | Lionel Morand |  | Rel-8 | 52 | Kimmo |  | RFC 6611 (was draft-ietf-mip6-bootstrapping-integrated) | 27 |  |
| 4046 | 1128.5.16 | Stage 3 for AAA/HSS related |  | 480d? | 2007-02-05 A | 2008-12-05 A | 100% | 2007-02-05 | 2008-12-05 | 480d? | finish no earlier than 2008-12-05 | C4 | 3840h | 3840h | SAES-SA-FP_n3GPP | Huawei | shahab.lavasani@huawei.com | Rel-8 | 34 | Kimmo |  | 29.273 |  |  |
| 4047 | 1128.5.17 | Stage 3 for EPC - AAA interface |  | 480d? | 2007-02-05 A | 2008-12-05 A | 100% | 2007-02-05 | 2008-12-05 | 480d? | finish no earlier than 2008-12-05 | C4 | 3840h | 3840h | SAES-SA-FP_n3GPP | Huawei | shahab.lavasani@huawei.com | Rel-8 | 34 | Kimmo |  | 29.273 |  |  |
| 4048 | 1128.5.18 | Deleted (already covered) SAES-SA-FP_n3GPP Optimized Handover with CDMA | milestone | 0d? | 2007-06-25 A | 2007-06-25 A | 100% | 2007-06-25 | 2007-06-25 | 0d? | finish no earlier than 2007-06-25 | S2 |  |  | SAES-SA-FP_n3GPP-OptCDMA | Nokia Siemens Networks |  | Rel-8 |  | Maurice | SAES-SA-FP_n3GPP-OptCDMA |  |  | SP-37 |

Notes:
- 4019: CP#43 completed
- 4020: SP#41 completed
- 4021: CP#43 completed
- 4022: SP#41 completed
- 4023: SP#41 completed
- 4024: CP#43 completed
- 4025: CP#43 completed
- 4026: CP#43 completed
- 4027: SP#41 completed (except: Handover of multiple PDNs=>Rel-9)
- 4028: CP#43 completed
- 4029: CP#43 completed
- 4030: CP#43 completed. SP#39 retained in Rel-8 (in addition to the essential functionality defined in SP-070699). Replaces UID_340037
- 4031: SP#40 completed
- 4032: SP#41 completed
- 4033: CP#42 completed
- 4034: CP#56 completed
- 4035: SP#53/IETF#81 completed
- 4036: CP#42 completed
- 4037: CP#43 completed
- 4038: SP#40 completed
- 4039: SP#42 completed
- 4040: CP#42 completed
- 4041: CP#42 completed
- 4042: CP#43 completed
- 4043: CP#43 completed
- 4044: CP#43 completed
- 4045: CP#56 completed
- 4046: CP#42 completed
- 4047: CP#42 completed
- 4048: SP#37 stopped

| ID | WBS | Task | Type | Duration | Start | Finish | Complete | Baseline start | Baseline finish | Baseline duration | Constraint | Resources | Work | Actual work | Acronym | WI rapporteur name | Release | MCC resp | Acronym_3GU_Export | Impacted TSs and TRs | PCG approved | TSG approved | PCG stopped | TSG stopped | Special Focus Doc |
| --- | --- | --- | --- | --- | --- | --- | --- | --- | --- | --- | --- | --- | --- | --- | --- | --- | --- | --- | --- | --- | --- | --- | --- | --- | --- |
| 4049 | 1128.6 | **Single Radio Voice Call Continuity for 3GPP (SRVCC)** |  | 569d? | 2007-01-02 A | 2009-03-06 A | 100% | 2007-01-02 | 2009-03-06 | 569d? |  | S2; C1; C4 | 19856h | 19856h | SAES-SRVCC | Nokia Siemens Networks | Rel-8 | Maurice | SAES-SRVCC |  |  |  |  |  |  |
| 4050 | 1128.6.1 | Stage 2 for 2G/3G SRVCC |  | 448d? | 2007-01-02 A | 2008-09-18 A | 100% | 2007-01-02 | 2008-09-18 | 448d? | finish no earlier than 2008-09-15 | S2 | 3584h | 3584h | SAES-SRVCC | Nokia Siemens Networks | Rel-8 | Maurice |  | New 23.216 |  |  |  |  |  |
| 4051 | 1128.6.2 | Stage 3 for SRVCC in EPS |  | 201d? | 2008-05-30 A | 2009-03-06 A | 100% | 2008-05-30 | 2009-03-06 | 201d? | finish no earlier than 2009-03-06 | C1 | 1608h | 1608h | SAES-SRVCC | Nokia Siemens Networks | Rel-8 | Frederic |  | 23.009, 24.008, New 24.301 | 21 | 41 |  |  |  |
| 4052 | 1128.6.3 | MME to MSC interface for SRVCC |  | 126d? | 2008-09-12 A | 2009-03-06 A | 100% | 2008-09-12 | 2009-03-06 | 126d? | finish no earlier than 2009-03-06 | C4 | 1008h | 1008h | SAES-SRVCC | Nokia Siemens Networks | Rel-8 | Kimmo |  | 23.003, 23.008, New (29.274, 29.277, 29.280) | 21 | 41 |  |  |  |
| 4053 | 1128.7 | Voice Call Continuity for CDMA2000 1X |  | 249d? | 2007-06-25 A | 2008-06-05 A | 100% | 2007-06-25 | 2008-06-05 | 249d? | finish no earlier than 2008-06-13 | S2 | 1992h | 1992h | SAES-VCC_1X | Nokia Siemens Networks | Rel-8 | Maurice | SAES-VCC_1X |  |  |  |  |  |  |
| 4054 | 1128.8 | SAE impacts on IMS |  | 373d? | 2007-01-02 A | 2008-06-05 A | 100% | 2007-01-02 | 2008-06-05 | 373d? | finish no earlier than 2008-06-13 | S2 | 2984h | 2984h | SAES-SA_IMS | Nokia Siemens Networks | Rel-8 | Maurice | SAES-SA_IMS |  |  |  |  |  |  |
| 4055 | 1128.9 | **CS Fallback in EPS** |  | 258d? | 2008-03-12 A | 2009-03-06 A | 100% | 2008-03-12 | 2009-03-06 | 258d? |  | S2; C1; C4 | 9384h | 9384h | SAES-CSFB | T-Mobile, Vodafone | Rel-8 | Maurice | SAES-CSFB |  | 21 | 39 |  |  |  |
| 4056 | 1128.9.1 | Stage 2 for CS Fallback in EPS |  | 62d? | 2008-03-12 A | 2008-06-05 A | 100% | 2008-03-12 | 2008-06-05 | 62d? | finish no earlier than 2008-12-05 | S2 | 496h | 496h | SAES-CSFB | T-Mobile, Vodafone | Rel-8 | Maurice |  | New (23.272, 23.401) | 21 | 40 |  |  |  |
| 4057 | 1128.9.2 | CT1 part of Stage 3 for CS Fallback in EPS |  | 201d? | 2008-05-30 A | 2009-03-06 A | 100% | 2008-05-30 | 2009-03-06 | 201d? | finish no earlier than 2009-03-06 | C1 | 1608h | 1608h | SAES-CSFB | NEC | Rel-8 | Frederic |  | 24.007, 24.008, 24.011, 29.018, New (24.301, 24.801, 29.118) | 21 | 40 |  |  |  |
| 4058 | 1128.9.3 | CT4 part of Stage 3 for CS Fallback in EPS |  | 136d? | 2008-05-30 A | 2008-12-05 A | 100% | 2008-05-30 | 2008-12-05 | 136d? | finish no earlier than 2008-12-05 | C4 | 1088h | 1088h | SAES-CSFB | NEC | Rel-8 | Kimmo |  | 23.007, 23.008, 29.274, New 29.277 | 21 | 40 |  |  |  |
| 4059 | 1128.10 | System enhancements for the use of IMS services in local breakout |  | 62d? | 2008-03-12 A | 2008-06-05 A | 100% | 2008-03-12 | 2008-06-05 | 62d? | finish no earlier than 2008-06-05 | S2 | 496h | 496h | SAES-IMS_LBO | Telecom Italia | Rel-8 | Maurice | SAES-IMS_LBO | 23.228, 23.221, 23.203 | 21 | 39 |  |  |  |
| 4060 | 1128.11 | **EPC Data Definitions** |  | 309d? | 2008-01-07 A | 2009-03-12 A | 100% | 2008-01-07 | 2009-03-12 | 309d? |  | S5 | 7144h | 7144h | EPC-OAM |  | Rel-8 | Mirko | EPC-OAM |  | 21 | 39 |  |  |  |
| 4061 | 1128.11.1 | EPC Network Resource Model (NRM) Integration Reference Point (IRP) |  | 309d? | 2008-01-07 A | 2009-03-12 A | 100% | 2008-01-07 | 2009-03-12 | 309d? | finish no earlier than 2009-03-12 | S5 | 2472h | 2472h | EPC-OAM | Huawei | Rel-8 | Mirko |  | New (32.751, 32.752, 32.753, 32.755) | 21 | 38 |  |  |  |
| 4062 | 1128.11.2 | Performance measurements for EPC |  | 275d? | 2008-02-22 A | 2009-03-12 A | 100% | 2008-02-22 | 2009-03-12 | 275d? | finish no earlier than 2009-03-12 | S5 | 2200h | 2200h | EPC-OAM | China Mobile | Rel-8 | Mirko |  | New 32.426 | 21 | 39 |  |  |  |
| 4063 | 1128.12 | EPC Charging |  | 309d? | 2008-01-07 A | 2009-03-12 A | 100% | 2008-01-07 | 2009-03-12 | 309d? | finish no earlier than 2009-03-12 | S5 | 2472h | 2472h | EPC-CH | Nokia Siemens Networks | Rel-8 | Mirko | EPC-CH | 32.240, 32.296, 32.251, 32.252, 32.298, 32.299 | 21 | 38 |  |  |  |
| 4064 | 1128.13 | Domain Name System Procedures for Evolved Packet System (DEPS) |  | 179.75d? | 2008-05-30 A | 2009-03-06 A | 100% | 2008-05-30 | 2009-03-06 | 179.75d? | finish no earlier than 2009-03-06 | C4 | 1438h | 1438h | SAES-DEPS | TeliaSonera | Rel-8 | Kimmo | SAES-DEPS | 23.003, New 29.303 | 21 | 40 |  |  |  |
| 4065 | 1128.14 | InterWorking Function (IWF) between MAP based and Diameter based interfaces |  | 126d? | 2008-09-12 A | 2009-03-06 A | 100% | 2008-09-12 | 2009-03-06 | 126d? | finish no earlier than 2009-03-06 | C4 | 1008h | 1008h | SAES-MAP2Diam | Huawei | Rel-8 | Kimmo | SAES-MAP2Diam | New 29.305 | 21 | 41 |  |  |  |
| 4066 | 1128.15 | **CT6 aspects of SAE** |  | 847d? | 2008-03-07 A | 2011-06-03 A | 100% | 2008-03-07 | 2011-06-03 | 847d? |  | C6 | 13480h | 13480h | SAES | Nokia | Rel-8 | Xavier |  |  | 21 | 39 |  |  |  |
| 4067 | 1128.15.1 | Core specification for CT6 aspects of SAE |  | 321d? | 2008-03-07 A | 2009-05-29 A | 100% | 2008-03-07 | 2009-05-29 | 321d? | finish no earlier than 2009-05-29 | C6 | 2568h | 2568h | SAES | Nokia | Rel-8 | Xavier |  | 31.102, 31.111 | 21 | 39 |  |  |  |
| 4068 | 1128.15.2 | Test interworking of LTE Terminals with the USIM |  | 526d? | 2008-12-05 A | 2010-12-10 A | 100% | 2008-12-05 | 2010-12-10 | 526d? | finish no earlier than 2010-12-10 | C6 | 4208h | 4208h | SAES-USIM_LTE-Test | Comprion | Rel-8 | Xavier | SAES-USIM_LTE-Test | 31.121, 31.124 | 22 | 42 |  |  |  |
| 4069 | 1128.15.3 | Test interworking of IP Multimedia Services Identity Module (ISIM) terminals with IP Multimedia Subsystem (IMS) |  | 186d? | 2010-09-17 A | 2011-06-03 A | 100% | 2010-09-17 | 2011-06-03 | 186d? | finish no earlier than 2011-06-03 | C6 | 1488h | 1488h | SAES-ISIM_IMS_Test | Comprion | Rel-8 | Xavier | SAES-ISIM_IMS_Test | 31.121, 31.124, New TS 31.134 | 25 | 49 |  |  |  |
| 4070 | 1128.16 | Issues for CT1 TR 24.801 |  | 420d? | 2007-01-04 A | 2008-12-05 A | 100% | 2007-01-04 | 2008-12-05 | 420d? | finish no earlier than 2008-12-05 | C1 | 3360h | 3360h | SAES | Nokia Siemens Networks | Rel-8 | Frederic |  | 24.801 | 21 | 39 |  |  |  |
| 4071 | 1128.17 | Issues for CT3 TR 29.804 |  | 420d? | 2007-02-05 A | 2008-09-12 A | 100% | 2007-02-05 | 2008-09-12 | 420d? | finish no earlier than 2008-12-12 | C3 | 3360h | 3360h | SAES | Ericsson | Rel-8 | Adrian |  | 29.804 | 21 | 39 |  |  |  |
| 4072 | 1128.18 | Deleted - Issues for CT4 TR 29.803 |  | 420d? | 2007-01-04 A | 2008-09-12 A | 100% | 2007-01-04 | 2008-09-12 | 420d? | finish no earlier than 2008-12-11 | C4 | 3360h | 3360h | SAES | Huawei | Rel-8 | Kimmo |  | 29.803 | 21 | 39 | PCG-21 | CP-41 |  |
| 4073 | 1128.19 | Deleted (covered by 380068): Functions and procedures for SAE to support LCS | milestone | 0d? | 2008-03-03 A | 2008-03-03 A | 100% | 2008-03-03 | 2008-03-03 | 0d? | finish no earlier than 2008-03-03 | S2 |  |  | SAES-SA-FP_LCS | Nokia Siemens Networks | Rel-8 | Maurice | SAES-SA-FP_LCS |  |  |  |  | SP-37 |  |
| 4074 | 1128.20 | Deleted (covered by 380064): SAE aspects of Emergency Calls | milestone | 0d? | 2008-03-03 A | 2008-03-03 A | 100% | 2008-03-03 | 2008-03-03 | 0d? | start no earlier than 2008-03-03 | S2 |  |  | SAES-SA-EmCall | Nokia Siemens Networks | Rel-8 | Maurice | SAES-SA-EmCall |  |  |  |  | SP-37 | Public Safety (I-A) |

Notes:
- 4049: CP#43 completed. SP#38 WID approved (extract from SAE WID SP-070817). / WI rapporteur e-mail: curt.c.wong@nokia.com
- 4050: SP#41 completed. SP#38 WID approved / WI rapporteur e-mail: curt.c.wong@nokia.com
- 4051: CP#43 completed / WI rapporteur e-mail: robert.zaus@nsn.com
- 4052: CP#43 completed / WI rapporteur e-mail: Giorgi Gulbani
- 4053: SP#40 completed / WI rapporteur e-mail: balazs.bertenyi@nsn.com
- 4054: SP#40 completed / WI rapporteur e-mail: balazs.bertenyi@nsn.com
- 4055: CP#43 completed / WI rapporteur e-mail: sabine.demel@t-mobile.at, chris.pudney@vodafone.com
- 4056: SP#40 completed / WI rapporteur e-mail: sabine.demel@t-mobile.at, chris.pudney@vodafone.com
- 4057: CP#43 completed / WI rapporteur e-mail: yannick.lair@nectech.fr
- 4058: CP#42 completed / WI rapporteur e-mail: yannick.lair@nectech.fr
- 4059: SP#40 completed / WI rapporteur e-mail: mario.madella@telecomitalia.it
- 4060: SP#43 completed
- 4061: SP#43 completed / WI rapporteur e-mail: WANG, Xuelong
- 4062: SP#43 completed / WI rapporteur e-mail: Li Jian (lijian@chinamobile.com), Liang Shuangchun (liangshuangchun@cmdi.chinamobile.com)
- 4063: SP#43 completed / WI rapporteur e-mail: Gerald.Goermer@nsn.com
- 4064: CP#43 completed / WI rapporteur e-mail: jouni.korhonen@teliasonera.com
- 4065: CP#43 completed. Triggered by UID_380023 (FS_MAP2Diam) / WI rapporteur e-mail: liming49985@huawei.com
- 4066: CP#44 completed core specification / WI rapporteur e-mail: Rune Lindholm
- 4067: CP#44 completed (specified Network Measurement Results collection via USAT) / WI rapporteur e-mail: Rune Lindholm
- 4068: CP#50 completed. Steering of Roaming test cases have been introduced. Remaining issues CSG display testing (Provide Local Information, Call Control for EPS/PDN, Event Download (Access Technology Change - Multiple Access Technologies) / WI rapporteur e-mail: Udo Willenbrink (uwillenbrink@comprion.com )
- 4069: CP#52 completed. Linked to R5 UID_1273 Provisioning of IP-based multimedia services (24.229, 31.103), R8 UID_390021 CT6 aspects of SAE, UID_420018 Test interworking of LTE Terminals with the USIM, R UID_450018 Testing SMS over IMS in E-UTRAN (34.229). / WI rapporteur e-mail: Udo Willenbrink (uwillenbrink@comprion.com )
- 4070: CP#43 completed / WI rapporteur e-mail: robert.zaus@nsn.com
- 4071: CP#41 completed / WI rapporteur e-mail: j.javier.pastor@ericsson.com
- 4072: CP#41 Work stopped and continued in Normative specifications
- 4073: SP#37 stopped
- 4074: SP#37 stopped

| ID | WBS | Task | Type | Duration | Start | Finish | Complete | Baseline start | Baseline finish | Baseline duration | Constraint | Resources | Work | Actual work | Acronym | Release | TSG approved | MCC resp | TSG stopped | Acronym_3GU_Export | WI rapporteur name | WI rapporteur e-mail | PCG approved | Status Report | PCG stopped |
| --- | --- | --- | --- | --- | --- | --- | --- | --- | --- | --- | --- | --- | --- | --- | --- | --- | --- | --- | --- | --- | --- | --- | --- | --- | --- |
| 4075 | 1128.21 | **Deleted - CT aspects of SAES** |  | 138d? | 2007-09-04 A | 2008-03-14 A | 100% | 2007-09-04 | 2008-03-14 | 138d? |  | C3; C1; C4 | 3312h | 1104h | SAES-St3 | Rel-8 | 34 | Frederic | SP-37 | SAES-St3 |  |  |  |  |  |
| 4076 | 1128.21.1 | Deleted - CT1 aspects of SAES | milestone | 0d? | 2007-09-04 A | 2007-09-04 A | 100% | 2007-09-04 | 2007-09-04 | 0d? | start no earlier than 2007-09-04 | C1 |  |  | SAES-St3 | Rel-8 |  | Frederic | SP-37 |  |  |  |  |  |  |
| 4077 | 1128.21.2 | Deleted - Interoperability | milestone | 0d? | 2008-03-14 A | 2008-03-14 A | 100% | 2008-03-14 | 2008-03-14 | 0d? | start no earlier than 2008-03-14 | C1 |  |  | SAES-St3-interop | Rel-8 | 34 | Frederic | SP-37 | SAES-St3-interop |  |  |  |  |  |
| 4078 | 1128.21.3 | Deleted - CT3 aspects of SAES | milestone | 0d? | 2007-09-04 A | 2007-09-04 A | 100% | 2007-09-04 | 2007-09-04 | 0d? | start no earlier than 2007-09-04 | C3 |  |  | SAES | Rel-8 |  | Adrian | SP-37 |  |  |  |  |  |  |
| 4079 | 1128.21.4 | Deleted - CT4 aspects of SAES | milestone | 0d? | 2007-09-04 A | 2007-09-04 A | 100% | 2007-09-04 | 2007-09-04 | 0d? | start no earlier than 2007-09-04 | C4 |  |  | SAES | Rel-8 |  | Kimmo | SP-37 |  |  |  |  |  |  |
| 4080 | 1128.21.5 | Deleted - UE to EPC NAS signalling (incl. MBMS and QoS aspects) | milestone | 0d? | 2008-03-14 A | 2008-03-14 A | 100% | 2008-03-14 | 2008-03-14 | 0d? | start no earlier than 2008-03-14 | C1 |  |  | SAES-St3-sig | Rel-8 | 34 | Frederic | SP-37 | SAES-St3-sig |  |  |  |  |  |
| 4081 | 1128.21.6 | Deleted - User and Control plane protocols | milestone | 0d? | 2007-09-21 A | 2007-09-21 A | 100% | 2007-09-21 | 2007-09-21 | 0d? | start no earlier than 2007-09-21 | C4 |  |  | SAES-St3-prot | Rel-8 | 34 | Kimmo | SP-37 | SAES-St3-prot |  |  |  |  |  |
| 4082 | 1128.22 | Deleted - Architecture enhancements for non-3GPP accesses | milestone | 0d? | 2007-09-04 A | 2007-09-04 A | 100% | 2007-09-04 | 2007-09-04 | 0d? | start no earlier than 2007-09-04 | S2 |  |  | SAES-non_3GPP | Rel-8 | 34 | Maurice | SP-34 | SAES-non_3GPP | Motorola | Irfan.Ali@motorola.com |  |  |  |
| 4083 | 1128.23 | Deleted - Stage 2 of architecture for the 3GPP System Architecture Evolution | milestone | 0d? | 2007-10-02 A | 2007-10-02 A | 100% | 2007-10-02 | 2007-10-02 | 0d? | start no earlier than 2007-10-02 | S2 |  |  | SAES-St2 | Rel-8 |  | Maurice | SP-34 | SAES-St2 | Vodafone | chris.pudney@vodafone.com |  |  |  |
| 4084 | 1128.24 | Deleted - SA aspects of System Architecture Evolution |  | 384d? | 2006-04-12 A | 2007-10-01 A | 100% | 2006-04-12 | 2007-10-01 | 384d? | finish no earlier than 2007-10-02 | S2 | 3072h | 3072h | SAES-SA | Rel-8 |  | Maurice | SP-34 | SAES-SA |  |  |  |  |  |
| 4085 | 1129 | Conformance Test Aspects – Mobility management based on DSMIPv6 (Dual-Stack Mobile IPv6) |  | 261d? | 2009-09-18 A | 2010-09-17 A | 100% | 2009-09-18 | 2010-09-17 | 261d? | finish no earlier than 2010-09-17 | R5 | 2088h | 2088h | DSMIPv6_UEConTest | Rel-8 | 45 | Ingbert |  | DSMIPv6_UEConTest | Qualcomm | Lena Chaponniere (lchaponn@qualcomm.com) | 23 | RP-100738 |  |
| 4086 | 1130 | **IMS Centralized Service control** |  | 2392.1d? | 2005-11-01 A | 2014-12-09 A | 100% | 2005-11-01 | 2014-12-05 | 2387.1d? |  | S1; S2; C1; C3; C4; IETF | 239598h | 239598h | ICSRA | Rel-8 | 37 | Alain |  | ICSRA | AT&T | Randolph Wohlert (rwohlert@tri.sbc.com) |  |  |  |
| 4087 | 1130.1 | Stage 1 for ICS Requirement and Architecture |  | 138d? | 2007-09-03 A | 2008-03-12 A | 100% | 2007-09-03 | 2008-03-12 | 138d? | finish no earlier than 2007-12-14 | S1 | 1104h | 1104h | ICSRA | Rel-8 | 38 | Alain |  |  | AT&T | Randolph Wohlert (rwohlert@tri.sbc.com) | 21 |  |  |
| 4088 | 1130.2 | Stage 2 for ICS Requirement and Architecture |  | 125d? | 2007-12-14 A | 2008-06-05 A | 100% | 2007-12-14 | 2008-06-05 | 125d? | start no earlier than 2007-12-14 | S2 | 1000h | 1000h | ICSRA-St2 | Rel-8 | 38 | Maurice |  | ICSRA-St2 | Alcatel-Lucent |  | 21 |  |  |
| 4089 | 1130.3 | **Stage 3 for ICSRA – Protocol, Addressing, Subscriber Data** |  | 2392.1d? | 2005-11-01 A | 2014-12-09 A | 100% | 2005-11-01 | 2014-12-05 | 2387.1d? |  | C1; C3; C4; IETF | 122674h | 122674h | ICSRA | Rel-8 |  | Frederic |  |  | Ericsson | sean.schneyer@ericsson.com |  |  |  |
| 4090 | 1130.3.1 | CT1 aspects - Stage 3 for ICSRA |  | 201d? | 2008-05-30 A | 2009-03-06 A | 100% | 2008-05-30 | 2009-03-06 | 201d? | finish no earlier than 2009-03-06 | C1 | 1608h | 1608h | ICSRA | Rel-8 | 40 | Frederic |  |  | Ericsson | Sean Schneyer | 21 |  |  |
| 4091 | 1130.3.2 | (IETF) CT1 aspects - Stage 3 for ICSRA (draft-ietf-salud-alert-info-urns) |  | 1244d? | 2008-05-30 A | 2014-12-09 A | 100% | 2008-05-30 | 2014-12-05 | 1242d? | finish no earlier than 2014-12-09 | C1-IETF | 9952h | 9952h | ICSRA | Rel-8 | 52 | Frederic |  |  | Roland Jesske | Roland Jesske | 27 |  |  |
| 4092 | 1130.3.3 | (IETF) CT1 aspects - Stage 3 for ICSRA (RFC 6871) |  | 779d? | 2008-05-30 A | 2013-03-01 A | 100% | 2008-05-30 | 2013-03-01 | 779d? | finish no earlier than 2013-02-28 | C1-IETF | 6232h | 6232h | ICSRA | Rel-8 | 52 | Frederic |  |  | Andrew Allen |  | 27 |  |  |
| 4093 | 1130.3.4 | (IETF) CT1 aspects - Stage 3 for ICSRA (RFC 7195) |  | 1117d? | 2008-05-30 A | 2014-06-13 A | 100% | 2008-05-30 | 2014-06-13 | 1117d? | finish no earlier than 2014-06-13 | C1-IETF | 8936h | 8936h | ICSRA | Rel-8 | 52 | Frederic |  |  | Andrew Allen |  | 27 |  |  |
| 4094 | 1130.3.5 | (IETF) CT1 aspects - Stage 3 for ICSRA (RFC 7006) |  | 977d? | 2008-06-03 A | 2013-12-06 A | 100% | 2008-06-03 | 2013-12-06 | 977d? | finish no earlier than 2013-12-06 | C1-IETF | 7816h | 7816h | ICSRA | Rel-8 | 52 | Frederic |  |  | Andrew Allen |  | 27 |  |  |
| 4095 | 1130.3.6 | CT3 aspects - Stage 3 for ICSRA |  | 201d? | 2008-05-30 A | 2009-03-06 A | 100% | 2008-05-30 | 2009-03-06 | 201d? | finish no earlier than 2009-03-06 | C3 | 1608h | 1608h | ICSRA | Rel-8 | 40 | Adrian |  |  | Mavenir | Brett Wallis ( brett@mavenir.com) | 21 |  |  |
| 4096 | 1130.3.7 | CT4 aspects - Stage 3 for ICSRA |  | 136d? | 2008-05-30 A | 2008-12-05 A | 100% | 2008-05-30 | 2008-12-05 | 136d? | start no earlier than 2008-05-30 | C4 | 1088h | 1088h | ICSRA | Rel-8 | 40 | Kimmo |  |  | Ericsson | Sean Schneyer | 21 |  |  |
| 4097 | 1130.3.8 | (IETF) CT4 aspects - Stage 3 for ICSRA (RFC 7254) |  | 1034.8d? | 2005-11-01 A | 2014-06-13 A | 100% | 2005-11-01 | 2014-06-13 | 1034.8d? | finish no earlier than 2014-06-13 | C4-IETF | 8278.4h | 8278.4h | ICSRA | Rel-8 | 52 | Kimmo |  |  | Andrew Allen |  | 27 |  |  |
| 4098 | 1130.3.9 | Deleted - Stage 3 for ICSRA – I1 interface |  | 76d? | 2008-05-30 A | 2008-09-12 A | 100% | 2008-05-30 | 2008-09-12 | 76d? | finish no earlier than 2008-09-12 | C1 | 608h | 608h | ICSRA | Rel-8 | 40 | Frederic | CP-41 |  | Huawei | xupeili@huawei.com | 21 |  | PCG-21 |

Notes:
- 4075: SP#37 stopped
- 4076: SP#37 stopped
- 4077: SP#37 stopped
- 4078: SP#37 stopped
- 4079: SP#37 stopped / Impacted TSs and TRs: 29.803
- 4080: SP#37 stopped
- 4081: SP#37 stopped
- 4082: SP#34 stopped. Replaced by UID_350027 and its children / Impacted TSs and TRs: 23.402
- 4083: SP#34 stopped. Replaced by UIDs 340018 and 340037. (SP#34 report discussion of SP-060917.) / Impacted TSs and TRs: 23.002, 23.060, 23.107, 23.203, 23.228, 23.234, 23.246, 23.271, 23.279
- 4084: SP#34 stopped
- 4085: RP#49 completed. Testing for CT1's UID_360022 (24.303) under Rel-8 Feature SAES / Impacted TSs and TRs: 36.508, 36.523-1, 36.523-2, 36.523-3
- 4086: CP#46 completed
- 4087: SP#39 completed / Impacted TSs and TRs: 22.101
- 4088: SP#40 completed / Impacted TSs and TRs: 23.292, 23.206
- 4089: CP#46 completed
- 4090: CP#46 completed / Impacted TSs and TRs: 24.229, new (24.292, 24.286)
- 4091: In RFC Editors Queue. Dec.14: 75->90; 7/3/16: 90%->100 / Impacted TSs and TRs: draft-ietf-salud-alert-info-urns
- 4092: CP#59 completed / Impacted TSs and TRs: RFC 6871 (was draft-ietf-mmusic-sdp-media-capabilities)
- 4093: CP#64 complete / Impacted TSs and TRs: RFC 7195 (was draft-ietf-mmusic-sdp-cs)
- 4094: CP#62 completed / Impacted TSs and TRs: RFC7006 (was draft-ietf-mmusic-sdp-miscellaneous-caps)
- 4095: CP#43 completed / Impacted TSs and TRs: new 29.292
- 4096: CP#42 completed / Impacted TSs and TRs: 23.003, 29.232, 23.018, 29.002
- 4097: CP#64 complete / Impacted TSs and TRs: RFC 7254 (was draft-montemurro-gsma-imei-urn)
- 4098: CP#41 work stopped / Impacted TSs and TRs: 24.293

| ID | WBS | Task | Duration | Start | Finish | Complete | Baseline start | Baseline finish | Baseline duration | Constraint | Resources | Work | Actual work | Acronym | Release | TSG approved | MCC resp | Acronym_3GU_Export | WI rapporteur name | WI rapporteur e-mail | PCG approved |
| --- | --- | --- | --- | --- | --- | --- | --- | --- | --- | --- | --- | --- | --- | --- | --- | --- | --- | --- | --- | --- | --- |
| 4099 | 1131 | **IMS Multimedia Telephony and Supplementary Services** | 2002d? | 2007-05-02 A | 2014-12-09 A | 100% | 2007-05-02 | 2014-12-05 | 1997d? |  | S1; S5; C1; C3; C4; IETF | 272222h | 272222h | IMSTSS | Rel-8 | 37 | Alain | IMSTSS |  |  |  |
| 4100 | 1131.1 | **General aspects of IMS Sup Services** | 395d? | 2007-09-03 A | 2009-03-06 A | 100% | 2007-09-03 | 2009-03-06 | 395d? |  | S1; C1; C3; C4 | 19232h | 19232h | IMSSS-Gal | Rel-8 | 37 | Alain | IMSSS-Gal | Ericsson | Susana Sabater |  |
| 4101 | 1131.1.1 | Service and Capability for Core IMS - inclusion of TISPAN requirements | 75d? | 2007-09-03 A | 2007-12-14 A | 100% | 2007-09-03 | 2007-12-14 | 75d? | finish no earlier than 2007-12-14 | S1 | 600h | 600h | TISCAPR8 | Rel-8 | 37 | Alain | TISCAPR8 | Ericsson | Susana Sabater |  |
| 4102 | 1131.1.2 | Documentation of TISPAN R1 and R2 in CT1 | 208d? | 2007-11-28 A | 2008-09-12 A | 100% | 2007-11-28 | 2008-09-12 | 208d? | finish no earlier than 2008-09-12 | C1 | 1664h | 1664h | REDOC_TIS-C1 | Rel-8 | 38 | Frederic | REDOC_TIS-C1 | Nokia Siemens Networks | peter.leis@nsn.com | 21 |
| 4103 | 1131.1.3 | Documentation of TISPAN R1 and R2 in CT3 | 333d? | 2007-11-28 A | 2009-03-06 A | 100% | 2007-11-28 | 2009-03-06 | 333d? | finish no earlier than 2009-03-06 | C3 | 2664h | 2664h | REDOC_TIS-C3 | Rel-8 | 38 | Adrian | REDOC_TIS-C3 | Nokia Siemens Networks | peter.leis@nsn.com | 21 |
| 4104 | 1131.1.4 | Documentation of TISPAN R1 and R2 in CT4 | 208d? | 2007-11-28 A | 2008-09-12 A | 100% | 2007-11-28 | 2008-09-12 | 208d? | finish no earlier than 2008-09-12 | C4 | 1664h | 1664h | REDOC_TIS-C4 | Rel-8 | 38 | Kimmo | REDOC_TIS-C4 | Nokia Siemens Networks | peter.leis@nsn.com | 21 |
| 4105 | 1131.2 | **IMS Multimedia Telephony Service** | 394d? | 2007-09-10 A | 2009-03-12 A | 100% | 2007-09-10 | 2009-03-12 | 394d? |  | S1; S5 | 9296h | 9296h | IMS-MMTel | Rel-8 | 37 | Alain | IMS-MMTel |  |  |  |
| 4106 | 1131.2.1 | Merging TISPAN MMTel [requirements] for Common IMS | 65d? | 2007-09-10 A | 2007-12-07 A | 100% | 2007-09-10 | 2007-12-07 | 65d? | finish no earlier than 2007-12-07 | S1 | 520h | 520h | TMMTEL | Rel-8 | 37 | Alain | TMMTEL | Nokia Siemens Networks |  |  |
| 4107 | 1131.2.2 | Multimedia Telephony Service and Supplementary Services (MMTel) offline Charging | 309d? | 2008-01-07 A | 2009-03-12 A | 100% | 2008-01-07 | 2009-03-12 | 309d? | finish no earlier than 2009-03-12 | S5 | 2472h | 2472h | MMTel-CH | Rel-8 | 38 | Mirko | MMTel-CH | Alcatel-Lucent | maryse.gardella@alcatel-lucent.com | 21 |
| 4108 | 1131.3 | **Call Completion on Busy Subscriber (CCBS)/Call Completion on Non-Reachable (CCNR) on IMS** | 1608d? | 2007-05-02 A | 2013-06-14 A | 100% | 2007-05-02 | 2013-06-14 | 1608d? |  | C1; C3; IETF | 71528h | 71528h | CCBS_CCNR | Rel-8 | 38 | Frederic | CCBS_CCNR | Deutsche Telekom | martin.huelsemann@telekom.de | 21 |
| 4109 | 1131.3.1 | CT1 part of Stage 3 CCBS_CCNR | 483d? | 2007-05-02 A | 2009-03-06 A | 100% | 2007-05-02 | 2009-03-06 | 483d? | finish no earlier than 2009-03-06 | C1 | 3864h | 3864h | CCBS_CCNR | Rel-8 | 38 | Frederic |  | Deutsche Telekom | martin.huelsemann@telekom.de | 21 |
| 4110 | 1131.3.2 | CT3 part of Stage 3 CCBS_CCNR | 418d? | 2007-05-02 A | 2008-12-05 A | 100% | 2007-05-02 | 2008-12-05 | 418d? | finish no earlier than 2008-12-05 | C3 | 3344h | 3344h | CCBS_CCNR | Rel-8 | 38 | Adrian |  | Deutsche Telekom | martin.huelsemann@telekom.de | 21 |
| 4111 | 1131.3.3 | (IETF) Stage 3 CCBS_CCNR [RFC 6910 (was draft-ietf-bliss-call-completion)] | 1608d? | 2007-05-02 A | 2013-06-14 A | 100% | 2007-05-02 | 2013-06-14 | 1608d? | finish no earlier than 2013-06-10 | C1-IETF; C3-IETF | 25728h | 25728h | CCBS_CCNR | Rel-8 | 52 | Frederic |  | Roland Jesske |  | 27 |
| 4112 | 1131.4 | **Flexible Alerting** | 288d? | 2008-01-30 A | 2009-03-06 A | 100% | 2008-01-30 | 2009-03-06 | 288d? |  | S1; C1 | 7582.4h | 7582.4h | FA | Rel-8 | 39 | Alain | FA | Nortel | milanpa@nortel.com | 21 |
| 4113 | 1131.4.1 | Stage 1 FA | 92d? | 2008-01-30 A | 2008-06-05 A | 100% | 2008-01-30 | 2008-06-05 | 92d? |  | S1 | 670.4h | 670.4h | FA | Rel-8 | 39 | Alain |  | Telecom Italia |  | 21 |
| 4114 | 1131.4.2 | Stage 3 FA | 288d? | 2008-01-30 A | 2009-03-06 A | 100% | 2008-01-30 | 2009-03-06 | 288d? | finish no earlier than 2009-03-06 | C1 | 2304h | 2304h | FA | Rel-8 | 39 | Frederic |  | Nortel | milanpa@nortel.com | 21 |
| 4115 | 1131.5 | **Communication Wait on IMS** | 1965d? | 2007-06-22 A | 2014-12-09 A | 100% | 2007-06-22 | 2014-12-05 | 1960d? |  | C1; C3; IETF | 61880h | 61880h | CW_IMS | Rel-8 | 38 | Frederic | CW_IMS | Deutsche Telekom | martin.huelsemann@telekom.de | 21 |
| 4116 | 1131.5.1 | CT1 part of Stage 3 CW-IMS | 331d? | 2007-11-30 A | 2009-03-06 A | 100% | 2007-11-30 | 2009-03-06 | 331d? | finish no earlier than 2009-03-06 | C1 | 2648h | 2648h | CW_IMS | Rel-8 | 38 | Frederic |  | Deutsche Telekom | martin.huelsemann@telekom.de | 21 |
| 4117 | 1131.5.2 | (IETF) Stage 3 CW-IMS (salud-alert-info-urns) | 1244d? | 2007-06-22 A | 2014-12-09 A | 100% | 2007-06-22 | 2014-12-05 | 1242d? | finish no earlier than 2014-12-09 | C1-IETF | 9952h | 9952h | CW_IMS | Rel-8 | 52 | Frederic |  | Roland Jesske | Roland Jesske | 27 |
| 4118 | 1131.5.3 | CT3 part of Stage 3 CW-IMS | 265d? | 2007-11-30 A | 2008-12-04 A | 100% | 2007-11-30 | 2008-12-04 | 265d? | finish no earlier than 2008-12-05 | C3 | 2120h | 2120h | CW_IMS | Rel-8 | 38 | Adrian |  | Deutsche Telekom | martin.huelsemann@telekom.de | 21 |
| 4119 | 1131.6 | **IMS Charging** | 389d? | 2007-09-17 A | 2009-03-12 A | 100% | 2007-09-17 | 2009-03-12 | 389d? |  | S5 | 6608h | 6608h | CH8_IMS | Rel-8 | 37 | Mirko | CH8 | Alcatel-Lucent | maryse.gardella@alcatel-lucent.com |  |
| 4120 | 1131.6.1 | Add Interconnection Border Control Function (IBCF) to IMS Charging | 128d? | 2007-09-17 A | 2008-03-12 A | 100% | 2007-09-17 | 2008-03-12 | 128d? | finish no earlier than 2008-03-12 | S5 | 1024h | 1024h | CH8_IMS | Rel-8 | 37 | Mirko |  | Alcatel-Lucent | maryse.gardella@alcatel-lucent.com |  |
| 4121 | 1131.6.2 | Advice of Charge (AoC) support in IMS Charging | 309d? | 2008-01-07 A | 2009-03-12 A | 100% | 2008-01-07 | 2009-03-12 | 309d? | finish no earlier than 2009-03-12 | S5 | 2472h | 2472h | CH8_IMS | Rel-8 | 38 | Mirko |  | Nokia Siemens Networks | Gerald.Goermer@nsn.com | 21 |
| 4122 | 1132 | **3GPP2 Input to Common IMS** | 200d? | 2008-03-07 A | 2008-12-11 A | 100% | 2008-03-07 | 2008-12-11 | 200d? |  | S1; S2; S3; C1; C3; C4 | 21453.2h | 21453.2h | CIMS_3GPP2 | Rel-8 | 39 | Alain | CIMS_3GPP2, IMS_Common | Nortel | Amar Deol (deola@nortelnetworks.com) | 21 |
| 4123 | 1132.1 | Stage 1 CIMS_3GPP2 | 30.65d? | 2008-03-12 A | 2008-06-05 A | 100% | 2008-03-12 | 2008-06-05 | 30.65d? | finish no earlier than 2008-06-12 | S1 | 245.2h | 245.2h | CIMS_3GPP2 | Rel-8 | 39 | Alain |  | Nortel | Amar Deol (deola@nortelnetworks.com) | 21 |
| 4124 | 1132.2 | Stage 2 CIMS_3GPP2 | 62d? | 2008-03-12 A | 2008-06-05 A | 100% | 2008-03-12 | 2008-06-05 | 62d? | finish no earlier than 2008-09-11 | S2 | 496h | 496h | CIMS_3GPP2 | Rel-8 | 39 | Maurice |  | Nortel | Amar Deol (deola@nortelnetworks.com) | 21 |
| 4125 | 1132.3 | Security CIMS_3GPP2 | 197d? | 2008-03-12 A | 2008-12-11 A | 100% | 2008-03-12 | 2008-12-11 | 197d? | finish no earlier than 2008-12-11 | S3 | 1576h | 1576h | CIMS_3GPP2 | Rel-8 | 39 | Mirko |  | Nortel | Amar Deol (deola@nortelnetworks.com) | 21 |

Notes:
- 4099: SP#43 completed
- 4100: CP#43 completed
- 4101: SP#39 completed / Impacted TSs and TRs: 22.228, 22.115, 22.101
- 4102: CP#41 completed / Impacted TSs and TRs: 24.141, 24.147, 24.173, 24.229, 24.247, 24.341, 24.604, 24.605, 24.606, 24.607, 24.608, 24.610, 24.611, 24.616, 24.623, 24.628, 24.629, 24.647, 24.654
- 4103: CP#43 completed / Impacted TSs and TRs: 29.162, 29.163, 29.658
- 4104: CP#41 completed / Impacted TSs and TRs: 29.228, 29.229
- 4105: SP#43 completed
- 4106: SP#38 completed / Impacted TSs and TRs: 22.173
- 4107: CP#43 completed / Impacted TSs and TRs: 32.275, 32.298/299
- 4108: CP#43 completed
- 4109: CP#43 completed / Impacted TSs and TRs: 24.642, 24.229, 24.173
- 4110: CP#42 completed / Impacted TSs and TRs: 29.163
- 4111: CP#60 completed / Impacted TSs and TRs: RFC 6910 (was draft-ietf-bliss-call-completion)
- 4112: CP#43 completed
- 4113: SP#40 completed / Impacted TSs and TRs: 22.173
- 4114: CP#43 completed / Impacted TSs and TRs: 24.239, 24.173
- 4115: CP#43 completed
- 4116: CP#43 completed / Impacted TSs and TRs: 24.615, 24.229, 24.173
- 4117: In RFC Editors Queue. Dec.14: 75->90; 7/3/16: 90%->100 / Impacted TSs and TRs: draft-ietf-salud-alert-info-urns
- 4118: CP#42 completed / Impacted TSs and TRs: 29.163
- 4119: SP#39 completed / Impacted TSs and TRs: 32.260, 32.298
- 4120: SP#39 completed / Impacted TSs and TRs: 32.260, 32.298
- 4121: SP#43 completed / Impacted TSs and TRs: 32.240, 32.260, 32.296, 32.298, 32.299, new 32.280
- 4122: TSG#42 completed. Acronym changed from "CIMS_3GPP2, IMS_Common"
- 4123: SP#40 completed. Acronym changed from "CIMS_3GPP2, IMS_Common" / Impacted TSs and TRs: 22.228, 22.173, 22.101, 22.153
- 4124: SP#40 completed. Acronym changed from "CIMS_3GPP2, IMS_Common" / Impacted TSs and TRs: 23.002, 23.141, 23.203, 23.167, 23.228
- 4125: SP#42 completed [issues addressed under UID_370078 (IMS-Sec)]. Acronym changed from "CIMS_3GPP2, IMS_Common" / Impacted TSs and TRs: 33.141, 33.203, 33.210

| ID | WBS | Task | Duration | Start | Finish | Complete | Baseline start | Baseline finish | Baseline duration | Constraint | Resources | Work | Actual work | Acronym | PCG approved | WI rapporteur name | WI rapporteur e-mail | Release | TSG approved | MCC resp | Acronym_3GU_Export | TSG stopped |
| --- | --- | --- | --- | --- | --- | --- | --- | --- | --- | --- | --- | --- | --- | --- | --- | --- | --- | --- | --- | --- | --- | --- |
| 4126 | 1132.4 | **Stage 3 CIMS_3GPP2** | 200d? | 2008-03-07 A | 2008-12-11 A | 100% | 2008-03-07 | 2008-12-11 | 200d? |  | C1; C3; C4 | 9536h | 9536h | REDOC_3GPP2 | 21 | Alcatel-Lucent | orsic@alcatel-lucent.com | Rel-8 | 39 | Frederic | REDOC_3GPP2 |  |
| 4127 | 1132.4.1 | Stage 3 CIMS_3GPP2 (CT1) | 196d? | 2008-03-07 A | 2008-12-05 A | 100% | 2008-03-07 | 2008-12-05 | 196d? | finish no earlier than 2008-12-11 | C1 | 1568h | 1568h | REDOC_3GPP2 | 21 | Alcatel-Lucent | orsic@alcatel-lucent.com | Rel-8 | 39 | Frederic |  |  |
| 4128 | 1132.4.2 | Stage 3 CIMS_3GPP2 (CT3) | 196d? | 2008-03-07 A | 2008-12-05 A | 100% | 2008-03-07 | 2008-12-05 | 196d? | finish no earlier than 2008-12-05 | C3 | 1568h | 1568h | REDOC_3GPP2 | 21 | Alcatel-Lucent | orsic@alcatel-lucent.com | Rel-8 | 39 | Adrian |  |  |
| 4129 | 1132.4.3 | Stage 3 CIMS_3GPP2 (CT4) | 200d? | 2008-03-07 A | 2008-12-11 A | 100% | 2008-03-07 | 2008-12-11 | 200d? | finish no earlier than 2008-12-11 | C4 | 1600h | 1600h | REDOC_3GPP2 | 21 | Alcatel-Lucent | orsic@alcatel-lucent.com | Rel-8 | 39 | Kimmo |  |  |
| 4130 | 1133 | **IMS Enhancements for support of Packet Cable access** | 388d? | 2006-12-06 A | 2008-05-30 A | 100% | 2006-12-06 | 2008-05-30 | 388d? |  | S2; S3; C1; C3; C4 | 58616h | 58616h | PktCbl |  | Cablelabs | Bernie McKibben (b.mckibben@cablelabs.com) | Rel-8 | 35 | Maurice | PktCbl |  |
| 4131 | 1133.1 | **IMS Enhancements for Cable Client Types and Deployment Models** | 345d? | 2007-02-05 A | 2008-05-30 A | 100% | 2007-02-05 | 2008-05-30 | 345d? |  | S2; C1 | 9752h | 9752h | PktCbl-Deploy |  | Cablelabs | Bernie McKibben (b.mckibben@cablelabs.com) | Rel-8 |  | Maurice | PktCbl-Deploy |  |
| 4132 | 1133.1.1 | Architecture aspects of PktCbl-Deploy | 219d? | 2007-02-05 A | 2007-12-06 A | 100% | 2007-02-05 | 2007-12-06 | 219d? | finish no earlier than 2007-12-03 | S2 | 1752h | 1752h | PktCbl-Deploy |  | Cablelabs | Bernie McKibben (b.mckibben@cablelabs.com) | Rel-8 |  | Maurice |  |  |
| 4133 | 1133.1.2 | CT1 aspects of PktCbl-Deploy | 310d? | 2007-03-26 A | 2008-05-30 A | 100% | 2007-03-26 | 2008-05-30 | 310d? | finish no earlier than 2008-06-15 | C1 | 2480h | 2480h | PktCbl-Deploy |  | Cablelabs | D.Hancock@CableLabs.com | Rel-8 |  | Frederic |  |  |
| 4134 | 1133.2 | **IMS Inter-working aspects in Support of Cable Regulatory requirements** | 290d? | 2007-02-05 A | 2008-03-14 A | 100% | 2007-02-05 | 2008-03-14 | 290d? |  | S2; C1; C3 | 12320h | 12320h | PktCbl-Intw |  | Cablelabs | B.McKibben@CableLabs.com | Rel-8 |  | Maurice | PktCbl-Intw |  |
| 4135 | 1133.2.1 | Architecture aspects of PktCbl-Interwork | 160d? | 2007-02-05 A | 2007-09-14 A | 100% | 2007-02-05 | 2007-09-14 | 160d? | start no earlier than 2007-02-05 | S2 | 1280h | 1280h | PktCbl-Intw |  | Cablelabs | B.McKibben@CableLabs.com | Rel-8 |  | Maurice |  |  |
| 4136 | 1133.2.2 | CT1,CT3 aspects of PktCbl-Interwork | 255d? | 2007-03-26 A | 2008-03-14 A | 100% | 2007-03-26 | 2008-03-14 | 255d? | finish no earlier than 2008-03-15 | C1; C3 | 4080h | 4080h | PktCbl-Intw |  | Cablelabs | D.Hancock@CableLabs.com | Rel-8 |  | Frederic |  |  |
| 4137 | 1133.3 | **IMS Enhancements for Security Requirements in Support of Cable Deployments** | 388d? | 2006-12-06 A | 2008-05-30 A | 100% | 2006-12-06 | 2008-05-30 | 388d? |  | S3; C1; C3; C4 | 21024h | 21024h | PktCbl-Sec |  | Cablelabs | s.dotson@cablelabs.com | Rel-8 | 34 | Mirko | PktCbl-Sec |  |
| 4138 | 1133.3.1 | SA3 aspects of PktCbl-Sec | 331d? | 2006-12-06 A | 2008-03-12 A | 100% | 2006-12-06 | 2008-03-12 | 331d? | finish no earlier than 2007-12-20 | S3 | 2648h | 2648h | PktCbl-Sec |  | Cablelabs | s.dotson@cablelabs.com | Rel-8 |  | Mirko |  |  |
| 4139 | 1133.3.2 | CT1 aspects of PktCbl-Sec | 310d? | 2007-03-26 A | 2008-05-30 A | 100% | 2007-03-26 | 2008-05-30 | 310d? | finish no earlier than 2008-06-06 | C1 | 2480h | 2480h | PktCbl-Sec |  | Cablelabs | D.Hancock@CableLabs.com | Rel-8 |  | Frederic |  |  |
| 4140 | 1133.3.3 | CT3 aspects of PktCbl-Sec | 180d? | 2007-03-26 A | 2007-11-30 A | 100% | 2007-03-26 | 2007-11-30 | 180d? | finish no earlier than 2008-03-15 | C3 | 1440h | 1440h | PktCbl-Sec | 21 | Cablelabs | D.Hancock@CableLabs.com | Rel-8 | 38 | Adrian |  |  |
| 4141 | 1133.3.4 | CT4 aspects of PktCbl-Sec | 255d? | 2007-03-26 A | 2008-03-14 A | 100% | 2007-03-26 | 2008-03-14 | 255d? | finish no earlier than 2008-03-14 | C4 | 2040h | 2040h | PktCbl-Sec |  | Cablelabs | D.Hancock@CableLabs.com | Rel-8 |  | Kimmo |  |  |
| 4142 | 1134 | **IMS System enhancements for corporate network access** | 1901d? | 2007-06-22 A | 2014-09-12 A | 100% | 2007-06-22 | 2014-12-05 | 1960d? |  | S2; S1; C1; C4; IETF | 91240.9h | 91240.9h | IMS_Corp |  | Orange | Delphin Barankanira | Rel-8 |  | Maurice | IMS_Corp |  |
| 4143 | 1134.1 | SA1 aspects of IMS_Corp | 23.6d? | 2008-03-12 A | 2008-06-05 A | 100% | 2008-03-12 | 2008-06-05 | 23.6d? | finish no earlier than 2008-06-05 | S1 | 188.8h | 188.8h | IMS_Corp | 21 | Telecom Italia |  | Rel-8 | 39 | Alain |  |  |
| 4144 | 1134.2 | SA2 aspects of IMS_Corp | 325d? | 2007-06-22 A | 2008-09-18 A | 100% | 2007-06-22 | 2008-09-18 | 325d? | finish no earlier than 2008-12-25 | S2 | 2600h | 2600h | IMS_Corp |  | Orange | Delphin Barankanira | Rel-8 |  | Maurice |  |  |
| 4145 | 1134.3 | CT1 aspects of IMS_Corp | 532d? | 2008-03-07 A | 2010-03-19 A | 100% | 2008-03-07 | 2010-03-19 | 532d? | finish no earlier than 2010-03-19 | C1 | 4244.09h | 4244.09h | IMS_Corp | 21 | Alcatel-Lucent | Keith Drage (drage@alcatel-lucent.com) | Rel-8 | 39 | Frederic |  |  |
| 4146 | 1134.4 | (IETF) CT1 aspects of IMS_Corp (RFC 7316) | 825d? | 2011-06-29 A | 2014-09-12 A | 100% | 2011-06-29 | 2014-12-05 | 885d? | finish no earlier than 2014-09-12 | C1-IETF | 6600h | 6600h | IMS_Corp | 27 | Keith Drage | Keith Drage (drage@alcatel-lucent.com) | Rel-8 | 53 | Frederic |  |  |
| 4147 | 1134.5 | CT4 aspects of IMS_Corp | 196d? | 2008-02-26 A | 2008-12-05 A | 100% | 2008-02-26 | 2008-12-05 | 196d? | finish no earlier than 2008-12-11 | C4 | 1568h | 1568h | IMS_Corp | 21 | Alcatel-Lucent | Keith Drage (drage@alcatel-lucent.com) | Rel-8 | 39 | Kimmo |  |  |
| 4148 | 1135 | **Maintenance of TISPAN documentation** | 1829d? | 2007-07-02 A | 2014-06-13 A | 100% | 2007-07-02 | 2014-06-13 | 1829d? |  | S2; C1; C3; C4; IETF | 85904h | 85904h | MAINTISP | 21 |  |  | Rel-8 | 38 | Maurice | MAINTISP |  |
| 4149 | 1135.1 | Maintenance of TISPAN R2 | 86d? | 2007-11-09 A | 2008-03-07 A | 100% | 2007-11-09 | 2008-03-07 | 86d? | start no earlier than 2007-11-09 | C1; C3; C4 | 2064h | 2064h | MAINT_R2 | 21 | Alcatel-Lucent | Keith Drage (drage@alcatel-lucent.com) | Rel-8 | 38 | Frederic | MAINT_R2 |  |
| 4150 | 1135.2 | Deleted - (IETF) Maintenance of TISPAN R2 (avasarala-dispatch-comm-div-notification) | 1117d? | 2007-11-09 A | 2014-06-13 A | 100% | 2007-11-09 | 2014-06-13 | 1117d? | finish no earlier than 2014-06-13 | C1-IETF | 8936h | 8936h | MAINT_R2_IETF | 27 | Andrew Allen |  | Rel-8 | 52 | Frederic | MAINT_R2_IETF | SP-69 |
| 4151 | 1135.3 | Documentation of TISPAN NGN R1 and R2 in 3GPP SA2 | 104d? | 2008-01-14 A | 2008-06-05 A | 100% | 2008-01-14 | 2008-06-05 | 104d? | finish no earlier than 2008-06-20 | S2 | 832h | 832h | IMS_Comm_Doc | 21 | Nokia Siemens Networks | jozsef.varga@nsn.com | Rel-8 | 38 | Maurice | IMS_Comm_Doc |  |
| 4152 | 1135.4 | Maintenance of TISPAN release 2 common IMS | 114d? | 2007-07-02 A | 2007-12-06 A | 100% | 2007-07-02 | 2007-12-06 | 114d? | finish no earlier than 2007-12-06 | S2 | 912h | 912h | IMS_Comm_Mtce8 | 21 | Telecom Italia | antonio.ascolese@telecomitalia.it | Rel-8 | 38 | Maurice | IMS_Comm_Mtce8 |  |

Notes:
- 4126: -
- 4127: CP#42 completed / Impacted TSs and TRs: 23.218, 24.141, 24.147, 24.173, 24.229, 24.238, 24.247, 24.604, 24.605, 24.606, 24.607, 24.608, 24.610, 24.611, 24.629, 24.930
- 4128: CP#42 completed / Impacted TSs and TRs: 29.163, 29.212, 29.213, 29.214
- 4129: CP#42 completed / Impacted TSs and TRs: 29.228, 29.229, 29.328, 29.329
- 4130: CP#40 completed
- 4131: CP#40 completed
- 4132: SP#38 completed / Impacted TSs and TRs: 23.228
- 4133: CP#40 completed
- 4134: CP#39 completed
- 4135: SP#37 completed / Impacted TSs and TRs: 23.228
- 4136: CP#39 completed / Impacted TSs and TRs: 24.229
- 4137: CP#40 completed
- 4138: SP#39 completed / Impacted TSs and TRs: 33.203, 33.210, 33.220
- 4139: CP#40 completed / Impacted TSs and TRs: 24.229
- 4140: CP#38 completed / Impacted TSs and TRs: 29.163
- 4141: CP#39 completed / Impacted TSs and TRs: 29.228, 29.229, 23.008
- 4142: CP#47 completed
- 4143: SP#40 completed
- 4144: no Stage 2 impacts / Impacted TSs and TRs: 23.228
- 4145: CP#47 completed / Impacted TSs and TRs: 24.229, 24.503
- 4146: CP#65 completed / Impacted TSs and TRs: RFC 7316 (was draft-vanelburg-dispatch-private-network-ind)
- 4147: CP#42 completed / Impacted TSs and TRs: 29.228, 29.229, 23.003, 23.008, 29.433
- 4148: SP#40 completed
- 4149: CP#39 completed / Impacted TSs and TRs: 24.406, 24.407, 24.410, 24.411, 24.423, 24.430, 24.447, 24.451, 24.454, 24.503, 24.505, 24.508, 24.516, 24.528, 24.529, 29.412, 29.421, 29.433, 29.458, 29.527, 29.624
- 4150: CP#64 Draft removed from 3GPP documentation / Impacted TSs and TRs: draft-avasarala-dispatch-comm-div-notification
- 4151: SP#40 completed / Impacted TSs and TRs: 23.228, 23.204, 23.167
- 4152: SP#38 completed / Impacted TSs and TRs: 23.506, 23.507,23.517, 23.521

| ID | WBS | Task | Type | Duration | Start | Finish | Complete | Baseline start | Baseline finish | Baseline duration | Constraint | Resources | Work | Actual work | Acronym | PCG approved | WI rapporteur name | WI rapporteur e-mail | Release | TSG approved | MCC resp | Acronym_3GU_Export | Impacted TSs and TRs |
| --- | --- | --- | --- | --- | --- | --- | --- | --- | --- | --- | --- | --- | --- | --- | --- | --- | --- | --- | --- | --- | --- | --- | --- |
| 4153 | 1136 | **IMS Service Continuity** |  | 318d? | 2008-03-12 A | 2009-05-29 A | 100% | 2008-03-12 | 2009-05-29 | 318d? |  | S2; S1; C1 | 10712h | 10712h | IMS-Cont | 21 | LG Electronics | JaeSeung SONG (anthonys@lge.com) | Rel-8 | 39 | Maurice | IMS-Cont |  |
| 4154 | 1136.1 | Stage 1 IMS Service Continuity |  | 62d? | 2008-03-12 A | 2008-06-05 A | 100% | 2008-03-12 | 2008-06-05 | 62d? | start no earlier than 2008-03-12 | S1 | 496h | 496h | IMS-Cont | 21 | LG Electronics | JaeSeung SONG (anthonys@lge.com) | Rel-8 | 39 | Alain |  |  |
| 4155 | 1136.2 | Stage 2 IMS Service Continuity |  | 62d? | 2008-03-12 A | 2008-06-05 A | 100% | 2008-03-12 | 2008-06-05 | 62d? | finish no earlier than 2008-06-05 | S2 | 496h | 496h | IMS-Cont | 21 | LG Electronics | JaeSeung SONG (anthonys@lge.com) | Rel-8 | 39 | Maurice |  | 23.237, 23.292 |
| 4156 | 1136.3 | Stage 3 IMS Service Continuity |  | 261d? | 2008-05-30 A | 2009-05-29 A | 100% | 2008-05-30 | 2009-05-29 | 261d? | finish no earlier than 2009-05-29 | C1 | 2088h | 2088h | IMS-Cont | 21 | Huawei | Lili Yang (kadyyang@huawei.com) | Rel-8 | 40 | Frederic |  | 24.237, 24.229, 24.216 |
| 4157 | 1137 | **Security Enhancements for IMS** |  | 643.3d? | 2006-09-19 A | 2009-03-06 A | 100% | 2006-09-19 | 2009-03-06 | 643.3d? |  | S3; C1; C4 | 29847.2h | 29847.2h | IMS-Sec |  | Ericsson | Bengt.Sahlin@ericsson.com | Rel-8 | 37 | Mirko | IMS-Sec |  |
| 4158 | 1137.1 | Stage 2 for IMS-Sec |  | 466d? | 2007-03-01 A | 2008-12-11 A | 100% | 2007-03-01 | 2008-12-11 | 466d? | finish no earlier than 2008-12-11 | S3 | 3728h | 3728h | IMS-Sec |  | Ericsson | Bengt.Sahlin@ericsson.com | Rel-8 |  | Mirko |  | 33.203, 33.141, 33.803 |
| 4159 | 1137.2 | CT1 part of Stage 3 for IMS-Sec |  | 392d? | 2006-09-19 A | 2008-12-05 A | 100% | 2006-09-19 | 2008-12-05 | 392d? | finish no earlier than 2008-12-05 | C1 | 3136h | 3136h | IMS-Sec | 21 | Ericsson |  | Rel-8 | 39 | Frederic |  |  |
| 4160 | 1137.3 | CT4 part of Stage 3 for IMS-Sec |  | 457d? | 2007-06-07 A | 2009-03-06 A | 100% | 2007-06-07 | 2009-03-06 | 457d? | finish no earlier than 2009-03-06 | C4 | 3656h | 3656h | IMS-Sec | 21 | Ericsson |  | Rel-8 | 39 | Kimmo |  |  |
| 4161 | 1137.4 | CT1 part of Network Attachment Subsystem (NASS) Bundled Authentication |  | 343d? | 2007-11-14 A | 2009-03-06 A | 100% | 2007-11-14 | 2009-03-06 | 343d? | finish no earlier than 2009-03-06 | C1 | 2744h | 2744h | NBA | 21 | Alcatel-Lucent | Keith Drage (drage@alcatel-lucent.com) | Rel-8 | 39 | Frederic | NBA | 24.229 |
| 4162 | 1137.5 | CT4 part of Network Attachment Subsystem (NASS) Bundled Authentication |  | 143d? | 2007-11-14 A | 2008-05-30 A | 100% | 2007-11-14 | 2008-05-30 | 143d? | start no earlier than 2007-11-14 | C4 | 1144h | 1144h | NBA-CT4 | 21 | Alcatel-Lucent |  | Rel-8 | 39 | Kimmo | NBA-CT4 | 29.229, 29.228, 23.008 |
| 4163 | 1138 | **IMS initiated and controlled PSS and MBMS User Service** |  | 924d? | 2008-03-12 A | 2011-09-21 A | 100% | 2008-03-12 | 2011-09-21 | 924d? |  | S4; S3; IETF | 28108.8h | 28108.8h | IMS_PSS_MBMS_US |  | FT, Ericsson | olle.franceschi@ericsson.com | Rel-8 |  | Paolo | IMS_PSS_MBMS_US |  |
| 4164 | 1138.1 | SA4, SA3 part of IMS initiated and controlled PSS and MBMS User Service | milestone | 0d? | 2008-03-12 A | 2008-03-12 A | 100% | 2008-03-12 | 2008-03-12 | 0d? | finish no earlier than 2009-03-12 | S4; S3 |  |  | IMS_PSS_MBMS_US |  | FT, Ericsson | olle.franceschi@ericsson.com | Rel-8 |  | Paolo |  | 26.234, 26.346, 33.246, New 26.237 |
| 4165 | 1138.2 | (IETF) IMS initiated and controlled PSS and MBMS User Service (RFC 6080) |  | 743.6d? | 2008-03-12 A | 2011-09-21 A | 100% | 2008-03-12 | 2011-09-21 | 743.6d? | finish no earlier than 2011-09-21 | S4-IETF | 5932.8h | 5932.8h | IMS_PSS_MBMS_US | 27 | Ericsson |  | Rel-8 | 52 | Paolo |  | RFC 6080 (was draft-ietf-sipping-config-framework) |
| 4166 | 1139 | **Multimedia interworking between IMS and CS networks** |  | 836d? | 2005-09-23 A | 2008-12-05 A | 100% | 2005-09-23 | 2008-12-05 | 836d? |  | C3; C4 | 22800h | 22800h | MIW-IMS | 36 | Vodafone | nico.gabriele@vodafone.com | Rel-8 | 71 | Adrian | MIW-IMS |  |
| 4167 | 1139.1 | Stage 1 and 2 defined in earlier Releases |  | 49d? | 2005-09-23 A | 2005-11-30 A | 100% | 2005-09-23 | 2005-11-30 | 49d? | start no earlier than 2005-09-23 | S2 | 392h | 392h | MIW-IMS |  | Vodafone | nico.gabriele@vodafone.com | Rel-8 |  | Maurice |  |  |
| 4168 | 1139.2 | Stage 3 of MW-IMS |  | 571d? | 2005-09-23 A | 2007-11-30 A | 100% | 2005-09-23 | 2007-11-30 | 571d? | finish no earlier than 2007-09-14 | C3 | 4568h | 4568h | MIW-IMS-St3C3 |  | Vodafone | nico.gabriele@vodafone.com | Rel-8 |  | Adrian | MIW-IMS-St3 | 29.863, 29.163 |
| 4169 | 1139.3 | Stage 3 for MW-IMS, MONA extension |  | 285d? | 2007-11-05 A | 2008-12-05 A | 100% | 2007-11-05 | 2008-12-05 | 285d? | finish no earlier than 2008-12-05 | C3 | 2280h | 2280h | MIW-IMS-St3C3_MONA | 21 | Vodafone | Christer.Holmberg@ericsson.com | Rel-8 | 38 | Adrian |  | 29.863, 29.163 |
| 4170 | 1139.4 | Mn interface (MGCF – IM MGW) |  | 273d? | 2007-11-21 A | 2008-12-05 A | 100% | 2007-11-21 | 2008-12-05 | 273d? | finish no earlier than 2008-12-19 | C4 | 2184h | 2184h | MIW-IMS-St3C4 | 21 | Vodafone | Christer.Holmberg@ericsson.com | Rel-8 | 38 | Kimmo |  | 29.332 |
| 4171 | 1140 | **IMS Stage 3 IETF Protocol Alignment - phase 2** |  | 1965d? | 2007-06-22 A | 2014-12-09 A | 100% | 2007-06-22 | 2014-12-05 | 1960d? |  | C1; IETF | 55368h | 55368h | IMSProtoc2 |  | Alcatel-Lucent | Keith Drage (drage@alcatel-lucent.com) | Rel-8 |  | Frederic | IMSProtoc2 |  |
| 4172 | 1140.1 | CT1 aspects of IMS Stage 3 IETF Protocol Alignment - phase 2 |  | 446d? | 2007-06-22 A | 2009-03-06 A | 100% | 2007-06-22 | 2009-03-06 | 446d? | finish no earlier than 2009-03-06 | C1 | 3568h | 3568h | IMSProtoc2 |  | Alcatel-Lucent | Keith Drage (drage@alcatel-lucent.com) | Rel-8 |  | Frederic |  | 23.218, 24.229, 24.930 |
| 4173 | 1140.2 | (IETF) IMS Stage 3 IETF Protocol Alignment (draft-bakker-sipping-3gpp-ims-xml-body-handling) |  | 715d? | 2007-06-22 A | 2012-12-07 A | 100% | 2007-06-22 | 2012-12-07 | 715d? | finish no earlier than 2012-12-07 | C1-IETF | 5720h | 5720h | IMSProtoc2 | 27 | Andrew Allen |  | Rel-8 | 52 | Frederic |  | draft-bakker-sipping-3gpp-ims-xml-body-handling |
| 4174 | 1140.3 | (IETF) IMS Stage 3 IETF Protocol Alignment (RFC 6544) |  | 587d? | 2007-06-22 A | 2012-06-15 A | 100% | 2007-06-22 | 2012-06-15 | 587d? | finish no earlier than 2012-04-20 | C1-IETF | 4688h | 4688h | IMSProtoc2 | 27 | Keith Drage |  | Rel-8 | 52 | Frederic |  | RFC 6544 (was draft-ietf-mmusic-ice-tcp) |
| 4175 | 1140.4 | (IETF) IMS Stage 3 IETF Protocol Alignment (draft-ietf-salud-alert-info-urns) |  | 1244d? | 2007-06-22 A | 2014-12-09 A | 100% | 2007-06-22 | 2014-12-05 | 1242d? | finish no earlier than 2014-12-09 | C1-IETF | 9952h | 9952h | IMSProtoc2 | 27 | Roland Jesske | Roland Jesske | Rel-8 | 52 | Frederic |  | draft-ietf-salud-alert-info-urns |
| 4176 | 1141 | **Interworking between User-to-User Signalling (UUS) and SIP** |  | 1850d? | 2007-11-30 A | 2014-12-09 A | 100% | 2007-11-30 | 2014-12-05 | 1845d? |  | C1; C3; IETF | 68624.4h | 68624.4h | UUSIW | 21 | Huawei | Lili Yang (kadyyang@huawei.com) | Rel-8 | 38 | Kimmo | UUSIW |  |
| 4177 | 1141.1 | CT1 part of Stage 3 MGCF UUSIW |  | 266d? | 2007-11-30 A | 2008-12-05 A | 100% | 2007-11-30 | 2008-12-05 | 266d? | finish no earlier than 2008-12-05 | C1 | 2128h | 2128h | UUSIW | 21 | Huawei | Lili Yang (kadyyang@huawei.com) | Rel-8 | 38 | Frederic |  | 24.279, 24.229 |
| 4178 | 1141.2 | (IETF) Stage 3 MGCF UUSIW (cuss-sip-uui) |  | 227.03d? | 2007-11-30 A | 2014-12-09 A | 100% | 2007-11-30 | 2014-12-05 | 225.03d? | finish no earlier than 2014-12-09 | C1-IETF; C3-IETF | 3632.4h | 3632.4h | UUSIW | 27 | Roland Jesske | Roland Jesske | Rel-8 | 52 | Frederic |  | RFC 7433 |
| 4179 | 1141.3 | (IETF) Stage 3 MGCF UUSIW (cuss-sip-uui-isdn) |  | 986.5d? | 2011-03-17 A | 2014-12-09 A | 100% | 2011-03-17 | 2014-12-05 | 984.5d? | finish no earlier than 2014-12-09 | C1-IETF; C3-IETF | 15784h | 15784h | UUSIW | 28 | Keith Drage | Keith Drage (drage@alcatel-lucent.com) | Rel-8 | 55 | Frederic |  | RFC 7434 |
| 4180 | 1141.4 | CT3 part of Stage 3 MGCF UUSIW |  | 335d? | 2007-11-30 A | 2009-03-12 A | 100% | 2007-11-30 | 2009-03-12 | 335d? | finish no earlier than 2009-03-12 | C3 | 2680h | 2680h | UUSIW | 21 | Huawei | Lili Yang (kadyyang@huawei.com) | Rel-8 | 38 | Adrian |  | 29.163 |

Notes:
- 4153: CP#44 completed
- 4154: SP#40 completed
- 4155: SP#40 completed
- 4156: CP#44 completed
- 4157: CP#43 completed
- 4158: SP#42 completed. SP#46 withdrawn draft 33.178-100 and 33.978 from Rel-8 onwards
- 4159: CP#42 completed
- 4160: CP#43 completed
- 4161: CP#43 completed
- 4162: CP#40 completed
- 4163: SP#39 WID approved
- 4164: SP#43 completed
- 4165: SP#53/IETF#81 completed
- 4166: CP#42 completed
- 4167: SP#31 Moved from FS section Feb 2006
- 4168: Moved from Rel-7. Feature extended in Rel-8 by including Stage 3 covering MONA UID_380021
- 4169: CP#42 completed
- 4170: CP#42 completed
- 4171: CP#43 completed
- 4172: CP#43 completed
- 4173: CP#58 completed. ietf-draft discontinued. Documented within 3GPP
- 4174: CP#56 completed
- 4175: In RFC Editors Queue. Dec.14: 75->90; 7/3/16: 90%->100
- 4176: CP#43 completed
- 4177: CP#42 completed
- 4178: In RFC Editors Queue. Mar15: 90->100%. RFC updated (was draft-ietf-cuss-sip-uui). June 2015: RFC 7433 (was draft-ietf-cuss-sip-uui)
- 4179: In RFC Editors Queue. Dec.14: 75->90. Mar15: 90->100%. RFC updated (was draft-ietf-cuss-sip-uui-isdn). June 2015: RFC 7434 (was draft-ietf-cuss-sip-uui-isdn)
- 4180: CP#43 completed

| ID | WBS | Task | Type | Duration | Start | Finish | Complete | Baseline start | Baseline finish | Baseline duration | Constraint | Resources | Work | Actual work | Acronym | PCG approved | WI rapporteur name | WI rapporteur e-mail | Release | TSG approved | MCC resp | Acronym_3GU_Export | Impacted TSs and TRs | Special Focus Doc | Status Report |
| --- | --- | --- | --- | --- | --- | --- | --- | --- | --- | --- | --- | --- | --- | --- | --- | --- | --- | --- | --- | --- | --- | --- | --- | --- | --- |
| 4181 | 1142 | **Support of Overlap signalling** |  | 331d? | 2007-11-30 A | 2009-03-06 A | 100% | 2007-11-30 | 2009-03-06 | 331d? |  | C3; C1; C4 | 15304.2h | 15304.2h | Overlap | 21 | Deutsche Telekom | r.jesske@telekom.de | Rel-8 | 38 | Adrian | Overlap |  |  |  |
| 4182 | 1142.1 | Stage 3 Overlap (CT1) |  | 331d? | 2007-11-30 A | 2009-03-06 A | 100% | 2007-11-30 | 2009-03-06 | 331d? | finish no earlier than 2009-03-06 | C1 | 2648h | 2648h | Overlap | 21 | Deutsche Telekom | r.jesske@telekom.de | Rel-8 | 38 | Frederic |  | 24.229 |  |  |
| 4183 | 1142.2 | Stage 3 Overlap (CT3) |  | 331d? | 2007-11-30 A | 2009-03-06 A | 100% | 2007-11-30 | 2009-03-06 | 331d? | finish no earlier than 2009-03-06 | C3 | 2648h | 2648h | Overlap | 21 | Deutsche Telekom | r.jesske@telekom.de | Rel-8 | 38 | Adrian |  | 29.163 |  |  |
| 4184 | 1142.3 | Stage 3 Overlap (CT4) |  | 258.02d? | 2007-11-30 A | 2008-12-05 A | 100% | 2007-11-30 | 2008-12-05 | 258.02d? | start no earlier than 2007-11-30 | C4 | 2064.16h | 2064.16h | Overlap | 21 | Deutsche Telekom | r.jesske@telekom.de | Rel-8 | 38 | Kimmo |  | 29.228, 29.229 |  |  |
| 4185 | 1143 | **AS/MRFC Stage 2 and 3** |  | 1203d? | 2007-11-14 A | 2012-06-15 A | 100% | 2007-11-14 | 2012-06-15 | 1203d? |  | C1; IETF | 28384h | 28384h | MRFC_TS | 21 | Hewlett-Packard | mark.syrett@hp.com | Rel-8 | 38 | Frederic | MRFC_TS |  |  |  |
| 4186 | 1143.1 | AS/MRFC Stage 2 |  | 278d? | 2007-11-14 A | 2008-12-05 A | 100% | 2007-11-14 | 2008-12-05 | 278d? | finish no earlier than 2008-12-05 | C1 | 2224h | 2224h | MRFC_TS | 21 | Hewlett-Packard | mark.syrett@hp.com | Rel-8 | 38 | Frederic |  | 23.218 |  |  |
| 4187 | 1143.2 | AS/MRFC Stage 3 |  | 278d? | 2007-11-14 A | 2008-12-05 A | 100% | 2007-11-14 | 2008-12-05 | 278d? | finish no earlier than 2008-12-05 | C1 | 2224h | 2224h | MRFC_TS | 21 | Hewlett-Packard | mark.syrett@hp.com | Rel-8 | 38 | Frederic |  | 24.229, 24.147, 24.247 |  |  |
| 4188 | 1143.3 | (IETF) AS/MRFC Stage 2 and 3 (RFC 6505) |  | 590d? | 2007-11-14 A | 2012-06-15 A | 100% | 2007-11-14 | 2012-06-15 | 590d? | finish no earlier than 2012-06-15 | C1-IETF | 4688h | 4688h | MRFC_TS | 27 | Keith Drage |  | Rel-8 | 52 | Frederic |  | RFC 6505 (was draft-ietf-mediactrl-mixer-control-package) |  |  |
| 4189 | 1144 | **IMS Restoration Procedures** |  | 201d? | 2008-05-30 A | 2009-03-06 A | 100% | 2008-05-30 | 2009-03-06 | 201d? |  | C4; C1 | 6432h | 6432h | IMS_RP | 21 | Ericsson | german.blanco@ericsson.com | Rel-8 | 40 | Kimmo | IMS_RP |  |  |  |
| 4190 | 1144.1 | IMS Restoration Procedures (CT4) |  | 201d? | 2008-05-30 A | 2009-03-06 A | 100% | 2008-05-30 | 2009-03-06 | 201d? | finish no earlier than 2009-03-06 | C4 | 1608h | 1608h | IMS_RP | 21 | Ericsson | german.blanco@ericsson.com | Rel-8 | 40 | Kimmo |  | 23.380, 29.228, 29.229, 29.230, 23.008 |  |  |
| 4191 | 1144.2 | IMS Restoration Procedures (CT1) |  | 201d? | 2008-05-30 A | 2009-03-06 A | 100% | 2008-05-30 | 2009-03-06 | 201d? | finish no earlier than 2009-03-06 | C1 | 1608h | 1608h | IMS_RP | 21 | Ericsson | german.blanco@ericsson.com | Rel-8 | 40 | Frederic |  | 24.229 |  |  |
| 4192 | 1145 | IMS Application Server Service Data Descriptions for AS interoperability |  | 125d? | 2008-09-12 A | 2009-03-06 A | 100% | 2008-09-12 | 2009-03-06 | 125d? | finish no earlier than 2009-03-06 | C4 | 1000h | 1000h | IMS_ASIO | 21 | Alcatel-Lucent | nhberry@alcatel-lucent.com | Rel-8 | 41 | Kimmo | IMS_ASIO | 29.328, 29.329, 29.364 |  |  |
| 4193 | 1146 | **I-WLAN Network Selection Principle (NSP)** |  | 451d? | 2007-06-14 A | 2009-03-06 A | 100% | 2007-06-14 | 2009-03-06 | 451d? |  | S1; C1; C6 | 13859.2h | 13859.2h | IWLANNSP |  | Telefónica O2 | chris.friel@O2.com | Rel-8 | 34 | Alain | IWLANNSP |  | WLAN |  |
| 4194 | 1146.1 | Stage 1 for I-WLAN NSP | milestone | 0d? | 2007-06-14 A | 2007-06-14 A | 100% | 2007-06-14 | 2007-06-14 | 0d? |  | S1 |  |  | IWLANNSP | 21 | Telefónica O2 | chris.friel@O2.com | Rel-8 | 39 | Alain |  | 22.234 | WLAN |  |
| 4195 | 1146.2 | CT1 part of Stage 3 for I-WLAN NSP |  | 261d? | 2008-03-07 A | 2009-03-06 A | 100% | 2008-03-07 | 2009-03-06 | 261d? | finish no earlier than 2008-12-05 | C1 | 2088h | 2088h | IWLANNSP | 21 | Research In Motion | Adrian Buckley (abuckley@rim.com) | Rel-8 | 39 | Frederic |  | 24.234 | WLAN |  |
| 4196 | 1146.3 | CT6 part of Stage 3 for I-WLAN NSP |  | 118.4d? | 2008-03-07 A | 2008-12-11 A | 100% | 2008-03-07 | 2008-12-11 | 118.4d? | finish no earlier than 2008-12-11 | C6 | 947.2h | 947.2h | IWLANNSP | 21 | Research In Motion | Adrian Buckley (abuckley@rim.com) | Rel-8 | 39 | Xavier |  | 31.102, 31.111 | WLAN |  |
| 4197 | 1147 | **Mobility between 3GPP-WLAN Interworking and 3GPP Systems** |  | 386d? | 2007-09-14 A | 2009-03-06 A | 100% | 2007-09-14 | 2009-03-06 | 386d? |  | S2; C1 | 9304h | 9304h | IWLAN_Mob |  | Orange | xiaobao.chen@orange-ftgroup.com | Rel-8 | 37 | Maurice | IWLAN_Mob |  | WLAN |  |
| 4198 | 1147.1 | Stage 2 for Mobility between 3GPP-WLAN Interworking and 3GPP Systems |  | 190d? | 2007-09-14 A | 2008-06-05 A | 100% | 2007-09-14 | 2008-06-05 | 190d? | finish no earlier than 2008-09-08 | S2 | 1520h | 1520h | IWLAN_Mob | 21 | Orange | xiaobao.chen@orange-ftgroup.com | Rel-8 | 38 | Maurice |  | new 23.327 | WLAN |  |
| 4199 | 1147.2 | CT1 aspects of Mobility between 3GPP-WLAN Interworking and 3GPP Systems |  | 201d? | 2008-05-30 A | 2009-03-06 A | 100% | 2008-05-30 | 2009-03-06 | 201d? | finish no earlier than 2009-03-06 | C1 | 1608h | 1608h | IWLAN_Mob | 21 | Orange | reina.nader@orange-ftgroup.com | Rel-8 | 40 | Frederic |  | 24.303, new 24.327 | WLAN |  |
| 4200 | 1148 | Conformance Test Aspects – Mobility between 3GPP WLAN Interworking and 3GPP Systems |  | 206d? | 2009-12-04 A | 2010-09-17 A | 100% | 2009-12-04 | 2010-09-17 | 206d? | finish no earlier than 2010-09-17 | R5 | 1648h | 1648h | IWLAN_Mob_UEConTest | 24 | Qualcomm | Patrick Stupar (pstupar@qualcomm.com) | Rel-8 | 46 | Ingbert | IWLAN_Mob_UEConTest | 34.108, 34.123-1, 34.123-2, 34.123-3 | WLAN | RP-100740 |
| 4201 | 1149 | **Enhancements for Voice Group Call Service (VGCS) Applications (EVA)** |  | 919d? | 2006-03-15 A | 2009-09-18 A | 100% | 2006-03-15 | 2009-09-18 | 919d? |  | S1; C1; C4; G2 | 45559.5h | 45559.5h | EVA |  | Nortel | Amar Deol (deola@nortelnetworks.com) | Rel-8 |  | Alain | EVA |  |  |  |
| 4202 | 1149.1 | SA1 aspects of EVA |  | 191d? | 2006-03-15 A | 2006-12-06 A | 100% | 2006-03-15 | 2006-12-06 | 191d? | finish no earlier than 2006-12-06 | S1 | 1528h | 1528h | EVA |  | Nortel | Amar Deol (deola@nortelnetworks.com) | Rel-8 |  | Alain |  | 42.068 |  |  |
| 4203 | 1149.2 | VGCS/VBS and GPRS Interactions |  | 145d? | 2007-09-03 A | 2008-03-21 A | 100% | 2007-09-03 | 2008-03-21 | 145d? | finish no earlier than 2008-03-21 | S1 | 1160h | 1160h | EVA |  | Huawei | Ling Liu | Rel-8 | 37 | Alain |  | 42.068, 42.069 |  |  |
| 4204 | 1149.3 | CT1 aspects of EVA |  | 862d? | 2006-06-02 A | 2009-09-18 A | 100% | 2006-06-02 | 2009-09-18 | 862d? | finish no earlier than 2009-12-04 | C1 | 6887.53h | 6887.53h | EVA |  | Nortel | milanpa@nortel.com | Rel-8 |  | Frederic |  | 43.068, 44.068 |  |  |
| 4205 | 1149.4 | CT4 aspects of EVA |  | 391d? | 2006-06-02 A | 2007-11-30 A | 100% | 2006-06-02 | 2007-11-30 | 391d? | finish no earlier than 2007-06-01 | C4 | 3128h | 3128h | EVA |  | Nortel |  | Rel-8 |  | Kimmo |  | 29.002 |  |  |
| 4206 | 1149.5 | GERAN2 aspects of EVA |  | 431d? | 2006-06-30 A | 2008-02-22 A | 100% | 2006-06-30 | 2008-02-22 | 431d? | finish no earlier than 2008-02-22 | G2 | 3448h | 3448h | EVA |  | Nortel | frank.billenkamp@nortel.com | Rel-8 |  | Gert |  | 44.018, 48.008 |  |  |

Notes:
- 4181: CP#43 completed
- 4182: CP#43 completed
- 4183: CP#43 completed
- 4184: CP#42 completed
- 4185: Triggered by Study UID_7048 (MRFC)
- 4186: CP#42 completed
- 4187: CP#42 completed
- 4188: CP#56 completed
- 4189: CP#43 completed. Triggered by Study TR 23.820 (FS_IMS_RP) UID_350018
- 4190: CP#43 completed
- 4191: CP#43 completed
- 4192: CP#43 completed. Triggered by UID_360030 (FS_IMS_ASIO)
- 4193: CP#43 completed
- 4194: SP#36 completed
- 4195: CP#43 completed
- 4196: CP#42 completed
- 4197: CP#43 completed
- 4198: SP#40 completed
- 4199: CP#43 completed
- 4200: RP#49 completed. Testing for Rel-8 UID_400013 CT1 aspects of mobility between 3GPP WLAN Interworking and 3GPP Systems (24.327)
- 4201: CP#45 completed
- 4202: SP#38 completed
- 4203: SP#39 completed
- 4204: CP#45 completed
- 4205: CP#38 completed
- 4206: GP#37 completed

| ID | WBS | Task | Type | Duration | Start | Finish | Complete | Baseline start | Baseline finish | Baseline duration | Constraint | Resources | Work | Actual work | Acronym | WI rapporteur name | WI rapporteur e-mail | Release | MCC resp | Acronym_3GU_Export | Impacted TSs and TRs | TSG stopped | Special Focus Doc | TSG approved | PCG approved | Status Report |
| --- | --- | --- | --- | --- | --- | --- | --- | --- | --- | --- | --- | --- | --- | --- | --- | --- | --- | --- | --- | --- | --- | --- | --- | --- | --- | --- |
| 4207 | 1150 | **Personal Network Management** |  | 955d? | 2005-07-11 A | 2009-03-06 A | 100% | 2005-07-11 | 2009-03-06 | 955d? |  | S1; C1; S3 | 46368h | 46368h | PNM | Vodafone | armin.toepfer@vodafone.com | Rel-8 | Alain | PNM |  |  |  |  |  |  |
| 4208 | 1150.1 | Stage 1 for PNM |  | 276d? | 2005-07-11 A | 2006-07-31 A | 100% | 2005-07-11 | 2006-07-31 | 276d? | start no earlier than 2005-07-11 | S1 | 2208h | 2208h | PNM | Vodafone | armin.toepfer@vodafone.com | Rel-8 | Alain |  | 22.259 |  |  |  |  |  |
| 4209 | 1150.2 | Stage 2 for PNM |  | 445d? | 2007-03-26 A | 2008-12-05 A | 100% | 2007-03-26 | 2008-12-05 | 445d? | finish no earlier than 2008-12-05 | C1 | 3560h | 3560h | PNM | Vodafone | yang.lu@vodafone.com | Rel-8 | Frederic |  | 23.259 |  |  |  |  |  |
| 4210 | 1150.3 | **Stage 3 for PNM** |  | 510d? | 2007-03-26 A | 2009-03-06 A | 100% | 2007-03-26 | 2009-03-06 | 510d? |  | C1; C4 | 15800h | 15800h | PNM | Vodafone | yang.lu@vodafone.com | Rel-8 | Frederic |  |  |  |  |  |  |  |
| 4211 | 1150.3.1 | CT1 aspects of Stage 3 PNM |  | 510d? | 2007-03-26 A | 2009-03-06 A | 100% | 2007-03-26 | 2009-03-06 | 510d? | finish no earlier than 2008-12-05 | C1 | 4080h | 4080h | PNM | Vodafone | yang.lu@vodafone.com | Rel-8 | Frederic |  | 24.259, 24.229 |  |  |  |  |  |
| 4212 | 1150.3.2 | Deleted - CT4 aspects of Stage 3 PNM |  | 445d? | 2007-03-26 A | 2008-12-05 A | 100% | 2007-03-26 | 2008-12-05 | 445d? | finish no earlier than 2008-12-11 | C4 | 3560h | 3560h | PNM | Vodafone | yang.lu@vodafone.com | Rel-8 | Kimmo |  |  | CP-42 |  |  |  |  |
| 4213 | 1150.4 | Key establishment between a UICC hosting device and a remote device |  | 235d? | 2006-12-06 A | 2007-10-30 A | 100% | 2006-12-06 | 2007-10-30 | 235d? | finish no earlier than 2007-10-30 | S3 | 1880h | 1880h | PNM | Ericsson | Vesa.Lehtovirta@ericsson.com | Rel-8 | Mirko |  | 33.259 |  |  |  |  |  |
| 4214 | 1150.5 | Deleted - Actual Requirements of PNM | milestone | 0d? | 2007-03-26 A | 2007-03-26 A | 100% | 2007-03-26 | 2007-03-26 | 0d? | finish no earlier than 2007-03-26 | C1 |  |  | PNM | Ericsson |  | Rel-8 | Frederic |  |  | SP-37 |  |  |  |  |
| 4215 | 1151 | **eCall Data Transfer** |  | 637d? | 2006-09-28 A | 2009-03-06 A | 100% | 2006-09-28 | 2009-03-06 | 637d? |  | S1; C1 | 14840h | 14840h | EData | Airbiquity | rrobinson@airbiquity.com | Rel-8 | Alain | EData |  |  | Public Safety (I-A) |  |  |  |
| 4216 | 1151.1 | eData Requirements |  | 380d? | 2006-09-28 A | 2008-03-12 A | 100% | 2006-09-28 | 2008-03-12 | 380d? | finish no earlier than 2006-12-07 | S1 | 3040h | 3040h | EData | Airbiquity | rrobinson@airbiquity.com | Rel-8 | Alain |  | 22.101, 22.105 |  | Public Safety (I-A) | 37 |  |  |
| 4217 | 1151.2 | Transfer of data during an emergency call |  | 201d? | 2008-05-30 A | 2009-03-06 A | 100% | 2008-05-30 | 2009-03-06 | 201d? | finish no earlier than 2009-03-06 | C1 | 1608h | 1608h | EData | T-Mobile | Dieter Jacobsohn | Rel-8 | Frederic |  | 24.008 |  | Public Safety (I-A) | 40 | 21 |  |
| 4218 | 1152 | eCall data transfer Phase 2: Comparison of alternative in-band modem solutions and standardization of one in-band modem solution |  | 472d? | 2007-12-06 A | 2009-09-24 A | 100% | 2007-12-06 | 2009-09-24 | 472d? | finish no earlier than 2009-09-24 | S4 | 3768.09h | 3768.09h | eCall_Phase2 | Airbiquity | lhong@airbiquity.com & rrobinson@airbiquity.com | Rel-8 | Paolo | eCall_Phase2 | 26.267, 26.268, 26.269, 26.967, 26.969 |  | Public Safety (I-A) |  |  |  |
| 4219 | 1153 | eCall Conformance Testing |  | 261d? | 2009-09-04 A | 2010-09-03 A | 100% | 2009-09-04 | 2010-09-03 | 261d? | finish no earlier than 2010-09-03 | G3new | 2088h | 2088h | eCall_MSTest | Ericsson, Qualcomm | Vikrant Jain (vikrantj@qualcomm.com) | Rel-8 | Ingbert | eCall_MSTest | 51.010-1, 51.010-2 |  | Public Safety (I-A) | 45 | 23 |  |
| 4220 | 1154 | Conformance Test Aspects – non-modem procedures of eCall sessions in UTRA |  | 186d? | 2009-09-18 A | 2010-06-04 A | 100% | 2009-09-18 | 2010-06-04 | 186d? | finish no earlier than 2010-06-04 | R5 | 1488h | 1488h | UMTS_eCall_UEConTest | Ericsson, Qualcomm | Shubhang Vora (svora@qualcomm.com) | Rel-8 | Ingbert | UMTS_eCall_UEConTest | 34.108, 34.123-1, 34.123-2, 34.123-3 |  | Public Safety (I-A) | 45 | 23 | RP-100489 |
| 4221 | 1155 | **IP Interconnection of Services** |  | 668d? | 2006-08-16 A | 2009-03-06 A | 100% | 2006-08-16 | 2009-03-06 | 668d? |  | S1; S2; S5; C3 | 44240h | 44240h | IPinterc | Telefónica O2 | chris.friel@O2.com | Rel-8 | Alain | IPinterc |  |  |  | 38 | 21 |  |
| 4222 | 1155.1 | Stage 1 for IPinterc |  | 70d? | 2007-12-06 A | 2008-03-12 A | 100% | 2007-12-06 | 2008-03-12 | 70d? | start no earlier than 2007-12-06 | S1 | 560h | 560h | IPinterc | Telefónica O2 | chris.friel@O2.com | Rel-8 | Alain |  | 22.101, 22.228 |  |  | 38 | 21 |  |
| 4223 | 1155.2 | **System enhancements for interconnection interfaces between two IMSs** |  | 668d? | 2006-08-16 A | 2009-03-06 A | 100% | 2006-08-16 | 2009-03-06 | 668d? |  | S2; S5; C3 | 22304h | 22304h | IMS_NNI | Telecom Italia | Mario Madella (mario.madella@telecomitalia.it) | Rel-8 | Maurice | IMS_NNI |  |  |  |  |  |  |
| 4224 | 1155.2.1 | Stage 2 for IMS_NNI |  | 120d? | 2007-06-22 A | 2007-12-06 A | 100% | 2007-06-22 | 2007-12-06 | 120d? | finish no earlier than 2007-12-21 | S2 | 960h | 960h | IMS_NNI | Telecom Italia | Mario Madella (mario.madella@telecomitalia.it) | Rel-8 | Maurice |  | 23.002, 23.228 |  |  |  |  |  |
| 4225 | 1155.2.2 | IMS inter-operator service interconnection interface |  | 461d? | 2007-06-01 A | 2009-03-06 A | 100% | 2007-06-01 | 2009-03-06 | 461d? | finish no earlier than 2009-03-06 | C3 | 3688h | 3688h | FBI2-IOPSI | Telecom Italia | antonio.ascolese@telecomitalia.it | Rel-8 | Adrian | FBI2-IOPSI | 29.865, 29.165 |  |  |  |  |  |
| 4226 | 1155.2.3 | Charging harmonization for NGN between 3GPP and ATIS-TMOC |  | 51d? | 2006-09-28 A | 2006-12-07 A | 100% | 2006-09-28 | 2006-12-07 | 51d? | finish no earlier than 2006-12-07 | S5 | 408h | 408h | FBI2-TISP2-CH | Amdocs | yishai.brown@amdocs.com | Rel-8 | Mirko | FBI2-TISP2-CH | 32.297 |  |  |  |  |  |
| 4227 | 1155.2.4 | Deleted - Protocol impact of FBI for TISPAN R2 |  | 152d? | 2006-08-16 A | 2007-03-15 A | 100% | 2006-08-16 | 2007-03-15 | 152d? | finish no earlier than 2007-03-15 | C1 | 1216h | 1216h | FBI2-TISP2-c1 | Ericsson |  | Rel-8 | Frederic | FBI2-TISP2-c1 |  | SP-38 |  |  |  |  |
| 4228 | 1155.2.5 | Deleted (never approved) - Stage 2 of FBI for TISPAN R2 - Rel 8 | milestone | 0d? | 2007-11-30 A | 2007-11-30 A | 100% | 2007-11-30 | 2007-11-30 | 0d? | finish no earlier than 2007-11-30 | S2 |  |  | FBI2-TISP2-s2 | Nokia Siemens Networks |  | Rel-8 | Maurice | FBI2-TISP2-s2 |  | SP-36 |  |  |  |  |
| 4229 | 1156 | **Support of (G)MSC-S – (G)MSC-S Nc Interface based on the SIP-I protocol** |  | 386d? | 2007-09-14 A | 2009-03-06 A | 100% | 2007-09-14 | 2009-03-06 | 386d? |  | C4; C3 | 14960h | 14960h | SIP_Nc | Vodafone | David.Hutton@vodafone.com | Rel-8 | Kimmo | SIP_Nc |  |  |  |  |  |  |
| 4230 | 1156.1 | Stage 1 for SIP_Nc (covered by Feature IPinterc) |  | 70d? | 2007-12-06 A | 2008-03-12 A | 100% | 2007-12-06 | 2008-03-12 | 70d? | start no earlier than 2007-12-06 | S1 | 560h | 560h | SIP_Nc | Telefónica O2 | chris.friel@O2.com | Rel-8 | Alain |  | 22.101, 22.228 |  |  | 41 | 21 |  |
| 4231 | 1156.2 | SIP-I based circuit-switched core network; Stage 2 |  | 321d? | 2007-09-14 A | 2008-12-05 A | 100% | 2007-09-14 | 2008-12-05 | 321d? | finish no earlier than 2008-12-11 | C4 | 2568h | 2568h | SIP_Nc-St2 | Vodafone | David.Hutton@vodafone.com | Rel-8 | Kimmo | SIP_Nc-St2 | 23.231, 23.153, 23.205 |  |  |  |  |  |
| 4232 | 1156.3 | Application of SIP-I Protocols to Circuit Switched (CS) core network architecture; Stage 3 |  | 321d? | 2007-09-14 A | 2008-12-05 A | 100% | 2007-09-14 | 2008-12-05 | 321d? | finish no earlier than 2008-12-11 | C4 | 2568h | 2568h | SIP_Nc-St3C4 | Vodafone | David.Hutton@vodafone.com | Rel-8 | Kimmo | SIP_Nc-St3 | 29.231, 29.232, 29.332 |  |  |  |  |  |
| 4233 | 1156.4 | Interworking between the 3GPP CS domain with SIP-I as signalling protocol and other networks |  | 386d? | 2007-09-14 A | 2009-03-06 A | 100% | 2007-09-14 | 2009-03-06 | 386d? | finish no earlier than 2009-03-06 | C3 | 3088h | 3088h | SIP_Nc-St3C3 | Nokia Siemens Networks | Thomas.Belling@nsn.com | Rel-8 | Adrian |  | 29.235, 23.172, 23.202, 29.007, 29.163, 29.414 |  |  |  |  |  |

Notes:
- 4207: CP#43 completed
- 4208: SP#31 completed
- 4209: CP#42 completed
- 4210: CP#43 completed
- 4211: CP#43 completed
- 4212: CP#42 no impact on CT4 specs
- 4213: SP#37 completed
- 4214: SP#37 stopped
- 4215: SP#39 completed. Linked to SA4 Feature UID_34042 (eCall_Phase2)
- 4216: SP#39 completed
- 4217: CP#43 completed
- 4218: SP#45 completed. Triggered by Study UID_360015 (eCALLIBMS). Linked to SA1 Feature UID_330005 (EData)
- 4219: GP#47 completed. GP#43 WID approved. Testing for Rel-8 eCall_Phase2 (UID_34042) and EData (UID_330005)
- 4220: RP#48 completed. Testing for Rel-8 eCall_Phase2 (UID_34042) and Edata (UID_330005)
- 4221: SP#43 completed
- 4222: SP#39 completed.
- 4223: CP#43 completed
- 4224: SP#38 completed
- 4225: CP#43 completed
- 4226: SP#34 completed
- 4227: SP#38 stopped
- 4228: SP#36 stopped
- 4229: CP#43 completed. Stage 1 in Feature UID_380060 (IPinterc). CP#40 updated WID CP-070517=>CP-080282
- 4230: 22/07/08 Created. Stage 1 for SIP_Nc (covered by SA1 Feature UID_380060 Ipinterc)
- 4231: CP#42 completed
- 4232: CP#42 completed
- 4233: CP#43 completed. CP#42 target 12/08=>03/09

| ID | WBS | Task | Type | Duration | Start | Finish | Complete | Baseline start | Baseline finish | Baseline duration | Constraint | Resources | Work | Actual work | Acronym | WI rapporteur name | WI rapporteur e-mail | Release | TSG approved | MCC resp | Special Focus Doc | Acronym_3GU_Export | Impacted TSs and TRs | PCG approved | Status Report |
| --- | --- | --- | --- | --- | --- | --- | --- | --- | --- | --- | --- | --- | --- | --- | --- | --- | --- | --- | --- | --- | --- | --- | --- | --- | --- |
| 4234 | 1157 | **Earthquake and Tsunami Warning System** |  | 440d? | 2007-09-10 A | 2009-05-15 A | 100% | 2007-09-10 | 2009-05-15 | 440d? |  | S1; S2; C1; C4; G2 | 21280h | 21280h | ETWS | NTT DoCoMo | kitaharar@nttdocomo.co.jp | Rel-8 | 37 | Alain | Public Safety (I-A) | ETWS |  |  |  |
| 4235 | 1157.1 | Stage 1 for ETWS |  | 133d? | 2007-09-10 A | 2008-03-12 A | 100% | 2007-09-10 | 2008-03-12 | 133d? | finish no earlier than 2008-03-12 | S1 | 1064h | 1064h | ETWS | NTT DoCoMo | kitaharar@nttdocomo.co.jp | Rel-8 | 37 | Alain | Public Safety (I-A) |  | 22.168 |  |  |
| 4236 | 1157.2 | SA2 aspects of ETWS |  | 179d? | 2008-01-14 A | 2008-09-18 A | 100% | 2008-01-14 | 2008-09-18 | 179d? | finish no earlier than 2008-09-08 | S2 | 1432h | 1432h | ETWS | NTT DoCoMo | tanakai@nttdocomo.co.jp | Rel-8 | 38 | Maurice | Public Safety (I-A) |  | 23.828, 23.401 | 21 |  |
| 4237 | 1157.3 | CT1 aspects of ETWS |  | 50.5d? | 2008-05-30 A | 2008-12-05 A | 100% | 2008-05-30 | 2008-12-05 | 50.5d? | finish no earlier than 2008-12-05 | C1 | 404h | 404h | ETWS | NTT DoCoMo | yamashitahi@s1.nttdocomo.co.jp | Rel-8 | 40 | Frederic | Public Safety (I-A) |  | 23.041 | 21 |  |
| 4238 | 1157.4 | CT4 aspects of ETWS |  | 50.5d? | 2008-09-26 A | 2008-12-05 A | 100% | 2008-09-26 | 2008-12-05 | 50.5d? | finish no earlier than 2008-12-05 | C4 | 404h | 404h | ETWS | NTT DoCoMo | yamashitahi@s1.nttdocomo.co.jp | Rel-8 | 40 | Kimmo | Public Safety (I-A) |  | 29.168 | 21 |  |
| 4239 | 1157.5 | ETWS primary notification message definition in GERAN |  | 47d? | 2009-03-12 A | 2009-05-15 A | 100% | 2009-03-12 | 2009-05-15 | 47d? | finish no earlier than 2009-05-15 | G2 | 376h | 376h | ETWS | Ericsson | claes-goran.persson@ericsson.com | Rel-8 | 43 | Gert | Public Safety (I-A) |  | 44.018, 44.060 | 22 |  |
| 4240 | 1158 | Conformance Test Aspects – UMTS Earthquake and Tsunami Warning System (ETWS) FDD |  | 207d? | 2009-05-29 A | 2010-03-12 A | 100% | 2009-05-29 | 2010-03-12 | 207d? | finish no earlier than 2010-03-12 | R5 | 1656h | 1656h | ETWS_UMTS_UEConTestFDD | NTT DoCoMo | Makoto Ito (itohm@nttdocomo.co.jp) | Rel-8 | 44 | Ingbert | Public Safety (I-A) | ETWS_UMTS_UEConTestFDD | 34.108, 34.123-1, 34.123-2 | 23 | RP-100068 |
| 4241 | 1159 | **In Case of Emergency numbers storage and easy access on UICC** |  | 519d? | 2007-03-13 A | 2009-03-06 A | 100% | 2007-03-13 | 2009-03-06 | 519d? |  | S1; C6 | 14552h | 14552h | ICE | Vodafone | armin.toepfer@vodafone.com | Rel-8 | 38 | Alain |  | ICE |  | 21 |  |
| 4242 | 1159.1 | Stage 1 for ICE |  | 262d? | 2007-03-13 A | 2008-03-12 A | 100% | 2007-03-13 | 2008-03-12 | 262d? | finish no earlier than 2008-03-12 | S1 | 2096h | 2096h | ICE | Vodafone | armin.toepfer@vodafone.com | Rel-8 | 38 | Alain |  |  | 22.030, 22.101 | 21 |  |
| 4243 | 1159.2 | CT6 aspects of ICE |  | 519d? | 2007-03-13 A | 2009-03-06 A | 100% | 2007-03-13 | 2009-03-06 | 519d? | finish no earlier than 2009-03-06 | C6 | 4152h | 4152h | ICE | Vodafone | armin.toepfer@vodafone.com | Rel-8 | 38 | Xavier |  |  | 31.102 | 21 |  |
| 4244 | 1160 | Local Charging Zone Requirements |  | 380d? | 2006-09-28 A | 2008-03-12 A | 100% | 2006-09-28 | 2008-03-12 | 380d? | finish no earlier than 2006-12-07 | S1 | 3040h | 3040h | LCZR | China Mobile | liuhongyfw@chinamobile.com | Rel-8 |  | Alain |  | LCZR | 22.115 |  |  |
| 4245 | 1161 | **Customized Alerting Tone (CAT) service** |  | 729d? | 2006-12-06 A | 2009-09-18 A | 100% | 2006-12-06 | 2009-09-18 | 729d? |  | S1; C1; C3; C4 | 39854h | 39854h | CAT | China Mobile | fenglingjuan@chinamobile.com | Rel-8 | 34 | Alain |  | CAT |  |  |  |
| 4246 | 1161.1 | Stage 1 for CAT |  | 207d? | 2006-12-06 A | 2007-09-20 A | 100% | 2006-12-06 | 2007-09-20 | 207d? | start no earlier than 2006-12-06 | S1 | 1656h | 1656h | CAT | China Mobile | fenglingjuan@chinamobile.com | Rel-8 | 37 | Alain |  |  | 22.182 |  |  |
| 4247 | 1161.2 | TISPAN requirements for customized multimedia information services |  | 71d? | 2007-09-03 A | 2007-12-10 A | 100% | 2007-09-03 | 2007-12-10 | 71d? | finish no earlier than 2007-12-10 | S1 | 568h | 568h | TISCMI | China Mobile | fenglingjuan@chinamobile.com | Rel-8 | 37 | Alain |  | TISCMI | 22.182 |  |  |
| 4248 | 1161.3 | **IMS CAT Supplementary Service** |  | 399d? | 2008-03-12 A | 2009-09-18 A | 100% | 2008-03-12 | 2009-09-18 | 399d? |  | C1; C3 | 10814.4h | 10814.4h | CAT-SS | Nortel | milanpa@nortel.com | Rel-8 | 39 | Frederic |  | CAT-SS |  | 21 |  |
| 4249 | 1161.3.1 | IMS CAT SS |  | 164d? | 2008-04-21 A | 2008-12-04 A | 100% | 2008-04-21 | 2008-12-04 | 164d? | finish no earlier than 2008-12-05 | C1 | 1312h | 1312h | CAT-SS | Nortel | milanpa@nortel.com | Rel-8 | 39 | Frederic |  |  | 24.182 | 21 |  |
| 4250 | 1161.3.2 | CAT solution for voice and video call in CS domain |  | 389.8d? | 2008-03-12 A | 2009-09-18 A | 100% | 2008-03-12 | 2009-09-18 | 389.8d? | finish no earlier than 2009-09-11 | C3 | 3118.4h | 3118.4h | CAT-SS | Nortel | milanpa@nortel.com | Rel-8 | 39 | Adrian |  |  | 29.163 | 21 |  |
| 4251 | 1161.4 | **CAT Service in 3GPP CS domain** |  | 126d? | 2008-09-12 A | 2009-03-06 A | 100% | 2008-09-12 | 2009-03-06 | 126d? |  | C4; C1 | 3487.6h | 3487.6h | CAT-3G_CS | China Mobile | zhaoyuyi@chinamobile.com | Rel-8 | 41 | Kimmo |  | CAT-3G_CS | 23.205, 23.231, 29.002 | 21 |  |
| 4252 | 1161.4.1 | CT4 part of CAT Service in 3GPP CS domain |  | 126d? | 2008-09-12 A | 2009-03-06 A | 100% | 2008-09-12 | 2009-03-06 | 126d? | finish no earlier than 2009-03-06 | C4 | 1008h | 1008h | CAT-3G_CS | China Mobile | zhaoyuyi@chinamobile.com | Rel-8 | 41 | Kimmo |  |  | 23.205, 23.231, 29.002 | 21 |  |
| 4253 | 1161.4.2 | CT1 part of CAT Service in 3GPP CS domain |  | 57.95d? | 2008-09-12 A | 2008-12-05 A | 100% | 2008-09-12 | 2008-12-05 | 57.95d? | start no earlier than 2008-09-12 | C1 | 463.6h | 463.6h | CAT-3G_CS | China Mobile | zhaoyuyi@chinamobile.com | Rel-8 | 41 | Frederic |  |  | 24.008, 23.014 | 21 |  |
| 4254 | 1162 | **Service-Level Interworking for Messaging Services** |  | 509d? | 2007-03-26 A | 2009-03-06 A | 100% | 2007-03-26 | 2009-03-06 | 509d? |  | S1; S2; C3; C1 | 20800h | 20800h | MESSIW | Huawei | ling.liu@huawei.com; duanxiaoqin@huawei.com | Rel-8 | 34 | Alain |  | MESSIW |  |  |  |
| 4255 | 1162.1 | Stage 1 for MESSIW | milestone | 0d? | 2007-03-26 A | 2007-03-26 A | 100% | 2007-03-26 | 2007-03-26 | 0d? | finish no earlier than 2007-12-01 | S1 |  |  | MESSIW | Huawei | ling.liu@huawei.com | Rel-8 |  | Alain |  |  | 22.105, 22.340 |  |  |
| 4256 | 1162.2 | Stage 2 for MESSIW |  | 227d? | 2007-04-26 A | 2008-03-07 A | 100% | 2007-04-26 | 2008-03-07 | 227d? | finish no earlier than 2008-03-07 | S2 | 1816h | 1816h | MESSIW | Huawei | patrice.hede@huawei.com | Rel-8 |  | Maurice |  |  | 23.811, 23.204 |  |  |
| 4257 | 1162.3 | CT3 part of Stage 3 for MESSIW |  | 201d? | 2008-05-30 A | 2009-03-06 A | 100% | 2008-05-30 | 2009-03-06 | 201d? | finish no earlier than 2008-12-05 | C3 | 1608h | 1608h | MESSIW | Huawei | xupeili@huawei.com | Rel-8 | 40 | Adrian |  |  | 29.311 | 21 |  |
| 4258 | 1162.4 | CT1 part of Stage 3 for MESSIW |  | 136d? | 2008-05-30 A | 2008-12-05 A | 100% | 2008-05-30 | 2008-12-05 | 136d? | finish no earlier than 2008-12-12 | C1 | 1088h | 1088h | MESSIW | Huawei | xupeili@huawei.com | Rel-8 | 40 | Frederic |  |  | 24.229 | 21 |  |

Notes:
- 4234: SP#43 Larger scope Feature UID_380057 (PWS) moved to Rel-9
- 4235: SP#39 completed
- 4236: SP#41 completed
- 4237: CP#42 completed
- 4238: CP#42 completed
- 4239: SP#44 completed with CT1 help (GERAN2 LS_in SP-090154)
- 4240: RP#47 completed. Testing for Rel-8 ETWS UID_370051
- 4241: CP#43 completed (ICE Graphics not included in Rel-8)
- 4242: SP#39 Stage 1 completed
- 4243: CP#43 completed (ICE Graphics not in Rel-8 / not explicitly in SA1 WID either)
- 4244: SP#39 Stage 1 completed
- 4245: CP#45 completed
- 4246: -
- 4247: SP#38 completed
- 4248: -
- 4249: CP#42 completed
- 4250: CP#45 completed. Triggered by Study UID_360031 (TR 29.882)
- 4251: -
- 4252: CP#43 completed. Triggered by Study UID_360031 (TR 29.882)
- 4253: CP#42 completed. Triggered by Study UID_360031 (TR 29.882)
- 4254: CP#43 completed
- 4255: SP#35 completed
- 4256: SP#39 completed
- 4257: CP#43 completed
- 4258: CP#42 completed

| ID | WBS | Task | Duration | Start | Finish | Complete | Baseline start | Baseline finish | Baseline duration | Constraint | Resources | Work | Actual work | Acronym | WI rapporteur name | WI rapporteur e-mail | Release | TSG approved | MCC resp | Special Focus Doc | Acronym_3GU_Export | Impacted TSs and TRs | PCG stopped | TSG stopped | PCG approved |
| --- | --- | --- | --- | --- | --- | --- | --- | --- | --- | --- | --- | --- | --- | --- | --- | --- | --- | --- | --- | --- | --- | --- | --- | --- | --- |
| 4259 | 1163 | **Multimedia Priority Service** | 858d? | 2006-06-08 A | 2009-09-18 A | 100% | 2006-06-08 | 2009-09-18 | 858d? |  | S1; C1; C3; C4 | 43016h | 43016h | PRIOR_EMR | Telcordia | jgarraha@telcordia.com | Rel-8 | 34 | Alain | Public Safety (I-A) | PRIOR |  |  |  |  |
| 4260 | 1163.1 | Service Requirements for PRIOR | 391d? | 2006-06-08 A | 2007-12-06 A | 100% | 2006-06-08 | 2007-12-06 | 391d? | finish no earlier than 2007-11-30 | S1 | 3128h | 3128h | PRIOR_EMR | Telcordia | jgarraha@telcordia.com | Rel-8 | 32 | Alain | Public Safety (I-A) | PRIOR-EMR | New 22.153 |  |  |  |
| 4261 | 1163.2 | CT1 part of Stage 3 for PRIOR | 732d? | 2006-12-01 A | 2009-09-18 A | 100% | 2006-12-01 | 2009-09-18 | 732d? | finish no earlier than 2009-09-18 | C1 | 5856h | 5856h | PRIOR_EMR | Alcatel-Lucent | Keith Drage (drage@alcatel-lucent.com) | Rel-8 | 34 | Frederic | Public Safety (I-A) |  | 24.229 |  |  |  |
| 4262 | 1163.3 | CT4 part of Stage 3 for PRIOR | 381d? | 2007-09-21 A | 2009-03-06 A | 100% | 2007-09-21 | 2009-03-06 | 381d? | finish no earlier than 2009-03-06 | C4 | 3048h | 3048h | PRIOR_EMR | Alcatel-Lucent | Keith Drage (drage@alcatel-lucent.com) | Rel-8 | 37 | Kimmo | Public Safety (I-A) |  | 23.008, 29.228, 29.229 |  |  |  |
| 4263 | 1163.4 | Deleted - Stage 3 for PRIOR | 441d? | 2007-09-21 A | 2009-05-29 A | 100% | 2007-09-21 | 2009-05-29 | 441d? | finish no earlier than 2009-05-29 | C3 | 3528h | 3528h | PRIOR-EMR | Alcatel-Lucent | Keith Drage (drage@alcatel-lucent.com) | Rel-8 | 37 | Adrian | Public Safety (I-A) |  | 29.212, 29.213, 29.214, 29.163 | PCG-23 | CP-44 |  |
| 4264 | 1164 | **Open Service Access (OSA) Rel-8** | 202d? | 2007-08-23 A | 2008-05-30 A | 100% | 2007-08-23 | 2008-05-30 | 202d? |  | S1; C5 | 25528h | 25528h | OSA8 | Orange | Song Dong | Rel-8 |  | Alain |  | OSA8 |  |  |  |  |
| 4265 | 1164.1 | OSA Stage 1 - Service Requirements | 145d? | 2007-08-23 A | 2008-03-12 A | 100% | 2007-08-23 | 2008-03-12 | 145d? | finish no earlier than 2007-12-04 | S1 | 1160h | 1160h | OSA8 | Orange, AePONA | Song Dong | Rel-8 |  | Alain |  |  | 22.127 |  |  |  |
| 4266 | 1164.2 | OSA Stage 1 - NGN Service Requirement | 140d? | 2007-09-03 A | 2008-03-14 A | 100% | 2007-09-03 | 2008-03-14 | 140d? | finish no earlier than 2008-03-14 | S1 | 1120h | 1120h | OSA8-IMSReq | Orange | Song Dong | Rel-8 | 37 | Alain |  | OSA8-IMS | 22.127 |  |  |  |
| 4267 | 1164.3 | **Rel-8 OSA Stage 2/3 enhancements** | 157d? | 2007-10-25 A | 2008-05-30 A | 100% | 2007-10-25 | 2008-05-30 | 157d? |  | C5 | 20016h | 20016h | OSA8-IMS | Alcatel-Lucent | unmehopa@alcatel-lucent.com | Rel-8 |  | Kimmo |  |  | 23.198, 29.198, 29.199 |  |  |  |
| 4268 | 1164.3.1 | Deleted - Ensure Parlay-X composable with identity management frameworks, in particular Liberty Alliance | 157d? | 2007-10-25 A | 2008-05-30 A | 100% | 2007-10-25 | 2008-05-30 | 157d? | finish no earlier than 2008-12-25 | C5 | 1256h | 1256h |  | Ericsson | catherine.mulligan@ericsson.com | Rel-8 | 37 | Kimmo |  |  | existing 29.199-xy | PCG-21 | CP-40 | 21 |
| 4269 | 1164.3.2 | Parlay-X Content Management web service (store/manage meta-data) | 157d? | 2007-10-25 A | 2008-05-30 A | 100% | 2007-10-25 | 2008-05-30 | 157d? | finish no earlier than 2008-12-04 | C5 | 1256h | 1256h | OSA8-IMS | Alcatel-Lucent | unmehopa@alcatel-lucent.com | Rel-8 | 37 | Kimmo |  |  | 29.199-21 |  |  |  |
| 4270 | 1164.3.3 | Parlay-X Policy web service | 157d? | 2007-10-25 A | 2008-05-30 A | 100% | 2007-10-25 | 2008-05-30 | 157d? | finish no earlier than 2008-12-04 | C5 | 1256h | 1256h | OSA8-IMS | Alcatel-Lucent | unmehopa@alcatel-lucent.com | Rel-8 | 37 | Kimmo |  |  | 29.199-22 |  |  |  |
| 4271 | 1164.3.4 | Parlay-X Terminal status web service | 157d? | 2007-10-25 A | 2008-05-30 A | 100% | 2007-10-25 | 2008-05-30 | 157d? | finish no earlier than 2008-05-30 | C5 | 1256h | 1256h | OSA8-IMS | Alcatel-Lucent | unmehopa@alcatel-lucent.com | Rel-8 | 37 | Kimmo |  |  | 29.199-08 |  |  |  |
| 4272 | 1164.3.5 | Deleted - Identify communication format used by a particular application | 157d? | 2007-10-25 A | 2008-05-30 A | 100% | 2007-10-25 | 2008-05-30 | 157d? | finish no earlier than 2008-05-30 | C5 | 1256h | 1256h |  | Ericsson | catherine.mulligan@ericsson.com | Rel-8 | 37 | Kimmo |  |  | existing 29.199-xy | PCG-21 | CP-40 | 21 |
| 4273 | 1164.3.6 | Deleted - Security on User Profile Management - reuse GUP API (22.127 CR 0084 S1-071794) | 128d? | 2007-12-05 A | 2008-05-30 A | 100% | 2007-12-05 | 2008-05-30 | 128d? | finish no earlier than 2008-12-25 | C5 | 1024h | 1024h |  | Telecom Italia | vincenzo.amorino@telecomitalia.it | Rel-8 | 38 | Kimmo |  |  | PXWS Framework | PCG-21 | CP-40 | 21 |
| 4274 | 1164.3.7 | Deleted - Privacy on Subscriber Identity (Liberty Alliance, OASIS) (22.127 CR 0085 S1-071835) | 128d? | 2007-12-05 A | 2008-05-30 A | 100% | 2007-12-05 | 2008-05-30 | 128d? | finish no earlier than 2008-12-25 | C5 | 1024h | 1024h |  | Telecom Italia | vincenzo.amorino@telecomitalia.it | Rel-8 | 38 | Kimmo |  |  | PXWS Framework | PCG-21 | CP-40 | 21 |
| 4275 | 1164.3.8 | Deleted - Topology Hiding (22.127 CR 0086 S1-071838) | 128d? | 2007-12-05 A | 2008-05-30 A | 100% | 2007-12-05 | 2008-05-30 | 128d? | finish no earlier than 2008-12-25 | C5 | 1024h | 1024h |  | Telecom Italia | vincenzo.amorino@telecomitalia.it | Rel-8 | 38 | Kimmo |  |  | PXWS Framework | PCG-21 | CP-40 | 21 |
| 4276 | 1164.3.9 | Deleted - Subscriber event notification (22.127 CR 0087 S1-071836) | 128d? | 2007-12-05 A | 2008-05-30 A | 100% | 2007-12-05 | 2008-05-30 | 128d? | finish no earlier than 2008-12-25 | C5 | 1024h | 1024h |  | Telecom Italia | vincenzo.amorino@telecomitalia.it | Rel-8 | 38 | Kimmo |  |  | PXWS Framework | PCG-21 | CP-40 | 21 |
| 4277 | 1164.3.10 | Deleted - Event notification (22.127 CR 0088 S1-071762) | 128d? | 2007-12-05 A | 2008-05-30 A | 100% | 2007-12-05 | 2008-05-30 | 128d? | finish no earlier than 2008-12-25 | C5 | 1024h | 1024h |  | Telecom Italia | vincenzo.amorino@telecomitalia.it | Rel-8 | 38 | Kimmo |  |  | PXWS Framework | PCG-21 | CP-40 | 21 |
| 4278 | 1164.3.11 | Deleted - Access policy (22.127 CR 0089 S1-071763) | 128d? | 2007-12-05 A | 2008-05-30 A | 100% | 2007-12-05 | 2008-05-30 | 128d? | finish no earlier than 2008-12-25 | C5 | 1024h | 1024h |  | Telecom Italia | vincenzo.amorino@telecomitalia.it | Rel-8 | 38 | Kimmo |  |  | PXWS Framework | PCG-21 | CP-40 | 21 |
| 4279 | 1164.3.12 | Deleted - API usage accounting (22.127 CR 0090 S1-071792) | 128d? | 2007-12-05 A | 2008-05-30 A | 100% | 2007-12-05 | 2008-05-30 | 128d? | finish no earlier than 2008-12-25 | C5 | 1024h | 1024h |  | Telecom Italia | vincenzo.amorino@telecomitalia.it | Rel-8 | 38 | Kimmo |  |  | PXWS Framework | PCG-21 | CP-40 | 21 |
| 4280 | 1164.3.13 | Presence alignment with OMA and IETF (22.127 CR 0092 S1-071764) | 128d? | 2007-12-05 A | 2008-05-30 A | 100% | 2007-12-05 | 2008-05-30 | 128d? | finish no earlier than 2008-05-30 | C5 | 1024h | 1024h | OSA8-IMS | Alcatel-Lucent | unmehopa@alcatel-lucent.com | Rel-8 | 38 | Kimmo |  |  | 29.199-14/13 |  |  | 21 |
| 4281 | 1164.3.14 | Deleted - Service identification (22.127 CR 0095 S1-071837) | 128d? | 2007-12-05 A | 2008-05-30 A | 100% | 2007-12-05 | 2008-05-30 | 128d? | finish no earlier than 2008-05-30 | C5 | 1024h | 1024h |  | Ericsson | catherine.mulligan@ericsson.com | Rel-8 | 38 | Kimmo |  |  | existing 29.199-xy | PCG-21 | CP-40 | 21 |
| 4282 | 1164.3.15 | Framework Enterprise Operator (Service Subscription function) | 102d? | 2008-01-10 A | 2008-05-30 A | 100% | 2008-01-10 | 2008-05-30 | 102d? | finish no earlier than 2008-05-30 | C5 | 816h | 816h | OSA8-IMS | Alcatel-Lucent | unmehopa@alcatel-lucent.com | Rel-8 | 39 | Kimmo |  |  | 29.198-03 |  |  | 21 |
| 4283 | 1164.3.16 | Mobility Emergency Location | 102d? | 2008-01-10 A | 2008-05-30 A | 100% | 2008-01-10 | 2008-05-30 | 102d? | finish no earlier than 2008-05-30 | C5 | 816h | 816h | OSA8-IMS | Alcatel-Lucent | unmehopa@alcatel-lucent.com | Rel-8 | 39 | Kimmo |  |  | 29.198-06 |  |  | 21 |
| 4284 | 1164.3.17 | Connectivity Manager SCF | 102d? | 2008-01-10 A | 2008-05-30 A | 100% | 2008-01-10 | 2008-05-30 | 102d? |  | C5 | 816h | 816h | OSA8-IMS | Alcatel-Lucent | unmehopa@alcatel-lucent.com | Rel-8 | 39 | Kimmo |  |  | 29.198-10 |  |  | 21 |
| 4285 | 1164.3.18 | PAM Presence Agent | 102d? | 2008-01-10 A | 2008-05-30 A | 100% | 2008-01-10 | 2008-05-30 | 102d? | finish no earlier than 2008-05-30 | C5 | 816h | 816h | OSA8-IMS | Alcatel-Lucent | unmehopa@alcatel-lucent.com | Rel-8 | 39 | Kimmo |  |  | 29.198-14 |  |  | 21 |

Notes:
- 4259: CP#45 completed
- 4260: SP#38 completed
- 4261: CP#45 completed
- 4262: CP#43 completed
- 4263: CP#44 stopped (Reason: No Rel-8 solution expected (LS sent to SA2, but not prioritized in SA2)
- 4264: SP#40 maintenance & new OSA work moved to OMA. Rel-9 onwards 3GPP references to 22.127 changed to OMA Parlay Service Access Requirements (OMA-RD-Parlay_Service_Access-V1_0-20100427-A).
- 4265: SP#40 maintenance & new OSA work moved to OMA. Rel-9 onwards 3GPP references to 22.127 changed to OMA Parlay Service Access Requirements (OMA-RD-Parlay_Service_Access-V1_0-20100427-A).
- 4266: SP#40 maintenance & new OSA work moved to OMA
- 4267: SP#40 maintenance & new OSA work moved to OMA
- 4268: CP#40: Work moved to OMA
- 4269: CP#40 completed
- 4270: CP#40 completed
- 4271: CP#40 completed
- 4272: CP#40: Work moved to OMA
- 4273: SP#38 SP-070853 R8 CRs 22.127 OSA Stage 1. CP#40: Work moved to OMA
- 4274: SP#38 SP-070853 R8 CRs 22.127 OSA Stage 1. CP#40: Work moved to OMA
- 4275: SP#38 SP-070853 R8 CRs 22.127 OSA Stage 1. CP#40: Work moved to OMA
- 4276: SP#38 SP-070853 R8 CRs 22.127 OSA Stage 1. CP#40: Work moved to OMA
- 4277: SP#38 SP-070853 R8 CRs 22.127 OSA Stage 1. CP#40: Work moved to OMA
- 4278: SP#38 SP-070853 R8 CRs 22.127 OSA Stage 1. CP#40: Work moved to OMA
- 4279: SP#38 SP-070853 R8 CRs 22.127 OSA Stage 1. CP#40: Work moved to OMA
- 4280: CP#40 completed
- 4281: SP#38 SP-070853 R8 CRs 22.127 OSA Stage 1. CP#40: Work moved to OMA
- 4282: CP#40 completed
- 4283: CP#40 completed
- 4284: CP#40 completed
- 4285: CP#40 completed

| ID | WBS | Task | Duration | Start | Finish | Complete | Remaining | Baseline start | Baseline finish | Baseline duration | Total slack | Constraint | Resources | Work | Actual work | Acronym | WI rapporteur name | Release | MCC resp | Acronym_3GU_Export | TSG approved | PCG approved | Status Report | Special Focus Doc |
| --- | --- | --- | --- | --- | --- | --- | --- | --- | --- | --- | --- | --- | --- | --- | --- | --- | --- | --- | --- | --- | --- | --- | --- | --- |
| 4286 | 1165 | **Paging Permission with Access Control (PPACR)** | 389d? | 2007-06-12 A | 2008-12-05 A | 100% |  | 2007-06-12 | 2008-12-05 | 389d? |  |  | S1; C1 | 9000h | 9000h | PPACR | NTT DoCoMo | Rel-8 | Alain | PPACR |  |  |  |  |
| 4287 | 1165.1 | Stage 1 for PPACR | 69d? | 2007-06-12 A | 2007-09-14 A | 100% |  | 2007-06-12 | 2007-09-14 | 69d? |  | finish no earlier than 2007-09-14 | S1 | 552h | 552h | PPACR-S1 | NTT DoCoMo | Rel-8 | Alain | PPACR-S1 | 37 |  |  |  |
| 4288 | 1165.2 | Stage 3 for PPACR (CT1) | 278d? | 2007-11-14 A | 2008-12-05 A | 100% |  | 2007-11-14 | 2008-12-05 | 278d? |  | finish no earlier than 2008-12-05 | C1 | 2224h | 2224h | PPACR-CT1 | NTT DoCoMo | Rel-8 | Frederic | PPACR-CT1 | 38 | 21 |  |  |
| 4289 | 1166 | Conformance Test Aspects – Paging Permission with Access Control (PPAC) | 61d? | 2010-09-17 A | 2010-12-10 A | 100% |  | 2010-09-17 | 2010-12-10 | 61d? |  | finish no earlier than 2010-12-10 | R5 | 488h | 488h | PPAC_UEConTest | NTT DoCoMo | Rel-8 | Ingbert | PPAC_UEConTest | 49 | 25 | RP-101074 |  |
| 4290 | 1167 | **Charging for multi-phases services** | 70d? | 2007-12-06 A | 2008-03-12 | 99% | 0d? | 2007-12-06 | 2008-03-12 | 70d? | 0d |  | S1 | 560h | 560h | CHRGMPH | Telecom Italia | Rel-8 | Alain | CHRGMPH | 38 | 21 |  |  |
| 4291 | 1167.1 | Stage 1 for CHRGMPH | 70d? | 2007-12-06 A | 2008-03-12 A | 100% |  | 2007-12-06 | 2008-03-12 | 70d? |  | start no earlier than 2007-12-06 | S1 | 560h | 560h | CHRGMPH-s1 | Telecom Italia | Rel-8 | Alain | CHRGMPH-s1 | 38 | 21 |  |  |
| 4292 | 1168 | **Home NodeB / eNodeB** | 327d? | 2007-12-06 A | 2009-03-06 A | 100% |  | 2007-12-06 | 2009-03-06 | 327d? |  |  | S1; C1; C4 | 10952h | 10952h | HomeNB | Vodafone | Rel-8 | Alain | HomeNB | 38 | 21 |  | HNB |
| 4293 | 1168.1 | Stage 1 for Home NodeB / eNodeB | 70d? | 2007-12-06 A | 2008-03-12 A | 100% |  | 2007-12-06 | 2008-03-12 | 70d? |  | start no earlier than 2007-12-06 | S1 | 560h | 560h | HomeNB-S1 | Vodafone | Rel-8 | Alain | HomeNB-S1 | 38 | 21 |  | HNB |
| 4294 | 1168.2 | Support of Closed Subscriber Group (CSG) | 66d? | 2008-12-05 A | 2009-03-06 A | 100% |  | 2008-12-05 | 2009-03-06 | 66d? |  | finish no earlier than 2009-03-06 | C4 | 528h | 528h |  | CT#42 | Rel-8 | Kimmo |  | 42 | 22 |  | HNB |
| 4295 | 1168.3 | CSG and Idle Mode Mobility for LTE Home eNodeB | 126d? | 2008-09-12 A | 2009-03-06 A | 100% |  | 2008-09-12 | 2009-03-06 | 126d? |  | finish no earlier than 2009-03-06 | C1 | 1008h | 1008h | HomeNB-LTE | Huawei | Rel-8 | Frederic | HomeNB-LTE | 41 | 21 |  | HNB |
| 4296 | 1168.4 | CSG and Idle Mode Mobility for 3G Home NodeB | 126d? | 2008-09-12 A | 2009-03-06 A | 100% |  | 2008-09-12 | 2009-03-06 | 126d? |  | finish no earlier than 2009-03-06 | C1 | 1008h | 1008h | HomeNB-3G | Qualcomm | Rel-8 | Frederic | HomeNB-3G | 41 | 21 |  | HNB |
| 4297 | 1169 | **UTRA HNB** | 326d? | 2008-03-07 A | 2009-06-04 A | 100% |  | 2008-03-07 | 2009-06-04 | 326d? |  |  | RP; S5 | 11008h | 11008h | HNB |  | Rel-8 | Issam | HNB | 39 | 21 |  | HNB |
| 4298 | 1169.1 | Support of UTRA HNB | 201d? | 2008-05-30 A | 2009-03-06 A | 100% |  | 2008-05-30 | 2009-03-06 | 201d? |  | finish no earlier than 2009-03-06 | R2 | 1608h | 1608h | HNB-supp | Huawei | Rel-8 | Yong-Jun | HNB-supp | 40 | 21 | RP-090040 | HNB |
| 4299 | 1169.2 | UTRAN Architecture for 3G HNB | 136d? | 2008-05-30 A | 2008-12-05 A | 100% |  | 2008-05-30 | 2008-12-05 | 136d? |  | finish no earlier than 2008-12-05 | R3 | 1088h | 1088h | HNB-arch | Alcatel-Lucent | Rel-8 | Juha | HNB-arch | 40 | 21 | RP-090042 | HNB |
| 4300 | 1169.3 | FDD Home NodeB RF requirements | 261d? | 2008-03-07 A | 2009-03-06 A | 100% |  | 2008-03-07 | 2009-03-06 | 261d? |  | finish no earlier than 2009-03-06 | R4 | 2088h | 2088h | HNB-RF | Motorola | Rel-8 | Issam | HNB-RF | 39 | 21 | RP-090041 | HNB |
| 4301 | 1169.4 | 3G Home NodeB OAM&P Type 1 Management Interface | 127d? | 2008-12-11 A | 2009-06-04 A | 100% |  | 2008-12-11 | 2009-06-04 | 127d? |  | finish no earlier than 2009-06-04 | S5 | 1008h | 1008h | HNB-3G_OAM | Huawei | Rel-8 | Mirko | HNB-3G_OAM | 42 | 22 |  | HNB |
| 4302 | 1170 | **UTRA HNB – UE Conformance Testing** | 327d? | 2009-03-06 A | 2010-06-04 A | 100% |  | 2009-03-06 | 2010-06-04 | 327d? |  |  | R5 | 5224h | 5224h | HNB-UEConTest |  | Rel-8 | Ingbert | HNB-UEConTest | 43 | 22 |  | HNB |
| 4303 | 1170.1 | Conformance Test Aspects – UTRA HNB (FDD) | 326d? | 2009-03-06 A | 2010-06-04 A | 100% |  | 2009-03-06 | 2010-06-04 | 326d? |  | finish no earlier than 2010-06-04 | R5 | 2608h | 2608h | HNB-UEConTestFDD | Huawei | Rel-8 | Ingbert | HNB-UEConTestFDD | 43 | 22 | RP-100482 | HNB |
| 4304 | 1171 | Lawful Interception in the 3GPP Rel-8 | 524d? | 2007-03-12 A | 2009-03-12 A | 100% |  | 2007-03-12 | 2009-03-12 | 524d? |  | finish no earlier than 2009-03-12 | S3 | 4192h | 4192h | LI8 | BMWI, Verizon | Rel-8 | Mirko | LI8 |  |  |  |  |
| 4305 | 1172 | **Generic Bootstrapping Architecture Push Function** | 258d? | 2008-03-12 A | 2009-03-06 A | 100% |  | 2008-03-12 | 2009-03-06 | 258d? |  |  | S3; C1; C4 | 10596.8h | 10596.8h | GBAPush | Ericsson | Rel-8 | Mirko | GBAPush | 39 | 21 |  |  |
| 4306 | 1172.1 | SA3 part of GBAPush (33.223) | 193d? | 2008-03-12 A | 2008-12-05 A | 100% |  | 2008-03-12 | 2008-12-05 | 193d? |  | finish no earlier than 2008-12-05 | S3 | 1544h | 1544h | GBAPush | Ericsson | Rel-8 | Mirko |  | 39 | 21 |  |  |
| 4307 | 1172.2 | CT1 part of GBAPush | 178.8d? | 2008-03-12 A | 2009-03-06 A | 100% |  | 2008-03-12 | 2009-03-06 | 178.8d? |  | finish no earlier than 2009-03-06 | C1 | 1430.4h | 1430.4h | GBAPush | Ericsson | Rel-8 | Frederic |  | 39 | 21 |  |  |
| 4308 | 1172.3 | CT4 part of GBAPush | 178.8d? | 2008-03-12 A | 2009-03-06 A | 100% |  | 2008-03-12 | 2009-03-06 | 178.8d? |  | finish no earlier than 2009-03-06 | C4 | 1430.4h | 1430.4h | GBAPush | Ericsson | Rel-8 | Kimmo |  | 39 | 21 |  |  |
| 4309 | 1173 | Requirements and Test methods for Wideband Terminals | 197d? | 2008-03-12 A | 2008-12-11 A | 100% |  | 2008-03-12 | 2008-12-11 | 197d? |  | start no earlier than 2008-03-12 | S4 | 1576h | 1576h | RETEM_WB_T | FT, Ericsson | Rel-8 | Paolo | RETEM_WB_T |  |  |  |  |
| 4310 | 1174 | Extending PSS and MBMS User Services for optimized Mobile TV | 266d? | 2007-12-06 A | 2008-12-11 A | 100% |  | 2007-12-06 | 2008-12-11 | 266d? |  | finish no earlier than 2008-12-11 | S4 | 2128h | 2128h | PSS_MBMS_OMTV | Ericsson | Rel-8 | Paolo | PSS_MBMS_OMTV |  |  |  |  |

Notes:
- 4286: CP#42 completed. Triggered by Study UID_330016 (PPAC). / WI rapporteur e-mail: Morita Takashi
- 4287: SP#37 completed / Impacted TSs and TRs: 22.011 / WI rapporteur e-mail: Morita Takashi
- 4288: CP#42 completed / Impacted TSs and TRs: 24.008, 23.122, 24.301
- 4289: RP#50 completed / Impacted TSs and TRs: UTRA 34.108, 34.123-1, 34.123-2, 34.123-3 / WI rapporteur e-mail: Takao.Shimizu.rp@nttdocomo.com
- 4290: SP#39 Stage 1 completed / Impacted TSs and TRs: 22.115 / WI rapporteur e-mail: Marco.DeLuca1@telecomitalia.it
- 4291: SP#39 completed / Impacted TSs and TRs: 22.115 / WI rapporteur e-mail: Marco.DeLuca1@telecomitalia.it
- 4292: CP#43 completed / WI rapporteur e-mail: John Watson
- 4293: SP#39 completed / Impacted TSs and TRs: 22.011, 22.115 / WI rapporteur e-mail: John Watson
- 4294: CP#43 completed. SP#42 SP-080874 22.011CR0141 confirmed Requirement to support roaming subscribers with CSG home network subscription but did NOT confirmed requirement for home network independent support of roamers in CSG / Impacted TSs and TRs: 29.002, 29.272, 23.008, 23.003 / WI rapporteur e-mail: Hannu Hietalahti
- 4295: CP#43 completed / Impacted TSs and TRs: 23.122, new (24.285, 24.301, 24.801) / WI rapporteur e-mail: zhang.peng@huawei.com
- 4296: CP#43 completed / Impacted TSs and TRs: 23.122, 24.008, new 24.285 / WI rapporteur e-mail: Osok Song
- 4297: SP#44 completed
- 4298: RP#43 completed / Impacted TSs and TRs: 25.304, 25.306, 25.331, new 25.367 / WI rapporteur e-mail: Yang Xudong (yangxudong@huawei.com)
- 4299: RP#42 completed / Impacted TSs and TRs: 25.401, 25.410, 25.412, 25.413, 25.414, 25.415, new (25.467, 25.468, 25.469) / WI rapporteur e-mail: Martin Warner (mw15@alcatel-lucent.com)
- 4300: RP#43 completed / Impacted TSs and TRs: 25.104, 25.141, new 25.967 / WI rapporteur e-mail: Ying Cai (yingcai@motorola.com)
- 4301: SP#44 completed. Complements work in BroadBand Forum / Impacted TSs and TRs: new (32.581, 32.582, 32.583, 32.584) / WI rapporteur e-mail: Zou Lan (zlan@huawei.com)
- 4302: RP#48 FDD completed. Testing for Feature UID_390033 UTRA HNB
- 4303: RP#48 completed / Impacted TSs and TRs: 34.108, 34.123-1, 34.123-2, 34.123-3 / WI rapporteur e-mail: Trica Li (trica_li@huawei.com)
- 4304: SP#43 completed / Impacted TSs and TRs: 33.106, 33.107, 33.108 / WI rapporteur e-mail: berthold.wilhelm@bnetza.de, ron_ryan@verizon.net
- 4305: CP#43 completed / WI rapporteur e-mail: Rolf Blom
- 4306: SP#42 completed 33.223 as Rel-8. TS 33.224 moved to Rel-9 under new UID_420039 / Impacted TSs and TRs: 33.223 / WI rapporteur e-mail: Rolf Blom
- 4307: CP#43 completed / Impacted TSs and TRs: 24.109 / WI rapporteur e-mail: Rolf Blom
- 4308: CP#43 completed / Impacted TSs and TRs: 29.109 / WI rapporteur e-mail: Rolf Blom
- 4309: SP#42 completed. SP#39 WID approved. / Impacted TSs and TRs: 26.131, 26.132 / WI rapporteur e-mail: stephane.ragot@orange-ftgroup.com, wanqing.shi@sonyericsson.com
- 4310: SP#42 completed. SP#38 WID approved. / Impacted TSs and TRs: 26.234, 26.346, 26.946 / WI rapporteur e-mail: thorsten.lohmar@ericsson.com

| ID | WBS | Task | Duration | Start | Finish | Complete | Baseline start | Baseline finish | Baseline duration | Constraint | Resources | Work | Actual work | Acronym | PCG approved | WI rapporteur name | Release | TSG approved | MCC resp | Acronym_3GU_Export | TSG stopped | PCG stopped |
| --- | --- | --- | --- | --- | --- | --- | --- | --- | --- | --- | --- | --- | --- | --- | --- | --- | --- | --- | --- | --- | --- | --- |
| 4311 | 1175 | **Encoding formats, transport formats and media description signalling for interworking, QoE, and other enhancements to MTSI-MHI** | 331d? | 2007-12-06 A | 2009-03-12 A | 100% | 2007-12-06 | 2009-03-12 | 331d? |  | S4; C3; C4 | 14936h | 14936h | MTSI_eMHI | 21 | Ericsson, Qualcomm | Rel-8 | 40 | Paolo | MTSI_eMHI |  |  |
| 4312 | 1175.1 | MTSI Video - Dynamic Rate Adaptation/Signalling of Image Size | 331d? | 2007-12-06 A | 2009-03-12 A | 100% | 2007-12-06 | 2009-03-12 | 331d? | finish no earlier than 2009-03-12 | S4 | 2648h | 2648h | MTSI_eMHI-DRASIS |  | Qualcomm, Samsung | Rel-8 |  | Paolo | MTSI_eMHI-DRASIS |  |  |
| 4313 | 1175.2 | CT3 part of Enhancement of interworking between MTSI and CS networks | 201d? | 2008-05-30 A | 2009-03-06 A | 100% | 2008-05-30 | 2009-03-06 | 201d? | finish no earlier than 2009-03-06 | C3 | 1608h | 1608h | MTSI_eMHI | 21 | Huawei | Rel-8 | 40 | Adrian |  |  |  |
| 4314 | 1175.3 | CT4 part of Enhancement of interworking between MTSI and CS networks | 201d? | 2008-05-30 A | 2009-03-06 A | 100% | 2008-05-30 | 2009-03-06 | 201d? | finish no earlier than 2009-03-06 | C4 | 1608h | 1608h | MTSI_eMHI | 21 | Huawei | Rel-8 | 40 | Kimmo |  |  |  |
| 4315 | 1175.4 | Deleted - CT1 part of Enhancement of interworking between MTSI and CS networks | 141d? | 2008-05-30 A | 2008-12-12 A | 100% | 2008-05-30 | 2008-12-12 | 141d? | start no earlier than 2008-05-30 | C1 | 1128h | 1128h | MTSI_eMHI | 21 | Huawei | Rel-8 | 40 | Frederic |  | CP-42 |  |
| 4316 | 1176 | **Rel-8 Operations, Administration, Maintenance and Provisioning (OAM&P)** | 1445d? | 2007-06-07 A | 2012-12-07 A | 100% | 2007-06-07 | 2012-12-07 | 1445d? |  | S5; C1; C4; IETF | 120270h | 120270h | OAM8 |  |  | Rel-8 | 34 | Mirko | OAM8 |  |  |
| 4317 | 1176.1 | **Rel-8 Network Infrastructure Management** | 653d? | 2007-06-07 A | 2009-12-04 A | 100% | 2007-06-07 | 2009-12-04 | 653d? |  | S5 | 19464h | 19464h | OAM8-NIM |  |  | Rel-8 | 34 | Mirko | OAM8-NIM |  |  |
| 4318 | 1176.1.1 | Telecom Management Methodology | 461d? | 2007-06-07 A | 2009-03-12 A | 100% | 2007-06-07 | 2009-03-12 | 461d? | finish no earlier than 2009-03-12 | S5 | 3688h | 3688h | OAM8-NIM |  | Ericsson | Rel-8 |  | Mirko |  |  |  |
| 4319 | 1176.1.2 | Advanced Alarming on Itf-N | 266d? | 2007-06-07 A | 2008-06-12 A | 100% | 2007-06-07 | 2008-06-12 | 266d? | finish no earlier than 2008-12-11 | S5 | 2128h | 2128h | OAM8-NIM |  | Nokia Siemens Networks | Rel-8 |  | Mirko |  |  |  |
| 4320 | 1176.1.3 | CN CS Bearer Transport Network (BTN) relative NRM | 266d? | 2007-06-07 A | 2008-06-12 A | 100% | 2007-06-07 | 2008-06-12 | 266d? | finish no earlier than 2008-12-11 | S5 | 2128h | 2128h | OAM8-NIM |  | China Mobile | Rel-8 |  | Mirko |  |  |  |
| 4321 | 1176.1.4 | Alignment with eTOM and M.3060 architectural concepts | 210d? | 2008-02-22 A | 2008-12-11 A | 100% | 2008-02-22 | 2008-12-11 | 210d? | start no earlier than 2008-02-22 | S5 | 1680h | 1680h | OAM8-NIM | 21 | TeliaSonera | Rel-8 | 39 | Mirko |  |  |  |
| 4322 | 1176.1.5 | IRP SOAP Solution Sets | 201d? | 2008-06-05 A | 2009-03-12 A | 100% | 2008-06-05 | 2009-03-12 | 201d? | finish no earlier than 2009-03-12 | S5 | 1608h | 1608h | OAM8-NIM | 21 | Ericsson | Rel-8 | 40 | Mirko |  |  |  |
| 4323 | 1176.1.6 | Create missing specifications for IRP XML definitions | 52d? | 2009-09-24 A | 2009-12-04 A | 100% | 2009-09-24 | 2009-12-04 | 52d? | finish no earlier than 2010-03-12 | S5 | 416h | 416h | OAM8-NIM | 23 | ZTE | Rel-8 | 45 | Mirko |  |  |  |
| 4324 | 1176.1.7 | Deleted - End point modelling for reference point | 324d? | 2007-09-17 A | 2008-12-11 A | 100% | 2007-09-17 | 2008-12-11 | 324d? | finish no earlier than 2008-12-11 | S5 | 2592h | 2592h | OAM8-NIM |  | Motorola | Rel-8 | 37 | Mirko |  | SP-41 | PCG-21 |
| 4325 | 1176.2 | **Rel-8 Performance Management** | 461d? | 2007-06-07 A | 2009-03-12 A | 100% | 2007-06-07 | 2009-03-12 | 461d? |  | S5 | 13712h | 13712h | OAM8-PM |  |  | Rel-8 | 34 | Mirko | OAM8-PM |  |  |
| 4326 | 1176.2.1 | IP bearer network Performance measurement definitions | 396d? | 2007-06-07 A | 2008-12-11 A | 100% | 2007-06-07 | 2008-12-11 | 396d? | finish no earlier than 2008-12-11 | S5 | 3168h | 3168h | OAM8-PM |  | China Mobile | Rel-8 |  | Mirko |  |  |  |
| 4327 | 1176.2.2 | HSUPA performance measurements | 396d? | 2007-06-07 A | 2008-12-11 A | 100% | 2007-06-07 | 2008-12-11 | 396d? | finish no earlier than 2008-12-11 | S5 | 3168h | 3168h | OAM8-PM |  | China Mobile | Rel-8 |  | Mirko |  |  |  |
| 4328 | 1176.2.3 | Key Performance Indicators (KPIs) for UMTS and GSM | 461d? | 2007-06-07 A | 2009-03-12 A | 100% | 2007-06-07 | 2009-03-12 | 461d? | finish no earlier than 2009-03-12 | S5 | 3688h | 3688h | OAM8-PM |  | China Mobile | Rel-8 |  | Mirko |  |  |  |
| 4329 | 1176.3 | **Rel-8 Trace Management** | 1249d? | 2008-03-07 A | 2012-12-07 A | 100% | 2008-03-07 | 2012-12-07 | 1249d? |  | C1; C4; IETF | 40854.4h | 40854.4h | OAM8-Trace |  |  | Rel-8 | 34 | Mirko | OAM8-Trace |  |  |
| 4330 | 1176.3.1 | CT1 part of Service Level Tracing in IMS | 196d? | 2008-03-07 A | 2008-12-05 A | 100% | 2008-03-07 | 2008-12-05 | 196d? | finish no earlier than 2008-12-05 | C1 | 1568h | 1568h | OAM8-Trace |  | Vodafone | Rel-8 |  | Frederic |  |  |  |
| 4331 | 1176.3.2 | (IETF) Service Level Tracing in IMS (draft-ietf-insipid-logme-marking) | 717d? | 2008-03-07 A | 2012-12-07 A | 100% | 2008-03-07 | 2012-12-07 | 717d? | finish no earlier than 2012-12-07 | C1-IETF | 5736h | 5736h | OAM8-Trace | 27 | Peter Dawes | Rel-8 | 52 | Frederic |  |  |  |
| 4332 | 1176.3.3 | (IETF) Service Level Tracing in IMS (draft-dawes-sipping-debug-event) | 98d? | 2008-03-07 A | 2011-12-09 A | 100% | 2008-03-07 | 2011-12-09 | 98d? | finish no earlier than 2011-12-09 | C1-IETF | 768.04h | 768.04h | OAM8-Trace | 27 | Peter Dawes | Rel-8 | 53 | Frederic |  |  |  |
| 4333 | 1176.3.4 | CT4 part of Service Level Tracing in IMS | 175.4d? | 2008-03-07 A | 2008-12-05 A | 100% | 2008-03-07 | 2008-12-05 | 175.4d? | finish no earlier than 2008-12-05 | C4 | 1403.2h | 1403.2h | OAM8-Trace | 21 | Vodafone | Rel-8 | 40 | Frederic |  |  |  |
| 4334 | 1176.3.5 | Deleted - CT3 part of Service Level Tracing in IMS | 175.4d? | 2008-03-07 A | 2008-12-05 A | 100% | 2008-03-07 | 2008-12-05 | 175.4d? | finish no earlier than 2008-12-05 | C3 | 1403.2h | 1403.2h | OAM8-Trace | 21 | Vodafone | Rel-8 | 40 | Adrian |  | CP-42 | PCG-22 |

Notes:
- 4311: TSG#43 completed / WI rapporteur e-mail: olle.franceschi@ericsson.com, nleung@qualcomm.com
- 4312: SP#43 completed / Impacted TSs and TRs: 26.114 / WI rapporteur e-mail: nleung@qualcomm.com & kyunghun.jung@samsung.com
- 4313: CP#43 completed / Impacted TSs and TRs: 29.163 / WI rapporteur e-mail: Tingfang Tang (tagna_online@huawei.com)
- 4314: CP#43 completed / Impacted TSs and TRs: 29.332 / WI rapporteur e-mail: Tingfang Tang (tagna_online@huawei.com)
- 4315: CP#42 stopped (No CT1-impact). WID updated CP-080422=>CP-080774 / WI rapporteur e-mail: Tingfang Tang (tagna_online@huawei.com)
- 4316: OAM8 is an umbrella Feature also for OAM&P related TEI8 type of changes that are not part of any other dedicated feature/WI / Impacted TSs and TRs: TR 30.818
- 4317: -
- 4318: SP#43 completed / Impacted TSs and TRs: 32.155, 32.153 / WI rapporteur e-mail: thomas.tovinger@ericsson.com
- 4319: SP#40 completed / Impacted TSs and TRs: 32.121, 32.122, 32.123 / WI rapporteur e-mail: SUERBAUM, Clemens
- 4320: SP#40 completed / Impacted TSs and TRs: 32.632, 32.633, 32.635 / WI rapporteur e-mail: Li Jian (lijian@chinamobile.com)
- 4321: SP#42 completed / Impacted TSs and TRs: 32.101/2, 32-series / WI rapporteur e-mail: tommy.berggren@teliasonera.com
- 4322: SP#43 completed / Impacted TSs and TRs: 32.111-7, 32.617, 32.417, 32.367, 32.347, 32.111-1, 32.111-2, 32.111-3, 32.111-5, 32.307, 32.317, 32.341, 32.342, 32.343, 32.345, 32.361, 32.362, 32.363, 32.365, 32.411, 32.412, 32.413, 32.415, 32.611, 32.612, 32.613, 32.615, 32.625 / WI rapporteur e-mail: edwin.tse@ericsson.com
- 4323: SP#46 completed. Create missing XML definitions specs for IRPs (Advanced Alarm Management, Communication Surveillance, Self-Configuration of Network Elements, Software Management) needed for implementation of Rel-8 Notification Log IRP (TS 32.33x) / Impacted TSs and TRs: new (32.125, 32.355, 32.505, 32.535), 32.150, 32.153, 32.335 / WI rapporteur e-mail: Shuqiang Huang (huangsq@zte.com.cn)
- 4324: SP#41 Work stopped. Contributions related to E-UTRAN/EPC to be submitted to UID_380036 E-UTRAN NRM IRP/ UID_380037 EPC NRM IRP / Impacted TSs and TRs: 32.152, 32.62/3/4x, 32.73x / WI rapporteur e-mail: Yizhi Yao (yzyao@motorola.com)
- 4325: - / WI rapporteur e-mail: Li Jian (lijian@chinamobile.com)
- 4326: SP#42 completed / Impacted TSs and TRs: 32.321, 32.322, 32.323, 32.325 / WI rapporteur e-mail: lilianyuan@chinamobile.com
- 4327: SP#42 completed / Impacted TSs and TRs: 32.405 / WI rapporteur e-mail: Li Jian (lijian@chinamobile.com)
- 4328: SP#43 completed / Impacted TSs and TRs: 32.410 / WI rapporteur e-mail: Li Jian (lijian@chinamobile.com), Liang Shuangchun (liangshuangchun@cmdi.chinamobile.com)
- 4329: -
- 4330: CP#42 completed / Impacted TSs and TRs: 24.323, 24.229 / WI rapporteur e-mail: peter.dawes@vodafone.com
- 4331: CP#58 Removed from Rel-8, Rel-9 and Rel-10 (Not completed internet-draft) / Impacted TSs and TRs: Rel-11 remains draft-dawes-dispatch-debug / WI rapporteur e-mail: peter.dawes@vodafone.com
- 4332: CP#54 Draft removed from 3GPP documentation, covered by draft-dawes-sipping-debug / Impacted TSs and TRs: draft-dawes-sipping-debug-event / WI rapporteur e-mail: peter.dawes@vodafone.com
- 4333: CP#42 completed / Impacted TSs and TRs: 29.228, 29.229 / WI rapporteur e-mail: peter.dawes@vodafone.com
- 4334: CP#42 stopped (No CT3-impact) / WI rapporteur e-mail: peter.dawes@vodafone.com

| ID | WBS | Task | Type | Duration | Start | Finish | Complete | Baseline start | Baseline finish | Baseline duration | Constraint | Resources | Work | Actual work | Acronym | Release | MCC resp | Acronym_3GU_Export | WI rapporteur name | WI rapporteur e-mail | PCG approved | TSG approved | PCG stopped | TSG stopped | Status Report |
| --- | --- | --- | --- | --- | --- | --- | --- | --- | --- | --- | --- | --- | --- | --- | --- | --- | --- | --- | --- | --- | --- | --- | --- | --- | --- |
| 4335 | 1177 | **Rel-8 Charging Management small Enhancements** |  | 716d? | 2006-03-16 A | 2008-12-11 A | 100% | 2006-03-16 | 2008-12-11 | 716d? |  | S5 | 12544h | 12544h | CH8 | Rel-8 | Mirko | CH8 |  |  |  |  |  |  |  |
| 4336 | 1177.1 | Online charging correlation |  | 457d? | 2006-03-16 A | 2007-12-14 A | 100% | 2006-03-16 | 2007-12-14 | 457d? | start no earlier than 2006-03-16 | S5 | 3656h | 3656h | CH8 | Rel-8 | Mirko |  | Orange | Chahine, Rony |  |  |  |  |  |
| 4337 | 1177.2 | SMS online charging |  | 137d? | 2007-06-07 A | 2007-12-14 A | 100% | 2007-06-07 | 2007-12-14 | 137d? | finish no earlier than 2007-12-14 | S5 | 1096h | 1096h | CH8 | Rel-8 | Mirko |  | Vodafone | Gavin.Wong@vodafone.com |  |  |  |  |  |
| 4338 | 1177.3 | Introduce Online Charging from SMS-SC into the SMS Charging Specifications |  | 61d? | 2008-09-18 A | 2008-12-11 A | 100% | 2008-09-18 | 2008-12-11 | 61d? | finish no earlier than 2008-12-11 | S5 | 488h | 488h | CH8 | Rel-8 | Mirko |  | Acision | erik.gebler@acision.com | 21 | 41 |  |  |  |
| 4339 | 1177.4 | Deleted - WLAN Offline Charging |  | 244d? | 2008-01-07 A | 2008-12-11 A | 100% | 2008-01-07 | 2008-12-11 | 244d? | finish no earlier than 2008-12-11 | S5 | 1952h | 1952h | CH8 | Rel-8 | Mirko |  | Alcatel-Lucent | maryse.gardella@alcatel-lucent.com | 21 | 38 | PCG-22 | SP-42 |  |
| 4340 | 1178 | **Conferencing enhancements for Mp interface** |  | 266d? | 2007-11-30 A | 2008-12-05 A | 100% | 2007-11-30 | 2008-12-05 | 266d? |  | C4 | 6384h | 6384h | eMp | Rel-8 | Kimmo | eMp | Huawei | Chencheng@huawei.com | 21 |  |  |  |  |
| 4341 | 1178.1 | Stage 2 for eMp |  | 266d? | 2007-11-30 A | 2008-12-05 A | 100% | 2007-11-30 | 2008-12-05 | 266d? | finish no earlier than 2008-12-11 | C4 | 2128h | 2128h | eMp | Rel-8 | Kimmo |  | Huawei | Chencheng@huawei.com | 21 | 38 |  |  |  |
| 4342 | 1178.2 | Stage 3 for eMp |  | 266d? | 2007-11-30 A | 2008-12-05 A | 100% | 2007-11-30 | 2008-12-05 | 266d? | finish no earlier than 2008-12-05 | C4 | 2128h | 2128h | eMp | Rel-8 | Kimmo |  | Huawei | Chencheng@huawei.com | 21 | 38 |  |  |  |
| 4343 | 1179 | **Contact Manager for 3GPP UICC applications** |  | 642d? | 2006-06-22 A | 2008-12-05 A | 100% | 2006-06-22 | 2008-12-05 | 642d? |  | C6 | 13352h | 13352h | eUPHBOOK | Rel-8 | Xavier | eUPHBOOK | Gemalto | Jacques.seif@gemalto.com |  |  |  |  |  |
| 4344 | 1179.1 | Requirements for Contact Manager |  | 392d? | 2006-06-22 A | 2007-12-21 A | 100% | 2006-06-22 | 2007-12-21 | 392d? | finish no earlier than 2007-12-21 | C6 | 3136h | 3136h | eUPHBOOK-St1 | Rel-8 | Xavier | eUPHBOOK-St1 | Gemalto | Jacques.seif@gemalto.com |  |  |  |  |  |
| 4345 | 1179.2 | External interface for eUPHBOOK |  | 220d? | 2007-05-07 A | 2008-03-07 A | 100% | 2007-05-07 | 2008-03-07 | 220d? | finish no earlier than 2008-03-07 | C6 | 1760h | 1760h | eUPHBOOK-Ext_Spec | Rel-8 | Xavier | eUPHBOOK-Ext_Spec | Gemalto | Jacques.seif@gemalto.com |  |  |  |  |  |
| 4346 | 1179.3 | Internal interface for eUPHBOOK |  | 415d? | 2007-05-07 A | 2008-12-05 A | 100% | 2007-05-07 | 2008-12-05 | 415d? | finish no earlier than 2008-12-05 | C6 | 3320h | 3320h | eUPHBOOK-Int_Spec | Rel-8 | Xavier | eUPHBOOK-Int_Spec | Gemalto | Jacques.seif@gemalto.com |  | 37 |  |  |  |
| 4347 | 1179.4 | Deleted - Implementation of eUPHBOOK | milestone | 0d? | 2007-06-21 A | 2007-06-21 A | 100% | 2007-06-21 | 2007-06-21 | 0d? | start no earlier than 2007-06-21 | C6 |  |  | eUPHBOOK-St23 | Rel-8 | Xavier | eUPHBOOK-St23 | Giesecke & Devrient | Claus Dietze |  |  |  | SP-33 |  |
| 4348 | 1180 | **Rel-8 LTE – 3G Long Term Evolution - Evolved Packet System RAN part** |  | 644d? | 2006-09-25 A | 2009-03-12 A | 100% | 2006-09-25 | 2009-03-12 | 644d? |  | RP; S5 | 50048h | 50048h | LTE | Rel-8 |  | LTE | NTT DoCoMo | Takehiro Nakamura (nakamurata@nttdocomo.co.jp) |  |  |  |  | RP-080741 |
| 4349 | 1180.1 | LTE – Physical Layer |  | 380d? | 2006-09-25 A | 2008-03-07 A | 100% | 2006-09-25 | 2008-03-07 | 380d? | finish no earlier than 2007-09-14 | R1 | 3040h | 3040h | LTE-Phys | Rel-8 | Patrick | LTE-Phys | NTT DoCoMo | Sadayuki Abeta |  |  |  |  | RP-080741 |
| 4350 | 1180.2 | LTE – Radio Interface Layer 2 and 3 Protocol Aspect |  | 575d? | 2006-09-25 A | 2008-12-05 A | 100% | 2006-09-25 | 2008-12-05 | 575d? | finish no earlier than 2008-12-11 | R2 | 4600h | 4600h | LTE-L23 | Rel-8 | Yong-Jun | LTE-L23 | Nokia Siemens Networks | benoist.sebire@nokia.com |  |  |  |  | RP-080741 |
| 4351 | 1180.3 | LTE – eUTRAN Interfaces |  | 575d? | 2006-09-25 A | 2008-12-05 A | 100% | 2006-09-25 | 2008-12-05 | 575d? | finish no earlier than 2008-12-11 | R3 | 4600h | 4600h | LTE-interfaces | Rel-8 | Juha | LTE-interfaces | Ericsson | Martin Israelsson |  |  |  |  | RP-080741 |
| 4352 | 1180.4 | LTE – Evolved UTRA and UTRAN RF Radio Transmission/Reception, System Performance Requirements and Conformance Testing |  | 575d? | 2006-09-25 A | 2008-12-05 A | 100% | 2006-09-25 | 2008-12-05 | 575d? | finish no earlier than 2008-12-11 | R4 | 4600h | 4600h | LTE-RF | Rel-8 | Issam | LTE-RF | Nokia Siemens Networks | Tuomo Saynajakangas |  |  |  |  | RP-080741 |
| 4353 | 1180.5 | LTE – FDD repeaters |  | 386d? | 2007-09-14 A | 2009-03-06 A | 100% | 2007-09-14 | 2009-03-06 | 386d? | finish no earlier than 2009-03-06 | R4 | 3088h | 3088h | LTE-Repeaters | Rel-8 | Issam | LTE-Repeaters | Powerwave Technologies, Andrew Wireless | ralf.michanikl@andrew.com, Alf.Ahlstrom@pwav.com |  | 37 |  |  | RP-090037 |
| 4354 | 1180.6 | **E-UTRAN Data Definitions** |  | 389d? | 2007-09-17 A | 2009-03-12 A | 100% | 2007-09-17 | 2009-03-12 | 389d? |  | S5 | 13096h | 13096h | E-UTRAN-OAM | Rel-8 | Mirko | E-UTRAN-OAM |  |  | 21 | 39 |  |  |  |
| 4355 | 1180.6.1 | Subscriber and Equipment Trace for E-UTRAN and EPC |  | 389d? | 2007-09-17 A | 2009-03-12 A | 100% | 2007-09-17 | 2009-03-12 | 389d? | finish no earlier than 2009-03-12 | S5 | 3112h | 3112h | E-UTRAN-OAM | Rel-8 | Mirko |  | Ericsson | robert.petersen@ericsson.com |  | 37 |  |  |  |
| 4356 | 1180.6.2 | E-UTRAN Network Resource Model (NRM) Integration Reference Point (IRP) |  | 309d? | 2008-01-07 A | 2009-03-12 A | 100% | 2008-01-07 | 2009-03-12 | 309d? | finish no earlier than 2009-03-12 | S5 | 2472h | 2472h | E-UTRAN-OAM | Rel-8 | Mirko |  | Ericsson | ELMDAHL, Per | 21 | 38 |  |  |  |
| 4357 | 1180.6.3 | Performance measurements for E-UTRAN |  | 275d? | 2008-02-22 A | 2009-03-12 A | 100% | 2008-02-22 | 2009-03-12 | 275d? | finish no earlier than 2009-03-12 | S5 | 2200h | 2200h | E-UTRAN-OAM | Rel-8 | Mirko |  | Motorola, Huawei | Yizhi Yao (yzyao@motorola.com) | 21 | 39 |  |  |  |
| 4358 | 1180.6.4 | Key Performance Indicators (KPIs) for E-UTRAN |  | 275d? | 2008-02-22 A | 2009-03-12 A | 100% | 2008-02-22 | 2009-03-12 | 275d? | finish no earlier than 2009-03-12 | S5 | 2200h | 2200h | E-UTRAN-OAM | Rel-8 | Mirko |  | Ericsson | ulf.hubinette@ericsson.com | 21 | 39 |  |  |  |

Notes:
- 4335: CH8 is an umbrella Feature also for OAM&P related TEI8 type of changes that are not part of any other dedicated feature/WI / Impacted TSs and TRs: TR 30.818
- 4336: SP#38 completed / Impacted TSs and TRs: 32.296
- 4337: SP#38 completed / Impacted TSs and TRs: 32.240, 32.299, new 32.274
- 4338: SP#42 completed. Linked to SA2 UID 32081 (Support of SMS over IP networks) and CT4 UID 340016 (Routeing of MT-SMS via the HPLMN). / Impacted TSs and TRs: 32.274, 32.299
- 4339: SP#42 stopped / Impacted TSs and TRs: 32.252, 32.298, 32.299
- 4340: CP#42 completed
- 4341: CP#42 completed / Impacted TSs and TRs: 23.333
- 4342: CP#42 completed / Impacted TSs and TRs: 29.333
- 4343: CP#42 completed. CP#40: WID updated CP-070622=>CP-080382. aka Enhanced USIM phonebook
- 4344: CP#38 completed / Impacted TSs and TRs: 21.111
- 4345: CP#39 completed / Impacted TSs and TRs: new 31.220
- 4346: CP#42 completed / Impacted TSs and TRs: new 31.221
- 4347: SP#33 stopped / Impacted TSs and TRs: 31.102
- 4348: RP#43 completed. Role model for SAE/LTE system wide project management by SA2 in SP-060166 / Impacted TSs and TRs: LTE 36.300, 36.938
- 4349: RP#39 completed / Impacted TSs and TRs: 36.201, 36.211, 36.212, 36.213, 36.214, 25.215, 25.225
- 4350: RP#42 completed / Impacted TSs and TRs: 36.302, 36.304, 36.306, 36.314, 36.321, 36.322, 36.323, 36.331, 25.302, 25.304, 25.331
- 4351: RP#42 completed / Impacted TSs and TRs: 36.401, 36.410, 36.411, 36.412, 36.413, 36.414, 36.420, 36.421, 36.422, 36.423, 36.424, 25.413
- 4352: RP#42 completed. RP#47 abandoned draft 36.801, 36.803, 36.804 / Impacted TSs and TRs: 36.101, 36.104, 36.113, 36.124, 36.133, 36.141, 36.942, 25.123, 25.133
- 4353: RP#43 completed. RP#47 create Rel-9 TR 36.956 (see R4-100386, RP-100320_RAN4 Report) / Impacted TSs and TRs: 36.106, 36.143, 25.113
- 4354: SP#43 completed
- 4355: SP#43 completed / Impacted TSs and TRs: 32.421, 2.422, 32.423, 2.441, 32.442, 32.443, 32.445
- 4356: SP#43 completed / Impacted TSs and TRs: new (32.761, 32.762, 32.763, 32.765)
- 4357: SP#43 completed / Impacted TSs and TRs: new 32.425
- 4358: SP#43 completed / Impacted TSs and TRs: new (32.450, 32.451)

| ID | WBS | Task | Duration | Start | Finish | Complete | Baseline start | Baseline finish | Baseline duration | Constraint | Resources | Work | Actual work | Acronym | PCG approved | WI rapporteur name | WI rapporteur e-mail | Release | TSG approved | MCC resp | Special Focus Doc | Acronym_3GU_Export | Status Report | PCG stopped | TSG stopped |
| --- | --- | --- | --- | --- | --- | --- | --- | --- | --- | --- | --- | --- | --- | --- | --- | --- | --- | --- | --- | --- | --- | --- | --- | --- | --- |
| 4359 | 1180.7 | **Self-Organizing Networks (SON)** | 210d? | 2008-02-22 A | 2008-12-11 A | 100% | 2008-02-22 | 2008-12-11 | 210d? |  | S5 | 6720h | 6720h | LTE_SON-OAM | 21 | Vodafone | GOMPAKIS, Panagiotis | Rel-8 | 39 | Mirko | SON | LTE_SON-OAM |  |  |  |
| 4360 | 1180.7.1 | SON Concepts and requirements | 210d? | 2008-02-22 A | 2008-12-11 A | 100% | 2008-02-22 | 2008-12-11 | 210d? |  | S5 | 1680h | 1680h | LTE_SON-OAM | 21 | Vodafone | GOMPAKIS, Panagiotis | Rel-8 | 39 | Mirko |  |  |  |  |  |
| 4361 | 1180.7.2 | Self-Establishment of eNBs, including automated Software Management | 210d? | 2008-02-22 A | 2008-12-11 A | 100% | 2008-02-22 | 2008-12-11 | 210d? | start no earlier than 2008-02-22 | S5 | 1680h | 1680h | LTE_SON-OAM | 21 | Nokia Siemens Networks | SUERBAUM, Clemens | Rel-8 | 39 | Mirko |  |  |  |  |  |
| 4362 | 1180.7.3 | SON Automatic Neighbour Relations (ANR) List Management | 210d? | 2008-02-22 A | 2008-12-11 A | 100% | 2008-02-22 | 2008-12-11 | 210d? | finish no earlier than 2008-12-11 | S5 | 1680h | 1680h | LTE_SON-OAM | 21 | Ericsson | edwin.tse@ericsson.com | Rel-8 | 39 | Mirko |  |  |  |  |  |
| 4363 | 1181 | **Rel-8 LTE – Terminal Conformance Test Specification** | 657d? | 2007-06-01 A | 2009-12-04 A | 100% | 2007-06-01 | 2009-12-04 | 657d? |  | R5 | 14336h | 14336h | LTE-UEConTest |  |  |  | Rel-8 |  | Ingbert |  | LTE-UEConTest |  |  |  |
| 4364 | 1181.1 | 3G LTE – Terminal Protocol Conformance Test Specifications | 657d? | 2007-06-01 A | 2009-12-04 A | 100% | 2007-06-01 | 2009-12-04 | 657d? | finish no earlier than 2009-12-04 | R5 | 5256h | 5256h | LTE-UEConTest_SIG |  | NEC, Motorola | david.lecompte@nectech.fr, Jacob.John@motorola.com | Rel-8 |  | Ingbert |  | LTE-UEConTest_SIG | RP-091060 |  |  |
| 4365 | 1181.2 | LTE – Terminal Radio Transmission and Reception Conformance Test Specifications | 657d? | 2007-06-01 A | 2009-12-04 A | 100% | 2007-06-01 | 2009-12-04 | 657d? |  | R5 | 5256h | 5256h | LTE-UEConTest_RF |  | Agilent | andrea_leonardi@agilent.com | Rel-8 |  | Ingbert |  | LTE-UEConTest_RF | RP-091059 |  |  |
| 4366 | 1182 | **Rel-8 Improvements of the Radio Interface** | 525d? | 2007-03-05 A | 2009-03-06 A | 100% | 2007-03-05 | 2009-03-06 | 525d? |  | RP | 18152h | 18152h | RInImp8 |  |  |  | Rel-8 |  | Issam |  | RInImp8 |  |  |  |
| 4367 | 1182.1 | UMTS 1500 MHz | 140d? | 2007-03-05 A | 2007-09-14 A | 100% | 2007-03-05 | 2007-09-14 | 140d? | finish no earlier than 2007-09-14 | R4 | 1120h | 1120h | RInImp8-UMTS1500 |  | NTT DoCoMo | Takehiro Nakamura (nakamurata@nttdocomo.co.jp) | Rel-8 |  | Issam |  | RInImp8-UMTS1500 | RP-070526 |  |  |
| 4368 | 1182.2 | UMTS 700 MHz FDD | 325d? | 2007-03-05 A | 2008-05-30 A | 100% | 2007-03-05 | 2008-05-30 | 325d? | finish no earlier than 2008-06-12 | R4 | 2600h | 2600h | RInImp8-UMTS700 |  | Nokia | Tuomo Saynajakangas | Rel-8 |  | Issam |  | RInImp8-UMTS700 | RP-080260 |  |  |
| 4369 | 1182.3 | UMTS 1880 MHz TDD | 126d? | 2008-09-12 A | 2009-03-06 A | 100% | 2008-09-12 | 2009-03-06 | 126d? | finish no earlier than 2009-03-09 | R4 | 1008h | 1008h | RInImp9-UMTS1880TDD | 21 | CATT | Yuexia Song (songyuexia@catt.cn) | Rel-8 | 41 | Issam |  | RInImp9-UMTS1880TDD | RP-090044 |  |  |
| 4370 | 1182.4 | UMTS 2300 MHz TDD LCR | 195d? | 2007-12-17 A | 2008-09-12 A | 100% | 2007-12-17 | 2008-09-12 | 195d? | finish no earlier than 2008-09-12 | R4 | 1560h | 1560h | RInImp8-UMTS2300TDD | 21 | CATT | Yuexia Song (songyuexia@catt.cn) | Rel-8 | 38 | Issam |  | RInImp8-UMTS2300TDD | RP-080517 |  |  |
| 4371 | 1182.5 | Further Improved Minimum Performance Requirements for HSDPA UE (FDD) - Two-Branch Interference Cancellation | 265d? | 2007-03-05 A | 2008-03-07 A | 100% | 2007-03-05 | 2008-03-07 | 265d? | finish no earlier than 2008-03-12 | R4 | 2120h | 2120h | RInImp8-2BIC |  | AT&T | Marc Grant | Rel-8 |  | Issam |  | RInImp8-2BIC | RP-080041 |  |  |
| 4372 | 1182.6 | CS Voice Service over HSPA | 167d? | 2007-07-19 A | 2008-03-07 A | 100% | 2007-07-19 | 2008-03-07 | 167d? |  | R2 | 1336h | 1336h | RInImp8-CsHspa |  | Nokia Siemens Networks | woonhee.hwang@nsn.com | Rel-8 | 37 | Yong-Jun |  | RInImp8-CsHspa | RP-080042 |  |  |
| 4373 | 1182.7 | Performance requirements for 15 code reception with 16QAM/QPSK (FDD) | 126d? | 2007-06-11 A | 2008-03-07 A | 100% | 2007-06-11 | 2008-03-07 | 126d? | finish no earlier than 2008-06-12 | R4 | 1008h | 1008h | RInImp8-Hsdpa15codes |  | Vodafone | tim.frost@vodafone.com | Rel-8 | 37 | Issam |  | RInImp8-Hsdpa15codes | RP-080043 |  |  |
| 4374 | 1182.8 | Deleted - UMTS 2300 MHz FDD/TDD | 400d? | 2007-03-05 A | 2008-09-12 A | 100% | 2007-03-05 | 2008-09-12 | 400d? | finish no earlier than 2008-12-11 | R4 | 3200h | 3200h | RInImp8-UMTS2300 |  | AT&T | Marc Grant | Rel-8 |  | Issam |  | RInImp8-UMTS2300 | RP-080515 | PCG-21 | RP-41 |
| 4375 | 1183 | **Rel-8 Improvements of the Radio Interface - UE Conformance Testing** | 396d? | 2007-06-01 A | 2008-12-05 A | 100% | 2007-06-01 | 2008-12-05 | 396d? |  | R5 | 6256h | 6256h |  |  |  |  | Rel-8 |  | Ingbert |  |  |  |  |  |
| 4376 | 1183.1 | Conformance Test Aspects – CS Voice Service over HSPA | 336d? | 2007-06-01 A | 2008-09-12 A | 100% | 2007-06-01 | 2008-09-12 | 336d? | finish no earlier than 2008-09-12 | R5 | 2688h | 2688h | RInImp8-CsHspa_UEConTest |  | Huawei | baoyi@huawei.com | Rel-8 |  | Ingbert |  | RInImp8-CsHspa_UEConTest | RP-080542 |  |  |
| 4377 | 1183.2 | Conformance Test Aspects – Performance requirements for 15 code reception with 16QAM/QPSK (FDD) | 195d? | 2008-03-07 A | 2008-12-05 A | 100% | 2008-03-07 | 2008-12-05 | 195d? | finish no earlier than 2008-12-05 | R5 | 1560h | 1560h | RInImp8-UEConTest_Hsdpa15codes | 21 | Ericsson | Mikael.Ziren@Ericsson.com | Rel-8 | 40 | Ingbert |  | RInImp8-UEConTest_ Hsdpa15codes | RP-080818 |  |  |
| 4378 | 1184 | **Rel-8 RAN improvements** | 520d? | 2007-06-04 A | 2009-05-29 A | 100% | 2007-06-04 | 2009-05-29 | 520d? |  | RP | 37481.6h | 37481.6h |  |  |  |  | Rel-8 |  |  |  |  |  |  |  |
| 4379 | 1184.1 | Combination of 64QAM and MIMO for HSDPA (FDD) | 205d? | 2007-06-04 A | 2008-09-12 A | 100% | 2007-06-04 | 2008-09-12 | 205d? | finish no earlier than 2008-09-12 | R1 | 1640h | 1640h | RANimp-64QamMimoHsdpa |  | Ericsson | Johan.Bergman@ericsson.com | Rel-8 |  | Patrick |  | RANimp-64QamMimoHsdpa | RP-080518 |  |  |
| 4380 | 1184.2 | Improved L2 for uplink | 186d? | 2007-09-14 A | 2008-05-30 A | 100% | 2007-09-14 | 2008-05-30 | 186d? | finish no earlier than 2008-05-30 | R2 | 1488h | 1488h | RANimp-UplinkL2dataRates |  | Ericsson | Janne.Peisa@ericsson.com | Rel-8 | 37 | Yong-Jun |  | RANimp-UplinkL2dataRates | RP-080265 |  |  |
| 4381 | 1184.3 | Enhanced Uplink for CELL_FACH State in FDD | 321d? | 2007-09-14 A | 2008-12-05 A | 100% | 2007-09-14 | 2008-12-05 | 321d? | finish no earlier than 2008-12-12 | R2 | 2568h | 2568h | RANimp-UplinkEnhState |  | Nokia Siemens Networks | markus.wimmer@nsn.com | Rel-8 | 37 | Yong-Jun |  | RANimp-UplinkEnhState | RP-080804 |  |  |
| 4382 | 1184.4 | Enhanced UE Discontinuous Reception (DRX) for FDD | 261d? | 2007-09-14 A | 2008-09-12 A | 100% | 2007-09-14 | 2008-09-12 | 261d? | finish no earlier than 2008-09-12 | R2 | 2088h | 2088h | RANimp-DRX |  | Nokia | luis.barreto@nokia.com | Rel-8 | 37 | Yong-Jun |  | RANimp-DRX | RP-080520 |  |  |
| 4383 | 1184.5 | Enhancements for Serving Radio Network Subsystem (SRNS) Relocation Procedure | 261d? | 2007-09-14 A | 2008-09-12 A | 100% | 2007-09-14 | 2008-09-12 | 261d? | finish no earlier than 2008-09-12 | R3 | 2088h | 2088h | RANimp-SrnsReloc |  | Nokia Siemens Networks | masatoshi.nakamata@nsn.com | Rel-8 | 37 | Juha |  | RANimp-SrnsReloc | RP-080521 |  |  |
| 4384 | 1184.6 | Enhancements for FDD HSPA Evolution | 321d? | 2007-09-14 A | 2008-12-05 A | 100% | 2007-09-14 | 2008-12-05 | 321d? | finish no earlier than 2008-12-05 | R3; R2 | 5136h | 5136h | RANimp-HSPAEvo |  | Nokia Siemens Networks | masatoshi.nakamata@nsn.com | Rel-8 | 37 | Juha |  | RANimp-HSPAEvo | RP-080805 |  |  |
| 4385 | 1184.7 | 64QAM for 1.28 Mcps TDD HSDPA | 264d? | 2007-12-04 A | 2008-12-05 A | 100% | 2007-12-04 | 2008-12-05 | 264d? | finish no earlier than 2008-12-05 | R1 | 2112h | 2112h | RANimp-64Qam1.28TDD | 21 | ZTE | zfmail@zte.com.cn | Rel-8 | 38 | Patrick |  | RANimp-64Qam1.28TDD | RP-080806 |  |  |
| 4386 | 1184.8 | Enhanced CELL_FACH state in 1.28 Mcps TDD | 264d? | 2007-12-04 A | 2008-12-05 A | 100% | 2007-12-04 | 2008-12-05 | 264d? | finish no earlier than 2008-12-12 | R2 | 2112h | 2112h | RANimp-EnhState1.28TDD | 21 | ZTE | zhang.yincheng@zte.com.cn | Rel-8 | 38 | Yong-Jun |  | RANimp-EnhState1.28TDD | RP-080807 |  |  |
| 4387 | 1184.9 | Continuous Connectivity for packet data users for 1.28 Mcps TDD | 321d? | 2008-03-07 A | 2009-05-29 A | 100% | 2008-03-07 | 2009-05-29 | 321d? | finish no earlier than 2009-05-29 | R1 | 2568h | 2568h | RANimp-LCRCPC | 21 | TD Tech | chenying@td-tech.com | Rel-8 | 39 | Patrick |  | RANimp-LCRCPC | RP-090394 |  |  |
| 4388 | 1184.10 | HSPA VoIP to WCDMA/GSM CS continuity | 261d? | 2008-03-07 A | 2009-03-06 A | 100% | 2008-03-07 | 2009-03-06 | 261d? | finish no earlier than 2009-03-06 | R2 | 2088h | 2088h | RANimp-HSPAVoIP | 21 | Nokia | Simone.Provvedi@nokia.com | Rel-8 | 39 | Yong-Jun |  | RANimp-HSPAVoIP | RP-090050 |  |  |
| 4389 | 1184.11 | HS-DSCH Serving Cell Change Enhancements | 196d? | 2008-03-07 A | 2008-12-05 A | 100% | 2008-03-07 | 2008-12-05 | 196d? | finish no earlier than 2008-12-12 | R2 | 1568h | 1568h | RANimp-HSDSCH | 21 | Ericsson | henrik.enbuske@ericsson.com | Rel-8 | 39 | Yong-Jun |  | RANimp-HSDSCH | RP-080811 |  |  |
| 4390 | 1184.12 | MIMO for 1.28 Mcps TDD. Linked to Rel-8 Study on Scope of future HSPA Evolution for 1.28 Mcps TDD (UID_370041) TR 25.824 | 351.6d? | 2008-01-24 A | 2009-05-29 A | 100% | 2008-01-24 | 2009-05-29 | 351.6d? | finish no earlier than 2009-05-29 | R1; R4 | 5625.6h | 5625.6h | RANimp-MIMOLCR | 21 | CATT | wangke@datangmobile.cn | Rel-8 | 40 | Patrick |  | RANimp-MIMOLCR | RP-090313 |  |  |
| 4391 | 1184.13 | Dual-Cell HSDPA operation on adjacent carriers | 140d? | 2008-11-17 A | 2009-05-29 A | 100% | 2008-11-17 | 2009-05-29 | 140d? | finish no earlier than 2009-05-29 | R1; R4 | 2240h | 2240h | RANimp-DCHSDPA | 21 | Ericsson | johan.bergman@ericsson.com | Rel-8 | 40 | Patrick |  | RANimp-DCHSDPA | RP-080814 |  |  |

Notes:
- 4359: SP#42 completed (WT UID_390007 moved to Rel-9)
- 4360: SP#42 completed / Impacted TSs and TRs: new 32.500
- 4361: SP#42 completed / Impacted TSs and TRs: new (32.501, 32.502, 32.503, 32.531, 32.532, 32.533)
- 4362: SP#42 completed / Impacted TSs and TRs: 32.761, 32.762, 32.763, 32.765, new 32.511
- 4363: Testing for Feature UID_20068 (LTE)
- 4364: RP#46 completed / Impacted TSs and TRs: 36.521-1, 36.521-2, 36.508, 36.509, 36.523-1, 36.523-2, 36.523-3
- 4365: RP#46 completed. RP#50 TR 36.903 v100 for Approval / Impacted TSs and TRs: 36.521-1, 36.521-2, 36.521-3, new TR 36.903
- 4366: -
- 4367: RP#37 completed / Impacted TSs and TRs: 25.101, 25.104, 25.133, 25.141, 25.331, 25.942, 25.306, 25.307, 34.121
- 4368: RP#40 completed / Impacted TSs and TRs: 25.101, 25.104, 25.133, 25.141, 25.331, 25.942, 25.306, 25.307, 34.121
- 4369: RP#43 completed / Impacted TSs and TRs: 25.102, 25.105, 25.113, 25.123, 25.142, 34.124, 25.307
- 4370: RP#41 completed. RP#47 abandoned draft 25.828 / Impacted TSs and TRs: 25.102, 25.105, 25.113, 25.123, 25.142, 34.124, 25.306, 25.331, 34.122
- 4371: RP#39 completed / Impacted TSs and TRs: 25.101
- 4372: RP#39 completed / Impacted TSs and TRs: 25.323, 25.331, 25.322
- 4373: RP#39 completed / Impacted TSs and TRs: 25.101
- 4374: RP#41 stopped / Impacted TSs and TRs: 25.101, 25.104, 25.133, 25.141, 25.331, 25.942, 25.306, 25.307, 34.121
- 4375: 05/08: Linked to Feature UID_20028 (RInImp)
- 4376: RP#41 completed / Impacted TSs and TRs: 34.108, 34.123-1, 34.123-2, 34.123-3
- 4377: RP#42 completed / Impacted TSs and TRs: 34.121-1, 34.121-2
- 4378: -
- 4379: RP#41 completed / Impacted TSs and TRs: 25.308, 25.211, 25.212, 25.213, 25.306, 25.331, 25.433, 25.435, 25.423, 25.425, 25.101, 25.104, 25.141
- 4380: RP#40 completed. Linked to UID_370037 Enhanced Uplink for CELL_FACH State in FDD / Impacted TSs and TRs: 25.319, 25.301, 25.306, 25.321, 25.331, 25.433, 25.435, 25.423, 25.425, 25.427
- 4381: RP#42 completed. Linked to UID_370036 Improved L2 for uplink / Impacted TSs and TRs: 25.309, 25.211, 25.214, 25.321, 25.331, 25.423, 25.433
- 4382: RP#41 completed. Continuation of Rel-7 work item "Continuous connectivity for packet data users" UID_20046. / Impacted TSs and TRs: 25.306, 25.308, 25.321, 25.331, 25.423
- 4383: RP#41 completed. Linked to UID_370040 Enhancements for FDD HSPA Evolution / Impacted TSs and TRs: 25.306, 25.308, 25.321, 25.331, 25.423, 25.433, 25.214, 25.133
- 4384: RP#42 completed. Triggered by Rel-7 Study on Scope of future FDD HSPA Evolution (UID_20065) TR 25.999 / Impacted TSs and TRs: 25.401, 25.413, 25.420, 25.423, 25.427, 25.433, 25.446, 25.301, 25.346
- 4385: RP#42 completed. Linked to Rel-8 Study on Scope of future HSPA Evolution for 1.28 Mcps TDD (UID_370041) TR 25.824 / Impacted TSs and TRs: 25.102, 25.105, 25.123, 25.142, 25.201, 25.221, 25.222, 25.223, 25.224, 25.306, 25.308, 25.321, 25.331, 25.423, 25.433
- 4386: RP#42 completed. Linked to Rel-8 Study on Scope of future HSPA Evolution for 1.28 Mcps TDD (UID_370041) TR 25.824 / Impacted TSs and TRs: 25.123, 25.221, 25.222, 25.224, 25.301, 25.302, 25.304, 25.306, 25.308, 25.319, 25.321, 25.331, 25.401, 25.423, 25.425, 25.433, 25.435
- 4387: RP#44 completed. Linked to Rel-8 Study on Scope of future HSPA Evolution for 1.28 Mcps TDD (UID_370041) TR 25.824 / Impacted TSs and TRs: 25.929, 25.308, 25.319
- 4388: RP#43 completed / Impacted TSs and TRs: 25.331, 25.413
- 4389: RP#42 completed / Impacted TSs and TRs: 25.101, 25.104, 25.133, 25.212, 25.214, 25.308, 25.321, 25.331, 25.423, 25.433
- 4390: RP#43 completed / Impacted TSs and TRs: 25.201, 25.221, 25.222, 25.223, 25.224, 25.306, 25.308, 25.321, 25.331, 25.423, 25.433, 25.102, 25.105, 25.142
- 4391: RP#42 completed. Triggered by UID_390032 Study on Dual-Cell HSDPA (withdrawn TR 25.825 v100). / Impacted TSs and TRs: 25.101, 25.104, 25.133, 25.141, 25.211, 25.212, 25.213, 25.214, 25.215, 25.306, 25.308, 25.321, 25.331, 25.423, 25.433

| ID | WBS | Task | Duration | Start | Finish | Complete | Baseline start | Baseline finish | Baseline duration | Constraint | Resources | Work | Actual work | Release | MCC resp | Acronym | PCG approved | WI rapporteur name | TSG approved | Status Report | Acronym_3GU_Export |
| --- | --- | --- | --- | --- | --- | --- | --- | --- | --- | --- | --- | --- | --- | --- | --- | --- | --- | --- | --- | --- | --- |
| 4392 | 1185 | **Rel-8 RAN improvements - UE Conformance Testing** | 602d? | 2008-05-30 A | 2010-09-17 A | 100% | 2008-05-30 | 2010-09-17 | 602d? |  | R5 | 29391.2h | 29391.2h | Rel-8 | Ingbert |  |  |  |  |  |  |
| 4393 | 1185.1 | Conformance Test Aspects – Combination of 64QAM and MIMO for HSDPA (FDD) | 322d? | 2008-09-12 A | 2009-12-04 A | 100% | 2008-09-12 | 2009-12-04 | 322d? | finish no earlier than 2009-12-04 | R5 | 2576h | 2576h | Rel-8 | Ingbert | RANimp-UEConTest_64QamMimoHsdpa | 21 | Ericsson | 41 | RP-091058 | RANimp-UEConTest_64QamMimoHsdpa |
| 4394 | 1185.2 | Conformance Test Aspects – Improved L2 for uplink | 341d? | 2008-05-30 A | 2009-09-18 A | 100% | 2008-05-30 | 2009-09-18 | 341d? | finish no earlier than 2009-09-18 | R5 | 2728h | 2728h | Rel-8 | Ingbert | RANimp-UEConTest_UplinkL2dataRates | 21 | Ericsson | 40 | RP-090712 | RANimp-UEConTest_UplinkL2dataRates |
| 4395 | 1185.3 | Conformance Test Aspects – 1.28 Mcps TDD Improved L2 support for high data rates | 342d? | 2009-05-29 A | 2010-09-17 A | 100% | 2009-05-29 | 2010-09-17 | 342d? | finish no earlier than 2010-09-17 | R5 | 2736h | 2736h | Rel-8 | Ingbert | RANimp-UEConTest_ImprovedL2LCRTDD | 23 | CATT | 44 | RP-100737 | RANimp-UEConTest_ImprovedL2LCRTDD |
| 4396 | 1185.4 | Conformance Test Aspects – 64QAM for 1.28 Mcps TDD HSDPA | 261d? | 2008-05-30 A | 2009-05-29 A | 100% | 2008-05-30 | 2009-05-29 | 261d? | finish no earlier than 2009-05-29 | R5 | 2088h | 2088h | Rel-8 | Ingbert | RANimp-UEConTest_64Qam1.28TDD | 21 | ZTE | 40 | RP-090415 | RANimp-UEConTest_64Qam1.28TDD |
| 4397 | 1185.5 | Conformance Test Aspects – Dual-Cell HSDPA operation on adjacent carriers | 391d? | 2008-12-05 A | 2010-06-04 A | 100% | 2008-12-05 | 2010-06-04 | 391d? | finish no earlier than 2010-06-04 | R5 | 3128h | 3128h | Rel-8 | Ingbert | RANimp-UEConTest_DCHSDPA | 22 | Qualcomm | 42 | RP-100479 | RANimp-UEConTest_DCHSDPA |
| 4398 | 1185.6 | Conformance Test Aspects – Enhanced Uplink for CELL_FACH State in FDD | 326d? | 2009-03-06 A | 2010-06-04 A | 100% | 2009-03-06 | 2010-06-04 | 326d? | finish no earlier than 2010-06-04 | R5 | 2608h | 2608h | Rel-8 | Ingbert | RANimp-UEConTest_EnhancedRACHCellFACHState | 22 | Nokia | 43 | RP-100483 | RANimp-UEConTest_EnhancedRACHCellFACHState |
| 4399 | 1185.7 | Conformance Test Aspects – Receiver Type3i | 196d? | 2009-03-06 A | 2009-12-04 A | 100% | 2009-03-06 | 2009-12-04 | 196d? | finish no earlier than 2009-12-04 | R5 | 1568h | 1568h | Rel-8 | Ingbert | RANimp-UEConTest_ReceiverType3i | 22 | Qualcomm | 43 | RP-091066 | RANimp-UEConTest_ReceiverType3i |
| 4400 | 1185.8 | Conformance Test Aspects – Enhanced CELL_FACH State in LCR TDD | 341d? | 2009-05-30 A | 2010-09-17 A | 100% | 2009-05-30 | 2010-09-17 | 341d? | finish no earlier than 2010-09-17 | R5 | 2728h | 2728h | Rel-8 | Ingbert | RANimp-UEConTest_EnhancedCellFACHStateLCRTDD | 23 | CATT | 44 | RP-100735 | RANimp-UEConTest_EnhancedCellFACHStateLCRTDD |
| 4401 | 1185.9 | Conformance Test Aspects – Continuous Connectivity for packet data users for 1.28 Mcps TDD | 261d? | 2009-09-18 A | 2010-09-17 A | 100% | 2009-09-18 | 2010-09-17 | 261d? | finish no earlier than 2010-09-17 | R5 | 2088h | 2088h | Rel-8 | Ingbert | RANimp-UEConTest_CPCLCRTDD | 23 | ZTE | 45 | RP-100739 | RANimp-UEConTest_CPCLCRTDD |
| 4402 | 1185.10 | Conformance Test Aspects – MIMO for 1.28 Mcps TDD | 186d? | 2009-09-18 A | 2010-06-04 A | 100% | 2009-09-18 | 2010-06-04 | 186d? | finish no earlier than 2010-06-04 | R5 | 1488h | 1488h | Rel-8 | Ingbert | RANimp-UEConTest_MIMOLCRTDD | 23 | ZTE | 45 | RP-100660 | RANimp-UEConTest_MIMOLCRTDD |
| 4403 | 1185.11 | Conformance Test Aspects – HS-DSCH Serving Cell Change Enhancements | 131d? | 2009-09-18 A | 2010-03-19 A | 100% | 2009-09-18 | 2010-03-19 | 131d? | finish no earlier than 2010-03-12 | R5 | 1048h | 1048h | Rel-8 | Ingbert | HSDSCH_UEConTest | 23 | Qualcomm | 45 | RP-100077 | HSDSCH_UEConTest |
| 4404 | 1186 | 3.84 Mcps TDD MBMS over a Single Frequency Network (MBSFN) Integrated Mobile Broadcast | 395d? | 2007-06-04 A | 2008-12-05 A | 100% | 2007-06-04 | 2008-12-05 | 395d? |  | R1 | 3160h | 3160h | Rel-8 | Patrick | MBSFN-DOB |  | Ericsson |  | RP-080218 | MBSFN-DOB |
| 4405 | 1187 | Conformance Test Aspects – 3.84 Mcps TDD MBMS over a Single Frequency Network (MBSFN) Integrated Mobile Broadcast | 211d? | 2009-05-30 A | 2010-03-19 A | 100% | 2009-05-30 | 2010-03-19 | 211d? | finish no earlier than 2010-03-19 | R5 | 1688h | 1688h | Rel-8 | Ingbert | MBSFN_IMB_UEConTest | 23 | IPwireless | 44 | RP-100070 | MBSFN_IMB_UEConTest |
| 4406 | 1188 | **GERAN support for GERAN - 3G Long Term Evolution interworking** | 1365d? | 2006-09-08 A | 2011-11-25 A | 100% | 2006-09-08 | 2011-11-25 | 1365d? |  | GP; G1; C1; G3new | 69960h | 69960h | Rel-8 | Paolo | GELTE |  | Nokia, Nokia Siemens Networks |  |  | GELTE |
| 4407 | 1188.1 | G1 part of GERAN support for GERAN - 3G Long Term Evolution interworking | 641d? | 2006-09-08 A | 2009-02-20 A | 100% | 2006-09-08 | 2009-02-20 | 641d? | finish no earlier than 2009-02-20 | G1 | 5128h | 5128h | Rel-8 | Paolo | GELTE |  | Nokia, Nokia Siemens Networks |  |  |  |
| 4408 | 1188.2 | G2 part of GERAN support for GERAN - 3G Long Term Evolution interworking | 641d? | 2006-09-08 A | 2009-02-20 A | 100% | 2006-09-08 | 2009-02-20 | 641d? | finish no earlier than 2009-02-20 | G2 | 5128h | 5128h | Rel-8 | Paolo | GELTE |  | Nokia, Nokia Siemens Networks |  |  |  |
| 4409 | 1188.3 | CT1 part of GERAN support for GERAN - 3G Long Term Evolution interworking | 641d? | 2006-09-08 A | 2009-02-20 A | 100% | 2006-09-08 | 2009-02-20 | 641d? | finish no earlier than 2009-02-20 | C1 | 5128h | 5128h | Rel-8 | Paolo | GELTE |  | Nokia, Nokia Siemens Networks |  |  |  |
| 4410 | 1188.4 | Testing for GERAN support for GERAN - 3G Long Term Evolution interworking | 1363d? | 2006-09-08 A | 2011-11-25 A | 100% | 2006-09-08 | 2011-11-25 | 1363d? | finish no earlier than 2011-11-25 | G3new | 10896h | 10896h | Rel-8 | Ingbert | GELTE |  | Renesas Mobile |  |  |  |
| 4411 | 1189 | U-TDOA Enhancement | 131d? | 2007-05-18 A | 2007-11-16 A | 100% | 2007-05-18 | 2007-11-16 | 131d? | finish no earlier than 2007-05-18 | GP | 1048h | 1048h | Rel-8 | Paolo | GUTEN |  | TruePosition |  |  | GUTEN |
| 4412 | 1190 | **GAN Enhancements** | 604.2d? | 2007-05-15 A | 2009-09-04 A | 100% | 2007-05-15 | 2009-09-04 | 604.2d? |  | GP | 9432h | 9432h | Rel-8 | Paolo | GANENH |  | T-Mobile |  |  | GANENH |
| 4413 | 1190.1 | Update to GAN specifications | 126d? | 2007-08-31 A | 2008-02-22 A | 100% | 2007-08-31 | 2008-02-22 | 126d? | finish no earlier than 2008-02-22 | GP | 1008h | 1008h | Rel-8 | Paolo | GANENH-SPEC |  | T-Mobile |  |  | GANENH-SPEC |
| 4414 | 1190.2 | Update TS 51.010 Mobile Station (MS) Conformance Specification for GAN Enhancements | 526d? | 2007-05-15 A | 2009-09-04 A | 100% | 2007-05-15 | 2009-09-04 | 526d? | finish no earlier than 2009-09-04 | G3new | 4208h | 4208h | Rel-8 | Ingbert | GANENH-MStest |  | T-Mobile |  |  | GANENH-MStest |
| 4415 | 1191 | **AoIP (A-interface over IP)** | 2335d? | 2000-01-03 A | 2008-12-11 A | 100% | 2000-01-03 | 2008-12-11 | 2335d? |  | GP; S4; C4; C1; C3 | 119396h | 119396h | Rel-8 | Paolo | AoIP | 21 | China Mobile, Ericsson |  |  | AoIP |
| 4416 | 1191.1 | GERAN aspects of AoIP | 2321d? | 2000-01-03 A | 2008-11-21 A | 100% | 2000-01-03 | 2008-11-21 | 2321d? | finish no earlier than 2008-11-21 | GP | 18560h | 18560h | Rel-8 | Paolo | AoIP | 21 | China Mobile, Ericsson | 40 |  |  |
| 4417 | 1191.2 | Media Requirements for CS over IP based User Plane | 267d? | 2007-12-05 A | 2008-12-11 A | 100% | 2007-12-05 | 2008-12-11 | 267d? | finish no earlier than 2008-12-11 | S4 | 1996.09h | 1996.09h | Rel-8 | Paolo | AoIP-CSoIP | 21 | China Mobile, Ericsson | 40 |  | AoIP-CSoIP |

Notes:
- 4392: Linked to Feature UID_20029 (RANimp)
- 4393: RP#46 completed. Testing for UID_360013 / Impacted TSs and TRs: 34.108, 34.121-1, 34.121-2, 34.123-1, 34.123-2 / WI rapporteur e-mail: leif.mattisson@ericsson.com
- 4394: RP#45 completed. Testing for UID_370036 / Impacted TSs and TRs: 34.108, 34.123-1, 34.123-2, 34.123-3 / WI rapporteur e-mail: leif.mattisson@ericsson.com
- 4395: RP#49 completed. Testing for Rel-7 UID_340039 Improved L2 support for high data rates and Rel-8 UID_370036 Improved L2 for uplink / Impacted TSs and TRs: 34.108, 34.123-1, 34.123-2, 34.123-3 / WI rapporteur e-mail: Xiaozhong Chen (chenxiaozhong@datangmobile.cn)
- 4396: RP#44 completed. Testing for UID_380075 / Impacted TSs and TRs: 34.108, 34.122, 34.123-1, 34.123-2, 34.123-3 / WI rapporteur e-mail: ma.zijiang@zte.com.cn
- 4397: RP#48 completed. Testing for UID_400052 / Impacted TSs and TRs: 34.108, 34.121-1, 34.121-2, 34.123-1, 34.123-2, 34.123-3 / WI rapporteur e-mail: Shubhang Vora (svora@qualcomm.com)
- 4398: RP#48 completed. Testing for UID_370037 / Impacted TSs and TRs: 34.108, 34.121-1, 34.121-2, 34.123-1, 34.123-2, 34.123-3 / WI rapporteur e-mail: jarkko.hellsten@nokia.com
- 4399: RP#46 completed. Testing for Receiver Type3i in 25.101 UE radio Tx and Rx FDD / Impacted TSs and TRs: 34.108, 34.121-1, 34.121-2 / WI rapporteur e-mail: Ashok Kumar Narayanaswamy (anarayan@qualcomm.com)
- 4400: RP#49 completed. Testing for UID_380076 / Impacted TSs and TRs: 34.108, 34.123-1, 34.123-2, 34.123-3 / WI rapporteur e-mail: Xiaozhong Chen (chenxiaozhong@datangmobile.cn)
- 4401: RP#49 completed. Testing for UID_390028 / Impacted TSs and TRs: 34.108, 34.123-1, 34.123-2, 34.123-3 / WI rapporteur e-mail: huang.he4@zte.com.cn
- 4402: PR#48 completed. Testing for UID_400050 / Impacted TSs and TRs: 34.108, 34.122, 34.123-1, 34.123-2, 34.123-3 / WI rapporteur e-mail: huang.chun2@zte.com.cn
- 4403: RP#47 completed. Testing for UID_390030 / Impacted TSs and TRs: 34.108, 34.121-1, 34.121-2, 34.123-1, 34.123-2, 34.123-3 / WI rapporteur e-mail: Shubhang Vora (svora@qualcomm.com)
- 4404: RP#42 completed. WID updated RP-070493=>RP-081124 (changed WI title "MBSFN Downlink Optimized Broadcast (DOB) 3.84 Mcps TDD" => "3.84Mcps TDD MBSFN Integrated Mobile Broadcast"). / Impacted TSs and TRs: 25.102, 25.105, 25.123, 25.201, 25.221, 25.222, 25.223, 25.224, 25.304, 25.306, 25.331, 25.346, 25.402, 25.433 / WI rapporteur e-mail: Lars.Lindbom@ericsson.com
- 4405: RP#47 completed. Testing for Rel-8 MBSFN-DOB UID_360008 / Impacted TSs and TRs: 34.108, 34.122, 34.123-1, 34.123-2, 34.123-3 / WI rapporteur e-mail: Phil Young (pyoung@ipwireless.com)
- 4406: GP#41 completed. GP#52 completed MS conformance testing / Impacted TSs and TRs: 44.018, 44.060, 45.002, 45.008, 45.010, 48.008, 48.018, 51.010 / WI rapporteur e-mail: sergio.parolari@nsn.com, vlora.rexhepi@nokia.com
- 4407: GP#41 completed / Impacted TSs and TRs: 43.055, 43.129, 43.246, 45.002, 45.008, 45.010 / WI rapporteur e-mail: sergio.parolari@nsn.com, vlora.rexhepi@nokia.com
- 4408: GP#41 completed / Impacted TSs and TRs: 44.018, 44.060, 48.008, 48.018 / WI rapporteur e-mail: sergio.parolari@nsn.com, vlora.rexhepi@nokia.com
- 4409: - / Impacted TSs and TRs: 24.008 / WI rapporteur e-mail: sergio.parolari@nsn.com, vlora.rexhepi@nokia.com
- 4410: GP#52 completed / Impacted TSs and TRs: 51.010 / WI rapporteur e-mail: deepa.kamath@renesasmobile.com
- 4411: GP#36 completed U-TDOA (Uplink Time Difference of Arrival) / Impacted TSs and TRs: 43.059, 45.008, 48.071 / WI rapporteur e-mail: Terry Brooks (terri.brooks@trueposition.com)
- 4412: GP#37 completed. GP#43 completed Testing / WI rapporteur e-mail: mohammed.versi@t-mobile.com
- 4413: GP#37 completed / Impacted TSs and TRs: 43.318, 44.318 / WI rapporteur e-mail: mohammed.versi@t-mobile.com
- 4414: GP#43 completed / Impacted TSs and TRs: 51.010 / WI rapporteur e-mail: mohammed.versi@t-mobile.com
- 4415: GP#40/TSG#42 completed . Triggered by TR 43.903 Study on A-interface over IP (AINTIP) UID_50589. / WI rapporteur e-mail: wangshuaiyu@chinamobile.com, paul.schliwa-bertling@ericsson.com
- 4416: GP#40 completed. GP#39 updated WID GP-080901=>GP-081362. / Impacted TSs and TRs: 48.001, 48.002, 48.008, 48.020, 49.008, 48.103 / WI rapporteur e-mail: wangshuaiyu@chinamobile.com, paul.schliwa-bertling@ericsson.com
- 4417: SP#42 completed / Impacted TSs and TRs: 26.102, 26.103, 26.202 / WI rapporteur e-mail: Karl.Hellwig@Ericsson.com

| ID | WBS | Task | Type | Duration | Start | Finish | Complete | Baseline start | Baseline finish | Baseline duration | Constraint | Resources | Work | Actual work | Acronym | PCG approved | WI rapporteur name | Release | TSG approved | MCC resp | Acronym_3GU_Export | Impacted TSs and TRs | Status Report | TSG stopped | Special Focus Doc | PCG stopped |
| --- | --- | --- | --- | --- | --- | --- | --- | --- | --- | --- | --- | --- | --- | --- | --- | --- | --- | --- | --- | --- | --- | --- | --- | --- | --- | --- |
| 4418 | 1191.3 | **Core Network Impacts for A-Interface User Plane over IP** |  | 136d? | 2008-05-30 A | 2008-12-05 A | 100% | 2008-05-30 | 2008-12-05 | 136d? |  | C4; C1; C3 | 5440h | 5440h | AoIP-CN | 21 | Ericsson | Rel-8 | 40 | Kimmo | AoIP-CN |  |  |  |  |  |
| 4419 | 1191.3.1 | CT4 part of Core Network Impacts for A-Interface User Plane over IP |  | 136d? | 2008-05-30 A | 2008-12-05 A | 100% | 2008-05-30 | 2008-12-05 | 136d? | start no earlier than 2008-05-30 | C4 | 1088h | 1088h | AoIP-CN | 21 | Ericsson | Rel-8 | 40 | Kimmo |  | 23.205, 23.153, 23.231, 29.232 |  |  |  |  |
| 4420 | 1191.3.2 | CT1 part of Core Network Impacts for A-Interface User Plane over IP |  | 68d? | 2008-05-30 A | 2008-12-05 A | 100% | 2008-05-30 | 2008-12-05 | 68d? | finish no earlier than 2008-12-05 | C1 | 544h | 544h | AoIP-CN | 21 | Ericsson | Rel-8 | 40 | Frederic |  | 23.009 |  |  |  |  |
| 4421 | 1191.3.3 | CT3 part of Core Network Impacts for A-Interface User Plane over IP |  | 68d? | 2008-05-30 A | 2008-12-05 A | 100% | 2008-05-30 | 2008-12-05 | 68d? | finish no earlier than 2008-12-05 | C3 | 544h | 544h | AoIP-CN | 21 | Ericsson | Rel-8 | 40 | Adrian |  | 29.007 |  |  |  |  |
| 4422 | 1192 | New multicarrier BTS class |  | 261d? | 2007-08-31 A | 2008-08-29 A | 100% | 2007-08-31 | 2008-08-29 | 261d? | finish no earlier than 2008-08-29 | G1 | 2088h | 2088h | MCBTS |  | Alcatel-Lucent | Rel-8 |  | Paolo | MCBTS | 45.005, 45.050, 51.021 |  |  |  |  |
| 4423 | 1193 | **Support for Additional Navigation Satellite Systems (ANSS) for LCS** |  | 150d? | 2008-05-16 A | 2008-12-11 A | 100% | 2008-05-16 | 2008-12-11 | 150d? |  | S1; G2; R2 | 5784h | 5784h | ANSS |  | Qualcomm | Rel-8 |  | Paolo | ANSS |  |  |  |  |  |
| 4424 | 1193.1 | Stage 1 for ANSS for LCS |  | 1d? | 2008-12-11 A | 2008-12-11 A | 100% | 2008-12-11 | 2008-12-11 | 1d? | start no earlier than 2008-12-11 | S1 | 8h | 8h | ANSS | 22 |  | Rel-8 | 42 | Alain |  | 22.071 |  |  |  |  |
| 4425 | 1193.2 | GERAN2 part of Support for Additional Navigation Satellite Systems (ANSS) for LCS |  | 136d? | 2008-05-16 A | 2008-11-21 A | 100% | 2008-05-16 | 2008-11-21 | 136d? | start no earlier than 2008-05-16 | G2 | 1088h | 1088h | ANSS |  | Qualcomm | Rel-8 |  | Paolo |  | 43.059, 44.031, 49.031, 44.071, 48.031, 51.010 |  |  |  |  |
| 4426 | 1193.3 | RAN2 part of Support for Additional Navigation Satellite Systems (ANSS) for LCS |  | 136d? | 2008-05-30 A | 2008-12-05 A | 100% | 2008-05-30 | 2008-12-05 | 136d? | finish no earlier than 2008-12-08 | R2 | 1088h | 1088h | RANimp-ANSS | 21 | Qualcomm | Rel-8 | 40 | Yong-Jun | RANimp-ANSS | 25.305, 25.306, 25.331, 25.413, 25.423, 25.433, 25.453 | RP-080813 |  |  |  |
| 4427 | 1194 | **Conformance testing for the Latency Reductions feature** |  | 532d? | 2008-02-22 A | 2010-03-05 A | 100% | 2008-02-22 | 2010-03-05 | 532d? |  | G1; G3new | 14848h | 14848h | CTLATRED | 21 | Ericsson | Rel-8 |  | Paolo | CTLATRED |  |  |  |  |  |
| 4428 | 1194.1 | MS conformance testing for the Latency Reductions feature |  | 532d? | 2008-02-22 A | 2010-03-05 A | 100% | 2008-02-22 | 2010-03-05 | 532d? | finish no earlier than 2010-03-05 | G3new | 4248h | 4248h | CTLATRED-MStest | 21 | Ericsson | Rel-8 |  | Ingbert | CTLATRED-MStest | 51.010 |  |  |  |  |
| 4429 | 1194.2 | BTS conformance testing for the Latency Reductions feature |  | 261d? | 2008-02-22 A | 2009-02-20 A | 100% | 2008-02-22 | 2009-02-20 | 261d? | finish no earlier than 2009-02-20 | G1 | 2088h | 2088h | CTLATRED-BTStest | 21 | Ericsson | Rel-8 |  | Paolo | CTLATRED-BTStest | 51.021 |  |  |  |  |
| 4430 | 1195 | MS conformance testing of changes introduced by WI "Support of Packet-switched Handover for GERAN A/Gb mode" |  | 196d? | 2008-02-22 A | 2008-11-21 A | 100% | 2008-02-22 | 2008-11-21 | 196d? | finish no earlier than 2008-11-21 | G3new | 1568h | 1568h | PSHCT-MStest | 21 | Rohde & Schwarz | Rel-8 |  | Ingbert | PSHCT-MStest | 51.010 |  |  |  |  |
| 4431 | 1196 | (Small) Technical Enhancements and Improvements for Rel-8 |  | 509d? | 2007-01-01 A | 2008-12-11 A | 100% | 2007-01-01 | 2008-12-11 | 509d? | finish no earlier than 2008-12-11 | SP; CP; RP; GP | 16288h | 16288h | TEI8 |  |  | Rel-8 |  | All | TEI8 |  |  |  |  |  |
| 4432 | 1197 | (IETF) (Small) Technical Enhancements and Improvements for Rel-8 |  | 650d? | 2007-01-01 A | 2012-09-07 A | 100% | 2007-01-01 | 2012-09-07 | 650d? | finish no earlier than 2012-09-07 | C1-IETF | 5200h | 5200h | TEI8_IETF | 27 | christer.holmberg@ericsson.com | Rel-8 | 52 | Frederic | TEI8_IETF | RFC 6714 (was draft-ietf-simple-msrp-cema) |  |  |  |  |
| 4433 | 1198 | Test - (Small) Technical Enhancements and Improvements for Rel-8 |  | 993.6d? | 2007-03-07 A | 2010-12-24 A | 100% | 2007-03-07 | 2010-12-24 | 993.6d? | finish no earlier than 2010-12-24 | R5; G3new | 15897.6h | 15897.6h | TEI8_Test | 21 |  | Rel-8 | 40 | Ingbert | TEI8_Test |  |  |  |  |  |
| 4434 | 1199 | **Deleted - All-IP Network** |  | 448d? | 2004-06-28 A | 2006-03-15 A | 100% | 2004-06-28 | 2006-03-15 | 448d? |  | S1 | 7168h | 7168h | AIPN |  | NTT DoCoMo | Rel-8 |  | Alain | AIPN |  |  | SP-38 |  |  |
| 4435 | 1199.1 | Deleted - Stage 1 |  | 448d? | 2004-06-28 A | 2006-03-15 A | 100% | 2004-06-28 | 2006-03-15 | 448d? | finish no earlier than 2006-03-15 | S1 | 3584h | 3584h | AIPN |  | NTT DoCoMo | Rel-8 |  | Alain |  | 22.258 |  | SP-38 |  |  |
| 4436 | 1200 | Deleted - was Rel-7 - LCS for 3GPP Interworking WLAN | milestone | 0d? | 2007-09-28 A | 2007-09-28 A | 100% | 2007-09-28 | 2007-09-28 | 0d? | start no earlier than 2007-09-28 | S2 |  |  | LCS4_IWLAN |  | LG Electronics | Rel-8 | 34 | Maurice | LCS4_IWLAN | 23.234, 23.271, 23.167 |  | SP-35 | WLAN |  |
| 4437 | 1201 | Deleted - never approved- FBI Phase 2 | milestone | 0d | 2007-09-28 A | 2007-09-28 A | 100% | 2007-09-28 | 2007-09-28 | 0d | start no earlier than 2007-09-28 | S2 |  |  | FBI2 |  | Nokia Siemens Networks | Rel-8 |  | Maurice | FBI2 |  |  | SP-38 |  |  |
| 4438 | 1202 | Deleted -Enhancements to BS30 Bearer service for Videotelephony | milestone | 0d? | 2007-03-15 A | 2007-03-15 A | 100% | 2007-03-15 | 2007-03-15 | 0d? | finish no earlier than 2007-03-15 | S1 |  |  | BS30 |  |  | Rel-8 |  | Alain | BS30 | 22.002, 22.004, 22.101, 22.105, 24.008 |  | SP-38 |  |  |
| 4439 | 1203 | Deleted - IMS Enhancements Rel-8 |  | 75d? | 2007-09-03 A | 2007-12-14 A | 100% | 2007-09-03 | 2007-12-14 | 75d? |  | S1 | 600h | 600h | IMS8 |  | Telecom Italia | Rel-8 | 37 | Alain | IMS8 |  |  | SP-38 |  |  |
| 4440 | 1204 | **Deleted - Contact Manager Conformance Test specifications** |  | 471d? | 2008-06-02 A | 2010-03-19 A | 100% | 2008-06-02 | 2010-03-19 | 471d? |  | C6 | 11304h | 11304h | eUPHBOOK-Test | 21 | Comprion, Gemalto | Rel-8 | 40 | Xavier | eUPHBOOK-Test |  |  | CP-47 |  | PCG-24 |
| 4441 | 1204.1 | Deleted - Contact Manager for 3GPP UICC applications test specifications |  | 471d? | 2008-06-02 A | 2010-03-19 A | 100% | 2008-06-02 | 2010-03-19 | 471d? | finish no earlier than 2010-03-19 | C6 | 3768h | 3768h | eUPHBOOK-Test | 21 | Comprion | Rel-8 | 40 | Xavier |  | 31.320 (external interface for communication with the ME) |  | CP-47 |  | PCG-24 |
| 4442 | 1204.2 | Deleted - Contact Manager API for Java™ Card test specification |  | 471d? | 2008-06-02 A | 2010-03-19 A | 100% | 2008-06-02 | 2010-03-19 | 471d? | finish no earlier than 2010-03-19 | C6 | 3768h | 3768h | eUPHBOOK-Test | 21 | Gemalto | Rel-8 | 40 | Xavier |  | 31.321 (internal interface (API)) |  | CP-47 |  | PCG-24 |
| 4443 | 1205 | Deleted - MS conformance testing of Support of Conversational Services in A/Gb mode via the PS domain |  | 401d? | 2008-02-25 A | 2009-09-04 A | 100% | 2008-02-25 | 2009-09-04 | 401d? | finish no earlier than 2009-09-04 | G3new | 3208h | 3208h | SCSAGBCT-MStest | 21 | Nokia | Rel-8 |  | Ingbert | SCSAGBCT-MStest | 51.010 |  | GP-43 |  | PCG-23 |
| 4444 | 1206 | Release 8 Studies | milestone | 0d? | 2005-10-07 A | 2005-10-07 A | 100% | 2005-10-07 | 2010-11-12 | 1332d? | start no earlier than 2000-01-03 | CP; GP; RP; SP |  |  |  |  |  | Rel-8 |  | All |  |  |  |  |  |  |
| 4445 | 1207 | Study on Customised Alerting Tone (CAT) Requirements |  | 245d? | 2005-10-07 A | 2006-09-14 A | 100% | 2005-10-07 | 2006-09-14 | 245d? | start no earlier than 2005-10-07 | S1 | 1960h | 1960h | FS_CAT |  | China Mobile | Rel-8 |  | Alain | FS_CAT | 22.982 |  |  |  |  |
| 4446 | 1208 | Study on Facilitating Machine to Machine Communication in GSM and UMTS (M2M) |  | 350d? | 2005-11-04 A | 2007-03-08 A | 100% | 2005-11-04 | 2007-03-08 | 350d? | finish no earlier than 2006-06-16 | S1 | 2800h | 2800h | FS_M2M |  | Siemens | Rel-8 |  | Alain | FS_M2M | 22.868 |  |  | MTC, M2M |  |
| 4447 | 1209 | Study on Network Composition |  | 526d? | 2005-12-07 A | 2007-12-12 A | 100% | 2005-12-07 | 2007-12-12 | 526d? | finish no earlier than 2006-09-27 | S1 | 4208h | 4208h | FS_NetComp |  | Nokia Siemens Networks | Rel-8 |  | Alain | FS_NetComp | 22.980 |  |  |  |  |
| 4448 | 1210 | Study on Requirements of IMS Multimedia Conferencing |  | 330d? | 2006-06-08 A | 2007-09-12 A | 100% | 2006-06-08 | 2007-09-12 | 330d? | finish no earlier than 2007-03-21 | S1 | 2640h | 2640h | FS_IMSconf |  | China Mobile | Rel-8 |  | Alain | FS_IMSconf | 22.948 |  |  |  |  |
| 4449 | 1211 | Study on support of a Public Warning System |  | 140d? | 2007-09-03 A | 2008-03-14 A | 100% | 2007-09-03 | 2008-03-14 | 140d? |  | S1 | 1120h | 1120h | FS_PWS |  | T-Mobile | Rel-8 |  | Alain | FS_PWS | 22.968 |  |  | Public Safety (I-A) |  |
| 4450 | 1212 | Study on Paging Permission with Access Control |  | 256d? | 2006-09-28 A | 2007-09-20 A | 100% | 2006-09-28 | 2007-09-20 | 256d? | finish no earlier than 2007-09-20 | S1 | 2048h | 2048h | FS_PPAC |  | NTT DoCoMo | Rel-8 |  | Alain | FS_PPAC | 22.908 |  |  |  |  |
| 4451 | 1213 | Study on Non-3GPP access Network Selection Principles (NSP) |  | 392d? | 2006-12-06 A | 2008-06-05 A | 100% | 2006-12-06 | 2008-06-05 | 392d? | finish no earlier than 2007-11-19 | S1 | 3136h | 3136h | FS_N3GtoNSP |  | Telefónica O2 | Rel-8 | 34 | Alain | FS_N3GtoNSP | 22.912 |  |  |  |  |
| 4452 | 1214 | Study on Value Added Services for Short Message Service |  | 263d? | 2006-12-06 A | 2007-12-07 A | 100% | 2006-12-06 | 2007-12-07 | 263d? | finish no earlier than 2007-12-07 | S1 | 2104h | 2104h | FS_VAS4SMS |  | China Mobile | Rel-8 | 34 | Alain | FS_VAS4SMS | 22.942 |  |  |  |  |
| 4453 | 1215 | Study on Service continuity between mobile and WLAN networks |  | 262d? | 2006-12-06 A | 2007-12-06 A | 100% | 2006-12-06 | 2007-12-06 | 262d? | finish no earlier than 2008-12-25 | S1 | 2096h | 2096h | FS_SMLSWLAN |  | NEC | Rel-8 | 34 | Alain | FS_SMLSWLAN | 22.937 |  |  | WLAN |  |
| 4454 | 1216 | Study on Services Alignment and Migration |  | 331d? | 2006-12-06 A | 2008-03-12 A | 100% | 2006-12-06 | 2008-03-12 | 331d? | finish no earlier than 2007-09-20 | S1 | 2648h | 2648h | FS_ServAl |  | Telefónica O2 | Rel-8 | 37 | Alain | FS_ServAl | 22.983 |  |  |  |  |

Notes:
- 4418: CP#42 completed. Updated WID CP-080278=>CP-080722 / WI rapporteur e-mail: philip.hodges@ericsson.com
- 4419: CP#42 completed. Updated WID CP-080278=>CP-080722 / WI rapporteur e-mail: philip.hodges@ericsson.com
- 4420: CP#42 completed. Updated WID CP-080278=>CP-080722 / WI rapporteur e-mail: philip.hodges@ericsson.com
- 4421: CP#42 completed. Updated WID CP-080278=>CP-080722 / WI rapporteur e-mail: philip.hodges@ericsson.com
- 4422: GP#39 completed / WI rapporteur e-mail: thomas.bitzer@alcatel-lucent.de
- 4423: GP#40 completed / WI rapporteur e-mail: Mungal Dhanda
- 4424: SP#42 completed by 22.071 CR0077
- 4425: GP#40 completed / WI rapporteur e-mail: Mungal Dhanda
- 4426: RP#42 WI closed at 95%. Considers Rel-9 performance requirements / WI rapporteur e-mail: Etienne Chaponniere (echaponn@qualcomm.com)
- 4427: GP#45 completed / WI rapporteur e-mail: mats.y.samuelsson@ericsson.com, hakan.e.grunditz@ericsson.com
- 4428: GP#45 completed / WI rapporteur e-mail: hakan.e.grunditz@ericsson.com
- 4429: GP#41 completed / WI rapporteur e-mail: mats.y.samuelsson@ericsson.com
- 4430: GP#40 completed / WI rapporteur e-mail: Franz.Segerer@ROHDE-SCHWARZ.COM
- 4431: SP#42 completed
- 4432: CP#57 completed / WI rapporteur e-mail: christer.holmberg@ericsson.com
- 4433: -
- 4434: SP#38 stopped. 25/07/08 Moved UID_31059 Study on All-IP Network (FS_AIPN/was AIPFS) to Rel-7 out of the stopped Rel-8 Feature UID_31067 Deleted - All-IP Network (AIPN) / WI rapporteur e-mail: c.masyu@nttdocomo.co.jp
- 4435: 22.258 withdrawn, superseded by 22.278 (UID 320022). SP#38 stopped / WI rapporteur e-mail: c.masyu@nttdocomo.co.jp
- 4436: SP#35 stopped / WI rapporteur e-mail: dhshim@lge.com
- 4437: SP#38 stopped
- 4438: SP#38 stopped (no support) / WI rapporteur e-mail: andre.jarvis@three.co.uk
- 4439: SP#38 stopped
- 4440: CP#47 work stopped/abandoned / WI rapporteur e-mail: Udo Willenbrink, Jacques Seif
- 4441: CP#47 work stopped/abandoned / WI rapporteur e-mail: Udo Willenbrink (uwillenbrink@comprion.com )
- 4442: CP#47 work stopped/abandoned / WI rapporteur e-mail: jacques.seif@gemalto.com
- 4443: GP#43 work stopped/abandoned (completion 0%) / WI rapporteur e-mail: arsi.heino@nokia.com
- 4444: -
- 4445: Spin-off Rel-8 Feature Customized Alerting Tone (CAT) Service UID_340029 / WI rapporteur e-mail: Qing Huang (huangqing@chinamobile.com)
- 4446: SP#35 completed. Spin-off SA3 Study on Security Aspects of Remote Provisioning and Change of Subscription for M2M (UID_370053). SP#40 Spin-off new Feature UID_410030 (NIMTC) / WI rapporteur e-mail: Juergen Merkel
- 4447: SP#38 completed / WI rapporteur e-mail: joerg.swetina@neclab.eu
- 4448: SP#37 completed. Spin-off New Feature UID_370026 Value-Added Services for Short Message Service (VAS4SMS) / WI rapporteur e-mail: Qing Huang (huangqing@chinamobile.com)
- 4449: SP#39 completed. Spin-off Rel-9 Feature UID_380057 (PWS) / WI rapporteur e-mail: mark.younge@t-mobile.com
- 4450: SP#37 completed. Spin-off new Feature UID_370084 (PPACR) / WI rapporteur e-mail: Katsuhiro NOGUCHI (noguchi@nttdocomo.co.jp)
- 4451: SP#38 completed. Spin-off New Feature UID_380062 (N3GTONSP). SP#40 WID updated SP-060930=>SP-080318. TR re-approved with new # 22.812=>22.912 / WI rapporteur e-mail: chris.friel@O2.com
- 4452: SP#38 completed. Spin-off New Feature UID_370026 (VAS4SM) / WI rapporteur e-mail: Qing Huang (huangqing@chinamobile.com)
- 4453: SP#38 completed / WI rapporteur e-mail: joerg.swetina@neclab.eu
- 4454: SP#39 completed. Spin-off Rel-9 Feature UID_330017 Services Alignment and Migration (ServAl) / WI rapporteur e-mail: chris.friel@O2.com

| ID | WBS | Task | Duration | Start | Finish | Complete | Baseline start | Baseline finish | Baseline duration | Constraint | Resources | Work | Actual work | Acronym | WI rapporteur name | WI rapporteur e-mail | Release | MCC resp | Acronym_3GU_Export | Impacted TSs and TRs | PCG approved | TSG approved | Special Focus Doc | Status Report | PCG stopped | TSG stopped |
| --- | --- | --- | --- | --- | --- | --- | --- | --- | --- | --- | --- | --- | --- | --- | --- | --- | --- | --- | --- | --- | --- | --- | --- | --- | --- | --- |
| 4455 | 1217 | **Study on 3GPP System Architecture Evolution** | 1115d? | 2004-12-03 A | 2009-03-12 A | 100% | 2004-12-03 | 2009-03-12 | 1115d? |  | S2; S3 | 34064h | 34064h | FS_SAE | Vodafone | chris.pudney@vodafone.com | Rel-8 | Maurice | FS_SAE |  |  |  |  |  |  |  |
| 4456 | 1217.1 | Stage 2 Interim conclusion for RAN Work to start | 990d? | 2004-12-03 A | 2008-09-18 A | 100% | 2004-12-03 | 2008-09-18 | 990d? | finish no earlier than 2005-09-23 | S2 | 7920h | 7920h | FS_SAE | Vodafone | chris.pudney@vodafone.com | Rel-8 | Maurice |  | 23.882 |  |  |  |  |  |  |
| 4457 | 1217.2 | Stage 2 study on 3GPP architectural development | 704d? | 2006-01-09 A | 2008-09-18 A | 100% | 2006-01-09 | 2008-09-18 | 704d? | finish no earlier than 2007-09-28 | S2 | 5632h | 5632h | FS_SAE | Vodafone | chris.pudney@vodafone.com | Rel-8 | Maurice |  | 23.882 |  |  |  |  |  |  |
| 4458 | 1217.3 | Security study for Inter-access mobility between non-3GPP and 3GPP system | 334d? | 2007-09-03 A | 2009-03-12 A | 100% | 2007-09-03 | 2009-03-12 | 334d? | finish no earlier than 2009-03-12 | S3 | 2672h | 2672h | FS_SAE | Nokia | dajiang.zhang@nokia.com | Rel-8 | Mirko |  | 33.821, 33.822 |  |  |  |  |  |  |
| 4459 | 1218 | Study on Stage 2 aspects of IMS Service Brokering | 589d? | 2006-06-19 A | 2008-09-18 A | 100% | 2006-06-19 | 2008-09-18 | 589d? | finish no earlier than 2008-09-18 | S2 | 4712h | 4712h | FS_ISB_ST2 | Telcordia | raquel@research.telcordia.com | Rel-8 | Maurice | FS_ISB_ST2 | 23.810 |  |  |  |  |  |  |
| 4460 | 1219 | Study on IMS utilizing multicast bearer services | 447d? | 2006-03-22 A | 2007-12-06 A | 100% | 2006-03-22 | 2007-12-06 | 447d? | finish no earlier than 2007-12-03 | S2 | 3576h | 3576h | FS_MLTICAST-IMS | Nokia Siemens Networks |  | Rel-8 | Maurice | FS_MLTICAST-IMS | 23.847 |  |  |  |  |  |  |
| 4461 | 1220 | Study on Multimedia Session Continuity | 291d? | 2007-04-26 A | 2008-06-05 A | 100% | 2007-04-26 | 2008-06-05 | 291d? | finish no earlier than 2008-06-05 | S2 | 2328h | 2328h | FS_MMSC | LG Electronics |  | Rel-8 | Maurice | FS_MMSC | 23.893 |  |  |  |  |  |  |
| 4462 | 1221 | **Study on centralized IMS service control** | 363d? | 2006-10-23 A | 2008-03-12 A | 100% | 2006-10-23 | 2008-03-12 | 363d? |  | S2; S1 | 10856h | 10856h | FS_ICS | Ericsson | peter.bleckert@ericsson.com | Rel-8 | Alain | FS_ICS |  | 21 | 38 |  |  |  |  |
| 4463 | 1221.1 | Study on centralized IMS services requirements | 268d? | 2007-03-05 A | 2008-03-12 A | 100% | 2007-03-05 | 2008-03-12 | 268d? | start no earlier than 2007-03-05 | S1 | 2144h | 2144h | FS_ICS-S1 | NEC | joerg.swetina@neclab.eu | Rel-8 | Alain | FS_ICS-S1 | 22.892 |  | 37 |  |  |  |  |
| 4464 | 1221.2 | Study on centralized IMS services control | 363d? | 2006-10-23 A | 2008-03-12 A | 100% | 2006-10-23 | 2008-03-12 | 363d? | finish no earlier than 2008-02-21 | S2 | 2904h | 2904h | FS_IMS_CSC | Alcatel-Lucent | andy.bennett@alcatel-lucent.com | Rel-8 | Maurice | FS_IMS_CSC | 23.892 |  |  |  |  |  |  |
| 4465 | 1222 | Study on Architecture of IMS based Customized Alerting Tone (CAT) | 208d? | 2007-12-04 A | 2008-09-18 A | 100% | 2007-12-04 | 2008-09-18 | 208d? | finish no earlier than 2008-09-08 | S2 | 1664h | 1664h | FS_CAT-St2 | China Mobile | WANG, Jing (wangjing@chinamobilecom) | Rel-8 | Maurice | FS_CAT-St2 | 23.872 | 21 | 38 |  |  |  |  |
| 4466 | 1223 | Study on Home (e)NodeB Security | 321d? | 2007-12-20 A | 2009-03-12 A | 100% | 2007-12-20 | 2009-03-12 | 321d? | finish no earlier than 2009-03-10 | S3 | 2568h | 2568h | FS_HNB_Sec | Huawei | yangyanmei@huawei.com | Rel-8 | Mirko | FS_HNB_Sec | 33.820 | 21 | 38 | HNB |  |  |  |
| 4467 | 1224 | Study on Transferring of emergency call data – in-band modem solution | 265d? | 2006-12-07 A | 2007-12-12 A | 100% | 2006-12-07 | 2007-12-12 | 265d? | finish no earlier than 2008-09-18 | S4 | 2120h | 2120h | eCALLIBMS | Airbiquity | lhong@airbiquity.com | Rel-8 | Paolo | eCALLIBMS | 26.967 |  |  | Public Safety (I-A) |  |  |  |
| 4468 | 1225 | Study on Element Operations Systems Function (EOSF) definition | 266d? | 2007-06-07 A | 2008-06-12 A | 100% | 2007-06-07 | 2008-06-12 | 266d? | finish no earlier than 2008-12-11 | S5 | 2128h | 2128h | OAM7-NIM-EOSF | China Mobile | Li Jian (lijian@chinamobile.com) | Rel-8 | Mirko | OAM7-NIM-EOSF | 32.819 |  |  |  |  |  |  |
| 4469 | 1226 | Study on SA5 MTOSI XML Harmonization | 351d? | 2006-05-10 A | 2007-09-12 A | 100% | 2006-05-10 | 2007-09-12 | 351d? | finish no earlier than 2007-12-14 | S5 | 2808h | 2808h | OAM8-NIM-XML | Nortel | jduguay@nortel.com | Rel-8 | Mirko | OAM8-NIM-XML | 32.818 |  |  |  |  |  |  |
| 4470 | 1227 | Study on Common Profile Storage (CPS) Framework of User Data for network services and management | 244d? | 2006-07-03 A | 2007-06-07 A | 100% | 2006-07-03 | 2007-06-07 | 244d? | finish no earlier than 2007-06-07 | S5 | 1952h | 1952h | OAM7-CPS | T-Mobile | istvan.aba@t-mobile.at | Rel-8 | Mirko | OAM7-CPS | 32.808 |  |  |  |  |  |  |
| 4471 | 1228 | Study on Management for LTE and SAE | 526d? | 2006-12-07 A | 2008-12-11 A | 100% | 2006-12-07 | 2008-12-11 | 526d? | finish no earlier than 2008-12-11 | S5 | 4208h | 4208h | FS_OAM_LTE_SAE | Ericsson | robert.petersen@ericsson.com | Rel-8 | Mirko | FS_OAM_LTE_SAE | 32.816 |  | 34 |  |  |  |  |
| 4472 | 1229 | Study on Charging Aspects of 3GPP System Evolution | 179d? | 2007-04-02 A | 2007-12-06 A | 100% | 2007-04-02 | 2007-12-06 | 179d? | finish no earlier than 2007-12-06 | S5 | 1432h | 1432h | FS_SAEcharg | Nokia Siemens Networks | Gerald.Goermer@nsn.com | Rel-8 | Mirko | FS_SAEcharg | 32.820 |  |  |  |  |  |  |
| 4473 | 1230 | Study on AS-MRFC media server control protocol | 583d? | 2006-03-22 A | 2008-06-13 A | 100% | 2006-03-22 | 2008-06-13 | 583d? | finish no earlier than 2008-06-13 | C1 | 4664h | 4664h | MRFC | Hewlett-Packard | mark.syrett@hp.com | Rel-8 | Frederic | MRFC | 24.880 |  |  |  |  |  |  |
| 4474 | 1231 | Study on IMS Restoration Procedures | 310d? | 2007-03-26 A | 2008-05-30 A | 100% | 2007-03-26 | 2008-05-30 | 310d? | finish no earlier than 2008-05-30 | C4 | 2480h | 2480h | FS_IMS_RP | Ericsson | german.blanco@ericsson.com | Rel-8 | Kimmo | FS_IMS_RP | 23.820 |  |  |  |  |  |  |
| 4475 | 1232 | Study on IMS Application Server Service Data Descriptions for AS interoperability | 261d? | 2007-09-14 A | 2008-09-12 A | 100% | 2007-09-14 | 2008-09-12 | 261d? | finish no earlier than 2008-09-12 | C4 | 2088h | 2088h | FS_IMS_ASIO | Alcatel-Lucent | Jean-Jacques Trottin | Rel-8 | Kimmo | FS_IMS_ASIO | 29.864 |  |  |  |  |  |  |
| 4476 | 1233 | Study on Customized Alerting Tone (CAT) solution for voice and video call in CS domain | 261d? | 2007-09-14 A | 2008-09-12 A | 100% | 2007-09-14 | 2008-09-12 | 261d? |  | C4 | 626.4h | 626.4h | FS_CAT_VVC_CS | China Mobile | zhanghao@chinamobile.com | Rel-8 | Kimmo | FS_CAT_VVC_CS | 29.882 |  |  |  |  |  |  |
| 4477 | 1234 | Study on InterWorking Function between MAP based and Diameter based interfaces | 266d? | 2007-11-30 A | 2008-12-05 A | 100% | 2007-11-30 | 2008-12-05 | 266d? | finish no earlier than 2008-12-05 | C4 | 2128h | 2128h | FS_MAP2Diam | Huawei | liming49985@huawei.com | Rel-8 | Kimmo | FS_MAP2Diam | 29.805 | 21 | 38 |  |  |  |  |
| 4478 | 1235 | Study on Scope of future HSPA Evolution for 1.28 Mcps TDD | 186d? | 2007-09-14 A | 2008-05-30 A | 100% | 2007-09-14 | 2008-05-30 | 186d? | finish no earlier than 2008-05-30 | R1 | 1488h | 1488h | FS_RAN-LCRTDDHSPAEvo | RITT | Xu Fei | Rel-8 | Patrick | FS_RAN-LCRTDDHSPAEvo | 25.824 |  | 37 |  | RP-080290 |  |  |
| 4479 | 1236 | Study on Synchronized E-DCH for UTRA FDD | 126d? | 2007-09-14 A | 2008-03-07 A | 100% | 2007-09-14 | 2008-03-07 | 126d? | finish no earlier than 2008-03-14 | R1 | 1008h | 1008h | FS_RAN-UplinkSync | Nokia Siemens Networks | Karri.Ranta-aho@nsn.com | Rel-8 | Patrick | FS_RAN-UplinkSync | 25.823 |  | 37 |  | RP-080068 |  |  |
| 4480 | 1237 | Study on Improved network controlled mobility between LTE and 3GPP2/mobile WiMAX radio technologies | 131d? | 2007-06-04 A | 2007-12-03 A | 100% | 2007-06-04 | 2007-12-03 | 131d? | finish no earlier than 2007-12-03 | R4 | 1048h | 1048h | FS_RAN-LTEmob | Motorola | hao.bi@Motorola.com | Rel-8 | Issam | FS_RAN-LTEmob | 36.938 |  |  |  | RP-070827 |  |  |
| 4481 | 1238 | Study on 3G Home NodeB/eNodeB | 325d? | 2007-03-05 A | 2008-05-30 A | 100% | 2007-03-05 | 2008-05-30 | 325d? | finish no earlier than 2008-05-30 | R4 | 2600h | 2600h | FS_RAN-HNBeNB | Motorola | howard.thomas@motorola.com | Rel-8 | Issam | FS_RAN-HNBeNB | 25.820 |  |  | HNB | RP-080289 |  |  |
| 4482 | 1239 | Study on A-interface over IP | 126d? | 2007-08-31 A | 2008-02-22 A | 100% | 2007-08-31 | 2008-02-22 | 126d? | finish no earlier than 2008-02-22 | GP | 1008h | 1008h | AINTIP | China Mobile, Ericsson | paul.schliwa-bertling@ericsson.com | Rel-8 | Paolo | AINTIP | 43.903 |  |  |  |  |  |  |
| 4483 | 1240 | Study on Multi-User Reusing-One-Slot | 782d? | 2007-11-16 A | 2010-11-12 A | 100% | 2007-11-16 | 2010-11-12 | 782d? | finish no earlier than 2010-11-12 | GP | 6248h | 6248h | MUROS | Nokia Siemens Networks | juergen.hofmann@nsn.com | Rel-8 | Paolo | MUROS | 45.914 |  |  |  |  |  |  |
| 4484 | 1241 | Study on Optimized Transmit Pulse Shape for Downlink EGPRS2-B | 657d? | 2007-11-16 A | 2010-05-21 A | 100% | 2007-11-16 | 2010-05-21 | 657d? | finish no earlier than 2010-05-27 | G1 | 5248.44h | 5248.44h | WIDER | Research In Motion, Nokia Siemens Networks | jdwyer@RIM.COM and eddie.riddington@nsn.com | Rel-8 | Paolo | WIDER | 45.913 |  |  |  |  |  |  |
| 4485 | 1242 | Deleted - Study on Mobility between 3GPP-WLAN Interworking and 3GPP Systems | 393d? | 2007-03-20 A | 2008-09-18 A | 100% | 2007-03-20 | 2008-09-18 | 393d? | finish no earlier than 2008-09-18 | S2 | 3144h | 3144h | FS_SM3GWLAN | Orange |  | Rel-8 | Maurice | FS_SM3GWLAN | withdrawn 23.827 |  |  | WLAN |  | PCG-21 | SP-41 |
| 4486 | 1243 | Deleted - equals 340035 -FS on Service continuity between mobile and WLAN networks | 75d? | 2007-09-03 A | 2007-12-14 A | 100% | 2007-09-03 | 2007-12-14 | 75d? | finish no earlier than 2007-12-14 | S1 | 600h | 600h | FSSCMobToW | BT | mike.meyerstein@bt.com | Rel-8 | Alain | FSSCMobToW | 22.937 |  | 37 |  |  | PCG-21 | SP-39 |
| 4487 | 1244 | Deleted - Study on Evaluation of LCS Control Plane Solution for EPS | 100d? | 2008-01-14 A | 2008-05-30 A | 100% | 2008-01-14 | 2008-05-30 | 100d? | finish no earlier than 2009-03-20 | S2 | 800h | 800h | FS_LCS_EPS | SiRF |  | Rel-8 | Maurice | FS_LCS_EPS | 23.891 |  | 38 |  |  | PCG-21 | SP-40 |
| 4488 | 1245 | Deleted - Study on HS-PDSCH serving cell change enhancements | 60d? | 2007-12-17 A | 2008-03-07 A | 100% | 2007-12-17 | 2008-03-07 | 60d? | finish no earlier than 2008-06-12 | R4 | 480h | 480h | FS_RAN-HSPDSCH | Qualcomm |  | Rel-8 | Issam | FS_RAN-HSPDSCH | none | 21 | 38 |  | RP-080070 | PCG-21 | RP-39 |
| 4489 | 1246 | Deleted - Study on Dual-Cell HSDPA operation | 261d? | 2007-08-15 A | 2009-03-06 A | 100% | 2007-08-15 | 2009-03-06 | 261d? | finish no earlier than 2009-03-06 | R1 | 2088h | 2088h | FS_RAN-DCHS | Qualcomm | Josef Blanz | Rel-8 | Patrick | FS_RAN-DCHS | withdrawn 25.825 v100 | 21 | 39 |  | RP-090066 | PCG-22 | RP-43 |
| 4490 | 1247 | Release 7 Features | 679d? | 2005-05-02 A | 2007-12-06 A | 100% | 2005-05-02 | 2007-12-06 | 679d? | start no earlier than 2000-01-01 | CP; GP; RP; SP | 21728h | 21728h |  |  |  | Rel-7 | All |  |  |  |  |  |  |  |  |

Notes:
- 4455: SP#43 completed
- 4456: SP#41 completed
- 4457: SP#41 completed
- 4458: SP#43 completed
- 4459: SP#41 completed. No spin-off activity proposed. [Note: IMS Service Brokering enhancements UID_31088 moved back from R8 to R7 to give a home to 22228CR0036_(Rel-7)_S1-051232. Hence, Rel-7 ISB has Stage 1 only (and is misaligned with Rel-7 Stages 2/3.]
- 4460: SP#38 completed
- 4461: SP#40 completed
- 4462: SP#39 completed
- 4463: SP#39 completed
- 4464: SP#39 completed
- 4465: SP#41 completed as Rel-8
- 4466: SP#43 completed. Linked to RAN4 Study on 3G Home NodeB/eNodeB (UID_350039) and to SA5 Study on Self-Organizing Networks (SON) related OAM interfaces for Home NodeB (UID_360007)
- 4467: SP#38 completed. Spin-off WID UID_34042 (eCall_Phase2)
- 4468: SP#40 completed. WID updated SP-050608=>SP-070307
- 4469: SP#37 completed. WID updated SP-050295=>SP-070305
- 4470: SP#36 completed. Spin-off New Feature UID_400034 User Data Convergence (UDC)
- 4471: SP#42 completed
- 4472: SP#38 completed
- 4473: CP#40 completed. Spin-off New Feature UID_380035 (MRFC_TS)
- 4474: CP#40 completed. Spin-off WID UID_400012 (IMS_RP)
- 4475: CP#41 completed. Linked to SA5 Study on Common Profile Storage framework UID_320006. Spin-off WID UID_410003 (IMS_ASIO)
- 4476: CP#41 completed. Spin-off WID under Feature CAT UID_340029
- 4477: CP#42 completed. Spin-off implementation Building Block UID_410007 (MAP2Diam) under the SAES Feature UID_320005
- 4478: RP#40 completed
- 4479: RP#39 completed
- 4480: RP#38 completed
- 4481: RP#40 completed
- 4482: GP#37 completed. Spin-off implementation Feature AoIP (A-interface over IP) UID_50591
- 4483: GP#48 completed as Rel-8. Spin-off implementation WI UID_420002 VAMOS (Voice services over Adaptive Multi-user channels on One Slot)
- 4484: GP#46 completed
- 4485: SP#41 stopped. Draft TR 23.827 content implemented in TS 23.327.
- 4486: SP#39 stopped
- 4487: SP#40 spin-off Feature UID_400038 (LCS_CPS_EPS). SP#40 FS stopped
- 4488: RP#39 stopped (no TR produced). Spin-off HS-DSCH Serving Cell Change Enhancements (UID_39003)
- 4489: RP#43 stopped (draft TR 25.825 v100 withdrawn). Conclusions in RP-090318 (RAN1 findings of the UTRA Multi-Carrier Evolution study). RP#42 New WI approved on Dual-Cell HSDPA operation on adjacent carriers (UID_400052)
- 4490: -

| ID | WBS | Task | Type | Duration | Start | Finish | Complete | Baseline start | Baseline finish | Baseline duration | Constraint | Resources | Work | Actual work | Acronym | WI rapporteur name | WI rapporteur e-mail | Release | MCC resp | Acronym_3GU_Export | TSG stopped | PCG approved | TSG approved | Status Report | Special Focus Doc |
| --- | --- | --- | --- | --- | --- | --- | --- | --- | --- | --- | --- | --- | --- | --- | --- | --- | --- | --- | --- | --- | --- | --- | --- | --- | --- |
| 4491 | 1248 | **Identification of Communication Services in IMS** |  | 620d? | 2005-05-02 A | 2007-09-14 A | 100% | 2005-05-02 | 2007-09-14 | 620d? |  | S2; S1; C1; S5 | 29048h | 29048h | ServID | Ericsson | stephen.terrill@ericsson.com | Rel-7 | Maurice | ServID |  |  |  |  |  |
| 4492 | 1248.1 | TR on ServID |  | 232d? | 2005-05-02 A | 2006-03-21 A | 100% | 2005-05-02 | 2006-03-21 | 232d? | finish no earlier than 2006-03-20 | S2 | 1856h | 1856h | ServID | Ericsson | stephen.terrill@ericsson.com | Rel-7 | Maurice |  |  |  |  |  |  |
| 4493 | 1248.2 | Stage 1,2 of ServID |  | 144d? | 2005-11-11 A | 2006-05-31 A | 100% | 2005-11-11 | 2006-05-31 | 144d? | start no earlier than 2005-11-11 | S1; S2 | 2304h | 2304h | ServID | Ericsson | stephen.terrill@ericsson.com | Rel-7 | Maurice |  |  |  |  |  |  |
| 4494 | 1248.3 | Stage 3 of ServID |  | 250d? | 2006-03-31 A | 2007-03-15 A | 100% | 2006-03-31 | 2007-03-15 | 250d? | finish no earlier than 2007-03-15 | C1 | 2000h | 2000h | ServID | Ericsson | christer.holmberg@ericsson.com | Rel-7 | Frederic |  |  |  |  |  |  |
| 4495 | 1248.4 | Charging of ServID |  | 381d? | 2006-03-31 A | 2007-09-14 A | 100% | 2006-03-31 | 2007-09-14 | 381d? | finish no earlier than 2007-09-14 | S5 | 3048h | 3048h | ServID | Orange | alain.bibas@orange-ft.com | Rel-7 | Mirko |  |  |  |  |  |  |
| 4496 | 1249 | **Supporting Globally Routable User Agent URIs in IMS** |  | 415d? | 2005-11-14 A | 2007-06-15 A | 100% | 2005-11-14 | 2007-06-15 | 415d? |  | S2; S1; C1 | 14920h | 14920h | GRUU | Research In Motion | Adrian Buckley (abuckley@rim.com) | Rel-7 | Maurice | GRUU |  |  |  |  |  |
| 4497 | 1249.1 | Deleted - TR on GRUU |  | 219d? | 2005-11-14 A | 2006-09-14 A | 100% | 2005-11-14 | 2006-09-14 | 219d? | finish no earlier than 2006-09-14 | S2 | 1752h | 1752h | GRUU | Research In Motion | Adrian Buckley (abuckley@rim.com) | Rel-7 | Maurice |  | SP-32 |  |  |  |  |
| 4498 | 1249.2 | Stage 1,2 of GRUU |  | 65d? | 2006-07-03 A | 2006-09-29 A | 100% | 2006-07-03 | 2006-09-29 | 65d? | start no earlier than 2006-07-03 | S1; S2 | 1040h | 1040h | GRUU | Research In Motion | Adrian Buckley (abuckley@rim.com) | Rel-7 | Maurice |  |  |  |  |  |  |
| 4499 | 1249.3 | Stage 3 of GRUU |  | 271d? | 2006-06-02 A | 2007-06-15 A | 100% | 2006-06-02 | 2007-06-15 | 271d? | finish no earlier than 2007-06-15 | C1 | 2168h | 2168h | GRUU | CableLabs | Bernie McKibben (b.mckibben@cablelabs.com) | Rel-7 | Frederic |  |  |  |  |  |  |
| 4500 | 1250 | **Multimedia Telephony Service for IMS** |  | 2919d? | 2006-02-01 A | 2017-03-15 A | 100% | 2006-02-01 | 2007-06-15 | 357d? |  | S1; C1; S4 | 81952h | 81952h | MTSI | Ericsson | peter.bleckert@ericsson.com | Rel-7 | Alain | MTSI |  | 35 | 69 |  |  |
| 4501 | 1250.1 | Stage 1 of MTSI |  | 173d? | 2006-02-01 A | 2006-09-29 A | 100% | 2006-02-01 | 2006-09-29 | 173d? | start no earlier than 2006-02-01 | S1 | 1384h | 1384h | MTSI-REQ | Ericsson | peter.bleckert@ericsson.com | Rel-7 | Alain | MTSI-REQ |  |  |  |  |  |
| 4502 | 1250.2 | Stage 3 of MTSI |  | 330d? | 2006-03-10 A | 2007-06-14 A | 100% | 2006-03-10 | 2007-06-14 | 330d? | finish no earlier than 2007-06-15 | C1 | 2640h | 2640h | MTSI | Ericsson | christer.holmberg@ericsson.com | Rel-7 | Frederic | MTSI |  |  |  |  |  |
| 4503 | 1250.3 | Media handling and interaction in MTSI |  | 262d? | 2006-03-15 A | 2007-03-15 A | 100% | 2006-03-15 | 2007-03-15 | 262d? | finish no earlier than 2007-03-15 | S4 | 2096h | 2096h | MTSI-MHI | Ericsson | olle.franceschi@ericsson.com | Rel-7 | Paolo | MTSI-MHI |  |  |  |  |  |
| 4504 | 1250.4 | UE Conformance Test Aspects - Multimedia Telephony Services for IMS (MTSI) over fixed access |  | 393d? | 2015-09-15 A | 2017-03-15 A | 100% |  |  |  | finish no earlier than 2017-03-15 | R5 | 3144h | 3144h | MTSI_FIXED_ACCESS-UEConTest | Telecom Italia |  | Rel-7 |  |  |  | 35 | 69 |  |  |
| 4505 | 1250.5 | UE Conformance Test Aspects – Multimedia Telephony Services for IMS (MTSI) over WLAN |  | 329d? | 2015-09-15 A | 2016-12-15 A | 100% |  |  |  | finish no earlier than 2016-12-15 | R5 | 2632h | 2632h | MTSI_WLAN-UEConTest | Ericsson |  | Rel-7 |  |  |  | 35 | 69 |  |  |
| 4506 | 1250.6 | Deleted - duplicates UID7039 - IMS Multimedia Telephony Service | milestone | 0d? | 2007-06-15 A | 2007-06-15 A | 100% | 2007-06-15 | 2007-06-15 | 0d? | start no earlier than 2007-06-15 | S1 |  |  | MMTEL | Ericsson | peter.bleckert@ericsson.com | Rel-7 | Alain | MMTEL | SP-32 |  |  |  |  |
| 4507 | 1251 | Multimedia Telephony Service for IMS (MTSI) - UE Conformance Testing |  | 387d | 2007-09-19 A | 2009-03-12 A | 100% | 2007-09-19 | 2009-03-12 | 387d | finish no earlier than 2009-03-13 | R5 | 1664h | 1664h | MTSI-UEConTest | Ericsson, Motorola | Leif.Mattisson@ericsson.com, Jacob.John@motorola.com | Rel-7 | Ingbert | MTSI-UEConTest |  |  |  | RP-090056 |  |
| 4508 | 1252 | TISPAN requirements for Multimedia Telephony with PSTN/ISDN simulation services |  | 58d? | 2007-09-18 A | 2007-12-06 A | 100% | 2007-09-18 | 2007-12-06 | 58d? | start no earlier than 2007-09-18 | S1 | 464h | 464h | TMMTEL7 |  |  | Rel-7 | Alain | TMMTEL7 |  |  | 37 |  |  |
| 4509 | 1253 | **Maintenance of TISPAN release 1 common IMS** |  | 180d? | 2007-07-02 A | 2008-03-07 A | 100% | 2007-07-02 | 2008-03-07 | 180d? |  | S2 | 5808h | 5808h | MCIMSTR1 | Ericsson | Raymond Forbes | Rel-7 | Maurice | MCIMSTR1 |  | 21 | 38 |  |  |
| 4510 | 1253.1 | SA1 aspects of MCIMSTR1 |  | 58d? | 2007-09-18 A | 2007-12-06 A | 100% | 2007-09-18 | 2007-12-06 | 58d? | finish no earlier than 2007-12-06 | S1 | 464h | 464h | MCIMSTR1-S1 | Telecom Italia | Marco.DeLuca1@telecomitalia.it | Rel-7 | Alain | MCIMSTR1-S1 |  | 21 | 38 |  |  |
| 4511 | 1253.2 | SA2 aspects of MCIMSTR1 |  | 58d? | 2007-09-18 A | 2007-12-06 A | 100% | 2007-09-18 | 2007-12-06 | 58d? | finish no earlier than 2007-12-06 | S2 | 464h | 464h | MCIMSTR1-S2 | Ericsson | Raymond Forbes | Rel-7 | Maurice | MCIMSTR1-S2 |  | 21 | 38 |  |  |
| 4512 | 1253.3 | SA1,SA2 part of Maintenance of TISPAN release 1 common IMS |  | 114d? | 2007-07-02 A | 2007-12-06 A | 100% | 2007-07-02 | 2007-12-06 | 114d? | finish no earlier than 2007-12-06 | S2; S1 | 1824h | 1824h | IMS_Comm_Mtce7 | BT, Ericsson | Dick Knight, Raymond Forbes | Rel-7 | Maurice | IMS_Comm_Mtce7 |  | 21 | 38 |  |  |
| 4513 | 1253.4 | Maintenance of TISPAN R1 |  | 86d? | 2007-11-09 A | 2008-03-07 A | 100% | 2007-11-09 | 2008-03-07 | 86d? | start no earlier than 2007-11-09 | C1; C3; C4 | 2064h | 2064h | MAINT_R1 | Alcatel-Lucent | Keith Drage (drage@alcatel-lucent.com) | Rel-7 | Frederic | MAINT_R1 |  | 21 | 38 |  |  |
| 4514 | 1254 | **PS domain and IMS impacts for supporting IMS Emergency calls (EMC1)** |  | 2934d? | 2000-09-18 A | 2011-12-09 A | 100% | 2000-09-18 | 2011-12-09 | 2934d? |  | S2; S1; C1; C4; IETF | 185422h | 185422h | EMC1 | Siemens | Rainer Liebhart | Rel-7 | Maurice | EMC1 |  |  |  |  | Public Safety (I-A) |
| 4515 | 10.1.1 | Service Requirements for IP-based emergency calls |  | 985d | 2000-09-18 A | 2004-06-25 A | 100% | 2000-09-18 | 2004-06-25 | 985d | finish no earlier than 2004-06-25 | S1 | 7880h | 7880h | EMC1 | Siemens | Rainer Liebhart | Rel-7 | Alain |  |  |  |  |  | Public Safety (I-A) |
| 4516 | 1254.2 | Study on Stage 2 for IMS-level solution |  | 668d? | 2003-02-26 A | 2005-09-16 A | 100% | 2003-02-26 | 2005-09-16 | 668d? | finish no earlier than 2005-09-16 | S2 | 5344h | 5344h | EMC1 | Siemens | Rainer Liebhart | Rel-7 | Maurice |  |  |  |  |  | Public Safety (I-A) |
| 4517 | 1254.3 | Study on Stage 2 for GPRS-level solution |  | 301d? | 2004-10-14 A | 2005-12-08 A | 100% | 2004-10-14 | 2005-12-08 | 301d? | finish no earlier than 2005-12-08 | S2 | 2408h | 2408h | EMC1 | Siemens | Rainer Liebhart | Rel-7 | Maurice |  |  |  |  |  | Public Safety (I-A) |
| 4518 | 1254.4 | Stage 2 Specification Phase - IMS-level |  | 200d? | 2005-09-05 A | 2006-06-09 A | 100% | 2005-09-05 | 2006-06-09 | 200d? | finish no earlier than 2006-06-09 | S2 | 1600h | 1600h | EMC1 | Siemens | Rainer Liebhart | Rel-7 | Maurice |  |  |  |  |  | Public Safety (I-A) |
| 4519 | 1254.5 | Deleted - Stage 2 Specification Phase - GPRS-level | milestone | 0d? | 2007-03-02 A | 2007-03-02 A | 100% | 2007-03-02 | 2007-03-02 | 0d? | start no earlier than 2007-03-02 | S2 |  |  | EMC1 | Siemens | Rainer Liebhart | Rel-7 | Maurice |  | SP-32 |  |  |  | Public Safety (I-A) |

Notes:
- 4491: WID approved SP#28. WID updated SP#32
- 4492: - / Impacted TSs and TRs: 23.816
- 4493: - / Impacted TSs and TRs: 22.228, 23.228, 23.203
- 4494: CP#32 approved WID / Impacted TSs and TRs: 23.218, 24.229
- 4495: - / Impacted TSs and TRs: 32.260, 32.298, 32.299
- 4496: SP#29 approved WID
- 4497: Abandoned
- 4498: SP#29 approved WID / Impacted TSs and TRs: 22.228, 23.228, 23.218, 24.229
- 4499: CP#32 approved WID / Impacted TSs and TRs: 24.229
- 4500: -
- 4501: - / Impacted TSs and TRs: 22.173
- 4502: - / Impacted TSs and TRs: 24.173
- 4503: - / Impacted TSs and TRs: 26.114
- 4504: tested: REL-7 SA/CT WI MTSI;1/1/16: Compl:0%->5%; 22/3/16: Compl:5%->15%1/7/16: Compl:15%->30% ; 21/...
- 4505: tested: REL-7 WI MTSI; 1/1/16: Compl:0%->5%1/1/16: WID: RP-151334->RP-15177022/3/16: Compl:5%->10%
- 4506: - / Impacted TSs and TRs: 22.173
- 4507: RP#43 completed. Linked UID_7038 (MTSI) / Impacted TSs and TRs: 34.123-1, 34.123-2, 34.123-3, 34.229-1, 34.229-2
- 4508: - / Impacted TSs and TRs: 22.273 (EI 181 002 maintenance)
- 4509: - / Impacted TSs and TRs: http://www.3gpp.org/specs/TISPAN-IMS-ansfer.htm
- 4510: - / Impacted TSs and TRs: 22.173, 22.273
- 4511: - / Impacted TSs and TRs: 23.406, 23.417, 23.508,23.509, 23.511
- 4512: SP#38 completed / Impacted TSs and TRs: 22.173, 22.273, 22.401, 23.406, 23.417, 23.508, 23.509, 23.511
- 4513: CP#39 completed / Impacted TSs and TRs: 24.404, 24.405, 24.406, 24.407, 24.408, 24.410, 24.411, 24.416, 29.421, 24.423, 24.428, 24.429, 29.433, 24.441, 24.403, 29.427, 24.430, 29.412
- 4514: - / Impacted TSs and TRs: EMC1
- 4515: - / Impacted TSs and TRs: 22.101
- 4516: - / Impacted TSs and TRs: 23.867
- 4517: - / Impacted TSs and TRs: 23.867
- 4518: - / Impacted TSs and TRs: 23.060, 23.167, 23.203, 23.221, 23.228, 23.234, 23.271, 23.406
- 4519: -

| ID | WBS | Task | Type | Duration | Start | Finish | Complete | Baseline start | Baseline finish | Baseline duration | Constraint | Resources | Work | Actual work | Acronym | WI rapporteur name | WI rapporteur e-mail | Release | MCC resp | Special Focus Doc | Impacted TSs and TRs | PCG approved | TSG approved | TSG stopped | Acronym_3GU_Export | Created at | Status Report |
| --- | --- | --- | --- | --- | --- | --- | --- | --- | --- | --- | --- | --- | --- | --- | --- | --- | --- | --- | --- | --- | --- | --- | --- | --- | --- | --- | --- |
| 4520 | 10.1 | **Emergency Call Enhancements for IP& PS Based Calls – stage 3** |  | 1549d? | 2006-01-09 A | 2011-12-09 A | 100% | 2006-01-09 | 2011-12-09 | 1549d? |  | C1; C4; IETF | 50829.8h | 50829.8h | EMC1 | Ericsson | alf.heidermark@ericsson.com | Rel-7 | Frederic | Public Safety (I-A) |  |  |  |  |  |  |  |
| 4521 | 10.1.2 | CT1 IMS aspects to support IMS Emergency sessions |  | 350.82d | 2006-01-09 A | 2007-06-15 A | 100% | 2006-01-09 | 2007-06-15 | 350.82d | finish no earlier than 2007-06-15 | C1 | 2806.57h | 2806.57h | EMC1 | Ericsson | alf.heidermark@ericsson.com | Rel-7 | Frederic | Public Safety (I-A) | 24.229 |  |  |  |  |  |  |
| 4522 | 1254.6.2 | (IETF) CT1 IMS aspects to support IMS Emergency sessions |  | 452d? | 2006-01-09 A | 2011-12-09 A | 100% | 2006-01-09 | 2011-12-09 | 452d? | finish no earlier than 2011-12-09 | C1-IETF | 3608h | 3608h | EMC1 | Keith Drage |  | Rel-7 | Frederic | Public Safety (I-A) | RFC 6442 (was draft-ietf-sipcore-location-conveyance) | 27 | 52 |  |  |  |  |
| 4523 | 10.1.2 | Deleted - CT3 IMS aspects to support IMS Emergency sessions |  | 95d | 2006-05-08 A | 2006-09-15 A | 100% | 2006-05-08 | 2006-09-15 | 95d | finish no earlier than 2006-09-15 | C3 | 760h | 760h | EMC1 | Ericsson | alf.heidermark@ericsson.com | Rel-7 | Adrian | Public Safety (I-A) | 29.163 |  |  | CP-33 |  |  |  |
| 4524 | 10.1.5 | Deleted - CT3 PS domain aspects to support IMS Emergency sessions |  | 95d | 2006-05-08 A | 2006-09-15 A | 100% | 2006-05-08 | 2006-09-15 | 95d | start no earlier than 2006-05-08 | C3 | 760h | 760h | EMC1 | Ericsson | alf.heidermark@ericsson.com | Rel-7 | Adrian | Public Safety (I-A) | 29.061 |  |  | CP-33 |  |  |  |
| 4525 | 10.1.5 | CT1 PS domain aspects to support IMS Emergency sessions |  | 349.9d | 2006-01-09 A | 2007-06-15 A | 100% | 2006-01-09 | 2007-06-15 | 349.9d | finish no earlier than 2007-06-15 | C1 | 2799.2h | 2799.2h | EMC1 | Ericsson | alf.heidermark@ericsson.com | Rel-7 | Frederic | Public Safety (I-A) | 24.008, 24.234 |  |  |  |  |  |  |
| 4526 | 10.1.5 | CT4 PS domain aspects to support IMS Emergency sessions |  | 365d | 2006-01-09 A | 2007-06-01 A | 100% | 2006-01-09 | 2007-06-01 | 365d | finish no earlier than 2007-06-01 | C4 | 2920h | 2920h | EMC1-GPRSc4 | Ericsson | alf.heidermark@ericsson.com | Rel-7 | Kimmo | Public Safety (I-A) | 29.060 |  |  |  | EMC1-GPRSc4 |  |  |
| 4527 | 1255 | IMS Support of Conferencing |  | 355d? | 2005-11-04 A | 2007-03-15 A | 100% | 2005-11-04 | 2007-03-15 | 355d? | finish no earlier than 2007-03-15 | C1 | 2840h | 2840h | IMSconf | Alcatel-Lucent | Keith Drage (drage@alcatel-lucent.com) | Rel-7 | Frederic |  | 24.147, 24.229 |  |  |  | IMSconf |  |  |
| 4528 | 1256 | Performance Characterization of VoIMS over HSDPA\EUL channels |  | 713d? | 2005-03-15 A | 2007-12-06 A | 100% | 2005-03-15 | 2007-12-06 | 713d? | finish no earlier than 2007-12-06 | S4 | 5704h | 5704h | VoIMS-PCVoIMS | Alcatel-Lucent | mcgowan@alcatel-lucent.com | Rel-7 | Paolo |  | 26.935 |  |  |  | VoIMS-PCVoIMS |  |  |
| 4529 | 1257 | **WLAN-UMTS Interworking Phase 2** |  | 371d? | 2004-01-05 A | 2005-06-07 A | 100% | 2004-01-05 | 2005-06-07 | 371d? |  | S1; S2 | 6856h | 6856h | WLAN2 | Telenor | frederic.paint@telenor.com | Rel-7 | Alain | WLAN | 33.234 (SP-36 SA3 CRs approved) |  |  |  | WLAN2, WLAN-SC |  |  |
| 4530 | 1257.1 | Stage 1 on Session Continuity |  | 115d? | 2004-01-05 A | 2004-06-11 A | 100% | 2004-01-05 | 2004-06-11 | 115d? | start no earlier than 2004-01-05 | S1 | 920h | 920h | WLAN2 |  |  | Rel-7 | Alain | WLAN | 22.234 |  |  |  |  | SP-24 |  |
| 4531 | 1257.2 | Stage 2 on Session Continuity: covered by SAE | milestone | 0d? | 2005-06-07 A | 2005-06-07 A | 100% | 2005-06-07 | 2005-06-07 | 0d? | finish no earlier than 2005-06-07 | S2 |  |  | WLAN2 |  |  | Rel-7 | Maurice | WLAN |  |  |  |  |  |  |  |
| 4532 | 1258 | **WLAN Interworking – Private Network access from WLAN 3GPP IP Access** |  | 252d? | 2005-10-10 A | 2006-09-26 A | 100% | 2005-10-10 | 2006-09-26 | 252d? |  | S2; C1; C3; C4 | 17704h | 17704h | WLANPNA | NEC | Toshiyuki Tamura (tamurato@aj.jp.nec.com) | Rel-7 | Maurice | WLAN |  |  |  |  | WLANPNA |  |  |
| 4533 | 1258.1 | WLAN-PNA - Stage 2 |  | 185d? | 2005-10-10 A | 2006-06-23 A | 100% | 2005-10-10 | 2006-06-23 | 185d? | start no earlier than 2005-10-10 | S2 | 1480h | 1480h | WLANPNA-st2 | NEC | Toshiyuki Tamura (tamurato@aj.jp.nec.com) | Rel-7 | Maurice | WLAN | 23.234, 33.234 |  |  |  | WLANPNA-st2 |  |  |
| 4534 | 1258.2 | **WLAN-PNA - Stage 3** |  | 170d? | 2006-02-01 A | 2006-09-26 A | 100% | 2006-02-01 | 2006-09-26 | 170d? |  | C1; C3; C4 | 8160h | 8160h | WLANPNA-st3 | NEC |  | Rel-7 | Frederic | WLAN |  |  |  |  | WLANPNA-st3 |  |  |
| 4535 | 1258.2.1 | CT1 aspets for WLAN-PNA |  | 170d? | 2006-02-01 A | 2006-09-26 A | 100% | 2006-02-01 | 2006-09-26 | 170d? | start no earlier than 2006-02-01 | C1 | 1360h | 1360h | WLANPNA-st3 | NEC |  | Rel-7 | Frederic | WLAN | 24.234 |  |  |  |  |  |  |
| 4536 | 1258.2.2 | CT3 aspets for WLAN-PNA |  | 170d? | 2006-02-01 A | 2006-09-26 A | 100% | 2006-02-01 | 2006-09-26 | 170d? | start no earlier than 2006-02-01 | C3 | 1360h | 1360h | WLANPNA-st3 | NEC |  | Rel-7 | Adrian | WLAN | 29.161 |  |  |  |  |  |  |
| 4537 | 1258.2.3 | Deleted - CT4 aspets for WLAN-PNA |  | 170d? | 2006-02-01 A | 2006-09-26 A | 100% | 2006-02-01 | 2006-09-26 | 170d? | start no earlier than 2006-02-01 | C4 | 1360h | 1360h | WLANPNA-st3 | NEC |  | Rel-7 | Kimmo | WLAN | 29.234 |  |  | CP-32 |  |  |  |
| 4538 | 1259 | **Enhancements to support QoS provisioning over 3GPP/WLAN Interworking** |  | 520d? | 2005-03-14 A | 2007-03-09 A | 100% | 2005-03-14 | 2007-03-09 | 520d? |  | S2; C4; C1 | 16680h | 16680h | WLANQOS | Samsung |  | Rel-7 | Maurice | WLAN |  |  |  |  | WLANQOS |  |  |
| 4539 | 1259.1 | Deleted - TR on support of QoS on WLAN |  | 232d? | 2005-03-14 A | 2006-01-31 A | 100% | 2005-03-14 | 2006-01-31 | 232d? | start no earlier than 2005-03-14 | S2 | 1856h | 1856h | WLANQOS | Samsung |  | Rel-7 | Maurice | WLAN | 23.836 |  |  | SP-32 |  |  |  |
| 4540 | 1259.2 | Stage 2 on support of QoS over 3GPP/WLAN interworking |  | 108d? | 2006-02-01 A | 2006-06-30 A | 100% | 2006-02-01 | 2006-06-30 | 108d? | start no earlier than 2006-02-01 | S2 | 864h | 864h | WLANQOS | Samsung |  | Rel-7 | Maurice | WLAN | 23.234 |  |  |  |  |  |  |
| 4541 | 1259.3 | Stage 3 CT4 on support of QoS over 3GPP/WLAN Interworking |  | 121d? | 2006-09-22 A | 2007-03-09 A | 100% | 2006-09-22 | 2007-03-09 | 121d? | finish no earlier than 2007-03-09 | C4 | 968h | 968h | WLANQOS | Huawei | zhang.peng@huawei.com | Rel-7 | Kimmo | WLAN | 29.234, 23.008 |  |  |  |  |  |  |
| 4542 | 1259.4 | Stage 3 CT1 on support of QoS over 3GPP/WLAN Interworking |  | 64d? | 2006-09-04 A | 2006-11-30 A | 100% | 2006-09-04 | 2006-11-30 | 64d? | finish no earlier than 2006-11-30 | C1 | 512h | 512h | WLANQOS | Huawei | zhang.peng@huawei.com | Rel-7 | Frederic | WLAN | 24.234 |  | 34 |  |  |  |  |
| 4543 | 1260 | **Location Services enhancements** |  | 906d? | 2004-06-28 A | 2007-12-17 A | 100% | 2004-06-28 | 2007-12-17 | 906d? |  | S1; S2; GP; C4; R2 | 81525.6h | 81525.6h | LCS3 |  |  | Rel-7 | Alain |  |  |  |  |  | LCS3 |  |  |
| 4544 | 1260.1 | Stage 2 for LCS3 (including IMS emergency location aspects) |  | 446d? | 2004-12-31 A | 2006-09-15 A | 100% | 2004-12-31 | 2006-09-15 | 446d? | finish no earlier than 2006-09-15 | S2 | 3568h | 3568h | LCS3 | SiRF | brodilitz@sirf.com | Rel-7 | Maurice |  | 23.271 |  |  |  |  |  |  |
| 4545 | 1260.2 | LCS Enhancements related to Location-Based Services |  | 695d? | 2005-01-03 A | 2007-08-31 A | 100% | 2005-01-03 | 2007-08-31 | 695d? | finish no earlier than 2007-08-31 | GP | 5560h | 5560h | LCS3-LBS | SiRF | kjudge@sirf.com | Rel-7 | Paolo |  | 43.059, 44.031, 48.008, 49.031 |  |  |  | LCS3-LBS |  |  |
| 4546 | 1260.3 | CT4 aspects for LCS UEPos-LBS |  | 240d? | 2006-01-02 A | 2006-12-01 A | 100% | 2006-01-02 | 2006-12-01 | 240d? | finish no earlier than 2006-12-01 | C4 | 1920h | 1920h | LCS3-UEPos-LBS | SiRF | brodilitz@sirf.com | Rel-7 | Kimmo |  | 24.030, 24.080, 29.002 |  |  |  | LCS3-UEPos-LBS |  |  |
| 4547 | 1260.4 | UE positioning - Velocity |  | 394d? | 2005-03-15 A | 2006-09-15 A | 100% | 2005-03-15 | 2006-09-15 | 394d? | finish no earlier than 2006-09-15 | R2 | 3152h | 3152h | LCS3-UEPos-Velocity | SiRF | BRodilitz@SiRF.com | Rel-7 | Yong-Jun |  | 25.305, 25.331, 25.410, 25.413, 25.453 |  |  |  | LCS3-UEPos-Velocity |  | RP-060459 |
| 4548 | 1260.5 | Inclusion of Uplink TDOA UE positioning method in the UTRAN specifications |  | 849d? | 2004-09-15 A | 2007-12-17 A | 100% | 2004-09-15 | 2007-12-17 | 849d? | finish no earlier than 2007-12-17 | R2 | 6792h | 6792h | LCS3-UEPos-UTDOA | TruePosition | Robert Gross (rgross@polariswireless.com) | Rel-7 | Yong-Jun |  | 25.305, 25.453, new TS 25.111 |  |  |  | LCS3-UEPos-UTDOA |  | RP-070797 |

Notes:
- 4520: -
- 4521: -
- 4522: CP#54 completed
- 4523: Cancelled for Rel-7 and there is no corresponding Rel-8 WI
- 4524: Cancelled for Rel-7 and there is no corresponding Rel-8 WI
- 4525: -
- 4526: -
- 4527: CP#35 revised WID
- 4528: -
- 4529: Created at SP#27 because of WLAN items belonging to Rel-7. Acronym changed from "WLAN2, WLAN-SC"
- 4530: Acronym changed from "WLAN2, WLAN-SC"
- 4531: Acronym changed from "WLAN2, WLAN-SC"
- 4532: -
- 4533: Approved at SP#29
- 4534: Approved at CP#29
- 4535: Approved at CP#29
- 4536: Approved at CP#29
- 4537: CT4#31; no impacts identified, therefore completed. CP-32 stopped
- 4538: Moved from FS section Feb 06. SP-30 updated WID
- 4539: SP#32 stopped
- 4540: SP#30 updated WID
- 4541: CP#33 approved WID
- 4542: CP#33 approved WID
- 4543: -
- 4544: SP#27 approved WID
- 4545: -
- 4546: -
- 4547: -
- 4548: -

| ID | WBS | Task | Duration | Start | Finish | Complete | Baseline start | Baseline finish | Baseline duration | Constraint | Resources | Work | Actual work | Acronym | WI rapporteur name | WI rapporteur e-mail | Release | MCC resp | Special Focus Doc | Acronym_3GU_Export | TSG stopped | TSG approved | Status Report | PCG approved |
| --- | --- | --- | --- | --- | --- | --- | --- | --- | --- | --- | --- | --- | --- | --- | --- | --- | --- | --- | --- | --- | --- | --- | --- | --- |
| 4549 | 1260.6 | **LCS for 3GPP Interworking WLAN** | 700d? | 2004-06-28 A | 2007-03-02 A | 100% | 2004-06-28 | 2007-03-02 | 700d? |  | S1; S2 | 17501.6h | 17501.6h | LCS3-IWLAN | Telcordia | Mike Loushine | Rel-7 | Alain | WLAN | LCS3-IWLAN |  |  |  |  |
| 4550 | 1260.6.1 | FS on 3GPP system to WLAN Interworking with LCS | 512.7d? | 2004-06-28 A | 2006-06-30 A | 100% | 2004-06-28 | 2006-06-30 | 512.7d? | finish no earlier than 2005-09-29 | S1 | 4101.6h | 4101.6h | LCS3-IWLAN-FSs1 | Telcordia | Mike Loushine | Rel-7 | Alain |  | LCS3-IWLAN-FSs1 |  |  |  |  |
| 4551 | 1260.6.2 | Deleted - Study of work on an LCS architecture for I-WLAN. | 180d? | 2006-06-26 A | 2007-03-02 A | 100% | 2006-06-26 | 2007-03-02 | 180d? | finish no earlier than 2007-03-02 | S2 | 1440h | 1440h | LCS3-IWLAN-FSs2 | LG Electronics | dhshim@lge.com ; phede@lge.com | Rel-7 | Maurice |  | LCS3-IWLAN-FSs2 | SP-35 |  |  |  |
| 4552 | 1260.6.3 | Stage 2 for LCS architecture for I-WLAN | 95d? | 2006-10-23 A | 2007-03-02 A | 100% | 2006-10-23 | 2007-03-02 | 95d? | finish no earlier than 2007-03-02 | S2 | 760h | 760h | LCS3-IWLAN | LG Electronics | dhshim@lge.com ; phede@lge.com | Rel-7 | Maurice |  | LCS3-IWLAN |  | 34 |  |  |
| 4553 | 1260.7 | Deleted - UE positioning Rel-7 | 849d? | 2004-09-15 A | 2007-12-17 A | 100% | 2004-09-15 | 2007-12-17 | 849d? |  | RP | 6792h | 6792h | LCS3-UEpos |  |  | Rel-7 | Yong-Jun |  | LCS3-UEpos | RP-38 |  |  |  |
| 4554 | 1261 | **MBMS Enhancements** | 625d? | 2005-07-11 A | 2007-11-30 A | 100% | 2005-07-11 | 2007-11-30 | 625d? |  | S1; R1; C3 | 20844.6h | 20844.6h | MBMSE | China Mobile | liuhongyfw@chinamobile.com | Rel-7 | Alain |  | MBMSE |  |  |  |  |
| 4555 | 1261.1 | Stage 1 of MBMSE | 109d? | 2005-07-11 A | 2005-12-08 A | 100% | 2005-07-11 | 2005-12-08 | 109d? | finish no earlier than 2005-12-08 | S1 | 872h | 872h | MBMSE | China Mobile | liuhongyfw@chinamobile.com | Rel-7 | Alain |  |  |  | 34 |  |  |
| 4556 | 1261.2 | MBMS FDD Physical layer Enhancements | 117.29d? | 2006-12-15 A | 2007-06-04 A | 100% | 2006-12-15 | 2007-06-04 | 117.29d? | finish no earlier than 2007-06-04 | R1 | 938.32h | 938.32h | MBMSE-RANPhysFDD | Ericsson | Lars.Lindbom@ericsson.com | Rel-7 | Patrick |  | MBMSE-RANPhysFDD |  | 34 | RP-070290 |  |
| 4557 | 1261.3 | MBMS TDD Physical layer Enhancements | 117.29d? | 2006-12-15 A | 2007-06-04 A | 100% | 2006-12-15 | 2007-06-04 | 117.29d? | finish no earlier than 2007-06-04 | R1 | 938.32h | 938.32h | MBMSE-RANPhysTDD | IPWireless | Nicholas Anderson | Rel-7 | Patrick |  | MBMSE-RANPhysTDD |  | 34 | RP-070291 |  |
| 4558 | 1261.4 | MBMS Low Chip Rate TDD Physical Layer Enhancement | 127d? | 2007-03-16 A | 2007-09-10 A | 100% | 2007-03-16 | 2007-09-10 | 127d? | finish no earlier than 2007-09-10 | R1 | 1016h | 1016h | MBMSE-RANPhysLCRTDD | RITT | Lin Hui | Rel-7 | Patrick |  | MBMSE-RANPhysLCRTDD |  |  | RP-070292 |  |
| 4559 | 1261.5 | MBMS Mz interface | 260d? | 2006-12-04 A | 2007-11-30 A | 100% | 2006-12-04 | 2007-11-30 | 260d? | finish no earlier than 2007-05-11 | C3 | 2080h | 2080h | MBMSMz | Huawei | Deng Tingting (ttdeng@huawei.com) | Rel-7 | Adrian |  | MBMSMz |  | 34 |  |  |
| 4560 | 1262 | **MBMS - UE Conformance Testing** | 657d? | 2007-06-01 A | 2009-12-04 A | 100% | 2007-06-01 | 2009-12-04 | 657d? |  | R5 | 13848h | 13848h | MBMSE_UEConTest |  |  | Rel-7 | Ingbert |  | MBMSE_UEConTest |  | 40 |  | 21 |
| 4561 | 1262.1 | Conformance Test Aspects – MBMS TDD Physical layer Enhancements – MBSFN for HCR and VHCR TDD | 336d? | 2007-06-01 A | 2008-09-12 A | 100% | 2007-06-01 | 2008-09-12 | 336d? | start no earlier than 2007-06-01 | R5 | 2688h | 2688h | MBMSE-RANPhysTDD_UEConTest | IPWireless | tspeight@ipwireless.com | Rel-7 | Ingbert |  | MBMSE-RANPhysTDD_UEConTest |  |  | RP-080541 |  |
| 4562 | 1262.2 | Conformance Test Aspects – MBMS LCR TDD Physical Layer Enhancement | 342d? | 2008-05-30 A | 2009-09-18 A | 100% | 2008-05-30 | 2009-09-18 | 342d? | finish no earlier than 2009-09-18 | R5 | 2728h | 2728h | MBMSE-RANPhysLCRTDD_UEConTest | CATT | chenxiaozhong@datangmobile.cn | Rel-7 | Ingbert |  | MBMSE-RANPhysLCRTDD_UEConTest |  | 40 | RP-090715 | 21 |
| 4563 | 1262.3 | Conformance Test Aspects – MBSFN for FDD | 397d? | 2008-05-30 A | 2009-12-04 A | 100% | 2008-05-30 | 2009-12-04 | 397d? | finish no earlier than 2009-12-04 | R5 | 3176h | 3176h | MBMSE-UEConTest_RANPhysFDD | Huawei | Xiang Li (trica_li@huawei.com) | Rel-7 | Ingbert |  | MBMSE-UEConTest_RANPhysFDD |  | 40 | RP-091214 | 21 |
| 4564 | 1263 | MBMS User Service Extensions | 392d? | 2005-12-07 A | 2007-06-07 A | 100% | 2005-12-07 | 2007-06-07 | 392d? | finish no earlier than 2007-06-07 | S4 | 3136h | 3136h | MBMSUSE | Ericsson | Thorsten.Lohmar@ericsson.com | Rel-7 | Paolo |  | MBMSUSE |  |  |  |  |
| 4565 | 1264 | **Advanced Global Navigation Satellite System (AGNSS) concept** | 830d? | 2004-06-28 A | 2007-08-31 A | 100% | 2004-06-28 | 2007-08-31 | 830d? |  | S1; S2; GP; R2 | 36129.6h | 36129.6h | LCS3-AGNSS | Alcatel | Michel.monnerat@thalesaleniaspace.com | Rel-7 | Alain |  | LCS3-AGNSS |  |  |  |  |
| 4566 | 1264.1 | Stage 1/2 for Towards AGNSS Concept | 1d? | 2007-02-16 A | 2007-02-16 A | 100% | 2007-02-16 | 2007-02-16 | 1d? | start no earlier than 2007-02-16 | S1; S2 | 16h | 16h | AGNSS | Alcatel | richard.couty@space.alcatel.fr | Rel-7 | Alain |  | AGNSS |  |  |  |  |
| 4567 | 1264.2 | Towards AGNSS Concept | 811.2d? | 2004-06-28 A | 2007-08-31 A | 100% | 2004-06-28 | 2007-08-31 | 811.2d? | finish no earlier than 2007-08-31 | GP | 6489.6h | 6489.6h | AGNSS-GP | Alcatel | richard.couty@space.alcatel.fr | Rel-7 | Paolo |  | AGNSS-GP |  |  |  |  |
| 4568 | 1264.3 | Global Navigation Satellite System (GNSS) in UTRAN | 383d? | 2005-12-15 A | 2007-06-04 A | 100% | 2005-12-15 | 2007-06-04 | 383d? | finish no earlier than 2007-06-04 | R2 | 3064h | 3064h | LCS3-GNSS-UTRAN | France Telecom | alain.abinakhoul@francetelecom.com | Rel-7 | Yong-Jun |  | LCS3-GNSS-UTRAN |  |  | RP-070482 |  |
| 4569 | 1265 | A-GPS Minimum Performance | 351d? | 2006-04-28 A | 2007-08-31 A | 100% | 2006-04-28 | 2007-08-31 | 351d? | finish no earlier than 2007-08-31 | G1; G3 | 5616h | 5616h | GAGR | Spirent | richard.catmur@spirentcom.com | Rel-7 | Paolo |  | GAGR |  |  |  |  |
| 4570 | 1266 | **Unstructured Supplementary Service Data (USSD) message delivery and transfer to USIM** | 376d? | 2004-03-05 A | 2005-08-12 A | 100% | 2004-03-05 | 2005-08-12 | 376d? |  | S1; C6 | 8778.4h | 8778.4h | USSD-USIM | Axalto | Christophe Dubois (cdubois@axalto.com) | Rel-7 | Alain |  | USSD-USIM |  |  |  |  |
| 4571 | 1266.1 | Stage 1 for USSD message delivery and transfer to USIM | 152d? | 2004-03-18 A | 2004-10-15 A | 100% | 2004-03-18 | 2004-10-15 | 152d? | start no earlier than 2004-03-18 | S1 | 1216h | 1216h | USSD-USIM | Axalto | Christophe Dubois (cdubois@axalto.com) | Rel-7 | Alain |  |  |  |  |  |  |
| 4572 | 1266.2 | Alignment with requirements regarding USSD usage | 193.3d? | 2004-03-05 A | 2005-08-12 A | 100% | 2004-03-05 | 2005-08-12 | 193.3d? | finish no earlier than 2005-08-12 | C6 | 1546.4h | 1546.4h | USSD-USIM | Axalto | Christophe Dubois (cdubois@axalto.com) | Rel-7 | Xavier |  |  |  |  |  |  |

Notes:
- 4549: -
- 4550: - / Impacted TSs and TRs: new TR 22.935
- 4551: SP#41 TR withdrawn. All work transferred to specs / Impacted TSs and TRs: 23.837
- 4552: - / Impacted TSs and TRs: 23.234, 23.271, 23.167
- 4553: -
- 4554: -
- 4555: - / Impacted TSs and TRs: 22.146, 22.246, 22.228
- 4556: - / Impacted TSs and TRs: 25.211, 25.212, 25.213, 25.101, 25.104, 25.331, 25.433, 25.346, 25.306
- 4557: - / Impacted TSs and TRs: 25.346, 25.221, 25.222, 25.223, 25.224, 25.306, 25.331, 25.402, 25.433, 25.102, 25.105, 25.123
- 4558: - / Impacted TSs and TRs: 25.346, 25.221, 25.222, 25.223, 25.224, 25.306, 25.331, 25.402, 25.433, 25.102, 25.105, 25.123
- 4559: - / Impacted TSs and TRs: 29.061
- 4560: Linked to Rel-7 Feature UID_31084 (MBMSE)
- 4561: RP#41 completed / Impacted TSs and TRs: 34.108, 34.122, 34.123-1/2/3
- 4562: RP#45 completed / Impacted TSs and TRs: 34.108, 34.123-1
- 4563: RP#46 completed / Impacted TSs and TRs: 34.108, 34.109, 34.121-1, 34.121-2, 34.123-1, 34.123-2, 34.123-3
- 4564: - / Impacted TSs and TRs: 26.346, 26.946
- 4565: -
- 4566: - / Impacted TSs and TRs: 22.071, 23.271
- 4567: GP#36 completed / Impacted TSs and TRs: 43.030, 43.059, 44.031, 44.035, 44.071, 48.008, 48.018, 48.031, 49.031
- 4568: - / Impacted TSs and TRs: 25.305, 25.331, 25.306, 25.413, 25.423, 25.433, 25.453, 25.302, 25.215, 25.401, 25.402, 25.450, 25.452
- 4569: - / Impacted TSs and TRs: 45.005, 51.010
- 4570: -
- 4571: - / Impacted TSs and TRs: 22.090
- 4572: - / Impacted TSs and TRs: 31.111, 31.115, 31.130

| ID | WBS | Task | Type | Duration | Start | Finish | Complete | Baseline start | Baseline finish | Baseline duration | Constraint | Resources | Work | Actual work | Acronym | WI rapporteur name | WI rapporteur e-mail | Release | MCC resp | Acronym_3GU_Export | Impacted TSs and TRs | PCG approved | TSG approved | TSG stopped |
| --- | --- | --- | --- | --- | --- | --- | --- | --- | --- | --- | --- | --- | --- | --- | --- | --- | --- | --- | --- | --- | --- | --- | --- | --- |
| 4573 | 1267 | **Combinational Services** |  | 296d? | 2005-01-17 A | 2006-03-06 A | 100% | 2005-01-17 | 2006-03-06 | 296d? |  | S1; S2; C1; S4 | 14648h | 14648h | CSICS | TeliaSonera | Robert.Frank@teliasonera.com | Rel-7 | Alain | CSICS |  |  |  |  |
| 4574 | 1267.1 | Stage 1 for CSICS |  | 104d? | 2005-01-17 A | 2005-06-09 A | 100% | 2005-01-17 | 2005-06-09 | 104d? | start no earlier than 2005-01-17 | S1 | 832h | 832h | CSICS | TeliaSonera | Robert.Frank@teliasonera.com | Rel-7 | Alain |  | 22.279 |  |  |  |
| 4575 | 1267.2 | Stage 2 for CSICS |  | 130d? | 2005-01-17 A | 2005-07-15 A | 100% | 2005-01-17 | 2005-07-15 | 130d? | start no earlier than 2005-01-17 | S2 | 1040h | 1040h | CSICS | TeliaSonera | Robert.Frank@teliasonera.com | Rel-7 | Maurice |  | 23.279 |  |  |  |
| 4576 | 1267.3 | Stage 3 for CSICS CN aspects |  | 221d? | 2005-05-02 A | 2006-03-06 A | 100% | 2005-05-02 | 2006-03-06 | 221d? | finish no earlier than 2006-03-06 | C1 | 1768h | 1768h | CSICS | Vodafone | peter.dawes@vodafone.com | Rel-7 | Frederic |  | 24.879, 24.279, 24.229, 24.008 |  |  |  |
| 4577 | 1267.4 | Stage 3 for codec aspects |  | 192d? | 2005-03-15 A | 2005-12-07 A | 100% | 2005-03-15 | 2005-12-07 | 192d? | finish no earlier than 2005-12-07 | S4 | 1536h | 1536h | CSICS-Codec | Ericsson | Per.Frojdh@ericsson.com | Rel-7 | Paolo | CSICS-Codec | 26.141, 26.235 |  |  |  |
| 4578 | 1268 | **CAMEL Trunk Triggers** |  | 251d? | 2004-12-17 A | 2005-12-05 A | 100% | 2004-12-17 | 2005-12-05 | 251d? |  | S1; C4 | 8032h | 8032h | TTCAMEL | Nortel | Amar Deol (deola@nortelnetworks.com) | Rel-7 | Alain | TTCAMEL |  |  |  |  |
| 4579 | 1268.1 | Stage 1 for CAMEL Trunk Triggers |  | 251d? | 2004-12-17 A | 2005-12-05 A | 100% | 2004-12-17 | 2005-12-05 | 251d? |  | S1 | 2008h | 2008h | TTCAMEL | Nortel | Amar Deol (deola@nortelnetworks.com) | Rel-7 | Alain |  | 22.078 |  |  |  |
| 4580 | 1268.2 | CAMEL Trunk Originated Trigger Detection Points |  | 251d? | 2004-12-17 A | 2005-12-05 A | 100% | 2004-12-17 | 2005-12-05 | 251d? | start no earlier than 2004-12-17 | C4 | 2008h | 2008h | CamelR7 | Nortel | David Hutton (dhutton@nortel.com) | Rel-7 | Kimmo | CamelR7 |  |  |  |  |
| 4581 | 1269 | **IMS Service Brokering enhancements** |  | 69d? | 2005-12-07 A | 2006-03-13 A | 100% | 2005-12-07 | 2006-03-13 | 69d? |  | S1 | 1104h | 1104h | ISB | Telcordia | jbakker@telcordia.com | Rel-7 | Alain | ISB | 22.228 |  |  |  |
| 4582 | 1269.1 | Stage 1 for ISB |  | 69d? | 2005-12-07 A | 2006-03-13 A | 100% | 2005-12-07 | 2006-03-13 | 69d? | finish no earlier than 2006-03-13 | S1 | 552h | 552h | ISB-s1 | Telcordia | jbakker@telcordia.com | Rel-7 | Alain | ISB-s1 | 22.228 |  |  |  |
| 4583 | 1270 | **Enhancements of VGCS for public authority officials** |  | 731d? | 2004-08-27 A | 2007-06-15 A | 100% | 2004-08-27 | 2007-06-15 | 731d? |  | S1; C1; C4; G2 | 49312h | 49312h | EVGCS |  |  | Rel-7 | Alain | EVGCS | 43.068, 44.068, 24.008, 29.002 | 38 | 75 |  |
| 4584 | 1270.1 | Stage 1 for Enhancements of VGCS for public authority officials | milestone | 0d? | 2004-08-27 A | 2004-08-27 A | 100% | 2004-08-27 | 2004-08-27 | 0d? | finish no earlier than 2004-08-27 | S1 |  |  | EVGCS | Siemens | joerg.swetina@neclab.eu | Rel-7 | Alain |  | 42.068, 43.068 |  |  |  |
| 4585 | 1270.2 | **Architecture and protocol aspects** |  | 731d? | 2004-08-27 A | 2007-06-15 A | 100% | 2004-08-27 | 2007-06-15 | 731d? |  | C1; C4 | 20752h | 20752h | EVGCS | Siemens | robert.zaus@nsn.com | Rel-7 | Frederic |  | 43.068, 44.068 |  |  |  |
| 4586 | 1270.2.1 | CT1 aspects of EVGCS |  | 731d? | 2004-08-27 A | 2007-06-15 A | 100% | 2004-08-27 | 2007-06-15 | 731d? | finish no earlier than 2006-09-15 | C1 | 5848h | 5848h | EVGCS | Siemens | robert.zaus@nsn.com | Rel-7 | Frederic |  | 43.068, 44.068, 24.008 |  |  |  |
| 4587 | 1270.2.2 | CT4 aspects of EVGCS |  | 401d? | 2004-08-27 A | 2006-03-10 A | 100% | 2004-08-27 | 2006-03-10 | 401d? | finish no earlier than 2006-03-10 | C4 | 3208h | 3208h | EVGCS | Siemens | robert.zaus@nsn.com | Rel-7 | Kimmo |  | 29.002 |  |  |  |
| 4588 | 1270.3 | GERAN2 aspects of EVGCS |  | 646d? | 2004-08-27 A | 2007-02-16 A | 100% | 2004-08-27 | 2007-02-16 | 646d? | finish no earlier than 2007-02-16 | G2 | 5168h | 5168h | EVGCS | Siemens | kenneth.isaacs@roke.co.uk | Rel-7 | Gert |  |  | 38 | 75 |  |
| 4589 | 1271 | **Improvements of VGCS for parallel use of services** |  | 523d? | 2005-03-15 A | 2007-03-15 A | 100% | 2005-03-15 | 2007-03-15 | 523d? |  | S1 | 12230.2h | 12230.2h | IVGCS |  |  | Rel-7 | Alain | IVGCS |  |  |  |  |
| 4590 | 1271.1 | Service Requirements for VGCS improvements |  | 62d? | 2005-03-15 A | 2005-06-08 A | 100% | 2005-03-15 | 2005-06-08 | 62d? | finish no earlier than 2005-06-08 | S1 | 496h | 496h | IVGCS | T-Mobile | kurt.bischinger@t-mobile.at | Rel-7 | Alain |  | 42.068 |  |  |  |
| 4591 | 1271.2 | Stage 2 modifications for VGCS improvements |  | 335d? | 2005-12-01 A | 2007-03-14 A | 100% | 2005-12-01 | 2007-03-14 | 335d? | start no earlier than 2005-12-01 | C1 | 2680h | 2680h | IVGCS | T-Mobile | kurt.bischinger@t-mobile.at | Rel-7 | Frederic |  | 43.068 |  |  |  |
| 4592 | 1271.3 | **Protocol aspects** |  | 336d? | 2005-12-01 A | 2007-03-15 A | 100% | 2005-12-01 | 2007-03-15 | 336d? |  | C1 | 5376h | 5376h | IVGCS | T-Mobile | Dieter Jacobsohn | Rel-7 | Frederic |  | 44.068 |  |  |  |
| 4593 | 1271.3.1 | CT1 aspects of IVGCS |  | 336d? | 2005-12-01 A | 2007-03-15 A | 100% | 2005-12-01 | 2007-03-15 | 336d? | finish no earlier than 2007-03-15 | C1 | 2688h | 2688h | IVGCS | T-Mobile |  | Rel-7 | Frederic |  | 43.068, 44.068 |  |  |  |
| 4594 | 1271.3.2 | Deleted - CT4 aspects of IVGCS | milestone | 0d? | 2007-03-09 A | 2007-03-09 A | 100% | 2007-03-09 | 2007-03-09 | 0d? | finish no earlier than 2007-03-09 | C4 |  |  | IVGCS-St3-c4 | T-mobile |  | Rel-7 | Kimmo | IVGCS-St3-c4 | 29.002 |  |  | CP-35 |
| 4595 | 1272 | **Open Service Access (OSA) Rel-7** |  | 584d? | 2005-03-15 A | 2007-06-08 A | 100% | 2005-03-15 | 2007-06-08 | 584d? |  | S1; C5 | 29776h | 29776h | OSA7 | AePONA | eamonn.murray@aepona.com | Rel-7 | Alain | OSA7 |  |  |  |  |
| 4596 | 1272.1 | **OSA Service Broker** |  | 449d? | 2005-03-15 A | 2006-12-01 A | 100% | 2005-03-15 | 2006-12-01 | 449d? |  | S1; C5 | 10176h | 10176h | OSA7-SB | AePONA | eamonn.murray@aepona.com | Rel-7 | Alain | OSA7-SB |  |  |  |  |
| 4597 | 1272.1.1 | Service Requirements for OSA Service Broker |  | 62d? | 2005-03-15 A | 2005-06-08 A | 100% | 2005-03-15 | 2005-06-08 | 62d? | finish no earlier than 2005-06-08 | S1 | 496h | 496h | OSA7 | AePONA | eamonn.murray@aepona.com | Rel-7 | Alain |  | 22.127 |  |  |  |
| 4598 | 1272.1.2 | Stage 2 OSA API Service Brokering |  | 156d? | 2006-04-28 A | 2006-12-01 A | 100% | 2006-04-28 | 2006-12-01 | 156d? |  | C5 | 1248h | 1248h | OSA7 | AePONA | damian.oneill@aepona.com | Rel-7 | Kimmo |  | 23.198 |  |  |  |
| 4599 | 1272.1.3 | Stage 3 OSA API Service Brokering |  | 156d? | 2006-04-28 A | 2006-12-01 A | 100% | 2006-04-28 | 2006-12-01 | 156d? | finish no earlier than 2006-12-01 | C5 | 1248h | 1248h | OSA7 | AePONA | damian.oneill@aepona.com | Rel-7 | Kimmo |  | 29.198-16 |  |  |  |

Notes:
- 4573: -
- 4574: -
- 4575: -
- 4576: -
- 4577: -
- 4578: -
- 4579: -
- 4580: -
- 4581: No CR submitted in rel-8 (according to CR database).
- 4582: No Rel-8 changes
- 4583: Moved from Rel-6 UID_50563 Enhancements of VGCS in public networks for communication of public authority officials
- 4584: Voice Group Call Service
- 4585: -
- 4586: -
- 4587: -
- 4588: -
- 4589: Voice Group Call Service
- 4590: -
- 4591: -
- 4592: Previous name (before CT32) was Architecture and protocol aspects
- 4593: -
- 4594: CT4#33 stage 2 solution is still open.
- 4595: -
- 4596: -
- 4597: -
- 4598: -
- 4599: -

| ID | WBS | Task | Type | Duration | Start | Finish | Complete | Baseline start | Baseline finish | Baseline duration | Constraint | Resources | Work | Actual work | Acronym | Impacted TSs and TRs | WI rapporteur name | WI rapporteur e-mail | Release | MCC resp | TSG approved | Acronym_3GU_Export | TSG stopped | Status Report |
| --- | --- | --- | --- | --- | --- | --- | --- | --- | --- | --- | --- | --- | --- | --- | --- | --- | --- | --- | --- | --- | --- | --- | --- | --- |
| 4600 | 1272.2 | **Rel-7 OSA Stage 2/3 enhancements** |  | 291d? | 2006-04-28 A | 2007-06-08 A | 100% | 2006-04-28 | 2007-06-08 | 291d? |  | C5 | 10256h | 10256h | OSA7 | 29.198/9, 23.198 | AePONA | damian.oneill@aepona.com | Rel-7 | Kimmo |  |  |  |  |
| 4601 | 1272.2.1 | Parlay X Message Broadcast Web Service |  | 156d? | 2006-04-28 A | 2006-12-01 A | 100% | 2006-04-28 | 2006-12-01 | 156d? | finish no earlier than 2006-12-01 | C5 | 1248h | 1248h | OSA7 | 29.199-15, 23.198 | ETRI |  | Rel-7 | Kimmo |  |  |  |  |
| 4602 | 1272.2.2 | Parlay X Geocoding Web Service |  | 156d? | 2006-04-28 A | 2006-12-01 A | 100% | 2006-04-28 | 2006-12-01 | 156d? | finish no earlier than 2006-12-01 | C5 | 1248h | 1248h | OSA7 | 29.199-16, 23.198 | ETRI |  | Rel-7 | Kimmo |  |  |  |  |
| 4603 | 1272.2.3 | Parlay X Application driven QoS Web Service |  | 226d? | 2006-04-28 A | 2007-03-09 A | 100% | 2006-04-28 | 2007-03-09 | 226d? | finish no earlier than 2007-03-09 | C5 | 1808h | 1808h | OSA7 | 29.199-17, 23.198 | BT |  | Rel-7 | Kimmo |  |  |  |  |
| 4604 | 1272.2.4 | Parlay-X Device Capabilities and Configuration |  | 162d? | 2006-10-26 A | 2007-06-08 A | 100% | 2006-10-26 | 2007-06-08 | 162d? | finish no earlier than 2007-06-09 | C5 | 1296h | 1296h | OSA7 | 29.199-18, 23.198 | Telenor |  | Rel-7 | Kimmo | 34 |  |  |  |
| 4605 | 1272.2.5 | Parlay-X Multimedia Streaming Session Management Web Service |  | 97d? | 2006-10-26 A | 2007-03-09 A | 100% | 2006-10-26 | 2007-03-09 | 97d? | start no earlier than 2006-10-26 | C5 | 776h | 776h | OSA7 | 29.199-19, 23.198 | Telenor |  | Rel-7 | Kimmo | 34 |  |  |  |
| 4606 | 1272.2.6 | Parlay-X Multimedia Multicast Control Web Service |  | 97d? | 2006-10-26 A | 2007-03-09 A | 100% | 2006-10-26 | 2007-03-09 | 97d? | start no earlier than 2006-10-26 | C5 | 776h | 776h | OSA7 | 29.199-20, 23.198 | ETRI |  | Rel-7 | Kimmo | 34 |  |  |  |
| 4607 | 1272.2.7 | OSA API Conference Call Control SCF |  | 97d? | 2006-10-26 A | 2007-03-09 A | 100% | 2006-10-26 | 2007-03-09 | 97d? | start no earlier than 2006-10-26 | C5 | 776h | 776h | OSA7 | 29.198-04-5, 23.198 | Ericsson |  | Rel-7 | Kimmo | 34 |  |  |  |
| 4608 | 1273 | **Selective Disabling of UE Capabilities** |  | 624.36d? | 2005-01-24 A | 2007-06-15 A | 100% | 2005-01-24 | 2007-06-15 | 624.36d? |  | S1; S2; C1 | 22341.5h | 22341.5h | SDoUE |  | Motorola |  | Rel-7 | Alain |  | SDoUE |  |  |
| 4609 | 1273.1 | Stage 1 of SDoUE |  | 393.6d? | 2005-01-24 A | 2006-12-08 A | 100% | 2005-01-24 | 2006-12-08 | 393.6d? | finish no earlier than 2006-12-08 | S1 | 3148.8h | 3148.8h | SDoUE-CR | 22.011 | Motorola |  | Rel-7 | Alain |  | SDoUE-CR |  |  |
| 4610 | 1273.2 | Deleted - TR on different possible architectures |  | 195d? | 2005-03-21 A | 2005-12-16 A | 100% | 2005-03-21 | 2005-12-16 | 195d? | finish no earlier than 2005-12-16 | S2 | 1560h | 1560h | SDoUE-FS | 23.805 abandonned at SP-30; descendant C1 24.305 | Vodafone | Gavin.Wong@vodafone.com | Rel-7 | Maurice |  | SDoUE-FS | SP-30 |  |
| 4611 | 1273.3 | Stage 3 of SDoUE |  | 331d? | 2006-03-10 A | 2007-06-15 A | 100% | 2006-03-10 | 2007-06-15 | 331d? | finish no earlier than 2007-06-15 | C1 | 2648h | 2648h | SDoUE | 24.305 | Ericsson | christian.herrero@ericsson.com | Rel-7 | Frederic |  |  |  |  |
| 4612 | 1274 | **Network selection enhancements (NSP)** |  | 328d? | 2006-03-15 A | 2007-06-15 A | 100% | 2006-03-15 | 2007-06-15 | 328d? |  | S1 | 6320h | 6320h | NSP |  | O2 | chris.friel@O2.com | Rel-7 | Alain |  | NSP |  |  |
| 4613 | 1274.1 | Stage 1 of NSP |  | 191d? | 2006-03-15 A | 2006-12-06 A | 100% | 2006-03-15 | 2006-12-06 | 191d? | start no earlier than 2006-03-15 | S1 | 1528h | 1528h | NSP-TS | 22.101, 22.011, 23.122, 24.008, 25.304, 31.102, 45.008 | O2 | chris.friel@O2.com | Rel-7 | Alain |  | NSP-TS |  |  |
| 4614 | 1274.2 | Procedural aspects of NSP |  | 271d? | 2006-06-02 A | 2007-06-15 A | 100% | 2006-06-02 | 2007-06-15 | 271d? | finish no earlier than 2007-06-15 | C1 | 2168h | 2168h | NSP-CR | 23.122, 24.008, 31.102 | Motorola | Andrew Howell | Rel-7 | Frederic |  | NSP-CR |  |  |
| 4615 | 1275 | Network selection enhancements (NSP) - UE Conformance Testing |  | 396d? | 2007-06-01 A | 2008-12-05 A | 100% | 2007-06-01 | 2008-12-05 | 396d? | finish no earlier than 2008-12-05 | R5 | 3168h | 3168h | NSP-CR_UEConTest | 34.108, 34.123-1, 34.123-2, 34.123-3 | Nokia | jarkko.hellsten@nokia.com | Rel-7 | Ingbert |  | NSP-CR_UEConTest |  | RP-080819 |
| 4616 | 1276 | **Access Class Barring and Overload Protection** |  | 650d? | 2004-03-15 A | 2006-09-08 A | 100% | 2004-03-15 | 2006-09-08 | 650d? |  | S2; C1 | 13968h | 13968h | ACBOP | 23.898 | Vodafone | chris.pudney@vodafone.com | Rel-7 | Maurice |  | ACBOP |  |  |
| 4617 | 1276.1 | TR on Stage 2 |  | 274d? | 2004-03-15 A | 2005-03-31 A | 100% | 2004-03-15 | 2005-03-31 | 274d? | finish no earlier than 2005-03-31 | S2 | 2192h | 2192h | ACBOP | 23.898 | NTT DoCoMo | Jean-Jacques Davidian (davidian@docomo.fr) | Rel-7 | Maurice |  |  |  |  |
| 4618 | 1276.2 | Stage 3 CN aspects of ACBOP |  | 172d? | 2005-06-06 A | 2006-01-31 A | 100% | 2005-06-06 | 2006-01-31 | 172d? | start no earlier than 2005-06-06 | C1 | 1376h | 1376h | ACBOP | 24.008 |  |  | Rel-7 | Frederic |  |  |  |  |
| 4619 | 1276.3 | Deleted - Potential impact on Iu interface Overload functionality | milestone | 0d? | 2004-03-15 A | 2004-03-15 A | 100% | 2004-03-15 | 2004-03-15 | 0d? | finish no earlier than 2004-03-15 | RP |  |  | ACBOP | 25.413 |  |  | Rel-7 | Issam |  |  | RP-25 |  |
| 4620 | 1276.4 | Deleted - Extra ACBOP information in RAN | milestone | 0d? | 2004-03-15 A | 2004-03-15 A | 100% | 2004-03-15 | 2004-03-15 | 0d? | finish no earlier than 2004-03-15 | RP |  |  | ACBOP | 25.331 |  |  | Rel-7 | Issam |  |  | RP-25 |  |
| 4621 | 1276.5 | Deleted - Extra ACBOP information in GERAN | milestone | 0d? | 2006-09-08 A | 2006-09-08 A | 100% | 2006-09-08 | 2006-09-08 | 0d? | start no earlier than 2006-09-08 | GP |  |  | ACBOP | 44.018 |  |  | Rel-7 | Paolo |  |  | RP-33 |  |
| 4622 | 1277 | **System enhancements for Fixed Broadband access to IMS** |  | 2117d? | 2003-11-05 A | 2011-12-09 A | 100% | 2003-11-05 | 2011-12-09 | 2117d? |  | S2; S3; S5; C1; C3; C4; IETF | 369944h | 369944h | FBI |  |  |  | Rel-7 | Maurice |  | FBI |  |  |
| 4623 | 1277.1 | **TISPAN Rel 1 related aspects** |  | 2117d? | 2003-11-05 A | 2011-12-09 A | 100% | 2003-11-05 | 2011-12-09 | 2117d? |  | S2; S3; C1; C3; C4; IETF | 239320h | 239320h | FBI-TIS1 |  |  |  | Rel-7 | Maurice |  | FBI-TIS1 |  |  |
| 4624 | 1277.1.1 | Stage 2 of FBI for TISPAN R1 |  | 365d? | 2004-10-14 A | 2006-03-08 A | 100% | 2004-10-14 | 2006-03-08 | 365d? | start no earlier than 2004-10-14 | S2 | 2920h | 2920h |  |  |  |  | Rel-7 | Maurice |  |  |  |  |

Notes:
- 4600: CP#34 updated WID CP-060607=>CP-070200
- 4601: -
- 4602: -
- 4603: -
- 4604: -
- 4605: -
- 4606: -
- 4607: -
- 4608: Moved from FS section Feb 06
- 4609: Moved from FS section Feb 06
- 4610: Moved from FS section Feb 06. Abandoned at SP-30
- 4611: -
- 4612: -
- 4613: -
- 4614: -
- 4615: RP#42 completed. Testing for Feature UID_7041 (NSP-CR)
- 4616: -
- 4617: -
- 4618: -
- 4619: -
- 4620: -
- 4621: -
- 4622: -
- 4623: -
- 4624: -

| ID | WBS | Task | Duration | Start | Finish | Complete | Baseline start | Baseline finish | Baseline duration | Constraint | Resources | Work | Actual work | WI rapporteur name | WI rapporteur e-mail | Release | MCC resp | PCG approved | TSG approved | Acronym | Acronym_3GU_Export | Special Focus Doc | TSG stopped |
| --- | --- | --- | --- | --- | --- | --- | --- | --- | --- | --- | --- | --- | --- | --- | --- | --- | --- | --- | --- | --- | --- | --- | --- |
| 4625 | 1277.1.2 | **Protocol impact of FBI for TISPAN R1** | 2117d? | 2003-11-05 A | 2011-12-09 A | 100% | 2003-11-05 | 2011-12-09 | 2117d? |  | S3; C1; C3; C4; IETF | 133840h | 133840h | Siemens | peter.leis@nsn.com | Rel-7 | Frederic |  |  |  |  |  |  |
| 4626 | 1277.1.2.1 | (IETF) CT aspects of FBI for TISPAN R1 | 2117d? | 2003-11-05 A | 2011-12-09 A | 100% | 2003-11-05 | 2011-12-09 | 2117d? | start no earlier than 2003-11-05 | C1-IETF; C3-IETF | 33872h | 33872h | Roland Jesske |  | Rel-7 | Frederic | 27 | 52 |  |  |  |  |
| 4627 | 1277.1.2.2 | CT1 aspects of FBI for TISPAN R1 | 802d? | 2003-11-05 A | 2006-11-30 A | 100% | 2003-11-05 | 2006-11-30 | 802d? | finish no earlier than 2006-11-30 | C1 | 6416h | 6416h | Siemens | peter.leis@nsn.com | Rel-7 | Frederic |  |  |  |  |  |  |
| 4628 | 1277.1.2.3 | CT3 aspects of FBI for TISPAN R1 | 808d? | 2003-11-05 A | 2006-12-08 A | 100% | 2003-11-05 | 2006-12-08 | 808d? | finish no earlier than 2006-12-08 | C3 | 6464h | 6464h | Siemens | peter.leis@nsn.com | Rel-7 | Adrian |  |  |  |  |  |  |
| 4629 | 1277.1.2.4 | CT4 aspects of FBI for TISPAN R1 | 301d? | 2006-01-13 A | 2007-03-09 A | 100% | 2006-01-13 | 2007-03-09 | 301d? | finish no earlier than 2007-03-09 | C4 | 2408h | 2408h | Siemens | peter.leis@nsn.com | Rel-7 | Kimmo |  |  | FBI-TIS1-st3-c4 | FBI-TIS1-st3-c4 |  |  |
| 4630 | 1277.1.3 | Security Enhancements for FBI | 118d? | 2005-06-28 A | 2005-12-08 A | 100% | 2005-06-28 | 2005-12-08 | 118d? | start no earlier than 2005-06-28 | S3 | 944h | 944h | Ericsson | Bengt.Sahlin@ericsson.com | Rel-7 | Mirko |  |  | FBI-ISE | FBI-ISE |  |  |
| 4631 | 1277.2 | **PacketCable Related aspects** | 291d? | 2006-02-01 A | 2007-03-14 A | 100% | 2006-02-01 | 2007-03-14 | 291d? |  | S2; S5; C1 | 12072h | 12072h | CableLabs | Bernie McKibben (b.mckibben@cablelabs.com) | Rel-7 | Maurice |  |  | FBI-PCBL | FBI-PCBL |  |  |
| 4632 | 1277.2.1 | Stage 1,2 of FBI for PacketCable | 228d? | 2006-02-01 A | 2006-12-15 A | 100% | 2006-02-01 | 2006-12-15 | 228d? | finish no earlier than 2006-12-15 | S2 | 1824h | 1824h | CableLabs | Bernie McKibben (b.mckibben@cablelabs.com) | Rel-7 | Maurice |  |  |  |  |  |  |
| 4633 | 1277.2.2 | Protocol impact of FBI for PacketCable | 228d? | 2006-05-01 A | 2007-03-14 A | 100% | 2006-05-01 | 2007-03-14 | 228d? | finish no earlier than 2007-03-15 | C1 | 1824h | 1824h |  |  | Rel-7 | Frederic |  |  |  |  |  |  |
| 4634 | 1277.2.3 | SA5 Charging aspects of FBI for PacketCable | 180d? | 2006-03-31 A | 2006-12-07 A | 100% | 2006-03-31 | 2006-12-07 | 180d? | finish no earlier than 2006-12-07 | S5 | 1440h | 1440h | CableLabs | Bernie McKibben (b.mckibben@cablelabs.com) | Rel-7 | Mirko |  |  | FBI-PCBL-CH | FBI-PCBL-CH |  |  |
| 4635 | 1278 | **Support of SMS over generic 3GPP IP access** | 696d? | 2004-10-14 A | 2007-06-14 A | 100% | 2004-10-14 | 2007-06-14 | 696d? |  | S2; C4; C1 | 37544h | 37544h | Huawei | zhangwenlin@huawei.com | Rel-7 | Maurice |  |  | SMSIP | SMSIP | WLAN |  |
| 4636 | 1278.1 | FS on SMSIP | 173d? | 2004-10-14 A | 2005-06-13 A | 100% | 2004-10-14 | 2005-06-13 | 173d? | start no earlier than 2004-10-14 | S2 | 1384h | 1384h | Huawei | zhangwenlin@huawei.com | Rel-7 | Maurice |  |  |  |  | WLAN |  |
| 4637 | 1278.2 | Stage 2 for SMSIP | 333d? | 2005-06-08 A | 2006-09-15 A | 100% | 2005-06-08 | 2006-09-15 | 333d? | finish no earlier than 2006-09-15 | S2 | 2664h | 2664h | Huawei | zhangwenlin@huawei.com | Rel-7 | Maurice |  |  |  |  | WLAN |  |
| 4638 | 1278.3 | **Stage 3 for SMSIP** | 527d? | 2005-06-08 A | 2007-06-14 A | 100% | 2005-06-08 | 2007-06-14 | 527d? |  | C4; C1 | 16792h | 16792h | Nokia | jari.jansson@nokia.com | Rel-7 | Kimmo |  |  | SMSIP-St3 | SMSIP-St3 | WLAN |  |
| 4639 | 1278.3.1 | CT1 aspects for SMSIP | 527d? | 2005-06-08 A | 2007-06-14 A | 100% | 2005-06-08 | 2007-06-14 | 527d? | finish no earlier than 2007-06-15 | C1 | 4216h | 4216h | Nokia | jari.jansson@nokia.com | Rel-7 | Frederic |  |  |  |  | WLAN |  |
| 4640 | 1278.3.2 | CT4 aspects for SMSIP | 518d? | 2005-06-08 A | 2007-06-01 A | 100% | 2005-06-08 | 2007-06-01 | 518d? | finish no earlier than 2007-06-01 | C4 | 4144h | 4144h | Nokia | jari.jansson@nokia.com | Rel-7 | Kimmo |  |  | SMSIP-St3-c4 | SMSIP-St3-c4 | WLAN |  |
| 4641 | 1279 | **Evolution of Policy Control and Charging** | 817d? | 2004-10-14 A | 2007-11-30 A | 100% | 2004-10-14 | 2007-11-30 | 817d? |  | S2; S5; C3; C1 | 54112h | 54112h | Nokia | balazs.bertenyi@nsn.com | Rel-7 | Maurice |  |  | PCC | PCC |  |  |
| 4642 | 1279.1 | Deleted - TR for PCC | 315d? | 2004-10-14 A | 2005-12-29 A | 100% | 2004-10-14 | 2005-12-29 | 315d? | finish no earlier than 2005-12-28 | S2 | 2520h | 2520h | Nokia | balazs.bertenyi@nsn.com | Rel-7 | Maurice |  |  |  |  |  | SP-33 |
| 4643 | 1279.2 | Stage 2 for PCC | 315d? | 2005-07-04 A | 2006-09-15 A | 100% | 2005-07-04 | 2006-09-15 | 315d? | finish no earlier than 2006-09-15 | S2 | 2520h | 2520h | Nokia | balazs.bertenyi@nsn.com | Rel-7 | Maurice |  |  |  |  |  |  |
| 4644 | 1279.3 | Evolution of policy control and flow based bearer level charging | 109d? | 2006-08-01 A | 2006-12-29 A | 100% | 2006-08-01 | 2006-12-29 | 109d? | start no earlier than 2006-08-01 | S2 | 872h | 872h | Nokia | balazs.bertenyi@nsn.com | Rel-7 | Maurice |  |  |  |  |  |  |
| 4645 | 1279.4 | SA5 Charging aspects of PCC | 316d? | 2006-03-31 A | 2007-06-15 A | 100% | 2006-03-31 | 2007-06-15 | 316d? | finish no earlier than 2007-06-15 | S5 | 2528h | 2528h | Orange | alain.bibas@orange-ft.com | Rel-7 | Mirko |  |  | PCC-CH | PCC-CH |  |  |
| 4646 | 1279.5 | Gx reference point for Policy and Charging Control | 521d? | 2005-12-02 A | 2007-11-30 A | 100% | 2005-12-02 | 2007-11-30 | 521d? | finish no earlier than 2007-09-14 | C3 | 4168h | 4168h | Siemens | Thomas.Belling@nsn.com | Rel-7 | Adrian |  |  | PCC-Gx | PCC-Gx |  |  |
| 4647 | 1279.6 | **Rx reference point for PCC CT3 aspects** | 521d? | 2005-12-02 A | 2007-11-30 A | 100% | 2005-12-02 | 2007-11-30 | 521d? |  | C3; C1 | 15360h | 15360h | Ericsson | j.javier.pastor@ericsson.com | Rel-7 | Adrian |  |  | PCC-Rx | PCC-Rx |  |  |
| 4648 | 1279.6.1 | PCC-Rx CT3 aspects | 521d? | 2005-12-02 A | 2007-11-30 A | 100% | 2005-12-02 | 2007-11-30 | 521d? | finish no earlier than 2007-09-14 | C3 | 4168h | 4168h | Ericsson | j.javier.pastor@ericsson.com | Rel-7 | Adrian |  |  | PCC-Rx-c3 | PCC-Rx-c3 |  |  |
| 4649 | 1279.6.2 | PCC-Rx CT1 aspects | 357d? | 2005-12-02 A | 2007-06-15 A | 100% | 2005-12-02 | 2007-06-15 | 357d? | finish no earlier than 2007-06-15 | C1 | 2856h | 2856h | Ericsson | j.javier.pastor@ericsson.com | Rel-7 | Frederic |  |  | PCC-Rx-Gx-c1 | PCC-Rx-Gx-c1 |  |  |

Notes:
- 4625: -
- 4626: CP#54 completed / Impacted TSs and TRs: RFC 6432 (was draft-jesske-dispatch-update3326-reason-responses)
- 4627: - / Impacted TSs and TRs: 24.819, 24.229
- 4628: - / Impacted TSs and TRs: 29.163, 29.209
- 4629: CT4#32: a set of CRs on FBI for cable labs / Impacted TSs and TRs: 29.229
- 4630: Duplicated entry ("ACCSEC2", "Access Security Enhancements", SP-040865) deleted by A.Sultan / Impacted TSs and TRs: 33.203
- 4631: -
- 4632: - / Impacted TSs and TRs: 22.228, 23.228
- 4633: -
- 4634: 03/2006 SP#31 WID approved / Impacted TSs and TRs: 32.240, 32.260, 32.298, 32.299
- 4635: SP#33 updated WID (removed MMS)
- 4636: SP#33 updated WID / Impacted TSs and TRs: 23.804
- 4637: SP#33 updated WID / Impacted TSs and TRs: 23.204
- 4638: CP#34 updated WID
- 4639: CP#34 updated WID / Impacted TSs and TRs: 23.040, 24.229
- 4640: CP#34 updated WID / Impacted TSs and TRs: 23.008, 29.002
- 4641: SP-29 approved WID. SP-31 updated WID adding SA5 charging. 23.125 will be discontinued from Rel-7.
- 4642: SP-30: S2 has no intention for TR completion / Impacted TSs and TRs: 23.803
- 4643: SP-29 approved WID. SP-31 updated WID. 23.125 will be discontinued from Rel-7. / Impacted TSs and TRs: 23.203
- 4644: SP-29 approved WID. SP-31 updated WID. 23.125 will be discontinued from Rel-7. / Impacted TSs and TRs: 23.207, 23.002, 23.228
- 4645: SP-31 updated WID with SA5 charging. / Impacted TSs and TRs: 32.250, 32.251, 32.298, 32.299
- 4646: - / Impacted TSs and TRs: 29.212 (not progressed to Rel-7: 29.210, 29.207, 29.208)
- 4647: WID approved at CP#30, Revised at CP#31, Revised at CP#33
- 4648: - / Impacted TSs and TRs: 29.213, 29.214 (not progressed to Rel-7: 29.209, 29.211)
- 4649: - / Impacted TSs and TRs: 24.229

| ID | WBS | Task | Type | Duration | Start | Finish | Complete | Baseline start | Baseline finish | Baseline duration | Constraint | Resources | Work | Actual work | Acronym | WI rapporteur name | WI rapporteur e-mail | Release | MCC resp | Special Focus Doc | Acronym_3GU_Export | Impacted TSs and TRs | TSG stopped | TSG approved |
| --- | --- | --- | --- | --- | --- | --- | --- | --- | --- | --- | --- | --- | --- | --- | --- | --- | --- | --- | --- | --- | --- | --- | --- | --- |
| 4650 | 1280 | **Voice Call Continuity between CS and IMS (incl. I-WLAN)** |  | 641d? | 2004-12-31 A | 2007-06-15 A | 100% | 2004-12-31 | 2007-06-15 | 641d? |  | S2; S1; S5; C1; C4 | 43592h | 43592h | VCC | Alcatel-Lucent | Keith Drage (drage@alcatel-lucent.com) | Rel-7 | Maurice | WLAN | VCC |  |  |  |
| 4651 | 1280.1 | TR for Voice Call Continuity between CS and IMS (incl. I-WLAN) |  | 245d? | 2004-12-31 A | 2005-12-08 A | 100% | 2004-12-31 | 2005-12-08 | 245d? | finish no earlier than 2005-12-08 | S2 | 1960h | 1960h |  | Alcatel-Lucent | andy.bennett@alcatel-lucent.com | Rel-7 | Maurice | WLAN |  | 23.806 |  |  |
| 4652 | 1280.2 | Stage 1 for Voice Call Continuity between CS and IMS (incl. I-WLAN) |  | 140d? | 2005-03-17 A | 2005-09-28 A | 100% | 2005-03-17 | 2005-09-28 | 140d? | finish no earlier than 2005-09-28 | S1 | 1120h | 1120h |  | Alcatel-Lucent | andy.bennett@alcatel-lucent.com | Rel-7 | Alain | WLAN |  | 22.101 |  |  |
| 4653 | 1280.3 | Stage 2 for Voice Call Continuity between CS and IMS (incl. I-WLAN) |  | 264d? | 2005-09-06 A | 2006-09-08 A | 100% | 2005-09-06 | 2006-09-08 | 264d? | finish no earlier than 2006-09-08 | S2 | 2112h | 2112h |  | Alcatel-Lucent | andy.bennett@alcatel-lucent.com | Rel-7 | Maurice | WLAN |  | 23.206 |  |  |
| 4654 | 1280.4 | SA5 Charging for Voice Call Continuity between CS and IMS (incl. I-WLAN) |  | 325d? | 2006-03-17 A | 2007-06-14 A | 100% | 2006-03-17 | 2007-06-14 | 325d? | finish no earlier than 2007-06-14 | S5 | 2600h | 2600h | VCC-CH | Orange | alain.bibas@orange-ft.com | Rel-7 | Mirko | WLAN | VCC-CH | 32.250, 32.260 |  |  |
| 4655 | 1280.5 | **Stage 3 for Voice Call Continuity between CS and IMS (incl. I-WLAN)** |  | 358d? | 2006-02-01 A | 2007-06-15 A | 100% | 2006-02-01 | 2007-06-15 | 358d? |  | C1; C4 | 10160h | 10160h |  | Alcatel-Lucent | Keith Drage (drage@alcatel-lucent.com) | Rel-7 | Frederic | WLAN |  |  |  |  |
| 4656 | 1280.5.1 | CT1 aspects of Stage 3 for Voice Call Continuity between CS and IMS (incl. I-WLAN) |  | 358d? | 2006-02-01 A | 2007-06-15 A | 100% | 2006-02-01 | 2007-06-15 | 358d? | finish no earlier than 2007-06-15 | C1 | 2864h | 2864h |  | Alcatel-Lucent | Keith Drage (drage@alcatel-lucent.com) | Rel-7 | Frederic | WLAN |  | 24.206, 24.216 |  |  |
| 4657 | 1280.5.2 | CT4 aspects of Stage 3 for Voice Call Continuity between CS and IMS (incl. I-WLAN) |  | 196d? | 2006-06-09 A | 2007-03-09 A | 100% | 2006-06-09 | 2007-03-09 | 196d? | start no earlier than 2006-06-09 | C4 | 1568h | 1568h | VCC-St3-c4 | Alcatel-Lucent | Keith Drage (drage@alcatel-lucent.com) | Rel-7 | Kimmo | WLAN | VCC-St3-c4 | 23.003 |  |  |
| 4658 | 1280.5.3 | Deleted - CT3 aspects of Stage 3 for Voice Call Continuity between CS and IMS (incl. I-WLAN) | milestone | 0d? | 2006-11-02 A | 2006-11-02 A | 100% | 2006-11-02 | 2006-11-02 | 0d? | finish no earlier than 2006-11-02 | C3 |  |  |  | Alcatel-Lucent | Keith Drage (drage@alcatel-lucent.com) | Rel-7 | Adrian | WLAN |  | 29.163 | CP-33 |  |
| 4659 | 1281 | **One Tunnel solution for optimization of Packet Data Traffic** |  | 418d? | 2006-03-27 A | 2007-10-31 A | 100% | 2006-03-27 | 2007-10-31 | 418d? |  | S2 | 7048h | 7048h | OPTUNEL | Nokia | antti.j.pasanen@nokia.com | Rel-7 | Maurice |  | OPTUNEL |  |  |  |
| 4660 | 1281.1 | Deleted - Study on Stage 2 for One Tunnel solution |  | 125d? | 2006-03-27 A | 2006-09-15 A | 100% | 2006-03-27 | 2006-09-15 | 125d? | finish no earlier than 2005-09-12 | S2 | 1000h | 1000h | OPTUNEL-Study | Nokia | antti.j.pasanen@nokia.com | Rel-7 | Maurice |  | OPTUNEL-Study | 23.809 | SP-34 |  |
| 4661 | 1281.2 | One Tunnel Deployment Guideline |  | 268d? | 2006-10-23 A | 2007-10-31 A | 100% | 2006-10-23 | 2007-10-31 | 268d? | finish no earlier than 2007-10-31 | S2 | 2144h | 2144h | OPTUNEL-Guide | Huawei | lan.liu@huawei.com | Rel-7 | Maurice |  | OPTUNEL-Guide | 23.919 |  | 34 |
| 4662 | 1281.3 | Stage 2 specification for One Tunnel solution |  | 70d? | 2006-09-11 A | 2006-12-15 A | 100% | 2006-09-11 | 2006-12-15 | 70d? | finish no earlier than 2006-12-15 | S2 | 560h | 560h | OPTUNEL-Stage2 | Nokia | antti.j.pasanen@nokia.com | Rel-7 | Maurice |  | OPTUNEL-Stage2 | 23.060 |  |  |
| 4663 | 1282 | **CSI Terminating Session handling** |  | 267d? | 2006-06-08 A | 2007-06-15 A | 100% | 2006-06-08 | 2007-06-15 | 267d? |  | S2; C1 | 6864h | 6864h | CSItermS | Samsung | Osok Song | Rel-7 | Maurice |  | CSItermS |  |  |  |
| 4664 | 1282.1 | Stage 2 of CStermS |  | 192d? | 2006-06-08 A | 2007-03-02 A | 100% | 2006-06-08 | 2007-03-02 | 192d? | start no earlier than 2006-06-08 | S2 | 1536h | 1536h |  | Samsung | Osok Song | Rel-7 | Maurice |  |  | 23.279 |  | 34 |
| 4665 | 1282.2 | Stage 3 of CStermS |  | 132d? | 2006-12-14 A | 2007-06-15 A | 100% | 2006-12-14 | 2007-06-15 | 132d? | finish no earlier than 2007-06-15 | C1 | 1056h | 1056h |  | Samsung | chenho.chin@samsung.com | Rel-7 | Frederic |  |  | 24.229, 24.279 |  | 34 |
| 4666 | 1282.3 | Deleted - duplicated with UID 340015 -Stage 3 CSI Terminating Session handling | milestone | 0d? | 2007-03-09 A | 2007-03-09 A | 100% | 2007-03-09 | 2007-03-09 | 0d? | start no earlier than 2007-03-09 | C1 |  |  |  | Samsung | chenho.chin@samsung.com | Rel-7 | Frederic |  |  | 24.229, 24.179, 24.279 | CP-34 | 34 |
| 4667 | 1283 | Liberty Alliance and 3GPP Security Interworking |  | 451d? | 2005-03-10 A | 2006-11-30 A | 100% | 2005-03-10 | 2006-11-30 | 451d? | finish no earlier than 2006-11-30 | S3 | 3608h | 3608h | LibSec | Nokia | Silke.Holtmanns@nokia.com | Rel-7 | Mirko |  | LibSec | 33.980 |  |  |
| 4668 | 1284 | Trust Requirements for Open Platforms in 3GPP |  | 499d? | 2005-01-03 A | 2006-11-30 A | 100% | 2005-01-03 | 2006-11-30 | 499d? | finish no earlier than 2006-11-30 | S3 | 3992h | 3992h | TrustOP | Nokia | Silke.Holtmanns@nokia.com | Rel-7 | Mirko |  | TrustOP | 33.905 |  |  |
| 4669 | 1285 | Development of UEA2 and UIA2 |  | 268d? | 2004-12-01 A | 2005-12-09 A | 100% | 2004-12-01 | 2005-12-09 | 268d? | finish no earlier than 2005-12-09 | S3 | 2144h | 2144h | AlgUEA2 | TeliaSonera | per.christoffersson@teliasonera.com | Rel-7 | Mirko |  | AlgUEA2 | 35.919, 35.215, 35.216, 35.217, 35.218 |  |  |
| 4670 | 1286 | Lawful Interception in the 3GPP Rel-7 architecture |  | 118d? | 2005-06-28 A | 2005-12-08 A | 100% | 2005-06-28 | 2005-12-08 | 118d? | start no earlier than 2005-06-28 | S3 | 944h | 944h | LI-7A | BMWI | berthold.wilhelm@regtp.de | Rel-7 | Mirko |  | LI-7A | 33.106, 33.107, 33.108 |  |  |
| 4671 | 1287 | Key establishment between a UICC and a terminal |  | 201.45d? | 2005-12-07 A | 2006-09-28 A | 100% | 2005-12-07 | 2006-09-28 | 201.45d? | finish no earlier than 2006-09-28 | S3 | 1611.6h | 1611.6h | KeyEstUTerm | Gemalto | mireille.pauliac@gemplus.com | Rel-7 | Mirko |  | KeyEstUTerm | 33.110 |  |  |
| 4672 | 1288 | NDS Authentication Framework Extension for Transport Layer Security |  | 50d? | 2006-09-28 A | 2006-12-06 A | 100% | 2006-09-28 | 2006-12-06 | 50d? | finish no earlier than 2006-09-28 | S3 | 400h | 400h | NDSAFTLS | Nokia | tiina.s.koskinen@nokia.com | Rel-7 | Mirko |  | NDSAFTLS | 33.310 |  |  |
| 4673 | 1289 | **Security enhancements** |  | 319d? | 2005-09-12 A | 2006-11-30 A | 100% | 2005-09-12 | 2006-11-30 | 319d? |  | S3; C1; C4 | 16376h | 16376h | SEC7 |  |  | Rel-7 | Mirko |  | SEC7 |  |  |  |
| 4674 | 1289.1 | HTTPS connection between a UICC and a NAF |  | 1d? | 2005-09-12 A | 2005-09-12 A | 100% | 2005-09-12 | 2005-09-12 | 1d? | start no earlier than 2005-09-12 | S3; C1 | 16h | 16h | SEC7-HSUN | Gemalto | JSeif@axalto.com, mireille.pauliac@gemplus.com | Rel-7 | Mirko |  | SEC7-HSUN | 33.918, 33.222, 24.109 |  |  |
| 4675 | 1289.2 | 2G GBA: 2G SIM usage in 3GPP GAA framework |  | 61d? | 2005-09-12 A | 2005-12-05 A | 100% | 2005-09-12 | 2005-12-05 | 61d? | finish no earlier than 2005-12-05 | S3 | 488h | 488h | SEC7-2GGBA | Nokia | Silke.Holtmanns@nokia.com | Rel-7 | Mirko |  | SEC7-2GGBA | 33.920, 33.220 |  |  |
| 4676 | 1289.3 | Generic Authentication Architecture usage extensions and optimizations |  | 319d? | 2005-09-12 A | 2006-11-30 A | 100% | 2005-09-12 | 2006-11-30 | 319d? | finish no earlier than 2006-11-30 | S3 | 2552h | 2552h | SEC7-GAA2 | Nokia | Silke.Holtmanns@nokia.com | Rel-7 | Mirko |  | SEC7-GAA2 | 33.220, 29.109, 24.109, (33.223 goes to R8) |  |  |

Notes:
- 4650: WID approved SP#27; updated SP#28; updated SP#32
- 4651: -
- 4652: -
- 4653: -
- 4654: 03/2006 SP#31 WID approved
- 4655: -
- 4656: -
- 4657: -
- 4658: -
- 4659: -
- 4660: TR for Info SP-33. SP-34: S2 Report intention to discontinue TR
- 4661: -
- 4662: -
- 4663: Triggered by the abandoned Study UID_32117
- 4664: -
- 4665: CP-34 approved WID. CP-35 updated WID
- 4666: CP-34 approved WID
- 4667: WID approved SP#27.
- 4668: WID approved SP#26.
- 4669: WID approved SP#26, Dependant on Funding Availability.
- 4670: -
- 4671: -
- 4672: TLS profile is moved to Rel-8
- 4673: -
- 4674: -
- 4675: -
- 4676: 33.223 goes to R8

| ID | WBS | Task | Duration | Start | Finish | Complete | Baseline start | Baseline finish | Baseline duration | Constraint | Resources | Work | Actual work | Acronym | WI rapporteur name | WI rapporteur e-mail | Release | MCC resp | Acronym_3GU_Export | Impacted TSs and TRs | PCG approved | TSG approved | TSG stopped |
| --- | --- | --- | --- | --- | --- | --- | --- | --- | --- | --- | --- | --- | --- | --- | --- | --- | --- | --- | --- | --- | --- | --- | --- |
| 4677 | 1289.4 | **SS7 TCAP security Gateway** | 241d? | 2005-09-12 A | 2006-08-14 A | 100% | 2005-09-12 | 2006-08-14 | 241d? |  | S3; C4 | 5664h | 5664h | SEC7-NDS-TCAPsec | Siemens | marc.blommaert.ext@nsn.com | Rel-7 | Mirko | SEC7-NDS-TCAPsec |  |  |  |  |
| 4678 | 1289.4.1 | SA3 aspects of SEC7-NDS-TCAPsec | 130d? | 2005-09-12 A | 2006-03-10 A | 100% | 2005-09-12 | 2006-03-10 | 130d? | finish no earlier than 2006-03-10 | S3 | 1040h | 1040h | SEC7-NDS-TCAPsec-SA3 | Siemens | marc.blommaert.ext@nsn.com | Rel-7 | Mirko | SEC7-NDS-TCAPsec-SA3 | 33.204 |  |  |  |
| 4679 | 1289.4.2 | TCAPsec Gateway | 96d? | 2006-04-03 A | 2006-08-14 A | 100% | 2006-04-03 | 2006-08-14 | 96d? | start no earlier than 2006-04-01 | C4 | 768h | 768h | SEC7-TCAP | Siemens | Ulrich.wiehe@gksag.de | Rel-7 | Kimmo | SEC7-TCAP | 29.204, 29.002 |  |  |  |
| 4680 | 1290 | IMS Stage 3 IETF Protocol Alignment | 589d? | 2004-12-10 A | 2007-03-14 A | 100% | 2004-12-10 | 2007-03-14 | 589d? | finish no earlier than 2007-03-15 | C1 | 4712h | 4712h | IMSProtoc |  |  | Rel-7 | Frederic | IMSProtoc | 24.930 | 36 | 71 |  |
| 4681 | 1291 | **Interoperability between VGCS/VBS and A/Gb flexibility** | 253d? | 2006-03-22 A | 2007-03-09 A | 100% | 2006-03-22 | 2007-03-09 | 253d? |  | C1; C4 | 7344h | 7344h | VGCSFlex | Siemens | robert.zaus@nsn.com | Rel-7 | Frederic | VGCSFlex |  |  |  |  |
| 4682 | 1291.1 | CT1 aspects of VGCSFlex | 159d? | 2006-03-22 A | 2006-10-30 A | 100% | 2006-03-22 | 2006-10-30 | 159d? | finish no earlier than 2006-10-30 | C1 | 1272h | 1272h |  | Siemens | robert.zaus@nsn.com | Rel-7 | Frederic |  | 43.068, 43.069 |  |  |  |
| 4683 | 1291.2 | CT4 aspects of VGCSFlex | 253d? | 2006-03-22 A | 2007-03-09 A | 100% | 2006-03-22 | 2007-03-09 | 253d? | finish no earlier than 2007-03-09 | C4 | 2024h | 2024h | VGCSFlex-c4 | Siemens | robert.zaus@nsn.com | Rel-7 | Kimmo | VGCSFlex-c4 | 29.002 |  |  |  |
| 4684 | 1292 | DIAMETER on the GGSN Gi interface | 586d? | 2004-09-10 A | 2006-12-08 A | 100% | 2004-09-10 | 2006-12-08 | 586d? | finish no earlier than 2006-12-08 | C3 | 4688h | 4688h | DIAMGi | Vodafone | Nico.Gabriele@vodafone.com | Rel-7 | Adrian | DIAMGi | 29.061 |  |  |  |
| 4685 | 1293 | DIAMETER on the PDG Wi interface | 586d? | 2004-09-10 A | 2006-12-08 A | 100% | 2004-09-10 | 2006-12-08 | 586d? | finish no earlier than 2006-12-08 | C3 | 4688h | 4688h | DIAMWi | Vodafone | Nico.Gabriele@vodafone.com | Rel-7 | Adrian | DIAMWi | 29.161 |  |  |  |
| 4686 | 1294 | Interworking between the 3GPP CS domain with BICC or ISUP as signalling protocol and external SIP-I networks | 478d? | 2006-09-22 A | 2008-07-22 A | 100% | 2006-09-22 | 2008-07-22 | 478d? | finish no earlier than 2007-09-14 | C3 | 3824h | 3824h | ExtSIPI | Siemens | Thomas.Belling@nsn.com | Rel-7 | Adrian | ExtSIPI | 29.164 |  |  |  |
| 4687 | 1295 | PDU multiplexing at Nb Interface with IP transport | 427d? | 2006-12-04 A | 2008-07-22 A | 100% | 2006-12-04 | 2008-07-22 | 427d? | start no earlier than 2006-12-04 | C3 | 3416h | 3416h | NbIPMux | Alcatel-Lucent | Jean.Rzeznik@alcatel-lucent.fr | Rel-7 | Adrian | NbIPMux | 29.414 |  | 34 |  |
| 4688 | 1296 | **Mp (MRFC - MRFP) interface** | 345d? | 2006-02-13 A | 2007-06-08 A | 100% | 2006-02-13 | 2007-06-08 | 345d? |  | C4; C1 | 9904h | 9904h | Mp | Ericsson | philip.hodges@ericsson.com | Rel-7 | Kimmo | Mp |  |  |  |  |
| 4689 | 1296.1 | CT1 aspects of Mp | 1d | 2006-02-13 A | 2006-02-13 A | 100% | 2006-02-13 | 2006-02-13 | 1d | finish no earlier than 2006-02-13 | C1 | 8h | 8h |  | Ericsson | philip.hodges@ericsson.com | Rel-7 | Frederic |  | 24.229 |  |  |  |
| 4690 | 1296.2 | Deleted - CT3 aspects of Mp | 1d | 2006-09-22 A | 2006-09-22 A | 100% | 2006-09-22 | 2006-09-22 | 1d | start no earlier than 2006-09-22 | C3 | 8h | 8h |  | Ericsson | philip.hodges@ericsson.com | Rel-7 | Adrian |  | 29.162 |  |  | CP-33 |
| 4691 | 1296.3 | Procedures description | 201d? | 2006-06-02 A | 2007-03-09 A | 100% | 2006-06-02 | 2007-03-09 | 201d? | finish no earlier than 2007-03-09 | C4 | 1608h | 1608h | Mp-PROCc4 | Huawei | Chencheng@huawei.com | Rel-7 | Kimmo | Mp-PROCc4 | 23.333 |  |  |  |
| 4692 | 1296.4 | Stage 3 for Mp (MRFC - MRFP) interface | 345d | 2006-02-13 A | 2007-06-08 A | 100% | 2006-02-13 | 2007-06-08 | 345d | finish no earlier than 2007-06-08 | C4 | 2760h | 2760h | Mp-St3c4 | Ericsson | philip.hodges@ericsson.com | Rel-7 | Kimmo | Mp-St3c4 | 29.333 |  |  |  |
| 4693 | 1297 | Routeing of MT-SMS via the HPLMN | 71d? | 2006-12-01 A | 2007-03-09 A | 100% | 2006-12-01 | 2007-03-09 | 71d? | finish no earlier than 2007-03-09 | C4; C1 | 1136h | 1136h | SMSviaH | Vodafone | Nick.Russell@vodafone.com | Rel-7 | Kimmo | SMSviaH | 23.040, 29.002 |  | 34 |  |
| 4694 | 1298 | Mobile Termination whilst the MS is moving to another MSC | 60d? | 2007-03-09 A | 2007-05-31 A | 100% | 2007-03-09 | 2007-05-31 | 60d? | start no earlier than 2007-03-09 | C4 | 480h | 480h | MTmovMS | Alcatel-Lucent | bruno.landais@alcatel-lucent.fr | Rel-7 | Kimmo | MTmovMS | 23.008, 23.012, 23.018, 23.078, 23.079, 29.002 |  |  |  |
| 4695 | 1299 | ISIM API for Java Card | 620d? | 2005-03-14 A | 2007-07-27 A | 100% | 2005-03-14 | 2007-07-27 | 620d? | finish no earlier than 2007-07-27 | C6 | 4960h | 4960h | APIJAVA | Sun | Sebastian Hans | Rel-7 | Xavier | APIJAVA | 31.103, 102 241 | 38 | 74 |  |
| 4696 | 1300 | Rel-7 (U)SIM API Testing (TS 31.213) | 211d? | 2009-05-30 A | 2010-03-19 A | 100% | 2009-05-30 | 2010-03-19 | 211d? | finish no earlier than 2010-03-12 | C6 | 1688h | 1688h | USIM_API_Test | Sagem Orga | gerrit.hartbrod@sagem-orga.com | Rel-7 | Xavier | USIM_API_Test | 31.213 | 23 | 44 |  |
| 4697 | 1301 | High speed interface between the UICC and the ME | 311d? | 2006-09-22 A | 2007-11-30 A | 100% | 2006-09-22 | 2007-11-30 | 311d? | finish no earlier than 2007-11-30 | C6 | 2488h | 2488h | HSI | Gemalto | jacques.seif@GEMALTO.COM | Rel-7 | Xavier | HSI | 31.101 |  |  |  |
| 4698 | 1302 | Video Codec Performance Requirements | 634d? | 2005-01-03 A | 2007-06-07 A | 100% | 2005-01-03 | 2007-06-07 | 634d? | finish no earlier than 2007-06-07 | S4 | 5072h | 5072h | VICPer | Siemens | juergen.pandel@siemens.com | Rel-7 | Paolo | VICPer | 26.234, 26.235, 26.346, 26.140, 26.902 |  |  |  |
| 4699 | 1303 | Dynamic and Interactive Multimedia Scenes | 583d? | 2005-03-15 A | 2007-06-07 A | 100% | 2005-03-15 | 2007-06-07 | 583d? | finish no earlier than 2007-06-07 | S4 | 4664h | 4664h | DIMS | Streamezzo | gaelle.martin-cocher@streamezzo.com | Rel-7 | Paolo | DIMS | 26.140, 26.142, 26.234, 26.244, 23.346 |  |  |  |
| 4700 | 1304 | 3G-324M Video Telephony Call Setup Times Improvements | 341d? | 2005-06-08 A | 2006-09-27 A | 100% | 2005-06-08 | 2006-09-27 | 341d? | finish no earlier than 2006-09-27 | S4 | 2728h | 2728h | VTCSTI | Vodafone | edward.hall@vodafone.co.uk | Rel-7 | Paolo | VTCSTI | 26.911 |  |  |  |

Notes:
- 4677: -
- 4678: -
- 4679: -
- 4680: TR 24.930: Signalling flows for the session setup in the IM CN subsystem based on Session Initiation Protocol (SIP)
- 4681: Voice Group Call Service
- 4682: -
- 4683: -
- 4684: -
- 4685: -
- 4686: -
- 4687: -
- 4688: -
- 4689: -
- 4690: CP#34: CT3 not involved in Mp interface definition
- 4691: -
- 4692: -
- 4693: WID approved in CP#34
- 4694: -
- 4695: -
- 4696: CP#47 completed. Update of Rel-6 (U)SIM API for Java Card Testing UID_43007 under Rel-6 UICC/USIM enhancements and interworking UID_1800
- 4697: Following ETSI publication of TS 102 600, expected to be completed at CT6 meeting 45
- 4698: -
- 4699: -
- 4700: -

| ID | WBS | Task | Duration | Start | Finish | Complete | Baseline start | Baseline finish | Baseline duration | Constraint | Resources | Work | Actual work | Acronym | WI rapporteur name | WI rapporteur e-mail | Release | MCC resp | Acronym_3GU_Export | TSG stopped |
| --- | --- | --- | --- | --- | --- | --- | --- | --- | --- | --- | --- | --- | --- | --- | --- | --- | --- | --- | --- | --- |
| 4701 | 1305 | **Optimizations for Multimedia Telephony over IMS** | 2d? | 2005-09-28 A | 2005-09-29 A | 100% | 2005-09-28 | 2005-09-28 | 0d? |  | S4 | 32h | 32h | OMTIMS | Ericsson | olle.franceschi@ericsson.com | Rel-7 | Paolo | OMTIMS |  |
| 4702 | 1305.1 | Deleted - Characterisation of Adaptive Jitter Management Performance for VoIP Services | 2d? | 2005-09-28 A | 2005-09-29 A | 100% | 2005-09-28 | 2005-09-28 | 0d? | finish no earlier than 2005-09-29 | S4 | 16h | 16h | OMTIMS-CAJMP | Lucent | dhuo@lucent.com | Rel-7 | Paolo | OMTIMS-CAJMP | SP-35 |
| 4703 | 1306 | End-to-End Multimedia Services Performance Metrics | 382d? | 2005-09-28 A | 2007-03-15 A | 100% | 2005-09-28 | 2007-03-15 | 382d? | finish no earlier than 2007-03-15 | S4 | 3056h | 3056h | E2EMSPM | China Mobile | zhangyanyf@chinamobile.com | Rel-7 | Paolo | E2EMSPM |  |
| 4704 | 1307 | Packet Switched Streaming Enhancements | 261d? | 2006-06-08 A | 2007-06-07 A | 100% | 2006-06-08 | 2007-06-07 | 261d? | finish no earlier than 2007-06-07 | S4 | 2088h | 2088h | PSSe | Ericsson | olle.franceschi@ericsson.com | Rel-7 | Paolo | PSSe |  |
| 4705 | 1308 | **Rel-7 Operations, Administration, Maintenance and Provisioning (OAM&P)** | 472.86d? | 2005-09-02 A | 2007-06-26 A | 100% | 2005-09-02 | 2007-06-26 | 472.86d? |  | S5 | 82725.8h | 82725.8h | OAM7 | Huawei | Christian.Toche@huawei.com | Rel-7 | Mirko | OAM7 |  |
| 4706 | 1308.1 | **Rel-7 Network Infrastructure Management** | 465d? | 2005-09-02 A | 2007-06-14 A | 100% | 2005-09-02 | 2007-06-14 | 465d? |  | S5 | 41800h | 41800h | OAM7-NIM |  |  | Rel-7 | Mirko | OAM7-NIM |  |
| 4707 | 1308.1.1 | Enhance NRM to accommodate NGN (IMS as basis of the Next Generation Network) | 465d? | 2005-09-02 A | 2007-06-14 A | 100% | 2005-09-02 | 2007-06-14 | 465d? | finish no earlier than 2007-06-14 | S5 | 3720h | 3720h |  | Motorola |  | Rel-7 | Mirko |  |  |
| 4708 | 1308.1.2 | Co-operative Element Management interface (CO-OP) (Study + Implementation) | 400d? | 2005-09-02 A | 2007-03-15 A | 100% | 2005-09-02 | 2007-03-15 | 400d? | finish no earlier than 2007-03-15 | S5 | 3200h | 3200h |  | Motorola |  | Rel-7 | Mirko |  |  |
| 4709 | 1308.1.3 | Network Management (NM) Itf-N performance criteria | 465d? | 2005-09-02 A | 2007-06-14 A | 100% | 2005-09-02 | 2007-06-14 | 465d? | finish no earlier than 2007-06-14 | S5 | 3720h | 3720h |  | China Mobile |  | Rel-7 | Mirko |  |  |
| 4710 | 1308.1.4 | Delta synchronization between IRP Manager and IRP Agent (Study + Implementation) | 465d? | 2005-09-02 A | 2007-06-14 A | 100% | 2005-09-02 | 2007-06-14 | 465d? | finish no earlier than 2007-06-14 | S5 | 3720h | 3720h |  | Siemens |  | Rel-7 | Mirko |  |  |
| 4711 | 1308.1.5 | Subscription Management (SuM) IRP Solution Sets | 330d? | 2005-09-02 A | 2006-12-07 A | 100% | 2005-09-02 | 2006-12-07 | 330d? | finish no earlier than 2006-12-07 | S5 | 2640h | 2640h |  | Ericsson |  | Rel-7 | Mirko |  |  |
| 4712 | 1308.1.6 | Integration Reference Point (IRP) Security Management | 400d? | 2005-09-02 A | 2007-03-15 A | 100% | 2005-09-02 | 2007-03-15 | 400d? | finish no earlier than 2007-03-15 | S5 | 3200h | 3200h |  | Huawei | Christian.Toche@huawei.com | Rel-7 | Mirko |  |  |
| 4713 | 1308.1.7 | Partial suspension of Itf-N during maintenance/testing (Study + Implementation) | 465d? | 2005-09-02 A | 2007-06-14 A | 100% | 2005-09-02 | 2007-06-14 | 465d? | finish no earlier than 2007-06-14 | S5 | 3720h | 3720h |  | Siemens |  | Rel-7 | Mirko |  |  |
| 4714 | 1308.1.8 | Deleted - Management of Legacy Equipment | 336d? | 2005-09-02 A | 2006-12-15 A | 100% | 2005-09-02 | 2006-12-15 | 336d? | finish no earlier than 2006-12-15 | S5 | 2688h | 2688h |  | Siemens |  | Rel-7 | Mirko |  | SP-35 |
| 4715 | 1308.1.9 | Deleted - Rules for Vendor Specific Extensions | 400d? | 2005-09-02 A | 2007-03-15 A | 100% | 2005-09-02 | 2007-03-15 | 400d? | finish no earlier than 2007-03-15 | S5 | 3200h | 3200h |  | Siemens |  | Rel-7 | Mirko |  | SP-35 |
| 4716 | 1308.1.10 | Backward and Forward Compatibility of IRP systems | 465d? | 2005-09-02 A | 2007-06-14 A | 100% | 2005-09-02 | 2007-06-14 | 465d? | finish no earlier than 2007-06-14 | S5 | 3720h | 3720h |  | Ericsson |  | Rel-7 | Mirko |  |  |
| 4717 | 1308.1.11 | Repeater Network Resource Model (NRM) definition | 214d? | 2006-02-13 A | 2006-12-07 A | 100% | 2006-02-13 | 2006-12-07 | 214d? | finish no earlier than 2006-12-07 | S5 | 1712h | 1712h |  | China Mobile |  | Rel-7 | Mirko |  |  |
| 4718 | 1308.1.12 | UTRAN radio channel power monitoring | 284d? | 2006-02-13 A | 2007-03-15 A | 100% | 2006-02-13 | 2007-03-15 | 284d? | finish no earlier than 2007-03-15 | S5 | 2272h | 2272h |  | China Mobile |  | Rel-7 | Mirko |  |  |
| 4719 | 1308.1.13 | Notification XML Schema | 71d? | 2006-12-07 A | 2007-03-15 A | 100% | 2006-12-07 | 2007-03-15 | 71d? | finish no earlier than 2007-03-15 | S5 | 568h | 568h |  | Huawei | Christian.Toche@huawei.com | Rel-7 | Mirko |  |  |
| 4720 | 1308.2 | **Rel-7 Performance Management** | 465d? | 2005-09-02 A | 2007-06-14 A | 100% | 2005-09-02 | 2007-06-14 | 465d? |  | S5 | 22992h | 22992h | OAM7-PM |  |  | Rel-7 | Mirko | OAM7-PM |  |
| 4721 | 1308.2.1 | Performance measurements definition for CN CS | 400d? | 2005-09-02 A | 2007-03-15 A | 100% | 2005-09-02 | 2007-03-15 | 400d? | finish no earlier than 2007-03-15 | S5 | 3200h | 3200h |  | China Mobile |  | Rel-7 | Mirko |  |  |
| 4722 | 1308.2.2 | Enhancement UTRAN performance measurements definition | 465d? | 2005-09-02 A | 2007-06-14 A | 100% | 2005-09-02 | 2007-06-14 | 465d? | finish no earlier than 2007-06-14 | S5 | 3720h | 3720h |  | China Mobile |  | Rel-7 | Mirko |  |  |
| 4723 | 1308.2.3 | Add TDD specific counters in Performance measurement | 330d? | 2005-09-02 A | 2006-12-07 A | 100% | 2005-09-02 | 2006-12-07 | 330d? | finish no earlier than 2006-12-15 | S5 | 2640h | 2640h |  | CATT |  | Rel-7 | Mirko |  |  |
| 4724 | 1308.2.4 | ATM bearer network Performance measurements | 400d? | 2005-09-02 A | 2007-03-15 A | 100% | 2005-09-02 | 2007-03-15 | 400d? | finish no earlier than 2007-03-15 | S5 | 3200h | 3200h |  | ZTE |  | Rel-7 | Mirko |  |  |
| 4725 | 1308.2.5 | Performance measurements definition for IMS | 465d? | 2005-09-02 A | 2007-06-14 A | 100% | 2005-09-02 | 2007-06-14 | 465d? | finish no earlier than 2007-06-14 | S5 | 3720h | 3720h |  | China Mobile |  | Rel-7 | Mirko |  |  |
| 4726 | 1308.2.6 | HSDPA performance measurements | 349d? | 2006-02-13 A | 2007-06-14 A | 100% | 2006-02-13 | 2007-06-14 | 349d? | finish no earlier than 2007-06-14 | S5 | 2792h | 2792h |  | China Mobile |  | Rel-7 | Mirko |  |  |

Notes:
- 4701: Aug2015: 99%->100 / Impacted TSs and TRs: 26.235, 26.236
- 4702: SP-35 stopped
- 4703: - / Impacted TSs and TRs: 26.944
- 4704: - / Impacted TSs and TRs: 26.234, 26.244
- 4705: OAM7 is an umbrella Feature also for OAM&P related TEI7 type of changes that are not part of any other dedicated feature/WI / Impacted TSs and TRs: TR 30.817
- 4706: -
- 4707: - / Impacted TSs and TRs: 32.731/2/3/5, 32.631/2/3/5
- 4708: - / Impacted TSs and TRs: 32.806, 32.814, 32.101
- 4709: - / Impacted TSs and TRs: 32.811
- 4710: - / Impacted TSs and TRs: 32.391/2/3/5
- 4711: - / Impacted TSs and TRs: 32.307/317/607/667/665, 32.101, 32.175
- 4712: - / Impacted TSs and TRs: 32.372/3/5, 32.111,32.30x,32.32x,32.33x,32.34x,32.35x,32.36x,32.41x,32.60x,32.61x,32.66x
- 4713: - / Impacted TSs and TRs: 32.381/2/3/5
- 4714: Request to TSG#35 to STOP the WI / Impacted TSs and TRs: new 32.xxx
- 4715: Request to TSG#35 to STOP the WI / Impacted TSs and TRs: 32.62n; For n = 1 to 5
- 4716: - / Impacted TSs and TRs: 32.154
- 4717: - / Impacted TSs and TRs: 32.721/2/3/5
- 4718: - / Impacted TSs and TRs: 32.405, 32.64n; For n = 1 to 5
- 4719: 12/2006 SP#34 WID approved / Impacted TSs and TRs: New 32.325/345/365/415, CR to 32.335/615/665
- 4720: -
- 4721: - / Impacted TSs and TRs: 32.407, 32.408
- 4722: - / Impacted TSs and TRs: 32.405
- 4723: - / Impacted TSs and TRs: 32.405
- 4724: - / Impacted TSs and TRs: No impact on 32.404, 32.405, 32.406, 32.407
- 4725: - / Impacted TSs and TRs: 32.404,32.409,32.437, 32.632/3/4/5
- 4726: - / Impacted TSs and TRs: 32.405

| ID | WBS | Task | Type | Duration | Start | Finish | Complete | Baseline start | Baseline finish | Baseline duration | Constraint | Resources | Work | Actual work | Acronym | WI rapporteur name | Release | MCC resp | Acronym_3GU_Export | TSG stopped | WI rapporteur e-mail | Status Report |
| --- | --- | --- | --- | --- | --- | --- | --- | --- | --- | --- | --- | --- | --- | --- | --- | --- | --- | --- | --- | --- | --- | --- |
| 4727 | 44.5 | **Rel-7 Trace Management** |  | 472.86d? | 2005-09-02 A | 2007-06-26 A | 100% | 2005-09-02 | 2007-06-26 | 472.86d? |  | S5 | 14150.9h | 14150.9h | OAM7-Trace | Vodafone | Rel-7 | Mirko | OAM7-Trace |  |  |  |
| 4728 | 1308.3.1 | End-to-end Service Level tracing for IMS |  | 350d? | 2005-11-11 A | 2007-03-15 A | 100% | 2005-11-11 | 2007-03-15 | 350d? | finish no earlier than 2007-03-15 | S5 | 2800h | 2800h |  | Vodafone | Rel-7 | Mirko |  | SP-31 |  |  |
| 4729 | 1308.3.2 | Trace record content for UTRAN TDD |  | 330d? | 2005-09-02 A | 2006-12-07 A | 100% | 2005-09-02 | 2006-12-07 | 330d? | finish no earlier than 2006-12-07 | S5 | 2640h | 2640h |  | Nokia | Rel-7 | Mirko |  |  |  |  |
| 4730 | 1308.3.3 | IRP for Subscriber and Equipment Trace Management |  | 465d? | 2005-09-02 A | 2007-06-14 A | 100% | 2005-09-02 | 2007-06-14 | 465d? | finish no earlier than 2007-06-14 | S5 | 3720h | 3720h |  | Nokia | Rel-7 | Mirko |  |  |  |  |
| 4731 | 1308.3.4 | Deleted - SIP enhancements for trace | milestone | 0d? | 2007-06-15 A | 2007-06-26 A | 100% | 2007-06-15 | 2007-06-26 | 0d? | start no earlier than 2007-06-15 | C1 |  |  |  |  | Rel-7 | Frederic |  | CP-32 |  |  |
| 4732 | 1308.3.5 | Deleted - duplicated with UID 35063 - IRP for Subscriber and Equipment Trace Management |  | 336d? | 2005-09-02 A | 2006-12-15 A | 100% | 2005-09-02 | 2006-12-15 | 336d? | finish no earlier than 2006-12-15 | S5 | 2688h | 2688h |  | Nokia | Rel-7 | Mirko |  | SP-33 |  |  |
| 4733 | 1309 | **Rel-7 Charging Management small Enhancements** |  | 279d? | 2006-05-22 A | 2007-06-14 A | 100% | 2006-05-22 | 2007-06-14 | 279d? |  | S5 | 5952h | 5952h | CH7 | Orange | Rel-7 | Mirko | CH7 |  | alain.bibas@orange-ft.com |  |
| 4734 | 1309.1 | Alternate Charged Party (ACP) for IMS |  | 279d? | 2006-05-22 A | 2007-06-14 A | 100% | 2006-05-22 | 2007-06-14 | 279d? | finish no earlier than 2007-06-14 | S5 | 2232h | 2232h | CH7-IMS-ACP | Lucent | Rel-7 | Mirko | CH7-IMS-ACP |  | njmazzarella@alcatel-lucent.com |  |
| 4735 | 1309.2 | Align 3GPP Charging with OMA PoC Enabler Release 2.0 |  | 186d? | 2006-09-28 A | 2007-06-14 A | 100% | 2006-09-28 | 2007-06-14 | 186d? | finish no earlier than 2007-06-14 | S5 | 1488h | 1488h | CH7-PoC | Siemens | Rel-7 | Mirko | CH7-PoC |  | Gerald.Goermer@nsn.com |  |
| 4736 | 8.5 | **Multiple-Input Multiple-Output (MIMO) antennas** |  | 1301d? | 2003-03-14 A | 2008-03-07 A | 100% | 2003-03-14 | 2008-03-07 | 1301d? |  | R1; R5 | 55848h | 55848h | MIMO | Alcatel-Lucent | Rel-7 | Patrick | MIMO |  | hchuang@Alcatel-Lucent.com |  |
| 4737 | 1310.1 | MIMO - Physical layer |  | 915d? | 2003-09-12 A | 2007-03-15 A | 100% | 2003-09-12 | 2007-03-15 | 915d? | finish no earlier than 2007-03-15 | R1 | 7320h | 7320h | MIMO-Phys | Alcatel-Lucent | Rel-7 | Patrick | MIMO-Phys |  | hchuang@Alcatel-Lucent.com | RP-070037 |
| 4738 | 1310.2 | MIMO - Layer 2,3 aspects |  | 915d? | 2003-09-12 A | 2007-03-15 A | 100% | 2003-09-12 | 2007-03-15 | 915d? | finish no earlier than 2007-03-15 | R2 | 7320h | 7320h | MIMO-L23 | Alcatel-Lucent | Rel-7 | Yong-Jun | MIMO-L23 |  | hchuang@Alcatel-Lucent.com | RP-070037 |
| 4739 | 1310.3 | MIMO - Iub/Iur Protocol Aspects |  | 1045d? | 2003-03-14 A | 2007-03-15 A | 100% | 2003-03-14 | 2007-03-15 | 1045d? | finish no earlier than 2007-03-15 | R3 | 8360h | 8360h | MIMO-IurIub | Alcatel-Lucent | Rel-7 | Juha | MIMO-IurIub |  | hchuang@Alcatel-Lucent.com | RP-070037 |
| 4740 | 1310.4 | MIMO - RF Radio Transmission/Reception, System Performance Requirements and Conformance Testing |  | 982d? | 2003-12-12 A | 2007-09-17 A | 100% | 2003-12-12 | 2007-09-17 | 982d? | finish no earlier than 2007-09-17 | R4 | 7856h | 7856h | MIMO-RF | Alcatel-Lucent | Rel-7 | Issam | MIMO-RF |  | ngm@Alcatel-Lucent.com | RP-070531 |
| 4741 | 1310.5 | **UE Conformance Testing for Multiple Input Multiple Output antennas (MIMO)** |  | 261d? | 2007-03-09 A | 2008-03-07 A | 100% | 2007-03-09 | 2008-03-07 | 261d? |  | R5 | 4176h | 4176h | MIMO-UEConTest | Qualcomm | Rel-7 | Ingbert | MIMO-UEConTest |  | svora@qualcomm.com |  |
| 4742 | 1310.5.1 | Conformance Test Aspects – Multiple Input Multiple Output Antennas (MIMO) for FDD |  | 261d? | 2007-03-09 A | 2008-03-07 A | 100% | 2007-03-09 | 2008-03-07 | 261d? | finish no earlier than 2008-03-07 | R5 | 2088h | 2088h | MIMO-UEConTest_FDD | Qualcomm | Rel-7 | Ingbert | MIMO-UEConTest_FDD |  | svora@qualcomm.com |  |
| 4743 | 1311 | **Rel-7 Improvements of the Radio Interface** |  | 709d? | 2004-09-15 A | 2007-06-04 A | 100% | 2004-09-15 | 2007-06-04 | 709d? |  | RP; GP | 40520h | 40520h |  |  | Rel-7 | Issam |  |  |  |  |
| 4744 | 1311.1 | Extended UMTS 1.7/2.1 GHz |  | 198d? | 2006-03-15 A | 2006-12-15 A | 100% | 2006-03-15 | 2006-12-15 | 198d? | finish no earlier than 2006-12-15 | R4 | 1584h | 1584h | RInImp-UMTS1721Ext | Ericsson | Rel-7 | Issam | RInImp-UMTS1721Ext |  | johan.skold@ericsson.com | RP-060681 |
| 4745 | 1311.2 | UMTS 2.6 GHz 7.68 Mcps TDD |  | 67d? | 2006-06-15 A | 2006-09-15 A | 100% | 2006-06-15 | 2006-09-15 | 67d? | finish no earlier than 2006-09-15 | R4 | 536h | 536h | RInImp-UMTS26VHCRTDD | IPWireless | Rel-7 | Issam | RInImp-UMTS26VHCRTDD |  | Shin Horng Wong (shwong@ipwireless.com) | RP-060451 |
| 4746 | 1311.3 | UMTS 2.6 GHz |  | 195d? | 2004-09-15 A | 2005-06-14 A | 100% | 2004-09-15 | 2005-06-14 | 195d? | finish no earlier than 2005-06-14 | R4 | 1560h | 1560h | RInImp-UMTS2600 | Nokia | Rel-7 | Issam | RInImp-UMTS2600 |  | jussi.numminen@nokia.com | RP-050184 |
| 4747 | 1311.4 | UMTS 2.6 GHz TDD |  | 261d? | 2004-12-15 A | 2005-12-14 A | 100% | 2004-12-15 | 2005-12-14 | 261d? | finish no earlier than 2005-12-15 | R4 | 2088h | 2088h | RInImp-UMTS2600TDD | IPWireless | Rel-7 | Issam | RInImp-UMTS2600TDD |  | Shin Horng Wong (shwong@ipwireless.com) | RP-050661 |
| 4748 | 1311.5 | UMTS 900 MHz |  | 261d? | 2004-12-15 A | 2005-12-14 A | 100% | 2004-12-15 | 2005-12-14 | 261d? | finish no earlier than 2005-12-15 | R4 | 2088h | 2088h | RInImp-UMTS900 | Nortel | Rel-7 | Issam | RInImp-UMTS900 |  | Yannick Li (yli@nortelnetworks.com) | RP-050662 |
| 4749 | 1311.6 | UMTS 1700 MHz |  | 197d? | 2005-03-15 A | 2005-12-14 A | 100% | 2005-03-15 | 2005-12-14 | 197d? | finish no earlier than 2005-12-15 | R4 | 1576h | 1576h | RInImp-UMTS1700 | NTT DoCoMo | Rel-7 | Issam | RInImp-UMTS1700 |  | Takehiro Nakamura (nakamurata@nttdocomo.co.jp) | RP-050824 |
| 4750 | 1311.7 | UE Antenna Performance Evaluation Method and Requirements |  | 644d? | 2004-12-15 A | 2007-06-04 A | 100% | 2004-12-15 | 2007-06-04 | 644d? | finish no earlier than 2007-06-04 | R4; GP | 10304h | 10304h | RInImp-UEAnt | TeliaSonera | Rel-7 | Issam | RInImp-UEAnt |  | Christian.Bergljung@TeliaSonera.com | RP-070281 |
| 4751 | 1311.8 | Improved Performance Requirements for HSDPA UE based on Rx Diversity (type 1) & LMMSE equalizer (type 2) | milestone | 0d? | 2005-03-15 A | 2005-03-15 A | 100% | 2005-03-15 | 2005-03-15 | 0d? | finish no earlier than 2005-03-15 | R4 |  |  | RInImp-HSPerf-Type3 | Cingular | Rel-7 | Issam | RInImp-HSPerf-Type3 |  | Marc Grant | RP-060015 |

Notes:
- 4727: -
- 4728: 07/2005: OMA (Stage 1), Stage 2/3 SA5, CT1/3/4 / Impacted TSs and TRs: 32.101, 32.421, 32.422, 32.423
- 4729: - / Impacted TSs and TRs: 32.421, 32.422, 32.423
- 4730: - / Impacted TSs and TRs: 32.441, 32.442, 32.443, 32.445, 32.632, 32.633, 32.635
- 4731: combined with UID 11067
- 4732: - / Impacted TSs and TRs: 32.421,32.422,32.423. 3 new 32.4x1,2,3
- 4733: CH7 is an umbrella Feature also for OAM&P related TEI7 type of changes that are not part of any other dedicated feature/WI / Impacted TSs and TRs: TR 30.817
- 4734: - / Impacted TSs and TRs: 32.240, 32.260, 32.298, 32.299
- 4735: 09/2006 SP#33 WID approved / Impacted TSs and TRs: 32.240, 32.272, 32.299, 32.298
- 4736: Completed Sep 2007; SR in RP-070037and RP-070531 / Impacted TSs and TRs: 25.876, 25.996
- 4737: Completed Sep 2007; SR in RP-070037 / Impacted TSs and TRs: 25.211, 25.212, 25.213, 25.214, 25.215, 25.221
- 4738: Completed Sep 2007; SR in RP-070037 / Impacted TSs and TRs: 25.876
- 4739: Completed Sep 2007; SR in RP-070037
- 4740: Completed Sep 2007; SR in RP-070531
- 4741: BB place holder for a number of RAN5 Tasks
- 4742: - / Impacted TSs and TRs: TS 34.108, TS 34.109, TS 34.121-1, TS 34.121-2, TS 34.123-1, TS 34.123-2, TS 34.123-3
- 4743: Generic feature
- 4744: RP#34 completed. Introduction of Band X (Extended UMTS 1.7/2.1 GHz) in 25.307 / Impacted TSs and TRs: 25.806, 25.101, 25.104, 25.133, 24.141, 25.331, 25.306, 25.307, 25.423, 25.461, 25.463, 34.121
- 4745: RP#33 completed / Impacted TSs and TRs: 25.102, 25.105, 25.123, 25.113, 25.142, 34.124
- 4746: RP#28 completed / Impacted TSs and TRs: 25.101, 25.104, 25.133, 25.141, 25.331, 25.942, 25.306, 25.307, 34.121
- 4747: RP#30 completed / Impacted TSs and TRs: 25.102, 25.105, 25.113, 25.123, 25.142, 25.331, 25.942, 25.306, 25.307, 34.122, 34.124
- 4748: RP#30 completed / Impacted TSs and TRs: 25.101, 25.104, 25.113, 25.133, 25.141, 25.331, 25.942, 25.306, 25.307, 34.121
- 4749: RP#30 completed / Impacted TSs and TRs: 25.101, 25.104, 25.113, 25.133, 25.141, 25.306, 25.307, 25.331, 34.121
- 4750: RP#36 completed / Impacted TSs and TRs: 25.101, new TR (25.914, 25.963)
- 4751: RP#27 completed / Impacted TSs and TRs: 25.101
